# 3GPP_Release-2000

Schedule from MS Project, 1999-01-01 to 2018-04-16, A marks actual dates.

## Calendars

- Standard: Mon-Fri 08:00-12:00, 13:00-17:00; Sat-Sun off. Exceptions (off unless hours are given): 2000-01-15 08:00-12:00, 13:00-17:00, 2009-05-30 08:00-12:00, 13:00-17:00, 2011-08-27 to 2011-08-28 08:00-12:00, 13:00-17:00, 2011-09-24 08:00-12:00, 13:00-17:00, 2012-06-02 08:00-12:00, 13:00-17:00, 2012-09-01 08:00-12:00, 13:00-17:00, 2012-11-18 08:00-12:00, 13:00-17:00, 2012-11-24 08:00-12:00, 13:00-17:00, 2013-02-16 08:00-12:00, 13:00-17:00, 2013-06-02 08:00-12:00, 13:00-17:00, 2013-08-10 to 2013-08-11 08:00-12:00, 13:00-17:00, 2013-09-14 08:00-12:00, 13:00-17:00, 2014-03-01 08:00-12:00, 13:00-17:00, 2014-08-24 08:00-12:00, 13:00-17:00, 2014-09-21 08:00-12:00, 13:00-17:00, 2014-10-05 08:00-12:00, 13:00-17:00, 2016-06-18 08:00-12:00, 13:00-17:00.

## Resources

| Resource |
| --- |
| NP |
| N1 |
| N2 |
| N3 |
| N4 |
| N5 |
| TP |
| T1 |
| T2 |
| T3 |
| RP |
| R1 |
| R2 |
| R3 |
| R4 |
| SP |
| S1 |
| S2 |
| S3 |
| S4 |
| S5 |
| PCG |
| GP |
| No |
| CN4 |
| ? |
| WG G2 |
| G2 |
| G1 |
| G4 |
| G3 |
| All |
| Generic |
| MLST |
| G5 |
| S3, G2 |
| WG T2 |
| GP,G1 |
| G4,G5 |
| OMA |
| GP-G2 |
| Yes |
| GP, |
| N4, |
| GP, N1 |
| CT5 |
| C5 |
| C1 |
| C4 |
| C3 |
| C6 |
| G1, |
| 4 |
| ct |
| c,s,r |
| CT,RAN,SA |
| G2, |
| G1, G3 |
| CT6 |
| CT1 |
| CT1, CT3, CT4 |
| C1, C3, C4 |
| CP |
| R5 |
| C |
| Rel-8 |
| GP, G2 |
| R1,R4 |
| S5,C1 |
| CT,RAN,SA,GERAN |
| S3,C1,C4 |
| 5 |
| S1,C1,C3,C4,S5 |
| S1,C1,C3,C5 |
| S1,C1,C3,C4 |
| S1,S5 |
| S2,S3 |
| RAN,SA |
| RP,S5 |
| S2,CT |
| S1,CT |
| S1,CT,GERAN |
| S1,C5 |
| S3,CT |
| S4,CT |
| C1,SA |
| S1,S2 |
| S1,S4 |
| S2,S2,S3,CT |
| S2,S3,CT |
| S1,CT,GX |
| S1,S4,CT |
| S2,S2,S3,S5,CT |
| S1,S2,CT |
| S1,S2,S3,CT |
| S1,S2,S3,S5CT |
| S1,S2,S3,S5,CT |
| S2,S5,CT |
| S4,S3 |
| S1,C1 |
| CP,C1 |
| C1,C3 |
| C1,C3,C4 |
| S1,S5,CT |
| C4,C3 |
| CP,RAN,SA,GERAN |
| S1,S2,S3,S5,CP |
| S2,S3,CP |
| S2,CP |
| S1,CP,GX |
| S1,CP |
| S1,S4,CP |
| S1,S2,CP |
| S1,S2,S3,CP |
| S2,S5,CP |
| S3,CP |
| S1,S5,CP |
| RAN,SA,GERAN |
| S1,S2,S3,S5,C1,C3,C4,C6 |
| S2,S3,C1,C3,C4 |
| S2,C4 |
| S2,C1,C3,C4 |
| S2,C1,C4 |
| S2,S3,C1,C4 |
| S1,C1,C4,G2 |
| C1,C4 |
| S1,C1,C3 |
| S1,S4,C1,C3,C4 |
| S1,S2,S3,C1,C3,C4 |
| S2,S5,C3 |
| S1,S2,C1,C4 |
| S2,C1 |
| S2,C1,C3 |
| S3,C1,C3,C4 |
| S1,S5,C1,C3,C4 |
| S2,C3,C4 |
| C3,C1 |
| R2,R4 |
| R2,R5 |
| RP,R5 |
| RP,S5,R5 |
| R1,R5 |
| S1,C1,R5 |
| S1,C1,S4,R5 |
| GERAN |
| G3new |
| G1, G3new |
| C4,C1,C3 |
| R1.R4 |
| R1, R4 |
| R2,R3 |
| C3,C4 |
| S4,C3 |
| S4,C3,C1,C4 |
| S1,S2,C1 |
| S1,S2<C1,C3,C4 |
| S1,S2,C1,C3,C4 |
| S5,C1,C3,C4 |
| GP,C4 |
| C4,C1 |
| S2,S1 |
| RP,SP,GP |
| RP,SP,CP,GP |
| CP,GP,RP,SP |
| GP,C4,S4 |
| S1,C1,C4 |
| S1,S2,C3,C1 |
| R2,R4,R3 |
| CP,GP, RP,SP |
| S2,S1,C1,S5 |
| S2,S1,C1 |
| S1,C1,S4 |
| S1,S2,GP,C4,R2 |
| S1,GP,R2 |
| S1,C6 |
| S1,S2,C1,S4 |
| S2,S3,S5,C1,C3,C4 |
| S2,S5,C1 |
| S2,S3,S5 |
| CP,GP, RP,SP,TP |
| S2,C4,C1 |
| S1,C1,C4,S3 |
| S2,S5 |
| S3,C1 |
| S3,C4 |
| S1,C4 |
| S2,S5,C3,C1 |
| S2,S1,S5,C1,C4 |
| S1,R1,C3 |
| S1,C1,R2 |
| S2,S1,C1,C4 |
| S1,C1,C6 |
| GP,S4,C4,C1,C3 |
| C3,C1,C4 |
| S1,C4,C1 |
| S1,S3 |
| S1,S2,S5,C3,C4 |
| R4,G1 |
| G1,R4 |
| RP,GP |
| R4,GP |
| R3,R2 |
| C6,RP,SP |
| R5,C6 |
| CP,RP,SP |
| RP,SP,CP |
| R3,S5 |
| S1,S2,RP |
| S1,S2,S5,RP |
| S2,S1,RP |
| Rel-9 |
| S3,C6 |
| S1,S2,S3,S5,RP |
| S2,S1,S3 |
| S1,S2,S3 |
| S1,S2,S3,S5 |
| C6,R5 |
| S1,S2,RP,GP |
| S1,S2,S4,S5,RP,GP |
| GP,G2 |
| GP,GP, N1 |
| GP,S2,G1,G2 |
| GP,R2,R3,S2,G1,G2 |
| GP,S2,S5,R2,R3,G2,G1 |
| GP,R3 |
| N4,S2 |
| GP,RP |
| GP,S2,RP |
| G5,G4 |
| G4,R3 |
| S2,R2,R4 |
| S1,S2,R2,R4 |
| GP,S5 |
| S1,S2,S5 |
| R4,R5 |
| R4,R2,R3,R5 |
| S2,S5,N4,RP |
| S1,S2,S3,S5,NP |
| S2,S4,S5 |
| T2,S1,S4,S5 |
| SP,RP |
| S2,RP |
| S1,S2,CP,G2 |
| CP,SP |
| S1,G2 |
| SP,CP |
| S1,S2,S5,C3 |
| S1,C1,S3 |
| G1,G3new |
| C4, C3, C1C4 |
| C4,C3,C1 |
| S1,S2,S3,S5,R2,R3,R4 |
| S1,S2,S3,R2 |
| S2,S3,S5,C4,R2 |
| S1,S5,C1 |
| S1,S2,S3,C1,C3,C4,R2 |
| Ggp |
| S3,S2,C1,C4,G2 G3new |
| R1,R2,R3,R4 |
| R4,R1,R2,R3 |
| R4,R2,R3 |
| S1,C1,C4,R2 |
| R4,R2 |
| S2,C4,R2,R4 |
| S2,C4,R2 |
| S2,S3,S5,C3,C4,R2 |
| S1,S2,S4,T2 |
| S1,S2,S4 |
| S1,S2,S4,R5 |
| S3,S2,C1,C4,G2,G3new |
| GP,C1 |
| S1,S5,C4 |
| S1,S2,S3,S5,R2,R3,R4,GP |
| GP,C4,C3,C1 |
| SMG9 |
| SMG1 |
| SMG2 |
| N3,R5 |
| N1, N2, N4, G1, G2, R3, S1, SMG2 |
| S1,SMG1 |
| SMG1,N4 |
| N1,C1,N4,S1,T2,G2,SMG1,SMG2,SMG3,SMG7,SMG9 |
| SMG1,N2 |
| S1,S2,N2,N4 |
| N4,N2 |
| G1,G2 |
| G1,G2,C1 |
| G1,G2,N1 |
| SMG2, SMG1, SMG3, SMG4, SMG7, SMG9, SMG10, G1, G2, G3, N1, N3, T2 |
| SMG2,G1 |
| S1,G1,G2 |
| SMG1,N1,G1,G2 |
| G2,G1 |
| G1,G2,G3,S1,S2,SMG1,SMG2,SMG7,N1,N2,N3,N4,T2 |
| 23.003, 23.008, 29.060 |
| S1, S2, SMG1, SMG2, SMG12, G2, N1, N2, N4 |
| S1,S2,SMG1,SMG2,SMG12,G2,N1,N2,N4 |
| S1,SMG2,N1,N2,N4 |
| SMG1,T2 |
| S1,N1,N2,N4 |
| S1,S2,N5 |
| SMG2,SMG7,G2,T2 |
| S3,N1,N2,N3 |
| S3,N1,N2,N4 |
| SMG9,T3 |
| SMG2,SMG3,SMG7,G2,N2 |
| SMG2,N1,G1,G2 |
| S1,N2 |
| N1,N3 |
| S2,N1 |
| N1,N2,N4 |
| N2,N1,N4 |
| N2,N4 |
| S1,T3 |
| T2,N3 |
| S3,N2 |
| T2,S1 |
| S1,N4 |
| SMG1,SMG2,SMG7 |
| N1,S1,T1 |
| SMG1,SMG3 |
| N4,S2,N1 |
| S1,S2,SMG1,SMG2,SMG7,G1,G2,G3,N1,N2,N3,N4,T2 |
| SMG1,N3 |
| S1,N3 |
| CP,SP,SMG |
| CP,SP,TP,GP,SMG |
| NP,SP,TP,GP,SMG |
| NP,GP, RP,SP,TP |
| SMG2,SMG1,SMG3,SMG4,SMG7,SMG9,SMG10,G1,G2,G3,N1,N3,T2 |
| S1,N2,N4 |
| S1,S2,S3,C1,C3,C4,R2,R3 |
| R2,R3,R1,R4 |
| R2,R3,R4 |
| R2,R1,R3,R4 |
| S2,C4,R2,R3,R4 |
| S2,C4,R2,R1,R3,R4 |
| S2,S3,S5,C3,C4,R2,R3,R4 |
| R1,R2,R4 |
| R3,R1,R4 |
| S2, |
| S2,G2, |
| S1,S2,G2, |
| S1,S2,G2,R2,R3, |
| S1,S2,C4,G2,R2,R3 |
| S1,S2,N4,G2,R2,R3 |
| S1,S2,SMG1,SMG2,SMG12,G2,N1,N2,N4,R2,R3 |
| S1,SMG1,T2 |
| S1,SMG1,S2 |
| S1,N4,N2 |
| T2,N1,N3 |
| S3,N2,N4 |
| SMG1,SMG2,SMG3,SMG7,SMG9,N1,C1,N4,S1,T2,G2 |
| SMG1,N2,N4 |
| S2,T2,N1,N2,N4 |
| S1,T2 |
| S1,S2,C4 |
| S1,S2,N4,RP |
| S2,N4 |
| S1,S2,N3,N4,RP |
| S1,S2,SMG1,SMG2,SMG12,T2,G2,N1,N2,N4,R2,R3 |
| S1,T2,N1,N3 |
| S1,S2,SMG1,SMG2,SMG12,T2,G2,N1,N2,N3,N4,R2,R3 |
| S1,S2,S3,SMG1,SMG2,SMG12,G2,N1,N2,N4,R2,R3 |
| S1,S2,SMG,G1,G2,G3,N1,N2,N3,N4,T2 |
| S1,S2,SMG,T2,G2,N1,N2,N3,N4,R2,R3 |
| S1,S3,SMG,G1,G2,G3,N1,N2,N3,N4,T2 |
| S1,S3,T2,N2,N4 |
| S1,S2,SMG,T2,G1,G2,G3,N1,N2,N3,N4 |
| G2,S2 |
| T1,R5 |
| R5,T1 |
| S1,S2,S4,T1,R5 |
| S1,S2,S4,S5,T1,RP,GP |
| S1,S2,S3,S5,R2,R3,R4,GP,C1 |
| S1,S2,S3,SMG1,SMG2,SMG12,N1,N2,N4,R2,R3 |
| S1,S2,SMG,T2,N1,N2,N3,N4,R2,R3 |
| NP,SP,TP,SMG |
| S1,S2,SMG,T2,N1,N2,N3,N4 |
| SMG,N1 |
| SMG |
| S1,S2,SMG1,SMG2,SMG7,N1,N2,N3,N4,T2 |
| SMG2,SMG1,SMG3,SMG4,SMG7,SMG9,SMG10,N1,N3,T2 |
| S1,SMG |
| SMG2,SMG7,T2 |
| SMG2,S2 |
| N1,N2,N4,R3,S1,SMG |
| SMG2,SMG3,SMG7,N2 |
| SMG1,SMG2,SMG3,SMG7,SMG9,N1,C1,N4,S1,T2 |
| S1,S2,SMG,N3,N4,RP |
| S1,S2,S4,SMG,N3,N4,RP |
| S2,C1,C4,R2,R1,R3,R4 |
| R2,S2,S4 |
| G3new,R5 |
| GP,R4 |
| S2,S4,R2 |
| SP,GP |
| RP,SP |
| S2,S1,S3,S5 |
| S3,S1 |
| N4,N1,N2,S2 |
| S2,G1,G2,R2,R3 |
| S2,G1,G2 |
| G1,G2,R2,R3 |
| N4,T3 |
| S3,S2,N1,N4,T3,OMA |
| T2,S1,S4,S5,OMA |
| S2,N3 |
| S4,S1 |
| N4,N3,S1 |
| R5,G3new |
| R4,R2,R1 |
| S2,R2 |
| C3, C4,C1 |
| S3,C1,C4,C3 |
| C1,C4,C3 |
| S2,C1,C4,C3 |
| R3,R5 |
| S1,S2,C3 |
| R1,R2 |
| S3,C1,C4,G2,G3new |
| R1,R3 |
| GP,N1 |
| R1,R2,R3 |
| R3,R2,R4 |
| R4,R3 |
| S1,S2,R2,R3 |
| S1,S2,S3,C1,C3,C4,R2,R3,R5 |
| S2,S1,S5 |
| C4, C1 |
| C3, C1, C4 |
| S2,S1,S3,S5,C4,C1 |
| S2,C3,C1,C4 |
| S2,S1,S5,C3 |
| GP,S2,C1 |
| GP,S2,C1,G2 |
| G2,S2,C1 |
| v |
| G3new,G1,G2 |
| G1,G2,C1,G3new |
| S2,S1,S5,C1,C3 |
| C1,C3,C4,R5 |
| R2,R1 |
| S1<S2,N1,R2,R5 |
| S1,S2,N1,R2,R5 |
| S2,R5 |
| S1,S2,S5,R5 |
| S2,C1,C4,R2,R1,R3,R4,R5 |
| S1,S2,S3,S5,NP,R5 |
| S1,S2,S4,S5,RP,R5,GP |
| S1,S2,S3,S5,C1,C6,R2,R3,R4 |
| S1,S2,S3,S5,C1,C6,R2,R3,R4,GP |
| S4,R2 |
| S1,S2,C1,C4,G2 |
| S4,C3,C4 |
| S5,C1,C4 |
| S2,C4,C3,C1 |
| C4, C3, C1 |
| S2,S4,R2,C4,C3,C1 |
| GP1,GP2 |
| GP,GP1,GP2 |
| GP,G1,G2 |
| G2,R3 |
| S1,S2,S3,C1,C3,C4,G2 |
| GP,G1,C1 |
| S1,S2,C4,C3,C1 |
| - |
| GP,G1,G2,G3new |
| S1,S2,S3,C1,C3,C4,G2,R2,R3 |
| S1,S2,C1,C3,C4,G2,R2,R3 |
| C1,C6 |
| GP,G2,C4 |
| S2,C3 |
| R5,R4 |
| C4,GP,G2 |
| S1,S2,C1,C4,G2,R2,R3 |
| R1,R2,R4,S3 |
| S2,S5,C3,C1,C4 |
| S2,S4,C4,C3,C1 |
| S2,S4 |
| S3,S1,S2 |
| S1,S2,S3,C1,R2 |
| S3,S1,S2,C1,R2 |
| S2,C3,S5 |
| S1,S2,C1,C4,C3,G2,R2,R3 |
| S5,C4 |
| S2,S1,C3 |
| C1,C4,C3,C6 |
| S1,S2,C1,C4,C3,C6,G2,R2,R3 |
| R1,R2,R4,S3,C4,C6 |
| R4,R1,R4,R1,R2,R3,R3 |
| S2,R3,R2 |
| S1,S2,S5,CP |
| S1,S3,CP |
| C6,C1 |
| R4,R2,R1,R3 |
| R3,R1,R2 |
| R1,R4,R2,R3 |
| S2,C4,C1,C3 |
| R3,R1,R2,R4 |
| C4,S1 |
| S2,S5,R3,GP, |
| S2,S5,R3,GP |
| S1,S2,S3,S5,C1,C3,C4 |
| S2,S3,S5,C1,C3,C4,C6 |
| S5,S1 |
| 03.06.2011 |
| CT1 CT3, CT4 |
| CT3, |
| CT4 |
| CT3 |
| GP,G2,G1 |
| S5,S1,C1 |
| SP,RP,CP |
| SP,CP,GP,RP |
| R1,R2,R4,R3 |
| R4,R2,R5 |
| R2,R4,R5 |
| R1,R2,R4,S2,S3,C4,C6 |
| C1-IETF |
| S4-IETF |
| C1-IETF, C3-IETF, C4-IETF |
| S3-IETF |
| C4-IETF |
| C1-IETF, C3-IETF |
| S2,S4,C1,R2 |
| S2,S4,C3,C4 |
| S2,S4,C1,C3,R2 |
| S1,S2,C1,IETF |
| S4,IETF |
| C1,C4,IETF |
| S2,S4,C1,C3,R2,IETF |
| S3,C1,C4,C3,IETF |
| S3,C4,IETF |
| C1,IETF |
| S1,S2,S3,S5,C1,C3,C4,C6,IETF |
| S2,S3,C1,C4,IETF |
| S1,S2,C1,C3,C4,IETF |
| C1,C3,C4,IETF |
| S1,S5,C1,C3,C4,IETF |
| C1,C3,IETF |
| S2,C1,C3,C4,IETF |
| S2,S4,C3,C4,IETF |
| S5,C1,C4,IETF |
| S5,C1,C3,C4,IETF |
| S2,S3,S5,C1,C3,C4,IETF |
| S2,IETF |
| S3,C1,C3,C4,IETF |
| S2,S3,C1,C3,C4,IETF |
| S3,S2 |
| S3,S2,C1 |
| S3,S1,S2,C1 |
| S2,S5,N3 |
| S1,S2,S3,S5,N1,N3,N4,T3 |
| S5,N4,R3 |
| S1,S2,S5,C1,C4,C3,C6,G2,R2,R3 |
| S2,N1,N4,R3,GP |
| T2,S3 |
| S3,N4,N1 |
| S2,N3,N4 |
| S3,T2 |
| S2,S1,S3,S5,RP,GP |
| S1,S2,S3,S5,R5 |
| S1,S2,S3,S5,NP,T3,T1,R5 |
| S3,T3 |
| GP,S3 |
| S1,S2,S3,S4,S5,RP,R5,GP |
| N1,N4 |
| S1,S2,S3,S4,N1,N3,N4,OMA |
| S2,C1,C3,C4,G2,R2,R3 |
| S1,C4,C3 |
| S2,S1,C1,C4,IETF |
| C1,C3,C4,C6 |
| C4,C1,C6 |
| S1,S2,S3,C1,C3,C4,C6 |
| S2,S1,C1,C3,C4 |
| S1,S2,C1,C3 |
| C1.IETF |
| C1-IETF,C4-IETF |
| G1,C1 |
| G1,S2,C4 |
| G2,S2,C4 |
| R1,R2,R3,R4,R5 |
| R2,R4,R3,R5 |
| R3,R2,R5 |
| R2,R3,C1,C6 |
| S1,S2,S3,C1,C3,C4,C6,R2,R3 |
| R4,R1 |
| S2,S4,C4,C3,C1,IETF |
| S2,C4,C3 |
| S3.C4,C1 |
| G2,C4 |
| R4,G1,G3new |
| C4,G2 |
| S3,C4,C1 |
| R2,R3,R5 |
| R1,R2,R4,R5 |
| S1,S2,S3,S5,C1,C6,R2,R3,R4,R5,GP |
| S1,C1,C4,R2,R5 |
| S2,S3,S5,C3,C4,R2,R3,R4,R5 |
| R2,R1,R3,R4,R5 |
| S3-IETF, C1-IETF |
| S3-IETF,C1-IETF |
| C1-IETF,C3-IETF |
| S2-IETF |
| S2,S1,C1,C3,C4,IETF |
| 25.101, 25.104, 25.141, 25.317 |
| S1,G2,S2,C1 |
| S1,C1,C4,R2,R3,R5 |
| S5,S2 |
| S4,C3,C4,IETF |
| S4,S3,C3,C4,IETF |
| S4,S3,C3,C4 |
| S4,S3,IETF |
| S1,S2,S3,S5,C1,C3,C4,C6,R2,R3 |
| C1,C4,C6 |
| S1,S2,S5,C1,C4,C6,G2,R2,R3 |
| GP,G1,C1,G3new |
| S2,S5,C1,C3 |
| C4,C3,G2 |
| S2,S1,S5,C3,C1,C4 |
| C3,C4,C1 |
| S2,S1,S5,C3,C4,C1 |
| RAN1 |
| RAN2 |
| RAN3 |
| RAN4 |
| R4,R2,R3, |
| Feasibility Study on LTE Device to Device Communications – Radio Aspects |
| SMG1,SMG2,SMG3,SMG7,SMG9,N1,N4,S1,T2 |
| C3-IETF, C4-IETF |
| S3-IETF,C1-IETF,C3-IETF |
| C3-IETF |
| C3,IETF |
| S2,C1,C4,C3,IETF |
| S1,S2,S3,C1,C3,C4,R2,R3,R5,IETF |
| C1-IETF,C3-IETF,C4-IETF |
| C4,C1,C3,IETF |
| S2,C4,C1,C3,IETF |
| C1,C4,C3,IETF |
| S2,S1,T2,N1,N4,R3,R2 |
| S2,S1,S2,S1,N1,N4 |
| S2,S1,N1,N4 |
| S2,R2,G1 |
| S2,S1,S3,S5,N4,R2,R3,GP |
| S1,S2,N4 |
| S2,OMA |
| S2,N4,OMA |
| S2,S5,N4,R2,R4 |
| S2,S5,N4,R2,R4,OMA |
| GP,R2 |
| S1,S2,GP,R2 |
| G1,G3 |
| S1,G2,R2 |
| S2,S5,N4,R2,R4,R5,OMA |
| SR5 |
| S3,C4,C1,R5 |
| S3,S1,C1 |
| S2,C4,C3,G2 |
| SP,CP,RP |
| S3,R5 |
| GP,G2,G3new |
| S1,S2,S3,S4,S5,N1,N3,RP,R5,GP |
| S1,S2,S3,S4,S5,N1,N3,RP,R5,T1,GP |
| S1,S2,S3,S4,S5,N1,N3,RP,R5,T1,GP,G2,G3new |
| S1,S2,S3,S4,S5,N1,N3,R2,R4,R5,T1,GP,G2,G3new |
| S1,S2,S5,C1,C4,C6,G2,R2,R3,G3new |
| SP,CP,RP,GP |
| G2,G1,G3new |
| G2,G1,C1,G3new |
| RAN |
| R |
| S2,S1,S3,S5,R2 |
| S2,S1,S3,S5,R2,R3 |
| S1,S2,S5,C1,C4,C6,G2,R2,R3,R5,G3new |
| C1,C4,R5,IETF |
| C1,R5 |
| R3,R1 |
| R3,GP |
| S3,IETF |
| S1,S2,S5,C1,C3,C4,C6,R2,R3 |
| S3,C4,C1,C3 |
| C1,C4,S1 |
| C1,C4,R3 |
| R2,R1,R3 |
| R1,R4,R2,R3,R5 |
| RAN5 |
| S2,C4,C1,R3 |
| G1,G2,G3new |
| S4,C1 |
| S4,C4,C1,C3 |
| 14/06/2013 08:00 |
| S2,C1,C3,IETF |
| C3, C1 |
| R3,C4 |
| S2,S1,C1,C3 |
| R3,S2,C4 |
| R% |
| G1,C1,G3new |
| R3,S2,C4,G2 |
| S1,S3,N4 |
| S1,OMA |
| S1,S2,S4,OMA |
| S5,S2,N3 |
| S3,C4,C1,C3,IETF |
| S1,S2,S5,C1,C3,C4,C6,R2,R3,R5 |
| S2,S1,S5<c3 |
| S2,C1,C4,C6 |
| S2,S1,S3,C1,C4,C6 |
| S2,S1,S3,C1 |
| R2,R3,R4,G2,G1,G3new |
| C1,C3,R5 |
| ,C4,C6 |
| S2,S1,S3,C1,C4,C6,R2 |
| S2,S1,S3,C1,C4,C6,R2,R3 |
| S2,S1,S3,C1,C3,C4,C6,R2,R3 |
| S1,S2,S3,IETF |
| S1,S2,S3,C1,C3 |
| S1,S2,S3,C4,C1,C3 |
| C1,S1 |
| C34 |
| S1,S2,S3,C1,C4,IETF |
| IETF |
| SMG12 |
| SMG7 |
| SMG3 |
| SMG4 |
| SMG10 |
| C3-IETF,C4-IETF |
| NP,GP,RP,SP,TP |
| S3,G2 |
| R2,S2 |
| R2,S2,C1 |
| R2,C1 |
| S1` |
| R2,S1,C1 |
| C1-IET |
| 18/06/2014 08:00 |
| C4-IET |
| RAN1 (primary) |
| C3.S2 |
| C3-IET |
| S6 |
| ` |
| SA5 |
| Rel-13 |
| Rel-14 |
| 18/06/2015 |
| SA2 |
| S3-IET |
| SA1 |
| SA4-IETF |
| R6 |
| S3LI |

## Schedule

| ID | WBS | Task | Type | Duration | Start | Finish | Complete | Remaining | Total slack | Constraint | Resources | Work | Actual work | Release | Acronym | PCG approved | Impacted TSs and TRs | WI rapporteur name | WI rapporteur e-mail | TSG approved |
| --- | --- | --- | --- | --- | --- | --- | --- | --- | --- | --- | --- | --- | --- | --- | --- | --- | --- | --- | --- | --- |
| 1 | 1 | Work Plan 3GPP version December 2nd 2016 |  | 1d? | 2000-01-03 | 2000-01-03 |  |  | 4789d |  |  |  |  |  |  |  |  |  |  |  |
| 2 | 2 | pre-TSG#74 version: UID in the range 74xxxx not yet approved |  | 1d? | 2000-01-03 | 2000-01-03 |  |  | 4789d |  |  |  |  |  |  |  |  |  |  |  |
| 3 | 3 | Next target: Rel-14 St.3: Mar 2017 |  | 1d? | 2000-01-03 | 2000-01-03 |  |  | 4789d |  |  |  |  |  |  |  |  |  |  |  |
| 5 | 4 | Release 15 Features |  | 395d? | 2016-03-15 A | 2017-09-15 A | 100% |  |  | start no earlier than 2016-03-15 | SP; RP; CP; GP | 12640h | 12640h | Rel-15 |  |  |  |  |  |  |
| 6 | 5 | Release 15 Features on 5G | milestone | 0d? | 2016-06-09 A | 2016-06-09 A | 100% |  |  | finish no earlier than 2016-06-09 | SP; RP; CP; GP |  |  | Rel-15 |  |  |  |  |  |  |
| 7 | 6 | New Services and Markets Technology Enablers |  | 201d? | 2016-06-09 A | 2017-03-15 | 75% | 50.25d? | 283d | finish no earlier than 2017-03-15 | S1 | 1608h | 1206h | Rel-15 | SMARTER | PCG-37 | 22.261 | Li, Alice | alice.li@vodafone.com | TSG#72 |
| 8 | 7 | 5G System Architecture - Phase 1 |  | 271d? | 2016-12-01 | 2017-12-14 |  |  | 87d | finish no earlier than 2017-12-14 | S2 | 2168h |  | Rel-15 | 5GS_Ph1 |  | TS 23.228, TS 23.401, TS 23.167, TS 23.271, TS 23.002 | China Mobile, Tao Sun | suntao@chinamobile.com |  |
| 9 | 8 | Other Release 15 Features | milestone | 0d? | 2016-06-09 A | 2016-06-09 A | 100% |  |  | finish no earlier than 2016-06-09 | SP; RP; CP; GP |  |  | Rel-15 |  |  |  |  |  |  |
| 10 | 9 | Inclusion of WLAN direct discovery technologies as an alternative for ProSe direct discovery |  | 23d? | 2016-11-15 A | 2016-12-15 A | 100% |  |  | finish no earlier than 2016-12-15 | S1 | 184h | 184h | Rel-15 | ProSe_WLAN_DD |  | 22.278 | Intel Corporation; Ana Lucia Pinheiro | ana.lucia.a.pinheiro@intel.com |  |
| 11 | 10 | Enhanced Calling Name Service |  | 66d? | 2016-09-15 A | 2016-12-15 A | 100% |  |  | finish no earlier than 2016-12-15 | S1 | 528h | 528h | Rel-15 | eCNAM | PCG-37 | 22.173 | Hala Mowafy, Ericsson |  | TSG-73 |
| 12 | 11 | Server and Network Assisted DASH for 3GPP Multimedia Services |  | 206d? | 2016-12-01 | 2017-09-14 |  |  | 152d | finish no earlier than 2017-09-14 | S4 | 1648h |  | Rel-15 | SAND |  | TS 26.247 | Ozgur Oyman, Intel | ozgur.oyman@intel.com |  |
| 13 | 12 | **LTE Measurement Gap Enhancement** |  | 329d? | 2016-03-15 A | 2017-06-15 | 11% | 292.46d? | 217d |  | R4 | 7368h | 818.32h | Rel-15 | LTE_meas_gap_enh | PCG-36 |  | Intel |  | TSG#71 |
| 14 | 12.1 | Core part: LTE Measurement Gap Enhancement |  | 263d? | 2016-03-15 A | 2017-03-15 | 25% | 197.25d? | 283d | finish no earlier than 2017-03-15 | R4 | 2104h | 526h | Rel-15 | LTE_meas_gap_enh-Core | PCG-36 |  | Intel |  | TSG#71 |
| 15 | 12.2 | Perf. part: LTE Measurement Gap Enhancement |  | 329d? | 2016-03-15 | 2017-06-15 |  |  | 217d | finish no earlier than 2017-06-15 | R4 | 2632h |  | Rel-15 | LTE_meas_gap_enh-Perf | PCG-36 |  | Intel |  | TSG#71 |
| 16 | 13 | **Enhancements of Base Station (BS) RF and EMC requirements for Active Antenna System (AAS)** |  | 395d? | 2016-03-15 A | 2017-09-15 | 4% | 379.22d? | 151d |  | R4 | 8424h | 336.67h | Rel-15 | AASenh_BS_LTE_UTRA | PCG-36 |  | Huawei |  | TSG#71 |
| 17 | 13.1 | Core part: Enhancements of Base Station (BS) RF and EMC requirements for Active Antenna System (AAS) |  | 263d? | 2016-03-15 A | 2017-03-15 | 10% | 236.7d? | 283d | finish no earlier than 2017-03-15 | R4 | 2104h | 210.4h | Rel-15 | AASenh_BS_LTE_UTRA-Core | PCG-36 |  | Huawei |  | TSG#71 |
| 18 | 13.2 | Perf. part: Enhancements of Base Station (BS) RF and EMC requirements for Active Antenna System (AAS) |  | 395d? | 2016-03-15 | 2017-09-15 |  |  | 151d | finish no earlier than 2017-09-15 | R4 | 3160h |  | Rel-15 | AASenh_BS_LTE_UTRA-Perf | PCG-36 |  | Huawei |  | TSG#71 |
| 19 | 14 | **Shortened TTI and processing time for LTE** |  | 458d? | 2016-06-15 A | 2018-03-15 | 2% | 448.43d? | 22d |  | R1 | 9960h | 208.13h | Rel-15 | LTE_sTTIandPT | PCG-37 |  | Ericsson |  | TSG#72 |
| 20 | 14.1 | Core part: Shortened TTI and processing time for LTE |  | 329d? | 2016-06-15 A | 2017-09-15 | 5% | 312.55d? | 151d | finish no earlier than 2017-09-15 | R1 | 2632h | 131.6h | Rel-15 | LTE_sTTIandPT-Core | PCG-37 |  | Ericsson |  | TSG#72 |
| 21 | 14.2 | Perf. part: Shortened TTI and processing time for LTE |  | 458d? | 2016-06-15 | 2018-03-15 |  |  | 22d | finish no earlier than 2018-03-15 | R4 | 3664h |  | Rel-15 | LTE_sTTIandPT-Perf | PCG-37 |  | Ericsson |  | TSG#72 |
| 22 | 15 | **Enhanced CRS and SU-MIMO Interference Mitigation Performance Requirements for LTE** |  | 327d? | 2016-09-15 | 2017-12-15 |  |  | 86d |  | R4 | 5232h |  | Rel-15 | LTE_eCRSIM_eSUMIMO | PCG-37 |  | Intel |  | TSG-73 |
| 23 | 15.1 | Perf. part: Enhanced CRS and SU-MIMO Interference Mitigation Performance Requirements for LTE |  | 327d? | 2016-09-15 | 2017-12-15 |  |  | 86d | finish no earlier than 2017-12-15 | R4 | 2616h |  | Rel-15 | LTE_eCRSIM_eSUMIMO-Perf | PCG-37 | 36.176 | Intel |  | TSG-73 |
| 24 | 16 | Release 15 Studies |  | 395d? | 2016-06-09 A | 2017-12-12 A | 100% |  |  | start no earlier than 2016-06-09 | SP; RP; CP; GP | 12640h | 12640h | Rel-15 |  |  |  |  |  |  |
| 25 | 17 | Release 15 Studies on 5G | milestone | 0d? | 2016-06-09 A | 2016-06-09 A | 100% |  |  | finish no earlier than 2016-06-09 | SP; RP; CP; GP |  |  | Rel-15 |  |  |  |  |  |  |
| 26 | 18 | Study on Management Aspects of Next Generation Network architecture and features |  | 199d? | 2016-06-13 A | 2017-03-15 | 10% | 179.1d? | 283d | finish no earlier than 2017-03-15 | S5 | 1592h | 159.2h | Rel-15 | FS_MAN_NGNAF | PCG-37 | TR (new); 28.802 | Nokia Networks, Yizhi Yao | Yizhi.yao@nokia.com | TSG#72 |
| 27 | 19 | Study on Management and Orchestration Architecture of Next Generation Network and Service |  | 199d? | 2016-06-13 A | 2017-03-15 | 10% | 179.1d? | 283d | start no earlier than 2016-06-13 | S5 | 1592h | 159.2h | Rel-15 | FS_NGNS_MOA | PCG-37 | TR xy.abc; 28.800 | Huawei Technologies, Zou Lan | zoulan@huawei.com | TSG#72 |
| 28 | 20 | Study on management and orchestration of network slicing for next generation network |  | 199d? | 2016-06-13 A | 2017-03-15 | 25% | 149.25d? | 283d | start no earlier than 2016-06-13 | S5 | 1592h | 398h | Rel-15 | FS_MONETS | PCG-37 | 32.8xx; 28.801 | Ericsson , Robert Petersen |  | TSG#72 |
| 29 | 21 | Study on management aspects of virtualized network functions that are part of the NR |  | 259d? | 2016-09-19 A | 2017-09-14 | 5% | 246.05d? | 152d | finish no earlier than 2017-09-14 | S5 | 2072h | 103.6h | Rel-15 | FS_MA_RNVNF | PCG-37 | TR 32.864 | Intel (Joey Chou | joey.chou@intel.com | TSG-73 |
| 30 | 22 | Other Release 15 Studies | milestone | 0d? | 2016-06-09 A | 2016-06-09 A | 100% |  |  | finish no earlier than 2016-06-09 | SP; RP; CP; GP |  |  | Rel-15 |  |  |  |  |  |  |
| 31 | 23 | Study on Enhancement of 3GPP support for V2X services |  | 137d? | 2016-06-09 A | 2016-12-15 | 95% | 6.85d? | 347d | finish no earlier than 2016-12-15 | S1 | 1096h | 1041.2h | Rel-15 | FS_eV2X | PCG-37 | 22.886 | LG Electronics, SungDuck Chun | sungduck.chun@lge.com | TSG#72 |
| 32 | 24 | Study on architecture enhancements to ProSe UE-to-Network Relay |  | 206d? | 2016-12-01 A | 2017-09-14 | 5% | 195.7d? | 152d | finish no earlier than 2017-09-14 | S2 | 1648h | 82.4h | Rel-15 | FS_eProSe_Relay |  | 23.7xx | Dario Serafino Tonesi, Huawei | dario.tonesi@huawei.com |  |
| 33 | 25 | Study on unlicensed spectrum offloading system enhancements |  | 141d? | 2016-12-01 A | 2017-06-15 | 10% | 126.9d? | 217d | finish no earlier than 2017-06-15 | S2 | 1128h | 112.8h | Rel-15 | FS_USOS |  | TR 23.xxx | Haris Zisimopoulos, Qualcomm Incorporated | harisz@qti.qualcomm.com |  |
| 34 | 26 | Study on enhanced VoLTE performance |  | 206d? | 2016-12-01 A | 2017-09-14 | 5% | 195.7d? | 152d | finish no earlier than 2017-09-14 | S2 | 1648h | 82.4h | Rel-15 | FS_eVoLP |  | 23.8xx | Xiaobo Wu, Huawei | wuxiaobo@ huawei.com |  |
| 35 | 27 | Study on Future Railway Mobile Communication System |  | 137d? | 2016-06-09 A | 2016-12-15 | 40% | 82.2d? | 347d | finish no earlier than 2016-12-15 | S1 | 1096h | 438.4h | Rel-15 | FS_FRMCS | PCG-37 | 22.989 | Merkel, Juergen | Merkel, Juergen - Nokia Networks | TSG#72 |
| 36 | 28 | Study on LTE bandwidth flexibility enhancements |  | 329d? | 2016-03-15 A | 2017-06-15 | 50% | 164.5d? | 217d | finish no earlier than 2017-06-15 | R4 | 2632h | 1316h | Rel-15 | FS_LTE_BW_flex | PCG-36 | 36.740 | Huawei |  | TSG#71 |
| 37 | 29 | Study on enhancements of Public Warning System |  | 259d? | 2016-09-19 A | 2017-09-14 | 5% | 246.05d? | 152d | finish no earlier than 2017-09-14 | S1 | 2072h | 103.6h | Rel-15 | FS_ePWS | PCG-37 |  | SyncTechno Inc., Hyounhee Koo | koo at synctechno dot com | TSG-73 |
| 38 | 30 | Study on Maritime Communication Services over 3GPP system |  | 194d? | 2016-09-19 A | 2017-06-15 | 10% | 174.6d? | 217d | finish no earlier than 2017-06-15 | S1 | 1552h | 155.2h | Rel-15 | FS_MARCOM | PCG-37 |  | SyncTechno Inc., Hyounhee Koo | koo at synctechno dot com | TSG-73 |
| 39 | 31 | Study on Provision of Access to Local Operator Services |  | 75d? | 2016-12-01 A | 2017-03-15 | 75% | 18.75d? | 283d | finish no earlier than 2017-03-15 | S1 | 600h | 450h | Rel-15 | FS_PARLOS |  | 22.xxx | Covell, Betsy | betsy.covell@nokia.com |  |
| 40 | 32 | Study on Enhancement of LTE for Efficient delivery of Streaming Service |  | 206d? | 2016-12-01 | 2017-09-14 |  |  | 152d | finish no earlier than 2017-09-14 | S1 | 1648h |  | Rel-15 | FS_ eLESTR |  | 22.xxx | China Telecommunications, XIA Xu | xiaxu@ctbri.com.cn |  |
| 41 | 33 | Study on a RESTful HTTP-based Solution Set |  | 194d? | 2016-09-19 A | 2017-06-15 | 5% | 184.3d? | 217d | finish no earlier than 2017-06-15 | S5 | 1552h | 77.6h | Rel-15 | FS_OAM_RESTFUL | PCG-37 | 32.866 | Nokia: Pollakowski, Olaf |  | TSG-73 |
| 42 | 34 | Study on interference cancellation receiver for LTE BS |  | 196d? | 2016-09-15 | 2017-06-15 |  |  | 217d | finish no earlier than 2017-06-15 | R4 | 1568h |  | Rel-15 | FS_LTE_IC_BS | PCG-37 | 36.766 | China Telecom |  | TSG-73 |
| 43 | 35 | Study on Management Enhancement of CUPS of EPC Nodes |  | 206d? | 2016-12-01 | 2017-09-14 |  |  | 152d | finish no earlier than 2017-09-14 | S5 | 1648h |  | Rel-15 | FS_MECUPS |  | TR 32.xxx | Huawei; Jiang, Junyi | jiangjunyi@huawei.com |  |
| 44 | 36 | Study on Policy and Charging for Volume Based Charging |  | 140d? | 2016-12-01 | 2017-06-14 |  |  | 218d | finish no earlier than 2017-06-14 | C3 | 1120h |  | Rel-15 | FS_PC_VBC |  | TR 29.xxx | Huang, Zhenning, China Mobile | huangzhenning <at> chinamobile <dot> com |  |
| 45 | 37 | Release 14 Features |  | 655d? | 2014-12-12 A | 2017-06-14 A | 100% |  |  | start no earlier than 2014-12-12 | SP; RP; CP; GP | 20960h | 20960h | Rel-14 |  |  |  |  |  |  |
| 46 | 38 | Release 14 on Mission Critical | milestone | 0d? | 2016-06-09 A | 2016-06-09 A | 100% |  |  | finish no earlier than 2016-06-09 | SP; RP; CP; GP |  |  | Rel-14 |  |  |  |  |  |  |

Notes:
- 5: -
- 6: -
- 7: Resulting from FS_SMARTER; 19/9/16: 0%->55; 6/10/16: 22.261 added;; 1/12/16: FCD:09/16->03/20; 1/12/16: 55%->75
- 9: -
- 10: 1/12/16: 0%->100
- 11: 1/12/16: 0%->100
- 14: ; 1/7/16: Compl:0%->10%; 1/7/16: CD:Thu 15/06/17->Wed 15/03/17; 1/7/16: WID: RP-160678->RP-160912; ...26/9/16: Compl:10%->25%26/9/16: R...
- 15: 1/7/16: WID: RP-160678->RP-1609121/7/16: Release: Rel-15->Rel-14
- 16: follow-up WI of REL-13 WI AAS_BS_LTE_UTRA
- 17: follow-up WI of REL-13 WI AAS_BS_LTE_UTRA1/7/16: Compl:0%->5%1/7/16: CD:Fri 15/09/17->Wed 15/03/17...26/9/16: Compl:5%->10%;...
- 18: 1/7/16: WID: RP-160548->RP-1609401/7/16: Release: Rel-15->Rel-14; 26/9/16: WID: RP-160940->RP-161668;...
- 20: 26/9/16: Compl:0%->5%...
- 21: ; 26/9/16: WID: RP-161299->RP-161922
- 23: 6/10/16: 36.176 added;
- 24: -
- 25: -
- 26: 28/7/16: 28.802 added;; 19/9/16: 0%->5; 1/12/16: 5%->10
- 27: 28/7/16: 28.800 added;; 19/9/16: 0%->10
- 28: 28/7/16: 28.801 added;; 19/9/16: 0%->10; 1/12/16: 10%->25
- 29: 6/10/16: Acronym FS_MA_RVNF ->FS_MA_RNVNF ; 6/10/16: 32.864 added;; 1/12/16: 0%->5
- 30: -
- 31: 19/9/16: 30%->70; 6/10/16: 22.886 added;; 1/12/16: 70%->95
- 32: 1/12/16: 0%->5
- 33: 1/12/16: 0%->10
- 34: 1/12/16: 0%->5
- 35: 19/9/16: 0%->25; 6/10/16: 22.989 added;; 1/12/16: 25%->40; 1/12/16: WID:SP-160371->SP-160903
- 36: 1/7/16: Compl:0%->50%; ...; 28/7/16: 36.740 added;; 26/9/16: WID: RP-161328->RP-161670
- 37: 22.xxx; 1/12/16: 0%->5
- 38: 22.xxx; 1/12/16: 0%->10
- 39: 1/12/16: 0%->75
- 41: 6/10/16: 32.866 added;; 1/12/16: 0%->5
- 42: 6/10/16: 36.766 added;
- 45: -
- 46: -

| ID | WBS | Task | Duration | Start | Finish | Complete | Remaining | Total slack | Constraint | Resources | Work | Actual work | Acronym | PCG approved | Release | TSG approved | Impacted TSs and TRs | WI rapporteur name | WI rapporteur e-mail |
| --- | --- | --- | --- | --- | --- | --- | --- | --- | --- | --- | --- | --- | --- | --- | --- | --- | --- | --- | --- |
| 47 | 39 | **Mission Critical Improvements** | 568d? | 2015-04-14 A | 2017-06-14 | 52% | 271.99d? | 218d |  | S1; S6; C1; C3; C4; C6 | 61560h | 27646h | MCImp | PCG-36 | Rel-14 | SP-70 |  |  |  |
| 48 | 39.1 | Mission Critical Push to Talk over LTE Realignment | 138d? | 2015-12-07 A | 2016-06-15 A | 100% |  |  | finish no earlier than 2016-06-15 | S1 | 1104h | 1104h | MCImp-MCPTTR | PCG-36 | Rel-14 | SP-70 | 22.179 | Andrew Thiessen | andrew (at) its (dot) bldrdoc (dot) gov |
| 49 | 39.2 | **Enhancements for Mission Critical Push To Talk** | 264d? | 2016-06-13 A | 2017-06-14 | 24% | 200.7d? | 218d |  | S6 | 7736h | 2152.06h | MCImp-eMCPTT | PCG-37 | Rel-14 | TSG#72 | TS 23.PTT, TS 23.CFA, TS 23.VID, TS 23.DAT; 23.379 | Lazara, Dom | dom.lazara@motorolasolutions.com |
| 50 | 39.2.1 | Stage 2 of Enhancements for Mission Critical Push To Talk | 135d? | 2016-06-13 A | 2016-12-15 A | 100% |  |  | finish no earlier than 2016-12-15 | S6 | 1080h | 1080h | MCImp-eMCPTT | PCG-37 | Rel-14 | TSG#72 | TS 23.PTT, TS 23.CFA, TS 23.VID, TS 23.DAT; 23.379 | Lazara, Dom | dom.lazara@motorolasolutions.com |
| 51 | 39.2.2 | **Stage 3 of Enhancements for Mission Critical Push To Talk** | 140d? | 2016-12-01 | 2017-06-14 |  |  | 218d |  | ct | 4544h |  | MCImp-eMCPTT-CT |  | Rel-14 |  |  | FREDERICKS, Bob | bobfredericks@motorolasolutions.com |
| 52 | 39.2.2.1 | CT1 aspects of Enhancements for Mission Critical Push To Talk | 140d? | 2016-12-01 | 2017-06-14 |  |  | 218d | finish no earlier than 2017-06-14 | C1 | 1120h |  | MCImp-eMCPTT-CT |  | Rel-14 |  | 24.379, 24.380, 24.381, 24.382, 24.383, 24.384 | FREDERICKS, Bob | bobfredericks@motorolasolutions.com |
| 53 | 39.2.2.2 | CT3 aspects of Enhancements for Mission Critical Push To Talk | 74d? | 2016-12-01 | 2017-03-14 |  |  | 284d | finish no earlier than 2017-03-14 | C3 | 592h |  | MCImp-eMCPTT-CT |  | Rel-14 |  | 29.165, 29.213, 29.214 | FREDERICKS, Bob | bobfredericks@motorolasolutions.com |
| 54 | 39.2.2.3 | CT4 aspects of Enhancements for Mission Critical Push To Talk | 74d? | 2016-12-01 | 2017-03-14 |  |  | 284d | finish no earlier than 2017-03-14 | C4 | 592h |  | MCImp-eMCPTT-CT |  | Rel-14 |  | 23.003, 29.228, 23.335, 29.283 | FREDERICKS, Bob | bobfredericks@motorolasolutions.com |
| 55 | 39.2.2.4 | CT6 aspects of Enhancements for Mission Critical Push To Talk | 140d? | 2016-12-01 | 2017-06-14 |  |  | 218d | finish no earlier than 2017-06-14 | C6 | 1120h |  | MCImp-eMCPTT-CT |  | Rel-14 |  | 31.102, 31.103 | FREDERICKS, Bob | bobfredericks@motorolasolutions.com |
| 56 | 39.3 | Mission Critical Services Common Requirements | 138d? | 2015-12-07 A | 2016-06-15 A | 100% |  |  | finish no earlier than 2016-06-15 | S1 | 1104h | 1104h | MCImp-MCCoRe | PCG-36 | Rel-14 | SP-70 | New TS 22.280 | Andrew Thiessen | andrew (at) its (dot) bldrdoc (dot) gov |
| 57 | 39.4 | Common functional architecture to support mission critical services | 135d? | 2016-06-13 A | 2016-12-15 | 95% | 6.75d? | 347d | finish no earlier than 2016-12-15 | S6 | 1080h | 1026h | MCImp-MC_ARCH | PCG-37 | Rel-14 | TSG#72 | TS 23.CFA, TS 23.PTT, TS 23.VID, TS 23.DAT; 23.280 | Niranth Amogh, Huawei Telecommunications India | namogh@huawei.com |
| 58 | 39.5 | **Mission Critical Video over LTE** | 568d? | 2015-04-14 A | 2017-06-14 | 50% | 282.22d? | 218d |  | S1; S6 | 13504h | 7068.8h | MCImp-MCVideo | PCG-36 | Rel-14 | SP-70 |  | Emmanuelle Villebrun | Emmanuelle.villebrun@gendarmerie.interieur.gouv.fr |
| 59 | 39.5.1 | Study on Mission Critical Video over LTE | 176d? | 2015-04-14 A | 2015-12-15 A | 100% |  |  | finish no earlier than 2015-12-15 | S1 | 1408h | 1408h | FS_MCVideo | PCG-34 | Rel-14 | SP-67 | New TR 22.879 | Villebrun, Emmanuelle (French MoI) | emmanuelle.villebrun@gendarmerie.interieur.gouv.fr |
| 60 | 39.5.2 | Stage 1 of MCVideo | 138d? | 2015-12-07 A | 2016-06-15 A | 100% |  |  | finish no earlier than 2016-06-15 | S1 | 1104h | 1104h | MCImp-MCVideo | PCG-36 | Rel-14 | SP-70 | New TR 22.281 | Emmanuelle Villebrun | Emmanuelle.villebrun@gendarmerie.interieur.gouv.fr |
| 61 | 39.5.3 | Stage 2 for MCVideo | 135d? | 2016-06-13 A | 2016-12-15 | 95% | 6.75d? | 347d | finish no earlier than 2016-12-15 | S6 | 1080h | 1026h | MCImp-MCVideo | PCG-37 | Rel-14 | TSG#72 | TS 23.VID, TS 23.CFA, TS 23.PTT, TS 23.DAT; 23.281 | Niranth Amogh, Huawei Telecommunications India | namogh@huawei.com |
| 62 | 39.5.4 | **Stage 3 of MCVideo** | 140d? | 2016-12-01 | 2017-06-14 |  |  | 218d |  | ct | 4560h |  | MCImp-MCVIDEO-CT |  | Rel-14 |  |  | PATEL, Milan | milan.patel@huawei.com |
| 63 | 39.5.4.1 | CT1 aspects 3 of MCVideo | 140d? | 2016-12-01 | 2017-06-14 |  |  | 218d | finish no earlier than 2017-06-14 | C1 | 1120h |  | MCImp-MCVIDEO-CT |  | Rel-14 |  | 24.381, 24.382, 24.383, 24.384 | PATEL, Milan | milan.patel@huawei.com |
| 64 | 39.5.4.2 | CT3 aspects 3 of MCVideo | 75d? | 2016-12-01 | 2017-03-15 |  |  | 283d | finish no earlier than 2017-03-15 | C3 | 600h |  | MCImp-MCVIDEO-CT |  | Rel-14 |  | 29.165, 29.213, 29.214 | PATEL, Milan | milan.patel@huawei.com |
| 65 | 39.5.4.3 | CT4 aspects 3 of MCVideo | 75d? | 2016-12-01 | 2017-03-15 |  |  | 283d | finish no earlier than 2017-03-15 | C4 | 600h |  | MCImp-MCVIDEO-CT |  | Rel-14 |  | 23.003, 23.335, 29.283 | PATEL, Milan | milan.patel@huawei.com |
| 66 | 39.5.4.4 | CT6 aspects 3 of MCVideo | 140d? | 2016-12-01 | 2017-06-14 |  |  | 218d | finish no earlier than 2017-06-14 | C6 | 1120h |  | MCImp-MCVIDEO-CT |  | Rel-14 |  | 31.102, 31.103 | PATEL, Milan | milan.patel@huawei.com |
| 67 | 39.6 | **Mission Critical Data over LTE** | 568d? | 2015-04-14 A | 2017-06-14 | 50% | 282.22d? | 218d |  | S1; S6 | 13504h | 7054.74h | MCImp-MCData | PCG-36 | Rel-14 | SP-70 |  | Emmanuelle Villebrun | Emmanuelle.villebrun@gendarmerie.interieur.gouv.fr |
| 68 | 39.6.1 | Study on Mission Critical Data Communications | 176d? | 2015-04-14 A | 2015-12-15 A | 100% |  |  | finish no earlier than 2015-12-15 | S1 | 1408h | 1408h | FS_MCDATA | PCG-34 | Rel-14 | SP-67 | New TR 22.880 | Villebrun, Emmanuelle (French MoI) | emmanuelle.villebrun@gendarmerie.interieur.gouv.fr |
| 69 | 39.6.2 | Stage 1 of MCData | 138d? | 2015-12-07 A | 2016-06-15 A | 100% |  |  | finish no earlier than 2016-06-15 | S1 | 1104h | 1104h | MCImp-MCData | PCG-36 | Rel-14 | SP-70 | New TR 22.282 | Emmanuelle Villebrun | Emmanuelle.villebrun@gendarmerie.interieur.gouv.fr |
| 70 | 39.6.3 | Stage 2 for MCData | 135d? | 2016-06-13 A | 2016-12-15 | 95% | 6.75d? | 347d | start no earlier than 2016-06-13 | S6 | 1080h | 1026h | MCImp-MCData | PCG-37 | Rel-14 | TSG#72 | 23.282 | David Freeman (UK Home Office) | david@dnf-consulting.co.uk |

Notes:
- 47: Umbrella Feature
- 48: 2/3/16: FCD: 03/16->06/16. ES in SP-160102; 0->75%; 9/6/16: 75%->100
- 49: 28/7/16: 23.379 added;; 19/9/16: 0%->35; 1/12/16: 35%->100
- 50: 28/7/16: 23.379 added;; 19/9/16: 0%->35; 1/12/16: 35%->100
- 56: 2/3/16: FCD: 03/16->06/16. ES in SP-160104; 0->75%; 9/6/16: 75%->100
- 57: 28/7/16: 23.280 added;; 19/9/16: 0%->40; 1/12/16: 40%->95
- 58: 2/3/16: FCD: 03/16->06/16. ES in SP-160106; 0->80%; 9/6/16: 80%->100
- 59: 1/4/15:TR number added; June2015: Compl:0%->50; 07/09/15: 50%->70; 7/12/15: 70%->100
- 60: 2/3/16: FCD: 03/16->06/16. ES in SP-160106; 0->80%; 9/6/16: 80%->100
- 61: 28/7/16: 23.281 added;; 19/9/16: 0%->25; 1/12/16: 25%->95
- 67: 2/3/16: FCD: 03/16->06/16. ES in SP-160109; 0->80%; 9/6/16: 80%->100
- 68: 1/4/15:TR number added; June2015: Compl:0%->20; 07/09/15: 20%->90; 7/12/15: 90%->100
- 69: 2/3/16: FCD: 03/16->06/16. ES in SP-160109; 0->80%; 9/6/16: 80%->100
- 70: 28/7/16: 23.282 added;; 19/9/16: 0%->10; 1/12/16: 10%->95

| ID | WBS | Task | Type | Duration | Start | Finish | Complete | Remaining | Total slack | Constraint | Resources | Work | Actual work | Acronym | WI rapporteur name | WI rapporteur e-mail | Release | PCG approved | TSG approved |
| --- | --- | --- | --- | --- | --- | --- | --- | --- | --- | --- | --- | --- | --- | --- | --- | --- | --- | --- | --- |
| 71 | 39.6.4 | **Stage 3 of MCData** |  | 140d? | 2016-12-01 | 2017-06-14 |  |  | 218d |  | ct | 4560h |  | MCImp-MCDATA-CT | HASON, Baruh | baruh.hason@motorolasolutions.com | Rel-14 |  |  |
| 72 | 39.6.4.1 | CT1 aspects of MCData |  | 140d? | 2016-12-01 | 2017-06-14 |  |  | 218d | finish no earlier than 2017-06-14 | C1 | 1120h |  | MCImp-MCDATA-CT | HASON, Baruh | baruh.hason@motorolasolutions.com | Rel-14 |  |  |
| 73 | 39.6.4.2 | CT3 aspects of MCData |  | 75d? | 2016-12-01 | 2017-03-15 |  |  | 283d | finish no earlier than 2017-03-15 | C3 | 600h |  | MCImp-MCDATA-CT | HASON, Baruh | baruh.hason@motorolasolutions.com | Rel-14 |  |  |
| 74 | 39.6.4.3 | CT4 aspects of MCData |  | 75d? | 2016-12-01 | 2017-03-15 |  |  | 283d | finish no earlier than 2017-03-15 | C4 | 600h |  | MCImp-MCDATA-CT | HASON, Baruh | baruh.hason@motorolasolutions.com | Rel-14 |  |  |
| 75 | 39.6.4.4 | CT6 aspects of MCData |  | 140d? | 2016-12-01 | 2017-06-14 |  |  | 218d | finish no earlier than 2017-06-14 | C6 | 1120h |  | MCImp-MCDATA-CT | HASON, Baruh | baruh.hason@motorolasolutions.com | Rel-14 |  |  |
| 76 | 40 | Study on Mission Critical Security Enhancements |  | 195d? | 2016-06-17 A | 2017-03-15 | 35% | 126.75d? | 283d | finish no earlier than 2017-03-15 | S3 | 1560h | 546h | FS_MC_Sec | Haigh, Peter, CESG | peter.haigh@cesg.gsi.gov.uk | Rel-14 | PCG-37 | SP-72 |
| 77 | 41 | Study on mission critical system migration and interconnect between MCPTT systems |  | 135d? | 2016-06-13 A | 2016-12-15 | 48% | 70.2d? | 347d | finish no earlier than 2016-12-15 | S6 | 1080h | 518.4h | FS_MCSMI | Chater-Lea, David |  | Rel-14 | PCG-37 | SP-72 |
| 78 | 42 | Study on Mission Critical Communication Interworking between LTE and non-LTE Systems |  | 135d? | 2016-06-13 A | 2016-12-15 | 22% | 105.3d? | 347d | finish no earlier than 2016-12-15 | S6 | 1080h | 237.6h | FS_MCCI | Monnes, Peter (Harris Corp.) |  | Rel-14 | PCG-37 | TSG#72 |
| 79 | 43 | **Protocol enhancements for MCPTT over LTE** |  | 129d? | 2016-09-16 A | 2017-03-15 | 6% | 120.94d? | 283d |  | ct | 5160h | 322.46h | MCPTTProtoc1 |  |  | Rel-14 | PCG-37 | TSG-73 |
| 80 | 43.1 | CT1 aspects of MCPTTProtoc1 |  | 129d? | 2016-09-16 A | 2017-03-15 | 5% | 122.55d? | 283d | finish no earlier than 2017-03-15 | C1 | 1032h | 51.6h | MCPTTProtoc1 | Ricky Kaura | ricky.kaura@samsung.com | Rel-14 | PCG-37 | TSG-73 |
| 81 | 43.2 | CT3 aspects of MCPTTProtoc1 |  | 129d? | 2016-09-16 A | 2017-03-15 | 20% | 103.2d? | 283d | finish no earlier than 2017-03-15 | C3 | 1032h | 206.4h | MCPTTProtoc1 | Ricky Kaura | ricky.kaura@samsung.com | Rel-14 | PCG-37 | TSG-73 |
| 82 | 43.3 | CT4 aspects of MCPTTProtoc1 |  | 129d? | 2016-09-16 | 2017-03-15 |  |  | 283d | finish no earlier than 2017-03-15 | C4 | 1032h |  | MCPTTProtoc1 | Ricky Kaura | ricky.kaura@samsung.com | Rel-14 | PCG-37 | TSG-73 |
| 83 | 43.4 | CT6 aspects of MCPTTProtoc1 |  | 129d? | 2016-09-16 | 2017-03-15 |  |  | 283d | finish no earlier than 2017-03-15 | C6 | 1032h |  | MCPTTProtoc1 | Ricky Kaura | ricky.kaura@samsung.com | Rel-14 | PCG-37 | TSG-73 |
| 84 | 44 | Security of the Mission Critical Service |  | 194d? | 2016-09-19 A | 2017-06-15 | 25% | 145.5d? | 217d | finish no earlier than 2017-06-15 | S3 | 1552h | 388h | MCSec | Haigh, Peter, CESG | peter.haigh@cesg.gsi.gov.uk | Rel-14 | PCG-37 | TSG-73 |
| 85 | 45 | Release 14 on V2X | milestone | 0d? | 2016-06-09 A | 2016-06-09 A | 100% |  |  | finish no earlier than 2016-06-09 | SP; RP; CP; GP |  |  |  |  |  | Rel-14 |  |  |
| 86 | 46 | **LTE support for V2X services** |  | 681d? | 2015-02-09 A | 2017-09-15 | 57% | 296.16d? | 151d |  | S1; S2; R1; R4; ct | 60672h | 12701.5h | V2XLTE |  |  | Rel-14 | PCG-35 | SP-68 |
| 87 | 46.1 | Stage 1 for LTE support for V2X services |  | 137d? | 2015-09-09 A | 2016-03-17 A | 100% |  |  | finish no earlier than 2016-03-17 | S1 | 1096h | 1096h | V2XLTE |  |  | Rel-14 | PCG-35 | SP-68 |
| 88 | 46.2 | Architecture enhancements for LTE support of V2X services |  | 137d? | 2016-06-09 A | 2016-12-15 A | 100% |  |  | finish no earlier than 2016-12-15 | S2 | 1096h | 1096h | V2XARC | LG Electronics, LaeYoung Kim | laeyoung.kim@lge.com | Rel-14 | PCG-37 | TSG#72 |
| 89 | 46.3 | Security aspect of LTE support of V2X services |  | 141d? | 2016-12-01 | 2017-06-15 |  |  | 217d | finish no earlier than 2017-06-15 | S3 | 1128h |  | V2XLTE | Huawei, Marcus Wong | mwong@huawei.com | Rel-14 |  |  |
| 90 | 46.4 | **RAN aspects of LTE-based V2X Services** |  | 329d? | 2016-06-15 A | 2017-09-15 | 6% | 310.52d? | 151d |  | R1; R4 | 9472h | 384.23h | LTE_V2X | LG Electronics |  | Rel-14 | PCG-37 | TSG#72 |
| 91 | 46.4.1 | Core part: LTE-based V2X Services |  | 197d? | 2016-06-15 A | 2017-03-15 | 15% | 167.45d? | 283d | finish no earlier than 2017-03-15 | R1 | 1576h | 236.4h | LTE_V2X-Core | LG Electronics |  | Rel-14 | PCG-37 | TSG#72 |
| 92 | 46.4.2 | Perf. part: LTE-based V2X Services |  | 329d? | 2016-06-15 | 2017-09-15 |  |  | 151d | finish no earlier than 2017-09-15 | R4 | 2632h |  | LTE_V2X-Perf | LG Electronics |  | Rel-14 | PCG-37 | TSG#72 |
| 93 | 46.5 | **CT aspects of V2X Services** |  | 129d? | 2016-09-16 A | 2017-03-15 | 46% | 69.34d? | 283d |  | ct | 5160h | 2386.47h | V2X-CT | Taehun Kim | taehun78.kim@lge.com | Rel-14 | PCG-37 | TSG-73 |
| 94 | 46.5.1 | CT1 aspects of V2X Services |  | 129d? | 2016-09-16 A | 2017-03-15 | 65% | 45.15d? | 283d | finish no earlier than 2017-03-15 | C1 | 1032h | 670.8h | V2X-CT | Taehun Kim | taehun78.kim@lge.com | Rel-14 | PCG-37 | TSG-73 |
| 95 | 46.5.2 | CT3 aspects of V2X Services |  | 129d? | 2016-09-16 A | 2017-03-15 | 40% | 77.4d? | 283d | finish no earlier than 2017-03-15 | C3 | 1032h | 412.8h | V2X-CT | Taehun Kim | taehun78.kim@lge.com | Rel-14 | PCG-37 | TSG-73 |
| 96 | 46.5.3 | CT4 aspects of V2X Services |  | 129d? | 2016-09-16 A | 2017-03-15 | 80% | 25.8d? | 283d | finish no earlier than 2017-03-15 | C4 | 1032h | 825.6h | V2X-CT | Taehun Kim | taehun78.kim@lge.com | Rel-14 | PCG-37 | TSG-73 |
| 97 | 46.5.4 | CT6 aspects of V2X Services |  | 129d? | 2016-09-16 | 2017-03-15 |  |  | 283d | finish no earlier than 2017-03-15 | C6 | 1032h |  | V2X-CT | Taehun Kim | taehun78.kim@lge.com | Rel-14 | PCG-37 | TSG-73 |

Notes:
- 72: Impacted TSs and TRs: 24.381, 24.382, 24.383, 24.384
- 73: Impacted TSs and TRs: 29.165, 29.213, 29.214
- 74: Impacted TSs and TRs: 23.003, 23.335, 29.283
- 75: Impacted TSs and TRs: 31.102, 31.103
- 76: 28/7/16: 33.280 added;; 28/7/16: 39.880 added;; 19/9/16: WID:SP-160374->SP-160567. FCD: 12/16->03/17; 1/12/16: 0%->35 / Impacted TSs and TRs: TR 33.xxx; 33.280; 39.880
- 77: 28/7/16: 23.781 added;; 19/9/16: WID:SP-160340->SP-160526; FCD: 09/16->12/16; 19/9/16: 0%->40; 1/12/16: WID:SP-160526->SP-160880; 1/12/16: 40%->48 / Impacted TSs and TRs: New TR 23.781
- 78: 28/7/16: 23.782 added;; 19/9/16: WID:SP-160341->SP-160527; 19/9/16: 0%->20; 1/12/16: WID:SP-160527->SP-160881; 1/12/16: 20%->22 / Impacted TSs and TRs: New TR 23.782
- 80: Impacted TSs and TRs: 24.229, 24.379, 24.380, 24.381, 24.382, 24.383, 24.384, 24.980
- 81: 2/12/16: 0%->20 / Impacted TSs and TRs: 29.165, 29.212, 29.213, 29.214
- 82: Impacted TSs and TRs: 23.003, 23.008, 29.283
- 83: Impacted TSs and TRs: 31.102
- 84: 6/10/16: 33.180 added;; 1/12/16: 0%->25 / Impacted TSs and TRs: 33.180
- 85: -
- 86: 7/12/15: 0%->5; 28/1/16: 22.185 added; 2/3/16: 5%->90; 9/6/16: 90%->100 / Impacted TSs and TRs: 22.278; 22.185
- 87: 7/12/15: 0%->5; 28/1/16: 22.185 added; 2/3/16: 5%->90; 9/6/16: 90%->100 / Impacted TSs and TRs: 22.278; 22.185
- 88: 28/7/16: 23.285 added;; 19/9/16: 0%->85; 1/12/16: FCD:09/16->12/16; 1/12/16: 85%->100 / Impacted TSs and TRs: 23.285
- 89: Impacted TSs and TRs: TS 33.v2x
- 90: follow-up WI of REL-14 SI FS_LTE_V2X
- 91: follow-up WI of REL-14 SI FS_LTE_V2X26/9/16: Compl:0%->15%26/9/16: WID: RP-161298->RP-161894; 6/10/16: 36.786 added;; 6/10/16: added; / Impacted TSs and TRs: 36.786;
- 92: ; 26/9/16: WID: RP-161298->RP-161894
- 94: 6/10/16: 24.385 added;; 6/10/16: 24.386 added;; 2/12/16: 0%->65 / Impacted TSs and TRs: 23.122, 24.301, 24.334; 24.385; 24.386
- 95: 6/10/16: 29.387 added;; 2/12/16: 0%->40 / Impacted TSs and TRs: 29.212, 29.468; 29.387
- 96: 6/10/16: 29.388 added;; 6/10/16: 29.389 added;; 2/12/16: 0%->80 / Impacted TSs and TRs: 23.003, 23.007, 23.008, 29.272; 29.388; 29.389
- 97: Impacted TSs and TRs: 31.102, 31.111

| ID | WBS | Task | Type | Duration | Start | Finish | Complete | Remaining | Total slack | Constraint | Resources | Work | Actual work | Acronym | PCG approved | WI rapporteur name | WI rapporteur e-mail | Release | TSG approved | Status Report |
| --- | --- | --- | --- | --- | --- | --- | --- | --- | --- | --- | --- | --- | --- | --- | --- | --- | --- | --- | --- | --- |
| 98 | 46.6 | **Study on LTE support for V2X services** |  | 421d? | 2015-02-09 A | 2016-09-16 | 95% | 23.12d? | 411d |  | S1; S2; S3; R1 | 17936h | 6650.8h | FS_V2XLTE | PCG-34 | Ki-Dong Lee (LG electronics) | kidong.lee@lge.com | Rel-14 | SP-67 |  |
| 99 | 46.6.1 | Study on Stage 1 of LTE support for V2X services |  | 1d? | 2015-02-09 A | 2015-02-09 A | 100% |  |  | start no earlier than 2015-09-07 | S1 | 8h | 8h | FS_V2XLTE | PCG-34 | Ki-Dong Lee (LG electronics) | kidong.lee@lge.com | Rel-14 | SP-67 |  |
| 100 | 46.6.2 | Study on Stage 2 of LTE support for V2X services |  | 205d? | 2015-09-07 A | 2016-06-17 A | 100% |  |  | finish no earlier than 2016-06-17 | S2 | 1640h | 1640h | FS_V2XARC | PCG-36 | LG Electronics, LaeYoung Kim | laeyoung.kim@lge.com | Rel-14 | SP-70 |  |
| 101 | 46.6.3 | Study on security aspects for LTE support of V2X services |  | 271d? | 2015-09-07 A | 2016-09-16 | 85% | 40.65d? | 411d | finish no earlier than 2016-09-16 | S3 | 2168h | 1842.8h | FS_V2XLTE | PCG-36 | Huawei, Marcus Wong | mwong@huawei.com | Rel-14 | SP-70 |  |
| 102 | 46.6.4 | RAN1 Study on LTE-based V2X Services |  | 263d? | 2015-06-15 A | 2016-06-15 A | 100% |  |  | finish no earlier than 2016-09-15 | R1 | 2104h | 2104h | FS_LTE_V2X | PCG-35 | LG Electronics |  | Rel-14 | TSG-68 | RP-151311 |
| 103 | 47 | **Support for V2V services based on LTE sidelink** |  | 460d? | 2015-12-15 A | 2017-09-15 | 25% | 343.98d? | 151d |  | R1; R4; R5 | 17352h | 2582.85h | LTE_SL_V2V | PCG-36 | LG Electronics |  | Rel-14 | RP-70 |  |
| 104 | 47.1 | Core part: Support for V2V services based on LTE sidelink |  | 199d? | 2015-12-15 A | 2016-09-15 A | 100% |  |  | finish no earlier than 2016-09-15 | R1 | 1592h | 1592h | LTE_SL_V2V-Core | PCG-36 | LG Electronics |  | Rel-14 | RP-70 |  |
| 105 | 47.2 | Perf. part: Support for V2V services based on LTE sidelink |  | 328d? | 2015-12-15 | 2017-03-15 |  |  | 283d | finish no earlier than 2017-03-15 | R4 | 2624h |  | LTE_SL_V2V-Perf | PCG-36 | LG Electronics |  | Rel-14 | RP-70 |  |
| 106 | 47.3 | UE Conformance Test Aspects - Support for V2V services based on LTE sidelink |  | 262d? | 2016-09-15 | 2017-09-15 |  |  | 151d | finish no earlier than 2017-09-15 | R5 | 2096h |  | LTE_SL_V2V-UEConTest | PCG-37 | Huawei |  | Rel-14 | TSG-73 |  |
| 107 | 48 | Release 14 on CIoT | milestone | 0d? | 2016-06-09 A | 2016-06-09 A | 100% |  |  | finish no earlier than 2016-06-09 | SP; RP; CP; GP |  |  |  |  |  |  | Rel-14 |  |  |
| 108 | 49 | **Non-IP for Cellular Internet of Things (CIoT) for 2G/3G-GPRS(EC-EGPRS)** |  | 143d? | 2016-03-02 A | 2016-09-15 | 99% | 0d? | 0d |  | S2; C1; C4 | 9760h | 6632h | NonIP_GPRS | PCG-36 |  |  | Rel-14 | TSG#71 |  |
| 109 | 49.1 | Non-IP for Cellular IoT for EC-EGPRS |  | 76d? | 2016-03-02 A | 2016-06-15 A | 100% |  |  | start no earlier than 2016-03-02 | S2 | 608h | 608h | NonIP_GPRS | PCG-36 | Hans Ronneke, Ericsson | hans . Ronneke (a) ericsson . Com | Rel-14 | TSG#71 |  |
| 110 | 49.2 | **CT aspects for Non-IP for Cellular Internet of Things for EC-EGPRS** |  | 143d? | 2016-03-02 A | 2016-09-15 A | 100% |  |  |  | C1; C4 | 5720h | 5720h | NonIP_GPRS-CT | PCG-36 | Orange, Youssef CHADLI | youssef.chadli@orange.com | Rel-14 | TSG#71 |  |
| 111 | 49.2.1 | CT1 aspects for Non-IP for Cellular Internet of Things for EC-EGPRS |  | 143d? | 2016-03-02 A | 2016-09-15 A | 100% |  |  | finish no earlier than 2016-09-15 | C1 | 1144h | 1144h | NonIP_GPRS-CT | PCG-36 | Orange, Youssef CHADLI | youssef.chadli@orange.com | Rel-14 | TSG#71 |  |
| 112 | 49.2.2 | CT3 aspects for Non-IP for Cellular Internet of Things for EC-EGPRS |  | 143d? | 2016-03-02 A | 2016-09-15 A | 100% |  |  | finish no earlier than 2016-09-15 | C3 | 1144h | 1144h | NonIP_GPRS-CT | PCG-37 | Orange, Youssef CHADLI | youssef.chadli@orange.com | Rel-14 | CT-72 |  |
| 113 | 49.2.3 | CT4 aspects for Non-IP for Cellular Internet of Things for EC-EGPRS |  | 143d? | 2016-03-02 A | 2016-09-15 A | 100% |  |  | finish no earlier than 2016-09-15 | C4 | 1144h | 1144h | NonIP_GPRS-CT | PCG-36 | Orange, Youssef CHADLI | youssef.chadli@orange.com | Rel-14 | TSG#71 |  |
| 114 | 50 | **Further enhanced MTC for LTE** |  | 329d? | 2016-06-15 A | 2017-09-15 | 4% | 314.22d? | 151d |  | R1; R4 | 9472h | 307.34h | LTE_feMTC | PCG-37 | Ericsson |  | Rel-14 | TSG#72 |  |
| 115 | 50.1 | Core part: Further enhanced MTC for LTE |  | 197d? | 2016-06-15 A | 2017-03-15 | 12% | 173.36d? | 283d | finish no earlier than 2017-03-15 | R1 | 1576h | 189.12h | LTE_feMTC-Core | PCG-37 | Ericsson |  | Rel-14 | TSG#72 |  |
| 116 | 50.2 | Perf. part: Further enhanced MTC for LTE |  | 329d? | 2016-06-15 | 2017-09-15 |  |  | 151d | finish no earlier than 2017-09-15 | R4 | 2632h |  | LTE_feMTC-Perf | PCG-37 | Ericsson |  | Rel-14 | TSG#72 |  |
| 117 | 51 | **Enhancements of NB-IoT** |  | 329d? | 2016-06-15 A | 2017-09-15 | 5% | 312.98d? | 151d |  | R1; R4 | 9472h | 333h | NB_IOTenh | PCG-37 | Huawei |  | Rel-14 | TSG#72 |  |
| 118 | 51.1 | Core part: Enhancements of NB-IoT |  | 197d? | 2016-06-15 A | 2017-03-15 | 13% | 171.39d? | 283d | finish no earlier than 2017-03-15 | R1 | 1576h | 204.88h | NB_IOTenh-Core | PCG-37 | Huawei |  | Rel-14 | TSG#72 |  |
| 119 | 51.2 | Perf. part: Enhancements of NB-IoT |  | 329d? | 2016-06-15 | 2017-09-15 |  |  | 151d | finish no earlier than 2017-09-15 | R4 | 2632h |  | NB_IOTenh-Perf | PCG-37 | Huawei |  | Rel-14 | TSG#72 |  |
| 120 | 52 | AT Commands for CIoT |  | 65d? | 2016-09-16 A | 2016-12-15 | 95% | 3.25d? | 347d | finish no earlier than 2016-12-15 | C1 | 520h | 494h | AT_CIoT | PCG-37 | John-Luc Bakker |  | Rel-14 | TSG-73 |  |
| 121 | 53 | **Extended architecture support for Cellular Internet of Things** |  | 194d? | 2016-06-17 A | 2017-03-14 | 57% | 82.98d? | 284d |  | S2 | 4912h | 2634.69h | CIoT_Ext | PCG-37 | Intel : Puneet Jain | puneet.jain@intel.com | Rel-14 | TSG-73 |  |
| 122 | 53.1 | Study on extended architecture support for Cellular Internet of Things |  | 131d? | 2016-06-17 A | 2016-12-15 A | 100% |  |  | finish no earlier than 2016-12-15 | S2 | 1048h | 1048h | FS_CIoT_Ext | PCG-37 | Intel : Puneet Jain | puneet.jain@intel.com | Rel-14 | SP-72 |  |
| 123 | 53.2 | Stage 2 of Extended architecture support for Cellular Internet of Things |  | 67d? | 2016-09-15 A | 2016-12-16 A | 100% |  |  | finish no earlier than 2016-12-16 | S2 | 536h | 536h | CIoT_Ext | PCG-37 | Intel : Puneet Jain | puneet.jain@intel.com | Rel-14 | TSG-73 |  |

Notes:
- 98: 1/4/15:TR number added; June2015: Compl:25%->50; 07/09/15: 50%->75 / Impacted TSs and TRs: New TR 22.885
- 99: 1/4/15:TR number added; June2015: Compl:25%->50; 07/09/15: 50%->75; 7/12/15: 75%->100 / Impacted TSs and TRs: New TR 22.885
- 100: 11/12/15: WID:SP-150625->SP-150743; 7/3/16: 10%->22; 7/3/16: WID:SP-150743->SP-150852; 9/6/16: 22%->80; 19/9/16: 80%->100 / Impacted TSs and TRs: TR 23.785
- 101: 11/12/15: WID:SP-150715->SP-150743. 28/01/16: typo on name corrected, WD corrected (was SP-150743); 7/3/16: 0%->10; 19/9/16: 10%->65; 1/12/16: 65%->85 / Impacted TSs and TRs: TR 33.885
- 102: 29/09/15: Compl:0%->5% 29/09/15: Stat Rep: -->RP-151311 ; 28/1/16: 33.885 added;22/3/16: Compl:35%->50%22/3/16: CD:Wed 15/06/16->Thu 15/09/1622/3/16: WID: RP-15...; ;... / Impacted TSs and TRs: 33.885
- 104: 22/3/16: Compl:0%->15%22/3/16: WID: RP-152293->RP-1606491/7/16: Compl:15%->60%1/7/16: WID: RP-160649->RP-161272; 28/7/16: 36.785 added;; 26/9/16: Compl:60%->100%; 26/9/16: WID: RP-161272->RP-161603 / Impacted TSs and TRs: 36.785
- 105: 22/3/16: WID: RP-152293->RP-1606491/7/16: WID: RP-160649->RP-16127226/9/16: WID: RP-161272->RP-161603
- 107: -
- 109: 9/6/16: 0%->50; 19/9/16: 50%->100 / Impacted TSs and TRs: 23.060, 23.682, 23.401?
- 110: 11/6/16: WID:CP-160161->CP-160293
- 111: 11/6/16: 0%->50; 11/6/16: WID:CP-160161->CP-160293; 16/9/16: 50%->65; 2/12/16: 65%->100 / Impacted TSs and TRs: 24.008
- 112: 11/6/16: WID:CP-160161->CP-160293; 13/6/16: 0%->65; 20/9/16: 0%->100 / Impacted TSs and TRs: 29.060, 29.274, 29.002, 29.303, 23.008, 29.128, 29.272, 23.007
- 113: 11/6/16: WID:CP-160161->CP-160293; 13/6/16: 0%->65; 2/12/16: 65%->100 / Impacted TSs and TRs: 29.060, 29.274, 29.002, 29.303, 23.008, 29.128, 29.272, 23.007
- 115: 26/9/16: Compl:0%->12%26/9/16: WID: RP-161321->RP-161464
- 116: ; 26/9/16: WID: RP-161321->RP-161464
- 118: 26/9/16: Compl:0%->13%26/9/16: WID: RP-161324->RP-161901
- 119: 26/9/16: WID: RP-161324->RP-161901
- 120: 2/12/16: 10%->95
- 121: Impacted TSs and TRs: 23.401, 23.682, 23.060
- 122: 28/7/16: 23.730 added;; 19/9/16: 0%->70; 1/12/16: FCD:03/17->12/16; 1/12/16: 70%->100 / Impacted TSs and TRs: 23.730
- 123: 1/12/16: 0%->100; 1/12/16: WID:SP-160732->SP-160830 / Impacted TSs and TRs: 23.401, 23.682, 23.060, 23.271

| ID | WBS | Task | Type | Duration | Start | Finish | Complete | Remaining | Total slack | Constraint | Resources | Work | Actual work | Acronym | WI rapporteur name | WI rapporteur e-mail | Release | PCG approved | TSG approved |
| --- | --- | --- | --- | --- | --- | --- | --- | --- | --- | --- | --- | --- | --- | --- | --- | --- | --- | --- | --- |
| 124 | 53.3 | **Stage 3 of extended architecture enhancements for Cellular Internet of Things** |  | 74d? | 2016-12-01 | 2017-03-14 |  |  | 284d |  | ct | 1776h |  | CIoT_Ext-CT | Intel, Vivek Gupta | vivek.g.gupta@intel.com | Rel-14 |  |  |
| 125 | 53.3.1 | CT1 aspects of extended architecture enhancements for Cellular Internet of Things |  | 74d? | 2016-12-01 | 2017-03-14 |  |  | 284d | finish no earlier than 2017-03-14 | C1 | 592h |  | CIoT_Ext-CT | Intel, Vivek Gupta | vivek.g.gupta@intel.com | Rel-14 |  |  |
| 126 | 53.3.2 | CT4 aspects of extended architecture enhancements for Cellular Internet of Things |  | 74d? | 2016-12-01 | 2017-03-14 |  |  | 284d | finish no earlier than 2017-03-14 | C4 | 592h |  | CIoT_Ext-CT | Intel, Vivek Gupta | vivek.g.gupta@intel.com | Rel-14 |  |  |
| 127 | 54 | **Radio Interface Enhancements for Extended Coverage GSM for support of Cellular Internet of Things** |  | 130d? | 2016-09-15 | 2017-03-15 |  |  | 283d |  | R6 | 3120h |  | CIoT_EC_GSM_radio_enh | Nokia |  | Rel-14 | PCG-37 | TSG-73 |
| 128 | 54.1 | Core part: Radio Interface Enhancements for Extended Coverage GSM for support of Cellular Internet of Things |  | 130d? | 2016-09-15 | 2017-03-15 |  |  | 283d | finish no earlier than 2017-03-15 | R6 | 1040h |  | CIoT_EC_GSM_radio_enh-Core | Nokia |  | Rel-14 | PCG-37 | TSG-73 |
| 129 | 54.2 | Perf. part: Radio Interface Enhancements for Extended Coverage GSM for support of Cellular Internet of Things |  | 130d? | 2016-09-15 | 2017-03-15 |  |  | 283d | finish no earlier than 2017-03-15 | R6 | 1040h |  | CIoT_EC_GSM_radio_enh-Perf | Nokia |  | Rel-14 | PCG-37 | TSG-73 |
| 130 | 55 | Battery Efficient Security for very low Throughput MTC Devices |  | 64d? | 2016-09-19 | 2016-12-15 |  |  | 347d | finish no earlier than 2016-12-15 | S3 | 512h |  | BEST_MTC_Sec | Evans, Tim, VODAFONE Group Plc. |  | Rel-14 | PCG-37 | TSG-73 |
| 131 | 56 | **New band support for Rel-14 Narrowband Internet of Things (NB-IOT)** |  | 130d? | 2016-09-15 | 2017-03-15 |  |  | 283d |  | R4 | 3120h |  | NB_IOT_R14_bands | Ericsson |  | Rel-14 | PCG-37 | TSG-73 |
| 132 | 56.1 | Core part: New band support for Rel-14 Narrowband Internet of Things (NB-IOT) |  | 130d? | 2016-09-15 | 2017-03-15 |  |  | 283d | finish no earlier than 2017-03-15 | R4 | 1040h |  | NB_IOT_R14_bands-Core | Ericsson |  | Rel-14 | PCG-37 | TSG-73 |
| 133 | 56.2 | Perf. part: New band support for Rel-14 Narrowband Internet of Things (NB-IOT) |  | 130d? | 2016-09-15 | 2017-03-15 |  |  | 283d | finish no earlier than 2017-03-15 | R4 | 1040h |  | NB_IOT_R14_bands-Perf | Ericsson |  | Rel-14 | PCG-37 | TSG-73 |
| 134 | 57 | **Enhancements of Dedicated Core Networks selection mechanism** |  | 327d? | 2015-09-17 A | 2016-12-15 | 66% | 111.87d? | 347d |  | S2; ct | 7888h | 3127.3h | eDecor | Roland Gustafsson | Roland.Gustafsson@ericsson.com | Rel-14 | PCG-35 | SP-69 |
| 135 | 57.1 | Study on Enhancements of Dedicated Core Networks selection mechanism |  | 132d? | 2015-09-17 A | 2016-03-18 A | 100% |  |  | finish no earlier than 2016-03-18 | S2 | 1056h | 1056h | FS_eDecor | Roland Gustafsson | Roland.Gustafsson@ericsson.com | Rel-14 | PCG-35 | SP-69 |
| 136 | 57.2 | Enhancements of Dedicated Core Networks selection mechanism |  | 72d? | 2016-06-09 A | 2016-09-15 A | 100% |  |  | finish no earlier than 2016-09-15 | S2 | 576h | 576h | eDecor | Roland Gustafsson | Roland.Gustafsson@ericsson.com | Rel-14 | PCG-37 | TSG#72 |
| 137 | 57.3 | **CT aspects of eDecor** |  | 65d? | 2016-09-16 A | 2016-12-15 | 30% | 45.5d? | 347d |  | ct | 2080h | 624h | eDecor-CT | Mikael Wass | Mikael.wass@ericsson.com | Rel-14 | PCG-37 | TSG-73 |
| 138 | 57.3.1 | CT1 aspects of eDecor |  | 65d? | 2016-09-16 A | 2016-12-15 | 80% | 13d? | 347d | finish no earlier than 2016-12-15 | C1 | 520h | 416h | eDecor-CT | Mikael Wass | Mikael.wass@ericsson.com | Rel-14 | PCG-37 | TSG-73 |
| 139 | 57.3.2 | CT4 aspects of eDecor |  | 65d? | 2016-09-16 A | 2016-12-15 | 10% | 58.5d? | 347d | finish no earlier than 2016-12-15 | C4 | 520h | 52h | eDecor-CT | Mikael Wass | Mikael.wass@ericsson.com | Rel-14 | PCG-37 | TSG-73 |
| 140 | 57.3.3 | CT6 aspects of eDecor |  | 65d? | 2016-09-16 | 2016-12-15 |  |  | 347d | finish no earlier than 2016-12-15 | C6 | 520h |  | eDecor-CT | Mikael Wass | Mikael.wass@ericsson.com | Rel-14 | PCG-37 | TSG-73 |
| 141 | 58 | Study on Management aspects of selected IoT-related features |  | 194d? | 2016-09-19 A | 2017-06-15 | 5% | 184.3d? | 217d | finish no earlier than 2017-06-15 | S5 | 1552h | 77.6h | FS_OAM_IOT | Cisco Systems / Yanover, Vladimir |  | Rel-14 | PCG-37 | TSG-73 |
| 142 | 59 | Release 14 on WLAN | milestone | 0d? | 2016-06-09 A | 2016-06-09 A | 100% |  |  | finish no earlier than 2016-06-09 | SP; RP; CP; GP |  |  |  |  |  | Rel-14 |  |  |
| 143 | 60 | **EIR check for WLAN access to EPC** |  | 230d? | 2015-11-02 A | 2016-09-15 | 99% | 0d? | 0d |  | S2; ct | 5400h | 4312.05h | EWE | Alcatel-Lucent, Nicolas Drevon | Nicolas.Drevon@alcatel-lucent.com | Rel-14 | PCG-36 | SP-70 |
| 144 | 60.1 | Stage 2 of EWE |  | 165d? | 2015-11-02 A | 2016-06-17 A | 100% |  |  | finish no earlier than 2016-06-17 | S2 | 1320h | 1320h | EWE | Alcatel-Lucent, Nicolas Drevon | Nicolas.Drevon@alcatel-lucent.com | Rel-14 | PCG-36 | SP-70 |
| 145 | 60.2 | **CT aspects of EWE** |  | 70d? | 2016-06-13 A | 2016-09-15 A | 100% |  |  |  | ct | 1680h | 1680h | EWE-CT | Nokia, Bruno Landais | bruno.landais@nokia.com | Rel-14 | PCG-37 | TSG#72 |
| 146 | 60.2.1 | CT1 aspects of EWE |  | 70d? | 2016-06-13 A | 2016-09-15 A | 100% |  |  | finish no earlier than 2016-09-15 | C1 | 560h | 560h | EWE-CT | Nokia, Bruno Landais | bruno.landais@nokia.com | Rel-14 | PCG-37 | TSG#72 |
| 147 | 60.2.2 | CT4 aspects of EWE |  | 70d? | 2016-06-13 A | 2016-09-15 A | 100% |  |  | finish no earlier than 2016-09-15 | C4 | 560h | 560h | EWE-CT | Nokia, Bruno Landais | bruno.landais@nokia.com | Rel-14 | PCG-37 | TSG#72 |

Notes:
- 125: Impacted TSs and TRs: 24.301, 24.008
- 126: Impacted TSs and TRs: 23.008, 29.272, 29.002, 29.336, 29.128, 29.171, 29.172, 29.173
- 130: 6/10/16: 33.163 added; / Impacted TSs and TRs: 33.401, 43.020, 33.220; 33.163
- 134: 7/12/15: 0%->70; 7/3/16: 70%->80; 9/6/16: 80%->95 / Impacted TSs and TRs: 23.711
- 135: 7/12/15: 0%->70; 7/3/16: 70%->80; 9/6/16: 80%->95; 19/9/16: 95%->100 / Impacted TSs and TRs: 23.711
- 136: 19/9/16: 70%->100 / Impacted TSs and TRs: 23.401, 23.060, 23.251
- 138: 2/12/16: 0%->80 / Impacted TSs and TRs: 24.301, 24.008, 24.368
- 139: 2/12/16: 0%->10 / Impacted TSs and TRs: 29.303, 23.003, 23.008
- 140: Impacted TSs and TRs: 31.102, 31.111
- 141: 6/10/16: 32.857 added;; 1/12/16: 0%->5 / Impacted TSs and TRs: 32.857
- 142: -
- 143: 7/3/16: 45%->60; 9/6/16: 60%->100 / Impacted TSs and TRs: 23.002, 23.402
- 144: 7/3/16: 45%->60; 9/6/16: 60%->100 / Impacted TSs and TRs: 23.002, 23.402
- 146: 16/9/16: 0%->100 / Impacted TSs and TRs: 24.302
- 147: 2/12/16: 0%->100 / Impacted TSs and TRs: 29.273

| ID | WBS | Task | Type | Duration | Start | Finish | Complete | Remaining | Total slack | Constraint | Resources | Work | Actual work | Acronym | PCG approved | WI rapporteur name | WI rapporteur e-mail | Release | TSG approved | Impacted TSs and TRs |
| --- | --- | --- | --- | --- | --- | --- | --- | --- | --- | --- | --- | --- | --- | --- | --- | --- | --- | --- | --- | --- |
| 148 | 61 | **Support of EAP Re-authentication Protocol for WLAN Interworking** |  | 130d? | 2016-09-16 A | 2017-03-16 | 73% | 34.72d? | 282d |  | S3; ct | 6232h | 4481.23h | ERP | PCG-37 | ORANGE, Todor Gamishev | Todor dot Gamishev at Orange dot com | Rel-14 | TSG-73 |  |
| 149 | 61.1 | Support of EAP Re-authentication Protocol for WLAN Interworking |  | 129d? | 2016-09-16 A | 2017-03-15 | 90% | 12.9d? | 283d | finish no earlier than 2017-03-15 | S3 | 1032h | 928.8h | ERP | PCG-37 | ORANGE, Todor Gamishev | Todor dot Gamishev at Orange dot com | Rel-14 | TSG-73 | 33.402 |
| 150 | 61.2 | **CT aspects of ERP** |  | 130d? | 2016-09-16 A | 2017-03-16 | 65% | 45.5d? | 282d |  | ct | 3120h | 2028h | ERP-CT | PCG-37 | Orange, Julien Bournelle | Julien.bournelle@orange.com | Rel-14 | TSG-73 |  |
| 151 | 61.2.1 | CT1 aspects of ERP |  | 130d? | 2016-09-16 A | 2017-03-16 | 80% | 26d? | 282d | finish no earlier than 2017-03-16 | C1 | 1040h | 832h | ERP-CT | PCG-37 | Orange, Julien Bournelle | Julien.bournelle@orange.com | Rel-14 | TSG-73 | 24.302 |
| 152 | 61.2.2 | CT4 aspects of ERP |  | 130d? | 2016-09-16 A | 2017-03-16 | 50% | 65d? | 282d | finish no earlier than 2017-03-16 | C4 | 1040h | 520h | ERP-CT | PCG-37 | Orange, Julien Bournelle | Julien.bournelle@orange.com | Rel-14 | TSG-73 | 29.273, 23.008, 23.003 |
| 153 | 62 | **Phase 2 of the Support of Emergency services over WLAN** |  | 403d? | 2015-09-01 A | 2017-03-15 | 80% | 82.08d? | 283d |  | S2; ct | 11136h | 7474.57h | SEW2 | PCG-37 | Nicolas Drevon | nicolas.drevon@nokia.com | Rel-14 | TSG#72 | new 23.771, TS 23.402, TS 23.167 |
| 154 | 62.1 | Study on Phase 2 of the Support of Emergency services over WLAN |  | 208d? | 2015-09-01 A | 2016-06-16 A | 100% |  |  | finish no earlier than 2016-06-16 | S2 | 1664h | 1664h | FS_SEW2 | PCG-34 | Laurent Thiebaut, Alcatel Lucent | Laurent.thiebaut@alcatel-lucent.com | Rel-14 | SP-67 | new 23.771 |
| 155 | 62.2 | Support of Emergency services over WLAN - phase 2 |  | 70d? | 2016-06-13 A | 2016-09-15 A | 100% |  |  | finish no earlier than 2016-09-15 | S2 | 560h | 560h | SEW2 | PCG-37 | Nicolas Drevon | nicolas.drevon@nokia.com | Rel-14 | TSG#72 | TS 23.402, TS 23.167 |
| 156 | 62.3 | **CT aspects of SEW2** |  | 129d? | 2016-09-16 A | 2017-03-15 | 65% | 45.15d? | 283d |  | ct | 4128h | 2683.21h | SEW2-CT | PCG-37 | Jennifer Liu | jennifer.liu@nokia.com | Rel-14 | TSG-73 |  |
| 157 | 62.3.1 | CT1 aspects of SEW2 |  | 129d? | 2016-09-16 A | 2017-03-15 | 95% | 6.45d? | 283d | finish no earlier than 2017-03-15 | C1 | 1032h | 980.4h | SEW2-CT | PCG-37 | Jennifer Liu | jennifer.liu@nokia.com | Rel-14 | TSG-73 | 24.302, 24.312, 24.301, 24.244, 24.229, 24.237 |
| 158 | 62.3.2 | CT4 aspects of SEW2 |  | 129d? | 2016-09-16 A | 2017-03-15 A | 100% |  |  | finish no earlier than 2017-03-15 | C4 | 1032h | 1032h | SEW2-CT | PCG-37 | Jennifer Liu | jennifer.liu@nokia.com | Rel-14 | TSG-73 | 23.003, 29.272, 29.273, 29.274, 29.328 |
| 159 | 62.3.3 | CT6 aspects of SEW2 |  | 129d? | 2016-09-16 | 2017-03-15 |  |  | 283d | finish no earlier than 2017-03-15 | C6 | 1032h |  | SEW2-CT | PCG-37 | Jennifer Liu | jennifer.liu@nokia.com | Rel-14 | TSG-73 | 31.102 |
| 160 | 63 | T-ADS supporting WLAN Access |  | 134d? | 2016-03-15 A | 2016-09-15 A | 100% |  |  | finish no earlier than 2016-09-15 | S2 | 1072h | 1072h | TADS_WLAN | PCG-37 | Jiang Yi | jiangyi (at) chinamobile (dot) com | Rel-14 | SP-72 | TS 23.292, TS 23.221, TS 23.402 |
| 161 | 64 | **Enhanced LTE-WLAN Aggregation (LWA)** |  | 263d? | 2016-03-15 A | 2017-03-15 | 45% | 144.66d? | 283d |  | R2 | 4208h | 1893.54h | LTE_WLAN_aggr | PCG-36 | Intel |  | Rel-14 | TSG#71 |  |
| 162 | 64.1 | Core part: Enhanced LTE-WLAN Aggregation (LWA) |  | 263d? | 2016-03-15 A | 2017-03-15 | 45% | 144.65d? | 283d | finish no earlier than 2017-03-15 | R2 | 2104h | 946.8h | LTE_WLAN_aggr-Core | PCG-36 | Intel |  | Rel-14 | TSG#71 |  |
| 163 | 65 | Study on Complementary Features for Voice services over WLAN |  | 199d? | 2016-06-13 A | 2017-03-15 | 10% | 179.1d? | 283d | finish no earlier than 2017-03-15 | S2 | 1592h | 159.2h | FS_VoWLAN | PCG-37 | Nokia (Nicolas Drevon | nicolas.drevon@nokia.com | Rel-14 | SP-72 | 23.751 |
| 164 | 66 | Other Release 14 | milestone | 0d? | 2016-06-09 A | 2016-06-09 A | 100% |  |  | finish no earlier than 2016-06-09 | SP; RP; CP; GP |  |  |  |  |  |  | Rel-14 |  |  |
| 165 | 67 | **User Controlled Spoofed Call Treatment** |  | 146d? | 2016-08-23 A | 2017-03-14 | 41% | 86.2d? | 284d |  | S1; C1 | 1920h | 388h | SPECTRE | PCG-37 | Greg Schumacher, Sprint |  | Rel-14 | TSG-73 |  |
| 166 | 67.1 | Stage 1 of User Controlled Spoofed Call Treatment |  | 20d? | 2016-08-23 A | 2016-09-19 A | 100% |  |  | finish no earlier than 2016-09-19 | S1 | 160h | 160h | SPECTRE | PCG-37 | Greg Schumacher, Sprint |  | Rel-14 | TSG-73 | 22.228, 22.173 |
| 167 | 67.2 | Stage 3 of User Controlled Spoofed Call Treatment |  | 74d? | 2016-12-01 A | 2017-03-14 | 25% | 55.5d? | 284d | finish no earlier than 2017-03-14 | C1 | 592h | 148h | SPECTRE-CT |  | Dolly, Martin | md3135@att.com | Rel-14 |  | 24.229, 29.165 |
| 168 | 68 | **Evolution to and Interworking with eCall in IMS** |  | 355d? | 2015-05-11 A | 2016-09-15 | 83% | 60.22d? | 412d |  | S1; S2; C1; C6 | 17648h | 5793.4h | EIEI | PCG-35 | Kurt Bischinger |  | Rel-14 | SP-68 | 22.101 |
| 169 | 68.1 | Stage 1 of Evolution to and Interworking with eCall in IMS |  | 30d? | 2015-05-11 A | 2015-06-19 A | 100% |  |  | start no earlier than 2015-05-11 | S1 | 240h | 240h | EIEI | PCG-35 | Kurt Bischinger |  | Rel-14 | SP-68 | 22.101 |
| 170 | 68.2 | Stage 2 of Evolution to and Interworking with eCall in IMS |  | 131d? | 2015-12-11 A | 2016-06-10 A | 100% |  |  | finish no earlier than 2016-06-10 | S2 | 1048h | 1048h | EIEI | PCG-35 | Haris Zisimopoulos, Qualcomm Incorporated | harisz@qti.qualcomm.com | Rel-14 | SP-68 | 23.167, 23.401 |
| 171 | 68.3 | **CT aspects of evolution to and interworking with eCall in IMS** |  | 143d? | 2016-03-02 A | 2016-09-15 | 77% | 33.36d? | 412d |  | C1; C6 | 5720h | 4385.4h | EIEI-CT | PCG-36 | Lena Chaponniere | lguellec@qti.qualcomm.com | Rel-14 | TSG#71 |  |
| 172 | 68.3.1 | CT1 aspects of evolution to and interworking with eCall in IMS |  | 143d? | 2016-03-02 A | 2016-09-15 A | 100% |  |  | finish no earlier than 2016-09-15 | C1 | 1144h | 1144h | EIEI-CT | PCG-36 | Lena Chaponniere | lguellec@qti.qualcomm.com | Rel-14 | TSG#71 | 24.229, 24.301 |
| 173 | 68.3.2 | (IETF) Next-Generation Pan-European eCall (draft-ietf-ecrit-ecall) |  | 143d? | 2016-03-02 A | 2016-09-15 | 30% | 100.1d? | 412d | finish no earlier than 2016-09-15 | C1.IETF | 1144h | 343.2h | EIEI-CT | PCG-37 |  |  | Rel-14 | TSG#72 | draft-ietf-ecrit-ecall |
| 174 | 68.3.3 | CT6 aspects of evolution to and interworking with eCall in IMS |  | 143d? | 2016-03-02 A | 2016-09-15 A | 100% |  |  | finish no earlier than 2016-09-15 | C6 | 1144h | 1144h | EIEI-CT | PCG-36 | Lena Chaponniere | lguellec@qti.qualcomm.com | Rel-14 | TSG#71 | 31.102 |

Notes:
- 149: 1/12/16: 0%->90
- 151: 2/12/16: 0%->80
- 152: 2/12/16: 0%->50
- 154: June2015: Compl:0%->100, SP-150151->SP-150251; 7/12/15: 0%->30, FCD: 12/15->06/16; 7/3/16: 30%->75; 7/3/16: WID:SP-150251->SP-160173; 9/6/16: 75%->100
- 155: 11/6/16: 0%->45; 19/9/16: 45%->100
- 157: 2/12/16: 20%->95
- 158: 2/12/16: 0%->100
- 160: 19/9/16: 0%->100
- 161: follow-up WI of REL-13 WI LTE_WLAN_radio; no Perf. part
- 162: follow-up WI of REL-13 WI LTE_WLAN_radio; no Perf. part1/7/16: Compl:0%->25%1/7/16: WID: RP-160600->RP-160923; 26/9/16: Compl:25%->45%
- 163: 28/7/16: 23.751 added;; 19/9/16: 0%->10
- 164: -
- 165: 1/12/16: moved from Rel-15 to Rel-14; 1/12/16: WID:SP-160729->SP-160898
- 166: 1/12/16: moved from Rel-15 to Rel-14; 1/12/16: WID:SP-160729->SP-160898
- 167: 2/12/16: 0%->25
- 168: 12/15: created by MCC to distinguish Stage 1 from Stage 2
- 170: 7/3/16: 0%->20; 9/6/16: 20%->100. FCD: 03/16->06/16
- 172: 11/6/16: 0%->35; 16/9/16: 35%->85; 2/12/16: 85%->100
- 174: 16/9/16: 0%->100

| ID | WBS | Task | Duration | Start | Finish | Complete | Remaining | Total slack | Constraint | Resources | Work | Actual work | Acronym | PCG approved | WI rapporteur name | WI rapporteur e-mail | Release | TSG approved |
| --- | --- | --- | --- | --- | --- | --- | --- | --- | --- | --- | --- | --- | --- | --- | --- | --- | --- | --- |
| 175 | 69 | **Enhancement for TV service** | 502d? | 2015-04-14 A | 2017-03-14 | 60% | 200.02d? | 284d |  | S1; S2; S4 | 18256h | 5308.03h | EnTV | PCG-36 | Zhiming Li | Lizhiming@huawei.com | Rel-14 | SP-70 |
| 176 | 69.1 | Study on 3GPP Enhancement for TV Video service | 176d? | 2015-04-14 A | 2015-12-15 A | 100% |  |  | finish no earlier than 2015-12-15 | S1 | 1408h | 1408h | FS_EnTV | PCG-34 | Zhiming Li (Huawei) | lizhiming@huawei.com | Rel-14 | SP-67 |
| 177 | 69.2 | **System Architecture Enhancements to eMBMS for TV Video Service** | 201d? | 2016-03-11 A | 2016-12-15 | 99% | 0d? | 0d |  | S2; S4 | 4016h | 2492.06h | AE_enTV | PCG-36 |  |  | Rel-14 | TSG#71 |
| 178 | 69.2.1 | Study on System Architecture Enhancements to eMBMS for TV Video Service | 136d? | 2016-03-11 A | 2016-09-15 A | 100% |  |  | finish no earlier than 2016-09-15 | S2 | 1088h | 1088h | FS_AE_enTV | PCG-36 | Miguel Griot, Qualcomm | mgriot@qti.qualcomm.com | Rel-14 | TSG#71 |
| 179 | 69.2.2 | System Architecture Enhancements for TV service | 81d? | 2016-08-25 A | 2016-12-15 A | 100% |  |  | finish no earlier than 2016-12-15 | S2 | 648h | 648h | AE_enTV | PCG-37 | Miguel Griot, Qualcomm | mgriot@qti.qualcomm.com | Rel-14 | TSG-73 |
| 180 | 69.3 | Mobile Network Interface for MBMS Delivery of Media and TV services | 80d? | 2016-08-22 A | 2016-12-09 | 50% | 40d? | 351d | finish no earlier than 2016-12-09 | S4 | 640h | 320h | AE_enTV-MI_MTV | PCG-37 | Thorsten Lohmar | Thorsten.lohmar@ericsson.com | Rel-14 | TSG-73 |
| 181 | 69.4 | **Stage 3 of system architecture enhancements for TV service** | 74d? | 2016-12-01 A | 2017-03-14 | 10% | 66.6d? | 284d |  | ct | 2960h | 295.97h | AE_enTV-CT |  | Catovic, Amer | amerc@qti.qualcomm.com | Rel-14 |  |
| 182 | 69.4.1 | CT1 aspects of system architecture enhancements for TV service | 74d? | 2016-12-01 A | 2017-03-14 | 40% | 44.4d? | 284d | finish no earlier than 2017-03-14 | C1 | 592h | 236.8h | AE_enTV-CT |  | Catovic, Amer | amerc@qti.qualcomm.com | Rel-14 |  |
| 183 | 69.4.2 | CT3 aspects of system architecture enhancements for TV service | 74d? | 2016-12-01 | 2017-03-14 |  |  | 284d | finish no earlier than 2017-03-14 | C4 | 592h |  | AE_enTV-CT |  | Catovic, Amer | amerc@qti.qualcomm.com | Rel-14 |  |
| 184 | 69.4.3 | CT4 aspects of system architecture enhancements for TV service | 74d? | 2016-12-01 | 2017-03-14 |  |  | 284d | finish no earlier than 2017-03-14 | C4 | 592h |  | AE_enTV-CT |  | Catovic, Amer | amerc@qti.qualcomm.com | Rel-14 |  |
| 185 | 69.4.4 | CT6 aspects of system architecture enhancements for TV service | 74d? | 2016-12-01 | 2017-03-14 |  |  | 284d | finish no earlier than 2017-03-14 | C6 | 592h |  | AE_enTV-CT |  | Catovic, Amer | amerc@qti.qualcomm.com | Rel-14 |  |
| 186 | 70 | MBMS Transport Protocol and APIs | 330d? | 2015-12-11 A | 2017-03-15 | 70% | 99d? | 283d | finish no earlier than 2017-03-15 | S4 | 2640h | 1848h | TRAPI | PCG-36 | Samsung, Imed Bouazizi | i.bouazizi@samsung.com | Rel-14 | SP-70 |
| 187 | 71 | Multimedia Priority Service Modifications | 331d? | 2015-03-11 A | 2016-06-15 A | 100% |  |  | finish no earlier than 2016-06-15 | S1 | 2648h | 2648h | MPS_Mods | PCG-34 | Ray P. Singh (Applied Communications Science) | rsingh@appcomsci.com | Rel-14 | SP-67 |
| 188 | 72 | Lawful Interception Rel-14 | 328d? | 2016-06-15 A | 2017-09-14 | 10% | 295.2d? | 152d | finish no earlier than 2017-09-14 | S3LI | 2624h | 262.4h | LI14 | PCG-37 | Koen JASPERS, PIDS |  | Rel-14 | TSG#72 |
| 189 | 73 | **SIP Reason header extension** | 129d? | 2016-09-16 A | 2017-03-15 | 25% | 96.75d? | 283d |  | ct | 3096h | 774h | REAS_EXT | PCG-37 | Mohali, Marianne | marianne.mohali@orange.com | Rel-14 | TSG-73 |
| 190 | 73.1 | CT1 aspects of SIP Reason header extension | 129d? | 2016-09-16 A | 2017-03-15 | 50% | 64.5d? | 283d | finish no earlier than 2017-03-15 | C1 | 1032h | 516h | REAS_EXT | PCG-37 | Mohali, Marianne | marianne.mohali@orange.com | Rel-14 | TSG-73 |
| 191 | 73.2 | CT3 aspects of SIP Reason header extension | 129d? | 2016-09-16 | 2017-03-15 |  |  | 283d | finish no earlier than 2017-03-15 | C3 | 1032h |  | REAS_EXT | PCG-37 | Mohali, Marianne | marianne.mohali@orange.com | Rel-14 | TSG-73 |
| 192 | 74 | Enhancements to User Location Reporting Support | 73d? | 2015-09-09 A | 2015-12-18 A | 100% |  |  | finish no earlier than 2015-12-18 | S1 | 584h | 584h | eULRS | PCG-35 |  |  | Rel-14 | SP-68 |
| 193 | 75 | **Diameter Load Control Mechanism** | 597d? | 2014-12-03 A | 2017-03-15 | 98% | 10.85d? | 283d |  | ct | 8032h | 7448.03h | DLoCMe | PCG-37 | Nokia, Ulrich Wiehe | ulrich.wiehe@nokia.com | Rel-14 | TSG-73 |
| 194 | 75.1 | CT3 aspects of Diameter Load Control Mechanism | 65d? | 2016-09-16 A | 2016-12-15 A | 100% |  |  | finish no earlier than 2016-12-15 | C3 | 520h | 520h | DLoCMe | PCG-37 | Nokia, Ulrich Wiehe | ulrich.wiehe@nokia.com | Rel-14 | TSG-73 |
| 195 | 75.2 | CT4 aspects of Diameter Load Control Mechanism | 65d? | 2016-09-16 A | 2016-12-15 A | 100% |  |  | finish no earlier than 2016-12-15 | C4 | 520h | 520h | DLoCMe | PCG-37 | Nokia, Ulrich Wiehe | ulrich.wiehe@nokia.com | Rel-14 | TSG-73 |
| 196 | 75.3 | (IETF) Diameter Load Information Conveyance (draft-ietf-dime-load-03) | 74d? | 2016-12-02 A | 2017-03-15 | 90% | 7.4d? | 283d | finish no earlier than 2017-03-15 | C4-IETF | 592h | 532.8h | DLoCMe |  |  |  | Rel-14 |  |
| 197 | 75.4 | Study on Diameter Load Control Mechanisms | 203d? | 2014-12-03 A | 2015-09-11 A | 100% |  |  | finish no earlier than 2015-09-11 | C4 | 1624h | 1624h | FS_DLoCME | PCG-34 | Alcatel-Lucent |  | Rel-13 | CT-66 |
| 198 | 76 | **Diameter Base Protocol Specification Update** | 74d? | 2016-12-01 A | 2017-03-14 | 3% | 71.51d? | 284d |  | S5 | 2944h | 108.69h | DBPU |  | Huawei, Peter Schmitt | Peter.Schmitt@huawei.com | Rel-14 |  |
| 199 | 76.1 | **CT aspects of Diameter Base Protocol Specification Update** | 74d? | 2016-12-01 A | 2017-03-14 | 5% | 70.3d? | 284d |  | ct | 1776h | 88.79h | DBPU |  | Huawei, Peter Schmitt | Peter.Schmitt@huawei.com | Rel-14 |  |
| 200 | 76.1.1 | CT3 aspects of Diameter Base Protocol Specification Update | 74d? | 2016-12-01 | 2017-03-14 |  |  | 284d | finish no earlier than 2017-03-14 | C3 | 592h |  | DBPU |  | Huawei, Peter Schmitt | Peter.Schmitt@huawei.com | Rel-14 |  |
| 201 | 76.1.2 | CT4 aspects of Diameter Base Protocol Specification Update | 74d? | 2016-12-01 A | 2017-03-14 | 10% | 66.6d? | 284d | finish no earlier than 2017-03-14 | C4 | 592h | 59.2h | DBPU |  | Huawei, Peter Schmitt | Peter.Schmitt@huawei.com | Rel-14 |  |
| 202 | 76.2 | Charging aspects for Diameter Base Protocol Specification Update | 72d? | 2016-12-01 | 2017-03-10 |  |  | 286d | finish no earlier than 2017-03-10 | S5 | 576h |  | DBPU-CH |  | Nokia | Nokia, Maryse <dot> Gardella <at> Nokia <dot> com | Rel-14 |  |

Notes:
- 175: 2/3/16: 0%->100 / Impacted TSs and TRs: 22.101
- 176: 1/4/15:TR number added; June2015: Compl:0%->20; 07/09/15: 20%->75; 7/12/15: 75%->100 / Impacted TSs and TRs: TR 22.816
- 178: 9/6/16: 0%->70; 28/7/16: 23.746 added;; 19/9/16: 70%->100 / Impacted TSs and TRs: TR 23.746
- 179: 19/9/16: 0%->85; 1/12/16: FCD:09/16->12/16; 1/12/16: 85%->100 / Impacted TSs and TRs: TS 23.246
- 180: 06/10/16: Acronym: SA_enTV-MI_MTV -> AE_enTV-MI_MTV; 1/12/16: FCD:09/16->2/16; 1/12/16: 0%->50 / Impacted TSs and TRs: 26.346
- 182: 2/12/16: 0%->40 / Impacted TSs and TRs: 24.008
- 183: Impacted TSs and TRs: 29.061
- 184: Impacted TSs and TRs: 29.274, 23.003
- 185: Impacted TSs and TRs: 31.102
- 186: 28/1/16: 26.347 added;; 7/3/16: 0%->20; 11/6/16: 20%->35; 19/9/16: 35%->60. FCD: 09/16->03/17; 1/12/16: 60%->70 / Impacted TSs and TRs: 26.346, 26.852, New TS; 26.347
- 187: 1/4/15: rapporteur added, Impacted TS added. 6/15: 0->25%; 07/09/15: 25%->40; 7/12/15: 40%->70; 2/3/16: 70%->80; 9/6/16: 80%->100 / Impacted TSs and TRs: 22.153
- 188: 1/12/16: 0%->10
- 190: 2/12/16: 0%->50 / Impacted TSs and TRs: 24.229
- 191: Impacted TSs and TRs: 29.163, 29.292
- 192: 2/3/16: 0%->100
- 194: 2/12/16: 0%->100 / Impacted TSs and TRs: 29.272, 29.273, 29.228, 29.229, 29.328, 29.329, 29.336, 29.344, 29.345, 29.128, 29.283
- 195: 2/12/16: 0%->100 / Impacted TSs and TRs: 29.153, 29.154, 29.212, 29.214, 29.215, 29.217, 29.219, 29.213
- 196: 2/12/16: 0%->90
- 197: 0->5%. Mar. 15: 10%; 7/12/15: 10%->40; 13/6/16: 40%->100 / Impacted TSs and TRs: New 29.810
- 200: Impacted TSs and TRs: 29.061, 29.153, 29.154, 29.212, 29.214, 29.215, 29.217, 29.219, 29.368, 29.468, 29.213, 29.155, 29.201
- 201: 2/12/16: 0%->10 / Impacted TSs and TRs: 29.109, 29.128, 29.172, 29.173, 29.228, 29.229, 29.272, 29.273, 29.283, 29.328, 29.329, 29.336, 29.337, 29.338, 29.343, 29.344, 29.345
- 202: Impacted TSs and TRs: 32.240, 32.251, 32.260, 32.270, 32.271, 32.272, 32.273, 32.274, 32.275, 32.278, 32.280, 32.295, 32.296, 32.297, 32.299

| ID | WBS | Task | Duration | Start | Finish | Complete | Remaining | Baseline start | Baseline finish | Baseline duration | Total slack | Constraint | Resources | Work | Actual work | Acronym | PCG approved | Impacted TSs and TRs | WI rapporteur name | Release | TSG approved | WI rapporteur e-mail | TSG stopped | MCC resp | Acronym_3GU_Export | Status Report |
| --- | --- | --- | --- | --- | --- | --- | --- | --- | --- | --- | --- | --- | --- | --- | --- | --- | --- | --- | --- | --- | --- | --- | --- | --- | --- | --- |
| 203 | 77 | **Password based service activation for IMS Multimedia Telephony service** | 463d? | 2015-03-11 A | 2016-12-15 | 9% | 423.57d? |  |  |  | 347d |  | S1; ct | 10648h | 2899h | PWDIMS | PCG-34 | 22.173 | Peter Bleckert (Ericsson) | Rel-14 | SP-67 |  |  |  |  |  |
| 204 | 77.1 | Stage 1 for PWDIMS | 3d? | 2015-03-11 A | 2015-03-13 A | 100% |  |  |  |  |  | finish no earlier than 2015-03-13 | S1 | 24h | 24h | PWDIMS | PCG-34 | 22.173 | Peter Bleckert (Ericsson) | Rel-14 | SP-67 |  |  |  |  |  |
| 205 | 77.2 | **CT aspects for PWDIMS** | 135d? | 2016-06-13 A | 2016-12-15 | 7% | 124.88d? |  |  |  | 347d |  | ct | 3240h | 243h | PWDIMS-CT | PCG-37 |  | Axell, Jörgen | Rel-14 | TSG#72 |  |  |  |  |  |
| 206 | 77.2.1 | CT1 aspects for PWDIMS | 135d? | 2016-06-13 A | 2016-12-15 | 15% | 114.75d? |  |  |  | 347d | finish no earlier than 2016-12-15 | C1 | 1080h | 162h | PWDIMS-CT | PCG-37 | 24.623, 24.611 | Axell, Jörgen | Rel-14 | TSG#72 |  |  |  |  |  |
| 207 | 77.2.2 | CT3 aspects for PWDIMS | 135d? | 2016-06-13 | 2016-12-15 |  |  |  |  |  | 347d | finish no earlier than 2016-12-15 | C3 | 1080h |  | PWDIMS-CT | PCG-37 | 29.292 | Axell, Jörgen | Rel-14 | TSG#72 |  |  |  |  |  |
| 208 | 78 | **Enhancements to Multi-stream Multiparty Conferencing Media Handling** | 272d? | 2016-03-02 A | 2017-03-15 | 50% | 134.82d? |  |  |  | 283d |  | S4; ct | 14624h | 6123.61h | MMCMH_Enh | PCG-37 | TS 26.114 | Nikolai Leung | Rel-14 | TSG#72 | nleung@qti.qualcomm.com |  |  |  |  |
| 209 | 78.1 | Overall aspects of MMCMH_Enh | 196d? | 2016-06-13 A | 2017-03-10 | 80% | 39.2d? |  |  |  | 286d | finish no earlier than 2017-03-10 | S4 | 1568h | 1254.4h | MMCMH_Enh | PCG-37 | TS 26.114, TR 26.980 | Nikolai Leung | Rel-14 | TSG#72 | nleung@qti.qualcomm.com |  |  |  |  |
| 210 | 78.2 | **CT aspects of MMCMH_Enh** | 272d? | 2016-03-02 A | 2017-03-15 | 43% | 154.13d? |  |  |  | 283d |  | ct | 8704h | 3771.74h | MMCMH_Enh-CT | PCG-37 |  | Ericsson, Nevenka Biondic | Rel-14 | TSG#72 | nevenka.biondic@ericsson.com |  |  |  |  |
| 211 | 78.2.1 | CT1 aspects of MMCMH_Enh | 272d? | 2016-03-02 A | 2017-03-15 | 95% | 13.6d? |  |  |  | 283d | finish no earlier than 2017-03-15 | C1 | 2176h | 2067.2h | MMCMH_Enh-CT | PCG-37 | 24.229 | Ericsson, Nevenka Biondic | Rel-14 | TSG#72 | nevenka.biondic@ericsson.com |  |  |  |  |
| 212 | 78.2.2 | CT3 aspects of MMCMH_Enh | 272d? | 2016-03-02 | 2017-03-15 |  |  |  |  |  | 283d | finish no earlier than 2017-03-15 | C3 | 2176h |  | MMCMH_Enh-CT | PCG-37 | 29.162, 29.213, 29.214, 29.165 | Ericsson, Nevenka Biondic | Rel-14 | TSG#72 | nevenka.biondic@ericsson.com |  |  |  |  |
| 213 | 78.2.3 | CT4 aspects of MMCMH_Enh | 272d? | 2016-03-02 A | 2017-03-15 | 35% | 176.8d? |  |  |  | 283d | finish no earlier than 2017-03-15 | C4 | 2176h | 761.6h | MMCMH_Enh-CT | PCG-37 | 23.333, 29.333, 23.334, 29.334, 29.238 | Ericsson, Nevenka Biondic | Rel-14 | TSG#72 | nevenka.biondic@ericsson.com |  |  |  |  |
| 214 | 79 | **Deleted - CT aspects of (or "Enhancements of") MTSI Extension on Multi-stream** | 143d? | 2016-03-02 A | 2016-09-15 A | 100% |  |  |  |  |  |  | ct | 4576h | 4576h | MMCMH-CT | PCG-36 |  | Ericsson, Nevenka Biondic | Rel-14 | TSG#71 | nevenka.biondic@ericsson.com | CP-72 |  |  |  |
| 215 | 79.1 | deleted -CT1 aspects of MTSI Extension on Multi-stream | 143d? | 2016-03-02 A | 2016-09-15 A | 100% |  |  |  |  |  | start no earlier than 2016-03-02 | C1 | 1144h | 1144h | MMCMH-CT | PCG-36 | 24.229 | Ericsson, Nevenka Biondic | Rel-14 | TSG#71 | nevenka.biondic@ericsson.com | CP-72 |  |  |  |
| 216 | 79.2 | deleted -CT3 aspects of MTSI Extension on Multi-stream | 143d? | 2016-03-02 A | 2016-09-15 A | 100% |  |  |  |  |  | start no earlier than 2016-03-02 | C3 | 1144h | 1144h | MMCMH-CT | PCG-36 | 29.162, 29.213, 29.214, 29.165 | Ericsson, Nevenka Biondic | Rel-14 | TSG#71 | nevenka.biondic@ericsson.com | CP-72 |  |  |  |
| 217 | 79.3 | deleted -CT4 aspects of MTSI Extension on Multi-stream | 143d? | 2016-03-02 A | 2016-09-15 A | 100% |  |  |  |  |  | start no earlier than 2016-03-02 | C4 | 1144h | 1144h | MMCMH-CT | PCG-36 | 23.333, 29.333, 23.334, 29.334, 29.238 | Ericsson, Nevenka Biondic | Rel-14 | TSG#71 | nevenka.biondic@ericsson.com | CP-72 |  |  |  |
| 218 | 80 | **IMS Signalling Activated Trace** | 531d? | 2014-03-05 A | 2016-03-11 | 28% | 380.74d? | 2014-03-05 | 2014-09-12 | 138d? | 547d |  | C1; C3; C4; IETF | 39048h | 8846.79h | ISAT | PCG-32 |  | Vodafone | Rel-14 | CP-63 | peter.dawes @vodafone.com |  | Frederic | ISAT |  |
| 219 | 80.1 | CT1 part of IMS Signalling Activated Trace | 528d? | 2014-03-10 | 2016-03-11 |  |  | 2014-03-05 | 2014-09-12 | 138d? | 547d | finish no earlier than 2016-03-11 | C1 | 4224h |  | ISAT | PCG-32 | 24.229, 24.323 | Vodafone | Rel-14 | CP-63 | peter.dawes @vodafone.com |  | Frederic |  | CP-140606 |
| 220 | 80.2 | (IETF) IMS Signalling Activated Trace (draft-dawes-sipping-debug) | 391d? | 2014-09-12 A | 2016-03-11 | 28% | 281.52d? |  |  |  | 547d | finish no earlier than 2016-03-11 | C1-IETF | 3128h | 875.84h | ISAT | PCG-33 | draft-dawes-sipping-debug | Vodafone | Rel-14 | CP-65 | peter.dawes @vodafone.com |  |  |  |  |
| 221 | 80.3 | (IETF) IMS Signalling Activated Trace (draft-dawes-sipping-debug) | 391d? | 2014-09-12 A | 2016-03-11 | 25% | 293.25d? |  |  |  | 547d | finish no earlier than 2016-03-11 | C3-IETF | 3128h | 782h | ISAT | PCG-33 | draft-dawes-sipping-debug | Vodafone | Rel-14 | CP-65 | peter.dawes @vodafone.com |  |  |  |  |
| 222 | 80.4 | (IETF) IMS Signalling Activated Trace (draft-dawes-sipping-debug) | 391d? | 2014-09-12 A | 2016-03-11 | 25% | 293.25d? |  |  |  | 547d | finish no earlier than 2016-03-11 | C4-IETF | 3128h | 782h | ISAT | PCG-33 | draft-dawes-sipping-debug | Vodafone | Rel-14 | CP-65 | peter.dawes @vodafone.com |  |  |  |  |
| 223 | 80.5 | CT3 part of IMS Signalling Activated Trace | 528d? | 2014-03-10 | 2016-03-11 |  |  | 2014-03-05 | 2014-06-13 | 73d? | 547d | finish no earlier than 2016-03-11 | C3 | 4224h |  | ISAT | PCG-32 | 29.165 | Vodafone | Rel-14 | CP-63 | peter.dawes @vodafone.com |  | Adrian |  | CP-140564 |
| 224 | 80.6 | CT4 part of IMS Signalling Activated Trace | 528d? | 2014-03-05 A | 2016-03-11 | 90% | 52.8d? | 2014-03-05 | 2014-09-12 | 138d? | 547d | finish no earlier than 2016-03-11 | C4 | 4224h | 3801.6h | ISAT | PCG-32 | 23.008, 29.228, 29.229, 29.328, 29.329 | Vodafone | Rel-14 | CP-63 | peter.dawes @vodafone.com |  | Kimmo |  | CP-140480 |
| 225 | 81 | **Control and User Plane Separation of EPC nodes** | 391d? | 2015-09-17 A | 2017-03-15 | 61% | 153.14d? |  |  |  | 283d |  | S2; ct | 9928h | 4347.15h | CUPS | PCG-35 | 23.714; 23.214 | Huawei, Mirko Schramm | Rel-14 | SP-69 | mirko.schramm@huawei.com |  |  |  |  |
| 226 | 81.1 | Study on Control and User Plane Separation of EPC nodes | 197d? | 2015-09-17 A | 2016-06-17 A | 100% |  |  |  |  |  | finish no earlier than 2016-06-17 | S2 | 1576h | 1576h | FS_CUPS | PCG-35 | 23.714 | Huawei, Mirko Schramm | Rel-14 | SP-69 | mirko.schramm@huawei.com |  |  |  |  |
| 227 | 81.2 | Control and User Plane Separation of EPC nodes | 72d? | 2016-06-09 A | 2016-09-15 A | 100% |  |  |  |  |  | finish no earlier than 2016-09-15 | S2 | 576h | 576h | CUPS | PCG-37 | 23.214, 23.002, 23.203, 23.401, 23.402 | Huawei, Mirko Schramm | Rel-14 | TSG#72 | mirko.schramm@huawei.com |  |  |  |  |

Notes:
- 203: 1/4/15: rapporteur added, Impacted TS added. 31/07/15: 100%
- 204: 1/4/15: rapporteur added, Impacted TS added. 31/07/15: 100%
- 206: 2/12/16: 0%->15
- 209: 19/9/16: WID:SP-160272->SP-160785; 19/9/16: 0%->50; 1/12/16: 50%->80; 1/12/16: FCD:12/16->03/17
- 210: To be checked at SA4 if a part can stay in Rel-13 (now Stages 1 and 2 by SA4 in UID660050), while the CT aspects are in Rel-14. 06/16: Name changed from "CT aspects of (or "Enhancements of") MTSI Extension on Multi-stream". Acronym changed from "MMCMH-...; 13/6/16: WID:CP-160250->CP-160369
- 211: Name changed from "CT1 aspects of MTSI Extension on Multi-stream". Acronym changed from "MMCMH-CT"; 13/6/16: WID:CP-160117->CP-160250. FCD: 09/16->03/17; 13/6/16: WID:CP-160250->CP-160369; 2/12/16: 0%->95
- 212: Acronym changed from "MMCMH-CT"; 13/6/16: WID:CP-160117->CP-160250. FCD: 09/16->03/17; 13/6/16: WID:CP-160250->CP-160369
- 213: 3/6/16: WID:CP-160117->CP-160250. FCD: 09/16->03/17; 13/6/16: WID:CP-160250->CP-160369; 2/12/16: 0%->35
- 214: Deleted, "replaced" by MMCMH_Enh-CT
- 215: Deleted, "replaced" by MMCMH_Enh-CT
- 216: Deleted, "replaced" by MMCMH_Enh-CT
- 217: Deleted, "replaced" by MMCMH_Enh-CT
- 218: Mar 15: WID: CP-140195->CP-150091. ES in CP-150637. 8/3/16: Moved from Rel-13 at CT#71
- 219: CP66: moved to Rel-13. Mar 15: WID: CP-140195->CP-150091. ES in CP-150728
- 220: CP66: moved to Rel-13. Mar 15: WID: CP-140195->CP-150091. ES in CP-150637; 13/6/16: 25%->28
- 221: CP66: moved to Rel-13. Mar 15: WID: CP-140195->CP-150091. ES in CP-150637
- 222: CP66: moved to Rel-13. Mar 15: WID: CP-140195->CP-150091. ES in CP-150637
- 223: CP66: moved to Rel-13. Mar 15: WID: CP-140195->CP-150091. ES in CP-150637
- 224: CP66: moved to Rel-13. Mar.15: 90%. ES in CP-150615. 7/3/16: Rel-13->Rel-14
- 225: 7/12/15: 0%->20; 7/3/16: 20%->40; 9/6/16: 40%->100; 28/7/16: 23.214 added;
- 226: 7/12/15: 0%->20; 7/3/16: 20%->40; 9/6/16: 40%->100
- 227: 19/9/16: 0%->80; 1/12/16: 80%->100

| ID | WBS | Task | Duration | Start | Finish | Complete | Remaining | Total slack | Constraint | Resources | Work | Actual work | Acronym | PCG approved | WI rapporteur e-mail | Release | TSG approved |
| --- | --- | --- | --- | --- | --- | --- | --- | --- | --- | --- | --- | --- | --- | --- | --- | --- | --- |
| 228 | 81.3 | **CT aspects for CUPS** | 129d? | 2016-09-16 A | 2017-03-15 | 20% | 103.21d? | 283d |  | ct | 3096h | 619.15h | CUPS-CT | PCG-37 | peter.schmitt@huawei.com | Rel-14 | TSG-73 |
| 229 | 81.3.1 | CT3 aspects for CUPS | 129d? | 2016-09-16 | 2017-03-15 |  |  | 283d | finish no earlier than 2017-03-15 | C3 | 1032h |  | CUPS-CT | PCG-37 | peter.schmitt@huawei.com | Rel-14 | TSG-73 |
| 230 | 81.3.2 | CT4 aspects for CUPS | 129d? | 2016-09-16 A | 2017-03-15 | 40% | 77.4d? | 283d | finish no earlier than 2017-03-15 | C4 | 1032h | 412.8h | CUPS-CT | PCG-37 | peter.schmitt@huawei.com | Rel-14 | TSG-73 |
| 231 | 82 | **OAM14 Rel-14 Operations, Administration, Maintenance and Provisioning (OAM&P)** | 589d? | 2015-03-12 A | 2017-06-12 | 72% | 162.54d? | 220d |  | S5 | 29433.6h | 15805.2h | OAM14 | PCG-35 |  | Rel-14 | SP-68 |
| 232 | 82.1 | **Management of mobile networks that include virtualized network functions** | 456d? | 2015-06-15 A | 2017-03-12 | 72% | 127.28d? | 286d |  | S5 | 19256h | 11568h | OAM14-MAMO_VNF | PCG-35 | liujinglei@chinamobile.com | Rel-14 | SP-68 |
| 233 | 82.1.1 | Management concept, architecture and requirements for mobile networks that include virtualized network functions | 395d? | 2015-06-15 A | 2016-12-15 A | 100% |  |  | finish no earlier than 2016-12-15 | S5 | 3160h | 3160h | OAM14-MAMO_VNF-MCAR | PCG-35 | liujinglei@chinamobile.com | Rel-14 | SP-68 |
| 234 | 82.1.2 | Configuration Management for mobile networks that include virtualized network functions | 389d? | 2015-09-16 A | 2017-03-12 | 60% | 155.6d? | 286d | finish no earlier than 2017-03-12 | S5 | 3112h | 1867.2h | OAM14-MAMO_VNF-CM | PCG-35 | zhu.weihong@zte.com.cn | Rel-14 | SP-69 |
| 235 | 82.1.3 | Fault Management for mobile networks that include virtualized network functions | 389d? | 2015-09-16 A | 2017-03-12 | 80% | 77.8d? | 286d | finish no earlier than 2017-03-12 | S5 | 3112h | 2489.6h | OAM14-MAMO_VNF-FM | PCG-35 | kai.zhangkai@huawei.com | Rel-14 | SP-69 |
| 236 | 82.1.4 | Performance management for mobile networks that include virtualized network functions | 389d? | 2015-09-16 A | 2017-03-12 | 60% | 155.6d? | 286d | finish no earlier than 2017-03-12 | S5 | 3112h | 1867.2h | OAM14-MAMO_VNF-PM | PCG-35 | joey.chou@intel.com | Rel-14 | SP-69 |
| 237 | 82.1.5 | Lifecycle management for mobile networks that include virtualized network functions | 389d? | 2015-09-16 A | 2017-03-12 | 60% | 155.6d? | 286d | finish no earlier than 2017-03-12 | S5 | 3112h | 1867.2h | OAM14-MAMO_VNF-LCM | PCG-35 | anatoly.andrianov@nokia.com | Rel-14 | SP-69 |
| 238 | 82.2 | Filtering of PM measurements and data volume | 199d? | 2016-03-01 A | 2016-12-01 | 95% | 9.95d? | 357d | start no earlier than 2016-03-01 | S5 | 1592h | 1512.4h | OAM14-FILMEAS | PCG-36 | robert.petersen@ericsson.com | Rel-14 | TSG#71 |
| 239 | 82.3 | Study on OAM support for Licensed Shared Access (LSA) | 262d? | 2015-03-12 A | 2016-03-11 A | 100% |  |  | finish no earlier than 2016-03-11 | S5 | 2096h | 2096h | FS_OAM_LSA | PCG-34 | anatoly<dot>andrianov<at>nokia<dot>com | Rel-14 | SP-67 |
| 240 | 82.4 | OAM support for Licensed Shared Access (LSA) | 262d? | 2016-06-13 A | 2017-06-12 | 30% | 183.4d? | 220d | start no earlier than 2016-06-13 | S5 | 2096h | 628.8h | OAM14-LSA | PCG-37 |  | Rel-14 | TSG#72 |
| 241 | 83 | Development of super-wideband and fullband P.835 | 524d? | 2015-06-16 A | 2017-06-15 | 75% | 131d? | 217d | finish no earlier than 2017-06-15 | S4 | 4192h | 3144h | DESUDAPS | PCG-35 | sisabelle@audience.com | Rel-14 | SP-68 |
| 242 | 84 | Enhancing Location Capabilities for Indoor and Outdoor Emergency Communications | 200d? | 2015-03-11 A | 2015-12-15 A | 100% |  |  | finish no earlier than 2015-12-15 | S1 | 1600h | 1600h | ELIOT | PCG-34 | Gregory.schumacher@sprint.com | Rel-14 | SP-67 |
| 243 | 85 | Enhancements to Domain Selection between VoLTE and CDMA CS | 69d? | 2015-03-11 A | 2015-06-15 A | 100% |  |  | finish no earlier than 2015-06-15 | S1 | 552h | 552h | eDSVCC | PCG-34 | zhuhongmei@gsta.com | Rel-14 | SP-67 |
| 244 | 86 | Control of Applications when Third party Servers encounter difficulties | 93d? | 2015-05-11 A | 2015-09-16 A | 100% |  |  | finish no earlier than 2015-09-16 | S1 | 744h | 744h | CATS | PCG-35 | er-yoshida (at) kddi (dot) com | Rel-14 | SP-68 |
| 245 | 87 | **PS Data Off Services** | 353d? | 2015-11-09 A | 2017-03-14 | 45% | 192.9d? | 284d |  | S1; S2 | 9304h | 2688h | PS_Data_Off | PCG-36 | bruno.tossou@orange.com | Rel-14 | SP-70 |
| 246 | 87.1 | PS Data Off Services | 92d? | 2015-11-09 A | 2016-03-15 A | 100% |  |  | finish no earlier than 2016-03-15 | S1 | 736h | 736h | PS_Data_Off | PCG-36 | bruno.tossou@orange.com | Rel-14 | SP-70 |
| 247 | 87.2 | Study on Stage 2 of PS Data off function | 131d? | 2016-06-17 A | 2016-12-15 A | 100% |  |  | finish no earlier than 2016-12-15 | S2 | 1048h | 1048h | FS_PS_DATA_OFF | PCG-37 | david <dot> cailliere <at> orange <dot> com | Rel-14 | SP-72 |
| 248 | 87.3 | Stage 2 of PS Data Off | 21d? | 2016-11-17 A | 2016-12-15 A | 100% |  |  | finish no earlier than 2016-12-15 | S2 | 168h | 168h | PS_DATA_OFF |  | kris (dot) petit (at) orange (dot) com | Rel-14 |  |
| 249 | 87.4 | **Stage 3 of PS Data Off** | 74d? | 2016-12-01 | 2017-03-14 |  |  | 284d |  | ct | 2368h |  | PS_DATA_OFF-CT |  | Christian.Herrero at huawei.com | Rel-14 |  |
| 250 | 87.4.1 | CT1 aspects of PS Data Off | 74d? | 2016-12-01 | 2017-03-14 |  |  | 284d | finish no earlier than 2017-03-14 | C1 | 592h |  | PS_DATA_OFF-CT |  | Christian.Herrero at huawei.com | Rel-14 |  |
| 251 | 87.4.2 | CT3 aspects of PS Data Off | 74d? | 2016-12-01 | 2017-03-14 |  |  | 284d | finish no earlier than 2017-03-14 | C3 | 592h |  | PS_DATA_OFF-CT |  | Christian.Herrero at huawei.com | Rel-14 |  |
| 252 | 87.4.3 | CT6 aspects of PS Data Off | 74d? | 2016-12-01 | 2017-03-14 |  |  | 284d | finish no earlier than 2017-03-14 | C6 | 592h |  | PS_DATA_OFF-CT |  | Christian.Herrero at huawei.com | Rel-14 |  |
| 253 | 87.5 | Charging Aspect for 3GPP PS Data off Function | 72d? | 2016-12-01 | 2017-03-10 |  |  | 286d | finish no earlier than 2017-03-10 | S5 | 576h |  | PS_DATA_OFF-CH |  | chenshan@huawei.com | Rel-14 |  |
| 254 | 88 | SCC AS Restoration | 208d? | 2016-03-02 A | 2016-12-15 A | 100% |  |  | finish no earlier than 2016-12-15 | C4 | 1664h | 1664h | SCCAS_RES | PCG-36 | zhanghao@chinamobile.com | Rel-14 | TSG#71 |
| 255 | 89 | Paging Policy Enhancements and Procedure | 22d? | 2016-02-01 A | 2016-03-01 A | 100% |  |  | finish no earlier than 2016-03-01 | S1 | 176h | 176h | PPEPO_LTE | PCG-36 | zhangzy910@chinaunicom.cn | Rel-14 | TSG#71 |

Notes:
- 228: WI rapporteur name: Huawei, Peter Schmitt
- 229: Impacted TSs and TRs: 29.212, 29.213 / WI rapporteur name: Huawei, Peter Schmitt
- 230: 2/12/16: 0%->40 / Impacted TSs and TRs: 23.007, 29.274, 29.281, 29.303, 23.008 / WI rapporteur name: Huawei, Peter Schmitt
- 232: June2015: WID:SP-150308->SP-150362 / WI rapporteur name: Jinglei Liu, China Mobile
- 233: June2015: WID:SP-150309->SP-150363. Aug2015: FCD: Mar 2016; 07/09/15: 0%->20. 15/09/15: FCD: Mar 16->Dec 16, moved to Rel-14; 7/12/15: 20%->40; 7/3/16: 40%->50; 7/3/16: WID:SP-150363->SP-160023 ( FCD: Dec16->Sep16); 13/6/16: 50%->70; 19/9/16: FCD:09/16...; 1/12/16: 90%->100 / Impacted TSs and TRs: 28.xyz, 32.101 / WI rapporteur name: Jinglei Liu, China Mobile (liujinglei@chinamobile.com)
- 234: 5/10/15: 28.513; 28.512; 28.511; 28.510 added; 7/12/15: 0%->15; 7/3/16: 15%->20; 13/6/16: 20%->30; 19/9/16: 30%->50; 1/12/16: 50%->60; 1/12/16: FCD:12/16->03/17 / Impacted TSs and TRs: 28.513; 28.512; 28.511; 28.510; 28.621, 28.622, 28.623, 28.704, 28.707 / WI rapporteur name: ZTE Corporation (Zhu Weihong, zhu.weihong@zte.com.cn)
- 235: 5/10/15: 28.518; 28.517; 28.516; 28.515 added; 7/12/15: 0%->10; 7/3/16: 10%->15; 13/6/16: 15%->50; 13/6/16: WID:SP-150404->SP-160403; 19/9/16: 50%->75; 1/12/16: 75%->80; 1/12/16: 80%->; 1/12/16: FCD:12/16->03/17 / Impacted TSs and TRs: 28.515, 28.516, 28.517, 28.518, 32.111-1, 32.111-2, 32.111-6 / WI rapporteur name: Huawei (Kai ZHANG, kai.zhangkai@huawei.com)
- 236: 5/10/15: 28.523; 28.522; 28.521; 28.520 added; 7/12/15: 0%->10; 7/3/16: 10%->15; 13/6/16: 15%->30; 13/6/16: WID:SP-150401->SP-160402; 19/9/16: 30%->60; 1/12/16: FCD:12/16->03/17 / Impacted TSs and TRs: 28.523; 28.522; 28.521; 28.520; 32.426, 32.409, 32.401 / WI rapporteur name: Intel (Joey Chou, joey.chou@intel.com)
- 237: 5/10/15: 28.528; 28.527; 28.526; 28.525 added; 7/12/15: 0%->10; 7/3/16: 10%->15; 13/6/16: 15%->25; 13/6/16: WID:SP-150403->SP-160427; 19/9/16: 25%->40; 1/12/16: 40%->60; 1/12/16: FCD:12/16->03/17 / Impacted TSs and TRs: 28.525, 28.526, 28.527, 28.528, 28.704, 28.705, 28.706, 28.707, 28.708, 28.709 / WI rapporteur name: Anatoly Andrianov (anatoly.andrianov@nokia.com), Nokia Networks
- 238: 13/6/16: 0%->15; 19/9/16: WID:SP-160022->SP-160610; 19/9/16: 15%->60; 1/12/16: 60%->95 / Impacted TSs and TRs: New 32.817, 32.425, 32.412, 32.416, 32.130 / WI rapporteur name: Ericsson: Robert Petersen
- 239: June2015: Compl:0%->15; 07/09/15: 15%->70; 7/12/15: 70%->75; 7/3/16: 75%->100. 22/3/16: FCD: 09/15->03/16. Rel-13->Rel-14; 28/7/16: 28.303 added;; 28/7/16: 28.302 added;; 28/7/16: 28.301 added;; 28/7/16: 33.250 added;; 28/7/16: added; / Impacted TSs and TRs: 28.303; 28.302; 28.301; / WI rapporteur name: Nokia Networks, Anatoly Andrianov
- 240: 28/7/16: 28.303 added;; 28/7/16: 28.302 added;; 28/7/16: 28.301 added;; 19/9/16: 0%->20; 1/12/16: 20%->30 / Impacted TSs and TRs: 32.101; 28.303; 28.302; 28.301 / WI rapporteur name: Nokia: Olaf Pollakowski
- 241: 06/15: FCD corrected to Dec.15; Aug2015: 0%->5; 07/09/15: 5%->20, FCD: 12/15->06.16; 7/12/15: 20%->40, MOVED TO REL-14; 7/3/16: 40%->50. 15/4/16: 6/16->12/16; 11/6/16: 50%->60; 19/9/16: 60%->70, fcd: 12/16->06/17; 1/12/16: 70%->75 / Impacted TSs and TRs: 26.131, 26.132 / WI rapporteur name: Scott Isabelle (Knowles, Inc.)
- 242: 1/4/15: rapporteur added, Impacted TS added; June2015: Compl:0%->25; 07/09/15: 25%->80; 2/3/16: 80%->100 / Impacted TSs and TRs: 22.101, 22.071 / WI rapporteur name: Greg Schumacher
- 243: 1/4/15: rapporteur added, Impacted TS added; June2015: Compl:0%->100 / Impacted TSs and TRs: 22.101 / WI rapporteur name: China Telecom, Hongmei Zhu
- 244: 07/09/15: 0%->100 / Impacted TSs and TRs: 22.011 / WI rapporteur name: Eriko Yoshida, KDDI
- 245: 2/3/16: 0%->100 / Impacted TSs and TRs: 22.030 / WI rapporteur name: Orange, Bruno Tossou
- 246: 2/3/16: 0%->100 / Impacted TSs and TRs: 22.030 / WI rapporteur name: Orange, Bruno Tossou
- 247: 28/7/16: 23.702 added;; 19/9/16: 0%->60; 1/12/16: FCD:09/16->12/16; 1/12/16: 60%->100 / Impacted TSs and TRs: TR 23.702 / WI rapporteur name: Orange, david <dot> cailliere <at> orange <dot> com
- 248: 1/12/16: 0%->100 / Impacted TSs and TRs: 23.401, 23.203, 23.060, 23.228, 23.292, 23.221 / WI rapporteur name: Christophe Petit (Orange)
- 249: WI rapporteur name: Herrero Veron, Christian (Huawei)
- 250: Impacted TSs and TRs: 24.008, 24.301, 27.007, 24.229, 24.368, 24.167 / WI rapporteur name: Herrero Veron, Christian (Huawei)
- 251: Impacted TSs and TRs: 29.212, 29.213 / WI rapporteur name: Herrero Veron, Christian (Huawei)
- 252: Impacted TSs and TRs: 31.102, 31.103, 31.111 / WI rapporteur name: Herrero Veron, Christian (Huawei)
- 253: Impacted TSs and TRs: TS 32.251, TS 32.298, TS 32.299 / WI rapporteur name: Huawei， Chen, Shan
- 254: 13/6/16: 0%->100 / Impacted TSs and TRs: 23.380 / WI rapporteur name: China Mobile, Hao Zhang,
- 255: Impacted TSs and TRs: 22.101 / WI rapporteur name: China Unicom, Zhuoyun Zhang

| ID | WBS | Task | Duration | Start | Finish | Complete | Remaining | Total slack | Constraint | Resources | Work | Actual work | Acronym | PCG approved | WI rapporteur name | WI rapporteur e-mail | Release | TSG approved |
| --- | --- | --- | --- | --- | --- | --- | --- | --- | --- | --- | --- | --- | --- | --- | --- | --- | --- | --- |
| 256 | 90 | **Enhancement to Flexible Mobile Service Steering** | 355d? | 2015-05-11 A | 2016-09-15 | 99% | 0d? | 0d |  | S1; S2 | 4608h | 2124.83h | eFMSS | PCG-37 | China Mobile, Lu Lu | lulu@chinamobile.com | Rel-14 | SP-72 |
| 257 | 90.1 | Study on enhancement to FMSS for Rel 14 | 158d? | 2015-05-11 A | 2015-12-16 A | 100% |  |  | finish no earlier than 2015-12-16 | S1 | 1264h | 1264h | FS_eFMSS | PCG-35 | Lu Lu, China Mobile | lulu@chinamobile.com | Rel-14 | SP-68 |
| 258 | 90.2 | Stage 1 of Enhancement to Flexible Mobile Service Steering | 22d? | 2016-02-01 A | 2016-03-01 A | 100% |  |  | start no earlier than 2016-02-01 | S1 | 176h | 176h | eFMSS | PCG-36 | China Mobile, Lu Lu | lulu@chinamobile.com | Rel-14 | TSG#71 |
| 259 | 90.3 | Stage 2 of Enhancement to Flexible Mobile Service Steering | 66d? | 2016-06-17 A | 2016-09-15 A | 100% |  |  | finish no earlier than 2016-09-15 | S2 | 528h | 528h | eFMSS | PCG-37 | ZTE, Tricci So |  | Rel-14 | SP-72 |
| 260 | 91 | Unlicensed Spectrum Offloading System | 22d? | 2016-02-01 A | 2016-03-01 A | 100% |  |  | start no earlier than 2016-02-01 | S1 | 176h | 176h | USOS | PCG-36 | Edward Hall, Qualcomm Incorporated | edhall@qti.qualcomm.com | Rel-14 | TSG#71 |
| 261 | 92 | **Media Handling Extensions of IMS-based Telepresence** | 199d? | 2016-03-01 A | 2016-12-01 | 50% | 99.5d? | 357d |  | S4 | 4776h | 1751.2h | IMS_TELEP_EXT | PCG-36 | Ozgur Oyman, Intel | ozgur.oyman@intel.com | Rel-14 | TSG#71 |
| 262 | 92.1 | S4 aspects of Media Handling Extensions of IMS-based Telepresence | 199d? | 2016-03-01 A | 2016-12-01 A | 100% |  |  | finish no earlier than 2016-12-01 | S4 | 1592h | 1592h | IMS_TELEP_EXT | PCG-37 | Ozgur Oyman, Intel | ozgur.oyman@intel.com | Rel-14 | TSG#72 |
| 263 | 92.2 | (IETF) Other IETF aspects of IMS_TELEP_EXT | 199d? | 2016-03-01 | 2016-12-01 |  |  | 357d | finish no earlier than 2016-12-01 | S4-IETF | 1592h |  | IMS_TELEP_EXT | PCG-37 |  | ozgur.oyman@intel.com | Rel-14 | TSG#72 |
| 264 | 93 | Improved Streaming QoE Reporting in 3GPP | 273d? | 2016-03-01 A | 2017-03-15 | 65% | 95.55d? | 283d | finish no earlier than 2017-03-15 | S4 | 2184h | 1419.6h | IQoE | PCG-36 | Zhiming Li, Huawei | Lizhiming@huawei.com | Rel-14 | TSG#71 |
| 265 | 94 | New GPRS algorithms for EASE | 67d? | 2016-03-15 A | 2016-06-15 | 70% | 20.1d? | 479d | start no earlier than 2016-03-15 | S3 | 536h | 375.2h | EASE_ALGOs_SA3 | PCG-36 | Tim Evans, Vodafone |  | Rel-14 | TSG#71 |
| 266 | 95 | **S8 Home Routing Architecture for VoLTE** | 456d? | 2015-06-18 A | 2017-03-15 | 83% | 79.49d? | 283d |  | S2; S3; ct | 14307.2h | 8232.28h | V8 | PCG-36 |  |  | Rel-14 | TSG#71 |
| 267 | 95.1 | Study on S8 Home Routing Architecture | 191d? | 2015-06-18 A | 2016-03-10 A | 100% |  |  | finish no earlier than 2016-03-10 | S2 | 1528h | 1528h | FS_V8 | PCG-35 | Motohiro ABE | motohiro(dot)abe(dot)cu(at) nttdocomo (dot) com | Rel-14 | SP-68 |
| 268 | 95.2 | Study on LI in S8 Home Routing Architecture for VoLTE | 197d? | 2015-09-17 A | 2016-06-17 | 65% | 68.95d? | 477d | finish no earlier than 2016-06-17 | S3 | 1576h | 1024.4h | FS_LIV8 | PCG-35 | Greg Schumacher (SPRINT) Gregory | Schumacher@sprint.com | Rel-14 | SP-69 |
| 269 | 95.3 | S8 Home Routing Architecture for VoLTE | 135d? | 2016-06-13 A | 2016-12-15 A | 100% |  |  | finish no earlier than 2016-12-15 | S2 | 1080h | 1080h | V8 | PCG-37 | Motohiro ABE | motohiro(dot)abe(dot)cu(at) nttdocomo (dot) com | Rel-14 | TSG#72 |
| 270 | 95.4 | **CT Aspects of V8** | 65d? | 2016-09-16 A | 2016-12-15 A | 100% |  |  |  | ct | 1560h | 1560h | V8-CT | PCG-37 | Tsuyoshi Takakura (NTT DOCOMO) | tsuyoshi.takakura.ey@s1.nttdocomo.com | Rel-14 | TSG-73 |
| 271 | 95.4.1 | CT1 Aspects of V8 | 65d? | 2016-09-16 A | 2016-12-15 A | 100% |  |  | finish no earlier than 2016-12-15 | C1 | 520h | 520h | V8-CT | PCG-37 | Tsuyoshi Takakura (NTT DOCOMO) | tsuyoshi.takakura.ey@s1.nttdocomo.com | Rel-14 | TSG-73 |
| 272 | 95.4.2 | CT3 Aspects of V8 | 65d? | 2016-09-16 A | 2016-12-15 A | 100% |  |  | finish no earlier than 2016-12-15 | C3 | 520h | 520h | V8-CT | PCG-37 | Tsuyoshi Takakura (NTT DOCOMO) | tsuyoshi.takakura.ey@s1.nttdocomo.com | Rel-14 | TSG-73 |
| 273 | 95.5 | Charging Aspects of S8 Home Routing Architecture for VoLTE | 199d? | 2016-06-13 A | 2017-03-15 | 60% | 79.6d? | 283d | finish no earlier than 2017-03-15 | S5 | 1592h | 955.2h | CH14-V8 | PCG-37 | Chen, Ai (China Mobile) | chenai(at) chinamobile (dot) com | Rel-14 | TSG#72 |
| 274 | 96 | **Improvements of awareness of user location change** | 391d? | 2015-09-17 A | 2017-03-15 | 74% | 102.21d? | 283d |  | S2; ct | 9440h | 4941.59h | AULC | PCG-37 | Yang Xu | xuyang49@chinaunicom.cn | Rel-14 | TSG#72 |
| 275 | 96.1 | Study on improvement of awareness of user location change | 197d? | 2015-09-17 A | 2016-06-17 A | 100% |  |  | finish no earlier than 2016-06-17 | S2 | 1576h | 1576h | FS_AULC | PCG-35 | Yang Xu | xuyang49@chinaunicom.cn | Rel-14 | SP-69 |
| 276 | 96.2 | Improvements of awareness of user location change | 75d? | 2016-06-06 A | 2016-09-15 A | 100% |  |  | finish no earlier than 2016-09-15 | S2 | 600h | 600h | AULC | PCG-37 | Yang Xu | xuyang49@chinaunicom.cn | Rel-14 | TSG#72 |
| 277 | 96.3 | **CT Aspect of AULC** | 65d? | 2016-09-16 A | 2016-12-15 | 53% | 30.88d? | 347d |  | ct | 1560h | 819h | AULC-CT | PCG-37 | Huawei, Wu Yizhuang | wuyizhuang@huawei.com | Rel-14 | TSG-73 |
| 278 | 96.3.1 | CT3 Aspect of AULC | 65d? | 2016-09-16 A | 2016-12-15 | 10% | 58.5d? | 347d | finish no earlier than 2016-12-15 | C3 | 520h | 52h | AULC-CT | PCG-37 | Huawei, Wu Yizhuang | wuyizhuang@huawei.com | Rel-14 | TSG-73 |
| 279 | 96.3.2 | CT4 Aspect of AULC | 65d? | 2016-09-16 A | 2016-12-15 | 95% | 3.25d? | 347d | finish no earlier than 2016-12-15 | C4 | 520h | 494h | AULC-CT | PCG-37 | Huawei, Wu Yizhuang | wuyizhuang@huawei.com | Rel-14 | TSG-73 |
| 280 | 96.4 | Charging Aspects of Improvements of AULC | 128d? | 2016-09-19 A | 2017-03-15 | 40% | 76.8d? | 283d | finish no earlier than 2017-03-15 | S5 | 1024h | 409.6h | AULC-CH | PCG-37 | Huawei， Chen, Shan | chenshan@huawei.com | Rel-14 | TSG-73 |

Notes:
- 256: Impacted TSs and TRs: 22.115, 22.101
- 257: 7/12/15: 70%->100 / Impacted TSs and TRs: 22.808
- 258: Impacted TSs and TRs: 22.115, 22.101
- 259: 19/9/16: 0%->100 / Impacted TSs and TRs: 23.203
- 260: Impacted TSs and TRs: 22.101, 22.115
- 261: 11/6/16: 0%->10 / Impacted TSs and TRs: 26.223
- 262: 11/6/16: 0%->10; 19/9/16: 10%->60; 1/12/16: 60%->100 / Impacted TSs and TRs: 26.223
- 263: Impacted TSs and TRs: draft-ietf-payload-rtp-h265, -flexible-fec-scheme , draft-ietf-clue-framework , -datachannel, -signalling, -data-model-schema, -protocol, -rtp-mapping, draft-ietf-mmusic-sctp-sdp, -data-channel-sdpneg, draft-ietf-tsvwg-sctp-dtls-encaps
- 264: 11/6/16: 0%->10; 19/9/16: 10%->55. FDC: 12/16->03/17; 1/12/16: 55%->65 / Impacted TSs and TRs: New 26.909, 26.247, 26.346
- 265: Discussion whether it should be Rel-13. To be concluded at SA#72.; 13/6/16: 0%->60; 1/12/16: 60%->70 / Impacted TSs and TRs: 55.241, 55.242, 55.243, 55.251, 55.252, 55.253
- 266: Umbrella, created by MCC to group SA2 and SA3 activities
- 267: 07/09/15: 0%->10; 07/09/15: 10%->100; 7/12/15: 100%->10% (mistake?) then 10%->70, FCD: 12/15-?03/16; 7/3/16: 70%->80; 9/6/16: 80%->100 / Impacted TSs and TRs: New TR 23.xxx
- 268: 7/12/15: 0%->45; 28/1/16: 33.827 added;; 7/3/16: 45%->55; 19/9/16: 55%->65 / Impacted TSs and TRs: TR 33.827
- 269: 11/6/16: 0%->60; 19/9/16: 60%->95; 1/12/16: FCD:09/16->12/16; 1/12/16: 95%->100 / Impacted TSs and TRs: TS 23.228, TS 23.167, TS 23.203
- 271: 2/12/16: 40%->100 / Impacted TSs and TRs: 24.229
- 272: 2/12/16: 40%->100 / Impacted TSs and TRs: 29.212, 29.213, 29.214
- 273: 19/9/16: 0%->15; 1/12/16: FCD:12/16->03/17; 1/12/16: 15%->60; 1/12/16: WID:SP-160429->SP-160838 / Impacted TSs and TRs: 32.240, 32.251, 32.260
- 275: 7/12/15: 0%->40; 7/3/16: 40%->70; 9/6/16: 70%->100 / Impacted TSs and TRs: 23.710
- 276: 11/6/16: 0%->10; 19/9/16: 10%->100 / Impacted TSs and TRs: 23.401, 23.203, 23.060
- 278: 2/12/16: 0%->10 / Impacted TSs and TRs: 29.212, 29.213
- 279: 2/12/16: 0%->95 / Impacted TSs and TRs: 29.274
- 280: 1/12/16: 0%->40 / Impacted TSs and TRs: TS32.251, TS32.298, TS32.299

| ID | WBS | Task | Duration | Start | Finish | Complete | Remaining | Total slack | Constraint | Resources | Work | Actual work | Acronym | PCG approved | WI rapporteur name | WI rapporteur e-mail | Release | TSG approved |
| --- | --- | --- | --- | --- | --- | --- | --- | --- | --- | --- | --- | --- | --- | --- | --- | --- | --- | --- |
| 281 | 97 | **Service Domain Centralization** | 232d? | 2015-11-02 A | 2016-09-19 | 99% | 0d? | 0d |  | S2 | 3896h | 2488h | SeDoC | PCG-37 | Chris Joul (T-Mobile USA) | chris (dot) joul (at) t (dash) mobile (dot) com | Rel-14 | TSG#72 |
| 282 | 97.1 | Study on Service Domain Centralization | 230d? | 2015-11-02 A | 2016-09-15 A | 100% |  |  | finish no earlier than 2016-09-15 | S2 | 1840h | 1840h | FS_SeDoC | PCG-36 | Chris Joul (T-Mobile USA) | chris (dot) joul (at) t (dash) mobile (dot) com | Rel-14 | SP-70 |
| 283 | 97.2 | Service Domain Centralization | 25d? | 2016-08-16 A | 2016-09-19 A | 100% |  |  | finish no earlier than 2016-09-19 | S2 | 200h | 200h | SeDoC | PCG-37 | Chris Joul (T-Mobile USA) | chris (dot) joul (at) t (dash) mobile (dot) com | Rel-14 | TSG-73 |
| 284 | 98 | **Sponsored data connectivity improvements** | 295d? | 2015-11-02 A | 2016-12-15 | 85% | 45.5d? | 347d |  | S2; ct | 6320h | 2792h | SDCI | PCG-37 | Yang Xu | xuyang49@chinaunicom.cn | Rel-14 | TSG#72 |
| 285 | 98.1 | Study on sponsored data connectivity improvements | 160d? | 2015-11-02 A | 2016-06-10 A | 100% |  |  | finish no earlier than 2016-06-10 | S2 | 1280h | 1280h | FS_SDCI | PCG-36 | Yang Xu | xuyang49@chinaunicom.cn | Rel-14 | SP-70 |
| 286 | 98.2 | Sponsored data connectivity improvements | 70d? | 2016-06-13 A | 2016-09-15 A | 100% |  |  | finish no earlier than 2016-09-15 | S2 | 560h | 560h | SDCI | PCG-37 | Yang Xu | xuyang49@chinaunicom.cn | Rel-14 | TSG#72 |
| 287 | 98.3 | **CT Aspects of SDCI** | 65d? | 2016-09-16 A | 2016-12-15 | 30% | 45.5d? | 347d |  | ct | 1040h | 312h | SDCI-CT | PCG-37 | China Unicom, Xu, Yang | xuyang49@chinaunicom.cn | Rel-14 | TSG-73 |
| 288 | 98.3.1 | CT3 Aspects of SDCI | 65d? | 2016-09-16 A | 2016-12-15 | 30% | 45.5d? | 347d | finish no earlier than 2016-12-15 | C3 | 520h | 156h | SDCI-CT | PCG-37 | China Unicom, Xu, Yang | xuyang49@chinaunicom.cn | Rel-14 | TSG-73 |
| 289 | 99 | **Stage-3 SAE Protocol Development - Phase 5** | 272d? | 2016-03-02 A | 2017-03-15 | 80% | 54.39d? | 283d |  | C1 | 8704h | 6963.26h | SAES5 | PCG-36 | Interdigital, Aghili, Behrouz | Behrouz.aghili@interdigital.com | Rel-14 | TSG#71 |
| 290 | 99.1 | SAES5 CS Fallback in EPS | 272d? | 2016-03-02 A | 2017-03-15 | 70% | 81.6d? | 283d | start no earlier than 2016-03-02 | C1 | 2176h | 1523.2h | SAES5-CSFB | PCG-36 | Interdigital, Aghili, Behrouz | Behrouz.aghili@interdigital.com | Rel-14 | TSG#71 |
| 291 | 99.2 | SAES5 for support for non-3GPP accesses | 272d? | 2016-03-02 A | 2017-03-15 | 85% | 40.8d? | 283d | start no earlier than 2016-03-02 | C1 | 2176h | 1849.6h | SAES5-non3GPP | PCG-36 | Interdigital, Aghili, Behrouz | Behrouz.aghili@interdigital.com | Rel-14 | TSG#71 |
| 292 | 99.3 | SAE Protocol Development (Stage 3) - Phase 5 | 272d? | 2016-03-02 A | 2017-03-15 | 85% | 40.8d? | 283d | start no earlier than 2016-03-02 | C1 | 2176h | 1849.6h | SAES5 | PCG-37 |  |  | Rel-14 | CT-72 |
| 293 | 100 | **Group based enhancements in the network capability exposure functions** | 296d? | 2015-11-02 A | 2016-12-16 A | 100% |  |  |  | S2 | 4752h | 4752h | GENCEF | PCG-36 | Samsung, Sung Hwan Won | sunghwan.won@samsung.com | Rel-14 | SP-70 |
| 294 | 100.1 | Study on group based enhancements in the network capability exposure functions | 160d? | 2015-11-02 A | 2016-06-10 A | 100% |  |  | start no earlier than 2015-11-02 | S2 | 1280h | 1280h | FS_GENCEF | PCG-36 | Samsung, Sung Hwan Won | sunghwan.won@samsung.com | Rel-14 | SP-70 |
| 295 | 100.2 | Group based enhancements in the network capability exposure functions | 138d? | 2016-06-09 A | 2016-12-16 A | 100% |  |  | finish no earlier than 2016-12-16 | S2 | 1104h | 1104h | GENCEF | PCG-37 | Samsung, Sunghoon Kim | s.hun.kim@samsung.com | Rel-14 | TSG#72 |
| 296 | 101 | **Robust Call Setup for VoLTE subscriber in LTE** | 360d? | 2015-11-02 A | 2017-03-16 | 59% | 148.24d? | 282d |  | S2; C1; R2 | 10568h | 3280h | RobVoLTE | PCG-37 |  |  | Rel-14 | SP-72 |
| 297 | 101.1 | Study on Robust Call Setup for VoLTE subscriber in LTE | 160d? | 2015-11-02 A | 2016-06-10 A | 100% |  |  | start no earlier than 2015-11-02 | S2 | 1280h | 1280h | FS_RobVoLTE | PCG-36 | Xiaobo Wu, Huawei | wuxiaobo@ huawei.com | Rel-14 | SP-70 |
| 298 | 101.2 | Robust Call Setup for VoLTE subscriber in LTE | 66d? | 2016-06-17 A | 2016-09-15 A | 100% |  |  | finish no earlier than 2016-09-15 | S2 | 528h | 528h | RobVoLTE |  | Xiaobo Wu, Huawei | wuxiaobo@ huawei.com | Rel-14 | SP-72 |
| 299 | 101.3 | CT Aspects of RobVoLTE | 130d? | 2016-09-16 A | 2017-03-16 | 80% | 26d? | 282d | finish no earlier than 2017-03-16 | C1 | 1040h | 832h | RobVoLTE-CT | PCG-37 | PATEL, Milan | Milan.Patel@huawei.com | Rel-14 | TSG-73 |
| 300 | 101.4 | Core part: Voice and Video Enhancement for LTE | 130d? | 2016-09-15 | 2017-03-15 |  |  | 283d | finish no earlier than 2017-03-15 | R2 | 1040h |  | LTE_VoLTE_ViLTE_enh-Core | PCG-37 | CMCC |  | Rel-14 | TSG-73 |
| 301 | 101.5 | RAN-Assisted Codec Adaptation in MTSI | 75d? | 2016-12-01 | 2017-03-15 |  |  | 283d | finish no earlier than 2017-03-15 | S4 | 600h |  | LTE_VoLTE_ViLTE_enh-S4 |  | Ozgur Oyman, Intel | ozgur.oyman@intel.com | Rel-14 |  |
| 302 | 102 | Extension of UE Delay test methods and requirements | 199d? | 2016-06-13 A | 2017-03-15 | 30% | 139.3d? | 283d | finish no earlier than 2017-03-15 | S4 | 1592h | 477.6h | EXT_UED | PCG-37 | Stéphane Ragot, ORANGE | stephane.ragot@orange.com | Rel-14 | TSG#72 |
| 303 | 103 | **Improved operator control using new UE configuration parameters** | 199d? | 2016-06-13 A | 2017-03-15 | 38% | 124.38d? | 283d |  | C1; C6 | 6368h | 1791h | IOC_UE_conf | PCG-37 | Sedlacek, Ivo | ivo.sedlacek@ericsson.com | Rel-14 | TSG#72 |
| 304 | 103.1 | CT1 aspects of IOC_UE_conf | 199d? | 2016-06-13 A | 2017-03-15 | 75% | 49.75d? | 283d | finish no earlier than 2017-03-15 | C1 | 1592h | 1194h | IOC_UE_conf | PCG-37 | Sedlacek, Ivo | ivo.sedlacek@ericsson.com | Rel-14 | TSG#72 |
| 305 | 103.2 | CT6 aspects of IOC_UE_conf | 199d? | 2016-06-13 | 2017-03-15 |  |  | 283d | finish no earlier than 2017-03-15 | C6 | 1592h |  | IOC_UE_conf | PCG-37 | Adrian Buckley | abuckley@blackberry.com | Rel-14 | TSG#72 |
| 306 | 104 | Shared Subscription Data Update | 135d? | 2016-06-13 A | 2016-12-15 A | 100% |  |  | finish no earlier than 2016-12-15 | C4 | 1080h | 1080h | eSDU | PCG-37 | Nokia, Ulrich Wiehe | ulrich.wiehe@nokia.com | Rel-14 | TSG#72 |
| 307 | 105 | Security Assurance Specification for PGW network product class | 261d? | 2016-06-17 A | 2017-06-15 | 40% | 156.6d? | 217d | finish no earlier than 2017-06-15 | S3 | 2088h | 835.2h | SCAS_PGW | PCG-37 | Peng Jin, China Mobile | pengjin@chinamobile.com | Rel-14 | SP-72 |
| 308 | 106 | Security Assurance Specification for eNB network product class | 194d? | 2016-09-19 A | 2017-06-15 | 5% | 184.3d? | 217d | finish no earlier than 2017-06-15 | S3 | 1552h | 77.6h | SCAS_eNB | PCG-37 | Marcus Wong, Huawei Technologies | mwong@huawei.com | Rel-14 | TSG-73 |

Notes:
- 282: Comes back from previous release; 28/1/16: 23.719 added;; 7/3/16: 0%->30; 7/3/16: WID:SP-150626->SP-1601679/6/16: 30%->70; 11/6/16: WID:SP-160167->SP-160306. FCD: 06/16->09/16; 1/12/16: 70%->100 / Impacted TSs and TRs: 23.719
- 283: 19/9/16: 0%->100 / Impacted TSs and TRs: 23.292, 23.167
- 285: 28/1/16: 23.721 added;; 7/3/16: 10%->40; 9/6/16: 40%->100 / Impacted TSs and TRs: 23.721
- 286: 19/9/16: 0%->100 / Impacted TSs and TRs: 23.203, 23.682
- 287: 6/10/16: 29.251 added; / Impacted TSs and TRs: 29.251
- 288: 6/10/16: 29.250 added;; 2/12/16: 10%->30 / Impacted TSs and TRs: 29.212, 29.213, 29.214, 29.201, 29.250
- 289: Impacted TSs and TRs: 23.122, 24.008, 24.167, 24.229, 24.301, 24.302, 24.303, 24.304, 24.305, 24.312, 29.018, 29.118
- 290: 11/6/16: 0%->5; 16/9/16: 5%->20; 2/12/16: 20%->70 / Impacted TSs and TRs: 23.122, 24.008, 24.167, 24.229, 24.301, 24.302, 24.303, 24.304, 24.305, 24.312, 29.018, 29.118
- 291: 11/6/16: 0%->15; 16/9/16: 15%->20; 2/12/16: 20%->85 / Impacted TSs and TRs: 23.122, 24.008, 24.167, 24.229, 24.301, 24.302, 24.303, 24.304, 24.305, 24.312, 29.018, 29.118
- 292: Added following CT1's chair e-mail 14/06/16; 16/9/16: 0%->20; 2/12/16: 20%->85
- 294: 28/1/16: 23.773 added;; 28/1/16: 23.742 added;; 7/3/16: 0%->10; 9/6/16: 10%->100 / Impacted TSs and TRs: 23.xyz; 23.773; 23.742
- 295: 19/9/16: 0%->90; 1/12/16: FCD:09/16->12/16; 1/12/16: 90%->100 / Impacted TSs and TRs: 23.682
- 297: 28/1/16: 23.750 added;; 7/3/16: 0%->20; 9/6/16: 20%->100 / Impacted TSs and TRs: 23.8xx; 23.750
- 298: 19/9/16: 0%->100. 1/12/16: UID changed: 720085 -> 720301 (720085 was also used for RP-161181) / Impacted TSs and TRs: 23.228, 23.237
- 299: 2/12/16: 0%->80 / Impacted TSs and TRs: 24.229, 24.292
- 302: 19/9/16: WID:SP-160271->SP-160600; 19/9/16: 0%->20; 1/12/16: 20%->30 / Impacted TSs and TRs: TR 26.9xx, 26.131, 26.132
- 303: 11/6/16: 0%->10; 17/10/16: WID:CP-160296->CP-160374 / Impacted TSs and TRs: 24.167, 24.229, 24.301, 24.302, 24.312, 24.341, 24.368, 24.607, 24.623, TS 24.XXX, TS 24.YYY
- 304: 11/6/16: 0%->10; 16/9/16: 10%->20; 17/10/16: WID:CP-160296->CP-160374; 2/12/16: 20%->75 / Impacted TSs and TRs: 24.167, 24.229, 24.301, 24.302, 24.312, 24.341, 24.368, 24.607, 24.623, TS 24.XXX, TS 24.YYY
- 305: 11/6/16: 0%->10 / Impacted TSs and TRs: 31.102, 31.103
- 306: 13/6/16: 0%->25; 2/12/16: 25%->100 / Impacted TSs and TRs: 29.272, 29.002, 29.305, 29.230
- 307: 28/7/16: 33.250 added;; 19/9/16: 0%->10; 6/10/16: 33.216 added;; 1/12/16: 10%->40 / Impacted TSs and TRs: 33.250; 33.216
- 308: 6/10/16: 33.216 added;; 1/12/16: 0%->5 / Impacted TSs and TRs: TS 33.117, TR 33.926; 33.216

| ID | WBS | Task | Duration | Start | Finish | Complete | Remaining | Total slack | Constraint | Resources | Work | Actual work | Acronym | PCG approved | Release | TSG approved | Impacted TSs and TRs | WI rapporteur name | WI rapporteur e-mail |
| --- | --- | --- | --- | --- | --- | --- | --- | --- | --- | --- | --- | --- | --- | --- | --- | --- | --- | --- | --- |
| 309 | 107 | **Rel-14 Charging** | 273d? | 2016-03-01 A | 2017-03-15 | 40% | 164.99d? | 283d |  | S5 | 4944h | 1956.11h | CH14 | PCG-36 | Rel-14 | TSG#71 |  |  |  |
| 310 | 107.1 | Resource Optimization for PS Domain Online | 273d | 2016-03-01 A | 2017-03-15 | 50% | 136.5d | 283d | finish no earlier than 2017-03-15 | S5 | 2184h | 1092h | CH14-ROPOCH | PCG-36 | Rel-14 | TSG#71 | 32.251, 32.299 | Shrader, David(Ericsson) | david.shrader@ericsson.com |
| 311 | 107.2 | Charging for SMS via T4 | 72d? | 2016-12-01 | 2017-03-10 |  |  | 286d | finish no earlier than 2017-03-10 | S5 | 576h |  | CH14-SMST4 |  | Rel-14 |  | TS 32.274, TS 32.250 , TS 32.298, TS 32.299 | Nokia | Maryse <dot> Gardella <at> Nokia <dot> com |
| 312 | 108 | **Determination of Completeness of Charging Information in IMS** | 199d? | 2016-06-13 A | 2017-03-15 | 8% | 183.35d? | 283d |  | S5 | 4960h | 373.21h | CH14-DCCII | PCG-37 | Rel-14 | TSG#72 | 32.240, 32.260, 32.298, 32.299 | Jesske, Roland (Deutsche Telekom) |  |
| 313 | 108.1 | Determination of Completeness of Charging Information in IMS | 199d? | 2016-06-13 A | 2017-03-15 | 10% | 179.1d? | 283d | finish no earlier than 2017-03-15 | S5 | 1592h | 159.2h | CH14-DCCII | PCG-37 | Rel-14 | TSG#72 | 32.240, 32.260, 32.298, 32.299 | Jesske, Roland (Deutsche Telekom) |  |
| 314 | 108.2 | **CT Aspects of Determination of Completeness of Charging Information in IMS** | 74d? | 2016-12-01 A | 2017-03-14 | 5% | 70.3d? | 284d |  | ct | 1776h | 88.79h | CH14-DCCII-CT |  | Rel-14 |  |  | Michael KREIPL, Deutsche Telekom | michael(dot)kreipl(at)telekom(dot)de |
| 315 | 108.2.1 | CT1 Aspects of Determination of Completeness of Charging Information in IMS | 74d? | 2016-12-01 A | 2017-03-14 | 10% | 66.6d? | 284d | finish no earlier than 2017-03-14 | C1 | 592h | 59.2h | CH14-DCCII-CT |  | Rel-14 |  | 24.229 | Michael KREIPL, Deutsche Telekom | michael(dot)kreipl(at)telekom(dot)de |
| 316 | 108.2.2 | CT3 Aspects of Determination of Completeness of Charging Information in IMS | 74d? | 2016-12-01 | 2017-03-14 |  |  | 284d | finish no earlier than 2017-03-14 | C3 | 592h |  | CH14-DCCII-CT |  | Rel-14 |  | 29.165 | Michael KREIPL, Deutsche Telekom | michael(dot)kreipl(at)telekom(dot)de |
| 317 | 109 | **Enhanced LAA for LTE** | 394d? | 2015-12-15 A | 2017-06-15 | 28% | 281.94d? | 217d |  | R1; R4; R5 | 16288h | 3019.61h | LTE_eLAA | PCG-36 | Rel-14 | RP-70 |  | Ericsson |  |
| 318 | 109.1 | Core part: Enhanced LAA for LTE | 264d? | 2015-12-15 A | 2016-12-15 | 92% | 21.12d? | 347d | finish no earlier than 2016-12-15 | R1 | 2112h | 1943.04h | LTE_eLAA-Core | PCG-36 | Rel-14 | RP-70 |  | Ericsson |  |
| 319 | 109.2 | Perf. part: Enhanced LAA for LTE | 394d? | 2015-12-15 | 2017-06-15 |  |  | 217d | finish no earlier than 2017-06-15 | R4 | 3152h |  | LTE_eLAA-Perf | PCG-36 | Rel-14 | RP-70 |  | Ericsson |  |
| 320 | 109.3 | UE Conformance Test Aspects - Enhanced LAA for LTE | 196d? | 2016-09-15 | 2017-06-15 |  |  | 217d | finish no earlier than 2017-06-15 | R5 | 1568h |  | LTE_eLAA-UEConTest | PCG-37 | Rel-14 | TSG-73 |  | Intel |  |
| 321 | 110 | **RRC optimization for UMTS** | 199d? | 2015-12-15 A | 2016-09-15 A | 100% |  |  |  | R2 | 3184h | 3184h | UTRA_RRCopt | PCG-36 | Rel-14 | RP-70 |  | Ericsson |  |
| 322 | 110.1 | Core part: RRC optimization for UMTS | 199d? | 2015-12-15 A | 2016-09-15 A | 100% |  |  | finish no earlier than 2016-09-15 | R2 | 1592h | 1592h | UTRA_RRCopt-Core | PCG-36 | Rel-14 | RP-70 |  | Ericsson |  |
| 323 | 111 | **DTX/DRX enhancements in CELL_FACH** | 264d? | 2015-12-15 A | 2016-12-15 | 65% | 92.4d? | 347d |  | R2 | 4224h | 2745.57h | FACH_DTXDRX | PCG-36 | Rel-14 | RP-70 |  | Huawei |  |
| 324 | 111.1 | Core part: DTX/DRX enhancements in CELL_FACH | 264d? | 2015-12-15 A | 2016-12-15 | 65% | 92.4d? | 347d | finish no earlier than 2016-12-15 | R2 | 2112h | 1372.8h | FACH_DTXDRX-Core | PCG-36 | Rel-14 | RP-70 |  | Huawei |  |
| 325 | 112 | **AWS-3/4 Band for LTE** | 328d? | 2015-12-15 A | 2017-03-15 | 67% | 108.22d? | 283d |  | R4; R5 | 7344h | 3168h | LTE_AWS_3_4 | PCG-36 | Rel-14 | RP-70 |  | Dish Network |  |
| 326 | 112.1 | Core part: AWS-3/4 Band for LTE | 132d? | 2015-12-15 A | 2016-06-15 A | 100% |  |  | finish no earlier than 2016-09-15 | R4 | 1056h | 1056h | LTE_AWS_3_4-Core | PCG-36 | Rel-14 | RP-70 | 36.749 | Dish Network |  |
| 327 | 112.2 | Perf. part: AWS-3/4 Band for LTE | 132d? | 2015-12-15 A | 2016-06-15 A | 100% |  |  | finish no earlier than 2016-09-15 | R4 | 1056h | 1056h | LTE_AWS_3_4-Perf | PCG-36 | Rel-14 | RP-70 |  | Dish Network |  |
| 328 | 112.3 | UE Conformance Test Aspects – AWS-3/4 Band for LTE (Band 70) | 130d? | 2016-09-15 | 2017-03-15 |  |  | 283d | finish no earlier than 2017-03-15 | R5 | 1040h |  | LTE_AWS_3_4-UEConTest | PCG-37 | Rel-14 | TSG-73 |  | Dish Network |  |
| 329 | 113 | **LTE FDD in the Bands 1980-2010 MHz and 2170-2200MHz for Region 3** | 1d? | 2015-12-15 | 2015-12-15 |  |  | 610d |  | R4 | 16h |  | LTE_1980_2170_REG3 | PCG-36 | Rel-14 | RP-70 |  | KT Corp. |  |
| 330 | 113.1 | Core part: LTE FDD in the Bands 1980-2010 MHz and 2170-2200MHz for Region 3 | 1d? | 2015-12-15 | 2015-12-15 |  |  | 610d | finish no earlier than 2015-12-15 | R4 | 8h |  | LTE_1980_2170_REG3-Core | PCG-36 | Rel-14 | RP-70 |  | KT Corp. |  |
| 331 | 114 | **LTE 2.6 GHz FDD Supplemental DL band (2570-2620 MHz) and LTE Carrier Aggregation (2DL/1UL) with Band 3 for region 1** | 132d? | 2015-12-15 A | 2016-06-15 A | 100% |  |  |  | R4 | 3168h | 3168h | LTE_FDD_2600_CA_B3 | PCG-36 | Rel-14 | RP-70 |  | Orange |  |
| 332 | 114.1 | Core part: LTE 2.6 GHz FDD Supplemental DL band (2570-2620 MHz) and LTE Carrier Aggregation (2DL/1UL) with Band 3 for region 1 | 132d? | 2015-12-15 A | 2016-06-15 A | 100% |  |  | finish no earlier than 2016-09-15 | R4 | 1056h | 1056h | LTE_FDD_2600_CA_B3-Core | PCG-36 | Rel-14 | RP-70 | 36.858 | Orange |  |
| 333 | 114.2 | Perf. part: LTE 2.6 GHz FDD Supplemental DL band (2570-2620 MHz) and LTE Carrier Aggregation (2DL/1UL) with Band 3 for region 1 | 132d? | 2015-12-15 A | 2016-06-15 A | 100% |  |  | finish no earlier than 2016-09-15 | R4 | 1056h | 1056h | LTE_FDD_2600_CA_B3-Perf | PCG-36 | Rel-14 | RP-70 |  | Orange |  |

Notes:
- 309: Umbrella Feature
- 310: 13/6/16: 0%->10. FCD:09/16->03/17; 19/9/16: FCD: 09/16->03/17; 19/9/16: 10%->20; 1/12/16: 20%->50
- 312: 19/9/16: 0%->10
- 313: 19/9/16: 0%->10
- 315: 2/12/16: 0%->10
- 318: 22/3/16: Compl:0%->20%22/3/16: WID: RP-152272->RP-1604071/7/16: Compl:20%->60%1/7/16: WID: RP-160407->RP-160881; 26/9/16: Compl:60%->92%; 26/9/16: CD:Thu 15/09/16->Thu 15/12/16; 26/9/16: WID: ...
- 319: 22/3/16: WID: RP-152272->RP-160407; 1/7/16: WID: RP-160407->RP-16088126/9/16: CD:Wed 15/03/17->Thu 15/06/1726/9/16: WID: RP-160881->RP-161832
- 322: 22/3/16: Compl:0%->8%; ;...; 1/7/16: Compl:8%->70%26/9/16: Compl:70%->100%
- 324: 22/3/16: Compl:0%->20%; ...1/7/16: Compl:20%->50%26/9/16: Compl:50%->65%...
- 326: ; 22/3/16: Compl:0%->60%; 1/7/16: Compl:60%->100%; 1/7/16: CD:Th...
- 327: 1/7/16: Compl:0%->100%1/7/16: CD:Thu 15/09/16->Wed 15/06...
- 332: 28/1/16: 36.858 added;22/3/16: Compl:0%->40%22/3/16: WID: RP-152253->RP-160378; 1/7/16: Compl:40%->100%;...
- 333: ; 22/3/16: WID: RP-152253->RP-1603781/7/16: Compl:0%->100%1/7/16...

| ID | WBS | Task | Duration | Start | Finish | Complete | Remaining | Total slack | Constraint | Resources | Work | Actual work | Acronym | PCG approved | WI rapporteur name | Release | TSG approved | Impacted TSs and TRs | WI rapporteur e-mail |
| --- | --- | --- | --- | --- | --- | --- | --- | --- | --- | --- | --- | --- | --- | --- | --- | --- | --- | --- | --- |
| 334 | 115 | **Multi-Band Base Station testing with three or more bands** | 264d? | 2015-12-15 A | 2016-12-15 | 78% | 59.39d? | 347d |  | R4 | 6336h | 4268.62h | MB_BS_test_3B | PCG-36 | Alcatel-Lucent | Rel-14 | RP-70 |  |  |
| 335 | 115.1 | Core part: Multi-Band Base Station testing with three or more bands | 264d? | 2015-12-15 A | 2016-12-15 | 95% | 13.2d? | 347d | finish no earlier than 2016-12-15 | R4 | 2112h | 2006.4h | MB_BS_test_3B-Core | PCG-36 | Alcatel-Lucent | Rel-14 | RP-70 | 37.871 |  |
| 336 | 115.2 | Perf. part: Multi-Band Base Station testing with three or more bands | 264d? | 2015-12-15 A | 2016-12-15 | 60% | 105.6d? | 347d | finish no earlier than 2016-12-15 | R4 | 2112h | 1267.2h | MB_BS_test_3B-Perf | PCG-36 | Alcatel-Lucent | Rel-14 | RP-70 |  |  |
| 337 | 116 | **Performance enhancements for high speed scenario in LTE** | 394d? | 2015-12-15 A | 2017-06-15 | 33% | 263.88d? | 217d |  | R4 | 8416h | 2779.32h | LTE_high_speed | PCG-36 | NTT DOCOMO | Rel-14 | RP-70 |  |  |
| 338 | 116.1 | Core part: Performance enhancements for high speed scenario in LTE | 264d? | 2015-12-15 A | 2016-12-15 | 45% | 145.2d? | 347d | finish no earlier than 2016-12-15 | R4 | 2112h | 950.4h | LTE_high_speed-Core | PCG-36 | NTT DOCOMO | Rel-14 | RP-70 |  |  |
| 339 | 116.2 | Perf. part: Performance enhancements for high speed scenario in LTE | 394d? | 2015-12-15 A | 2017-06-15 | 25% | 295.5d? | 217d | finish no earlier than 2017-06-15 | R4 | 3152h | 788h | LTE_high_speed-Perf | PCG-36 | NTT DOCOMO | Rel-14 | RP-70 |  |  |
| 340 | 117 | Remote UE access via relay UE | 77d? | 2016-03-01 A | 2016-06-15 A | 100% |  |  | finish no earlier than 2016-06-15 | S1 | 616h | 616h | REAR | PCG-36 | Huawei, Laurence Meriau | Rel-14 | TSG#71 | 22.278, 22.115 | laurence.meriau@huawei.com |
| 341 | 118 | **Further Indoor Positioning Enhancements for UTRA and LTE** | 329d? | 2016-03-15 A | 2017-06-15 | 23% | 254.6d? | 217d |  | R2 | 6856h | 1498.97h | UTRA_LTE_iPos_enh2 | PCG-36 | Huawei | Rel-14 | TSG#71 |  |  |
| 342 | 118.1 | Core part: Further Indoor Positioning Enhancements for UTRA and LTE | 199d? | 2016-03-15 A | 2016-12-15 | 60% | 79.6d? | 347d | finish no earlier than 2016-12-15 | R2 | 1592h | 955.2h | UTRA_LTE_iPos_enh2-Core | PCG-36 | Huawei | Rel-14 | TSG#71 |  |  |
| 343 | 118.2 | Perf. part: Further Indoor Positioning Enhancements for UTRA and LTE | 329d? | 2016-03-15 | 2017-06-15 |  |  | 217d | finish no earlier than 2017-06-15 | R4 | 2632h |  | UTRA_LTE_iPos_enh2-Perf | PCG-36 | Huawei | Rel-14 | TSG#71 |  |  |
| 344 | 119 | **Signalling reduction to enable light connection for LTE** | 263d? | 2016-03-15 A | 2017-03-15 | 16% | 220.22d? | 283d |  | R2 | 6576h | 973.48h | LTE_LIGHT_CON | PCG-36 | Huawei | Rel-14 | TSG#71 |  |  |
| 345 | 119.1 | Core part: Signalling reduction to enable light connection for LTE | 263d? | 2016-03-15 A | 2017-03-15 | 30% | 184.1d? | 283d | finish no earlier than 2017-03-15 | R2 | 2104h | 631.2h | LTE_LIGHT_CON-Core | PCG-36 | Huawei | Rel-14 | TSG#71 |  |  |
| 346 | 119.2 | **Stage 3 of Signalling reduction to enable light connection for LTE** | 74d? | 2016-12-01 | 2017-03-14 |  |  | 284d |  | ct | 2368h |  | LTE_LIGHT_CON-CT |  | Herrero Veron, Christian (Huawei) | Rel-14 |  |  | Christian.Herrero at huawei.com |
| 347 | 119.2.1 | CT1 aspects of Signalling reduction to enable light connection for LTE | 74d? | 2016-12-01 | 2017-03-14 |  |  | 284d | finish no earlier than 2017-03-14 | C1 | 592h |  | LTE_LIGHT_CON-CT |  | Herrero Veron, Christian (Huawei) | Rel-14 |  | 24.008, 24.301, 29.118, 24.368, 27.007 | Christian.Herrero at huawei.com |
| 348 | 119.2.2 | CT4 aspects of Signalling reduction to enable light connection for LTE | 74d? | 2016-12-01 | 2017-03-14 |  |  | 284d | finish no earlier than 2017-03-14 | C4 | 592h |  | LTE_LIGHT_CON-CT |  | Herrero Veron, Christian (Huawei) | Rel-14 |  | 29.274, 29.272 | Christian.Herrero at huawei.com |
| 349 | 119.2.3 | CT6 aspects of Signalling reduction to enable light connection for LTE | 74d? | 2016-12-01 | 2017-03-14 |  |  | 284d | finish no earlier than 2017-03-14 | C6 | 592h |  | LTE_LIGHT_CON-CT |  | Herrero Veron, Christian (Huawei) | Rel-14 |  | 31.102 | Christian.Herrero at huawei.com |
| 350 | 120 | **Radiated performance requirements for the verification of multi-antenna reception of UEs in LTE** | 329d? | 2016-03-15 A | 2017-06-15 | 9% | 300.73d? | 217d |  | R4 | 6304h | 631.12h | LTE_MIMO_OTA | PCG-36 | Intel | Rel-14 | TSG#71 |  |  |
| 351 | 120.1 | Core part: Radiated performance requirements for the verification of multi-antenna reception of UEs in LTE | 263d? | 2016-03-15 A | 2017-03-15 | 15% | 223.55d? | 283d | finish no earlier than 2017-03-15 | R4 | 2104h | 315.6h | LTE_MIMO_OTA-Core | PCG-36 | Intel | Rel-14 | TSG#71 |  |  |
| 352 | 120.2 | UE Conformance Test Aspects - Radiated Performance of Multiple-antenna Receivers in the LTE UE | 196d? | 2016-09-15 | 2017-06-15 |  |  | 217d | finish no earlier than 2017-06-15 | R5 | 1568h |  | LTE_MIMO_OTA-UEConTest | PCG-37 | Intel | Rel-14 | TSG-73 |  |  |
| 353 | 121 | **Enhancements on Full-Dimension (FD) MIMO for LTE** | 395d? | 2016-03-15 A | 2017-09-15 | 16% | 331.85d? | 151d |  | R1 | 8424h | 1346.77h | LTE_eFDMIMO | PCG-36 | Samsung | Rel-14 | TSG#71 |  |  |
| 354 | 121.1 | Core part: Enhancements on Full-Dimension (FD) MIMO for LTE | 263d? | 2016-03-15 A | 2017-03-15 | 40% | 157.8d? | 283d | finish no earlier than 2017-03-15 | R1 | 2104h | 841.6h | LTE_eFDMIMO-Core | PCG-36 | Samsung | Rel-14 | TSG#71 |  |  |
| 355 | 121.2 | Perf. part: Enhancements on Full-Dimension (FD) MIMO for LTE | 395d? | 2016-03-15 | 2017-09-15 |  |  | 151d | finish no earlier than 2017-09-15 | R4 | 3160h |  | LTE_eFDMIMO-Perf | PCG-36 | Samsung | Rel-14 | TSG#71 |  |  |
| 356 | 122 | **Further mobility enhancements in LTE** | 199d? | 2016-03-15 A | 2016-12-15 | 50% | 99.5d? | 347d |  | R2 | 3184h | 1592h | LTE_eMob | PCG-36 | ZTE | Rel-14 | TSG#71 |  |  |
| 357 | 122.1 | Core part: Further mobility enhancements in LTE | 199d? | 2016-03-15 A | 2016-12-15 | 50% | 99.5d? | 347d | finish no earlier than 2016-12-15 | R2 | 1592h | 796h | LTE_eMob-Core | PCG-36 | ZTE | Rel-14 | TSG#71 |  |  |

Notes:
- 335: 22/3/16: Compl:0%->50%22/3/16: WID: RP-152205->RP-1600631/7/16: Compl:50%->90%; 26/9/16: Compl:90%->95%; 26/9/16...
- 336: 22/3/16: Compl:0%->5%22/3/16: WID: RP-152205->RP-160063; 1/7/16: Compl:5%->30%26/9/16: Compl:30%->60%26/...
- 338: 22/3/16: Compl:0%->5%22/3/16: WID: RP-152263->RP-160172; 1/7/16: Compl:5%->25%26/9/16: Compl:25%->45%
- 339: 22/3/16: WID: RP-152263->RP-1601721/7/16: Compl:0%->20%; 26/9/16: Compl:20%->25%
- 340: Previously known as "wearable devices"; 9/6/16: 0%->100; 9/6/16: WID:SP-160231->SP-160371
- 341: follow-up WI of REL-13 WI UTRA_LTE_iPos_enh
- 342: follow-up WI of REL-13 WI UTRA_LTE_iPos_enh1/7/16: Compl:0%->30%; 26/9/16: Compl:30%->60%; 26/9/16: WID:...
- 343: 26/9/16: CD:Wed 15/03/17->Thu 15/06/1726/9/16: WID: RP-160538->RP-161850
- 344: no Perf. part
- 345: no Perf. part; 1/7/16: Compl:0%->10%; 1/7/16: CD:Thu 15/12/16->Wed 15/03/17; 1/7/16: WID: RP-160540->RP-16093726/9/16: Compl:10%->30%
- 350: follow-up WI of REL-13 WI UTRA_LTE_MIMO_OTA-Core; no Perf. part
- 351: follow-up WI of REL-13 WI UTRA_LTE_MIMO_OTA-Core; no Perf. part1/7/16: Compl:0%->10%1/7/16: WID: RP-160603->RP-16091426/9/16: Compl:10%->15%
- 354: ; 1/7/16: Compl:0%->25%26/9/16: Compl:25%->40%
- 356: no Perf. part
- 357: no Perf. part; 1/7/16: Compl:0%->25%; 1/7/16: WID: RP-160636->RP-160921; 26/9/16: Compl:25%->50%

| ID | WBS | Task | Duration | Start | Finish | Complete | Remaining | Total slack | Constraint | Resources | Work | Actual work | Acronym | PCG approved | WI rapporteur name | Release | TSG approved | WI rapporteur e-mail | Impacted TSs and TRs |
| --- | --- | --- | --- | --- | --- | --- | --- | --- | --- | --- | --- | --- | --- | --- | --- | --- | --- | --- | --- |
| 358 | 123 | **Uplink Capacity Enhancements for LTE** | 395d? | 2016-03-15 A | 2017-09-15 | 16% | 331.85d? | 151d |  | R1 | 8424h | 1346.77h | LTE_UL_CAP_enh | PCG-36 | Ericsson | Rel-14 | TSG#71 |  |  |
| 359 | 123.1 | Core part: Uplink Capacity Enhancements for LTE | 263d? | 2016-03-15 A | 2017-03-15 | 40% | 157.8d? | 283d | finish no earlier than 2017-03-15 | R1 | 2104h | 841.6h | LTE_UL_CAP_enh-Core | PCG-36 | Ericsson | Rel-14 | TSG#71 |  |  |
| 360 | 123.2 | Perf. part: Uplink Capacity Enhancements for LTE | 395d? | 2016-03-15 | 2017-09-15 |  |  | 151d | finish no earlier than 2017-09-15 | R4 | 3160h |  | LTE_UL_CAP_enh-Perf | PCG-36 | Ericsson | Rel-14 | TSG#71 |  |  |
| 361 | 124 | **L2 latency reduction techniques for LTE** | 134d? | 2016-03-15 A | 2016-09-15 A | 100% |  |  |  | R2 | 2144h | 2144h | LTE_LATRED_L2 | PCG-36 | Ericsson | Rel-14 | TSG#71 |  |  |
| 362 | 124.1 | Core part: L2 latency reduction techniques for LTE | 134d? | 2016-03-15 A | 2016-09-15 A | 100% |  |  | finish no earlier than 2016-09-15 | R2 | 1072h | 1072h | LTE_LATRED_L2-Core | PCG-36 | Ericsson | Rel-14 | TSG#71 |  |  |
| 363 | 125 | **eMBMS enhancements for LTE** | 395d? | 2016-03-15 A | 2017-09-15 | 22% | 308.17d? | 151d |  | R1 | 8424h | 1324.84h | MBMS_LTE_enh2 | PCG-36 | Ericsson | Rel-14 | TSG#71 |  |  |
| 364 | 125.1 | Core part: eMBMS enhancements for LTE | 263d? | 2016-03-15 A | 2017-03-15 | 55% | 118.35d? | 283d | finish no earlier than 2017-03-15 | R1 | 2104h | 1157.2h | MBMS_LTE_enh2-Core | PCG-36 | Ericsson | Rel-14 | TSG#71 |  |  |
| 365 | 125.2 | Perf. part: eMBMS enhancements for LTE | 395d? | 2016-03-15 | 2017-09-15 |  |  | 151d | finish no earlier than 2017-09-15 | R4 | 3160h |  | MBMS_LTE_enh2-Perf | PCG-36 | Ericsson | Rel-14 | TSG#71 |  |  |
| 366 | 126 | **SRS (sounding reference signal) switching between LTE component carriers** | 263d? | 2016-03-15 A | 2017-03-15 | 24% | 200.7d? | 283d |  | R1 | 5800h | 1374.01h | LTE_SRS_switch | PCG-36 | Huawei | Rel-14 | TSG#71 |  |  |
| 367 | 126.1 | Core part: SRS (sounding reference signal) switching between LTE component carriers | 199d? | 2016-03-15 A | 2016-12-15 | 55% | 89.55d? | 347d | finish no earlier than 2016-12-15 | R1 | 1592h | 875.6h | LTE_SRS_switch-Core | PCG-36 | Huawei | Rel-14 | TSG#71 |  |  |
| 368 | 126.2 | Perf. part: SRS (sounding reference signal) switching between LTE component carriers | 263d? | 2016-03-15 | 2017-03-15 |  |  | 283d | finish no earlier than 2017-03-15 | R4 | 2104h |  | LTE_SRS_switch-Perf | PCG-36 | Huawei | Rel-14 | TSG#71 |  |  |
| 369 | 127 | **Downlink Multiuser Superposition Transmission for LTE** | 329d? | 2016-03-15 A | 2017-06-15 | 23% | 254.6d? | 217d |  | R1 | 6856h | 1590.39h | LTE_MUST | PCG-36 | MediaTek | Rel-14 | TSG#71 |  |  |
| 370 | 127.1 | Core part: Downlink Multiuser Superposition Transmission for LTE | 199d? | 2016-03-15 A | 2016-12-15 | 60% | 79.6d? | 347d | finish no earlier than 2016-12-15 | R1 | 1592h | 955.2h | LTE_MUST-Core | PCG-36 | MediaTek | Rel-14 | TSG#71 |  |  |
| 371 | 127.2 | Perf. part: Downlink Multiuser Superposition Transmission for LTE | 329d? | 2016-03-15 | 2017-06-15 |  |  | 217d | finish no earlier than 2017-06-15 | R4 | 2632h |  | LTE_MUST-Perf | PCG-36 | MediaTek | Rel-14 | TSG#71 |  |  |
| 372 | 128 | **IMS Stage-3 IETF Protocol Alignment** | 198d? | 2016-06-14 A | 2017-03-15 | 35% | 128.7d? | 283d |  | C1 | 6336h | 1902h | IMSProtoc8 | PCG-37 |  | Rel-14 | TSG#72 |  |  |
| 373 | 128.1 | CT1 aspects of IMS Stage-3 IETF Protocol Alignment | 198d? | 2016-06-14 A | 2017-03-15 | 75% | 49.5d? | 283d | finish no earlier than 2017-03-15 | C1 | 1584h | 1188h | IMSProtoc8 | PCG-37 | Alcatel-Lucent | Rel-14 | CT-72 | Keith Drage |  |
| 374 | 128.2 | (IETF) CT1 aspects of IMS Stage-3 IETF Protocol Alignment | 198d? | 2016-06-14 | 2017-03-15 |  |  | 283d | start no earlier than 2016-06-14 | C1-IETF | 1584h |  | IMSProtoc8 | PCG-37 | Alcatel-Lucent | Rel-14 | CT-72 | Keith Drage | draft-ietf-mmusic-dtls-sdp, draft-ietf-mmusic-4572-update |
| 375 | 128.3 | CT3 aspects of IMS Stage-3 IETF Protocol Alignment | 198d? | 2016-06-14 A | 2017-03-15 | 30% | 138.6d? | 283d | start no earlier than 2016-06-14 | C3 | 1584h | 475.2h | IMSProtoc8 | PCG-37 | Alcatel-Lucent | Rel-14 | CT-72 | Keith Drage |  |
| 376 | 129 | **Multi-Carrier Enhancements for UMTS** | 264d? | 2015-12-15 A | 2016-12-15 | 67% | 86.12d? | 347d |  | R2 | 4232h | 2851.45h | UTRA_MCe | PCG-37 | Huawei, HiSilicon | Rel-14 | TSG#72 |  |  |
| 377 | 129.1 | Study on Multi-Carrier Enhancements for UMTS | 132d? | 2015-12-15 A | 2016-06-15 A | 100% |  |  | finish no earlier than 2016-06-15 | R1 | 1056h | 1056h | FS_UTRA_MCe | PCG-36 | Huawei | Rel-14 | RP-70 |  | 25.707 |
| 378 | 129.2 | Core part: Multi-Carrier Enhancements for UMTS | 133d? | 2016-06-15 A | 2016-12-15 | 35% | 86.45d? | 347d | finish no earlier than 2016-12-15 | R2 | 1064h | 372.4h | UTRA_Mce-Core | PCG-37 | Huawei, HiSilicon | Rel-14 | TSG#72 |  |  |
| 379 | 130 | **Citizens Broadband Radio Service (CBRS) 3.5GHz band for LTE in the United States** | 133d? | 2016-06-15 A | 2016-12-15 | 35% | 86.45d? | 347d |  | R4 | 3192h | 1117.16h | LTE_TDD_3550_CBRS_US | PCG-37 | Nokia | Rel-14 | TSG#72 |  |  |
| 380 | 130.1 | Core part: Citizens Broadband Radio Service (CBRS) 3.5GHz band for LTE in the United States | 133d? | 2016-06-15 A | 2016-12-15 | 70% | 39.9d? | 347d | finish no earlier than 2016-12-15 | R4 | 1064h | 744.8h | LTE_TDD_3550_CBRS_US-Core | PCG-37 | Nokia | Rel-14 | TSG#72 |  | 36.744 |
| 381 | 130.2 | Perf. part: Citizens Broadband Radio Service (CBRS) 3.5GHz band for LTE in the United States | 133d? | 2016-06-15 | 2016-12-15 |  |  | 347d | finish no earlier than 2016-12-15 | R4 | 1064h |  | LTE_TDD_3550_CBRS_US-Perf | PCG-37 | Nokia | Rel-14 | TSG#72 |  |  |

Notes:
- 359: 1/7/16: Compl:0%->25%26/9/16: Compl:25%->40%
- 361: no Perf. part; follow-up WI of SI FS_LTE_LATRED
- 362: no Perf. part; follow-up WI of SI FS_LTE_LATRED; 1/7/16: Compl:0%->80%; 26/9/16: Compl:80%->100%
- 364: 1/7/16: Compl:0%->10%1/7/16: CD:Tue 15/03/16->Wed 15/03/171/7/16: WID: RP-160675->RP-16129726/9/16: Compl:10%->55%
- 365: ; 1/7/16: CD:Wed 15/06/16->Fri 15/09/17; 1/7/16: WID: RP-160675->RP-161297
- 367: 1/7/16: Compl:0%->35%1/7/16: WID: RP-160676->RP-160935; 26/9/16: Compl:35%->55%
- 368: 1/7/16: WID: RP-160676->RP-160935
- 370: ; 1/7/16: Compl:0%->40%; 1/7/16: WID: RP-160680->RP-16101926/9/16: Compl:40%->60%
- 371: 1/7/16: WID: RP-160680->RP-161019; 26/9/16: CD:Fri 15/09/17->Thu 15/06/17
- 372: 11/6/16: 0%->15
- 373: Mar.15: 0->10%; June2015: Compl:10%->30; 07/09/15: 30%->70; 7/12/15: 70%->100; 16/9/16: 0%->30; 2/12/16: 30%->75
- 375: 2/4/15: added, following CT3 chair's info that the WID also has a CT3 part; June2015: Compl:0%->20; 07/09/15: 20%->40; 7/12/15: 40%->100; 20/9/16: 0%->10; 2/12/16: 10%->30
- 376: no Perf. part; follow-up WI of REL-14 SI FS_UTRA_MCe
- 377: 22/3/16: Compl:0%->20%; 1/7/16: Compl:20%->100%; 28/7/16: 25.707 added;
- 378: no Perf. part; follow-up WI of REL-14 SI FS_UTRA_MCe; 26/9/16: Compl:0%->35%
- 380: 26/9/16: Compl:0%->70%; 6/10/16: 36.744 added;

| ID | WBS | Task | Duration | Start | Finish | Complete | Remaining | Baseline start | Baseline finish | Baseline duration | Total slack | Constraint | Resources | Work | Actual work | Acronym | PCG approved | WI rapporteur name | Release | TSG approved | Impacted TSs and TRs | WI rapporteur e-mail | MCC resp | Acronym_3GU_Export | Status Report |
| --- | --- | --- | --- | --- | --- | --- | --- | --- | --- | --- | --- | --- | --- | --- | --- | --- | --- | --- | --- | --- | --- | --- | --- | --- | --- |
| 382 | 131 | **LTE Band 41 UE power class 2 operation** | 133d? | 2016-06-15 A | 2016-12-15 | 64% | 47.74d? |  |  |  | 347d |  | R4 | 3720h | 2384.45h | LTE_B41_UE_PC2 | PCG-37 | Sprint | Rel-14 | TSG#72 |  |  |  |  |  |
| 383 | 131.1 | Core part: LTE Band 41 UE power class 2 operation | 133d? | 2016-06-15 A | 2016-12-15 | 80% | 26.6d? |  |  |  | 347d | finish no earlier than 2016-12-15 | R4 | 1064h | 851.2h | LTE_B41_UE_PC2-Core | PCG-37 | Sprint | Rel-14 | TSG#72 |  |  |  |  |  |
| 384 | 131.2 | Perf. part: LTE Band 41 UE power class 2 operation | 133d? | 2016-06-15 A | 2016-12-15 | 80% | 26.6d? |  |  |  | 347d | finish no earlier than 2016-12-15 | R4 | 1064h | 851.2h | LTE_B41_UE_PC2-Perf | PCG-37 | Sprint | Rel-14 | TSG#72 |  |  |  |  |  |
| 385 | 131.3 | UE Conformance Test Aspects – LTE Band 41 UE power class 2 operation | 66d? | 2016-09-15 | 2016-12-15 |  |  |  |  |  | 347d | finish no earlier than 2016-12-15 | R5 | 528h |  | LTE_B41_UE_PC2-UEConTest | PCG-37 | Sprint | Rel-14 | TSG-73 |  |  |  |  |  |
| 386 | 132 | **LTE UE Total Radiated Power (TRP) and Total Radiated Sensitivity (TRS) and UTRA Hand Phantom related UE TRP and TRS Requirements** | 1118d? | 2012-12-15 A | 2017-03-15 | 68% | 362.75d? | 2013-03-15 | 2015-06-12 | 591d? | 283d |  | R4; R5 | 23436h | 15813.2h | LTE_UTRA_TRP_TRS | PCG-30 | Nokia | Rel-14 | RP-58 | UTRA, LTE | petri.j.vasenkari@nokia.com | Issam | LTE_UTRA_TRP_TRS |  |
| 387 | 132.1 | Core part: LTE UE TRP and TRS and UTRA Hand Phantom related UE TRP and TRS Requirements | 983d? | 2012-12-15 A | 2016-12-15 | 60% | 393.2d? | 2013-03-15 | 2014-09-12 | 393d? | 347d | finish no earlier than 2016-12-15 | R4 | 7864h | 4718.4h | LTE_UTRA_TRP_TRS-Core | PCG-30 | Nokia | Rel-14 | RP-58 | 25.144, New (TS 37.144, TR 37.844) | petri.j.vasenkari@nokia.com | Issam | LTE_UTRA_TRP_TRS-Core | RP-151227 |
| 388 | 132.2 | Test part: LTE UE TRP and TRS and UTRA Hand Phantom | 786d? | 2014-03-15 A | 2017-03-15 | 77% | 180.78d? | 2014-03-06 | 2015-06-12 | 332d? | 283d | finish no earlier than 2017-03-15 | R5 | 6288h | 4841.76h | LTE_UTRA_TRP_TRS-UEConTest | PCG-32 | ZTE | Rel-14 | RP-63 | New TS 37.544 | TAYLOR Carolyn (carolyn.tayl@zte.com.cn) | Ingbert | LTE_UTRA_TRP_TRS-UEConTest | RP-151188 |
| 389 | 133 | **Dedicated Core Networks for GERAN** | 68d? | 2016-06-15 A | 2016-09-15 A | 100% |  |  |  |  |  |  | R6 | 1088h | 1088h | DECOR_GERAN | PCG-37 | Ericsson | Rel-14 | TSG#72 |  |  |  |  |  |
| 390 | 133.1 | Core part: Dedicated Core Networks for GERAN | 68d? | 2016-06-15 A | 2016-09-15 A | 100% |  |  |  |  |  | finish no earlier than 2016-12-15 | R6 | 544h | 544h | DECOR_GERAN-Core | PCG-37 | Ericsson | Rel-14 | TSG#72 |  |  |  |  |  |
| 391 | 134 | **Positioning Enhancements for GERAN** | 197d? | 2016-06-15 A | 2017-03-15 | 15% | 167.46d? |  |  |  | 283d |  | R6 | 4728h | 709.14h | ePOS_GERAN | PCG-37 | Ericsson | Rel-14 | TSG#72 |  |  |  |  |  |
| 392 | 134.1 | Core part: Positioning Enhancements for GERAN | 197d? | 2016-06-15 A | 2017-03-15 | 30% | 137.9d? |  |  |  | 283d | finish no earlier than 2017-03-15 | R6 | 1576h | 472.8h | ePOS_GERAN-Core | PCG-37 | Ericsson | Rel-14 | TSG#72 |  |  |  |  |  |
| 393 | 134.2 | Perf. part: Positioning Enhancements for GERAN | 197d? | 2016-06-15 | 2017-03-15 |  |  |  |  |  | 283d | finish no earlier than 2017-03-15 | R6 | 1576h |  | ePOS_GERAN-Perf | PCG-37 | Ericsson | Rel-14 | TSG#72 |  |  |  |  |  |
| 394 | 135 | **Quality of Experience (QoE) Measurement Collection for streaming services in UTRAN** | 597d? | 2014-12-03 A | 2017-03-15 | 72% | 167.62d? |  |  |  | 283d |  | R2 | 8480h | 6099.01h | UMTS_QMC_Streaming | PCG-37 | China Unicom | Rel-14 | TSG-73 |  |  |  |  |  |
| 395 | 135.1 | Study on KQIs for Service Experience | 333d? | 2014-12-03 A | 2016-03-11 A | 100% |  |  |  |  |  | finish no earlier than 2016-03-11 | S5 | 2664h | 2664h | FS_KQISE | PCG-34 | Li, Hui (hui.li(at)huawei.com) | Rel-14 | SP-66 | TR 32.8xy | hui.li(at)huawei.com |  |  |  |
| 396 | 135.2 | Core part: Quality of Experience (QoE) Measurement Collection for streaming services in UTRAN | 130d? | 2016-09-15 | 2017-03-15 |  |  |  |  |  | 283d | finish no earlier than 2017-03-15 | R2 | 1040h |  | UMTS_QMC_Streaming-Core | PCG-37 | China Unicom | Rel-14 | TSG-73 |  |  |  |  |  |
| 397 | 136 | **Flexible eNB-ID and Cell-ID in E-UTRAN** | 263d? | 2016-03-15 A | 2017-03-15 | 51% | 129.51d? |  |  |  | 283d |  | R3 | 4216h | 2139.94h | LTE_FNBID | PCG-37 | China Telecom | Rel-14 | TSG-73 |  |  |  |  |  |
| 398 | 136.1 | Study on flexible eNB-ID and Cell-ID in E-UTRAN | 134d? | 2016-03-15 A | 2016-09-15 A | 100% |  |  |  |  |  | finish no earlier than 2016-09-15 | R3 | 1072h | 1072h | FS_LTE_FNBID | PCG-36 | China Telecom | Rel-14 | TSG#71 | New TR 36.896 |  |  |  |  |
| 399 | 136.2 | Core part: Flexible eNB-ID and Cell-ID in E-UTRAN | 130d? | 2016-09-15 | 2017-03-15 |  |  |  |  |  | 283d | finish no earlier than 2017-03-15 | R3 | 1040h |  | LTE_FNBID-Core | PCG-37 | China Telecom | Rel-14 | TSG-73 |  |  |  |  |  |
| 400 | 137 | **Security Assurance Specification for 3GPP network products** | 794d? | 2013-12-09 A | 2016-12-15 | 96% | 33.96d? | 2013-12-09 | 2015-03-18 | 334d? | 347d |  | S3 | 21112h | 14780.5h | SCAS | PCG-32 | NTT DOCOMO | Rel-14 | SP-62 | 33.199; 33.926, 33.117; 33.250 | Alf Zugenmaier (alf.zugenmaier@hm.edu) | Mirko | SCAS |  |
| 401 | 137.1 | STOPPED - TR on Pilot development of Security Assurance Specification for MME network product class | 266d? | 2013-12-09 A | 2014-12-12 A | 100% |  | 2013-12-09 | 2014-12-10 | 264d? |  | finish no earlier than 2014-12-12 | S3 | 2120h | 2120h | SCAS-SA3Pil_TR | PCG-32 | NTT DOCOMO | Rel-14 | SP-62 | New TR 33.806 | Alf Zugenmaier (alf.zugenmaier@hm.edu) | Mirko |  |  |
| 402 | 137.2 | Security Assurance Specification for 3GPP network product classes | 790d? | 2013-12-13 A | 2016-12-15 | 90% | 79d? | 2013-12-10 | 2015-03-18 | 333d? | 347d | finish no earlier than 2016-12-15 | S3 | 6320h | 5688h | SCAS-SA3 | PCG-32 | China Mobile | Rel-14 | SP-62 | New TS 33.116, 33.117; 33.250 | Judy Zhu (zhuhongru@chinamobile.com) | Mirko |  |  |
| 403 | 137.3 | TR on Security Assurance scheme for 3GPP network products | 791d? | 2013-12-09 A | 2016-12-15 A | 100% |  | 2013-12-09 | 2014-12-10 | 264d? |  | finish no earlier than 2016-12-15 | S3 | 6320h | 6320h | SCAS-SA3TR | PCG-32 | NTT DOCOMO | Rel-14 | SP-62 | New TR 33.916; 33.216 | Alf Zugenmaier (alf.zugenmaier@hm.edu) | Mirko |  |  |
| 404 | 138 | **Addition of Power Class 1 UE to bands B3/B20/B28 for LTE** | 130d? | 2016-09-15 | 2017-03-15 |  |  |  |  |  | 283d |  | R4 | 2080h |  | LTE_HPUE_B3_B20_B28 | PCG-37 | Motorola Solutions | Rel-14 | TSG-73 |  |  |  |  |  |
| 405 | 138.1 | Core part: Addition of Power Class 1 UE to bands B3/B20/B28 for LTE | 130d? | 2016-09-15 | 2017-03-15 |  |  |  |  |  | 283d | finish no earlier than 2017-03-15 | R4 | 1040h |  | LTE_HPUE_B3_B20_B28-Core | PCG-37 | Motorola Solutions | Rel-14 | TSG-73 |  |  |  |  |  |

Notes:
- 382: follow-up WI of SI FS_LTE_B41_HPUE
- 383: follow-up WI of SI FS_LTE_B41_HPUE; 26/9/16: Compl:0%->80%
- 384: 26/9/16: Compl:0%->80%
- 386: Triggered by Rel-11 TR 37.902 Study on Measurements of radio performances for LTE terminals - TRP and TRS test methodology (FS_LTE_OTA) UID_550022
- 387: ; CD:Wed 18/03/15->Sun 15/03/15; Rel-12->Rel-13; Stat Rep: RP-141158->RP-141973 1st Apr 15: Compl:35%->40% 1st Apr 15: Stat Rep: RP-141973->RP-150104 03/07/15: Stat Rep: RP-150104->RP-150615 29/09/15: Compl:40%->50% 29/09/15: Stat Rep: RP-150615->RP-15...; ; ; ; ; ; ; ; ; ; ; ; ; ; ; ; ; ; ; ; ; ; ; ; ; ; ; ; ; ; ; ; ; ; ; ; ; ; ; ; ; ; 26/9/16: Compl:50%->60%
- 388: Stat Rep: RP-141132->RP-141848; Rel 12->Rel13 1st Apr 15: Compl:15%->20% 1st Apr 15: CD:Mon 15/06/15->Wed 15/06/16 1st Apr 15: WID: RP-140090->RP-150070 1st Apr 15: Stat Rep: RP-141848->RP-150069 03/07/15: Compl:20%->25% 03/07/15: Stat Rep: RP-150069->...; ; ; ; ; ; ; ; ; ; ; ; ; ; ; ; ; ; ; ; ; ; ; ; ; ; ; ; ; ; ; ; ; ; ; ; ; ; ; ; ; ; ; ; ; ; ; ; ; ; ; ; ; ; ; ; ; ; ; ; ; ; ; ; ; ; ; ; ; ; ; ; ; ; ; ; ; ; ; ; ; ; ; ; ; ; ; ; ; ; ; ; ; ; ; ; ; ; ; ; ; ; ; ; ; 26/9/16: Compl:75%->77%; ; ; ; ; ; ; ; ; ; ; ; ; ; ; ; ; ; ; ; ; ; ; ; ; ; ; ; ; ; ; ; ; ; ; ; ; ; ; ; ; ; ; ; ; ; ; ; ; ; ; ; ; ; ; ; ; ; ; ; ; ; ; ; ; ; ; ; ; ; ; ; ; ; ; ; ; ; ; ; ; ; ; ; ; ; ; ; ; ; ; ; ; ; ; ; ; ; ; ; ; ; ; ; ; 26/9/16: CD:Thu 15/09/16->Wed 15/03/17
- 389: no Perf. part; DECOR was a REL-13 SA2 feature
- 390: no Perf. part; DECOR was a REL-13 SA2 feature; 26/9/16: Compl:0%->100%...
- 392: 26/9/16: Compl:0%->30%
- 395: Mar 15: 0->5%; June2015: Compl:0%->40; 07/09/15: 40%->50; 14/09/15: WID:SP-140784->SP-150405; 7/12/15: 50%->75; 7/12/15: WID:SP-150405->SP-150676 ; 7/3/16: 75%->100. 22/3/16: FCD: 09/15->03/16. Rel-13->Rel-14
- 398: 1/7/16: Compl:0%->60%26/9/16: Compl:60%->100%
- 400: Triggered by Rel-12 TR 33.805 Study on Security Assurance Methodology for 3GPP Network Elements (FS_SECAM); June2015: WID:SP-130718->SP-150292. Aug 15: TR numb added; 28/1/16: 33.926 added;; 28/7/16: 33.250 added;06/10/16: moved to Rel-14 as per John/Mir
- 401: This TR collects input for the new TS 33.116. Dec.14: 55->70%. 3/3/15: 70->55%. 10/03/15: 55->75%; June2015: Compl:75%->80; 7/12/15: STOPPED AT 80% (marked as 100% here since no more work expected)
- 402: This TS contains results of the first WID objective; June2015: Compl:0%->5; 7/12/15: 5%->72.; 10/12/15: WID:SP-130718->SP-150716; 7/3/16: 72%->75; 28/7/16: 33.250 added;; 19/9/16: 75%->90. FCD set to 12.16 (was 03/16)
- 403: This TR contains results of the second WID objective. Dec.14: 75->85%; June2015: Compl:85%->90; 7/12/15: 90%->92; 10/12/15: WID:SP-130718->SP-150716; 19/9/16: 92%->98. FCD set to 12.16 (was 03/16); 6/10/16: 33.216 added;; 1/12/16: 81%->100

| ID | WBS | Task | Duration | Start | Finish | Complete | Remaining | Baseline start | Baseline finish | Baseline duration | Total slack | Constraint | Resources | Work | Actual work | Acronym | PCG approved | WI rapporteur name | Release | TSG approved | MCC resp | Special Focus Doc | Acronym_3GU_Export | Impacted TSs and TRs |
| --- | --- | --- | --- | --- | --- | --- | --- | --- | --- | --- | --- | --- | --- | --- | --- | --- | --- | --- | --- | --- | --- | --- | --- | --- |
| 406 | 139 | **4 receiver (RX) antenna ports with Carrier Aggregation (CA) for LTE downlink (DL)** | 262d? | 2016-09-15 | 2017-09-15 |  |  |  |  |  | 151d |  | R4 | 4720h |  | LTE_4Rx_AP_DL_CA | PCG-37 | Ericsson | Rel-14 | TSG-73 |  |  |  |  |
| 407 | 139.1 | Core part: 4 receiver (RX) antenna ports with Carrier Aggregation (CA) for LTE downlink (DL) | 66d? | 2016-09-15 | 2016-12-15 |  |  |  |  |  | 347d | finish no earlier than 2016-12-15 | R4 | 528h |  | LTE_4Rx_AP_DL_CA-Core | PCG-37 | Ericsson | Rel-14 | TSG-73 |  |  |  |  |
| 408 | 139.2 | Perf. part: 4 receiver (RX) antenna ports with Carrier Aggregation (CA) for LTE downlink (DL) | 262d? | 2016-09-15 | 2017-09-15 |  |  |  |  |  | 151d | finish no earlier than 2017-09-15 | R4 | 2096h |  | LTE_4Rx_AP_DL_CA-Perf | PCG-37 | Ericsson | Rel-14 | TSG-73 |  |  |  |  |
| 409 | 140 | **Requirements for a new UE category with single receiver based on Category 1 for LTE** | 196d? | 2016-09-15 | 2017-06-15 |  |  |  |  |  | 217d |  | R4 | 3664h |  | LTE_UE_cat_1RX | PCG-37 | Qualcomm | Rel-14 | TSG-73 |  |  |  |  |
| 410 | 140.1 | Core part: Requirements for a new UE category with single receiver based on Category 1 for LTE | 66d? | 2016-09-15 | 2016-12-15 |  |  |  |  |  | 347d | finish no earlier than 2016-12-15 | R4 | 528h |  | LTE_UE_cat_1RX-Core | PCG-37 | Qualcomm | Rel-14 | TSG-73 |  |  |  |  |
| 411 | 140.2 | Perf. part: Requirements for a new UE category with single receiver based on Category 1 for LTE | 196d? | 2016-09-15 | 2017-06-15 |  |  |  |  |  | 217d | finish no earlier than 2017-06-15 | R4 | 1568h |  | LTE_UE_cat_1RX-Perf | PCG-37 | Qualcomm | Rel-14 | TSG-73 |  |  |  |  |
| 412 | 141 | **Enhanced LTE WLAN Radio Level Integration with IPsec Tunnel (eLWIP)** | 130d? | 2016-09-15 | 2017-03-15 |  |  |  |  |  | 283d |  | R3 | 2080h |  | LTE_WLAN_eLWIP | PCG-37 | Nokia | Rel-14 | TSG-73 |  |  |  |  |
| 413 | 141.1 | Core part: Enhanced LTE WLAN Radio Level Integration with IPsec Tunnel (eLWIP) | 130d? | 2016-09-15 | 2017-03-15 |  |  |  |  |  | 283d | finish no earlier than 2017-03-15 | R3 | 1040h |  | LTE_WLAN_eLWIP-Core | PCG-37 | Nokia | Rel-14 | TSG-73 |  |  |  |  |
| 414 | 142 | (Small) Technical Enhancements and Improvements for Rel-14 | 29d? | 2015-05-11 A | 2015-06-18 A | 100% |  |  |  |  |  | start no earlier than 2015-05-11 | SP; CP; RP; R4 | 928h | 928h | TEI14 | PCG-35 |  | Rel-14 | SP-68 |  |  |  |  |
| 415 | 143 | **Rel-14 LTE Carrier Aggregation** | 131d? | 2015-09-15 A | 2016-03-15 | 90% | 13.09d? | 2014-03-06 | 2015-06-12 | 332d? | 545d |  | R4 | 9968h | 8897.13h | LTE_CA_Rel14 | PCG-30 |  | Rel-14 | RP-58 | Issam | CA | LTE_CA_Rel-13 |  |
| 416 | 143.1 | **LTE Advanced 4 Band Carrier Aggregation (4DL/1UL) of Band 4, Band 5, Band 12 and Band 12** | 131d? | 2015-09-15 A | 2016-03-15 | 90% | 13.09d? |  |  |  | 545d |  | R4 | 3144h | 2829.72h | LTE_CA_B4_B5_B12_B12 | PCG-35 | US Cellular | Rel-14 | RP-69 |  |  |  |  |
| 417 | 143.1.1 | Core part: LTE Advanced 4 Band Carrier Aggregation (4DL/1UL) of Band 4, Band 5, Band 12 and Band 12 | 131d? | 2015-09-15 A | 2016-03-15 | 90% | 13.1d? |  |  |  | 545d | finish no earlier than 2016-03-15 | R4 | 1048h | 943.2h | LTE_CA_B4_B5_B12_B12-Core | PCG-35 | US Cellular | Rel-14 | RP-69 |  |  |  |  |
| 418 | 143.1.2 | Perf. part: LTE Advanced 4 Band Carrier Aggregation (4DL/1UL) of Band 4, Band 5, Band 12 and Band 12 | 131d? | 2015-09-15 A | 2016-03-15 | 90% | 13.1d? |  |  |  | 545d | finish no earlier than 2016-03-15 | R4 | 1048h | 943.2h | LTE_CA_B4_B5_B12_B12-Perf | PCG-35 | US Cellular | Rel-14 | RP-69 |  |  |  |  |
| 419 | 143.2 | **LTE Advanced 4 Band Carrier Aggregation (4DL/1UL) of Band 4, Band 4, Band 12 and Band 12** | 131d? | 2015-09-15 A | 2016-03-15 | 90% | 13.09d? |  |  |  | 545d |  | R4 | 3144h | 2829.72h | LTE_CA_B4_B4_B12_B12 | PCG-35 | US Cellular | Rel-14 | RP-69 |  |  |  |  |
| 420 | 143.2.1 | Core part: LTE Advanced 4 Band Carrier Aggregation (4DL/1UL) of Band 4, Band 4, Band 12 and Band 12 | 131d? | 2015-09-15 A | 2016-03-15 | 90% | 13.1d? |  |  |  | 545d | finish no earlier than 2016-03-15 | R4 | 1048h | 943.2h | LTE_CA_B4_B4_B12_B12-Core | PCG-35 | US Cellular | Rel-14 | RP-69 |  |  |  |  |
| 421 | 143.2.2 | Perf. part: LTE Advanced 4 Band Carrier Aggregation (4DL/1UL) of Band 4, Band 4, Band 12 and Band 12 | 131d? | 2015-09-15 A | 2016-03-15 | 90% | 13.1d? |  |  |  | 545d | finish no earlier than 2016-03-15 | R4 | 1048h | 943.2h | LTE_CA_B4_B4_B12_B12-Perf | PCG-35 | US Cellular | Rel-14 | RP-69 |  |  |  |  |
| 422 | 143.3 | **LTE Advanced 4 Band Carrier Aggregation (4DL/1UL) of Band 2, Band 4, Band 12 and Band 12** | 131d? | 2015-09-15 A | 2016-03-15 | 90% | 13.09d? |  |  |  | 545d |  | R4 | 3144h | 2829.72h | LTE_CA_B2_B4_B12_B12 | PCG-35 | US Cellular | Rel-14 | RP-69 |  |  |  |  |
| 423 | 143.3.1 | Core part: LTE Advanced 4 Band Carrier Aggregation (4DL/1UL) of Band 2, Band 4, Band 12 and Band 12 | 131d? | 2015-09-15 A | 2016-03-15 | 90% | 13.1d? |  |  |  | 545d | finish no earlier than 2016-03-15 | R4 | 1048h | 943.2h | LTE_CA_B2_B4_B12_B12-Core | PCG-35 | US Cellular | Rel-14 | RP-69 |  |  |  |  |
| 424 | 143.3.2 | Perf. part: LTE Advanced 4 Band Carrier Aggregation (4DL/1UL) of Band 2, Band 4, Band 12 and Band 12 | 131d? | 2015-09-15 A | 2016-03-15 | 90% | 13.1d? |  |  |  | 545d | finish no earlier than 2016-03-15 | R4 | 1048h | 943.2h | LTE_CA_B2_B4_B12_B12-Perf | PCG-35 | US Cellular | Rel-14 | RP-69 |  |  |  |  |
| 425 | 144 | **Rel-14 LTE Advanced inter-band Carrier Aggregation** | 589d? | 2015-12-15 A | 2018-03-15 | 32% | 402.52d? | 2014-03-06 | 2015-06-12 | 332d? | 22d |  | R4 | 70840h | 22050.4h | LTE_AIBCA_Rel14 | PCG-30 |  | Rel-14 | RP-58 | Issam | CA | LTE_CA_Rel-13 |  |
| 426 | 144.1 | **LTE Advanced inter-band Carrier Aggregation Rel-14 for 5DL/1UL** | 328d? | 2015-12-15 A | 2017-03-15 | 30% | 229.6d? |  |  |  | 283d |  | R4 | 7872h | 2361.59h | LTE_CA_R14_5DL1UL | PCG-36 | Nokia Networks | Rel-14 | RP-70 |  |  |  |  |
| 427 | 144.1.1 | Core part: LTE Advanced inter-band Carrier Aggregation Rel-14 for 5DL/1UL | 328d? | 2015-12-15 A | 2017-03-15 | 60% | 131.2d? |  |  |  | 283d | finish no earlier than 2017-03-15 | R4 | 2624h | 1574.4h | LTE_CA_R14_5DL1UL-Core | PCG-36 | Nokia Networks | Rel-14 | RP-70 |  |  |  | 36.714-05-01 |
| 428 | 144.1.2 | Perf. part: LTE Advanced inter-band Carrier Aggregation Rel-14 for 5DL/1UL | 328d? | 2015-12-15 | 2017-03-15 |  |  |  |  |  | 283d | finish no earlier than 2017-03-15 | R4 | 2624h |  | LTE_CA_R14_5DL1UL-Perf | PCG-36 | Nokia Networks | Rel-14 | RP-70 |  |  |  |  |
| 429 | 144.2 | **LTE Advanced inter-band Carrier Aggregation Rel-14 for 2DL/1UL** | 328d? | 2015-12-15 A | 2017-03-15 | 50% | 164d? |  |  |  | 283d |  | R4 | 7872h | 3936h | LTE_CA_R14_2DL1UL | PCG-36 | Qualcomm | Rel-14 | RP-70 |  |  |  |  |
| 430 | 144.2.1 | Core part: LTE Advanced inter-band Carrier Aggregation Rel-14 for 2DL/1UL | 328d? | 2015-12-15 A | 2017-03-15 | 50% | 164d? |  |  |  | 283d | finish no earlier than 2017-03-15 | R4 | 2624h | 1312h | LTE_CA_R14_2DL1UL-Core | PCG-36 | Qualcomm | Rel-14 | RP-70 |  |  |  | 36.714-02-01 |
| 431 | 144.2.2 | Perf. part: LTE Advanced inter-band Carrier Aggregation Rel-14 for 2DL/1UL | 328d? | 2015-12-15 A | 2017-03-15 | 50% | 164d? |  |  |  | 283d | finish no earlier than 2017-03-15 | R4 | 2624h | 1312h | LTE_CA_R14_2DL1UL-Perf | PCG-36 | Qualcomm | Rel-14 | RP-70 |  |  |  |  |

Notes:
- 415: Acronym changed from "LTE_CA_Rel-13" to "LTE_CA_Rel13"
- 425: Acronym changed from "LTE_CA_Rel-13" to "LTE_CA_Rel13"
- 427: 28/1/16: 36.714-05-01 added;; 22/3/16: Compl:0%->15%; 22/3/16: WID: RP-151671->RP-1606151/7/16: Compl:15%->40%...; 26/9/16: Compl:40%->60%...
- 428: 22/3/16: WID: RP-151671->RP-1606151/7/16: WID: RP-160615->RP-16105226/9/16: WID: RP-161052->RP-161496
- 430: 28/1/16: 36.714-02-01 added;; 22/3/16: Compl:0%->20%; 22/3/16: WID: RP-152196->RP-160616; 1/7/16: Compl:20%->30%; 1/7/16: WI...26/9/16: Compl:30%->50%; ...
- 431: 22/3/16: WID: RP-152196->RP-1606161/7/16: Compl:0%->30%1/7/16: WID: RP-160616->RP-161202; 26/9/16: Compl:30%->50%;...

| ID | WBS | Task | Duration | Start | Finish | Complete | Remaining | Baseline start | Baseline finish | Baseline duration | Total slack | Constraint | Resources | Work | Actual work | Acronym | PCG approved | WI rapporteur name | Release | TSG approved | Impacted TSs and TRs | WI rapporteur e-mail | MCC resp | Status Report | Acronym_3GU_Export | Special Focus Doc |
| --- | --- | --- | --- | --- | --- | --- | --- | --- | --- | --- | --- | --- | --- | --- | --- | --- | --- | --- | --- | --- | --- | --- | --- | --- | --- | --- |
| 432 | 144.3 | **LTE Advanced inter-band Carrier Aggregation Rel-14 for 2DL/2UL** | 328d? | 2015-12-15 A | 2017-03-15 | 30% | 229.6d? |  |  |  | 283d |  | R4 | 7872h | 2361.59h | LTE_CA_R14_2DL2UL | PCG-36 | Huawei | Rel-14 | RP-70 |  |  |  |  |  |  |
| 433 | 144.3.1 | Core part: LTE Advanced inter-band Carrier Aggregation Rel-14 for 2DL/2UL | 328d? | 2015-12-15 A | 2017-03-15 | 60% | 131.2d? |  |  |  | 283d | finish no earlier than 2017-03-15 | R4 | 2624h | 1574.4h | LTE_CA_R14_2DL2UL-Core | PCG-36 | Huawei | Rel-14 | RP-70 | 36.714-02-02 |  |  |  |  |  |
| 434 | 144.3.2 | Perf. part: LTE Advanced inter-band Carrier Aggregation Rel-14 for 2DL/2UL | 328d? | 2015-12-15 | 2017-03-15 |  |  |  |  |  | 283d | finish no earlier than 2017-03-15 | R4 | 2624h |  | LTE_CA_R14_2DL2UL-Perf | PCG-36 | Huawei | Rel-14 | RP-70 |  |  |  |  |  |  |
| 435 | 144.4 | **LTE Advanced inter-band Carrier Aggregation Rel-14 for 3DL/3UL** | 328d? | 2015-12-15 A | 2017-03-15 | 15% | 278.81d? |  |  |  | 283d |  | R4 | 7872h | 1180.72h | LTE_CA_R14_3DL3UL | PCG-36 | Nokia Networks | Rel-14 | RP-70 |  |  |  |  |  |  |
| 436 | 144.4.1 | Core part: LTE Advanced inter-band Carrier Aggregation Rel-14 for 3DL/3UL | 328d? | 2015-12-15 A | 2017-03-15 | 15% | 278.8d? |  |  |  | 283d | finish no earlier than 2017-03-15 | R4 | 2624h | 393.6h | LTE_CA_R14_3DL3UL-Core | PCG-36 | Nokia Networks | Rel-14 | RP-70 | 36.714-03-03 |  |  |  |  |  |
| 437 | 144.4.2 | Perf. part: LTE Advanced inter-band Carrier Aggregation Rel-14 for 3DL/3UL | 328d? | 2015-12-15 A | 2017-03-15 | 15% | 278.8d? |  |  |  | 283d | finish no earlier than 2017-03-15 | R4 | 2624h | 393.6h | LTE_CA_R14_3DL3UL-Perf | PCG-36 | Nokia Networks | Rel-14 | RP-70 |  |  |  |  |  |  |
| 438 | 144.5 | **LTE Advanced inter-band Carrier Aggregation Rel-14 for xDL/2UL with x=3,4,5** | 328d? | 2015-12-15 A | 2017-03-15 | 35% | 213.2d? |  |  |  | 283d |  | R4 | 7872h | 2755.16h | LTE_CA_R14_xDL2UL | PCG-36 | LG Electronics | Rel-14 | RP-70 |  |  |  |  |  |  |
| 439 | 144.5.1 | Core part: LTE Advanced inter-band Carrier Aggregation Rel-14 for xDL/2UL with x=3,4,5 | 328d? | 2015-12-15 A | 2017-03-15 | 70% | 98.4d? |  |  |  | 283d | finish no earlier than 2017-03-15 | R4 | 2624h | 1836.8h | LTE_CA_R14_xDL2UL-Core | PCG-36 | LG Electronics | Rel-14 | RP-70 | 36.714-00-02 |  |  |  |  |  |
| 440 | 144.5.2 | Perf. part: LTE Advanced inter-band Carrier Aggregation Rel-14 for xDL/2UL with x=3,4,5 | 328d? | 2015-12-15 | 2017-03-15 |  |  |  |  |  | 283d | finish no earlier than 2017-03-15 | R4 | 2624h |  | LTE_CA_R14_xDL2UL-Perf | PCG-36 | LG Electronics | Rel-14 | RP-70 |  |  |  |  |  |  |
| 441 | 144.6 | **LTE Advanced inter-band Carrier Aggregation Rel-14 for 4DL/1UL** | 328d? | 2015-12-15 A | 2017-03-15 | 37% | 206.64d? |  |  |  | 283d |  | R4 | 7872h | 2912.62h | LTE_CA_R14_4DL1UL | PCG-36 | Ericsson | Rel-14 | RP-70 |  |  |  |  |  |  |
| 442 | 144.6.1 | Core part: LTE Advanced inter-band Carrier Aggregation Rel-14 for 4DL/1UL | 328d? | 2015-12-15 A | 2017-03-15 | 74% | 85.28d? |  |  |  | 283d | finish no earlier than 2017-03-15 | R4 | 2624h | 1941.76h | LTE_CA_R14_4DL1UL-Core | PCG-36 | Ericsson | Rel-14 | RP-70 | 36.714-04-01 |  |  |  |  |  |
| 443 | 144.6.2 | Perf. part: LTE Advanced inter-band Carrier Aggregation Rel-14 for 4DL/1UL | 328d? | 2015-12-15 | 2017-03-15 |  |  |  |  |  | 283d | finish no earlier than 2017-03-15 | R4 | 2624h |  | LTE_CA_R14_4DL1UL-Perf | PCG-36 | Ericsson | Rel-14 | RP-70 |  |  |  |  |  |  |
| 444 | 144.7 | **LTE Advanced intra-band Carrier Aggregation for xDL/yUL including contiguous and non-contiguous spectrum** | 328d? | 2015-12-15 A | 2017-03-15 | 47% | 173.84d? |  |  |  | 283d |  | R4 | 7872h | 3699.85h | LTE_CA_R14_intra | PCG-36 | Ericsson | Rel-14 | RP-70 |  |  |  |  |  |  |
| 445 | 144.7.1 | Core part: LTE Advanced intra-band Carrier Aggregation for xDL/yUL including contiguous and non-contiguous spectrum | 328d? | 2015-12-15 A | 2017-03-15 | 44% | 183.68d? |  |  |  | 283d | finish no earlier than 2017-03-15 | R4 | 2624h | 1154.56h | LTE_CA_R14_intra-Core | PCG-36 | Ericsson | Rel-14 | RP-70 | 36.714-00-00 |  |  |  |  |  |
| 446 | 144.7.2 | Perf. part: LTE Advanced intra-band Carrier Aggregation for xDL/yUL including contiguous and non-contiguous spectrum | 328d? | 2015-12-15 A | 2017-03-15 | 50% | 164d? |  |  |  | 283d | finish no earlier than 2017-03-15 | R4 | 2624h | 1312h | LTE_CA_R14_intra-Perf | PCG-36 | Ericsson | Rel-14 | RP-70 |  |  |  |  |  |  |
| 447 | 144.8 | **LTE Advanced inter-band Carrier Aggregation Rel-14 for 3DL/1UL** | 328d? | 2015-12-15 A | 2017-03-15 | 30% | 229.6d? |  |  |  | 283d |  | R4 | 7872h | 2361.59h | LTE_CA_R14_3DL1UL | PCG-36 | Huawei | Rel-14 | RP-70 |  |  |  |  |  |  |
| 448 | 144.8.1 | Core part: LTE Advanced inter-band Carrier Aggregation Rel-14 for 3DL/1UL | 328d? | 2015-12-15 A | 2017-03-15 | 60% | 131.2d? |  |  |  | 283d | finish no earlier than 2017-03-15 | R4 | 2624h | 1574.4h | LTE_CA_R14_3DL1UL-Core | PCG-36 | Huawei | Rel-14 | RP-70 | 36.714-03-01 |  |  |  |  |  |
| 449 | 144.8.2 | Perf. part: LTE Advanced inter-band Carrier Aggregation Rel-14 for 3DL/1UL | 328d? | 2015-12-15 | 2017-03-15 |  |  |  |  |  | 283d | finish no earlier than 2017-03-15 | R4 | 2624h |  | LTE_CA_R14_3DL1UL-Perf | PCG-36 | Huawei | Rel-14 | RP-70 |  |  |  |  |  |  |
| 450 | 144.9 | UE Conformance Test Aspects – Rel-14 CA configurations | 458d? | 2016-06-15 A | 2018-03-15 | 2% | 448.84d? |  |  |  | 22d | finish no earlier than 2018-03-15 | R5 | 3664h | 73.28h | LTE_CA_R14-UEConTest | PCG-37 | Ericsson | Rel-14 | TSG#72 |  |  |  |  |  |  |
| 451 | 145 | Release 14 Studies | 323d? | 2014-09-17 A | 2015-12-11 A | 100% |  |  |  |  |  | finish no earlier than 2015-12-11 | SP; RP; CP; GP | 10336h | 10336h |  |  |  | Rel-14 |  |  |  |  |  |  |  |
| 452 | 146 | Study on NB-IoT RF requirement for coexistence with CDMA | 133d? | 2016-06-15 A | 2016-12-15 | 35% | 86.45d? |  |  |  | 347d | finish no earlier than 2016-12-15 | R4 | 1064h | 372.4h | FS_NB_IOT_CDMA_coex | PCG-37 | China Telecom | Rel-14 | TSG#72 | 36.752 |  |  |  |  |  |
| 453 | 147 | Study on need for Multiple Access Point Names | 464d? | 2013-09-12 A | 2015-06-19 A | 100% |  | 2013-09-12 | 2014-12-10 | 327d? |  | finish no earlier than 2015-06-19 | S1 | 3704h | 3704h | FS_MAPN | PCG-31 | Giesecke & Devrient | Rel-14 | SP-61 | 22.802 | Ilario.macchi@gi-de.com | Alain | S1-143308 | FS_MAPN |  |
| 454 | 148 | Study on Multimedia Broadcast Supplement for Public Warning System | 264d? | 2013-12-11 A | 2014-12-12 A | 100% |  | 2013-12-11 | 2014-09-17 | 202d? |  | finish no earlier than 2014-12-12 | S1 | 2104h | 2104h | FS_MBSP | PCG-32 | Qualcomm | Rel-14 | SP-62 | 22.815 | Eddy Hall (edhall@qti.qualcomm.com) | Alain | S1-143312 | FS_MBSP | Public Safety (I-A) |
| 455 | 149 | Study on service aspects for dealing with User Control over spoofed calls | 271d? | 2014-03-07 A | 2015-03-20 A | 100% |  | 2014-03-07 | 2014-12-10 | 199d? |  | finish no earlier than 2015-03-20 | S1 | 2168h | 2168h | FS_UC_SPOOF | PCG-32 | Sprint | Rel-14 | SP-63 | 22.898 | Gregory.schumacher@sprint.com | Alain | S1-143314 | FS_UC_SPOOF |  |
| 456 | 150 | Study on User Location Reporting Support enhancements | 261d? | 2014-06-19 A | 2015-06-17 A | 100% |  | 2014-06-18 | 2015-06-17 | 261d? |  | finish no earlier than 2015-06-17 | S1 | 2088h | 2088h | FS_eULRS | PCG-33 | China Unicom | Rel-14 | SP-64 | 22.899 | Zhuoyun Zhang ( zhangzy910@chinaunicom.cn) |  | S1-143315 | FS_eULRS |  |
| 457 | 151 | Study on Control of Applications when Third party Servers encounter difficulties | 259d? | 2014-06-19 A | 2015-06-15 A | 100% |  | 2014-06-18 | 2014-12-10 | 126d? |  | finish no earlier than 2015-06-15 | S1 | 2072h | 2072h | FS_CATS | PCG-33 | KDDI | Rel-14 | SP-64 | 22.818 | Eriko Yoshida (er-yoshida@kddi.com) |  | S1-143316 | FS_CATS |  |
| 458 | 152 | Study on Paging Policy Enhancements and Procedure Optimizations in LTE | 176d? | 2015-04-14 A | 2015-12-15 A | 100% |  |  |  |  |  | finish no earlier than 2015-12-15 | S1 | 1408h | 1408h | FS_PPEPO_LTE | PCG-34 | Zhuoyun Zhang (China Unicom) | Rel-14 | SP-67 | New TR 22.838 | zhangzy910@chinaunicom.cn |  |  |  |  |
| 459 | 153 | Study on Overload Control for Diameter Charging Applications | 457d? | 2015-06-18 A | 2017-03-16 | 10% | 411.3d? |  |  |  | 282d | finish no earlier than 2017-03-16 | S5 | 3656h | 365.6h | FS_DOCME_CH | PCG-35 | GUO Wenjie, ZTE | Rel-14 | SP-68 | New TR 32.869 | guo.wenjie1@zte.com.cn |  |  |  |  |
| 460 | 154 | Study on forward compatibility for 3GPP Diameter Charging Applications | 194d? | 2016-09-19 A | 2017-06-15 | 10% | 174.6d? |  |  |  | 217d | finish no earlier than 2017-06-15 | S5 | 1552h | 155.2h | FS_FWDCA | PCG-37 | Nokia, Maryse <dot> Gardella <at> Nokia <dot> com | Rel-14 | TSG-73 | 32.870 | Nokia, Maryse <dot> Gardella <at> Nokia <dot> com |  |  |  |  |
| 461 | 155 | Study on Latency reduction techniques for LTE | 328d? | 2015-03-16 A | 2016-06-15 A | 100% |  |  |  |  |  | finish no earlier than 2016-06-15 | R2 | 2624h | 2624h | FS_LTE_LATRED | PCG-34 | Ericsson | Rel-14 | RP-67 | 36.881 |  |  | RP-151286 |  |  |
| 462 | 156 | Study on High Power LTE UE for Band 41 | 263d? | 2015-06-15 A | 2016-06-15 A | 100% |  |  |  |  |  | finish no earlier than 2016-12-15 | R4 | 2104h | 2104h | FS_LTE_B41_HPUE | PCG-35 | Sprint | Rel-14 | TSG-68 | 36.886 |  |  | RP-151436 |  |  |
| 463 | 157 | Study on channel model for frequency spectrum above 6 GHz | 197d? | 2015-09-15 A | 2016-06-15 A | 100% |  |  |  |  |  | finish no earlier than 2016-06-15 | R1 | 1576h | 1576h | FS_6GHz_CH_model | PCG-35 | Samsung | Rel-15 | RP-69 | 38.900 |  |  |  |  |  |
| 464 | 158 | Study on Media and Quality Aspects of SRVCC Enhancements | 192d? | 2015-06-18 A | 2016-03-11 A | 100% |  |  |  |  |  | finish no earlier than 2016-03-11 | S4 | 1536h | 1536h | FS_SETA_S4 | PCG-35 | Frédéric Gabin, Ericsson LM | Rel-14 | CP-68 | New TR 26.9xx, TS 26.114 | frederic . gabin @ ericsson . com |  |  |  |  |
| 465 | 159 | Study on OAM support for assessment of energy efficiency in mobile access networks | 359d? | 2015-11-02 A | 2017-03-15 | 80% | 71.8d? |  |  |  | 283d | finish no earlier than 2017-03-15 | S5 | 2872h | 2297.6h | FS_OAM_EE | PCG-36 | Cornily,Jean-Michel, ORANGE | Rel-14 | SP-70 | TR 32.856 | jeanmichel.cornily@orange.com |  |  |  |  |
| 466 | 160 | Study on OAM aspects of SON for AAS-based deployments | 356d? | 2015-11-02 A | 2017-03-12 | 70% | 106.8d? |  |  |  | 286d | finish no earlier than 2017-03-12 | S5 | 2848h | 1993.6h | FS_OAM_SON_AAS | PCG-36 | Nokia Networks (Yizhi Yao) | Rel-14 | SP-70 | TR (new) | Yizhi.yao@nokia.com |  |  |  |  |
| 467 | 161 | Study on SON for eCoMP for LTE | 197d? | 2016-06-15 A | 2017-03-15 | 10% | 177.3d? |  |  |  | 283d | finish no earlier than 2017-03-15 | R3 | 1576h | 157.6h | FS_LTE_SON_eCOMP | PCG-37 | Nokia | Rel-14 | TSG#72 |  |  |  |  |  |  |
| 468 | 162 | Deleted - Study on SON for eCoMP for LTE | 3d? | 2016-06-14 A | 2016-06-16 A | 100% |  |  |  |  |  | start no earlier than 2016-06-14 | R3 | 24h | 24h | delFS_LTE_SON_eCOMP | PCG-37 | Nokia | Rel-14 | SP-72 | 23.228, 23.237 |  |  |  |  |  |
| 469 | 163 | Study on UICC power optimization for MTC | 133d? | 2016-06-15 A | 2016-12-15 | 71% | 38d? |  |  |  | 347d |  | C6 | 1064h | 760h | FS_UICC_MTC_OPT | PCG-36 | Berionne, Michele | Rel-14 | CP-70 | 31.970 | micheleb [at] qti [dot] qualcomm [dot] com |  |  |  |  |
| 470 | 164 | Study on Implementation for the Partitioning of Itf-N | 263d? | 2016-03-01 A | 2017-03-01 | 40% | 157.8d? |  |  |  | 293d | start no earlier than 2016-03-01 | S5 | 2104h | 841.6h | FS_IMP_ITFN | PCG-36 | Hu, Yaxi, China Mobile | Rel-14 | TSG#71 | New TR 32.880 | huyaxi@cmdi.chinamobile.com |  |  |  |  |
| 471 | 165 | Study on Server and Network Assisted DASH for 3GPP | 209d? | 2016-03-01 A | 2016-12-15 A | 100% |  |  |  |  |  | finish no earlier than 2016-12-15 | S4 | 1672h | 1672h | FS_SAND | PCG-36 | Ozgur Oyman, Intel | Rel-14 | TSG#71 | TR26.957 | ozgur.oyman@intel.com |  |  |  |  |
| 472 | 166 | Study on Virtual Reality | 336d? | 2016-03-01 A | 2017-06-12 | 35% | 218.4d? |  |  |  | 220d | finish no earlier than 2017-06-12 | S4 | 2688h | 940.8h | FS_VR | PCG-36 | Gilles TENIOU, Orange | Rel-14 | TSG#71 | TR 26.918 | gilles.teniou@orange.com |  |  |  |  |
| 473 | 167 | Study on UE characteristics and performance for Video | 339d? | 2016-03-01 A | 2017-06-15 | 30% | 237.3d? |  |  |  | 217d | finish no earlier than 2017-06-15 | S4 | 2712h | 813.6h | FS_UE_VTPerf | PCG-36 | Stéphane PROUST, Orange | Rel-14 | TSG#71 | TR 26.932 | stephane.proust@orange.com |  |  |  |  |
| 474 | 168 | Study on MBMS usage for mission critical communication services | 209d? | 2016-03-01 A | 2016-12-15 | 95% | 10.45d? |  |  |  | 347d | finish no earlier than 2016-12-15 | S6 | 1672h | 1588.4h | FS_MBMS_MCservices | PCG-36 | Magnus Tränk, Ericsson LM | Rel-14 | TSG#71 | TR 23.780 | magnus.trank@ericsson.com |  |  |  |  |
| 475 | 169 | Study on Enhanced Isolated E-UTRAN Operation for Public Safety | 205d? | 2016-03-07 A | 2016-12-15 A | 100% |  |  |  |  |  | finish no earlier than 2016-12-15 | S2 | 1640h | 1640h | FS_IOPS_LB | PCG-36 | Antoine Mouquet, Orange | Rel-14 | TSG#71 | 23.798 | antoine.mouquet@orange.com |  |  |  |  |
| 476 | 170 | Study on Energy Efficiency Aspects of 3GPP Standards | 201d? | 2016-03-11 | 2016-12-15 |  |  |  |  |  | 347d | finish no earlier than 2016-12-15 | SP | 1608h |  | FS_ENEFF | PCG-36 | Orange, Xiaobao Chen | Rel-14 | TSG#71 | TR 21.866 | xiaobao.chen@orange.com |  |  |  |  |
| 477 | 171 | Study on enhancement of VoLTE | 134d? | 2016-03-15 A | 2016-09-15 A | 100% |  |  |  |  |  | finish no earlier than 2016-09-15 | R2 | 1072h | 1072h | FS_LTE_eVoLTE | PCG-36 | CMCC | Rel-14 | TSG#71 | 36.750 |  |  |  |  |  |
| 478 | 172 | Study on HSPA and LTE Joint Operation | 199d? | 2016-03-15 A | 2016-12-15 | 80% | 39.8d? |  |  |  | 347d | finish no earlier than 2016-12-15 | R3 | 1592h | 1273.6h | FS_UTRA_LTE_JOP | PCG-36 | China Unicom | Rel-14 | TSG#71 | New 37.805 |  |  |  |  |  |
| 479 | 173 | Study on LTE Advanced Carrier Aggregation of Band 3 and Band 39 | 263d? | 2016-03-15 A | 2017-03-15 | 50% | 131.5d? |  |  |  | 283d | finish no earlier than 2017-03-15 | R4 | 2104h | 1052h | FS_LTE_CA_B3_B39 | PCG-36 | ZTE | Rel-14 | TSG#71 |  |  |  |  |  |  |
| 480 | 174 | Study on Context Aware Service Delivery in RAN for LTE | 199d? | 2016-03-15 A | 2016-12-15 | 40% | 119.4d? |  |  |  | 347d | finish no earlier than 2016-12-15 | R3 | 1592h | 636.8h | FS_LTE_context | PCG-36 | CMCC | Rel-14 | TSG#71 |  |  |  |  |  |  |
| 481 | 175 | Study on further enhancements to Coordinated Multi-Point (CoMP) Operation for LTE | 263d? | 2016-03-15 A | 2017-03-15 | 30% | 184.1d? |  |  |  | 283d | finish no earlier than 2017-03-15 | R1 | 2104h | 631.2h | FS_feCOMP_LTE | PCG-36 | Intel | Rel-14 | TSG#71 |  |  |  |  |  |  |
| 482 | 176 | Study on further enhancements to LTE Device to Device (D2D), UE to network relays for IoT (Internet of Things) and wearables | 395d? | 2016-03-15 A | 2017-09-15 | 5% | 375.25d? |  |  |  | 151d | finish no earlier than 2017-09-15 | R2 | 3160h | 158h | FS_feD2D_IoT_relay_wearable | PCG-36 | Qualcomm | Rel-15 | TSG#71 | 36.746 |  |  |  |  |  |
| 483 | 177 | Study on Determination of Completeness of Charging Information in IMS | 267d? | 2015-03-05 A | 2016-03-11 A | 100% |  |  |  |  |  | finish no earlier than 2016-03-11 | S5 | 2136h | 2136h | FS_DCCHII | PCG-34 | Jesske, Roland | Rel-14 | SP-67 | 32.xyz | r.jesske@telekom.de |  |  |  |  |
| 484 | 178 | Study on Interactivity Support for 3GPP-based Streaming and Download Services | 587d? | 2014-12-12 A | 2017-03-10 | 80% | 117.4d? |  |  |  | 286d | finish no earlier than 2017-03-10 | S4 | 4696h | 3756.8h | FS_IS3 | PCG-34 | Lo, Charles, Qualcomm | Rel-14 | SP-66 | 26.953 | clo@qti.qualcomm.com |  |  |  |  |
| 485 | 179 | Study on Enhanced Acoustic Test Specifications | 1053d? | 2013-03-18 A | 2017-03-16 | 80% | 210.6d? | 2013-03-06 | 2014-09-17 | 401d? | 282d | finish no earlier than 2017-03-16 | S4 | 8424h | 6739.2h | FS_SEATS | PCG-30 | Knowles, Intel | Rel-14 | SP-59 | 26.931 | Scott Isabelle (Knowles), David Isherwood (Intel) | Paolo |  | FS_SEATS |  |
| 486 | 180 | Study on User Services Enhancements in 3GPP for TV Services | 196d? | 2016-06-13 A | 2017-03-10 | 60% | 78.4d? |  |  |  | 286d | finish no earlier than 2017-03-10 | S4 | 1568h | 940.8h | FS_USE_3GPP_4_TV | PCG-37 | Thomas Stockhammer, Qualcomm Incorporated | Rel-14 | TSG#72 | TR 26.9xx; 26.917 | tsto@qti.qualcomm.com |  |  |  |  |
| 487 | 181 | Study on MBMS usage and codecs for MCPTT call and MC Video Service | 199d? | 2016-06-13 A | 2017-03-15 | 60% | 79.6d? |  |  |  | 283d | finish no earlier than 2017-03-15 | S4 | 1592h | 955.2h | FS_MCP_V | PCG-37 | Zhiming Li, Huawei | Rel-14 | TSG#72 | 26.880 | lizhiming@huawei.com |  |  |  |  |
| 488 | 182 | Study on MBMS Extensions for Provisioning and Content Ingestion | 196d? | 2016-06-13 A | 2017-03-10 | 50% | 98d? |  |  |  | 286d | finish no earlier than 2017-03-10 | S4 | 1568h | 784h | FS_xMBMS | PCG-37 | Kyungmo Park, Samsung Electronics Co., Ltd | Rel-14 | TSG#72 | TR 26.981 | kyungmo.park@samsung.com |  |  |  |  |
| 489 | 183 | Study on Technical Requirements for a new secure platform for 3GPP applications | 135d? | 2016-06-13 A | 2016-12-15 | 15% | 114.75d? |  |  |  | 347d | finish no earlier than 2016-12-15 | C6 | 1080h | 162h | FS_NG_SP | PCG-37 | Heiko Kruse | Rel-14 | TSG#72 | TR 31.xxx | heiko.kruse@safrangroup.com |  |  |  |  |
| 490 | 184 | Study on global application of LTE Band 11 and of LTE Band 21 UEs | 133d? | 2016-06-15 A | 2016-12-15 | 30% | 93.1d? |  |  |  | 347d | finish no earlier than 2016-12-15 | R4 | 1064h | 319.2h | FS_LTE_B11_B21_global | PCG-37 | SoftBank | Rel-14 | TSG#72 | 36.745 |  |  |  |  |  |
| 491 | 185 | Study on Downlink MIMO for GERAN | 68d? | 2016-06-15 A | 2016-09-15 A | 100% |  |  |  |  |  | finish no earlier than 2016-09-15 | R6 | 544h | 544h | FS_DOMIMO_RAN6 | PCG-37 | Nokia, Alcatel-Lucent Shanghai Bell | Rel-14 | TSG#72 |  |  |  |  |  |  |
| 492 | 186 | Release 14 studies on 5G MObile Network for Advanced communications | 490d? | 2015-02-02 A | 2016-12-15 | 72% | 135d? |  |  |  | 347d |  | S1 | 2160h | 1080h |  | PCG-34 | Adrian Neal (Vodafone) | Rel-14 | SP-67 | New TR 22.891 | adrian.neal@vodafone.com |  |  |  |  |

Notes:
- 433: 28/1/16: 36.714-02-02 added;22/3/16: Compl:0%->20%22/3/16: WID: RP-152237->RP-160192; 1/7/16: Compl:20%->40%...; 26/9/16: Compl:40%->60%; ...
- 434: ; 22/3/16: WID: RP-152237->RP-1601921/7/16: WID: RP-160192->RP-16094726/9/16: WID: RP-160947->RP-161676
- 436: 28/1/16: 36.714-03-03 added;22/3/16: Compl:0%->1%1/7/16: Compl:1%->15%
- 437: ; 1/7/16: Compl:0%->15%
- 439: 28/1/16: 36.714-00-02 added;; 22/3/16: Compl:0%->10%; 22/3/16: WID: RP-152246->RP-160148; 1/7/16: Compl:10%->40%; ...26/9/16: Compl:40%->70%; ...
- 440: 22/3/16: WID: RP-152246->RP-1601481/7/16: WID: RP-160148->RP-160748; 26/9/16: WID: RP-160748->RP-161487
- 442: 28/1/16: 36.714-04-01 added;22/3/16: Compl:0%->30%22/3/16: WID: RP-152249->RP-1606141/7/16: Compl:30%->38%; ...26/9/16: Compl:38%->74%...
- 443: ; 22/3/16: WID: RP-152249->RP-160614; 1/7/16: Compl:0%->38%; 1/7/16: WID: RP-160614->RP-16082126/9/16: Compl:38%->0%; ...
- 445: 28/1/16: 36.714-00-00 added;22/3/16: Compl:0%->60%22/3/16: WID: RP-152250->RP-160613; 1/7/16: Compl:60%->50%; 1/7/16: WID: RP-160613...; 26/9/16: Compl:50%->44%...
- 446: ; 22/3/16: WID: RP-152250->RP-1606131/7/16: Compl:0%->50%1/7/16: WID: RP-160613->RP-16082226/9/16: WID: RP-160822->RP-161473
- 448: 28/1/16: 36.714-03-01 added;22/3/16: Compl:0%->15%22/3/16: WID: RP-152278->RP-1605821/7/16: Compl:15%->40%1/7/16...26/9/16: Compl:40%->60%...
- 449: 22/3/16: WID: RP-152278->RP-160582; 1/7/16: WID: RP-160582->RP-160945; 26/9/16: WID: RP-160945->RP-161674
- 450: testing REL-14 CA basket WIs: LTE_CA_R14_intra-Core, LTE_CA_R14_2DL1UL-Core, LTE_CA_R14_3DL1UL-Core, LTE_CA_R14_4DL1UL-Core, LTE_CA_R14_5DL1UL-Core, LTE_CA_R14_2DL2UL-Core, LTE_CA_R14_xDL2UL-Core, LTE_CA_R14_3DL3UL-Core; ;...
- 451: -
- 452: ; 26/9/16: Compl:0%->35%; 6/10/16: 36.752 added;
- 453: SP#65 moved to Rel-14. Completion 12/14=>03/15. Triggered by S1-133134 LS on GSMA Connected Living Programme Request for APN Storage in the SIM. Dec.14: 50->70%, CD: 03/15->06/15. Mar.15: 90%; June2015: Compl:90%->100
- 454: SP#65 completion 09/14=>12/14. Moved to Rel-14. TR 22.815v100 for Information. Linked to Rel-9 Feature PWS. Dec.14:70->100%
- 455: SP#65 moved to Rel-14. Linked to SA3 Rel-11 TR 33.838 PUCI and Rel-12 ongoing study TR 33.831 (FS_SPOOF). Dec.14: 70->90, CD: 12/14->03/15. Mar.15: 100%
- 456: SP#65 moved to Rel-14. Linked to Rel-12 SA2 TR 23.843 Study on Core Network Overload solutions (FS_CNO) and Rel-13 Feature Service Exposure and Enablement Support (SEES). Dec.14: 30->70%. Mar.15: 90%; June2015: Compl:90%->100
- 457: SP#65 completion 12/14=>03/15. Moved to Rel-14. Linked to Rel-13 Feature SEES and Rel-13 TR 22.806 (FS_ACDC). Dec.14: 30->60%, WID SP-140246->SP-140758, CD: 12/14->03/15. Mar.15: CD: 03/13->06/15. 60->90%; June2015: Compl:90%->100
- 458: 1/4/15:TR number added; June2015: Compl:0%->40; 07/09/15: 40%->60; 7/12/15: 60%->100
- 459: Aug2015: moved to Rel-14 (email CT and EG); 07/09/15: 0%->5; 7/3/16: 5%->10; 13/6/16: FCD:03/16->09/16; 19/9/16: FCD: 09/16->06/17
- 460: 6/10/16: 32.870 added;; 1/12/16: 0%->10
- 461: 03/07/15: Compl:0%->10% 03/07/15: Stat Rep: -->RP-150780 03/07/15: Release: Rel-13->Rel-14 29/09/15: Compl:10%->25% 29/09/15: Stat Rep: RP-150780->RP-151286 22/3/16: Compl:50%->60%;...
- 462: 7/9/15: TR added 29/09/15: Compl:0%->1% 29/09/15: Stat Rep: -->RP-151436 ; 22/3/16: Compl:10%->40%; 22/3/16: WID: RP-151104->RP-1600921/7/16: Compl...
- 463: will start only in RAN in Q4/15; 28/1/16: 38.900 added;; 22/3/16: Compl:10%->20%; 22/3/16: WID: RP-151606->RP-160210; 1/7/16: Compl:20%->100%. 2/12/16: Moved to Rel-15 according JMM email to move all 38.xxx related WIDs to Rel-15
- 464: Aug2015: 0%->25; 07/09/15: 25%->30; 7/12/15: 30%->80, FCD: 12/15->03/16, MOVED TO REL-14; 7/3/16: 80%->100
- 465: 13/6/16: WID:SP-150674->SP-160430; 13/6/16: 0%->55; 1/12/16: 55%->80
- 466: 13/6/16: 0%->40; 19/9/16: FCD:09/16->12/16; 19/9/16: 40%->60; 1/12/16: FCD:12/16->03/17; 1/12/16: 60%->70
- 467: 26/9/16: Compl:0%->10%.
- 468: 26/9/16: Compl:0%->10%. 1/12/16: Deleted: 720085 was allocated twice: to FS_LTE_SON-ECOMP (now in 720063) and to ROBVOLTE (now in 720301)
- 469: 7/3/16: 0%->100
- 470: 13/6/16: 0%->10; 19/9/16: 10%->35; 1/12/16: 35%->40
- 471: 11/6/16: 0%->10; 19/9/16: 10%->60; 1/12/16: 60%->100
- 472: 11/6/16: 0%->10; 19/9/16: 10%->40, FCD: 12/16->03/17; 1/12/16: FCD:03/17->06/17; 1/12/16: 40%->35
- 473: 11/6/16: 0%->10; 19/9/16: 10%->30, FCD: 12/16->06/17
- 474: 11/6/16: 0%->35. Name corrected; 19/9/16: WID:SP-160201->SP-160525; FCD: 09/16->12/16; 19/9/16: 35%->60; 23/9/16: WID:SP-160525->SP-160728; 1/12/16: 60%->95
- 475: 9/6/16: 0%->6; 28/7/16: 23.798 added;; 1/12/16: FCD:09/16->12/16; 1/12/16: 6%->100
- 476: 28/7/16: 21.866 added;
- 477: 1/7/16: Compl:0%->75%1/7/16: WI...; 28/7/16: 36.750 added;; 26/9/16: Compl:75%->100%
- 478: ; 1/7/16: Compl:0%->30%; 26/9/16: Compl:30%->80%; ;...
- 479: intention to capture results in existing TR 36.714-02-01 ; 1/7/16: Compl:0%->30%; ...26/9/16: Compl:30%->50%; ...
- 480: 1/7/16: Compl:0%->25%1/...26/9/16: Compl:25%->40%
- 481: ; 1/7/16: Compl:0%->15%...; 26/9/16: Compl:15%->30%
- 482: 1/7/16: Compl:0%->2%;…26/9/16: Compl:2%->5%; 6/10/16: 36.746 added;
- 483: 11/03/15: WID changed from FS_DCCII to FS_DCCHII as per SA5 chair request; June2015: Compl:0%->7; 07/09/15: 7%->15; 7/12/15: 15%->60, FCD: 09/15->03/16; 7/3/16: 60%->100. 22/3/16: Rel-13->Rel-14
- 484: TR number added. Mar. 15: 0->5%; June2015: Compl:5%->10; Aug2015: 10%->15; 07/09/15: 15%->30, FCD: 12/15->03/16; 7/3/16: 30%->40. 15/4/16: moved from Rel-13. FCD: 11/3/16->23/9/16; 11/6/16: 40%->50; 19/9/16: 50%->70, FCD:09/16->12/16; 1/12/16: 70%->80; 1/12/16: FCD:12/16->03/17
- 485: SP#65 completion 09/14=>12/14. Moved to Rel-13. Dec.14: 30->35%, CD 12/14->03/15. Mar.15: CD: 06/16. 40%; June2015: Compl:40%->45. FCD: 06/15->09/15. 7/9/15: FCD: 09/15->12/15; 7/12/15: 50%->60, FCD: 12/15->06/16; 7/3/16: 60%->65. 15/4/16: moved from R...
- 486: 19/9/16: 0%->30; 6/10/16: 26.917 added;; 1/12/16: 30%->60; 1/12/16: FCD:12/16->03/17
- 487: 28/7/16: 26.880 added;; 19/9/16: 0%->30, FCD: 12/16->03/17; 1/12/16: 30%->60
- 488: 28/7/16: 26.981 added;; 19/9/16: 0%->30; 1/12/16: 30%->50; 1/12/16: FCD:12/16->03/17
- 489: 16/9/16: 0%->15
- 490: 26/9/16: Compl:0%->30%; 6/10/16: 36.745 added;
- 491: continuation of GERAN SI UID 590034, DOMIMO under RAN626/9/16: Compl:0%->100%
- 492: 11/3: WID: SP-150050->150142; June2015: Compl:0%->20; 07/09/15: 20%->60. 07/12/15: Created by MCC as BB to dissociate SA1 versus SA2 aspects

| ID | WBS | Task | Type | Duration | Start | Finish | Complete | Remaining | Baseline start | Baseline finish | Baseline duration | Total slack | Constraint | Resources | Work | Actual work | Acronym | PCG approved | Impacted TSs and TRs | WI rapporteur name | WI rapporteur e-mail | Release | TSG approved | MCC resp | Special Focus Doc | Acronym_3GU_Export | Status Report | TSG stopped |
| --- | --- | --- | --- | --- | --- | --- | --- | --- | --- | --- | --- | --- | --- | --- | --- | --- | --- | --- | --- | --- | --- | --- | --- | --- | --- | --- | --- | --- |
| 493 | 187 | **Study on Stage 1 for New Services and Markets Technology Enablers** |  | 355d? | 2015-02-02 A | 2016-06-10 | 98% | 8.39d? |  |  |  | 482d |  | S1 | 10120h | 8334.03h | FS_SMARTER | PCG-34 | New TR 22.891 | Adrian Neal (Vodafone) | adrian.neal@vodafone.com | Rel-14 | SP-67 |  |  |  |  |  |
| 494 | 187.1 | General aspects of FS_SMARTER SA1 |  | 270d? | 2015-02-02 A | 2016-02-12 | 95% | 13.5d? |  |  |  | 567d | finish no earlier than 2016-02-12 | S1 | 2160h | 2052h | FS_SMARTER | PCG-34 | New TR 22.891 | Adrian Neal (Vodafone) | adrian.neal@vodafone.com | Rel-14 | SP-67 |  |  |  |  |  |
| 495 | 187.2 | FS_SMARTER – massive Internet of Things |  | 160d? | 2015-11-02 A | 2016-06-10 A | 100% |  |  |  |  |  | finish no earlier than 2016-06-10 | S1 | 1280h | 1280h | FS_SMARTER-mIoT | PCG-36 | New TR 22.861 | Adrian Neal (Vodafone) | adrian.neal@vodafone.com | Rel-14 | SP-70 |  |  |  |  |  |
| 496 | 187.3 | FS_SMARTER – Critical Communications |  | 160d? | 2015-11-02 A | 2016-06-10 | 95% | 8d? |  |  |  | 482d | finish no earlier than 2016-06-10 | S1 | 1280h | 1216h | FS_SMARTER-CRIC | PCG-36 | New TR 22.862 | Kanerva, Mikko | mikko.kanerva@nokia.com | Rel-14 | SP-70 |  |  |  |  |  |
| 497 | 187.4 | FS_SMARTER – enhanced Mobile Broadband |  | 160d? | 2015-11-02 A | 2016-06-10 A | 100% |  |  |  |  |  | finish no earlier than 2016-06-10 | S1 | 1280h | 1280h | FS_SMARTER-eMBB | PCG-36 | New TR 22.863 | Laurence Meriau | laurence.meriau@huawei.com | Rel-14 | SP-70 |  |  |  |  |  |
| 498 | 187.5 | FS_SMARTER – Network Operation |  | 160d? | 2015-11-02 A | 2016-06-10 A | 100% |  |  |  |  |  | finish no earlier than 2016-06-10 | S1 | 1280h | 1280h | FS_SMARTER-NEO | PCG-36 | New TR 22.864 | Lu Lu | lulu@chinamobile.com | Rel-14 | SP-70 |  |  |  |  |  |
| 499 | 188 | Study on Architecture and Security for next Generation System |  | 270d? | 2015-12-07 A | 2016-12-15 A | 100% |  |  |  |  |  | finish no earlier than 2016-12-15 | S2 | 2160h | 2160h | FS_NextGen | PCG-36 | TR 23.799 | suntao@chinamobile.com, devaki.chandramouli@nokia.com | suntao@chinamobile.com, devaki.chandramouli@nokia.com | Rel-14 | SP-70 |  |  |  |  |  |
| 500 | 189 | Study on Architecture and Security for Next Generation System |  | 273d? | 2016-03-01 A | 2017-03-15 | 45% | 150.15d? |  |  |  | 283d | finish no earlier than 2017-03-15 | S3 | 2184h | 982.8h | FS_NSA | PCG-36 | TR 33.899 | Vesa Torvinen, Ericsson | vesa.torvinen@ericsson.com | Rel-14 | SP-71 |  |  |  |  |  |
| 501 | 190 | Study on Scenarios and Requirements for Next Generation Access Technologies |  | 199d? | 2015-12-15 A | 2016-09-15 A | 100% |  |  |  |  |  | finish no earlier than 2016-09-15 | RP | 1592h | 1592h | FS_NG_SReq | PCG-36 |  | CMCC |  | Rel-14 | RP-70 |  |  |  |  |  |
| 502 | 191 | Study on New Radio (NR) Access Technology |  | 263d? | 2016-03-15 A | 2017-03-15 | 20% | 210.4d? |  |  |  | 283d | finish no earlier than 2017-03-15 | R1 | 2104h | 420.8h | FS_NR_newRAT | PCG-36 | TR 38.801, TR 38.912; 38.802 | NTT DOCOMO |  | Rel-15 | TSG#71 |  |  |  |  |  |
| 503 | 192 | Release 13 Features |  | 253.25d? | 2013-12-11 A | 2014-11-25 A | 100% |  | 2015-04-14 | 2015-12-25 | 183.25d? |  |  | SP; RP; CP; GP | 8104h | 8104h |  |  |  |  |  | Rel-13 |  |  |  |  |  |  |
| 504 | 193 | **Mission Critical Push To Talk over LTE (MCPTT)** |  | 672d? | 2013-12-11 A | 2016-06-30 | 96% | 28.44d? | 2013-12-11 | 2015-06-17 | 397d? | 467d |  | S1; S2; S3; S6; S4 | 54558.8h | 47708.8h | MCPTT | PCG-32 | Stage 1/2; | NIST | david.cypher@nist.gov | Rel-13 | SP-62 | Alain | Public Safety (A-A) | MCPTT |  |  |
| 505 | 193.1 | Study on Application Architecture to support MCPTT |  | 326d? | 2014-06-23 A | 2015-09-16 A | 100% |  | 2014-06-18 | 2014-12-10 | 126d? |  | finish no earlier than 2015-09-16 | S6 | 2608h | 2608h | MCPTT | PCG-33 | New TR 23.779 | Yannick Lair | yannick.lair@lge.com | Rel-13 | SP-64 |  | Public Safety (A-A) |  |  |  |
| 506 | 193.2 | SA2 Study on Architecture Enhancements at the EPS and IMS Level to Support MCPTT |  | 69d? | 2015-03-13 A | 2015-06-17 A | 100% |  |  |  |  |  | finish no earlier than 2015-06-17 | S2 | 552h | 552h | MCPTT | PCG-34 |  | Randy Bloomfield (randy@its.bldrdoc.gov) | Randy Bloomfield (randy@its.bldrdoc.gov) | Rel-13 | SP-67 |  |  |  |  |  |
| 507 | 193.3 | Study on Security Enhancements for MCPTT |  | 261d? | 2015-03-13 A | 2016-03-11 A | 100% |  |  |  |  |  | finish no earlier than 2016-03-11 | S3 | 2088h | 2088h | MCPTT | PCG-34 | 33.879; 33.280; 39.880 | Peter Haigh (peter.haigh at cesg.gsi.gov.uk) | Peter Haigh (peter.haigh at cesg.gsi.gov.uk) | Rel-13 | SP-67 |  |  |  |  |  |
| 508 | 193.4 | Study on media, codecs and MBMS enhancements for MCPTT |  | 326d? | 2014-12-12 A | 2016-03-11 | 85% | 48.9d? |  |  |  | 547d | finish no earlier than 2016-03-11 | S4 | 2608h | 2216.8h | MCPTT | PCG-34 | New TR 26.879 | Zhiming Li (lizhiming@huawei.com) | Zhiming Li (lizhiming@huawei.com) | Rel-13 | SP-67 |  |  |  |  |  |
| 509 | 193.5 | Stage 1 for MCPTT |  | 263d? | 2013-12-11 A | 2014-12-12 A | 100% |  | 2013-12-11 | 2014-12-10 | 261d? |  | finish no earlier than 2014-12-12 | S1 | 2104h | 2104h | MCPTT | PCG-32 | New TS 22.179 | NIST | david.cypher@nist.gov | Rel-13 | SP-62 | Alain | Public Safety (A-A) |  | SP-140502 |  |
| 510 | 193.6 | Functional architecture and information flows to support MCPTT |  | 127d? | 2015-06-18 A | 2015-12-11 A | 100% |  | 2014-06-18 | 2014-12-10 | 126d? |  | finish no earlier than 2015-12-11 | S6 | 1016h | 1016h | MCPTT | PCG-33 | New TS 23.179 | Yannick Lair | yannick.lair@lge.com | Rel-13 | SP-64 |  | Public Safety (A-A) |  |  |  |
| 511 | 193.7 | Security of MCPTT |  | 326d? | 2014-12-12 A | 2016-03-11 | 98% | 6.52d? |  |  |  | 547d | finish no earlier than 2016-03-11 | S3 | 2608h | 2555.84h | MCPTT | PCG-34 | TS 33.179 | Peter Haigh (peter.haigh at cesg.gsi.gov.uk) | Peter Haigh (peter.haigh at cesg.gsi.gov.uk) | Rel-13 | SP-66 |  |  |  |  |  |
| 512 | 193.8 | MCPTT Codecs and media handling |  | 267d? | 2015-03-05 A | 2016-03-11 | 85% | 40.05d? |  |  |  | 547d | finish no earlier than 2016-03-11 | S4 | 2136h | 1815.6h | MCPTT | PCG-34 | 26.346, new TS 26.179 | Zhiming Li (lizhiming@huawei.com) | Zhiming Li (lizhiming@huawei.com) | Rel-13 | SP-67 |  |  |  |  |  |
| 513 | 193.9 | **MCPTT protocol aspects** |  | 215d? | 2015-09-07 A | 2016-06-30 | 96% | 9.64d? |  |  |  | 467d |  | ct | 16584h | 14539h | MCPTT-CT | PCG-35 |  | Keith Drage, Alcatel-Lucent |  | Rel-13 | CP-69 |  |  |  |  |  |
| 514 | 193.9.1 | **CT1 aspects for MCPTT protocol aspects** |  | 135d? | 2015-09-07 A | 2016-03-11 A | 100% |  |  |  |  |  |  | C1 | 10800h | 10800h | MCPTT-CT | PCG-35 | 24.379, 24.380 24.38, 24.382, 24.383, 24.384, 24.229 | Samsung, Ricky Kaura | ricky.kaura@samsung.com | Rel-13 | CP-69 |  |  |  |  |  |
| 515 | 193.9.1.1 | Call Control – On Network |  | 135d? | 2015-09-07 A | 2016-03-11 A | 100% |  |  |  |  |  | finish no earlier than 2016-03-11 | C1 | 1080h | 1080h | MCPTT-CT | PCG-35 | 24.379 | Samsung, Ricky Kaura | ricky.kaura@samsung.com | Rel-13 | CP-69 |  |  |  |  |  |
| 516 | 193.9.1.2 | Call Control – Off Network |  | 135d? | 2015-09-07 A | 2016-03-11 A | 100% |  |  |  |  |  | finish no earlier than 2016-03-11 | C1 | 1080h | 1080h | MCPTT-CT | PCG-35 | 24.379 | Samsung, Ricky Kaura | ricky.kaura@samsung.com | Rel-13 | CP-69 |  |  |  |  |  |
| 517 | 193.9.1.3 | Floor Control – On Network |  | 135d? | 2015-09-07 A | 2016-03-11 A | 100% |  |  |  |  |  | finish no earlier than 2016-03-11 | C1 | 1080h | 1080h | MCPTT-CT | PCG-35 | 24.380 | Samsung, Ricky Kaura | ricky.kaura@samsung.com | Rel-13 | CP-69 |  |  |  |  |  |
| 518 | 193.9.1.4 | Floor Control – Off Network |  | 135d? | 2015-09-07 A | 2016-03-11 A | 100% |  |  |  |  |  | finish no earlier than 2016-03-11 | C1 | 1080h | 1080h | MCPTT-CT | PCG-35 | 24.380 | Samsung, Ricky Kaura | ricky.kaura@samsung.com | Rel-13 | CP-69 |  |  |  |  |  |
| 519 | 193.9.1.5 | Broadcast – Call Control and Floor Control |  | 135d? | 2015-09-07 A | 2016-03-11 A | 100% |  |  |  |  |  | finish no earlier than 2016-03-11 | C1 | 1080h | 1080h | MCPTT-CT | PCG-35 | 24.379, 24.380 | Samsung, Ricky Kaura | ricky.kaura@samsung.com | Rel-13 | CP-69 |  |  |  |  |  |
| 520 | 193.9.1.6 | Group management |  | 135d? | 2015-09-07 A | 2016-03-11 A | 100% |  |  |  |  |  | finish no earlier than 2016-03-11 | C1 | 1080h | 1080h | MCPTT-CT | PCG-35 | 24.381 | Samsung, Ricky Kaura | ricky.kaura@samsung.com | Rel-13 | CP-69 |  |  |  |  |  |
| 521 | 193.9.1.7 | Identity management |  | 135d? | 2015-09-07 A | 2016-03-11 A | 100% |  |  |  |  |  | finish no earlier than 2016-03-11 | C1 | 1080h | 1080h | MCPTT-CT | PCG-35 | 24.382 | Samsung, Ricky Kaura | ricky.kaura@samsung.com | Rel-13 | CP-69 |  |  |  |  |  |
| 522 | 193.9.1.8 | Management Object |  | 135d? | 2015-09-07 A | 2016-03-11 A | 100% |  |  |  |  |  | finish no earlier than 2016-03-11 | C1 | 1080h | 1080h | MCPTT-CT | PCG-35 | 24.383 | Samsung, Ricky Kaura | ricky.kaura@samsung.com | Rel-13 | CP-69 |  |  |  |  |  |
| 523 | 193.9.1.9 | Configuration management |  | 135d? | 2015-09-07 A | 2016-03-11 A | 100% |  |  |  |  |  | start no earlier than 2015-09-07 | C1 | 1080h | 1080h | MCPTT-CT | PCG-36 | 24.384 | Samsung, Ricky Kaura | ricky.kaura@samsung.com | Rel-13 | TSG#71 |  |  |  |  |  |
| 524 | 193.9.2 | CT3 aspects for MCPTT protocol aspects |  | 135d? | 2015-09-07 A | 2016-03-11 A | 100% |  |  |  |  |  | finish no earlier than 2016-03-11 | C3 | 1080h | 1080h | MCPTT-CT | PCG-35 | 29.165 | Alcatel-Lucent, Keith Drage | keith.drage@alcatel-lucent.com | Rel-13 | CP-69 |  |  |  |  |  |
| 525 | 193.9.3 | CT4 aspects for MCPTT protocol aspects |  | 135d? | 2015-09-07 A | 2016-03-11 A | 100% |  |  |  |  |  | finish no earlier than 2016-03-11 | C4 | 1080h | 1080h | MCPTT-CT | PCG-35 | 23.003, 23.008, 29.283 | Alcatel-Lucent, Keith Drage | keith.drage@alcatel-lucent.com | Rel-13 | CP-69 |  |  |  |  |  |
| 526 | 193.9.4 | CT6 aspects for MCPTT protocol aspects |  | 135d? | 2015-09-07 A | 2016-03-11 A | 100% |  |  |  |  |  | finish no earlier than 2016-03-11 | C6 | 1080h | 1080h | MCPTT-CT | PCG-36 | 31.102, 31.103 | Alcatel-Lucent, Keith Drage | keith.drage@alcatel-lucent.com | Rel-13 | CP-70 |  |  |  |  |  |
| 527 | 193.9.5 | (IETF) IANA Registration of New SIP Resource- Priority Namespace for MCPTT |  | 103d? | 2016-02-10 A | 2016-06-30 | 25% | 77.25d? |  |  |  | 467d | start no earlier than 2016-02-10 | C1-IETF | 824h | 206h | MCPTT-CT | PCG-36 | draft-holmberg-dispatch-mcptt-rp-namespace | Ericsson | christer.holmberg@ericsson.com | Rel-13 | TSG#71 |  |  |  |  |  |
| 528 | 193.10 | IMS Profile to support MCPTT |  | 130d? | 2015-09-14 A | 2016-03-11 A | 100% |  |  |  |  |  | finish no earlier than 2016-03-11 | C1 | 1040h | 1040h | MCPTT-Prof | PCG-35 | 24.980 | Huawei, PATEL Milan | Milan.Patel@huawei.com | Rel-13 | CP-69 |  |  |  |  |  |
| 529 | 193.11 | Deleted: SA2 aspects for MCPTT |  | 1d? | 2015-03-13 A | 2015-03-13 A | 100% |  | 2014-06-18 | 2015-06-17 | 261d? |  | finish no earlier than 2015-03-13 | S2 | 8h | 8h | MCPTT | PCG-33 | New TS 23.179 | Randy Bloomfield (randy@its.bldrdoc.gov) | Randy Bloomfield (randy@its.bldrdoc.gov) | Rel-13 | SP-64 |  | Public Safety (A-A) |  |  | SP-69 |
| 530 | 193.12 | Deleted (duplicated): Application Architecture to support MCPTT | milestone | 0d? | 2015-03-13 A | 2015-03-13 A | 100% |  |  |  |  |  | finish no earlier than 2015-03-13 | S6 |  |  | MCPTT | PCG-34 |  | U.S. Department of Commerce | Randy Bloomfield (randy@its.bldrdoc.gov) | Rel-13 | SP-67 |  |  |  |  | SP-69 |
| 531 | 193.13 | Deleted (duplicated): SA6 aspects for MCPTT |  | 261d? | 2014-12-12 A | 2015-12-11 A | 100% |  |  |  |  |  | finish no earlier than 2015-12-11 | S6 | 2088h | 2088h | MCPTT | PCG-34 |  | David Cypher (david.cypher at nist.gov) | David Cypher (david.cypher at nist.gov) | Rel-13 | SP-66 |  |  |  |  | SP-69 |

Notes:
- 494: 7/12/15: 60%->85; 2/3/16: 85%->95
- 495: 2/3/16: 35%->65; 9/6/16: 65%->100
- 496: 2/3/16: 15%->60; 9/6/16: 60%->95
- 497: 2/3/16: 40%->75; 9/6/16: 75%->100
- 498: 2/3/16: 30%->60; 19/9/16: 60%->100
- 499: 28/1/16: 23.799 added; Acronym corrected ("NexGen"->"NextGen"); 7/3/16: 5%->15; 10/3/16: WID:SP-150853->SP-160200. Name changed from "Study on Architecture for next Generation System"; 9/6/16: 15%->35; 19/9/16: 35%->64; 22/9/16: WID:SP-160227->SP-16072...; 1/12/16: 64%->100
- 500: 19/9/16: 0%->25; 22/9/16: WID:SP-160227->SP-160727; 22/9/16: FCD:12/16->03/17; 1/12/16: 25%->45
- 501: 22/3/16: Compl:0%->80%1/7/16: WID: RP-152257->RP-160811. 18/9/16: FCD: Sept 16, 80->95%26/9/16: Compl:95%->100%
- 502: includes RAN TR 38.801; 1/7/16: Compl:0%->10%; 1/7/16: CD:Thu 15/06/17->Wed 15/03/17; 1/7/16: WID: RP-160671->RP-161214; 1/7/16: Release: Rel-15->Rel-14; 28/7/16: 38.802 added; 26/9/16: Compl:10%->20%; 26/9/16: WID: RP-161214->RP-161596. 2/12/16: Moved to
- 503: -
- 504: SP#65 updated WID SP-140276=>SP-140435. Mar 15: WID: SP-140879->SP-150164. 4/15: S4 added. 6/15: WID updated
- 505: SP#65 completion 12/14=>06/15. Updated WID SP-140276=>SP-140435. Dec.14: 2->20%. Mar 15: WID: SP-140879->SP-150095. Mar15: 30%. Transferred to SA6. June 15: FCD shifted to Sept,WID updated; June2015: Compl:24%->50; June2015: Compl:50%->70. 3/8/15: Rapport; 07/09/15: 70%->100
- 506: Mar 2015: WID: SP-140879->SP-150164.; June2015: Compl:0%->30, WID updated; 07/09/15: 30%->100, "To be confirmed" deleted, since SA2 has completed it.
- 507: Mar 2015: WID: SP-140879->SP-150164. Name clarified.6/15: WID updated; 7/12/15: 0%->75; 10/12/15: FCD->March, ES in SP-150729; 7/3/16: 75%->80; 28/7/16: 33.280 added;; 28/7/16: 39.880 added;; 1/12/16: 80%->100
- 508: Mar 2015: WID: SP-140879->SP-150164. Name clarified. 5/5/15: TR number added; June2015: Compl:0%->5, WID updated; Aug2015: 5%->15; 07/09/15: 15%->40; 7/12/15: 40%->80, FCD: 12/15->03/16; 7/3/16: 80%->85
- 509: SP#65 completion 09/14=>12/14. Exception in SP-140502. TS 22.179v100 for Information. Completed. Mar 15: WID: SP-140879->SP-150164. 6/15: WID updated
- 510: June2015: added as per SP-150356; June2015: Compl:0%->15. 31 July: Rapporteur corrected. 3/8/15: name aligned to the WID; 07/09/15: 15%->50; 07/09/15: 50%->85. 15/09/15: FCD: 09/15->12/15; 7/3/16: 85%->100
- 511: Mar 2015: WID: SP-140879->SP-150164. Name clarified. FCD: 03/2016->12/2015; June2015: Compl:5%->15, WID updated. 7/9/15: TS number added; 7/12/15: 15%->60. FCD -> 03/16, ES in SP-150729; 7/3/16: 60%->85; 1/12/16: 85%->98
- 512: Mar 2015: WID: SP-140879->SP-150164. Name clarified. FCD: 03/2016->12/2015; June2015: Compl:0%->5, WID updated; Aug2015: 5%->15; 07/09/15: 15%->40. ES in SP-150663; 7/3/16: 40%->85
- 513: 7/12/15: WID:CP-150587->CP-150793; 28/1/16: 24.384 added;
- 514: 7/12/15: WID:CP-150587->CP-150793; 7/3/16: WID:CP-150863->CP-160160
- 515: Proposed by Atle after some talks with several interested parties; 7/12/15: 0%->50; 7/12/15: WID:CP-150587->CP-150863. FCD->03/16, ES in CP-150721; 7/3/16: 50%->100; 7/3/16: WID:CP-150863->CP-160160
- 516: Proposed by Atle after some talks with several interested parties; 7/12/15: 0%->75; 7/12/15: WID:CP-150587->CP-150863. FCD->03/16, ES in CP-150721; 7/3/16: 75%->100; 7/3/16: WID:CP-150863->CP-160160
- 517: Proposed by Atle after some talks with several interested parties; 7/12/15: 0%->80; 7/12/15: WID:CP-150587->CP-150863. FCD->03/16, ES in CP-150721; 7/3/16: 80%->100; 7/3/16: WID:CP-150863->CP-160160
- 518: Proposed by Atle after some talks with several interested parties; 7/12/15: 0%->85; 7/12/15: WID:CP-150587->CP-150863. FCD->03/16, ES in CP-150721; 7/3/16: 85%->100; 7/3/16: WID:CP-150863->CP-160160
- 519: Proposed by Atle after some talks with several interested parties; 7/12/15: 0%->50; 7/12/15: WID:CP-150587->CP-150863. FCD->03/16, ES in CP-150721; 7/3/16: 50%->100; 7/3/16: WID:CP-150863->CP-160160
- 520: Proposed by Atle after some talks with several interested parties; 7/12/15: 0%->75; 7/12/15: WID:CP-150587->CP-150863. FCD->03/16, ES in CP-150721; 7/3/16: 75%->100; 7/3/16: WID:CP-150863->CP-160160
- 521: Proposed by Atle after some talks with several interested parties; 7/12/15: WID:CP-150587->CP-150863. FCD->03/16, ES in CP-150721; 7/3/16: 0%->100; 7/3/16: WID:CP-150863->CP-160160
- 522: Proposed by Atle after some talks with several interested parties; 7/12/15: 0%->10; 7/12/15: WID:CP-150587->CP-150863. FCD->03/16, ES in CP-150721; 7/3/16: 10%->100. Name changed from "Configuration management"; 7/3/16: WID:CP-150863->CP-160160
- 523: Introduced from CT1 WP update in 03/16; 7/3/16: WID:CP-150863->CP-160160
- 524: 7/12/15: 0%->70; 7/12/15: WID:CP-150587->CP-150863. FCD -> 03/16, ES in CP-150643; 7/3/16: 70%->100; 7/3/16: WID:CP-150863->CP-160160
- 525: 7/12/15: WID:CP-150587->CP-150863. FCD -> 03/16, ES in CP-150864; 7/3/16: 0%->100; 7/3/16: WID:CP-150863->CP-160160
- 526: 7/12/15: WID:CP-150587->CP-150863. FCD -> 03/16, ES in CP-150866; 7/3/16: 0%->100; 7/3/16: WID:CP-150863->CP-160160
- 528: 12/15: TR # added; 7/12/15: 0%->60; 7/12/15: WID:CP-150500->CP-150794. FCD -> 03/16, ES in CP-150722; 7/3/16: 60%->100
- 529: Mar 2015: transferred to SA6. Was 06/14 to 06/15. 6/15: WID updated
- 530: Mar 2015: WID: SP-140879->SP-150164. Name clarified.6/15: WID updated. 7/15: removed since duplicates 640143 and 660054 (only 640143 is kept)
- 531: Mar 2015: WID: SP-140879->SP-150164. Name clarified. 6/15: WID updated. 31 July: deleted since duplicates 640143 and 670031 (only 640143 is kept)

| ID | WBS | Task | Duration | Start | Finish | Complete | Remaining | Baseline start | Baseline finish | Baseline duration | Total slack | Constraint | Resources | Work | Actual work | Acronym | PCG approved | Impacted TSs and TRs | WI rapporteur name | WI rapporteur e-mail | Release | TSG approved | MCC resp | Status Report | Special Focus Doc | Acronym_3GU_Export |
| --- | --- | --- | --- | --- | --- | --- | --- | --- | --- | --- | --- | --- | --- | --- | --- | --- | --- | --- | --- | --- | --- | --- | --- | --- | --- | --- |
| 532 | 194 | **MBMS Extensions and Profiling** | 202d? | 2015-03-05 A | 2015-12-11 A | 100% |  |  |  |  |  |  | S4 | 4848h | 4848h | MEPRO | PCG-34 | 26.346, new TR 26.852 | Imed Bouazizi, Samsung and Thorsten Lohmar, Ericsson | i.bouazizi@samsung.com, thorsten.lohmar@ericsson.com | Rel-13 | SP-67 |  |  |  |  |
| 533 | 194.1 | TR on Profiling and Extensions of MBMS | 202d? | 2015-03-05 A | 2015-12-11 A | 100% |  |  |  |  |  | finish no earlier than 2015-12-11 | S4 | 1616h | 1616h | MEPRO | PCG-34 | new TR 26.852 | Imed Bouazizi, Samsung and Thorsten Lohmar, Ericsson | i.bouazizi@samsung.com, thorsten.lohmar@ericsson.com | Rel-13 | SP-67 |  |  |  |  |
| 534 | 194.2 | Specification of MBMS Extensions and Profiling | 202d? | 2015-03-05 A | 2015-12-11 A | 100% |  |  |  |  |  | start no earlier than 2015-03-05 | S4 | 1616h | 1616h | MEPRO | PCG-34 | 26.346 | Imed Bouazizi, Samsung and Thorsten Lohmar, Ericsson | i.bouazizi@samsung.com, thorsten.lohmar@ericsson.com | Rel-13 | SP-67 |  |  |  |  |
| 535 | 195 | **Isolated E-UTRAN Operation for Public Safety** | 529d? | 2014-03-07 A | 2016-03-11 A | 100% |  | 2014-03-07 | 2014-09-17 | 139d? |  |  | S1 | 8600h | 8600h | IOPS | PCG-32 | New TS 22.346 | General Dynamics | paul.piggin@gd-broadband.com | Rel-13 | SP-63 | Alain | S1-143304 | Public Safety (A-A) | IOPS |
| 536 | 195.1 | Stage 1 fo Isolated E-UTRAN Operation for Public Safety | 140d? | 2014-03-07 A | 2014-09-17 A | 100% |  | 2014-03-07 | 2014-09-17 | 139d? |  | finish no earlier than 2014-09-17 | S1 | 1120h | 1120h | IOPS | PCG-32 | New TS 22.346 | General Dynamics | paul.piggin@gd-broadband.com | Rel-13 | SP-63 | Alain | S1-143304 | Public Safety (A-A) | IOPS |
| 537 | 195.2 | Stage 2 for Isolated E-UTRAN Operation for Public Safety | 140d? | 2015-06-18 A | 2015-12-30 A | 100% |  | 2014-03-07 | 2014-09-17 | 139d? |  | start no earlier than 2015-06-18 | S2 | 1120h | 1120h | IOPS | PCG-32 | 23.401 | Phil Young | phil.young@gd-broadband.com | Rel-13 | SP-63 | Alain |  | Public Safety (A-A) | IOPS |
| 538 | 195.3 | Security aspects for Isolated E-UTRAN Operation for Public Safety | 76d? | 2015-09-16 A | 2015-12-30 A | 100% |  | 2014-03-07 | 2014-09-17 | 139d? |  | start no earlier than 2015-09-16 | S3 | 608h | 608h | IOPS | PCG-32 | TS 33.401 | General Dynamics | paul.piggin@gd-ms.uk | Rel-13 | SP-63 | Alain |  | Public Safety (A-A) | IOPS |
| 539 | 195.4 | **CT aspects for IOPS** | 95d? | 2015-11-02 A | 2016-03-11 A | 100% |  |  |  |  |  |  | C6 | 1520h | 1520h | IOPS-CT | PCG-36 |  | Heiko Kruse, Morpho Cards GmbH | heiko.kruse@mrpho.com | Rel-13 | CP-70 |  |  |  |  |
| 540 | 195.4.1 | CT6 aspects for IOPS | 95d? | 2015-11-02 A | 2016-03-11 A | 100% |  |  |  |  |  | finish no earlier than 2016-03-11 | C6 | 760h | 760h | IOPS-CT | PCG-36 | 31.102 | Heiko Kruse, Morpho Cards GmbH | heiko.kruse@mrpho.com | Rel-13 | CP-70 |  |  |  |  |
| 541 | 196 | Service Requirements Maintenance for Group Communication System Enablers for LTE | 67d? | 2014-06-18 A | 2014-09-17 A | 100% |  | 2014-06-18 | 2014-09-17 | 66d? |  | finish no earlier than 2014-09-17 | S1 | 536h | 536h | SRM_GCSE_LTE | PCG-33 | 22.468 | Nokia Networks | Juergen.Merkel@nsn.com | Rel-13 | SP-64 |  | S1-143307 | Public Safety (A-A) | SRM_GCSE_LTE |
| 542 | 197 | Enhanced Calling Information Presentation | 330d? | 2014-09-15 A | 2015-12-16 A | 100% |  | 2013-12-11 | 2014-09-17 | 201d? |  | finish no earlier than 2015-12-16 | S1 | 2640h | 2640h | ECIP | PCG-32 | 22.182 (CAT), 22.183 (CRS) | China Mobile | LI Xiaofan (lixiaofan@chinamobile.com | Rel-13 | SP-62 | Alain | S1-143311 |  | ECIP |
| 543 | 198 | **Flexible Mobile Service Steering** | 392d? | 2014-09-15 A | 2016-03-11 | 100% | 0d? | 2013-12-11 | 2014-09-17 | 202d? | 0d |  | S1; S2 | 7943.76h | 6367.76h | FMSS | PCG-33 | 22.101 | China Mobile | Lu Lu (lulu@chinamobile.com) | Rel-13 | SP-65 | Alain | S1-143310 |  | FMSS |
| 544 | 198.1 | Stage 1 for Flexible Mobile Service Steering | 3d? | 2014-09-15 A | 2014-09-17 A | 100% |  | 2013-12-11 | 2014-09-17 | 202d? |  | start no earlier than 2014-09-15 | S1 | 23.85h | 23.85h | FMSS-ST1 | PCG-33 | 22.101 | China Mobile | Lu Lu (lulu@chinamobile.com) | Rel-13 | SP-65 | Alain | S1-143310 |  | FMSS |
| 545 | 198.2 | Flexible Mobile Service Steering TR Phase | 134d? | 2014-12-12 A | 2015-06-17 A | 100% |  |  |  |  |  | finish no earlier than 2015-06-17 | S2 | 1072h | 1072h | FMSS-SA2TR | PCG-34 | 23.718 | Lu Lu, China Mobile | lulu@chinamobile.com | Rel-13 | SP-66 |  |  |  |  |
| 546 | 198.3 | Flexible Mobile Service Steering - Stage 2 | 134d? | 2014-12-12 A | 2015-06-17 A | 100% |  |  |  |  |  | start no earlier than 2014-12-12 | S2 | 1072h | 1072h | FMSS-SA2 | PCG-34 |  | Lu Lu, China Mobile | lulu@chinamobile.com | Rel-13 | SP-66 |  |  |  |  |
| 547 | 198.4 | CT3 Aspect of Flexible Mobile Service Steering | 133d? | 2015-09-09 A | 2016-03-11 A | 100% |  |  |  |  |  | finish no earlier than 2016-03-11 | C3 | 1064h | 1064h | FMSS-CT | PCG-35 | 29.abc, 29.212, 29.213 | ZTE,Zhou Xiaoyun | zhou.xiaoyun@zte.com.cn | Rel-13 | CP-69 |  |  |  |  |
| 548 | 199 | GERAN UTRAN Sharing Enhancements | 63d? | 2014-09-19 A | 2014-12-12 A | 100% |  |  |  |  |  | finish no earlier than 2014-12-12 | S1 | 504h | 504h | GUSH | PCG-33 | 22.101 | Telefónica | chris.friel@telefonica.com | Rel-13 | SP-65 |  | SP-140515 |  | GUSH |
| 549 | 200 | **Application specific Congestion control for Data Communication** | 456d? | 2014-06-18 A | 2016-03-11 | 100% | 0d? | 2014-06-18 | 2014-09-17 | 66d? | 0d |  | S1; C1 | 17920h | 14808h | ACDC | PCG-33 | 22.011 | NTT DOCOMO | Atsushi Minokuchi (minokuchi@nttdocomo.co.jp) | Rel-13 | SP-64 |  | S1-143305 |  | ACDC |
| 550 | 200.1 | Stage 1 for Application specific Congestion control for Data Communication | 67d? | 2014-06-18 A | 2014-09-17 A | 100% |  | 2014-06-18 | 2014-09-17 | 66d? |  | finish no earlier than 2014-09-17 | S1 | 536h | 536h | ACDC-ST1 | PCG-33 | 22.011 | NTT DOCOMO | Atsushi Minokuchi (minokuchi@nttdocomo.co.jp) | Rel-13 | SP-64 |  | S1-143305 |  | ACDC |
| 551 | 200.2 | **Stage 3 for Application specific Congestion control for Data Communication** | 332d? | 2014-12-04 A | 2016-03-11 A | 100% |  |  |  |  |  |  | C1 | 7472h | 7472h | ACDC-CT | PCG-34 | TS 24.105, 24.301, 24.008, 27.007, 31.102 | Kim, Jaehyun, LGE | jaehyun7.kim@lge.com | Rel-13 | CT-66 |  |  |  |  |
| 552 | 200.2.1 | CT1 part of Stage 3 for Application specific Congestion control for Data Communication | 270d? | 2014-12-04 A | 2015-12-16 A | 100% |  |  |  |  |  | finish no earlier than 2015-12-16 | C1 | 2160h | 2160h | ACDC-CT | PCG-34 | 24.105, 24.301, 24.008, 27.007, 23.122 | Kim, Jaehyun, LGE | jaehyun7.kim@lge.com | Rel-13 | CT-66 |  |  |  |  |
| 553 | 200.2.2 | CT6 part of Stage 3 for Application specific Congestion control for Data Communication | 332d? | 2014-12-04 A | 2016-03-11 A | 100% |  |  |  |  |  | finish no earlier than 2016-03-11 | C6 | 2656h | 2656h | ACDC-CT | PCG-34 | 31.102 | Kim, Jaehyun, LGE | jaehyun7.kim@lge.com | Rel-13 | CT-66 |  |  |  |  |
| 554 | 200.3 | **RAN aspects of Application specific Congestion control for Data Communication** | 197d? | 2015-03-16 A | 2015-12-15 A | 100% |  |  |  |  |  |  | R2 | 3152h | 3152h | ACDC-RAN | PCG-34 |  | LG Electronics |  | Rel-13 | RP-67 |  |  |  |  |
| 555 | 200.3.1 | Core part: RAN aspects of Application specific Congestion control for Data Communication | 197d? | 2015-03-16 A | 2015-12-15 A | 100% |  |  |  |  |  | finish no earlier than 2015-12-15 | R2 | 1576h | 1576h | ACDC-RAN-Core | PCG-34 |  | LG Electronics |  | Rel-13 | RP-67 |  | RP-151275 |  |  |

Notes:
- 532: 1/4/15: TS number added; 14/09/15: WID:SP-150099->SP-150439
- 533: 8/4/15: line added; June2015: Compl:0%->10; Aug2015: 10%->15; 07/09/15: 15%->40; 14/09/15: WID:SP-150099->SP-150439; 7/12/15: 40%->100
- 534: 8/4/15: line added; June2015: Compl:0%->10; Aug2015: 10%->15; 07/09/15: 15%->40; 14/09/15: WID:SP-150099->SP-150439; 7/12/15: 40%->100
- 535: SP#65 completed. TS 22.346v100 for 1-step Approval. Triggered by Rel-13 TR 22.897 (FS_IOPS); 14/09/15: WID:SP 150358->SP-150463
- 536: SP#65 completed. TS 22.346v100 for 1-step Approval. Triggered by Rel-13 TR 22.897 (FS_IOPS); 14/09/15: WID:SP 150358->SP-150463
- 537: 07/09/15: 0%->100; 14/09/15: WID:SP 150358->SP-150463
- 538: 07/09/15: 0%->100; 11/12/15: 0%->100
- 540: ES in CP-150837; 7/3/16: 0%->100
- 541: SP#65 completed. Some Rel-12 service reqs have no Stage 2/3 implementation
- 542: SP#65 approved WID & completed. Triggered by Rel-13 TR 22.810. Linked to Multimedia Telephony Service for IMS (UID_7038), Customized Alerting Tone (CAT) UID_370028, Customized Ringing Signal (CRS) UID_380067. 31/07/15: 100%
- 543: SP#65 WID approved & completed. Triggered by Rel-13 TR 22.808 (FS_FMSS)
- 544: SP#65 WID approved & completed. Triggered by Rel-13 TR 22.808 (FS_FMSS). Dec.14: moved from Feature to S1 BB
- 545: 3/3: TR number added.Mar15: 15->20%; June2015: Compl:20%->85; 07/09/15: 85%->100
- 546: 07/09/15: 0%->90; 07/09/15: 90%->100
- 547: 07/09/15: 0%->20; 14/09/15: WID:CP-150488->CP-150577; 7/12/15: 20%->90; 7/12/15: WID:CP-150577->CP-150799. FCD -> 03/16. ES in CP-150646; 7/3/16: 90%->100
- 548: SP#65 exception in SP-140515. Triggered by TR 22.852 (FS_RSE and FS_GUSH). Completed.
- 549: SP#65 completed. Triggered by Rel-13 Study TR 22.806
- 550: Results from MCC Split of the SA1 feature into F+BB for stage 1
- 551: Presented at CT#66. June 2015: FCD: June->Dec 2015, WID: CP-140999-> CP-150282
- 552: Presented at CT#66; June2015: Compl:0%->10. June 2015: FCD: June->Dec 2015, WID: CP-140999-> CP-150282; 07/09/15: 5%->70; 7/12/15: 70%->100
- 553: Presented at CT#66. June 2015: FCD: June->Dec 2015, WID: CP-140999-> CP-150282. 12/15: FCD -> 03/16, ES in CP-150838; 7/3/16: 0%->100
- 555: 03/07/15: Compl:0%->25% 03/07/15: WID: RP-150512->RP-150662 03/07/15: Stat Rep: ->RP-150661 29/09/15: Compl:25%->70% 29/09/15: Stat Rep: RP-150661->RP-151275; 1/1/16: Compl:70%->100%

| ID | WBS | Task | Duration | Start | Finish | Complete | Remaining | Baseline start | Baseline finish | Baseline duration | Total slack | Constraint | Resources | Work | Actual work | Acronym | PCG approved | WI rapporteur name | WI rapporteur e-mail | Release | TSG approved | MCC resp | Acronym_3GU_Export | PCG stopped | TSG stopped | Status Report |
| --- | --- | --- | --- | --- | --- | --- | --- | --- | --- | --- | --- | --- | --- | --- | --- | --- | --- | --- | --- | --- | --- | --- | --- | --- | --- | --- |
| 556 | 201 | **User Plane Congestion management** | 667d? | 2012-09-12 A | 2015-03-18 A | 100% |  | 2012-02-02 | 2015-06-17 | 890d? |  |  | S1; S2; C3; C4 | 39368h | 39368h | UPCON | PCG-29 | KDDI | Eriko Yoshida (er-yoshida@kddi.com) | Rel-13 | SP-57 | Alain | UPCON |  |  |  |
| 557 | 201.1 | Stage 1 for User Plane Congestion management | 129d? | 2012-09-12 A | 2013-03-06 A | 100% |  | 2012-02-02 | 2013-03-06 | 289d? |  | start no earlier than 2012-09-12 | S1 | 1032h | 1032h | UPCON-ST1 | PCG-29 | KDDI | Eriko Yoshida (er-yoshida@kddi.com) | Rel-13 | SP-57 | Alain |  |  |  |  |
| 558 | 201.2 | TR on Stage 2 for User Plane Congestion management | 595d? | 2012-12-12 A | 2015-03-18 A | 100% |  | 2012-12-12 | 2014-12-10 | 525d? |  | finish no earlier than 2015-03-18 | S2 | 4760h | 4760h | UPCON-SA2TR | PCG-30 | Allot | Alla Goldner (agoldner@allot.com) | Rel-13 | SP-58 | Maurice |  |  |  |  |
| 559 | 201.3 | Deleted - Stage 2 for User Plane Congestion management | 261d? | 2012-12-19 A | 2013-12-11 A | 100% |  | 2012-12-19 | 2013-12-11 | 261d? |  | finish no earlier than 2013-12-11 | S2 | 2088h | 2088h | UPCON-SA2Del | PCG-30 | NEC | andreas.maeder@neclab.eu | Rel-13 | SP-58 | Maurice |  | PCG-32 | SP-62 |  |
| 560 | 201.4 | **BB1: RAN Downlink Traffic Differentiation, Congestion Detection and Reporting** | 269d? | 2014-03-07 A | 2015-03-13 A | 100% |  | 2014-03-07 | 2015-06-17 | 334d? |  |  | S2 | 10048h | 10048h | UPCON-DOTCON | PCG-32 | Allot | Alla Goldner (agoldner@allot.com) | Rel-13 | SP-63 | Maurice | UPCON-DOTCON |  |  |  |
| 561 | 201.4.1 | Stage 2 for RAN Downlink Traffic Differentiation, Congestion Detection and Reporting | 201d? | 2014-03-07 A | 2014-12-12 A | 100% |  | 2014-03-07 | 2015-06-17 | 334d? |  | finish no earlier than 2014-12-12 | S2 | 1608h | 1608h | UPCON-DOTCON-SA2 | PCG-32 | Allot | Alla Goldner (agoldner@allot.com) | Rel-13 | SP-63 | Maurice |  |  |  |  |
| 562 | 201.4.2 | **CT aspects of User Plane Congestion Management for BB1** | 262d? | 2014-03-18 A | 2015-03-13 A | 100% |  |  |  |  |  |  | C3 | 6288h | 6288h | UPCON-DOTCON-CT | PCG-33 | Huawei | Xia Haitao (xiahaitao@huawei.com) | Rel-13 | CP-65 |  | UPCON-DOTCON-CT |  |  |  |
| 563 | 201.4.2.1 | CT3 part of CT aspects of User Plane Congestion Management for BB1 | 262d? | 2014-03-18 A | 2015-03-13 A | 100% |  |  |  |  |  | finish no earlier than 2015-03-13 | C3 | 2096h | 2096h | UPCON-DOTCON-CT | PCG-33 | Huawei | Xia Haitao (xiahaitao@huawei.com) | Rel-13 | CP-65 |  |  |  |  |  |
| 564 | 201.4.2.2 | CT4 part of CT aspects of User Plane Congestion Management for BB1 | 262d? | 2014-03-18 A | 2015-03-13 A | 100% |  |  |  |  |  | finish no earlier than 2015-03-13 | C4 | 2096h | 2096h | UPCON-DOTCON-CT | PCG-33 | Huawei | Xia Haitao (xiahaitao@huawei.com) | Rel-13 | CP-65 |  |  |  |  |  |
| 565 | 201.5 | Deleted - BB2: Application and Content Prioritization | 140d? | 2014-03-07 A | 2014-09-17 A | 100% |  | 2014-03-07 | 2015-06-17 | 334d? |  | finish no earlier than 2014-09-17 | S2 | 1120h | 1120h | UPCON-CONDEL | PCG-32 | Allot | Alla Goldner (agoldner@allot.com) | Rel-13 | SP-63 | Maurice | UPCON-CON | PCG-33 | SP-65 |  |
| 566 | 201.6 | Deleted - BB3: Uplink traffic and attended/unattended traffic | 140d? | 2014-03-07 A | 2014-09-17 A | 100% |  | 2014-03-07 | 2015-06-17 | 334d? |  | finish no earlier than 2014-09-17 | S2 | 1120h | 1120h | UPCON-TRAFDEL | PCG-32 | Allot | Alla Goldner (agoldner@allot.com) | Rel-13 | SP-63 | Maurice | UPCON-TRAF | PCG-33 | SP-65 |  |
| 567 | 202 | **Media Handling Aspects of IMS-based Telepresence** | 660d? | 2014-09-09 A | 2017-03-15 | 79% | 141.71d? |  |  |  | 283d |  | S4 | 20696h | 14760.4h | IMS_TELEP_S4 | PCG-33 | Intel | ozgur.oyman@intel.com | Rel-13 | SP-65 |  | IMS_TELEP_S4 |  |  |  |
| 568 | 202.1 | TR on Media Handling Aspects of IMS-based Telepresence | 269d? | 2014-09-09 A | 2015-09-16 A | 100% |  |  |  |  |  | finish no earlier than 2015-09-16 | S4 | 2152h | 2152h | IMS_TELEP_S4 | PCG-33 | Intel | ozgur.oyman@intel.com | Rel-13 | SP-65 |  |  |  |  |  |
| 569 | 202.2 | Specification on Media Handling Aspects of IMS-based Telepresence | 334d? | 2014-09-09 A | 2015-12-16 A | 100% |  |  |  |  |  | finish no earlier than 2015-12-16 | S4 | 2672h | 2672h | IMS_TELEP_S4 | PCG-33 | Intel | ozgur.oyman@intel.com | Rel-13 | SP-65 |  |  |  |  |  |
| 570 | 202.3 | (IETF) CLUE Protocol (draft-ietf-clue-protocol) | 331d? | 2015-12-10 A | 2017-03-15 | 60% | 132.4d? |  |  |  | 283d | finish no earlier than 2017-03-15 | S4-IETF | 2648h | 1588.8h | IMS_TELEP_S4 | PCG-36 | Intel | ozgur.oyman@intel.com | Rel-13 | TSG#71 |  |  |  |  |  |
| 571 | 202.4 | (IETF) Mapping RTP streams to CLUE media captures (draft-ietf-clue-rtp-mapping) | 331d? | 2015-12-10 A | 2017-03-15 | 60% | 132.4d? |  |  |  | 283d | finish no earlier than 2017-03-15 | S4-IETF | 2648h | 1588.8h | IMS_TELEP_S4 | PCG-36 | Intel | ozgur.oyman@intel.com | Rel-13 | TSG#71 |  |  |  |  |  |
| 572 | 202.5 | (IETF) DTLS Encapsulation of SCTP Packets (draft-ietf-tsvwg-sctp-dtls-encaps) | 331d? | 2015-12-10 A | 2017-03-15 | 95% | 16.55d? |  |  |  | 283d | finish no earlier than 2017-03-15 | S4-IETF | 2648h | 2515.6h | IMS_TELEP_S4 | PCG-36 | Intel | ozgur.oyman@intel.com | Rel-13 | TSG#71 |  |  |  |  |  |
| 573 | 202.6 | (IETF) Using Simulcast in SDP and RTP Sessions (draft-ietf-mmusic-sdp-simulcast) | 331d? | 2015-12-10 A | 2017-03-15 | 60% | 132.4d? |  |  |  | 283d | finish no earlier than 2017-03-15 | S4-IETF | 2648h | 1588.8h | IMS_TELEP_S4 | PCG-36 | Ericsson | tomas.frankkila@ericsson.com | Rel-13 | TSG#71 |  |  |  |  |  |
| 574 | 203 | **RAN Sharing Enhancements** | 657d? | 2013-06-19 A | 2015-12-15 A | 100% |  | 2013-06-19 | 2013-12-11 | 129d? |  |  | S1; R3 | 16824h | 16824h | RSE | PCG-31 | NEC | joerg.swetina@neclab.eu | Rel-13 | SP-60 | Alain | RSE |  |  |  |
| 575 | 203.1 | Stage 1 for RAN Sharing Enhancements | 129d? | 2013-06-19 A | 2013-12-11 A | 100% |  | 2013-06-19 | 2013-12-11 | 129d? |  |  | S1 | 1032h | 1032h | RSE-SA1 | PCG-31 | NEC | joerg.swetina@neclab.eu | Rel-13 | SP-60 | Alain |  |  |  |  |
| 576 | 203.2 | **RAN aspects of RAN Sharing Enhancements for LTE** | 330d? | 2014-09-12 A | 2015-12-15 A | 100% |  | 2014-06-13 | 2015-06-12 | 261d? |  |  | R3 | 5280h | 5280h | RSE-RAN_LTE | PCG-33 | NEC | Siva.Vakeesar@emea.nec.com | Rel-13 | RP-65 |  | RSE-RAN_LTE |  |  |  |
| 577 | 203.2.1 | Core part: RAN aspects of RAN Sharing Enhancements for LTE | 330d? | 2014-09-12 A | 2015-12-15 A | 100% |  | 2014-06-13 | 2015-06-12 | 261d? |  | finish no earlier than 2015-12-15 | R3 | 2640h | 2640h | RSE-RAN_LTE-Core | PCG-33 | NEC | Siva.Vakeesar@emea.nec.com | Rel-13 | RP-65 |  | RSE-RAN_LTE-Core |  |  | RP-151295 |
| 578 | 204 | **Enhancements to WEBRTC interoperability** | 529d? | 2014-03-07 A | 2016-03-11 | 95% | 24.12d? | 2014-03-07 | 2015-06-17 | 334d? | 547d |  | S1; S2; S3 | 27336h | 16630.6h | eWebRTCi | PCG-32 | Alcatel-Lucent | betsy.covell@alcatel-lucent.com | Rel-13 | SP-63 | Alain | eWebRTCi |  |  |  |
| 579 | 204.1 | Stage 1 for Enhancements to WEBRTC interoperability | 139d? | 2014-03-07 A | 2014-09-17 A | 100% |  | 2014-03-07 | 2014-09-17 | 139d? |  | finish no earlier than 2014-09-17 | S1 | 1112h | 1112h | eWebRTCi | PCG-32 | Alcatel-Lucent | betsy.covell@alcatel-lucent.com | Rel-13 | SP-63 | Alain |  |  |  | S1-143303 |
| 580 | 204.2 | TR on Stage 2 for Enhancements to WEBRTC interoperability | 196d? | 2014-06-19 A | 2015-03-18 A | 100% |  | 2014-06-18 | 2015-03-18 | 196d? |  | finish no earlier than 2015-03-18 | S2 | 1568h | 1568h | eWebRTCi | PCG-33 | China Mobile | Yu Qing (yuqing@chinamobile.com) | Rel-13 | SP-64 |  |  |  |  |  |
| 581 | 204.3 | Stage 2 for Enhancements to WEBRTC interoperability | 261d? | 2014-06-23 A | 2015-06-17 A | 100% |  | 2014-06-18 | 2015-06-17 | 261d? |  | finish no earlier than 2015-06-17 | S2 | 2088h | 2088h | eWebRTCi | PCG-33 | China Mobile | Yu Qing (yuqing@chinamobile.com) | Rel-13 | SP-64 |  |  |  |  |  |
| 582 | 204.4 | TR on Security for Enhancements to WEBRTC interoperability | 273d? | 2014-09-17 A | 2015-09-30 A | 100% |  |  |  |  |  | start no earlier than 2014-09-17 | S3 | 2184h | 2184h | eWebRTCi | PCG-33 | Ericsson | vesa.lehtovirta@ericsson.com | Rel-13 | SP-65 |  |  |  |  |  |
| 583 | 204.5 | Security for Enhancements to WEBRTC interoperability | 273d? | 2014-09-17 A | 2015-09-30 A | 100% |  |  |  |  |  | start no earlier than 2014-09-17 | S3 | 2184h | 2184h | eWebRTCi | PCG-33 | Ericsson | vesa.lehtovirta@ericsson.com | Rel-13 | SP-65 |  |  |  |  |  |
| 584 | 204.6 | (IETF) Session Traversal Utilities for NAT (STUN) Extension for Third Party Authorization (draft-ietf-tram-turn-third-party-authz) | 198d? | 2014-09-17 A | 2015-08-12 A | 100% |  |  |  |  |  | start no earlier than 2014-09-17 | S3-IET | 1584h | 1584h | eWebRTCi | PCG-35 | Alcatel-Lucent |  | Rel-13 | CP-69 |  |  |  |  |  |

Notes:
- 556: SP#65 updated WID SP-140153=>SP-140631 (BBII & BBIII stopped). Triggered by Rel-12 TR 22.805 Study on User Plane Congestion management (FS_UPCON) / Impacted TSs and TRs: Stage 1/2/3
- 557: SP#63 moved to Rel-13 updated WID SP-120890=>SP-140153. SP#59 completed. Convert TR 22.805 clause 6 consolidated requirements to normative requirements in 22.101. 3/3/15: start date corrected (was Mar 12) / Impacted TSs and TRs: 22.101
- 558: SP#65 updated WID SP-140153=>SP-140631. TR 23.705v100 for Information. Dec.14: 87->98%. Mar15: 100% / Impacted TSs and TRs: new TR 23.705
- 559: SP#62 stopped at 0% completion / Impacted TSs and TRs: TBD
- 560: SP#65 updated WID SP-140153=>SP-140631. IncludES in CP-150RAN Congestion Detection: , RAN Traffic Differentiation, RAN Congestion Reporting, CN Congestion Mitigation mechanisms, Dynamic Policy Control
- 561: SP#65 updated WID SP-140153=>S2-142850 (added impacted specs). Dec.14: 70->100% only if RAN agrees to standardize the FPI / Impacted TSs and TRs: 23.060, 23.203, 23.401
- 562: Stage 3; WID: CP-140734->CP-140929. June 2015: WID: CP-140929-> CP-150365. / Impacted TSs and TRs: Stage 3
- 563: Dec.14: 0->60; WID: CP-140734->CP-140929. Mar.15: 60->95%; June2015: Compl:95%->100. WID: CP-140929-> CP-150365. / Impacted TSs and TRs: 29.201, 29.212, 29.213, 29.214, 29.215, 29.219, New TS 29.217 (PCC over Np)
- 564: Dec.14: 0->20; WID: CP-140734->CP-140929. Mar. 15: 50%; June2015: Compl:50%->90. WID: CP-140929-> CP-150365.; 07/09/15: 90%->100 / Impacted TSs and TRs: 23.003, 29.303, New TS 29.405 (UPCON over Nq)
- 565: SP#65 updated WID SP-140153=>SP-140631 (BBII & BBIII stopped). IncludES in CP-150Content specific UP prioritization (Video), Application specific UP prioritization / Impacted TSs and TRs: TBD
- 566: SP#65 updated WID SP-140153=>SP-140631 (BBII & BBIII stopped). IncludES in CP-150Uplink Congestion Management, Un/Attended UE Information / Impacted TSs and TRs: TBD
- 567: Can be seen as an "enhancement" of Rel-12 IMS-based Telepresence (IMS_TELEP) UID_530042. Mar. 15: 20%
- 568: Dec.14: 0->10%. 8/4/15: 20%; June2015: Compl:20%->30; Aug2015: 30%->35; 07/09/15: 35%->60; 7/12/15: 60%->100 / Impacted TSs and TRs: New TR 26.9xy
- 569: Dec.14: 0->10%. 8/4/15: 20%; June2015: Compl:20%->30; 07/09/15: 30%->60; 7/12/15: 60%->100 / Impacted TSs and TRs: New TS 26.1xy
- 570: Impacted TSs and TRs: 26.22
- 571: Impacted TSs and TRs: 26.22
- 572: Impacted TSs and TRs: 26.22
- 573: Impacted TSs and TRs: 26.114, 26.223
- 574: Triggered by Rel-12 TR 22.852 Study on RAN Sharing Enhancements (FS_RSE)
- 575: SP#62 completed / Impacted TSs and TRs: 22.101
- 576: Triggered by TR 36.856 Study on RAN aspects of RAN Sharing Enhancements for LTE (FS_RSE-RAN_LTE) & SA1 22.101 Stage 1 / Impacted TSs and TRs: LTE
- 577: ; CD:Mon 15/06/15->Tue 15/09/15; Stat Rep: -->RP-141891 1st Apr 15: Compl:15%->20% 1st Apr 15: Stat Rep: RP-141891->RP-150289 03/07/15: Compl:20%->75% 03/07/15: Stat Rep: RP-150289->RP-150875 29/09/15: Compl:75%->80% 29/09/15: CD:Tue 15/09/15->Tue 15/1...; ; ; ; ; ; ; ; ; ; ; ; ; ; ; ; ; ; ; ; ; ; ; ; ; ; ; ; ; ; ; ; ; ; ; ; ; ; ; ; 1/1/16: Compl:80%->100%; ; ; ; ; ; ; ; ; ; ; ; ; ; ; ; ; ; ; ; ; ; ; ; ; ; ; ; ; ; ; ; ; ; ; ; ; ; ; ; 1/1/16: WID: RP-141671->RP-151827 / Impacted TSs and TRs: 36.300, 36.413, 36.423
- 578: SP#65 updated WID SP-14028=>SP-140630 (added SA3 part, SA1 change). Add enhanced interoperability support for WebRTC to Rel-12 Web Real Time Communication (WebRTC) Access to IMS. / Impacted TSs and TRs: Stage 1/2
- 579: SP#65 completed. Updated WID SP-140286=>SP-140630 / Impacted TSs and TRs: 22.228
- 580: SP#65 updated WID SP-14028=>SP-140630 (added SA3 part). Dec.14: 9->55%; June2015: Compl:55%->85; 07/09/15: 85%->100 / Impacted TSs and TRs: New TR 23.706
- 581: SP#65 updated WID SP-14028=>SP-140630 (added SA3 part); June2015: Compl:0%->85; 07/09/15: 85%->100 / Impacted TSs and TRs: 23.228
- 582: SP#65 updated WID SP-14028=>SP-140630 (added SA3 part). Dec.14: 0->20%, TR number added. 3/3/15: 30%.; June2015: Compl:30%->75; 11/12/15: 54%->100; 11/12/15: 100%->100 / Impacted TSs and TRs: New TR 33.872
- 583: SP#65 updated WID SP-14028=>SP-140630 (added SA3 part). Dec.14: 0->20%; 11/12/15: 15%->100 / Impacted TSs and TRs: 33.203, 33.328
- 584: TS 33.203 CR0235draft-ietf-tram-turn-third-party-authz; 7/3/16: 10%->100 / Impacted TSs and TRs: 33.203, RRC 7635 (was draft-ietf-tram-turn-third-party-authz)

| ID | WBS | Task | Duration | Start | Finish | Complete | Remaining | Baseline start | Baseline finish | Baseline duration | Total slack | Constraint | Resources | Work | Actual work | Acronym | PCG approved | WI rapporteur name | WI rapporteur e-mail | Release | TSG approved | Impacted TSs and TRs | MCC resp | Acronym_3GU_Export | Special Focus Doc |
| --- | --- | --- | --- | --- | --- | --- | --- | --- | --- | --- | --- | --- | --- | --- | --- | --- | --- | --- | --- | --- | --- | --- | --- | --- | --- |
| 585 | 204.7 | **Stage 3 for Enhancements to WebRTC interoperability** | 135d? | 2015-09-07 A | 2016-03-11 | 84% | 21.09d? |  |  |  | 547d |  | ct | 6048h | 4340h | eWebRTCi-CT | PCG-35 | China Mobile, Song Yue | songyue@chinamobile.com | Rel-13 | CP-69 |  |  |  |  |
| 586 | 204.7.1 | CT1 aspects 3 for Enhancements to WebRTC interoperability | 75d? | 2015-09-07 A | 2015-12-18 A | 100% |  |  |  |  |  | finish no earlier than 2015-12-18 | C1 | 600h | 600h | eWebRTCi-CT | PCG-35 | China Mobile, Song Yue | songyue@chinamobile.com | Rel-13 | CP-69 | 24.371, 24.229 |  |  |  |
| 587 | 204.7.2 | CT3 aspects for Enhancements to WebRTC interoperability | 135d? | 2015-09-07 A | 2016-03-11 A | 100% |  |  |  |  |  | finish no earlier than 2016-03-11 | C3 | 1080h | 1080h | eWebRTCi-CT | PCG-35 | China Mobile, Song Yue | songyue@chinamobile.com | Rel-13 | CP-69 | 29.214 |  |  |  |
| 588 | 204.7.3 | CT4 aspects for Enhancements to WebRTC interoperability | 135d? | 2015-09-07 A | 2016-03-11 A | 100% |  |  |  |  |  | finish no earlier than 2016-03-11 | C4 | 1080h | 1080h | eWebRTCi-CT | PCG-35 | China Mobile, Song Yue | songyue@chinamobile.com | Rel-13 | CP-69 | 29.228, 23.334, 29.334, 23.008 |  |  |  |
| 589 | 204.7.4 | (IETF) SDP-based Data Channel Negotiation (draft-ietf-mmusic-data-channel-sdpneg) | 69d? | 2015-12-08 A | 2016-03-11 | 75% | 17.25d? |  |  |  | 547d | finish no earlier than 2016-03-11 | C1-IETF; SA4-IETF | 1104h | 828h | eWebRTCi-CT | PCG-36 | Ericsson | christer.holmberg@ericsson.com | Rel-13 | TSG#71 | 24.371, 24.229 |  |  |  |
| 590 | 204.7.5 | (IETF) MSRP over Data Channels (draft-ietf-mmusic-msrp-usage-data-channel) | 69d? | 2015-12-08 A | 2016-03-11 | 75% | 17.25d? |  |  |  | 547d | start no earlier than 2015-12-08 | C1-IETF | 552h | 414h | eWebRTCi-CT | PCG-36 | Ericsson | christer.holmberg@ericsson.com | Rel-13 | TSG#71 | 24.371, 24.229, 26.223 |  |  |  |
| 591 | 204.7.6 | (IETF) A Language for Rules Describing JSON Content (draft-newton-json-content-rules) | 69d? | 2015-12-08 A | 2016-03-11 | 25% | 51.75d? |  |  |  | 547d | start no earlier than 2015-12-08 | C3-IETF | 552h | 138h | eWebRTCi-CT | PCG-36 | Ericsson | christer.holmberg@ericsson.com | Rel-13 | TSG#71 | 24.371, 24.229, 26.223 |  |  |  |
| 592 | 205 | **Improvements to CS/PS coordination in UTRAN/GERAN Shared Networks** | 573d? | 2014-03-07 A | 2016-05-12 | 99% | 0d? | 2014-03-07 | 2014-12-10 | 199d? | 0d |  | S2 | 9768h | 6811.23h | CSPS_Coord | PCG-32 | Ericsson | roland.gustafsson@ericsson.com | Rel-13 | SP-63 | Stage 2 | Maurice | CSPS_Coord |  |
| 593 | 205.1 | TR on Stage 2 for Improvements to CS/PS coordination in UTRAN/GERAN Shared Networks | 140d? | 2014-03-07 A | 2014-09-17 A | 100% |  | 2014-03-07 | 2014-12-10 | 199d? |  | finish no earlier than 2014-09-17 | S2 | 1120h | 1120h | CSPS_Coord-SA2TR | PCG-32 | Ericsson | roland.gustafsson@ericsson.com | Rel-13 | TSG-63 | New TR 23.704 | Maurice |  |  |
| 594 | 205.2 | Stage 2 for Improvements to CS/PS coordination in UTRAN/GERAN Shared Networks | 201d? | 2014-03-12 A | 2014-12-12 A | 100% |  | 2014-03-07 | 2014-12-10 | 199d? |  | finish no earlier than 2014-12-12 | S2 | 1608h | 1608h | CSPS_Coord-SA2 | PCG-32 | Ericsson | roland.gustafsson@ericsson.com | Rel-13 | TSG-63 | 23.216, 23.251, 23.272 | Maurice |  |  |
| 595 | 205.3 | RAN aspects for improvements to CS/PS coordination in GERAN Shared Networks | 307d? | 2015-03-11 A | 2016-05-12 A | 100% |  |  |  |  |  | finish no earlier than 2016-05-12 | G2 | 2456h | 2456h | CSPS_Coord_GERAN |  | Nicklas Johansson, Ericsson LM | Nicklas.Johansson@Ericsson.com | Rel-13 | GP-65 | 48.008, 48.018 |  |  |  |
| 596 | 206 | **Enhancements to Proximity-based Services** | 1052d? | 2013-03-18 A | 2017-03-15 | 97% | 33.68d? | 2014-06-18 | 2015-06-12 | 258d? | 283d |  | S1; S2; S3 | 36608h | 28107.2h | eProSe | PCG-33 | Qualcomm | Eddy Hall (edhall@qti.qualcomm.com) | Rel-13 | SP-64 | Stage 1/2 |  | eProSe | Public Safety (A-A) |
| 597 | 206.1 | Stage 1 for Enhancements to Proximity-based Services | 66d? | 2014-06-19 A | 2014-09-17 A | 100% |  | 2014-06-18 | 2014-09-17 | 66d? |  | finish no earlier than 2014-09-17 | S1 | 528h | 528h | eProSe-SA1 | PCG-33 | Qualcomm | Eddy Hall (edhall@qti.qualcomm.com) | Rel-13 | SP-64 | 22.115, 22.278 |  |  | Public Safety (A-A) |
| 598 | 206.2 | Stage 2 for Enhancements to Proximity-based Services - Extensions | 326d? | 2014-06-23 A | 2015-09-16 A | 100% |  | 2014-06-18 | 2015-06-12 | 258d? |  | finish no earlier than 2015-09-16 | S2 | 2608h | 2608h | eProSe-Ext-SA2 | PCG-33 | Qualcomm | Haris Zisimopoulos (harisz@qti.qualcomm.com) | Rel-13 | SP-64 | 23.303, TBD |  | eProSe-Ext | Public Safety (A-A) |
| 599 | 206.3 | TR on Stage 2 for Enhancements to Proximity-based Services - Extensions | 193d? | 2014-06-18 A | 2015-03-13 A | 100% |  | 2014-06-18 | 2015-03-13 | 193d? |  | finish no earlier than 2015-03-13 | S2 | 1544h | 1544h | eProSe-Ext-SA2TR | PCG-33 | Qualcomm | Haris Zisimopoulos (harisz@qti.qualcomm.com) | Rel-13 | SP-64 | New TR 23.713 |  |  | Public Safety (A-A) |
| 600 | 206.4 | Security for Enhancements to Proximity-based Services - Extensions | 388d? | 2014-09-19 A | 2016-03-11 A | 100% |  |  |  |  |  | finish no earlier than 2016-03-11 | S3 | 3104h | 3104h | eProSe-Ext-SA3 | PCG-33 | Qualcomm | Adrian Escott (aescott@qti.qualcomm.com) | Rel-13 | SP-65 | 33.303 |  |  | Public Safety (A-A) |
| 601 | 206.5 | **CT aspects of enhancements to Proximity-based** | 195d? | 2015-06-15 A | 2016-03-11 A | 100% |  |  |  |  |  |  | C1 | 7304h | 7304h | eProSe-Ext-CT | PCG-35 | Lena Chaponniere | lguellec@qti.qualcomm.com | Rel-13 | CP-68 | 23.122, 24.301, 24.333, 24.334 |  |  |  |
| 602 | 206.5.1 | CT1 aspects of enhancements to Proximity-based | 195d? | 2015-06-15 A | 2016-03-11 A | 100% |  |  |  |  |  | finish no earlier than 2016-03-11 | C1 | 1560h | 1560h | eProSe-Ext-CT | PCG-35 | Lena Chaponniere | lguellec@qti.qualcomm.com | Rel-13 | CP-68 | 29.343 |  |  |  |
| 603 | 206.5.2 | CT3 aspects of enhancements to Proximity-based | 133d? | 2015-06-15 A | 2015-12-16 A | 100% |  |  |  |  |  | start no earlier than 2015-06-15 | C3 | 1064h | 1064h | eProSe-Ext-CT | PCG-35 | Lena Chaponniere | lguellec@qti.qualcomm.com | Rel-13 | CP-68 | 23.003, 23.008, 29.272, 29.344, 29.345 |  |  |  |
| 604 | 206.5.3 | CT4 aspects of enhancements to Proximity-based | 195d? | 2015-06-15 A | 2016-03-11 A | 100% |  |  |  |  |  | finish no earlier than 2016-03-11 | C4 | 1560h | 1560h | eProSe-Ext-CT | PCG-35 | Lena Chaponniere | lguellec@qti.qualcomm.com | Rel-13 | CP-68 | 31.102, 31.111 |  |  |  |
| 605 | 206.5.4 | CT6 aspects of enhancements to Proximity-based | 195d? | 2015-06-15 A | 2016-03-11 A | 100% |  |  |  |  |  | finish no earlier than 2016-03-11 | C6 | 1560h | 1560h | eProSe-Ext-CT | PCG-35 | Lena Chaponniere | lguellec@qti.qualcomm.com | Rel-13 | CP-68 | 31.102, 31.111 |  |  |  |
| 606 | 206.6 | Study on Security for Proximity-based Services | 596d? | 2013-03-18 A | 2015-06-17 A | 100% |  | 2013-03-07 | 2014-09-17 | 401d? |  | finish no earlier than 2015-06-17 | S3 | 4768h | 4768h | FS_ProSe_Sec | PCG-30 | Qualcomm | Adrian Escott (aescott@qti.qualcomm.com) | Rel-13 | SP-59 | 33.833 | Mirko | FS_ProSe_Sec | Public Safety (A-A) |
| 607 | 206.7 | Charging Aspects of Enhanced Proximity-based Services | 199d? | 2016-06-13 A | 2017-03-15 | 60% | 79.6d? |  |  |  | 283d | finish no earlier than 2017-03-15 | S5 | 1592h | 955.2h | CH14-ProSe | PCG-37 | Chen, Shan | chenshan@huawei.com | Rel-14 | TSG#72 | 32.240, 32.251, 32.277, 32.298, 32.299 |  |  |  |
| 608 | 207 | **voice over E-UTRAN Paging Policy Differentiation** | 133d? | 2014-06-16 A | 2014-12-12 A | 100% |  | 2014-06-16 | 2014-12-10 | 128d? |  |  | S1; S2; C4; C1; C3 | 9244.75h | 9244.75h | voE_UTRAN_PPD | PCG-33 | Alcatel-Lucent | (betsy.covell@alcatel-lucent.com) | Rel-13 | SP-64 | Stage 1/2 |  | voE_UTRAN_PPD |  |
| 609 | 207.1 | Stage 1 for voice over E-UTRAN Paging Policy Differentiation | 3d? | 2014-06-16 A | 2014-06-18 A | 100% |  | 2014-06-16 | 2014-06-18 | 3d? |  | finish no earlier than 2014-06-18 | S1 | 24h | 24h | voE_UTRA-N_PPD-SA1 | PCG-33 | Alcatel-Lucent | betsy.covell@alcatel-lucent.com | Rel-13 | SP-64 | 22.228, 22.278 |  |  |  |
| 610 | 207.2 | Stage 2 for voice over E-UTRAN Paging Policy Differentiation | 128d? | 2014-06-18 A | 2014-12-12 A | 100% |  | 2014-06-18 | 2014-12-10 | 126d? |  | finish no earlier than 2014-12-12 | S2 | 1024h | 1024h | voE_UTRAN_PPD-SA2 | PCG-33 | Alcatel-Lucent | laurent.thiebaut@alcatel-lucent.com | Rel-13 | SP-64 | 23.228, 23.401 |  |  |  |

Notes:
- 585: 7/12/15: WID:CP-150498->CP-150790->CP-150767
- 586: 7/12/15: 0%->100; 7/12/15: WID:CP-150498->CP-150790->CP-150767
- 587: 7/12/15: WID:CP-150498->CP-150790->CP-150767. ES in CP-150644; 7/3/16: 0%->100
- 588: 7/12/15: WID:CP-150498->CP-150790->CP-150767. ES in CP-150623; 7/3/16: 0%->100
- 589: 7/3/16: Introduced by IETF updates
- 590: 7/3/16: Introduced by IETF updates
- 591: 7/3/16: Introduced by IETF updates
- 592: Provide improvements to the solutions for CS/PS coordination in TS 23.251 to ensure that CS/PS coordination can be achieved for all mobility scenarios
- 593: SP#65 completed. TR 23.704v200 for Approval
- 594: Dec.14: 0->100%
- 595: June2015: Compl:0%->35; 07/09/15: 35%->50, FCD:08/15->11/15; 7/12/15: 50%->95, FCD: 12/15->02/16. 02/03/16: FCD: 02/16->05/16; 13/6/16: 95%->100
- 596: -
- 597: SP#65 completed. Some Rel-12 ProSe service requirements have not been implemented at Stage 2/3 level. These are taken up in Rel-13 Stage 2/3 and need Stage 1 appropriate service requirements. No new service requirements are introduced.
- 598: SP#65 updated WID SP-140385=>SP-140573 (added SA3 part). Mar15: WID: SP-140573 ->SP-150028; June2015: Compl:0%->30. FCD: June->Sept. 07/09/15: 24->70%; 07/09/15: 70%->90; 7/12/15: 90%->100
- 599: SP#65 updated WID SP-140385=>SP-140573 (added SA3 part). Acronym corrected: eProSe-Ex-SA2TRt->eProSe-Ext-SA2TR. Mar15: 60% Mar15: WID: SP-140573 ->SP-150028; June2015: Compl:60%->90; 07/09/15: 90%->95; 07/09/15: 95%->100
- 600: SP#65 updated WID SP-140385=>SP-140573 (added SA3 part). Acronym corrected: eProSe-Ex-SA3t->eProSe-Ext-SA3. Mar15: WID: SP-140573 ->SP-150028; 7/12/15: 0%->75; 10/12/15: FCD ->03/16, ES in SP-150714; 7/3/16: 75%->100
- 602: 07/09/15: 0%->40; 7/12/15: 40%->90. FCD -> 03/16, ES in CP-150724; 7/3/16: 90%->100
- 603: 07/09/15: 0%->60; 8/3/16: 60%->100
- 604: 07/09/15: 0%->10; 7/12/15: 10%->80. FCD->03/16. ES in CP-150616; 7/3/16: 80%->100
- 605: 7/12/15: FCD -> 03/16, ES in CP-150839. FCD->03/16. ES in CP-150616; 7/3/16: 0%->95; 8/3/16: 95%->100
- 606: SP#65 updated WID SP-140300=>SP-140629 (Moved the TR phase to Rel-13 as a stand-alone Study). Completion 09/14=>06/15. SP#64 TR 33.833 v100 for Information. 4/3/15: 95%->70% (more topics to be included); June2015: Compl:70%->75; 7/12/15: 75%->95; 7/3/1...; 1/12/16: 98%->100
- 607: 19/9/16: 0%->40; 1/12/16: 40%->60
- 608: -
- 609: SP#64 approved WID & completed
- 610: Architectural enhancements allowing a differentiated paging policy for IMS voice calls over E-UTRAN. Dec.14: 25->100%

| ID | WBS | Task | Duration | Start | Finish | Complete | Remaining | Baseline start | Baseline finish | Baseline duration | Total slack | Constraint | Resources | Work | Actual work | Acronym | PCG approved | WI rapporteur name | Release | TSG approved | Acronym_3GU_Export |
| --- | --- | --- | --- | --- | --- | --- | --- | --- | --- | --- | --- | --- | --- | --- | --- | --- | --- | --- | --- | --- | --- |
| 611 | 207.3 | **CT aspects of voice over E-UTRAN Paging Policy Differentiation** | 63d? | 2014-09-16 A | 2014-12-09 A | 100% |  |  |  |  |  |  | C4; C1; C3 | 3024h | 3024h | voE_UTRAN_PPD-CT | PCG-33 | Alcatel-Lucent | Rel-13 | CP-65 |  |
| 612 | 207.3.1 | CT4 part of CT aspects of voice over E-UTRAN Paging Policy Differentiation | 63d? | 2014-09-16 A | 2014-12-09 A | 100% |  |  |  |  |  | finish no earlier than 2014-12-09 | C4 | 504h | 504h | voE_UTRAN_PPD-CT | PCG-33 | Alcatel-Lucent | Rel-13 | CP-65 |  |
| 613 | 207.3.2 | CT1 part of CT aspects of voice over E-UTRAN Paging Policy Differentiation | 63d? | 2014-09-16 A | 2014-12-09 A | 100% |  |  |  |  |  | finish no earlier than 2014-12-09 | C1 | 504h | 504h | voE_UTRAN_PPD-CT | PCG-33 | Alcatel-Lucent | Rel-13 | CP-65 |  |
| 614 | 207.3.3 | CT3 part of CT aspects of voice over E-UTRAN Paging Policy Differentiation | 63d? | 2014-09-16 A | 2014-12-09 A | 100% |  |  |  |  |  | finish no earlier than 2014-12-09 | C3 | 504h | 504h | voE_UTRAN_PPD-CT | PCG-33 | Alcatel-Lucent | Rel-13 | CP-65 |  |
| 615 | 208 | **IP Flow Mobility support for S2a and S2b Interfaces** | 524d? | 2014-06-18 A | 2016-06-15 | 99% | 0d? | 2014-06-18 | 2015-06-17 | 261d? | 0d |  | S2 | 15656h | 14386.6h | NBIFOM | PCG-33 | Tricci So, ZTE | Rel-13 | SP-64 | NBIFOM |
| 616 | 208.1 | TR for IP Flow Mobility support for S2a and S2b Interfaces | 193d? | 2014-06-18 A | 2015-03-13 A | 100% |  | 2014-06-18 | 2015-03-13 | 193d? |  | finish no earlier than 2015-03-13 | S2 | 1544h | 1544h | NBIFOM-SA2TR | PCG-33 | Tricci So, ZTE | Rel-13 | SP-64 |  |
| 617 | 208.2 | Stage 2 for IP Flow Mobility support for S2a and S2b Interfaces | 326d? | 2014-06-23 A | 2015-09-16 A | 100% |  | 2014-06-18 | 2015-06-17 | 261d? |  | finish no earlier than 2015-09-16 | S2 | 2608h | 2608h | NBIFOM-SA2 |  | Tricci So, ZTE | Rel-13 | TSG-64 |  |
| 618 | 208.3 | Charging Aspects of IP Flow Mobility support for S2a and S2b Interfaces (NBIFOM) | 196d? | 2015-09-16 A | 2016-06-15 A | 100% |  | 2014-06-18 | 2015-06-17 | 261d? |  | finish no earlier than 2016-06-15 | S5 | 1568h | 1568h | NBIFOM-CH | PCG-35 | GUO Wenjie, ZTE | Rel-13 | CP-69 |  |
| 619 | 208.4 | **CT aspects of IP Flow Mobility support for S2a and S2b Interfaces** | 195d? | 2015-06-15 A | 2016-03-11 A | 100% |  |  |  |  |  |  | C1 | 5744h | 5744h | NBIFOM-CT | PCG-35 | Xingyue(Joy) Zhou, ZTECorporation | Rel-13 | CP-68 |  |
| 620 | 208.4.1 | CT1 aspects of IP Flow Mobility support for S2a and S2b Interfaces | 195d? | 2015-06-15 A | 2016-03-11 A | 100% |  |  |  |  |  | finish no earlier than 2016-03-11 | C1 | 1560h | 1560h | NBIFOM-CT | PCG-35 | Xingyue(Joy) Zhou, ZTECorporation. ES in 641 | Rel-13 | CP-68 |  |
| 621 | 208.4.2 | CT3 aspects of IP Flow Mobility support for S2a and S2b Interfaces | 195d? | 2015-06-15 A | 2016-03-11 A | 100% |  |  |  |  |  | finish no earlier than 2016-03-11 | C3 | 1560h | 1560h | NBIFOM-CT | PCG-35 | 680001Xingyue(Joy) Zhou, ZTECorporation. ES in 641 | Rel-13 | CP-68 |  |
| 622 | 208.4.3 | CT4 aspects of IP Flow Mobility support for S2a and S2b Interfaces | 133d? | 2015-06-15 A | 2015-12-16 A | 100% |  |  |  |  |  | start no earlier than 2015-06-15 | C4 | 1064h | 1064h | NBIFOM-CT | PCG-35 | Xingyue(Joy) Zhou, ZTECorporation | Rel-13 | CP-68 |  |
| 623 | 209 | **Double Resource Reuse for Multiple Media Sessions** | 264d? | 2014-03-14 A | 2015-03-13 A | 100% |  | 2014-03-14 | 2015-03-13 | 261d? |  |  | S2 | 5952h | 5952h | DRuMS | PCG-33 | Ericsson | Rel-13 | SP-64 | DRuMS |
| 624 | 209.1 | Stage 2 for Double Resource Reuse for Multiple Media Sessions | 264d? | 2014-03-14 A | 2015-03-13 A | 100% |  | 2014-03-14 | 2015-03-13 | 261d? |  | finish no earlier than 2015-03-13 | S2 | 2088h | 2088h | DRuMS-SA2 | PCG-33 | Ericsson | Rel-13 | SP-64 |  |
| 625 | 209.2 | **CT aspects of Double Resource Reuse for Multiple Media Sessions** | 73d? | 2014-12-03 A | 2015-03-13 A | 100% |  |  |  |  |  |  | C3 | 1752h | 1752h | DRuMS-CT | PCG-34 | Ericsson | Rel-13 | CT-66 |  |
| 626 | 209.2.1 | CT1 aspects of Double Resource Reuse for Multiple Media Sessions | 73d? | 2014-12-03 A | 2015-03-13 A | 100% |  |  |  |  |  | start no earlier than 2014-12-03 | C1 | 584h | 584h | DRuMS-CT | PCG-34 | Ericsson | Rel-13 | CT-66 |  |
| 627 | 209.2.2 | CT3 aspects of Double Resource Reuse for Multiple Media Sessions | 73d? | 2014-12-03 A | 2015-03-13 A | 100% |  |  |  |  |  | start no earlier than 2014-12-03 | C3 | 584h | 584h | DRuMS-CT | PCG-34 | Ericsson | Rel-13 | CT-66 |  |
| 628 | 210 | Lawful Interception in the 3GPP Rel-13 | 656d? | 2014-06-18 A | 2016-12-15 A | 100% |  | 2014-06-18 | 2015-12-09 | 386d? |  | finish no earlier than 2016-12-15 | S3 | 5248h | 5248h | LI13 | PCG-33 | PIDS, Alcatel-Lucent | Rel-13 | SP-64 | LI13 |
| 629 | 211 | Study on Lawful Interception Service Evolution | 386d? | 2014-06-23 A | 2015-12-09 | 10% | 347.4d? | 2014-06-18 | 2015-12-09 | 386d? | 614d | finish no earlier than 2015-12-09 | S3 | 3088h | 308.8h | FS_LISE | PCG-33 | Alcatel-Lucent | Rel-13 | SP-64 | FS_LISE |
| 630 | 212 | **Video enhancements by Region-Of-Interest information signalling** | 394d? | 2014-06-18 A | 2015-12-16 A | 100% |  | 2014-06-18 | 2015-06-17 | 261d? |  |  | S4 | 10016h | 10016h | ROI | PCG-33 | Intel | Rel-13 | SP-64 | ROI |
| 631 | 212.1 | SA4 aspects of Video enhancements by Region-Of-Interest information signalling | 329d? | 2014-06-18 A | 2015-09-16 A | 100% |  |  |  |  |  | finish no earlier than 2015-09-16 | S4 | 2632h | 2632h | ROI | PCG-33 | Intel | Rel-13 | SP-64 |  |
| 632 | 212.2 | **CT Aspects of Video Enhancements by Region-Of-Interest information signalling** | 133d? | 2015-06-15 A | 2015-12-16 A | 100% |  |  |  |  |  |  | C4 | 4256h | 4256h | ROI-CT | PCG-35 | Vivek Gupta, Intel | Rel-13 | CP-68 |  |
| 633 | 212.2.1 | CT1 Aspects of Video Enhancements by Region-Of-Interest information signalling | 133d? | 2015-06-15 A | 2015-12-16 A | 100% |  |  |  |  |  | start no earlier than 2015-06-15 | C1 | 1064h | 1064h | ROI-CT | PCG-35 | Vivek Gupta, Intel | Rel-13 | CP-68 |  |
| 634 | 212.2.2 | CT3 Aspects of Video Enhancements by Region-Of-Interest information signalling | 133d? | 2015-06-15 A | 2015-12-16 A | 100% |  |  |  |  |  | start no earlier than 2015-06-15 | C3 | 1064h | 1064h | ROI-CT | PCG-35 | Vivek Gupta, Intel | Rel-13 | CP-68 |  |
| 635 | 212.2.3 | CT4 Aspects of Video Enhancements by Region-Of-Interest information signalling | 133d? | 2015-06-15 A | 2015-12-16 A | 100% |  |  |  |  |  | start no earlier than 2015-06-15 | C4 | 1064h | 1064h | ROI-CT | PCG-35 | Vivek Gupta, Intel | Rel-13 | CP-68 |  |

Notes:
- 611: Stage 3 / Impacted TSs and TRs: Stage 3 / WI rapporteur e-mail: bruno.landais@alcatel-lucent.com
- 612: Mar.15: 0->100% / Impacted TSs and TRs: 29.274, 29.281 / WI rapporteur e-mail: bruno.landais@alcatel-lucent.com
- 613: Dec.14: 0->50%; 07/09/15: 50%->50; 7/12/15: 50%->100 / Impacted TSs and TRs: 24.229 / WI rapporteur e-mail: bruno.landais@alcatel-lucent.com
- 614: Mar.15: 0->100% / Impacted TSs and TRs: 29.061 / WI rapporteur e-mail: bruno.landais@alcatel-lucent.com
- 615: 06/15: WID: SP-140279->SP-150250 / Impacted TSs and TRs: Stage 2 / WI rapporteur e-mail: tso@zte.com.cn
- 616: Revived the Rel-12 DRAFT TR 23.861 stopped at SP#59 (at 40% completion). Dec.14: 20->60%; June2015: Compl:60%->90, WID: SP-140279->SP-150250 / Impacted TSs and TRs: New TR 23.861 / WI rapporteur e-mail: tso@zte.com.cn
- 617: June2015: Compl:0%->65, WID: SP-140279->SP-150250; 07/09/15: 52%->100 / Impacted TSs and TRs: 23.402, New TS 23.203 / WI rapporteur e-mail: tso@zte.com.cn
- 618: 7/12/15: 0%->50. ES in SP-150710 (wrong UID mentioned in the ES); 7/3/16: 50%->85%, FCD:03/16->06/16; 13/6/16: 85%->100 / Impacted TSs and TRs: 32.251, 32.298, 32.299 / WI rapporteur e-mail: guo.wenjie1@zte.com.cn
- 619: 14/09/15: WID:CP-150285->CP-150497; 7/12/15: WID:CP-150497->CP-150791->874 / Impacted TSs and TRs: 24.161 / WI rapporteur e-mail: zhou.xingyue@zte.com.cn
- 620: 07/09/15: 0%->25; 14/09/15: WID:CP-150285->CP-150497; 7/12/15: 25%->75; 7/12/15: WID:CP-150497->CP-150791->874. FCD -> 03/16. ES in CP-150725; 7/3/16: 75%->100 / Impacted TSs and TRs: 24.301, 24.302, 24.244, 24.008 / WI rapporteur e-mail: zhou.xingyue@zte.com.cn
- 621: 07/09/15: 0%->40; 14/09/15: WID:CP-150285->CP-150497; 7/12/15: 40%->95; 7/12/15: WID:CP-150497->CP-150791->874. FCD -> 03/16. ES in CP-150725; 7/3/16: 95%->100 / Impacted TSs and TRs: 29.212, 29.213, 29.214, 29.215 / WI rapporteur e-mail: zhou.xingyue@zte.com.cn
- 622: 07/09/15: 0%->20; 14/09/15: WID:CP-150285->CP-150497; 7/12/15: 20%->100; 7/12/15: WID:CP-150497->CP-150791->874 / Impacted TSs and TRs: 29.274, 23.008 / WI rapporteur e-mail: zhou.xingyue@zte.com.cn
- 623: - / Impacted TSs and TRs: Stage 2 / WI rapporteur e-mail: George.Foti@ericsson.com
- 624: Dec.14: 49->95%. Mar15: 100% / Impacted TSs and TRs: 23.203, 23.228 / WI rapporteur e-mail: George.Foti@ericsson.com
- 625: Impacted TSs and TRs: 24.229, 24.615, 24.610, 24.605, 29.212, 29.213, 29.214, 29.215
- 626: 5/5/15: C3 corrected in C1; June2015: Compl:65%->90; 07/09/15: 90%->100 / Impacted TSs and TRs: 24.229, 24.615, 24.610, 24.605
- 627: Mar.15: 65->95%; June2015: Compl:95%->100 / Impacted TSs and TRs: 29.212, 29.213, 29.214, 29.215 / WI rapporteur e-mail: Jan Holm
- 628: SP#65 updated WID SP-140400=>SP-140578. 2/4/15: WID SP-140815->SP-150111; June2015: Compl:0%->10. WID: SP-150111->SP-150290; 14/09/15: WID:SP-150290->SP-150460; 7/12/15: 10%->15; 7/3/16: 13%->20; 7/3/16: WID:SP-150460->SP-160043; 19/9/16: 20%->60. FCD se; 1/12/16: 60%->100 / Impacted TSs and TRs: 33.106, 33.107, 33.108 / WI rapporteur e-mail: Koen Jaspers (k.b.jaspers@minjus.nl), terry.jacobson@alcatel-lucent.com
- 629: Linked to LI13 which defines existing LI service requirements in TS 33.106 as well as existing HI1, HI2 & HI3 reference points. 3/3/15: 0->5%; 7/12/15: 5%->10 / Impacted TSs and TRs: 33.826 / WI rapporteur e-mail: terry.jacobson@alcatel-lucent.com
- 630: Dec.14: 5->20%. Mar.15: 40%; 07/09/15: 43%->100 / Impacted TSs and TRs: 26.114 / WI rapporteur e-mail: ozgur.oyman@intel.com
- 631: Created by MCC as the structure of the Feature get expanded to include CT aspects; June2015: Compl:40%->90, FCD: 06/15->09/15; Aug2015: Compl:90%->95 / Impacted TSs and TRs: 26.114 / WI rapporteur e-mail: ozgur.oyman@intel.com
- 632: 14/09/15: WID:CP-150241->CP-150425 / WI rapporteur e-mail: vivek.g.gupta@intel.com
- 633: 07/09/15: 100%->50; 14/09/15: WID:CP-150241->CP-150425; 7/12/15: 50%->100 / Impacted TSs and TRs: 24.229 / WI rapporteur e-mail: vivek.g.gupta@intel.com
- 634: 07/09/15: 100%->10; 14/09/15: WID:CP-150241->CP-150425; 7/12/15: 10%->100 / Impacted TSs and TRs: 29.162 / WI rapporteur e-mail: vivek.g.gupta@intel.com
- 635: 07/09/15: 100%->5; 14/09/15: WID:CP-150241->CP-150425; 7/12/15: 5%->100 / Impacted TSs and TRs: 23.334, 29.334, 29.238 / WI rapporteur e-mail: vivek.g.gupta@intel.com

| ID | WBS | Task | Duration | Start | Finish | Complete | Remaining | Baseline start | Baseline finish | Baseline duration | Total slack | Constraint | Resources | Work | Actual work | Acronym | PCG approved | WI rapporteur name | Release | TSG approved | Acronym_3GU_Export | Status Report | MCC resp |
| --- | --- | --- | --- | --- | --- | --- | --- | --- | --- | --- | --- | --- | --- | --- | --- | --- | --- | --- | --- | --- | --- | --- | --- |
| 636 | 213 | **TV video profile** | 396d? | 2014-09-09 A | 2016-03-11 A | 100% |  |  |  |  |  |  | S4 | 9504h | 9504h | TVProf | PCG-33 | Orange | Rel-13 | SP-65 | TVProf |  |  |
| 637 | 213.1 | TR on TV video profile | 396d? | 2014-09-09 A | 2016-03-11 A | 100% |  |  |  |  |  | finish no earlier than 2016-03-11 | S4 | 3168h | 3168h | TVProf-SA4TR | PCG-33 | Orange | Rel-13 | SP-65 |  |  |  |
| 638 | 213.2 | Specification on TV video profile | 396d? | 2014-09-09 A | 2016-03-11 A | 100% |  |  |  |  |  | finish no earlier than 2016-03-11 | S4 | 3168h | 3168h | TVProf-SA4 | PCG-33 | Orange | Rel-13 | SP-65 |  |  |  |
| 639 | 214 | Enhanced LTE UE Delay test methods and requirements | 464d? | 2014-09-09 A | 2016-06-15 A | 100% |  |  |  |  |  | finish no earlier than 2016-06-15 | S4 | 3712h | 3712h | E_LTE_UED | PCG-33 | Orange | Rel-13 | SP-65 | E_LTE_UED |  |  |
| 640 | 215 | HTML5 Presentation Layer | 334d? | 2014-09-09 A | 2015-12-16 A | 100% |  |  |  |  |  | finish no earlier than 2015-12-16 | S4 | 2672h | 2672h | HTML5 | PCG-33 | Samsung | Rel-13 | SP-65 | HTML5 |  |  |
| 641 | 216 | **Support of EVS in 3G Circuit-Switched networks** | 396d? | 2014-09-09 A | 2016-03-11 | 100% | 0d? |  |  |  | 0d |  | S4; C4; C1; C3; R1; R2; R3 | 42757.6h | 24952h | EVSoCS | PCG-33 | Qualcomm | Rel-13 | SP-65 | EVSoCS |  |  |
| 642 | 216.1 | SA4 aspects of EVS in 3G Circuit-Switched networks | 396d? | 2014-09-09 A | 2016-03-11 A | 100% |  |  |  |  |  | finish no earlier than 2016-03-11 | S4 | 3168h | 3168h | EVSoCS-S4 | PCG-33 | Qualcomm | Rel-13 | SP-65 | EVSoCS |  |  |
| 643 | 216.2 | **CT aspects of EVS in 3G Circuit-Switched Networks** | 268d? | 2015-03-04 A | 2016-03-11 A | 100% |  |  |  |  |  |  | C4; C1; C3 | 12344h | 12344h | EVSoCS-CT | PCG-34 | Qualcomm, Lena Chaponniere | Rel-13 | CP-67 |  |  |  |
| 644 | 216.2.1 | CT1 aspects of EVS in 3G Circuit-Switched Networks | 203d? | 2015-03-04 A | 2015-12-11 A | 100% |  |  |  |  |  | finish no earlier than 2015-12-11 | C1 | 1624h | 1624h | EVSoCS-CT | PCG-34 | Qualcomm, Lena Chaponniere | Rel-13 | CP-67 |  |  |  |
| 645 | 216.2.2 | CT3 aspects of EVS in 3G Circuit-Switched Networks | 268d? | 2015-03-04 A | 2016-03-11 A | 100% |  |  |  |  |  | finish no earlier than 2016-03-11 | C3 | 2144h | 2144h | EVSoCS-CT | PCG-34 | Qualcomm, Lena Chaponniere | Rel-13 | CP-67 |  |  |  |
| 646 | 216.2.3 | CT4 aspects of EVS in 3G Circuit-Switched Networks | 268d? | 2015-03-04 A | 2016-03-11 A | 100% |  |  |  |  |  | finish no earlier than 2016-03-11 | C4 | 2144h | 2144h | EVSoCS-CT | PCG-34 | Qualcomm, Lena Chaponniere | Rel-13 | CP-67 |  |  |  |
| 647 | 216.3 | **Support of EVS over UTRAN CS** | 130.67d? | 2015-06-16 A | 2015-12-15 A | 100% |  |  |  |  |  |  | R2; R1; R3 | 6272h | 6272h | EVSoCS_UTRAN | PCG-34 | Qualcomm | Rel-13 | RP-66 |  |  |  |
| 648 | 216.3.1 | Core part: Support of EVS over UTRAN CS | 130.67d? | 2015-06-16 A | 2015-12-15 A | 100% |  |  |  |  |  | finish no earlier than 2015-12-15 | R2; R1; R3 | 3136h | 3136h | EVSoCS_UTRAN-Core | PCG-34 | Francesco Pica - Qualcomm Incorporated | Rel-13 | RP-66 |  | RP-151282 |  |
| 649 | 217 | Enhanced DASH (Dynamic Adaptive Streaming over HTTP in 3GPP) | 334d? | 2014-09-09 A | 2015-12-16 A | 100% |  |  |  |  |  | finish no earlier than 2015-12-16 | S4 | 2672h | 2672h | eDASH | PCG-33 | Qualcomm, Huawei | Rel-13 | SP-65 | eDASH |  |  |
| 650 | 218 | **QoS End-to-end Multimedia Telephony Service for IMS (MTSI) extensions (Stage 3)** | 796d? | 2013-03-06 A | 2016-03-11 A | 100% |  | 2013-03-06 | 2015-03-13 | 533d? |  |  | S4; C3; C1; C4 | 53457.8h | 53457.8h | QOSE2EMTSI | PCG-30 | Ericsson | Rel-13 | SP-59 | QOSE2EMTSI |  | Paolo |
| 651 | 218.1 | TR on improved end-to-end QoS handling for MTSI | 589d? | 2013-12-11 A | 2016-03-11 A | 100% |  | 2013-12-11 | 2015-03-13 | 329d? |  | finish no earlier than 2016-03-11 | S4 | 4705.83h | 4705.83h | QOSE2EMTSI | PCG-32 | Ericsson | Rel-13 | SP-62 |  |  | Paolo |
| 652 | 218.2 | SA4 part of QoS End-to-end Multimedia Telephony Service for IMS (MTSI) extensions (Stage 3) | 792d? | 2013-03-06 A | 2016-03-11 A | 100% |  | 2013-03-06 | 2015-03-13 | 532d? |  | finish no earlier than 2016-03-11 | S4 | 6336h | 6336h | QOSE2EMTSI | PCG-30 | Ericsson | Rel-13 | SP-59 |  |  | Paolo |
| 653 | 218.3 | **CT Aspects of QoS End-to-End MTSI Extensions** | 353d? | 2014-11-05 A | 2016-03-11 A | 100% |  |  |  |  |  |  | C3; C1; C4 | 16944h | 16944h | QOSE2EMTSI-CT | PCG-34 | Ericsson | Rel-13 | CP-66 |  |  |  |
| 654 | 218.3.1 | CT3 Aspects of QoS End-to-End MTSI Extensions | 353d? | 2014-11-05 A | 2016-03-11 A | 100% |  |  |  |  |  | finish no earlier than 2016-03-11 | C3 | 2824h | 2824h | QOSE2EMTSI-CT | PCG-34 | Ericsson | Rel-13 | CP-66 |  |  |  |
| 655 | 218.3.2 | CT1 Aspects of QoS End-to-End MTSI Extensions | 353d? | 2014-11-05 A | 2016-03-11 A | 100% |  |  |  |  |  | finish no earlier than 2016-03-11 | C1 | 2824h | 2824h | QOSE2EMTSI-CT | PCG-34 | Ericsson | Rel-13 | CP-66 |  |  |  |
| 656 | 218.3.3 | CT4 Aspects of QoS End-to-End MTSI Extensions | 353d? | 2014-11-05 A | 2016-03-11 A | 100% |  |  |  |  |  | finish no earlier than 2016-03-11 | C4 | 2824h | 2824h | QOSE2EMTSI-CT | PCG-34 | Ericsson | Rel-13 | CP-66 |  |  |  |
| 657 | 219 | **MTSI Extension on Multi-stream Multiparty** | 322d? | 2014-12-12 A | 2016-03-07 | 83% | 53.53d? |  |  |  | 551d |  | S4 | 5752h | 5216.24h | MMCMH | PCG-34 | Tomas Frankkila, Ericsson LM | Rel-13 | SP-66 |  |  |  |
| 658 | 219.1 | Codec aspects for MMCMH | 265d? | 2014-12-12 A | 2015-12-17 A | 100% |  |  |  |  |  | finish no earlier than 2015-12-17 | S4 | 2120h | 2120h | MMCMH | PCG-34 | Tomas Frankkila, Ericsson LM | Rel-13 | SP-66 |  |  |  |
| 659 | 219.2 | (IETF) RTP Stream Pause and Resume (RFC 7728) | 66d? | 2015-12-07 A | 2016-03-07 A | 100% |  |  |  |  |  | finish no earlier than 2016-03-07 | S4-IETF | 528h | 528h | MMCMH | PCG-36 | Ericsson | Rel-13 | TSG#71 |  |  |  |
| 660 | 219.3 | (IETF) draft-ietf-mmusic-sdp-simulcast | 66d? | 2015-12-07 | 2016-03-07 |  |  |  |  |  | 551d | start no earlier than 2015-12-07 | S4-IETF | 528h |  | MMCMH | PCG-37 |  | Rel-13 | TSG#72 |  |  |  |

Notes:
- 636: Mar. 15: 5->15% / WI rapporteur e-mail: gilles.teniou@orange.com
- 637: Dec.14: 0->5%; June2015: Compl:15%->30; Aug2015: 30%->45; 07/09/15: 45%->70; 7/12/15: 70%->85, FCD: 12/15->03/16; 7/3/16: 85%->100 / Impacted TSs and TRs: New TR 26.9xy. ES in SP-150650 / WI rapporteur e-mail: gilles.teniou@orange.com
- 638: Dec.14: 0->5%; June2015: Compl:15%->30; Aug2015: 30%->45; 07/09/15: 45%->70; 7/12/15: 70%->85, FCD: 12/15->03/16. ES in SP-150650; 7/3/16: 85%->100 / Impacted TSs and TRs: 26.234, 26.244, 26.346, 26.247, New TS 26.xyz. ES in SP-150650 / WI rapporteur e-mail: gilles.teniou@orange.com
- 639: Mar. 15: 0->5%; June2015: Compl:5%->10; Aug2015: 10%->15; 07/09/15: 15%->50; 7/12/15: 50%->80, FCD: 12/15->03/16. ES in SP-150652; 7/3/16: FCD: 03/16->06/16; 11/6/16: 80%->100 / Impacted TSs and TRs: 26.131, 26.132 / WI rapporteur e-mail: stephane.ragot@orange.com
- 640: Triggered by Rel-12 TR 26.907 (Study of HTML5 and 3GPP User Services). Dec.14: 0->5%. Mar. 15: 10%; June2015: Compl:10%->20; Aug2015: 20%->40; 07/09/15: 40%->70; 7/12/15: 70%->100 / Impacted TSs and TRs: 26.140, 26.234, 26.247, 26.346, New TS 26.xyz / WI rapporteur e-mail: Imed Bouazizi (i.bouazizi@samsung.com)
- 641: Provide CS support of EVS to enhance voice quality in CS services over UTRAN (3G WCDMA). Dec.14: 0->5%; 28/1/16: 26.454 added;; 28/1/16: 26.453 added; / Impacted TSs and TRs: 26.103, 28.062, New TS 26.454; New TS 26.453 / WI rapporteur e-mail: Imre Varga (ivarga@qti.qualcomm.com)
- 642: Created by MCC (duplicated from previously single-line Feature) due to the introduction of the CT BB. Mar. 15: 10%; Aug2015: 10%->20; 07/09/15: 20%->40; 7/12/15: 40%->60, FCD:12/15->03/16. ES in SP-150655; 28/1/16: 26.454 added;; 28/1/16: 26.453 added;; 7/3/16: 60%->100 / Impacted TSs and TRs: 26.103, 28.062, New TS 26.454; New TS 26.453 / WI rapporteur e-mail: Imre Varga (ivarga@qti.qualcomm.com)
- 643: WI rapporteur e-mail: lguellec@qti.qualcomm.com
- 644: 07/09/15: 0%->90; 7/12/15: 90%->100 / Impacted TSs and TRs: 24.008 / WI rapporteur e-mail: lguellec@qti.qualcomm.com
- 645: June2015: Compl:0%->10; 07/09/15: 10%->15; 7/12/15: 15%->90. FCD -> 03/16, ES in CP-150638; 7/3/16: 90%->100 / Impacted TSs and TRs: 29.163, 29.414, 29.415 / WI rapporteur e-mail: lguellec@qti.qualcomm.com
- 646: June2015: Compl:0%->95. FCD -> 03/16, ES in CP-150618; 7/3/16: 95%->100 / Impacted TSs and TRs: 23.153, 23.334, 29.002, 29.231, 29.232, 29.332, 29.334 / WI rapporteur e-mail: lguellec@qti.qualcomm.com
- 647: WI rapporteur e-mail: Qualcomm
- 648: Rapporteur details and involved WGs updated 1st Apr 15: Compl:0%->10% 1st Apr 15: Stat Rep: ->RP-150128. 5/5/15: 0->10% 03/07/15: Compl:10%->25% 03/07/15: Stat Rep: RP-150128->RP-150759 29/09/15: Compl:25%->50% 29/09/15: CD:Tue 15/09/15->Tue 15/12/15 2...; ; ; ; ; ; ; ; ; ; ; ; ; ; ; ; ; ; ; ; ; 1/1/16: Compl:50%->100% / WI rapporteur e-mail: fpica@qti.qualcomm.com
- 649: Triggered by Rel-12 Dec.14: 0->10%. Mar. 15: 15%; June2015: Compl:15%->25. WID updated; Aug2015: 25%->30; 07/09/15: 30%->60; 14/09/15: WID:SP-150211->SP-150448; 7/12/15: 60%->100 / Impacted TSs and TRs: 26.233, 26.234, 26.244, 26.247, 26.938, TS 26.346, TR 26.946 / WI rapporteur e-mail: Thomas Stockhammer (tsto@qti.qualcomm.com), Li Zhiming (lizhiming@huawei.com)
- 650: SP#65 updated WID SP-130670=>SP-140601 (moved work from Rel-12 incl. new TR to Rel-13). Co-ordinate with SA2, CT1/3/4, IETF MMUSIC. Linked to SA4 Rel-7 Media handling and interaction in MTSI (MTSI-MHI) UID_7040 / WI rapporteur e-mail: tomas.frankkila@ericsson.com
- 651: SP#65 updated WID SP-130670=>SP-140601 (moved work from Rel12 incl. new TR to Rel-13). Completion 03/15=>06/15. Mar15: 26.924 for info. 8/4/15: 50%; Aug2015: 50%->60; 7/12/15: 75%->90, FCD: 06/15->03/16; 7/3/16: 90%->100 / Impacted TSs and TRs: new TR 26.924 / WI rapporteur e-mail: tomas.frankkila@ericsson.com
- 652: SP#65: WID SP-130670=>SP-140601 (moved from Rel12 incl. new TR to Rel-13). FCD 03/15=>06/15. St1 in TS 22.173. 12/14: 70->40%, CD: 06/15->09/15. 03/15: 50%. June 15: FCD: 09/15->12/15; 08/15: 60%; 09/15: 75%; 7/12. ES in SP-150658; 7/3/16: 90%->100 / Impacted TSs and TRs: 26.114 / WI rapporteur e-mail: tomas.frankkila@ericsson.com
- 654: 7/12/15: 0%->70. FCD -> 03/16, ES in CP-150636; 7/3/16: 70%->100 / Impacted TSs and TRs: 29.162, 29.163, 29.213, 29.214
- 655: FCD -> 03/16, ES in CP-150726; 7/3/16: 0%->100 / Impacted TSs and TRs: 24.229
- 656: FCD -> 03/16, ES in CP-150620; 7/3/16: 0%->100 / Impacted TSs and TRs: 23.333, 23.334, 29.238, 29.332, 29.333, 29.334
- 657: Mar. 15: 0->10%. WID: SP-140738->SP-150097; June2015: Compl:10%->30; Aug2015: 30%->50, FCD: sep->Dec 2015; 07/09/15: 50%->60; 7/12/15: 60%->100; 10/12/15: WID:SP-150097->SP-150660. Might be moved to Rel-14 (see note in UID710002) / Impacted TSs and TRs: 26.114, New TR 26.980 / WI rapporteur e-mail: tomas.frankkila@ericsson.com
- 658: Introduced by MCC to dissociate S4 from IeTF aspects / Impacted TSs and TRs: 26.114, New TR 26.980 / WI rapporteur e-mail: tomas.frankkila@ericsson.com
- 659: 02/2016: published as RFC 7728 / Impacted TSs and TRs: (IETF) RTP Stream Pause and Resume (RFC 7728) / WI rapporteur e-mail: tomas.frankkila@ericsson.com

| ID | WBS | Task | Duration | Start | Finish | Complete | Remaining | Baseline start | Baseline finish | Baseline duration | Total slack | Constraint | Resources | Work | Actual work | Acronym | PCG approved | Release | TSG approved | MCC resp | Special Focus Doc | Acronym_3GU_Export |
| --- | --- | --- | --- | --- | --- | --- | --- | --- | --- | --- | --- | --- | --- | --- | --- | --- | --- | --- | --- | --- | --- | --- |
| 661 | 220 | **Video Telephony Robustness Improvements Extensions** | 196d? | 2014-12-12 A | 2015-09-11 | 70% | 58.8d? |  |  |  | 677d |  | S4 | 6272h | 4390.4h | VTRI_EXT | PCG-34 | Rel-13 | SP-66 |  |  |  |
| 662 | 220.1 | TR on Video Telephony Robustness Improvements | 196d? | 2014-12-12 A | 2015-09-11 A | 100% |  |  |  |  |  | finish no earlier than 2015-09-11 | S4 | 1568h | 1568h | VTRI_EXT | PCG-34 | Rel-13 | SP-66 |  |  |  |
| 663 | 220.2 | Specification on Video Telephony Robustness Improvements | 196d? | 2014-12-12 A | 2015-09-11 A | 100% |  |  |  |  |  | finish no earlier than 2015-09-11 | S4 | 1568h | 1568h | VTRI_EXT | PCG-34 | Rel-13 | SP-66 |  |  |  |
| 664 | 220.3 | (IETF) RTP Payload Format for Non-Interleaved and Interleaved Parity Forward Error Correction (FEC) (draft-ietf-payload-flexible-fec-scheme) | 196d? | 2014-12-12 A | 2015-09-11 | 10% | 176.4d? |  |  |  | 677d | finish no earlier than 2015-09-11 | S4-IETF | 1568h | 156.8h | VTRI_EXT | PCG-35 | Rel-13 | CP-69 |  |  |  |
| 665 | 221 | Acoustic Test methods and Performance Objectives for Speakerphone Performance in Noisy Environments | 326d? | 2014-12-12 A | 2016-03-11 A | 100% |  |  |  |  |  | finish no earlier than 2016-03-11 | S4 | 2608h | 2608h | ATeMPO_SPINE | PCG-34 | Rel-13 | SP-66 |  |  |  |
| 666 | 222 | **Rel-13 Operations, Administration, Maintenance and Provisioning (OAM&P)** | 985d? | 2012-06-20 A | 2016-03-11 A | 100% |  | 2014-09-17 | 2015-12-11 | 323d? |  |  | S5 | 57504h | 57504h | OAM13 | PCG-32 | Rel-13 | SP-63 | Mirko | SON | OAM13 |
| 667 | 222.1 | Enhanced Network Management (NM) centralized Coverage and Capacity Optimization | 319d? | 2014-09-19 A | 2015-12-11 A | 100% |  | 2014-09-17 | 2015-12-11 | 319d? |  | finish no earlier than 2015-12-11 | S5 | 2552h | 2552h | SON-NM-CCO | PCG-29 | Rel-13 | SP-56 | Mirko | SON | SON-NM-CCO |
| 668 | 222.2 | **Compliance of 3GPP SA5 specifications to the NGMN Top Operational Efficiency (OPE) Recommendations** | 728d? | 2012-06-20 A | 2015-03-18 A | 100% |  | 2012-06-20 | 2014-09-17 | 595d? |  |  | S5 | 17368h | 17368h | OAM-NGMN_OPE | PCG-29 | Rel-13 | SP-56 | Mirko |  | OAM-NGMN_OPE |
| 669 | 222.2.1 | TR on Compliance of 3GPP SA5 specifications to the NGMN Top Operational Efficiency (OPE) Recommendations | 723d? | 2012-06-20 A | 2015-03-18 A | 100% |  | 2012-06-20 | 2014-09-17 | 593d? |  | finish no earlier than 2015-03-18 | S5 | 5784h | 5784h | OAM-NGMN_OPE | PCG-29 | Rel-13 | SP-56 | Mirko |  |  |
| 670 | 222.2.2 | TS work on Compliance of 3GPP SA5 specifications to the NGMN Top Operational Efficiency (OPE) Recommendations | 720d? | 2012-06-25 A | 2015-03-18 A | 100% |  | 2012-06-25 | 2014-09-17 | 590d? |  | finish no earlier than 2015-03-18 | S5 | 5760h | 5760h | OAM-NGMN_OPE | PCG-29 | Rel-13 | SP-56 | Mirko |  |  |
| 671 | 222.3 | Converged management Performance Management Interface Definitions | 910d? | 2012-06-20 A | 2015-12-11 A | 100% |  | 2012-06-20 | 2014-09-17 | 588d? |  | finish no earlier than 2015-12-11 | S5 | 7280h | 7280h | OAM-PMID | PCG-29 | Rel-13 | SP-56 | Mirko |  | OAM-PMID |
| 672 | 222.4 | **WLAN Management** | 788d? | 2012-06-27 A | 2015-06-17 A | 100% |  | 2012-06-20 | 2014-09-17 | 595d? |  |  | S5 | 18848h | 18848h | WLAN-OAM | PCG-29 | Rel-13 | SP-56 | Mirko | WLAN | WLAN-OAM |
| 673 | 222.4.1 | WLAN Network Resource Model for Type-2 interface | 784d? | 2012-06-27 A | 2015-06-17 A | 100% |  | 2012-06-27 | 2014-09-17 | 589d? |  | finish no earlier than 2015-06-17 | S5 | 6272h | 6272h | WLAN-OAM-SA5 | PCG-29 | Rel-13 | SP-56 | Mirko | WLAN |  |
| 674 | 222.4.2 | WLAN measurements defined in IEEE and IETF WLAN performance measurements for use on Type-2 interface | 784d? | 2012-06-27 A | 2015-06-17 A | 100% |  | 2012-06-27 | 2014-09-17 | 589d? |  | finish no earlier than 2015-06-17 | S5 | 6272h | 6272h | WLAN-OAM-SA5ietf | PCG-29 | Rel-13 | SP-56 | Mirko | WLAN |  |
| 675 | 222.5 | Energy Efficiency related Performance Measurements | 713d? | 2013-06-21 A | 2016-03-11 A | 100% |  | 2013-06-21 | 2014-09-17 | 326d? |  | finish no earlier than 2016-03-11 | S5 | 5704h | 5704h | OAM-PM_EE | PCG-31 | Rel-13 | SP-60 | Mirko |  | OAM-PM_EE |
| 676 | 222.6 | Multi-Broadcast Single Frequency Network (MBSFN) Minimization of Drive Tests (MDT) enhancement | 1d? | 2014-12-12 A | 2014-12-12 A | 100% |  |  |  |  |  | start no earlier than 2014-12-12 | S5 | 8h | 8h | MBSFN_MDT | PCG-34 | Rel-13 | SP-66 |  |  |  |
| 677 | 223 | **Rel-13 Charging** | 393d? | 2014-06-19 A | 2015-12-16 A | 100% |  | 2014-06-18 | 2015-12-09 | 386d? |  |  | S5 | 16236h | 16236h | CH13 | PCG-33 | Rel-13 | SP-64 |  |  | CH13 |
| 678 | 223.1 | **Inter-PLMN PS domain online charging** | 393d? | 2014-06-19 A | 2015-12-16 A | 100% |  | 2014-06-18 | 2015-12-09 | 386d? |  |  | S5 | 8360h | 8360h | iPLMN-PS-OCH | PCG-33 | Rel-13 | SP-64 |  |  | iPLMN-PS-OCH |
| 679 | 223.1.1 | TR on Inter-PLMN PS domain online charging | 261d? | 2014-06-19 A | 2015-06-17 A | 100% |  | 2014-06-18 | 2015-06-17 | 261d? |  | finish no earlier than 2015-06-17 | S5 | 2088h | 2088h | iPLMN-PS-OCH | PCG-33 | Rel-13 | SP-64 |  |  |  |
| 680 | 223.1.2 | Specification of Inter-PLMN PS domain online charging | 391d? | 2014-06-23 A | 2015-12-16 A | 100% |  | 2014-06-18 | 2015-12-09 | 386d? |  | finish no earlier than 2015-12-16 | S5 | 3128h | 3128h | iPLMN-PS-OCH | PCG-33 | Rel-13 | SP-64 |  |  |  |
| 681 | 223.2 | ULI and release causes for charging enhancement for VoLTE | 257d? | 2014-12-12 A | 2015-12-07 A | 100% |  |  |  |  |  | finish no earlier than 2015-12-07 | S5 | 2056h | 2056h | ULRELC-CH | PCG-34 | Rel-13 | SP-66 |  |  |  |
| 682 | 223.3 | Charging on enhancements for IMS Service Continuity | 135d? | 2015-03-05 A | 2015-09-09 A | 100% |  |  |  |  |  | finish no earlier than 2015-12-11 | S5 | 1080h | 1080h | CHeISC | PCG-34 | Rel-13 | SP-67 |  |  |  |
| 683 | 223.4 | Announcements for IMS Online Charging | 131d? | 2015-06-15 A | 2015-12-14 A | 100% |  |  |  |  |  | start no earlier than 2015-06-14 | S5 | 1048h | 1048h | ANIMO | PCG-35 | Rel-13 | SP-68 |  |  |  |
| 684 | 223.5 | Enhanced S2a Mobility Over Trusted WLAN access to EPC - Charging | 68.5d? | 2015-06-15 A | 2015-09-17 A | 100% |  |  |  |  |  | start no earlier than 2015-06-15 | S5 | 548h | 548h | eSaMOG-CH | PCG-35 | Rel-13 | SP-68 |  |  |  |

Notes:
- 661: New TR added. 3/3/15: "extensions" added in the title. Mar. 15: 0->10% / Impacted TSs and TRs: 26.922 (new), 26.114 / WI rapporteur name: Muhammed Coban, Qualcomm Incorporated / WI rapporteur e-mail: mcoban@qti.qualcomm.com
- 662: 3/3/15: created to distinguish TR and TS tasks; June2015: Compl:10%->40; Aug2015: 40%->95; 07/09/15: 95%->100 / Impacted TSs and TRs: 26.922 (new), 26.114 / WI rapporteur name: Muhammed Coban, Qualcomm Incorporated / WI rapporteur e-mail: mcoban@qti.qualcomm.com
- 663: 3/3/15: created to distinguish TR and TS tasks; June2015: Compl:10%->40; Aug2015: 40%->95; 07/09/15: 95%->100 / Impacted TSs and TRs: 26.922 (new), 26.114 / WI rapporteur name: Muhammed Coban, Qualcomm Incorporated / WI rapporteur e-mail: mcoban@qti.qualcomm.com
- 664: 26.114, draft-ietf-payload-flexible-fec-scheme. 7/10/15: rapporteur added / Impacted TSs and TRs: 26.114, draft-ietf-payload-flexible-fec-scheme / WI rapporteur name: Muhammed Coban, Qualcomm Incorporated / WI rapporteur e-mail: mcoban@qti.qualcomm.com
- 665: June2015: Compl:0%->10. Aug: FCD: Jun->Sep15; 07/09/15: 10%->30, FCD:09/15->12/15; 7/12/15: 40%->80, FCD: 12/15->03/16. ES in SP-150642; 7/3/16: 80%->100 / Impacted TSs and TRs: 26.131, 26.132 / WI rapporteur name: Andre Schevciw, Qualcomm Incorporated; Scott Isabelle, Audience Inc. / WI rapporteur e-mail: aschevci@qti.qualcomm.com; sisabelle@audience.com
- 666: OAM13 is an umbrella Feature for changes that are not part of any other dedicated feature/WI; June2015: WID:-->SP-150305; 5/10/15: 28.683 added; / Impacted TSs and TRs: 28.683
- 667: SP#64 work not started. Dec.14: 0->20, cd: 06/15->12/15. Mar 15: 20->30%; June2015: Compl:30%->50; 07/09/15: 50%->60; 7/12/15: 60%->100 / Impacted TSs and TRs: 28.627, 28.628, 32.103, 32.422, 32.425, 32.442 / WI rapporteur name: Ericsson / WI rapporteur e-mail: robert.petersen@ericsson.com
- 668: SP#65 updated WID SP-120349=>SP-140538. Completion 12/14=>03/15. Moved to Rel-13. Source of external requirements: NGMN Top OPE Recommendations 1.0 / WI rapporteur name: Huawei / WI rapporteur e-mail: christian.toche@huawei.com
- 669: SP#65 updated WID SP-120349=>SP-140538. Completion 12/14=>03/15. Moved to Rel-13.. Dec.14: 72->78. Mar 15: 80%; June2015: Compl:80%->85; 07/09/15: 85%->90; 7/12/15: 90%->100 / Impacted TSs and TRs: New TR 32.838 / WI rapporteur name: Huawei / WI rapporteur e-mail: christian.toche@huawei.com
- 670: SP#65 updated WID SP-120349=>SP-140538. Completion 12/14=>03/15. Moved to Rel-13; 7/12/15: 50%->100 / Impacted TSs and TRs: 32.101/2/3,32.111-1,32.111-2,32.111-6,32.15x,32.401,32.411,32.412,32.421,32.422,32.423,32.431,32.432,32.436,32.441,32.442,32.446,32.500,32.501,32.502,32.506,32.521,32.522,32.526,32.531,32.532,32.536,32.551,32.691,32.692,32.696,32.762 / WI rapporteur name: Huawei / WI rapporteur e-mail: christian.toche@huawei.com
- 671: SP#65 updated WID SP-130641=>SP-140613. Completion 09/14=>12/15. Moved to Rel-13. Completion 09/14=>12/15. Dec.14: 20->30; June2015: Compl:30%->60; 07/09/15: 60%->80; 7/12/15: 80%->100; 7/12/15: WID:SP-140613->SP-150678 / Impacted TSs and TRs: new TSs 32.863 / WI rapporteur name: Huawei / WI rapporteur e-mail: christian.toche@huawei.com
- 672: SP#65 moved to Rel-13. Updated WID SP-130042=>SP-140535 (split into Rel-12 Study & Rel-13 normative WI). TR 32.841 was completed as a Rel-12 Study and has triggered this normative work / WI rapporteur name: Intel / WI rapporteur e-mail: joey.chou@intel.com
- 673: SP#65 updated WID SP-130042=>SP-140535. Completion 09/14=>06/15. Moved to Rel-13. Dec.14: 10->20; June2015: Compl:20%->70; 07/09/15: 70%->80; 7/12/15: 80%->100 / Impacted TSs and TRs: new TS (28.680, 28.682), 28.681 / WI rapporteur name: Intel / WI rapporteur e-mail: joey.chou@intel.com
- 674: SP#65 updated WID SP-130042=>SP-140535. Completion 09/14=>06/15. Moved to Rel-13. 22/01:Acronym modified; June2015: Compl:5%->20; 07/09/15: 20%->60; 7/12/15: 60%->100 / Impacted TSs and TRs: new TS 28.403 / WI rapporteur name: Intel / WI rapporteur e-mail: joey.chou@intel.com
- 675: SP#65 updated WID SP-130263=>SP-140612. Completion 09/14=>06/15. Moved to Rel-13; June2015: Compl:25%->40; 07/09/15: 40%->50. ES in SP-150708; 7/3/16: 50%->100 / Impacted TSs and TRs: 32.425 / WI rapporteur name: Nokia Networks / WI rapporteur e-mail: Yizhi.yao@nsn.com
- 676: Mar 15: 0->15%; June2015: Compl:15%->100 / Impacted TSs and TRs: 32.421, 32.422, 32.423, 32.441, 32.442, 32.446 / WI rapporteur name: Padma Sudarsan (Alcatel-Lucent) / WI rapporteur e-mail: padma.sudarsan<AT>alcatel-lucent<DOT>com
- 677: CH13 is an umbrella Feature for changes that are not part of any other dedicated feature/WI; June2015: WID:-->SP-150307
- 678: Study and specify Gy Reference Point service data flows based online charging for inter-PLMN situations / Impacted TSs and TRs: Stage 2/3 / WI rapporteur name: Alcatel-Lucent / WI rapporteur e-mail: maryse.gardella@alcatel-lucent.com
- 679: Dec.14: 10->25%. Mar15: 20->60%. 06/15: 100%; 7/12/15: 100%->100 / Impacted TSs and TRs: New TR 32.843 / WI rapporteur name: Alcatel-Lucent / WI rapporteur e-mail: maryse.gardella@alcatel-lucent.com
- 680: 07/09/15: 0%->80; 7/12/15: 80%->100 / Impacted TSs and TRs: 32.251, 32.299 / WI rapporteur name: Alcatel-Lucent / WI rapporteur e-mail: maryse.gardella@alcatel-lucent.com
- 681: Acronym changed to ULRELC-CH. Mar15: 0->5%. CD: 12/14->09/15. 06/15: 20%; 07/09/15: 20%->40; 7/12/15: 40%->100, FCD: 09/15->12/15 / Impacted TSs and TRs: 32.251, 32.260, 32.299, 32.298, / WI rapporteur name: Alcatel-Lucent, Maryse Gardella / WI rapporteur e-mail: Alcatel-Lucent, Maryse <dot> Gardella <at> Alcatel-Lucent <dot> com
- 682: 06/15: 0->50%; 07/09/15: 50%->100. FCD: 12/15->09/15 / Impacted TSs and TRs: 32.260, 32.299, 32.298 / WI rapporteur name: Gerald Goermer / WI rapporteur e-mail: Gerald <dot> Goermer <at> nsn <dot> com
- 683: 07/09/15: 0%->30; 7/12/15: 30%->100; 7/12/15: WID:SP-150307->SP-150675 / Impacted TSs and TRs: 32.260, 32.275, 32.299, 32.240, 32.281 / WI rapporteur name: Amdocs, Naceur <dot> Lagha <at> Amdocs <dot> com
- 684: 07/09/15: 0%->30; 7/12/15: 30%->100 / Impacted TSs and TRs: 32.240, 32.251, 32.299, 32.298 / WI rapporteur name: Alcatel-Lucent, Maryse <dot> Gardella <at> Alcatel-Lucent <dot> com

| ID | WBS | Task | Duration | Start | Finish | Complete | Remaining | Baseline start | Baseline finish | Baseline duration | Total slack | Constraint | Resources | Work | Actual work | Acronym | PCG approved | WI rapporteur name | WI rapporteur e-mail | Release | TSG approved | MCC resp | Acronym_3GU_Export | Status Report |
| --- | --- | --- | --- | --- | --- | --- | --- | --- | --- | --- | --- | --- | --- | --- | --- | --- | --- | --- | --- | --- | --- | --- | --- | --- |
| 685 | 224 | **Support of Real-time Transport Protocol (RTP) / Real-time Transport Control Protocol (RTCP) multiplexing (signalling) in IMS** | 595d? | 2013-09-09 A | 2015-12-11 A | 100% |  | 2013-09-09 | 2014-09-12 | 267d? |  |  | C4; C1; C3 | 28464h | 28464h | RTCP_MUX | PCG-31 | Alcatel-Lucent | Albrecht.Schwarz@alcatel-lucent.com | Rel-13 | CP-61 | Kimmo | RTCP_MUX |  |
| 686 | 224.1 | CT4 part of Support of RTP / RTCP multiplexing (signalling) in IMS | 591d? | 2013-09-09 A | 2015-12-11 A | 100% |  | 2013-09-09 | 2014-09-12 | 266d? |  | finish no earlier than 2015-12-11 | C4 | 4728h | 4728h | RTCP_MUX | PCG-31 | Alcatel-Lucent | Albrecht.Schwarz@alcatel-lucent.com | Rel-13 | CP-61 | Kimmo |  |  |
| 687 | 224.2 | CT1 part of Support of RTP / RTCP multiplexing (signalling) in IMS | 591d? | 2013-09-13 A | 2015-12-11 A | 100% |  | 2013-09-10 | 2014-09-12 | 266d? |  | finish no earlier than 2015-12-11 | C1 | 4728h | 4728h | RTCP_MUX | PCG-31 | Alcatel-Lucent | Albrecht.Schwarz@alcatel-lucent.com | Rel-13 | CP-61 | Frederic |  |  |
| 688 | 224.3 | CT3 part of Support of RTP / RTCP multiplexing (signalling) in IMS | 591d? | 2013-09-13 A | 2015-12-11 A | 100% |  | 2013-09-10 | 2014-06-13 | 201d? |  | finish no earlier than 2015-12-11 | C3 | 4728h | 4728h | RTCP_MUX | PCG-31 | Alcatel-Lucent | Albrecht.Schwarz@alcatel-lucent.com | Rel-13 | CP-61 | Adrian |  |  |
| 689 | 225 | **LTE in the 1670-1675 MHz Band for US (on hold till 12/2014)** | 868d? | 2012-03-05 A | 2015-06-12 | 8% | 801.54d? | 2012-03-05 | 2015-06-12 | 865d? | 742d |  | R4; R2; R3 | 35264h | 2347.6h | LTE_FDD_1670_US | PCG-28 | LightSquared | masoud.olfat@lightsquared.com | Rel-13 | RP-55 | Issam | LTE_FDD_1670_US |  |
| 690 | 225.1 | Core part: LTE in the 1670-1675 MHz Band for US (on hold till 12/2014) | 313d? | 2013-08-06 A | 2015-03-13 | 15% | 266.05d? | 2013-08-06 | 2015-03-13 | 313d? | 807d | finish no earlier than 2015-03-13 | R4; R2; R3 | 7512h | 1126.8h | LTE_FDD_1670_US-Core | PCG-28 | LightSquared | masoud.olfat@lightsquared.com | Rel-13 | RP-55 | Issam | LTE_FDD_1670_US-Core | RP-141452 |
| 691 | 225.2 | Perf. Part: LTE in the 1670-1675 MHz Band for US (on hold till 12/2014) | 865d? | 2012-03-05 A | 2015-06-12 | 5% | 821.75d? | 2012-03-05 | 2015-06-12 | 865d? | 742d | finish no earlier than 2015-06-12 | R4 | 6920h | 346h | LTE_FDD_1670_US-Perf | PCG-28 | LightSquared | masoud.olfat@lightsquared.com | Rel-13 | RP-55 | Issam | LTE_FDD_1670_US-Perf | RP-141452 |
| 692 | 226 | **Enhanced Signalling for Inter-eNB Coordinated Multi-Point (CoMP) for LTE** | 328d? | 2014-06-18 A | 2015-09-15 A | 100% |  | 2014-06-13 | 2014-12-05 | 126d? |  |  | R3 | 5248h | 5248h | COMP_LTE_IeNB_sig | PCG-33 | Samsung | sunghwan.won@samsung.com | Rel-13 | RP-64 |  | COMP_LTE_IeNB_sig |  |
| 693 | 226.1 | Core part: Enhanced Signalling for Inter-eNB Coordinated Multi-Point (CoMP) for LTE | 328d? | 2014-06-18 A | 2015-09-15 A | 100% |  | 2014-06-13 | 2014-12-05 | 126d? |  | finish no earlier than 2015-09-15 | R3 | 2624h | 2624h | COMP_LTE_IeNB_sig-Core | PCG-33 | Samsung | sunghwan.won@samsung.com | Rel-13 | RP-64 |  | COMP_LTE_IeNB_sig-Core | RP-151213 |
| 694 | 227 | **2GHz FDD LTE in Region 1 (1980-2010MHz and 2170-2200MHz Bands)** | 592d? | 2014-06-17 A | 2016-09-15 | 99% | 0d? | 2014-06-13 | 2015-06-12 | 261d? | 0d |  | R4 | 12096h | 10512h | LTE_1980_2170_REG1 | PCG-33 | DISH Network | johny.kim@dish.com, mariam.sorond@dish.com | Rel-13 | RP-64 |  | LTE_1980_2170_REG1 |  |
| 695 | 227.1 | Core part: 2GHz FDD LTE in Region 1 (1980-2010MHz and 2170-2200MHz Bands) | 393d? | 2014-06-17 A | 2015-12-15 A | 100% |  | 2014-06-13 | 2015-06-12 | 261d? |  | finish no earlier than 2015-12-15 | R4 | 3144h | 3144h | LTE_1980_2170_REG1-Core | PCG-33 | DISH Network | johny.kim@dish.com, mariam.sorond@dish.com | Rel-13 | RP-64 |  | LTE_1980_2170_REG1-Core | RP-151299 |
| 696 | 227.2 | Perf. Part: 2GHz FDD LTE in Region 1 (1980-2010MHz and 2170-2200MHz Bands) | 393d? | 2014-06-18 A | 2015-12-15 A | 100% |  | 2014-06-13 | 2015-06-12 | 261d? |  | finish no earlier than 2015-12-15 | R4 | 3144h | 3144h | LTE_1980_2170_REG1-Perf | PCG-33 | DISH Network | johny.kim@dish.com, mariam.sorond@dish.com | Rel-13 | RP-64 |  | LTE_1980_2170_REG1-Perf | RP-151299 |
| 697 | 227.3 | UE Conformance Test Aspects - FDD LTE band 1980-2010 MHz and 2170-2200MHz (band 65) in Region1 and Region 3 | 134d? | 2016-03-15 A | 2016-09-15 A | 100% |  |  |  |  |  | finish no earlier than 2016-09-15 | R5 | 1072h | 1072h | LTE_1980_2170_REG1_REG3-UEConTest | PCG-36 | Dish Network |  | Rel-13 | TSG#71 |  |  |  |
| 698 | 228 | **Self Organizing Networks (SON) for Active Antenna System (AAS) based deployments** | 199d? | 2014-09-12 A | 2015-06-15 A | 100% |  | 2014-06-13 | 2015-06-12 | 261d? |  |  | R3; G2 | 4776h | 4776h | UTRA_LTE_SON_AAS | PCG-33 | Nokia Networks | krzysztof.kordybach@nsn.com | Rel-13 | RP-65 |  | UTRA_LTE_SON_AAS |  |
| 699 | 228.1 | Core part: Self Organizing Networks (SON) for Active Antenna System (AAS) based deployments | 199d? | 2014-09-12 A | 2015-06-15 A | 100% |  | 2014-06-13 | 2015-06-12 | 261d? |  | finish no earlier than 2015-06-15 | R3 | 1592h | 1592h | UTRA_LTE_SON_AAS-Core | PCG-33 | Nokia Networks | krzysztof.kordybach@nsn.com | Rel-13 | RP-65 |  | UTRA_LTE_SON_AAS-Core | RP-150727 |
| 700 | 229 | **Usage Monitoring Control PCC Extension** | 140d? | 2014-12-03 A | 2015-06-16 A | 100% |  |  |  |  |  |  | S2 | 2824h | 2824h | eUMONC | PCG-34 | CTBRI |  | Rel-13 | SP-66 |  |  |  |
| 701 | 229.1 | Stage 2 of Usage Monitoring Control PCC Extension | 140d? | 2014-12-03 A | 2015-06-16 A | 100% |  |  |  |  |  | finish no earlier than 2015-06-16 | S2 | 1120h | 1120h | eUMONC-SA2 | PCG-34 | China Telecom, Jinyan Li | lijy@ctbri.com.cn | Rel-13 | SP-66 |  |  |  |
| 702 | 229.2 | CT3 Aspect of Usage Monitoring Control extension | 73d? | 2014-12-03 A | 2015-03-13 A | 100% |  |  |  |  |  | finish no earlier than 2015-03-13 | C3 | 584h | 584h | eUMONC-CT3 | PCG-34 | ZTE |  | Rel-13 | CT-66 |  |  |  |
| 703 | 230 | **Enhanced P-CSCF discovery using signalling for access to EPC via WLAN** | 115d? | 2014-10-06 A | 2015-03-13 A | 100% |  |  |  |  |  |  | C1 | 2424h | 2424h | ePCSCF_WLAN | PCG-34 | Ericsson |  | Rel-13 | CT-66 |  |  |  |
| 704 | 230.1 | CT1 aspects of Enhanced P-CSCF discovery using signalling for access to EPC via WLAN | 73d? | 2014-12-03 A | 2015-03-13 A | 100% |  |  |  |  |  | finish no earlier than 2015-03-13 | C1 | 584h | 584h | ePCSCF_WLAN | PCG-34 | Ericsson |  | Rel-13 | CT-66 |  |  |  |
| 705 | 230.2 | CT4 aspects of Enhanced P-CSCF discovery using signalling for access to EPC via WLAN | 115d? | 2014-10-06 A | 2015-03-13 A | 100% |  |  |  |  |  | finish no earlier than 2015-03-13 | C4 | 920h | 920h | ePCSCF_WLAN | PCG-34 | Ericsson |  | Rel-13 | CT-66 |  |  |  |
| 706 | 231 | **P-CSCF Restoration Enhancements with WLAN** | 268.05d? | 2014-12-03 A | 2015-12-14 A | 100% |  |  |  |  |  |  | C4 | 6432.4h | 6432.4h | PCSCF_RES_WLAN | PCG-34 | Jean-Jacques Trottin, Alcatel-Lucent | jean-jacques.trottin@alcatel-lucent.com | Rel-13 | CT-66 |  |  |  |
| 707 | 231.1 | CT1 aspects of P-CSCF Restoration Enhancements with WLAN | 268d? | 2014-12-03 A | 2015-12-14 A | 100% |  |  |  |  |  | finish no earlier than 2015-12-11 | C1 | 2144h | 2144h | PCSCF_RES_WLAN | PCG-34 | Jean-Jacques Trottin, Alcatel-Lucent | jean-jacques.trottin@alcatel-lucent.com | Rel-13 | CT-66 |  |  |  |
| 708 | 231.2 | CT4 aspects of P-CSCF Restoration Enhancements with WLAN | 268d? | 2014-12-03 A | 2015-12-11 A | 100% |  |  |  |  |  | finish no earlier than 2015-12-11 | C4 | 2144h | 2144h | PCSCF_RES_WLAN | PCG-34 | Jean-Jacques Trottin, Alcatel-Lucent | jean-jacques.trottin@alcatel-lucent.com | Rel-13 | CT-66 |  |  |  |

Notes:
- 685: CP#65 moved to Rel-13. Stage 2/3 / Impacted TSs and TRs: Stage 2/3
- 686: CP#65 moved to Rel-13. Completion 09/14=>12/15. Dec.14: 10->100 / Impacted TSs and TRs: 23.334, 29.334
- 687: CP#65 moved to Rel-13. Completion 09/14=>12/15; 7/12/15: 0%->100 / Impacted TSs and TRs: 24.229
- 688: CP#65 moved to Rel-13. Completion 09/14=>12/15; 8/12/15: 0%->100 / Impacted TSs and TRs: 29.213, 29.214
- 689: RP#65 FS_LTE_FDD_1670_US is extended to 12/14 and this WI (LTE_FDD_1670_US) is on hold till 12/14 / Impacted TSs and TRs: LTE
- 690: RP#65 completion 03/15=>06/15. On hold till 12/2014 / Impacted TSs and TRs: 25.101, 25.104, 25.113, 25.133, 25.306, 25.307, 25.331, 25.461, 25.466, 34.124, 36.101, 36.104, 36.113, 36.124, 36.133, 36.307, new TR 36.832
- 691: RP#65 completion 06/15=>09/15. . On hold till 12/2014 / Impacted TSs and TRs: 25.133, 25.306, 25.307, 25.331, 25.461, 25.466, 34.124, 36.113, 36.124, 36.133, 36.141, 36.307
- 692: Triggered by TR 36.874 Study on Coordinated Multi-Point (CoMP) operation for LTE with Non-Ideal Backhaul (UID_600015) / Impacted TSs and TRs: LTE
- 693: CD:Thu 11/12/14->Mon 15/06/15; Compl:0%->15%; Stat Rep: -->RP-141805 1st Apr 15: Compl:15%->30% 1st Apr 15: Stat Rep: RP-141805->RP-150162 03/07/15: Compl:30%->90% 03/07/15: CD:Mon 15/06/15->Tue 15/09/15 03/07/15: Stat Rep: RP-150162->RP-150846 29/09/15: Compl:90%->100% 29/09/15: Stat Rep: RP-150846->RP-151213 / Impacted TSs and TRs: 36.300, 36.423
- 694: Triggered by TR 37.846 Study on 2GHz FDD for UTRA and LTE in Region 1 (1980-2010MHz and 2170-2200MHz Bands) FS_UTRA_LTE_1980_2170_REG1 / Impacted TSs and TRs: LTE
- 695: CD:Fri 12/06/15->Mon 15/06/15; Compl:5%->15%; Stat Rep: RP-141627->RP-141795 1st Apr 15: Compl:15%->35% 1st Apr 15: WID: RP-141710->RP-150424 1st Apr 15: Stat Rep: RP-141795->RP-150106 03/07/15: Compl:35%->70% 03/07/15: CD:Mon 15/06/15->Tue 15/12/15 03...; ; ; ; ; ; ; ; ; ; ; ; ; ; ; ; ; ; ; ; ; ; ; ; ; ; ; ; ; ; ; ; ; ; ; ; ; ; ; ; ; ; ; ; ; ; ; ; ; ; ; ; ; ; ; ; ; ; ; ; ; ; ; ; ; ; ; ; ; ; ; ; ; ; ; ; ; ; ; ; ; ; ; ; ; ; ; ; ; ; ; ; ; ; ; ; ; ; ; ; ; ; ; ; ; ; ; ; ; ; ; ; ; ; ; ; ; ; ; ; ; ; ; ; ; ; ; ; ; ; ; ; ; ; ; ; ; ; ; ; ; ; ; ; ; ; ; ; ; ; ; ; ; ; ; ; ; ; ; ; ; ; ; ; ; ; ; ; ; ; ; ; ; ; ; ; ; ; ; ; ; ; ; ; ; ; ; ; ; ; ; ; ; ; ; ; ; ; ; ; ; ; ; ; ; ; ; ; ; ; ; ; ; ; ; ; ; ; ; ; ; ; ; ; ; ; ; ; ; ; ; ; 1/1/16: Compl:90%->100%; ; ; ; ; ; ; ; ; ; ; ; ; ; ; ; ; ; ; ; ; ; ; ; ; ; ; ; ; ; ; ; ; ; ; ; ; ; ; ; ; ; ; ; ; ; ; ; ; ; ; ; ; ; ; ; ; ; ; ; ; ; ; ; ; ; ; ; ; ; ; ; ; ; ; ; ; ; ; ; ; ; ; ; ; ; ; ; ; ; ; ; ; ; ; ; ; ; ; ; ; ; ; ; ; ; ; ; ; ; ; ; ; ; ; ; ; ; ; ; ; ; ; ; ; ; ; ; ; ; ; ; ; ; ; ; ; ; ; ; ; ; ; ; ; ; ; ; ; ; ; ; ; ; ; ; ; ; ; ; ; ; ; ; ; ; ; ; ; ; ; ; ; ; ; ; ; ; ; ; ; ; ; ; ; ; ; ; ; ; ; ; ; ; ; ; ; ; ; ; ; ; ; ; ; ; ; ; ; ; ; ; ; ; ; ; ; ; ; ; ; ; ; ; ; ; ; ; ; ; ; ; 1/1/16: WID: RP-150424->RP-151732 / Impacted TSs and TRs: 36.101, 36.104, 36.133, 36.141, 36.307, generic TR 36.853 (3 Band CA with 1UL), New TR 36.862 (Technical Report for 2 GHz Band in Region 1)
- 696: CD:Fri 12/06/15->Mon 15/06/15; Compl:0%->0%; Stat Rep: RP-141627->RP-141795 1st Apr 15: WID: RP-141710->RP-150424 1st Apr 15: Stat Rep: RP-141795->RP-150106 03/07/15: CD:Mon 15/06/15->Tue 15/12/15 03/07/15: Stat Rep: RP-150106->RP-150705 29/09/15: Stat...; ; ; ; ; ; ; ; ; ; ; ; ; ; ; ; ; ; ; ; ; ; ; ; ; ; ; ; ; ; ; ; ; ; ; ; ; ; ; ; ; ; ; ; ; ; ; ; ; ; ; ; ; ; ; ; ; ; ; ; ; ; ; ; ; ; ; ; ; ; ; ; ; ; ; ; ; ; ; ; ; ; ; ; ; ; ; ; ; ; ; ; ; ; ; ; ; ; ; ; ; ; ; ; ; ; ; ; ; ; ; ; ; ; ; ; ; ; ; ; ; ; ; ; ; ; ; ; ; ; ; ; ; ; ; ; ; ; ; ; ; ; ; ; ; ; ; ; ; ; ; ; ; ; ; ; ; ; ; ; ; ; ; ; ; ; ; ; ; ; ; ; ; ; ; ; ; ; ; ; ; ; ; ; ; ; ; ; ; ; ; ; ; ; ; ; ; ; ; ; ; ; ; ; ; ; ; ; ; ; ; ; ; ; ; ; ; ; ; ; ; ; ; ; ; ; ; ; ; ; ; ; ; 1/1/16: Compl:0%->100%; ; ; ; ; ; ; ; ; ; ; ; ; ; ; ; ; ; ; ; ; ; ; ; ; ; ; ; ; ; ; ; ; ; ; ; ; ; ; ; ; ; ; ; ; ; ; ; ; ; ; ; ; ; ; ; ; ; ; ; ; ; ; ; ; ; ; ; ; ; ; ; ; ; ; ; ; ; ; ; ; ; ; ; ; ; ; ; ; ; ; ; ; ; ; ; ; ; ; ; ; ; ; ; ; ; ; ; ; ; ; ; ; ; ; ; ; ; ; ; ; ; ; ; ; ; ; ; ; ; ; ; ; ; ; ; ; ; ; ; ; ; ; ; ; ; ; ; ; ; ; ; ; ; ; ; ; ; ; ; ; ; ; ; ; ; ; ; ; ; ; ; ; ; ; ; ; ; ; ; ; ; ; ; ; ; ; ; ; ; ; ; ; ; ; ; ; ; ; ; ; ; ; ; ; ; ; ; ; ; ; ; ; ; ; ; ; ; ; ; ; ; ; ; ; ; ; ; ; ; ; ; ; 1/1/16: WID: RP-150424->RP-151732 / Impacted TSs and TRs: 36.101, 36.104, 36.133, 36.141, 36.307, 36.862
- 697: testing REL-13 LTE_1980_2170_REG1-Core and LTE_1980_2170_REG3-Core; ...;...
- 698: Triggered by TR 37.822 Study on Next-Generation SON for UTRA and LTE (FS_UTRA_LTE_NG_SON) / Impacted TSs and TRs: LTE
- 699: CD:Tue 16/06/15->Mon 15/06/15; Compl:0%->15%; Stat Rep: -->RP-141854 1st Apr 15: Compl:15%->25% 1st Apr 15: Stat Rep: RP-141854->RP-150110 03/07/15: Compl:25%->100% 03/07/15: Stat Rep: RP-150110->RP-150727 / Impacted TSs and TRs: 36.300, 36.423, 36.413, 25.413
- 701: June2015: Compl:6%->100. Verbal indication from SA2 chair / Impacted TSs and TRs: 23.203
- 702: Mar.15: 10->100% / Impacted TSs and TRs: 29.212, 29.215
- 704: . 12/12:0->100%. 5/5/15: acronym changed from ePCSCF_WLAN-CT1 to ePCSCF_WLAN / Impacted TSs and TRs: 24.229, 24.302
- 705: Mar.15: 0->100%. 5/5/15: acronym changed from ePCSCF_WLAN-CT1 to ePCSCF_WLAN / Impacted TSs and TRs: 29.274, 29.275
- 706: WID added, acronym. June 2015: WID: CP-140995-> CP-150275
- 707: CT4->CT1. 2/4/15: acronym changed to PCSCF_RES_WLAN; June2015: Compl:0%->10. June 2015: WID: CP-140995-> CP-150275; 07/09/15: 10%->70; 7/12/15: 70%->100 / Impacted TSs and TRs: 24.302, 24.229, 24.244, 24.008
- 708: Dec.14: 0->5%. Mar.15: 5->100%. 2/4/15: acronym changed to PCSCF_RES_WLAN; June2015: Compl:100%->75. June 2015: WID: CP-140995-> CP-150275; 07/09/15: 75%->85; 7/12/15: 85%->100 / Impacted TSs and TRs: New 29.8xy, 23.380, 29.273, 29.274, 29.275, 23.008

| ID | WBS | Task | Duration | Start | Finish | Complete | Remaining | Total slack | Constraint | Resources | Work | Actual work | Acronym | PCG approved | WI rapporteur name | WI rapporteur e-mail | Release | TSG approved |
| --- | --- | --- | --- | --- | --- | --- | --- | --- | --- | --- | --- | --- | --- | --- | --- | --- | --- | --- |
| 709 | 232 | **Mobile Equipment Identity signalling over WLAN** | 69d? | 2015-06-15 A | 2015-09-17 A | 100% |  |  |  | C4 | 1656h | 1656h | MEI_WLAN | PCG-35 | Bruno Landais, Alcatel-Lucent | bruno.landais@alcatel-lucent.com | Rel-13 | CP-68 |
| 710 | 232.1 | CT1 aspects of Mobile Equipment Identity signalling over WLAN | 69d? | 2015-06-15 A | 2015-09-17 A | 100% |  |  | start no earlier than 2015-06-15 | C1 | 552h | 552h | MEI_WLAN | PCG-35 | Bruno Landais, Alcatel-Lucent | bruno.landais@alcatel-lucent.com | Rel-13 | CP-68 |
| 711 | 232.2 | CT4 aspects of Mobile Equipment Identity signalling over WLAN | 69d? | 2015-06-15 A | 2015-09-17 A | 100% |  |  | start no earlier than 2015-06-15 | C4 | 552h | 552h | MEI_WLAN | PCG-35 | Bruno Landais, Alcatel-Lucent | bruno.landais@alcatel-lucent.com | Rel-13 | CP-68 |
| 712 | 233 | Authentication Signalling Improvements for WLAN | 195d? | 2015-06-15 A | 2016-03-11 A | 100% |  |  | finish no earlier than 2016-03-11 | C1 | 1560h | 1560h | ASI_WLAN | PCG-35 | Youyang Yu | yuyouyang@huawei.com | Rel-13 | CP-68 |
| 713 | 234 | **Stage-3 SAE Protocol Development - Phase 4** | 268d? | 2014-12-03 A | 2015-12-11 A | 100% |  |  |  | C1 | 8576h | 8576h | SAES4 | PCG-34 | interdigital |  | Rel-13 | CT-66 |
| 714 | 234.1 | SAE Protocol Development (Stage 3) - Phase 4 | 268d? | 2014-12-03 A | 2015-12-11 A | 100% |  |  | start no earlier than 2014-12-03 | C1 | 2144h | 2144h | SAES4 | PCG-34 | interdigital |  | Rel-13 | CT-66 |
| 715 | 234.2 | CS Fallback in EPS - Phase 4 | 268d? | 2014-12-03 A | 2015-12-11 A | 100% |  |  | start no earlier than 2014-12-03 | C1 | 2144h | 2144h | SAES4-CSFB | PCG-34 | interdigital |  | Rel-13 | CT-66 |
| 716 | 234.3 | SAE for support for non-3GPP accesses - Phase 4 | 268d? | 2014-12-03 A | 2015-12-11 A | 100% |  |  | start no earlier than 2014-12-03 | C1 | 2144h | 2144h | SAES4-non3GPP | PCG-34 | interdigital |  | Rel-13 | CT-66 |
| 717 | 235 | **Interworking solution for Called IN number and original called IN number ISUP parameters** | 73d? | 2014-12-03 A | 2015-03-13 | 74% | 19.1d? | 807d |  | C1; C3 | 2354.5h | 1738.34h | INNB_IW | PCG-34 | Orange |  | Rel-13 | CT-66 |
| 718 | 235.1 | Interworking solution for Called IN number and original called IN number ISUP parameters | 73d? | 2014-12-03 A | 2015-03-13 A | 100% |  |  | start no earlier than 2014-12-03 | C1 | 584h | 584h | INNB_IW | PCG-34 | Orange |  | Rel-13 | CT-66 |
| 719 | 235.2 | (IETF) CT1 part of Interworking solution for Called IN number and original called IN number ISUP parameters | 51.75d? | 2014-12-03 | 2015-03-10 |  |  | 810d | finish no earlier than 2015-03-10 | C1-IETF | 414h |  | INNB_IW | PCG-34 | Orange |  | Rel-13 | CT-66 |
| 720 | 235.3 | CT3 aspects of Interworking solution for Called IN number and original called IN number ISUP parameters | 73d? | 2014-12-03 A | 2015-03-13 A | 100% |  |  | finish no earlier than 2015-03-13 | C3 | 584h | 584h | INNB_IW | PCG-34 | Orange |  | Rel-13 | CT-66 |
| 721 | 236 | **Warning Status Report in EPS** | 204d? | 2014-12-03 A | 2015-09-14 A | 100% |  |  |  | C4 | 4896h | 4896h | WSR_EPS | PCG-34 | one2many |  | Rel-13 | CT-66 |
| 722 | 236.1 | CT1 aspects of Warning Status Report in EPS | 204d? | 2014-12-03 A | 2015-09-14 A | 100% |  |  | start no earlier than 2014-12-03 | C1 | 1632h | 1632h | WSR_EPS | PCG-34 | one2many |  | Rel-13 | CT-66 |
| 723 | 236.2 | CT4 aspects of Warning Status Report in EPS | 204d? | 2014-12-03 A | 2015-09-14 A | 100% |  |  | finish no earlier than 2015-09-14 | C4 | 1632h | 1632h | WSR_EPS | PCG-34 | one2many |  | Rel-13 | CT-66 |
| 724 | 237 | Shared Data Update for Multiple Subscriber | 1d? | 2014-12-03 A | 2014-12-03 A | 100% |  |  | start no earlier than 2014-12-03 | C4 | 8h | 8h | SHARED_SubData_UPD | PCG-34 | Huawei, Susan Shi | susan.shishufeng@huawei.com | Rel-13 | CT-66 |
| 725 | 238 | **IMS Stage-3 IETF Protocol Alignment** | 666d? | 2014-12-03 A | 2017-06-20 | 70% | 199.79d? | 214d |  | C1 | 11760h | 6003.22h | IMSProtoc7 | PCG-34 | Alcatel-Lucent | Keith Drage | Rel-13 | CT-66 |
| 726 | 238.1 | CT1 aspects of IMS Stage-3 IETF Protocol Alignment | 268d? | 2014-12-03 A | 2015-12-11 A | 100% |  |  | finish no earlier than 2015-12-11 | C1 | 2144h | 2144h | IMSProtoc7 | PCG-34 | Alcatel-Lucent | Keith Drage | Rel-13 | CT-66 |
| 727 | 238.2 | (IETF) CT1 aspects of IMS Stage-3 IETF Protocol Alignment | 268d? | 2016-06-13 A | 2017-06-20 | 10% | 241.2d? | 214d | finish no earlier than 2015-12-11 | C1 | 2144h | 214.4h | IMSProtoc7 | PCG-34 | Alcatel-Lucent | Keith Drage | Rel-13 | CT-66 |
| 728 | 238.3 | CT3 aspects of IMS Stage-3 IETF Protocol Alignment | 268d? | 2014-12-03 A | 2015-12-11 A | 100% |  |  | start no earlier than 2014-12-03 | C3 | 2144h | 2144h | IMSProtoc7 | PCG-34 | Alcatel-Lucent | Keith Drage | Rel-13 | CT-67 |
| 729 | 239 | Retry restriction for Improving System Efficiency | 205d? | 2015-03-04 A | 2015-12-15 A | 100% |  |  | finish no earlier than 2015-12-15 | C1 | 1640h | 1640h | RISE | PCG-34 | Huawei, Lin Shu | shulin@huawei.com | Rel-13 | CP-67 |
| 730 | 240 | **H.248 Aspects of WebRTC Data Channel on IMS Access Gateway** | 268d? | 2015-03-04 A | 2016-03-11 A | 100% |  |  |  | C4 | 4288h | 4288h | WebRTCH248DC | PCG-34 | China Mobile, Xiaoning Du | duxiaoning@chinamobile.com | Rel-13 | CP-67 |
| 731 | 240.1 | CT4 Aspect of H.248 Aspects of WebRTC Data Channel on IMS Access Gateway | 268d? | 2015-03-04 A | 2016-03-11 A | 100% |  |  | finish no earlier than 2016-03-11 | C4 | 2144h | 2144h | WebRTCH248DC | PCG-34 | China Mobile, Xiaoning Du. ES in 639 | duxiaoning@chinamobile.com | Rel-13 | CT-67 |
| 732 | 241 | Continuation of the Overload Control for PCC based Diameter applications | 203d? | 2015-03-04 A | 2015-12-11 A | 100% |  |  | finish no earlier than 2015-12-11 | C3 | 1624h | 1624h | cDOCME_PCC | PCG-34 | ZTE, Zhou Xiaoyun | zhou.xiaoyun@zte.com.cn | Rel-13 | CP-67 |
| 733 | 242 | Review of dedicated 3GPP UICC features | 200d? | 2015-03-09 A | 2015-12-11 A | 100% |  |  | finish no earlier than 2015-12-11 | C6 | 1600h | 1600h | Red_UCe | PCG-34 | Blackberry, Adrian Buckley | abuckley@blackberry.com | Rel-13 | CP-67 |

Notes:
- 709: Impacted TSs and TRs: 24.244, 24.302, 29.273, 29.274, 29.275, 23.008
- 710: 07/09/15: 0%->80; 7/12/15: 80%->100 / Impacted TSs and TRs: 24.244, 24.302
- 711: 07/09/15: 0%->90; 7/12/15: 90%->100 / Impacted TSs and TRs: 29.273, 29.274, 29.275, 23.008
- 712: 07/09/15: 0%->40; 7/12/15: 40%->95. FCD -> 03/16, ES in CP-150727; 7/3/16: 95%->100 / Impacted TSs and TRs: 24.302, 24.244
- 713: WP Structure created 24/03/15 to avoid confusion in Acronyms / Impacted TSs and TRs: 23.12, 24.008, 24.167, 24.229, 24.301, 24.302, 24.303, 24.304, 24.305, 24.312, 29.018, 29.118
- 714: WP Structure created 24/03/15 to avoid confusion in Acronyms. 5/5/15: acronym changed from "SAES4-CT1"; June2015: Compl:0%->30; 07/09/15: 30%->70; 7/12/15: 70%->100
- 715: WP Structure created 24/03/15 to avoid confusion in Acronyms; June2015: Compl:0%->30; 07/09/15: 30%->70; 7/12/15: 70%->100
- 716: WP Structure created 24/03/15 to avoid confusion in Acronyms; June2015: Compl:0%->30; 07/09/15: 30%->50; 7/12/15: 50%->100
- 718: 5/5/15: created; June2015: Compl:0%->70; 07/09/15: 70%->100 / Impacted TSs and TRs: 24.229
- 719: Mar15: resp WG:C1->C1-IETF. WID changed from INNB_IW-CT1 / Impacted TSs and TRs: draft-mohali-dispatch-cause-for-service-number
- 720: Mar.15: 80->90%. WID changed from INNB_IW-CT3; June2015: Compl:0%->98; 07/09/15: 98%->99; 7/12/15: 99%->100
- 721: 5/5/15: acronym changed from "WSR_EP"; 7/12/15: WID:CP-140998->CP-150792
- 722: 2/4/15: acronym changed to WSR_EP. 5/5/15: acronym changed from "WSR_EP"; 07/09/15: 0%->25; 7/12/15: 25%->100; 7/12/15: WID:CP-140998->CP-150792 / Impacted TSs and TRs: New TR 23.712
- 723: 2/4/15: acronym changed to WSR_EP. 5/5/15: acronym changed from "WSR_EP"; 7/12/15: 0%->100; 7/12/15: WID:CP-140998->CP-150792
- 724: Mar.15: 0->50%, WID: CP-140804->CP-150013; June2015: Compl:50%->95; 07/09/15: 95%->100 / Impacted TSs and TRs: 29.328, 29.364
- 725: Mar.15: 0->10% / Impacted TSs and TRs: 23.218, 24.998, 24.930
- 726: Mar.15: 0->10%; June2015: Compl:10%->30; 07/09/15: 30%->70; 7/12/15: 70%->100
- 727: Impacted TSs and TRs: draft-ietf-mmusic-dtls-sdp, draft-ietf-mmusic-4572-update
- 728: 2/4/15: added, following CT3 chair's info that the WID also has a CT3 part; June2015: Compl:0%->20; 07/09/15: 20%->40; 7/12/15: 40%->100
- 729: Continuation of Rel-12 SINE UID 620006. 5/5/15: acronym changed from "RISE"; June2015: Compl:0%->10; 07/09/15: 10%->70; 14/09/15: WID:CP-150092->CP-150495; 7/12/15: 70%->100
- 730: Impacted TSs and TRs: 23.334
- 731: June2015: Compl:0%->10; 07/09/15: 10%->20; 7/12/15: 20%->90; 7/3/16: 90%->100 / Impacted TSs and TRs: 23.334
- 732: Relates to UID 580026 (Study on Diameter overload control mechanism); June2015: Compl:0%->100 / Impacted TSs and TRs: 29.212, 29.215, 29.219, 29.217
- 733: Results from the homonymous Study; June2015: Compl:0%->60; 07/09/15: 60%->75; 7/3/16: 75%->100 / Impacted TSs and TRs: 31.102, 31.111, 31.121, 31.124

| ID | WBS | Task | Type | Duration | Start | Finish | Complete | Remaining | Baseline start | Baseline finish | Baseline duration | Total slack | Constraint | Resources | Work | Actual work | Acronym | PCG approved | WI rapporteur name | WI rapporteur e-mail | Release | TSG approved | Status Report | Acronym_3GU_Export | TSG stopped | MCC resp |
| --- | --- | --- | --- | --- | --- | --- | --- | --- | --- | --- | --- | --- | --- | --- | --- | --- | --- | --- | --- | --- | --- | --- | --- | --- | --- | --- |
| 734 | 243 | **Controlling IMS Media Plane with SDP Capability** |  | 195d? | 2015-06-15 A | 2016-03-11 A | 100% |  |  |  |  |  |  | C4 | 4680h | 4680h | SDPCN_IMS | PCG-35 | Weiwei(Tommy) Yang, Huawei. ES in 640 | tommy@huawei.com | Rel-13 | CP-68 |  |  |  |  |
| 735 | 243.1 | CT3 aspects of Controlling IMS Media Plane with SDP Capability |  | 195d? | 2015-06-15 A | 2016-03-11 A | 100% |  |  |  |  |  | finish no earlier than 2016-03-11 | C3 | 1560h | 1560h | SDPCN_IMS | PCG-35 | Weiwei(Tommy) Yang, Huawei. ES in 640 | tommy@huawei.com | Rel-13 | CP-68 |  |  |  |  |
| 736 | 243.2 | CT4 aspects of Controlling IMS Media Plane with SDP Capability |  | 195d? | 2015-06-15 A | 2016-03-11 A | 100% |  |  |  |  |  | finish no earlier than 2016-03-11 | C4 | 1560h | 1560h | SDPCN_IMS | PCG-35 | Weiwei(Tommy) Yang, Huawei. ES in 640 | tommy@huawei.com | Rel-13 | CP-68 |  |  |  |  |
| 737 | 244 | **(SA66: on hold) Co-ordinated packet data network gateway (P-GW) change for SIPTO** |  | 66d? | 2014-06-18 A | 2014-09-16 A | 100% |  | 2014-06-18 | 2014-09-17 | 66d? |  |  | S1 | 1056h | 1056h | CSIPTO | PCG-33 | Intel | Eric.siow@intel.com | Rel-13 | SP-64 | S1-143306 | CSIPTO |  |  |
| 738 | 244.1 | Stage 1 for Co-ordinated packet data network gateway (P-GW) change for SIPTO |  | 66d? | 2014-06-18 A | 2014-09-16 A | 100% |  | 2014-06-18 | 2014-09-17 | 66d? |  | finish no earlier than 2014-09-17 | S1 | 528h | 528h | CSIPTO-ST1 | PCG-33 | Intel | Eric.siow@intel.com | Rel-13 | SP-64 | S1-143306 | CSIPTO |  |  |
| 739 | 245 | **Enhanced CS Fallback (CSFB)** |  | 196d? | 2014-06-18 A | 2015-03-13 | 100% | 0d? | 2014-06-18 | 2015-03-18 | 196d? | 0d |  | S2; S3 | 4168h | 2600h | eCSFB | PCG-33 | China Unicom | Yang Xu (xuyang49@chinaunicom.cn) | Rel-13 | SP-64 |  | eCSFB |  |  |
| 740 | 245.1 | TR for Enhanced CS Fallback (CSFB) |  | 128d? | 2014-06-18 A | 2014-12-12 A | 100% |  | 2014-06-18 | 2014-12-10 | 126d? |  | finish no earlier than 2014-12-12 | S2 | 1024h | 1024h | eCSFB | PCG-33 | China Unicom | Yang Xu (xuyang49@chinaunicom.cn) | Rel-13 | SP-64 |  |  |  |  |
| 741 | 245.2 | Deleted - Stage 2 for Enhanced CS Fallback (CSFB) | milestone | 0d? | 2015-03-13 A | 2015-03-13 A | 100% |  | 2014-06-18 | 2015-03-18 | 196d? |  | start no earlier than 2015-03-13 | S2 |  |  | eCSFB | PCG-33 | China Unicom | Yang Xu (xuyang49@chinaunicom.cn) | Rel-13 | SP-64 |  |  | SP-69 |  |
| 742 | 245.3 | Deleted - Security for Enhanced CS Fallback (CSFB) |  | 1d? | 2014-09-18 A | 2014-09-18 A | 100% |  |  |  |  |  | start no earlier than 2014-09-17 | S3 | 8h | 8h | eCSFB | PCG-33 | China Unicom | Feng Gao (gaofeng149@chinaunicom.cn) | Rel-13 | SP-65 |  |  | SP-69 |  |
| 743 | 246 | **SRVCC Enhancements for Transcoding Avoidance** |  | 196d? | 2014-09-19 A | 2015-06-17 A | 100% |  |  |  |  |  |  | S2 | 2592h | 2592h | SETA | PCG-33 | Ericsson | George.Foti@ericsson.com | Rel-13 | SP-65 |  | SETA |  |  |
| 744 | 246.1 | TR for SRVCC Enhancements for Transcoding Avoidance |  | 128d? | 2014-09-19 A | 2015-03-13 A | 100% |  |  |  |  |  | finish no earlier than 2015-03-13 | S2 | 1024h | 1024h | SETA-SA2TR | PCG-33 | Ericsson | George.Foti@ericsson.com | Rel-13 | SP-65 |  |  |  |  |
| 745 | 246.2 | Deleted - Stage 2 for SRVCC Enhancements for Transcoding Avoidance | milestone | 0d? | 2015-06-17 A | 2015-06-17 A | 100% |  |  |  |  |  | start no earlier than 2015-06-17 | S2 |  |  | SETA-SA2 | PCG-33 | Ericsson | George.Foti@ericsson.com | Rel-13 | SP-65 |  |  | SP-69 |  |
| 746 | 247 | **Base Station (BS) RF requirements for Active Antenna System (AAS)** |  | 933d? | 2013-03-04 A | 2016-09-15 | 99% | 0d? | 2013-03-04 | 2014-12-05 | 465d? | 0d |  | R4 | 21184h | 15502.8h | AAS_BS_LTE_UTRA | PCG-30 | Huawei | ronnie.zhang@huawei.com | Rel-13 | RP-59 |  | AAS_BS_LTE_UTRA |  | Issam |
| 747 | 247.1 | Core part: Base Station (BS) RF requirements for Active Antenna System (AAS) |  | 793d? | 2013-03-04 A | 2016-03-15 A | 100% |  | 2013-03-04 | 2014-09-12 | 401d? |  | finish no earlier than 2016-03-15 | R4 | 6344h | 6344h | AAS_BS_LTE_UTRA-Core | PCG-30 | Huawei | ronnie.zhang@huawei.com | Rel-13 | RP-59 | RP-151241 | AAS_BS_LTE_UTRA-Core |  | Issam |
| 748 | 247.2 | Perf. part: Base Station (BS) RF requirements for Active Antenna System (AAS) |  | 922d? | 2013-03-15 A | 2016-09-15 A | 100% |  | 2013-03-07 | 2014-12-05 | 461d? |  | finish no earlier than 2016-09-15 | R4 | 7376h | 7376h | AAS_BS_LTE_UTRA-Perf | PCG-30 | Huawei | ronnie.zhang@huawei.com | Rel-13 | RP-59 | RP-151241 | AAS_BS_LTE_UTRA-Perf |  | Issam |
| 749 | 248 | **Enhanced LTE Device to Device Proximity Services** |  | 460d? | 2014-12-15 A | 2016-09-15 | 99% | 0d? |  |  |  | 0d |  | R2 | 11016h | 8126.35h | LTE_eD2D_Prox | PCG-34 | Qualcomm | Qualcomm | Rel-13 | RP-66 |  |  |  |  |
| 750 | 248.1 | Core part: Enhanced LTE Device to Device Proximity Services |  | 152.33d? | 2015-08-14 A | 2016-03-15 A | 100% |  |  |  |  |  | finish no earlier than 2016-03-15 | R2; R1; R3 | 3656h | 3656h | LTE_eD2D_Prox-Core | PCG-34 | Qualcomm Incorporated, Shailesh Patil | patil@qti.qualcomm.com | Rel-13 | RP-66 | RP-151337 |  |  |  |
| 751 | 248.2 | Perf. part: Enhanced LTE Device to Device Proximity Services |  | 460d? | 2014-12-15 A | 2016-09-15 A | 100% |  |  |  |  |  | finish no earlier than 2016-09-15 | R4 | 3680h | 3680h | LTE_eD2D_Prox-Perf | PCG-34 | Qualcomm | Qualcomm | Rel-13 | RP-66 | RP-151337 |  |  |  |
| 752 | 249 | **Radiated requirements for the verification of multi-antenna reception performance of UEs** |  | 327d? | 2014-12-15 A | 2016-03-15 A | 100% |  |  |  |  |  |  | R4 | 5232h | 5232h | UTRA_LTE_MIMO_OTA | PCG-34 | Intel | Intel | Rel-13 | RP-66 |  |  |  |  |
| 753 | 249.1 | Core part: Radiated requirements for the verification of multi-antenna reception performance of UEs |  | 327d? | 2014-12-15 A | 2016-03-15 A | 100% |  |  |  |  |  | finish no earlier than 2016-03-15 | R4 | 2616h | 2616h | UTRA_LTE_MIMO_OTA-Core | PCG-34 | Intel | Intel | Rel-13 | RP-66 | RP-151573 |  |  |  |
| 754 | 250 | **UE core requirements for uplink 64 QAM** |  | 197d? | 2014-12-15 A | 2015-09-15 A | 100% |  |  |  |  |  |  | R4 | 3152h | 3152h | LTE_UL64QAM | PCG-34 | Huawei | Huawei | Rel-13 | RP-66 |  |  |  |  |
| 755 | 250.1 | Core part: UE core requirements for uplink 64 QAM |  | 197d? | 2014-12-15 A | 2015-09-15 A | 100% |  |  |  |  |  | finish no earlier than 2015-09-15 | R4 | 1576h | 1576h | LTE_UL64QAM-Core | PCG-34 | Huawei | Huawei | Rel-13 | RP-66 | RP-151244 |  |  |  |
| 756 | 251 | UE Conformance Test Aspects - Core Requirements for Uplink 64QAM for E-UTRA |  | 132d? | 2015-06-15 A | 2015-12-15 A | 100% |  |  |  |  |  | finish no earlier than 2015-12-15 | R5 | 1056h | 1056h | LTE_UL64QAM-UEConTest | PCG-35 | CMCC |  | Rel-13 | TSG-68 | RP-151174 |  |  |  |
| 757 | 252 | **Performance requirements of MMSE-IRC receiver for LTE BS** |  | 393d? | 2014-12-15 A | 2016-06-15 A | 100% |  |  |  |  |  |  | R4 | 6288h | 6288h | LTE_MMSE_IRC_BS | PCG-34 | China Telecom | China Telecom | Rel-13 | RP-66 |  |  |  |  |
| 758 | 252.1 | Perf. part: Performance requirements of MMSE-IRC receiver for LTE BS |  | 393d? | 2014-12-15 A | 2016-06-15 A | 100% |  |  |  |  |  | finish no earlier than 2016-06-15 | R4 | 3144h | 3144h | LTE_MMSE_IRC_BS-Perf | PCG-34 | China Telecom | China Telecom | Rel-13 | RP-66 | RP-151215 |  |  |  |

Notes:
- 734: Impacted TSs and TRs: 23.334, 29.334, 29.162, 29.238, 23.333, 29.333, 29.163, 29.332, 29.292, 29.232, 29.235
- 735: 7/12/15: 0%->90. FCD->03/16. ES in CP-150614; 7/3/16: 90%->100 / Impacted TSs and TRs: 29.162, 29.163, 29.292, 29.235
- 736: 07/09/15: 0%->5; 7/12/15: 5%->70. FCD->03/16. ES in CP-150614; 7/3/16: 70%->100 / Impacted TSs and TRs: 23.334, 29.334, 29.238, 23.333, 29.333, 29.332, 29.232
- 737: SP#65 completed. Updated WID SP-140235=>SP-140509. Triggered by Rel-13 Study TR 22.828 (FS_CSIPTO) / Impacted TSs and TRs: 22.101
- 738: SP#65 completed. Updated WID SP-140235=>SP-140509. Triggered by Rel-13 Study TR 22.828 (FS_CSIPTO). Dec.14: former S1-only feature split / Impacted TSs and TRs: 22.101
- 739: SP#65 updated ID SP-140285=>SP-140579 (added SA3 part). Linked to Rel-8 WIs Single Radio Voice Call Continuity for 3GPP (SAES-SRVCC) and CS Fallback in EPS (SAES-CSFB) / Impacted TSs and TRs: Stage 2
- 740: SP#65 updated ID SP-140285=>SP-140579 (added SA3 part). Dec.14: 35->85%; 14/09/15: 85%->100. SA#69: decision not to continue the work on this. No normative work. / Impacted TSs and TRs: New TR 23.772
- 741: SP#65 updated ID SP-140285=>SP-140579 (added SA3 part) / Impacted TSs and TRs: 23.272
- 742: SP#65 updated ID SP-140285=>SP-140579; 14/09/15: 0%->100. SA#69: deleted, since SA2 has stopped the work.
- 743: Enhance chances for end-to-end transcoder free operation (TrFo) where possible/ ensure proper CS radio resources are reserved for optimal RAN codec. Address TrFo of EVS codecs during SRVCC that are not covered by Rel-12 / Impacted TSs and TRs: Stage 2
- 744: Dec.14: 0->70%; 14/09/15: 70%->100. Stopped without conclusion, no intention to continue the study nor to do any mormative work. / Impacted TSs and TRs: New TR 23.7xy
- 745: SA#69: stop the work on this. / Impacted TSs and TRs: 23.216, 23.237
- 746: Triggered by Rel-12 TR 37.840 Study of RF and EMC Requirements for Active Antenna Array System BS (FS_AAS_BS_LTE_UTRA) / Impacted TSs and TRs: UTRA, LTE, GERAN
- 747: ; CD:Thu 11/12/14->Tue 15/12/15; WID: RP-141966->RP-142235; Stat Rep: RP-141249->RP-141908; Release: Rel-12->Rel-13 03/07/15: Stat Rep: RP-141908->RP-150687 29/09/15: Compl:75%->80% 29/09/15: Stat Rep: RP-150687->RP-151241...; ;... / Impacted TSs and TRs: New TS 37.142 (AAS BS Tx & Rx), New TR 37.842, 37.114, 37.145-1, 37.145-2
- 748: ; CD:Sat 18/06/16->Wed 15/06/16; WID: RP-141966->RP-142235; Stat Rep: RP-141249->RP-141908; Release: Rel-12->Rel-13 03/07/15: Stat Rep: RP-141908->RP-150687 29/09/15: Stat Rep: RP-150687->RP-151241 22/3/16: Compl:2...;...; 26/9/16: Compl:95%->100% / Impacted TSs and TRs: New TS 37.1xy (AAS BS conformance testing)
- 750: Rapporteur details and involved WGs updated 1st Apr 15: WID: RP-142311->RP-150441 1st Apr 15: Stat Rep: ->RP-150095 03/07/15: Compl:0%->32% 03/07/15: Stat Rep: RP-150095->RP-150795 29/09/15: Compl:32%->55% 29/09/15: Stat Rep: RP-150795->RP-151337...; ; ; ; ; ; ; ; ; ; ; ; ; ; ; ; ; ; ; ; ; ; ; ; ; 22/3/16: Compl:90%->100%
- 751: 1st Apr 15: WID: RP-142311->RP-150441 1st Apr 15: Stat Rep: ->RP-150095 03/07/15: Stat Rep: RP-150095->RP-150795 29/09/15: Stat Rep: RP-150795->RP-151337; 1/1/16: CD...; 22/3/16: Compl:0%->10%;...26/9/16: Compl:85%->100%
- 753: 1st Apr 15: Compl:0%->5% 1st Apr 15: WID: RP-142221->RP-150261 1st Apr 15: Stat Rep: ->RP-150260 03/07/15: Compl:5%->15% 03/07/15: Stat Rep: RP-150260->RP-150746 29/09/15: Compl:15%->25% 29/09/15: WID: RP-150261->RP-151574 29/09/15: Stat Rep: RP-15074...; ; ; ; ; ; ; ; ; ; ; ; ; ; ; ; ; ; ; ; 22/3/16: Compl:30%->100%; ; ; ; ; ; ; ; ; ; ; ; ; ; ; ; ; ; ; ; 22/3/16: WID: RP-151878->RP-160344
- 755: 1st Apr 15: Compl:0%->10% 1st Apr 15: Stat Rep: ->RP-150232 03/07/15: Compl:10%->90% 03/07/15: WID: RP-142222->RP-150691 03/07/15: Stat Rep: RP-150232->RP-150688 29/09/15: Compl:90%->100% 29/09/15: Stat Rep: RP-150688->RP-151244
- 756: tested Core part: LTE_UL64QAM-Core which is not yet completed 29/09/15: Compl:0%->5% 29/09/15: Stat Rep: -->RP-151174 1/1/16: Compl:5%->100%
- 758: 1st Apr 15: Compl:0%->10% 1st Apr 15: WID: RP-142223->RP-150206 1st Apr 15: Stat Rep: ->RP-150204 03/07/15: Compl:10%->35% 03/07/15: Stat Rep: RP-150204->RP-150630 29/09/15: Compl:35%->50% 29/09/15: Stat Rep: RP-150630->RP-151215; ...; ;...;...

| ID | WBS | Task | Duration | Start | Finish | Complete | Remaining | Total slack | Constraint | Resources | Work | Actual work | Acronym | PCG approved | WI rapporteur name | WI rapporteur e-mail | Release | TSG approved | Status Report |
| --- | --- | --- | --- | --- | --- | --- | --- | --- | --- | --- | --- | --- | --- | --- | --- | --- | --- | --- | --- |
| 759 | 253 | **CRS Interference Mitigation for LTE Homogenous Deployments** | 327d? | 2014-12-15 A | 2016-03-15 A | 100% |  |  |  | R4 | 5232h | 5232h | LTE_CRSIM | PCG-34 | Ericsson | Ericsson | Rel-13 | RP-66 |  |
| 760 | 253.1 | Perf. part: CRS Interference Mitigation for LTE Homogenous Deployments | 327d? | 2014-12-15 A | 2016-03-15 A | 100% |  |  | finish no earlier than 2016-03-15 | R4 | 2616h | 2616h | LTE_CRSIM-Perf | PCG-34 | Ericsson | Ericsson | Rel-13 | RP-66 | RP-151171 |
| 761 | 254 | **Dual Connectivity enhancements for LTE** | 328d? | 2015-03-16 A | 2016-06-15 A | 100% |  |  |  | R2 | 6824h | 6824h | LTE_dualC_enh | PCG-34 | NTT DOCOMO |  | Rel-13 | RP-67 |  |
| 762 | 254.1 | Core part: Dual Connectivity enhancements for LTE | 197d? | 2015-03-16 A | 2015-12-15 A | 100% |  |  | finish no earlier than 2015-12-15 | R2 | 1576h | 1576h | LTE_dualC_enh-Core | PCG-34 | NTT DOCOMO |  | Rel-13 | RP-67 | RP-151330 |
| 763 | 254.2 | Perf. part: Dual Connectivity enhancements for LTE | 328d? | 2015-03-16 A | 2016-06-15 A | 100% |  |  | finish no earlier than 2016-06-15 | R4 | 2624h | 2624h | LTE_dualC_enh-Perf | PCG-34 | NTT DOCOMO |  | Rel-13 | RP-67 | RP-151330 |
| 764 | 255 | **Multicarrier Load Distribution of UEs in LTE** | 395d? | 2015-03-16 A | 2016-09-15 | 99% | 0d? | 0d |  | R2 | 7896h | 6075.65h | LTE_MC_load | PCG-34 | ZTE |  | Rel-13 | RP-67 |  |
| 765 | 255.1 | Core part: Multicarrier Load Distribution of UEs in LTE | 197d? | 2015-03-16 A | 2015-12-15 A | 100% |  |  | finish no earlier than 2015-12-15 | R2 | 1576h | 1576h | LTE_MC_load-Core | PCG-34 | ZTE |  | Rel-13 | RP-67 | RP-151190 |
| 766 | 255.2 | Perf. part: Multicarrier Load Distribution of UEs in LTE | 395d? | 2015-03-16 A | 2016-09-15 A | 100% |  |  | finish no earlier than 2016-09-15 | R4 | 3160h | 3160h | LTE_MC_load-Perf | PCG-34 | ZTE |  | Rel-13 | RP-67 | RP-151190 |
| 767 | 256 | **LTE-WLAN Radio Level Integration and Interworking Enhancement** | 524d? | 2015-03-16 A | 2017-03-15 | 68% | 166.35d? | 283d |  | R2 | 10488h | 4888.2h | LTE_WLAN_radio | PCG-34 | Intel |  | Rel-13 | RP-67 |  |
| 768 | 256.1 | Core part: LTE-WLAN Radio Level Integration and Interworking Enhancement | 262d? | 2015-03-16 A | 2016-03-15 A | 100% |  |  | finish no earlier than 2016-03-15 | R2 | 2096h | 2096h | LTE_WLAN_radio-Core | PCG-34 | Intel |  | Rel-13 | RP-67 | RP-151563 |
| 769 | 256.2 | Perf. part: LTE-WLAN Radio Level Integration and Interworking Enhancement | 262d? | 2015-03-16 A | 2016-03-15 A | 100% |  |  | finish no earlier than 2016-03-15 | R4 | 2096h | 2096h | LTE_WLAN_radio-Perf | PCG-34 | Intel |  | Rel-13 | RP-67 | RP-151563 |
| 770 | 256.3 | UE Conformance Test Aspects - WLAN/3GPP Radio Level Integration and Interworking Enhancement Interworking | 263d? | 2016-03-15 A | 2017-03-15 | 5% | 249.85d? | 283d | finish no earlier than 2017-03-15 | R5 | 2104h | 105.2h | LTE_WLAN_radio-UEConTest | PCG-36 | Intel |  | Rel-13 | TSG#71 |  |
| 771 | 257 | **RAN aspects for improvements to CS/PS coordination in UTRAN Shared Network** | 197d? | 2015-03-16 A | 2015-12-15 A | 100% |  |  |  | R3 | 3152h | 3152h | CSPS_Coord-UTRA | PCG-34 | Ericsson |  | Rel-13 | RP-67 |  |
| 772 | 257.1 | Core part: RAN aspects for improvements to CS/PS coordination in UTRAN Shared Network | 197d? | 2015-03-16 A | 2015-12-15 A | 100% |  |  | finish no earlier than 2015-12-15 | R3 | 1576h | 1576h | CSPS_Coord-UTRA-Core | PCG-34 | Ericsson |  | Rel-13 | RP-67 | RP-151289 |
| 773 | 258 | **LTE DL 4 Rx antenna ports** | 4443d? | 2000-01-03 A | 2016-12-15 | 97% | 145.43d? | 347d |  | R4 | 74256h | 44132.4h | LTE_4Rx_AP_DL | PCG-34 | Ericsson |  | Rel-13 | RP-67 |  |
| 774 | 258.1 | Core part: LTE DL 4 Rx antenna ports | 197d? | 2015-03-16 A | 2015-12-15 A | 100% |  |  | finish no earlier than 2015-12-15 | R4 | 1576h | 1576h | LTE_4Rx_AP_DL-Core | PCG-34 | Ericsson |  | Rel-13 | RP-67 | RP-151265 |
| 775 | 258.2 | Perf. part: LTE DL 4 Rx antenna ports | 4378d? | 2000-01-03 A | 2016-09-15 A | 100% |  |  | finish no earlier than 2016-09-15 | R4 | 35024h | 35024h | LTE_4Rx_AP_DL-Perf | PCG-34 | Ericsson |  | Rel-13 | RP-67 | RP-151265 |
| 776 | 258.3 | UE Conformance Test Aspects - LTE DL 4 Rx antenna ports | 264d? | 2015-12-15 A | 2016-12-15 | 40% | 158.4d? | 347d | finish no earlier than 2016-12-15 | R5 | 2112h | 844.8h | LTE_4Rx_AP_DL-UEConTest | PCG-36 | Ericsson |  | Rel-13 | RP-70 |  |
| 777 | 259 | **AWS-Extension Band for LTE** | 395d? | 2015-03-16 A | 2016-09-15 | 99% | 0d? | 0d |  | R4 | 7904h | 6320h | LTE_AWS_EXT | PCG-34 | Ericsson |  | Rel-13 | RP-67 |  |
| 778 | 259.1 | Core part: AWS-Extension Band for LTE | 197d? | 2015-03-16 A | 2015-12-15 A | 100% |  |  | finish no earlier than 2015-12-15 | R4 | 1576h | 1576h | LTE_AWS_EXT-Core | PCG-34 | Ericsson |  | Rel-13 | RP-67 | RP-151343 |
| 779 | 259.2 | Perf. part: AWS-Extension Band for LTE | 197d? | 2015-03-16 A | 2015-12-15 A | 100% |  |  | finish no earlier than 2015-12-15 | R4 | 1576h | 1576h | LTE_AWS_EXT-Perf | PCG-34 | Ericsson |  | Rel-13 | RP-67 | RP-151343 |
| 780 | 259.3 | UE Conformance Test Aspects - AWS-Extension Band for LTE (Band 66) | 199d? | 2015-12-15 A | 2016-09-15 A | 100% |  |  | finish no earlier than 2016-09-15 | R5 | 1592h | 1592h | LTE_AWS_EXT-UEConTest | PCG-36 | Ericsson |  | Rel-13 | RP-70 |  |
| 781 | 260 | **Additional bandwidth combination set for LTE Advanced inter-band Carrier Aggregation of Band 5 and Band 7** | 66d? | 2015-03-16 A | 2015-06-15 A | 100% |  |  |  | R4 | 1584h | 1584h | LTE_CA_B5_B7_BWset | PCG-34 | Nokia Networks |  | Rel-13 | RP-67 |  |
| 782 | 260.1 | Core part: Additional bandwidth combination set for LTE Advanced inter-band Carrier Aggregation of Band 5 and Band 7 | 66d? | 2015-03-16 A | 2015-06-15 A | 100% |  |  | finish no earlier than 2015-06-15 | R4 | 528h | 528h | LTE_CA_B5_B7_BWset-Core | PCG-34 | Nokia Networks |  | Rel-13 | RP-67 | RP-150536 |
| 783 | 260.2 | Perf. part: Additional bandwidth combination set for LTE Advanced inter-band Carrier Aggregation of Band 5 and Band 7 | 66d? | 2015-03-16 A | 2015-06-15 A | 100% |  |  | finish no earlier than 2015-06-15 | R4 | 528h | 528h | LTE_CA_B5_B7_BWset-Perf | PCG-34 | Nokia Networks |  | Rel-13 | RP-67 | RP-150536 |

Notes:
- 760: 1st Apr 15: Compl:0%->10% 1st Apr 15: CD:Mon 15/06/15->Tue 15/03/16 1st Apr 15: Stat Rep: ->RP-150061 03/07/15: Compl:10%->20% 03/07/15: Stat Rep: RP-150061->RP-150584 29/09/15: Compl:20%->30% 29/09/15: Stat Rep: RP-150584->RP-151171 ......
- 762: 03/07/15: Compl:0%->25% 03/07/15: Stat Rep: ->RP-150744 29/09/15: Compl:25%->55% 29/09/15: Stat Rep: RP-150744->RP-151330 1/1/16: Compl:55%->100%...
- 763: 03/07/15: Stat Rep: ->RP-150744 29/09/15: Stat Rep: RP-150744->RP-151330 ; 1/1/16: WID: RP-150490->RP-15173922/3/16: Compl:0%->50%;...
- 765: 03/07/15: Compl:0%->40% 03/07/15: WID: RP-150491->RP-150611 03/07/15: Stat Rep: ->RP-150610 29/09/15: Compl:40%->55% 29/09/15: WID: RP-150611->RP-151206 29/09/15: Stat Rep: RP-150610->RP-151190 ...
- 766: 03/07/15: WID: RP-150491->RP-150611 03/07/15: Stat Rep: ->RP-150610 29/09/15: WID: RP-150611->RP-151206 29/09/15: Stat Rep: RP-150610->RP-1511901/1/16:...22/3/16: Compl:70%->75%...; 26/9/16: Compl:90%->100%; 26/9/16: WID: RP-152181...
- 768: 03/07/15: Compl:0%->30% 03/07/15: WID: RP-150510->RP-151114 03/07/15: Stat Rep: ->RP-151081, 07/08/15: impacted TSs added 29/09/15: Compl:30%->35% 29/09/15: Stat Rep: RP-151081->RP-151563...;... / Impacted TSs and TRs: 36.461, 36.462, 36.463, 36.464, 36.465, 36.622, 36.623, 36.624, 36.625, 36.360
- 769: 03/07/15: WID: RP-150510->RP-151114 03/07/15: Stat Rep: ->RP-151081 29/09/15: Stat Rep: RP-151081->RP-1515631/1/16: Compl:0%->10% ; ...; 22/3/16: Compl:10%->100%; ...
- 770: testing REL-13 LTE_WLAN_radio-Core; 1/7/16: Compl:0%->5%; ...
- 772: 03/07/15: Compl:0%->45% 03/07/15: Stat Rep: ->RP-150842 29/09/15: Compl:45%->80% 29/09/15: CD:Tue 15/09/15->Tue 15/12/15 29/09/15: Stat Rep: RP-150842->RP-1512891/1/16: Compl:80%->100%
- 774: 03/07/15: Compl:0%->25% 03/07/15: Stat Rep: ->RP-150803 29/09/15: Compl:25%->50% 29/09/15: Stat Rep: RP-150803->RP-151265; 1/1/16: Compl:50%->100%
- 775: 03/07/15: Compl:0%->15% 03/07/15: CD:Mon 02/10/00->Wed 15/06/16 03/07/15: Stat Rep: ->RP-150803 29/09/15: Compl:15%->35% 29/09/15: Stat Rep: RP-150803->RP-151265...22/3/16: Compl:60%-...;...26/9/16: Compl:90%->100%
- 776: ; 22/3/16: Compl:0%->10%...; 1/7/16: Compl:10%->25%; ;...; 26/9/16: ...
- 778: 03/07/15: Compl:0%->20% 03/07/15: WID: RP-150428->RP-150800 03/07/15: Stat Rep: ->RP-150796 29/09/15: Compl:20%->50% 29/09/15: Stat Rep: RP-150796->RP-151343 ...
- 779: 03/07/15: WID: RP-150428->RP-150800 03/07/15: Stat Rep: ->RP-150796 29/09/15: Stat Rep: RP-150796->RP-151343;
- 780: ; 22/3/16: Compl:0%->10%...1/7/16: Compl:10%->65%26/9/16: Comp...
- 782: 03/07/15: Compl:0%->100% 03/07/15: WID: RP-150171->RP-150602 03/07/15: Stat Rep: ->RP-150536
- 783: 03/07/15: Compl:0%->100% 03/07/15: WID: RP-150171->RP-150602 03/07/15: Stat Rep: ->RP-150536

| ID | WBS | Task | Duration | Start | Finish | Complete | Constraint | Resources | Work | Actual work | Acronym | PCG approved | WI rapporteur name | Release | TSG approved | Status Report | WI rapporteur e-mail | TSG stopped |
| --- | --- | --- | --- | --- | --- | --- | --- | --- | --- | --- | --- | --- | --- | --- | --- | --- | --- | --- |
| 784 | 261 | **Additional bandwidth combination set for LTE Advanced inter-band Carrier Aggregation of Band 3 and Band 5** | 66d? | 2015-03-16 A | 2015-06-15 A | 100% |  | R4 | 1584h | 1584h | LTE_CA_B3_B5_BWset | PCG-34 | Samsung | Rel-13 | RP-67 |  |  |  |
| 785 | 261.1 | Core part: Additional bandwidth combination set for LTE Advanced inter-band Carrier Aggregation of Band 3 and Band 5 | 66d? | 2015-03-16 A | 2015-06-15 A | 100% | finish no earlier than 2015-06-15 | R4 | 528h | 528h | LTE_CA_B3_B5_BWset-Core | PCG-34 | Samsung | Rel-13 | RP-67 | RP-150536 |  |  |
| 786 | 261.2 | Perf. part: Additional bandwidth combination set for LTE Advanced inter-band Carrier Aggregation of Band 3 and Band 5 | 66d? | 2015-03-16 A | 2015-06-15 A | 100% | finish no earlier than 2015-06-15 | R4 | 528h | 528h | LTE_CA_B3_B5_BWset-Perf | PCG-34 | Samsung | Rel-13 | RP-67 | RP-150536 |  |  |
| 787 | 262 | **Multiflow Enhancements for UTRA** | 132d? | 2015-03-16 A | 2015-09-15 A | 100% |  | R2 | 2112h | 2112h | HSDPA_MFTX_enh | PCG-34 | Nokia | Rel-13 | RP-67 |  | alexander.sayenko@nokia.com |  |
| 788 | 262.1 | Core part: Multiflow Enhancements for UTRA | 132d? | 2015-03-16 A | 2015-09-15 A | 100% | finish no earlier than 2015-09-15 | R2 | 1056h | 1056h | HSDPA_MFTX_enh-Core | PCG-34 | Nokia | Rel-13 | RP-67 | RP-151302 | alexander.sayenko@nokia.com |  |
| 789 | 263 | **Message interworking during PS to CS SRVCC** | 68d? | 2015-06-15 A | 2015-09-16 A | 100% |  | C1 | 1632h | 1632h | mSRVCC | PCG-35 | Ivo Sedlacek, Ericsson | Rel-13 | CP-68 |  | ivo.sedlacek@ericsson.com |  |
| 790 | 263.1 | CT1 aspects of Message interworking during PS to CS SRVCC | 68d? | 2015-06-15 A | 2015-09-16 A | 100% | start no earlier than 2015-06-15 | C1 | 544h | 544h | mSRVCC | PCG-35 | Ivo Sedlacek, Ericsson | Rel-13 | CP-68 |  | ivo.sedlacek@ericsson.com |  |
| 791 | 263.2 | CT3 aspects of Message interworking during PS to CS SRVCC | 68d? | 2015-06-15 A | 2015-09-16 A | 100% | finish no earlier than 2015-09-16 | C3 | 544h | 544h | mSRVCC | PCG-35 | Ivo Sedlacek, Ericsson | Rel-13 | CP-68 |  | ivo.sedlacek@ericsson.com |  |
| 792 | 264 | **Support of Emergency services over WLAN – phase 1** | 192d? | 2015-06-18 A | 2016-03-11 A | 100% |  | S2 | 5896h | 5896h | SEW1 | PCG-35 | Laurent thiebaut | Rel-13 | SP-68 |  | Laurent.thiebaut@alcatel-lucent.com |  |
| 793 | 264.1 | Stage 2 of Support of Emergency services over WLAN - phase 1 | 65d? | 2015-06-18 A | 2015-09-16 A | 100% | finish no earlier than 2015-09-16 | S2 | 520h | 520h | SEW1 | PCG-35 | Laurent thiebaut | Rel-13 | SP-68 |  | Laurent.thiebaut@alcatel-lucent.com |  |
| 794 | 264.2 | **CT aspects of Support of Emergency services over WLAN – phase 1** | 135d? | 2015-09-07 A | 2016-03-11 A | 100% |  | ct | 3840h | 3840h | SEW1-CT | PCG-35 | Alcatel-Lucent, Jennifer Liu (CT1) | Rel-13 | CP-69 |  | jennifer.liu@alcatel-lucent.com |  |
| 795 | 264.2.1 | CT1 aspects of Support of Emergency services over WLAN – phase 1 | 135d? | 2015-09-07 A | 2016-03-11 A | 100% | finish no earlier than 2016-03-11 | C1 | 1080h | 1080h | SEW1-CT | PCG-35 | Alcatel-Lucent, Jennifer Liu (CT1) | Rel-13 | CP-69 |  | jennifer.liu@alcatel-lucent.com |  |
| 796 | 264.2.2 | CT3 aspects of Support of Emergency services over WLAN – phase 1 | 70d? | 2015-09-07 A | 2015-12-11 A | 100% | finish no earlier than 2015-12-11 | C3 | 560h | 560h | SEW1-CT | PCG-35 | Alcatel-Lucent, Jennifer Liu (CT1) | Rel-13 | CP-69 |  | jennifer.liu@alcatel-lucent.com |  |
| 797 | 264.2.3 | CT4 aspects of Support of Emergency services over WLAN – phase 1 | 70d? | 2015-09-07 A | 2015-12-11 A | 100% | finish no earlier than 2015-12-11 | C4 | 560h | 560h | SEW1-CT | PCG-35 | Alcatel-Lucent, Jennifer Liu (CT1) | Rel-13 | CP-69 |  | jennifer.liu@alcatel-lucent.com |  |
| 798 | 264.2.4 | CT6 aspects of Support of Emergency services over WLAN – phase 1 | 70d? | 2015-09-07 A | 2015-12-11 A | 100% | finish no earlier than 2015-12-11 | C6 | 560h | 560h | SEW1-CT | PCG-35 | Alcatel-Lucent, Jennifer Liu (CT1) | Rel-13 | CP-69 |  | jennifer.liu@alcatel-lucent.com |  |
| 799 | 265 | **MBMS Enhancements** | 264d? | 2014-12-03 A | 2015-12-07 A | 100% |  | S2 | 4320h | 4320h | MBMS_enh | PCG-34 | Nokia Networks, Curt Wong | Rel-13 | SP-66 |  |  |  |
| 800 | 265.1 | MBMS Enhancements TR Phase | 204d? | 2014-12-03 A | 2015-09-14 A | 100% | finish no earlier than 2015-09-14 | S2 | 1632h | 1632h | FS_MBMS_enh_TR | PCG-34 | Nokia Networks, Curt Wong | Rel-13 | SP-66 |  |  |  |
| 801 | 265.2 | MBMS Enhancements | 28d? | 2015-08-10 A | 2015-09-16 A | 100% | finish no earlier than 2015-09-16 | S2 | 224h | 224h | MBMS_enh_St2 | PCG-35 | Nokia Networks, Curt Wong | Rel-13 | CP-69 |  |  |  |
| 802 | 265.3 | **CT aspects of MBMS Enhancements** | 21d? | 2015-11-09 A | 2015-12-07 A | 100% |  | C3 | 344h | 344h | MBMS_enh-CT | PCG-36 | Nokia Networks, Thomas Belling | Rel-13 | CP-70 |  |  |  |
| 803 | 265.3.1 | CT3 aspects of MBMS enhancements | 21d? | 2015-11-09 A | 2015-12-07 A | 100% | start no earlier than 2015-11-09 | C3 | 168h | 168h | MBMS_enh-CT | PCG-36 | Nokia Networks, Thomas Belling | Rel-13 | CP-70 |  |  |  |
| 804 | 265.3.2 | CT4 aspects of MBMS enhancements | 21d? | 2015-11-09 A | 2015-12-07 A | 100% | finish no earlier than 2015-12-07 | C4 | 168h | 168h | MBMS_enh-CT | PCG-36 | Nokia Networks, Thomas Belling | Rel-13 | CP-70 |  |  |  |
| 805 | 265.4 | Deleted (not approved) - MBMS Enhancements - Stage 2 | 1d? | 2015-03-13 A | 2015-03-13 A | 100% | finish no earlier than 2015-03-13 | S2 | 8h | 8h | MBMS_enh_TS | PCG-34 | Rainer Liebhart | Rel-13 | SP-66 |  |  | SP-69 |
| 806 | 266 | **EPC Signalling Improvements for race scenarios** | 135d? | 2015-09-07 A | 2016-03-11 A | 100% |  | C4 | 2760h | 2760h | EPC_SIG_RACE | PCG-35 | Huawei, Peter Schmitt | Rel-13 | CP-69 |  | Huawei, Peter Schmitt, Peter.Schmitt@HUAWEI.COM |  |
| 807 | 266.1 | CT3 aspects for EPC Signalling Improvements for race scenarios | 135d? | 2015-09-07 A | 2016-03-11 A | 100% | finish no earlier than 2016-03-11 | C3 | 1080h | 1080h | EPC_SIG_RACE | PCG-35 | Huawei, Peter Schmitt | Rel-13 | CP-69 |  | Huawei, Peter Schmitt, Peter.Schmitt@HUAWEI.COM |  |
| 808 | 266.2 | CT4 aspects for EPC Signalling Improvements for race scenarios | 75d? | 2015-09-07 A | 2015-12-18 A | 100% | finish no earlier than 2015-12-18 | C4 | 600h | 600h | EPC_SIG_RACE | PCG-35 | Huawei, Peter Schmitt | Rel-13 | CP-69 |  | Huawei, Peter Schmitt, Peter.Schmitt@HUAWEI.COM |  |

Notes:
- 785: 03/07/15: Compl:0%->100% 03/07/15: Stat Rep: ->RP-150536
- 786: 03/07/15: Compl:0%->100% 03/07/15: Stat Rep: ->RP-150536
- 788: 03/07/15: Compl:0%->80% 03/07/15: WID: RP-150288->RP-151021 03/07/15: Stat Rep: ->RP-150827 29/09/15: Compl:80%->100% 29/09/15: Stat Rep: RP-150827->RP-151302
- 790: 07/09/15: 0%->25; 7/12/15: 25%->100 / Impacted TSs and TRs: 24.237, 24.292
- 791: 07/09/15: 0%->70; 7/12/15: 70%->100 / Impacted TSs and TRs: 29.292
- 792: 07/09/15: 0%->100 / Impacted TSs and TRs: TS 23.402, TS 23.167, TS 23.271, TS 23.203, TS 23.228
- 793: 07/09/15: 0%->100 / Impacted TSs and TRs: TS 23.402, TS 23.167, TS 23.271, TS 23.203, TS 23.228
- 795: 7/12/15: 60%->95. FCD -> 03/16, ES in CP-150729; 7/3/16: 95%->100 / Impacted TSs and TRs: 24.302, 24.229
- 796: 7/12/15: 0%->100 / Impacted TSs and TRs: 29.212, 29.214
- 797: 7/12/15: 0%->100 / Impacted TSs and TRs: 23.003, 23.008, 29.273, 29.274
- 798: 7/3/16: 0%->100 / Impacted TSs and TRs: 31.102
- 799: . 3/3: WID tdoc number updated; 14/09/15: WID:SP-140883->SP-150516
- 800: Acronym changed from "MBMS_enh-SA2TR". Mar15: 0->10%; June2015: Compl:10%->50; 07/09/15: 50%->70. acronym changed from "MBMS_enh" to "MBMS_enh_TR"; 07/09/15: 70%->100; 14/09/15: WID:SP-140883->SP-150516 / Impacted TSs and TRs: TR 23.8xy
- 801: SA#69: no normative work, moved as Study only. 14/10/15: corrected: was mentioned as FS_ / Impacted TSs and TRs: TS 23.246, TS 23.468
- 803: 8/12/15: 0%->100 / Impacted TSs and TRs: 29.061, 29.468
- 804: Impacted TSs and TRs: 29.274, 23.008, 29.230
- 805: Commented during RAN#67 that it should have never beeen here. 07/09/15: "undeleted", acronym changed from "MBMS_enh-del" to "MBMS_enh_TS". 14/10/15: SP-140883 was never approved so this line should have never appeared in the WP. / Impacted TSs and TRs: TS 23.246, TS 23.468
- 807: 7/12/15: FCD -> 03/16, ES in CP-150861; 8/12/15: 0%->100 / Impacted TSs and TRs: 29.212, 29.213
- 808: 7/12/15: 95%->100 / Impacted TSs and TRs: 29.274, 29.274, 29.275, 29.282, 29.273, 29.230, 23.008, 29.273

| ID | WBS | Task | Duration | Start | Finish | Complete | Remaining | Total slack | Constraint | Resources | Work | Actual work | Acronym | PCG approved | WI rapporteur name | WI rapporteur e-mail | Release | TSG approved | Status Report |
| --- | --- | --- | --- | --- | --- | --- | --- | --- | --- | --- | --- | --- | --- | --- | --- | --- | --- | --- | --- |
| 809 | 267 | **Diameter Message Priority** | 164d? | 2015-11-02 A | 2016-06-16 A | 100% |  |  |  | C4 | 3736h | 3736h | DiaPri | PCG-36 | Alcatel-Lucent, Jean-Jacques Trottin | jean-jacques.trottin@alcatel-lucent.com | Rel-13 | CP-70 |  |
| 810 | 267.1 | CT3 aspects of DiaPri | 95d? | 2015-11-02 A | 2016-03-11 A | 100% |  |  | finish no earlier than 2016-03-11 | C3 | 760h | 760h | DiaPri | PCG-36 | Intel, Vivek Gupta |  | Rel-13 | CP-70 |  |
| 811 | 267.2 | CT4 aspects of DiaPri | 95d? | 2015-11-02 A | 2016-03-11 A | 100% |  |  | finish no earlier than 2016-03-11 | C4 | 760h | 760h | DiaPri | PCG-36 | Alcatel-Lucent, Jean-Jacques Trottin | jean-jacques.trottin@alcatel-lucent.com | Rel-13 | CP-70 |  |
| 812 | 267.3 | (IETF) Diameter Routing Message Priority (draft-ietf-dime- | 138d? | 2015-12-08 A | 2016-06-16 A | 100% |  |  | finish no earlier than 2016-06-16 | C4-IETF | 1104h | 1104h | DiaPri | PCG-36 | Alcatel-Lucent, Jean-Jacques Trottin | jean-jacques.trottin@alcatel-lucent.com | Rel-13 | TSG#71 |  |
| 813 | 268 | **Downlink TPC Enhancements for UMTS** | 197d? | 2015-06-15 A | 2016-03-15 A | 100% |  |  |  | R1 | 4208h | 4208h | UTRA_EDL_TPC | PCG-35 | Huawei |  | Rel-13 | TSG-68 |  |
| 814 | 268.1 | Core part: Downlink TPC Enhancements for UMTS | 44d? | 2015-10-15 A | 2015-12-15 A | 100% |  |  | finish no earlier than 2015-12-15 | R1; R2; R3 | 1056h | 1056h | UTRA_EDL_TPC-Core | PCG-35 | Huawei |  | Rel-13 | TSG-68 | RP-151564 |
| 815 | 268.2 | Perf. part: Downlink TPC Enhancements for UMTS | 197d? | 2015-06-15 A | 2016-03-15 A | 100% |  |  | finish no earlier than 2016-03-15 | R4 | 1576h | 1576h | UTRA_EDL_TPC-Perf | PCG-35 | Huawei |  | Rel-13 | TSG-68 | RP-151564 |
| 816 | 269 | **Licensed-Assisted Access using LTE** | 395d? | 2015-06-15 A | 2016-12-15 | 67% | 131.78d? | 347d |  | R1 | 9488h | 4919.91h | LTE_LAA | PCG-35 | Ericsson |  | Rel-13 | TSG-68 |  |
| 817 | 269.1 | Core part: Licensed-Assisted Access using LTE | 132d? | 2015-06-15 A | 2015-12-15 A | 100% |  |  | finish no earlier than 2015-12-15 | R1 | 1056h | 1056h | LTE_LAA-Core | PCG-35 | Ericsson |  | Rel-13 | TSG-68 | RP-151390 |
| 818 | 269.2 | Perf. part: Licensed-Assisted Access using LTE | 395d? | 2015-06-15 A | 2016-12-15 | 90% | 39.5d? | 347d | finish no earlier than 2016-12-15 | R4 | 3160h | 2844h | LTE_LAA-Perf | PCG-35 | Ericsson |  | Rel-13 | TSG-68 | RP-151390 |
| 819 | 269.3 | UE Conformance Test Aspects - Licensed-Assisted Access using LTE | 264d? | 2015-12-15 A | 2016-12-15 | 15% | 224.4d? | 347d | finish no earlier than 2016-12-15 | R5 | 2112h | 316.8h | LTE_LAA-UEConTest | PCG-36 | Motorola Mobility |  | Rel-13 | RP-70 |  |
| 820 | 270 | **Elevation Beamforming/Full-Dimension (FD) MIMO for LTE** | 330d? | 2015-06-15 A | 2016-09-15 | 99% | 0d? | 0d |  | R1 | 6336h | 5379.73h | LTE_EBF_FDMIMO | PCG-35 | Samsung |  | Rel-13 | TSG-68 |  |
| 821 | 270.1 | Core part: Elevation Beamforming/Full-Dimension (FD) MIMO for LTE | 132d? | 2015-06-15 A | 2015-12-15 A | 100% |  |  | finish no earlier than 2015-12-15 | R1 | 1056h | 1056h | LTE_EBF_FDMIMO-Core | PCG-35 | Samsung |  | Rel-13 | TSG-68 | RP-151565 |
| 822 | 270.2 | Perf. part: Elevation Beamforming/Full-Dimension (FD) MIMO for LTE | 330d? | 2015-06-15 A | 2016-09-15 A | 100% |  |  | finish no earlier than 2016-09-15 | R4 | 2640h | 2640h | LTE_EBF_FDMIMO-Perf | PCG-35 | Samsung |  | Rel-13 | TSG-68 | RP-151565 |
| 823 | 271 | **L2/L3 Downlink enhancements for UMTS** | 132d? | 2015-06-15 A | 2015-12-15 A | 100% |  |  |  | R2 | 2112h | 2112h | UTRA_EDL_L23 | PCG-35 | Huawei |  | Rel-13 | TSG-68 |  |
| 824 | 271.1 | Core part: L2/L3 Downlink enhancements for UMTS | 132d? | 2015-06-15 A | 2015-12-15 A | 100% |  |  | finish no earlier than 2015-12-15 | R2 | 1056h | 1056h | UTRA_EDL_L23-Core | PCG-35 | Huawei |  | Rel-13 | TSG-68 | RP-151238 |
| 825 | 272 | **Support of single-cell point-to-multipoint transmission in LTE** | 330d? | 2015-06-15 A | 2016-09-15 | 99% | 0d? | 0d |  | R2 | 5824h | 4240h | LTE_SC_PTM | PCG-35 | Huawei |  | Rel-13 | TSG-68 |  |
| 826 | 272.1 | Core part: Support of single-cell point-to-multipoint transmission in LTE | 132d? | 2015-06-15 A | 2015-12-15 A | 100% |  |  | finish no earlier than 2015-12-15 | R2 | 1056h | 1056h | LTE_SC_PTM-Core | PCG-35 | Huawei |  | Rel-13 | TSG-68 | RP-151237 |
| 827 | 272.2 | Perf. part: Support of single-cell point-to-multipoint transmission in LTE | 132d? | 2015-06-15 A | 2015-12-15 A | 100% |  |  | finish no earlier than 2016-06-15 | R4 | 1056h | 1056h | LTE_SC_PTM-Perf | PCG-35 | Huawei |  | Rel-13 | TSG-68 | RP-151237 |
| 828 | 272.3 | UE Conformance Test Aspects - Support of single-cell point-to-multipoint transmission in LTE | 134d? | 2016-03-15 A | 2016-09-15 A | 100% |  |  | finish no earlier than 2016-12-15 | R5 | 1072h | 1072h | LTE_SC_PTM-UEConTest | PCG-36 | Huawei |  | Rel-13 | TSG#71 |  |
| 829 | 273 | **Extension of Dual Connectivity in E-UTRAN** | 132d? | 2015-06-15 A | 2015-12-15 A | 100% |  |  |  | R3 | 2112h | 2112h | LTE_dualC_ext | PCG-35 | Samsung |  | Rel-13 | TSG-68 |  |
| 830 | 273.1 | Core part: Extension of Dual Connectivity in E-UTRAN | 132d? | 2015-06-15 A | 2015-12-15 A | 100% |  |  | finish no earlier than 2015-12-15 | R3 | 1056h | 1056h | LTE_dualC_ext-Core | PCG-35 | Samsung |  | Rel-13 | TSG-68 | RP-151214 |
| 831 | 274 | **RAN sharing enhancements for UMTS** | 132d? | 2015-06-15 A | 2015-12-15 A | 100% |  |  |  | R3 | 2112h | 2112h | RSE_UTRA_GUSH | PCG-35 | Huawei |  | Rel-13 | TSG-68 |  |
| 832 | 274.1 | Core part: RAN sharing enhancements for UMTS | 132d? | 2015-06-15 A | 2015-12-15 A | 100% |  |  | finish no earlier than 2015-12-15 | R3 | 1056h | 1056h | RSE_UTRA_GUSH-Core | PCG-35 | Huawei |  | Rel-13 | TSG-68 | RP-151239 |

Notes:
- 810: ES in CP-150645; 7/3/16: 65%->100 / Impacted TSs and TRs: 29.153, 29.154, 29.201, 29.212, 29.213, 29.214, 29.215, 29.217, 29.219
- 811: ES in CP-150622; 7/3/16: 70%->100 / Impacted TSs and TRs: 29.228, 29.229, 29.272, 29.273, 29.328, 29.329, 29.336, 29.337, 29.338, 29.344, 29.345
- 812: 02/2016: publication requested; 2/12/16: 85%->100 / Impacted TSs and TRs: 29.227, 29.272, 29.273, 29.229
- 813: follow-up WI of REL-13 SI FS_UTRA_EDL; TPC = Transmit Power Control
- 814: follow-up WI of REL-13 SI FS_UTRA_EDL; TPC = Transmit Power Control 29/09/15: Compl:0%->35% 29/09/15: Stat Rep: -->RP-1515641/1/16: Compl:35%->100%1/1/16: WID: ...
- 815: follow-up WI of REL-13 SI FS_UTRA_EDL; TPC = Transmit Power Control 29/09/15: Stat Rep: -->RP-151564; 1/1/16: Compl:0%->80%; 1/1/16: WID: RP-151044->RP-151880...
- 816: follow-up WI of REL-13 SI FS_LTE_LAA
- 817: follow-up WI of REL-13 SI FS_LTE_LAA 29/09/15: Compl:0%->25% 29/09/15: Stat Rep: -->RP-1513901/1/16: Compl:25%->100%
- 818: follow-up WI of REL-13 SI FS_LTE_LAA 29/09/15: Stat Rep: -->RP-15139022/3/16: Compl:0%->33%; 1/7/16: Compl:3...; 26/9/16: Compl:50%->90%
- 819: ; 22/3/16: Compl:0%->5%1/7/16: Compl:5%->8%26/9/16: Compl:8%->15%
- 820: follow-up WI of REL-13 SI FS_LTE_EBF_FDMIMO
- 821: follow-up WI of REL-13 SI FS_LTE_EBF_FDMIMO 29/09/15: Compl:0%->25% 29/09/15: Stat Rep: -->RP-151565 1/1/16: Compl:25%->100%
- 822: follow-up WI of REL-13 SI FS_LTE_EBF_FDMIMO 29/09/15: Stat Rep: -->RP-151565 ; 1/1/16: Compl:0%->5%; 22/3/16: Compl:5%->35%;...26/9/16: Compl:70%->100%
- 823: no Perf. part; follow-up of Rel-13 SI FS_UTRA_EDL
- 824: no Perf. part; follow-up of Rel-13 SI FS_UTRA_EDL 29/09/15: Compl:0%->35% 29/09/15: WID: RP-151043->RP-151249 29/09/15: Stat Rep: -->RP-1512381/1/16: Compl:35%->100% ;
- 825: follow-up WI of REL-13 SI FS_LTE_SC_PTM
- 826: follow-up WI of REL-13 SI FS_LTE_SC_PTM 29/09/15: Compl:0%->30% 29/09/15: Stat Rep: -->RP-151237 1/1/16: Compl:30%->100%
- 827: follow-up WI of REL-13 SI FS_LTE_SC_PTM 29/09/15: Stat Rep: -->RP-1512371/1/16: Compl:0%->100% ...
- 828: testing REL-13 LTE_SC_PTM-Core1/7/16: Compl:0%->40%26/9/16...
- 829: no Perf. part; follow-up WI of REL-13 SI FS_LTE_dualC_ext;
- 830: no Perf. part; follow-up WI of REL-13 SI FS_LTE_dualC_ext; 29/09/15: Compl:0%->30% 29/09/15: Stat Rep: -->RP-151214; 1/1/16: Compl:3...
- 831: no Perf. part; follow-up WI for Rel-13 SI FS_RSE_UTRA_GUSH; note: GUSH was a REL-13 SA1 WI; there is an ongoing REL-13 WI for LTE: RSE-RAN_LTE;
- 832: no Perf. part; follow-up WI for Rel-13 SI FS_RSE_UTRA_GUSH; note: GUSH was a REL-13 SA1 WI; there is an ongoing REL-13 WI for LTE: RSE-RAN_LTE; 29/09/15: Compl:0%->30% 29/09/15: WID: RP-151086->RP-151251 29/09/15: Stat Rep: -->RP-151239 ; ...

| ID | WBS | Task | Duration | Start | Finish | Complete | Remaining | Total slack | Constraint | Resources | Work | Actual work | Acronym | PCG approved | WI rapporteur name | Release | TSG approved | Status Report | Impacted TSs and TRs | WI rapporteur e-mail |
| --- | --- | --- | --- | --- | --- | --- | --- | --- | --- | --- | --- | --- | --- | --- | --- | --- | --- | --- | --- | --- |
| 833 | 275 | **Interference mitigation for downlink control channels of LTE** | 263d? | 2015-06-15 A | 2016-06-15 A | 100% |  |  |  | R4 | 4208h | 4208h | LTE_IM_DLCCH | PCG-35 | Intel | Rel-13 | TSG-68 |  |  |  |
| 834 | 275.1 | Perf. part: Interference mitigation for downlink control channels of LTE | 263d? | 2015-06-15 A | 2016-06-15 A | 100% |  |  | finish no earlier than 2016-06-15 | R4 | 2104h | 2104h | LTE_IM_DLCCH-Perf | PCG-35 | Intel | Rel-13 | TSG-68 | RP-151301 |  |  |
| 835 | 276 | **Network-Assisted Interference Cancellation and Suppression for UMTS** | 66d? | 2015-09-15 A | 2015-12-15 A | 100% |  |  |  | R1 | 1056h | 1056h | UTRA_NAICS | PCG-35 | Huawei | Rel-13 | RP-69 |  |  |  |
| 836 | 276.1 | Core part: Network-Assisted Interference Cancellation and Suppression for UMTS | 66d? | 2015-09-15 A | 2015-12-15 A | 100% |  |  | finish no earlier than 2015-12-15 | R1 | 528h | 528h | UTRA_NAICS-Core | PCG-35 | Huawei | Rel-13 | RP-69 |  |  |  |
| 837 | 277 | **Dual Carrier HSUPA Enhancements for UTRAN CS** | 66d? | 2015-09-15 A | 2015-12-15 A | 100% |  |  |  | R2 | 1056h | 1056h | DC_HSUPA_CS | PCG-35 | Nokia Networks | Rel-13 | RP-69 |  |  |  |
| 838 | 277.1 | Core part: Dual Carrier HSUPA Enhancements for UTRAN CS | 66d? | 2015-09-15 A | 2015-12-15 A | 100% |  |  | finish no earlier than 2015-12-15 | R2 | 528h | 528h | DC_HSUPA_CS-Core | PCG-35 | Nokia Networks | Rel-13 | RP-69 |  |  |  |
| 839 | 278 | **Further Enhancements of Minimization of Drive Tests for E-UTRAN** | 524d? | 2015-03-16 A | 2017-03-15 | 53% | 248.28d? | 283d |  | R2 | 6304h | 2190.8h | LTE_eMDT2 | PCG-35 | CMCC | Rel-13 | RP-69 |  |  |  |
| 840 | 278.1 | Study on further Enhancements of Minimization of Drive Tests for E-UTRAN | 132d? | 2015-03-16 A | 2015-09-15 A | 100% |  |  | finish no earlier than 2015-09-15 | R2 | 1056h | 1056h | FS_LTE_eMDT2 | PCG-34 | CMCC | Rel-13 | RP-67 | RP-151181 | 36.880 |  |
| 841 | 278.2 | Core part: Further Enhancements of Minimization of Drive Tests for E-UTRAN | 66d? | 2015-09-15 A | 2015-12-15 A | 100% |  |  | finish no earlier than 2015-12-15 | R2 | 528h | 528h | LTE_eMDT2-Core | PCG-35 | CMCC | Rel-13 | RP-69 |  |  |  |
| 842 | 278.3 | UE Conformance Test Aspects – Further Enhancements of Minimization of Drive Tests for E-UTRAN | 197d? | 2016-06-15 A | 2017-03-15 | 5% | 187.15d? | 283d | finish no earlier than 2017-03-15 | R5 | 1576h | 78.8h | LTE_eMDT2-UEConTest | PCG-37 | Intel | Rel-13 | TSG#72 |  |  |  |
| 843 | 279 | **LTE-WLAN RAN Level Integration supporting legacy WLAN** | 131d? | 2015-09-15 A | 2016-03-15 A | 100% |  |  |  | R2 | 2096h | 2096h | LTE_WLAN_radio_legacy | PCG-35 | Alcatel-Lucent | Rel-13 | RP-69 |  |  |  |
| 844 | 279.1 | Core part: LTE-WLAN RAN Level Integration supporting legacy WLAN | 131d? | 2015-09-15 A | 2016-03-15 A | 100% |  |  | finish no earlier than 2016-03-15 | R2 | 1048h | 1048h | LTE_WLAN_radio_legacy-Core | PCG-35 | Alcatel-Lucent | Rel-13 | RP-69 |  | 36.361 |  |
| 845 | 280 | **Indoor Positioning enhancements for UTRA and LTE** | 459d? | 2015-09-15 A | 2017-06-15 | 65% | 159.68d? | 217d |  | R2 | 8208h | 4534h | UTRA_LTE_iPos_enh | PCG-35 | NextNav | Rel-13 | RP-69 |  |  |  |
| 846 | 280.1 | Core part: Indoor Positioning enhancements for UTRA and LTE | 66d? | 2015-09-15 A | 2015-12-15 A | 100% |  |  | finish no earlier than 2015-12-15 | R2 | 528h | 528h | UTRA_LTE_iPos_enh-Core | PCG-35 | NextNav | Rel-13 | RP-69 |  |  |  |
| 847 | 280.2 | Perf. part: Indoor Positioning enhancements for UTRA and LTE | 197d? | 2015-09-15 A | 2016-06-15 A | 100% |  |  | finish no earlier than 2016-06-15 | R4 | 1576h | 1576h | UTRA_LTE_iPos_enh-Perf | PCG-35 | NextNav | Rel-13 | RP-69 |  | 37.171; 37.958 |  |
| 848 | 280.3 | **CT aspects of Indoor Positionning** | 41d? | 2015-10-12 A | 2015-12-07 A | 100% |  |  |  | C4 | 328h | 328h | UTRA_LTE_iPos_enh-CT | PCG-36 | Ericsson, Jesús de Gregorio | Rel-13 | SP-70 |  | 29.171, 29.172, 29.230, 29.002 | jesus.de.gregorio@ericsson.com |
| 849 | 280.3.1 | CT4 aspects of Indoor Positionning | 41d? | 2015-10-12 A | 2015-12-07 A | 100% |  |  | finish no earlier than 2015-12-07 | C4 | 328h | 328h | UTRA_LTE_iPos_enh-CT | PCG-36 | Ericsson, Jesús de Gregorio | Rel-13 | CP-70 |  | 29.171, 29.172, 29.230, 29.002 | jesus.de.gregorio@ericsson.com |
| 850 | 280.4 | UE Conformance Test Aspects – Indoor Positioning Enhancement Support for LTE and UMTS | 263d? | 2016-06-15 A | 2017-06-15 | 25% | 197.25d? | 217d | finish no earlier than 2017-06-15 | R5 | 2104h | 526h | UTRA_LTE_iPos_enh-UEConTest | PCG-37 | NextNav | Rel-13 | TSG#72 |  |  |  |
| 851 | 281 | **Power saving enhancements for UMTS** | 197d? | 2015-06-15 A | 2016-03-15 A | 100% |  |  |  | R2 | 3160h | 3160h | UTRA_SDATA_POWSAV | PCG-35 | Ericsson | Rel-13 | TSG-68 |  |  |  |
| 852 | 281.1 | Core part: Power saving enhancements for UMTS | 132d? | 2015-06-15 A | 2015-12-15 A | 100% |  |  | finish no earlier than 2015-12-15 | R2 | 1056h | 1056h | UTRA_SDATA_POWSAV-Core | PCG-35 | Ericsson | Rel-13 | TSG-68 | RP-151291 |  |  |
| 853 | 281.2 | Perf. Part: Power saving enhancements for UMTS | 66d? | 2015-12-15 A | 2016-03-15 A | 100% |  |  | finish no earlier than 2016-03-15 | R4 | 528h | 528h | UTRA_SDATA_POWSAV-Perf | PCG-36 | Ericsson | Rel-13 | RP-70 |  |  |  |
| 854 | 282 | **700MHz E-UTRA FDD Band for Arab Region** | 197d? | 2015-06-15 A | 2016-03-15 | 99% | 0d? | 0d |  | R4 | 4728h | 3246.81h | LTE_FDD_700_ARAB | PCG-35 | Etisalat | Rel-13 | TSG-68 |  |  |  |
| 855 | 282.1 | Core part: 700MHz E-UTRA FDD Band for Arab Region | 197d? | 2015-06-15 A | 2016-03-15 A | 100% |  |  | finish no earlier than 2016-03-15 | R4 | 1576h | 1576h | LTE_FDD_700_ARAB-Core | PCG-35 | Etisalat | Rel-13 | TSG-68 | RP-151207 | 36.893 |  |
| 856 | 282.2 | Perf. part: 700MHz E-UTRA FDD Band for Arab Region | 197d? | 2015-06-15 A | 2016-03-15 A | 100% |  |  | finish no earlier than 2016-03-15 | R4 | 1576h | 1576h | LTE_FDD_700_ARAB-Perf | PCG-35 | Etisalat | Rel-13 | TSG-68 | RP-151207 |  |  |

Notes:
- 833: only Perf. part, no Core part;
- 834: only Perf. part, no Core part; 29/09/15: CD:Tue 15/03/16->Wed 15/06/16 29/09/15: Stat Rep: -->RP-1513011/1/16: Compl:0%->40%22/3/16: Compl:40%->70%;...;...
- 835: no Perf. part; follow-up WI REL-13 RAN1 SI FS_UTRA_NAICS
- 836: no Perf. part; follow-up WI REL-13 RAN1 SI FS_UTRA_NAICS ; 1/1/16: Compl:0%->100% ; 1/1/16: WID: RP-151577->RP-151879
- 837: no Perf. part; compare REL-13 WI HSUPA_DB_MC
- 838: no Perf. part; compare REL-13 WI HSUPA_DB_MC 1/1/16: Compl:0%->100% 1/1/16: WID: RP-151607->RP-151780
- 839: no Perf. part; follow-up WI of REL-13 SI FS_LTE_eMDT2
- 840: 03/07/15: Compl:0%->70% 03/07/15: Stat Rep: -->RP-150806 29/09/15: Compl:70%->100% 29/09/15: Stat Rep: RP-150806->RP-151181
- 841: no Perf. part; follow-up WI of REL-13 SI FS_LTE_eMDT2; 1/1/16: Compl:0%->100%
- 842: tested REL-13 WI: LTE_eMDT2-Core26/9/16: Com...
- 843: no Perf. part; compare REL-13 WI LTE_WLAN_radio
- 844: no Perf. part; compare REL-13 WI LTE_WLAN_radio1/1/16: Compl:0%->95% ...22/3/16: Compl:95%->100%...; 28/7/16: 36.361 added;
- 845: follow-up WI of REL-13 SI FS_UTRA_LTE_iPos_enh
- 846: follow-up WI of REL-13 SI FS_UTRA_LTE_iPos_enh1/1/16: Compl:0%->100%1/1/16: WID: RP-151624->RP-15225122/3/16: WID: RP-152251->RP-160332
- 847: follow-up WI of REL-13 SI FS_UTRA_LTE_iPos_enh 1/1/16: Compl:0%->10% 1/1/16: WID: RP-151624->RP-152251; 22/3/16: Compl:10%->20%; 22/3/16: WID: RP-152251->RP-160332;...; 28/7/16: 37.171 added;; 28/7/16: 37.958 added;
- 849: 8/12/15: 0%->100
- 850: tested REL-13 WI: UTRA_LTE_iPos_enh-Core; 26/9/1...
- 851: no Perf. part; follow-up WI of SI FS_UTRA_SDATA
- 852: no Perf. part; follow-up WI of SI FS_UTRA_SDATA 29/09/15: Compl:0%->25% 29/09/15: CD:Tue 15/03/16->Tue 15/12/15 29/09/15: WID: RP-151092->RP-151292 29/09/15: Stat Rep: -->RP-151291 29/09/15: Release: Rel-14->Rel-13 ...
- 853: ; 22/3/16: Compl:0%->100%
- 854: REL-independent from REL-9
- 855: REL-independent from REL-9. Aug 15: TR numb added 29/09/15: Compl:0%->15% 29/09/15: CD:Tue 15/03/16->Tue 15/12/15 29/09/15: Stat Rep: -->RP-151207 29/09/15: Release: Rel-14->Rel-13;...
- 856: REL-independent from REL-9 29/09/15: CD:Tue 15/03/16->Tue 15/12/15 29/09/15: Stat Rep: -->RP-151207 29/09/15: Release: Rel-14->Rel-13 ...

| ID | WBS | Task | Duration | Start | Finish | Complete | Remaining | Baseline start | Baseline finish | Baseline duration | Total slack | Constraint | Resources | Work | Actual work | Acronym | PCG approved | WI rapporteur name | Release | TSG approved | Status Report | WI rapporteur e-mail | MCC resp | Special Focus Doc | Acronym_3GU_Export |
| --- | --- | --- | --- | --- | --- | --- | --- | --- | --- | --- | --- | --- | --- | --- | --- | --- | --- | --- | --- | --- | --- | --- | --- | --- | --- |
| 857 | 283 | **European 700 Supplemental Downlink band (738-758 MHz) in E-UTRA and LTE Carrier Aggregation (2DL/1UL) with Band 20** | 132d? | 2015-06-15 A | 2015-12-15 A | 100% |  |  |  |  |  |  | R4 | 3168h | 3168h | LTE_CA_700EU_B20 | PCG-35 | TeliaSonera | Rel-13 | TSG-68 |  |  |  |  |  |
| 858 | 283.1 | Core part: European 700 Supplemental Downlink band (738-758 MHz) in E-UTRA and LTE Carrier Aggregation (2DL/1UL) with Band 20 | 132d? | 2015-06-15 A | 2015-12-15 A | 100% |  |  |  |  |  | finish no earlier than 2015-12-15 | R4 | 1056h | 1056h | LTE_CA_700EU_B20-Core | PCG-35 | TeliaSonera | Rel-13 | TSG-68 | RP-151232 |  |  |  |  |
| 859 | 283.2 | Perf. part: European 700 Supplemental Downlink band (738-758 MHz) in E-UTRA and LTE Carrier Aggregation (2DL/1UL) with Band 20 | 132d? | 2015-06-15 A | 2015-12-15 A | 100% |  |  |  |  |  | finish no earlier than 2016-03-15 | R4 | 1056h | 1056h | LTE_CA_700EU_B20-Perf | PCG-35 | TeliaSonera | Rel-13 | TSG-68 | RP-151232 |  |  |  |  |
| 860 | 284 | Release 13 Features on Internet of Things (IoT) | 438.25d? | 2013-09-12 A | 2015-05-12 A | 100% |  | 2015-04-14 | 2015-12-25 | 183.25d? |  |  | SP; RP; CP; GP | 14024h | 14024h |  |  |  | Rel-13 |  |  |  |  |  |  |
| 861 | 285 | Service Requirements Maintenance for Machine-Type Communications (MTC) | 194d? | 2015-09-15 A | 2016-06-10 A | 100% |  | 2013-12-12 | 2014-12-10 | 261d? |  |  | S1 | 1552h | 1552h | SRMMTC | PCG-32 | KPN | Rel-13 | SP-62 |  | toon.norp@tno.nl | Alain | MTC, M2M | SRMMTC |
| 862 | 286 | **Cellular (Narrowband) Internet of Things** | 329d? | 2015-09-15 A | 2016-12-15 | 80% | 64.4d? |  |  |  | 347d |  |  | 14560h | 9081.98h | CIoT | PCG-36 |  | Rel-13 | CP-70 |  |  |  |  |  |
| 863 | 286.1 | Stage 2 of CIoT | 1d? | 2015-10-05 A | 2015-10-05 | 95% | 0.05d? |  |  |  | 661d | start no earlier than 2015-10-05 | S2 | 8h | 7.6h | CIoT | PCG-36 | Intel, Puneet Jain | Rel-13 | SP-70 |  | puneet.jain@intel.com |  |  |  |
| 864 | 286.2 | Security Aspects of CIoT (aka NB-IoT) | 160d? | 2015-11-02 A | 2016-06-10 A | 100% |  |  |  |  |  | finish no earlier than 2016-06-10 | S3 | 1280h | 1280h | CIoT | PCG-36 | Tim Evans, Vodafone | Rel-13 | SP-70 |  |  |  |  |  |
| 865 | 286.3 | **CT aspects of CIoT** | 138d? | 2015-12-07 A | 2016-06-15 | 99% | 0d? |  |  |  | 0d |  | C1 | 4976h | 4138h | CIoT-CT | PCG-36 | Intel, Vivek Gupta | Rel-13 | CP-70 |  | vivek.g.gupta@intel.com |  |  |  |
| 866 | 286.3.1 | CT1 aspects of CIoT | 70d? | 2015-12-07 A | 2016-03-11 A | 100% |  |  |  |  |  | finish no earlier than 2016-03-11 | C1 | 560h | 560h | CIoT-CT | PCG-36 | Intel, Vivek Gupta | Rel-13 | CP-70 |  | vivek.g.gupta@intel.com |  |  |  |
| 867 | 286.3.2 | CT3 aspects of CIoT | 138d? | 2015-12-07 A | 2016-06-15 A | 100% |  |  |  |  |  | finish no earlier than 2016-06-15 | C3 | 1104h | 1104h | CIoT-CT | PCG-36 | Intel, Vivek Gupta | Rel-13 | CP-70 |  | vivek.g.gupta@intel.com |  |  |  |
| 868 | 286.3.3 | CT4 aspects of CIoT | 138d? | 2015-12-07 A | 2016-06-15 A | 100% |  |  |  |  |  | finish no earlier than 2016-06-15 | C4 | 1104h | 1104h | CIoT-CT | PCG-36 | Intel, Vivek Gupta | Rel-13 | CP-70 |  | vivek.g.gupta@intel.com |  |  |  |
| 869 | 286.3.4 | CT6 aspects of CIoT | 138d? | 2015-12-07 A | 2016-06-15 A | 100% |  |  |  |  |  | finish no earlier than 2016-06-15 | C6 | 1104h | 1104h | CIoT-CT | PCG-36 | Intel, Vivek Gupta | Rel-13 | CP-70 |  | vivek.g.gupta@intel.com |  |  |  |
| 870 | 286.4 | Charging Aspects of CIoT | 23d? | 2016-05-12 A | 2016-06-13 A | 100% |  |  |  |  |  | finish no earlier than 2016-06-13 | S5 | 184h | 184h | CIoT-CH | PCG-37 | Gardella, Maryse (Nokia) | Rel-13 | TSG#72 |  | Gardella, Maryse (Nokia) |  |  |  |
| 871 | 286.5 | **RAN aspects of CIoT aka Narrowband Internet of Things (IOT)** | 329d? | 2015-09-15 A | 2016-12-15 | 77% | 75.35d? |  |  |  | 347d |  | R1 | 6320h | 2953.98h | NB_IOT | PCG-35 | Vodafone | Rel-13 | RP-69 |  |  |  |  |  |
| 872 | 286.5.1 | Core part: Narrowband Internet of Things (IOT) | 197d? | 2015-09-15 A | 2016-06-15 A | 100% |  |  |  |  |  | finish no earlier than 2016-06-15 | R1 | 1576h | 1576h | NB_IOT-Core | PCG-35 | Vodafone | Rel-13 | RP-69 |  |  |  |  |  |
| 873 | 286.5.2 | Perf. part: Narrowband Internet of Things (IOT) | 264d? | 2015-12-15 A | 2016-12-15 | 60% | 105.6d? |  |  |  | 347d | finish no earlier than 2016-12-15 | R4 | 2112h | 1267.2h | NB_IOT-Perf | PCG-36 | Vodafone | Rel-13 | RP-70 |  |  |  |  |  |
| 874 | 286.6 | Management for NB-IoT | 25d? | 2016-05-12 A | 2016-06-15 A | 100% |  |  |  |  |  | finish no earlier than 2016-06-15 | S5 | 200h | 200h | NB_IOT-OAM | PCG-37 | Huawei, Kai ZHANG | Rel-13 | TSG#72 |  | kai.zhangkai@huawei.com |  |  |  |
| 875 | 286.7 | UE Conformance Test Aspects - Narrowband Internet of Things (NB-IOT) | 199d? | 2016-03-15 A | 2016-12-15 | 20% | 159.2d? |  |  |  | 347d | finish no earlier than 2016-12-15 | R5 | 1592h | 318.4h | NB_IOT-UEConTest | PCG-36 | CMCC | Rel-13 | TSG#71 |  |  |  |  |  |
| 876 | 287 | **Extended Coverage GSM (EC-GSM) for support of Cellular Internet of Things** | 255.5d? | 2015-09-25 A | 2016-09-15 | 69% | 77.98d? |  |  |  | 412d |  | G1; G2 | 8864h | 4044.7h | CIoT_EC_GSM | PCG-35 | Marteen Sunberg, Ericsson | Rel-13 | RP-69 |  | Marteen.Sunberg@Ericsson.com |  |  |  |
| 877 | 287.1 | Extended Coverage GSM (EC-GSM) for support of Cellular Internet of Things Core part | 164.5d? | 2015-09-25 A | 2016-05-12 A | 100% |  |  |  |  |  | finish no earlier than 2016-05-12 | G1; G2 | 2632h | 2632h | CIoT_EC_GSM-Core | PCG-36 | Marteen Sunberg, Ericsson | Rel-13 | SP-70 |  | Marteen.Sunberg@Ericsson.com |  |  |  |
| 878 | 287.2 | Test for CIoT_EC_GSM | 132d? | 2015-11-11 | 2016-05-12 |  |  |  |  |  | 503d | start no earlier than 2015-11-11 | G3 | 1056h |  | CIoT_EC_GSM_GERAN3new | PCG-36 | Sierra Wireless S.A | Rel-13 | SP-70 |  | Marteen.Sunberg@Ericsson.com |  |  |  |
| 879 | 287.3 | Perf. Part: Extended Coverage GSM (EC-GSM) for support of Cellular Internet of Things | 68d? | 2016-06-15 A | 2016-09-15 A | 100% |  |  |  |  |  | finish no earlier than 2016-09-15 | R6 | 544h | 544h | CIoT_EC_GSM-Perf | PCG-37 | Ericsson | Rel-13 | TSG#72 |  |  |  |  |  |
| 880 | 287.4 | MS Conformance Test Aspects - Extended Coverage GSM (EC-GSM) for support of Cellular Internet of Things | 68d? | 2016-06-15 A | 2016-09-15 A | 100% |  |  |  |  |  | finish no earlier than 2016-09-15 | R5 | 544h | 544h | CIoT_EC_GSM-MSConTest | PCG-37 | Ericsson | Rel-13 | TSG#72 |  |  |  |  |  |

Notes:
- 857: introduction of new DL only band and 2DL/1UL CA with it
- 858: introduction of new DL only band and 2DL/1UL CA with it. Aug 15: TR numb added 29/09/15: Compl:0%->80% 29/09/15: CD:Tue 15/03/16->Tue 15/12/15 29/09/15: WID: RP-150861->RP-151228 29/09/15: Stat Rep: -->RP-151232 29/09/15: Release: Rel-14->Rel-13... / Impacted TSs and TRs: 36.895
- 859: introduction of new DL only band and 2DL/1UL CA with it 29/09/15: WID: RP-150861->RP-151228 29/09/15: Stat Rep: -->RP-151232 29/09/15: Release: Rel-14->Rel-13 ...
- 860: -
- 861: SP#65 completed. Linked to Rel-13 SEES, Rel-12 Support for Interworking with M2M Service Enablement (MTCe-SIMSE), Service Requirement Maintenance (MTCe-SRM). Decide which MTC reqs with no Stage 2 should be removed/maintained in Rel-13. / Impacted TSs and TRs: 22.368
- 863: 7/3/16: 0%->95 / Impacted TSs and TRs: 23.401, 23.682, 23.251
- 864: 7/3/16: 0%->39; 19/9/16: 39%->100 / Impacted TSs and TRs: 33.401
- 865: 11/6/16: WID:CP-150795->CP-160292
- 866: 7/3/16: 0%->35; 11/6/16: 35%->100; 11/6/16: WID:CP-150795->CP-160292 / Impacted TSs and TRs: 24.301, 24.008, 23.122
- 867: 7/3/16: 0%->90; 11/6/16: WID:CP-150795->CP-160292; 13/6/16: 90%->100 / Impacted TSs and TRs: 29.061, 29.212
- 868: 7/3/16: 0%->65; 11/6/16: WID:CP-150795->CP-160292; 13/6/16: 65%->100 / Impacted TSs and TRs: 29.272, 29.274, 23.008, 23.007, 29.128, 29.275, 29.230, 29.336, 29.281, 29.002, 29.303
- 869: 11/6/16: WID:CP-150795->CP-160292; 13/6/16: 0%->100 / Impacted TSs and TRs: 31.102
- 870: 32.25x; 13/6/16: 0%->100 / Impacted TSs and TRs: 32.25x, 32.240, 32.251, 32.274, 32.299, 32.298, 32.297
- 871: no Perf. part; note: WI only stays in REL-13 because of PCG decision
- 872: no Perf. part; note: WI only stays in REL-13 because of PCG decision1/1/16: Compl:0%->25% 22/3/16: Compl:25%->75%;...1/7/16: Com... / Impacted TSs and TRs: 36.802
- 873: 22/3/16: WID: RP-152284->RP-160656; 1/7/16: WID: RP-160656->RP-16093326/9/16: Compl:0%->60%26/9/16: CD:Thu 15/09/16->Thu 15/12/16
- 874: 13/6/16: 0%->100 / Impacted TSs and TRs: 28.657, 28.658, 28.659, 32.425
- 875: testing REL-13 NB_IOT-Core1/7/16: Compl:0%->5%; 26/9...
- 876: 7/12/15: 0%->60
- 877: 7/12/15:created by MCC to distinguish core versus test parts. 2/3/16: FCD: 11/15->05/16, 40->90%; 13/6/16: 90%->100
- 878: 7/12/15: created GERAN. 2/3/16: G1,G2->G3, Acronym: CIoT_EC_GSM-Test->CIoT_EC_GSM_GERAN3new
- 879: related to GERAN REL-13 WI CIoT_EC_GSM-Core26/9/16: Compl:0%->100%
- 880: tested REL-13 WI: CIoT_EC_GSM-Core26/9/16: Compl...

| ID | WBS | Task | Duration | Start | Finish | Complete | Remaining | Baseline start | Baseline finish | Baseline duration | Total slack | Constraint | Resources | Work | Actual work | Acronym | PCG approved | WI rapporteur name | WI rapporteur e-mail | Release | TSG approved | Status Report | Acronym_3GU_Export |
| --- | --- | --- | --- | --- | --- | --- | --- | --- | --- | --- | --- | --- | --- | --- | --- | --- | --- | --- | --- | --- | --- | --- | --- |
| 881 | 288 | **Extended DRX cycle for Power Consumption** | 468d? | 2014-12-03 A | 2016-09-15 | 93% | 31.69d? |  |  |  | 412d |  | S2; R2; G2 | 27696h | 16780.9h | eDRX | PCG-35 | Miguel Griot | mgriot@qti.qualcomm.com | Rel-13 | SP-68 |  |  |
| 882 | 288.1 | Study on Extended DRX cycle for Power Consumption Optimization | 268d? | 2014-12-03 A | 2015-12-11 A | 100% |  |  |  |  |  | finish no earlier than 2015-12-11 | S2 | 2144h | 2144h | FS_eDRX | PCG-34 | Miguel Griot, Qualcomm | mgriot@qti.qualcomm.com | Rel-13 | SP-66 |  |  |
| 883 | 288.2 | Stage 2 for Extended DRX cycle for Power Consumption | 133d? | 2015-06-15 A | 2015-12-16 | 99% | 1.33d? |  |  |  | 609d | finish no earlier than 2015-12-16 | S2 | 1064h | 1053.36h | eDRX | PCG-35 | Miguel Griot | mgriot@qti.qualcomm.com | Rel-13 | SP-68 |  |  |
| 884 | 288.3 | **CT aspects of extended DRX cycle** | 135d? | 2015-09-07 A | 2016-03-11 A | 100% |  |  |  |  |  |  | ct | 4912h | 4912h | eDRX-CT | PCG-35 | Catovic, Amer, Qualcomm | Catovic, Amer, Qualcomm | Rel-13 | CP-69 |  |  |
| 885 | 288.3.1 | CT1 aspects of extended DRX cycle | 135d? | 2015-09-07 A | 2016-03-11 A | 100% |  |  |  |  |  | finish no earlier than 2016-03-11 | C1 | 1080h | 1080h | eDRX-CT | PCG-35 | Catovic, Amer, Qualcomm | Catovic, Amer, Qualcomm | Rel-13 | CP-69 |  |  |
| 886 | 288.3.2 | CT3 aspects of extended DRX cycle | 135d? | 2015-09-07 A | 2016-03-11 A | 100% |  |  |  |  |  | finish no earlier than 2016-03-11 | C3 | 1080h | 1080h | eDRX-CT | PCG-35 | Catovic, Amer, Qualcomm | Catovic, Amer, Qualcomm | Rel-13 | CP-69 |  |  |
| 887 | 288.3.3 | CT4 aspects of extended DRX cycle | 74d? | 2015-09-07 A | 2015-12-17 A | 100% |  |  |  |  |  | finish no earlier than 2015-12-17 | C4 | 592h | 592h | eDRX-CT | PCG-35 | Catovic, Amer, Qualcomm | Catovic, Amer, Qualcomm | Rel-13 | CP-69 |  |  |
| 888 | 288.3.4 | CT6 aspects of extended DRX cycle | 135d? | 2015-09-07 A | 2016-03-11 A | 100% |  |  |  |  |  | finish no earlier than 2016-03-11 | C6 | 1080h | 1080h | eDRX-CT | PCG-36 | Catovic, Amer, Qualcomm | Catovic, Amer, Qualcomm | Rel-13 | CP-70 |  |  |
| 889 | 288.4 | **RAN enhancements for extended DRX in LTE** | 262d? | 2015-03-16 A | 2016-03-15 A | 100% |  |  |  |  |  |  | R2 | 4192h | 4192h | LTE_extDRX | PCG-34 | Qualcomm |  | Rel-13 | RP-67 |  |  |
| 890 | 288.4.1 | Core part: RAN enhancements for extended DRX in LTE | 262d? | 2015-03-16 A | 2016-03-15 A | 100% |  |  |  |  |  | finish no earlier than 2016-03-15 | R2 | 2096h | 2096h | LTE_extDRX-Core | PCG-34 | Qualcomm |  | Rel-13 | RP-67 | RP-151338 |  |
| 891 | 288.5 | UE Conformance Test Aspects - RAN enhancements for extended DRX in LTE | 134d? | 2016-03-15 A | 2016-09-15 A | 100% |  |  |  |  |  | finish no earlier than 2016-12-15 | R5 | 1072h | 1072h | LTE_extDRX-UEConTest | PCG-36 | Qualcomm |  | Rel-13 | TSG#71 |  |  |
| 892 | 288.6 | **Extended DRX (eDRX) for GSM** | 184.5d? | 2015-08-28 A | 2016-05-12 | 44% | 102.46d? |  |  |  | 503d |  | G2; G1 | 4832h | 2072.8h | eDRX_GSM | PCG-35 | John Diachina, Ericsson LM | John.Diachina@Ericsson.com | Rel-13 | RP-69 |  |  |
| 893 | 288.6.1 | Core Part: Extended DRX (eDRX) for GSM | 60.5d? | 2015-08-28 A | 2015-11-20 A | 100% |  |  |  |  |  | finish no earlier than 2015-11-20 | G2; G1 | 968h | 968h | eDRX_GSM-Core | PCG-36 | John Diachina, Ericsson LM | John.Diachina@Ericsson.com | Rel-13 | SP-70 |  |  |
| 894 | 288.6.2 | MS test: Extended DRX (eDRX) for GSM | 114d? | 2015-12-07 A | 2016-05-12 | 15% | 96.9d? |  |  |  | 503d | start no earlier than 2015-12-07 | G3 | 912h | 136.8h | eDRX_GSM_GERAN3new | PCG-36 | Sierra Wireless S.A | John.Diachina@Ericsson.com | Rel-13 | SP-70 |  |  |
| 895 | 289 | **Optimizations to Support High Latency Communications** | 326d? | 2014-09-19 A | 2015-12-16 A | 100% |  |  |  |  |  |  | S2 | 5824h | 5824h | HLcom | PCG-34 | Ericsson, Hans Rönneke | hans.ronneke(at)ericsson.com | Rel-13 | SP-67 |  |  |
| 896 | 289.1 | Study on Optimizations to support High Latency communications | 196d? | 2014-09-19 A | 2015-06-17 A | 100% |  |  |  |  |  | finish no earlier than 2015-06-17 | S2 | 1568h | 1568h | FS_HLcom | PCG-33 | Ericsson | hans.ronneke@ericsson.com | Rel-13 | SP-65 |  | FS_HLcom |
| 897 | 289.2 | Optimizations to Support High Latency Communications | 73d? | 2015-03-05 A | 2015-06-15 A | 100% |  |  |  |  |  | finish no earlier than 2015-06-15 | S2 | 584h | 584h | HLcom | PCG-34 | Ericsson, Hans Rönneke | hans.ronneke(at)ericsson.com | Rel-13 | SP-67 |  |  |
| 898 | 289.3 | CT aspects of Optimizations to Support High Latency | 133d? | 2015-06-15 A | 2015-12-16 A | 100% |  |  |  |  |  | finish no earlier than 2015-12-16 | C4 | 1064h | 1064h | HLcom-CT | PCG-35 | Yong Yang, Ericsson | frank.yong.yang@ericsson.com | Rel-13 | CP-68 |  |  |
| 899 | 290 | **Further LTE Physical Layer Enhancements for MTC** | 593d? | 2014-09-12 A | 2016-12-15 | 81% | 113.92d? | 2014-06-13 | 2015-06-12 | 261d? | 347d |  | R1; R4; R2 | 30048h | 20586.7h | LTE_MTCe2_L1 | PCG-33 | Ericsson | johan.bergman@ericsson.com | Rel-13 | RP-65 |  | LTE_MTCe2_L1 |
| 900 | 290.1 | Core part: Further LTE Physical Layer Enhancements for MTC | 395d? | 2014-09-12 A | 2016-03-15 A | 100% |  | 2014-06-13 | 2015-06-12 | 261d? |  | finish no earlier than 2016-03-15 | R1; R2; R4 | 9480h | 9480h | LTE_MTCe2_L1-Core | PCG-33 | Ericsson | johan.bergman@ericsson.com | Rel-13 | RP-65 | RP-151186 | LTE_MTCe2_L1-Core |
| 901 | 290.2 | Perf. Part: Further LTE Physical Layer Enhancements for MTC | 593d? | 2014-09-12 A | 2016-12-15 | 80% | 118.6d? | 2014-06-13 | 2015-06-12 | 261d? | 347d | finish no earlier than 2016-12-15 | R4 | 4744h | 3795.2h | LTE_MTCe2_L1-Perf | PCG-33 | Ericsson | johan.bergman@ericsson.com | Rel-13 | RP-65 | RP-151186 | LTE_MTCe2_L1-Perf |
| 902 | 290.3 | UE Conformance Test Aspects - Further LTE Physical Layer Enhancements for MTC | 199d? | 2016-03-15 A | 2016-12-15 | 45% | 109.45d? |  |  |  | 347d | finish no earlier than 2016-12-15 | R5 | 1592h | 716.4h | LTE_MTCe2_L1-UEConTest | PCG-36 | Ericsson |  | Rel-13 | TSG#71 |  |  |
| 903 | 291 | EGPRS Access Security Enhancements in relation to Cellular IoT | 128d? | 2015-09-16 A | 2016-03-11 | 99% | 1.28d? |  |  |  | 547d | finish no earlier than 2016-03-11 | S3 | 1024h | 1013.76h | EASE_EC_GSM | PCG-35 | Vesa Torvinen, Ericsson |  | Rel-13 | SP-69 |  |  |
| 904 | 292 | **Group based Enhancements** | 394d? | 2014-06-18 A | 2015-12-16 A | 100% |  | 2014-06-18 | 2015-09-16 | 326d? |  |  | S2; S3 | 18676.8h | 18676.8h | GROUPE | PCG-33 | Huawei | ZhangWanqiang@huawei.com | Rel-13 | SP-64 |  | GROUPE |
| 905 | 292.1 | TR for Group based Enhancements | 196d? | 2014-06-18 A | 2015-03-18 A | 100% |  | 2014-06-18 | 2015-03-18 | 196d? |  | finish no earlier than 2015-03-18 | S2 | 1568h | 1568h | GROUPE | PCG-33 | Huawei, Wanqiang Zhang | ZhangWanqiang@huawei.com | Rel-13 | SP-64 |  |  |
| 906 | 292.2 | Stage 2 for Group based Enhancements | 261d? | 2014-06-23 A | 2015-06-17 A | 100% |  | 2014-06-18 | 2015-06-17 | 261d? |  | finish no earlier than 2015-06-17 | S2 | 2088h | 2088h | GROUPE | PCG-33 | Huawei | ZhangWanqiang@huawei.com | Rel-13 | SP-64 |  |  |
| 907 | 292.3 | TR on Security for Group based Enhancements | 231.6d? | 2014-06-18 A | 2015-06-12 A | 100% |  | 2014-06-18 | 2015-06-17 | 231.6d? |  | start no earlier than 2014-06-18 | S3 | 1852.8h | 1852.8h | GROUPE | PCG-33 | Samsung | Rajavelsamy R (rajvel@samsung.com) | Rel-13 | SP-64 |  |  |
| 908 | 292.4 | Security for Group based Enhancements | 326d? | 2014-06-23 A | 2015-09-16 A | 100% |  | 2014-06-18 | 2015-09-16 | 326d? |  | finish no earlier than 2015-09-16 | S3 | 2608h | 2608h | GROUPE | PCG-33 | Samsung | Rajavelsamy R (rajvel@samsung.com) | Rel-13 | SP-64 |  |  |

Notes:
- 881: June2015: WID:SP-150254->SP-150369 / Impacted TSs and TRs: 23.401, 23.060, 23.682, 23.271, 23.272
- 882: No Ran aspects yet. GERAN in FS_uPoD.29/1: TS number added Mar15: 0->30%; June2015: Compl:30%->95, Exc S granted in SP-150352; 07/09/15: 95%->100 / Impacted TSs and TRs: 23.770
- 883: June2015: WID:SP-150254->SP-150369; 07/09/15: 0%->95; 7/12/15: 95%->99 / Impacted TSs and TRs: 23.401, 23.060, 23.682, 23.271, 23.272
- 884: 14/09/15: WID:CP-150499->CP-150541
- 885: 14/09/15: WID:CP-150499->CP-150541; 7/12/15: 25%->80. FCD ->03/16. ES in CP-150723; 7/3/16: 80%->100 / Impacted TSs and TRs: 24.301, 24.008, 29.118
- 886: 14/09/15: WID:CP-150499->CP-150541. FCD ->03/16. ES in CP-150723; 8/12/15: 0%->100 / Impacted TSs and TRs: 29.338, 23.007, 29.274, 29.060, 29.172
- 887: 14/09/15: WID:CP-150499->CP-150541; 7/12/15: 40%->100; 8/12/15: 100%->95; 8/3/16: 95%->100 / Impacted TSs and TRs: 29.212
- 888: 7/12/15: Added. FCD ->03/16. ES in CP-150723; 8/3/16: 0%->100
- 890: 03/07/15: Compl:0%->15% 03/07/15: Stat Rep: ->RP-150798 29/09/15: Compl:15%->35% 29/09/15: WID: RP-150493->RP-151339 29/09/15: Stat Rep: RP-150798->RP-151338 ...; 22/3/16: Compl:95%->100%
- 891: testing REL-13 LTE_extDRX-Core and CT1 feature eDRX-CT...;...
- 892: 07/09/15: 0%->40; 7/12/15: 40%->100 / Impacted TSs and TRs: 43.064, 44.018, 44.060, 45.008, 48.018, 43.022
- 893: 7/12/15: created by MCC to distinguish Core versus test parts / Impacted TSs and TRs: 43.064, 44.018, 44.060, 45.008, 48.018, 43.022
- 894: 7/12/15: created by GERAN. 2/3/16: G1,G2->G3. Acronym: eDRX_GSM-Test -> eDRX_GSM_GERAN3new (to conform to WID); 0->15%
- 895: Impacted TSs and TRs: 23.401, 23.060, 23.682
- 896: Dec.14: 0->30%. Mar15: 70%; June2015: Compl:70%->100 / Impacted TSs and TRs: New TR 23.709
- 897: June 2015: created by MCC as a result of the split of the one-line Feature into a several-lines Feature (now Stage 2 and Stage 3 aspects); June2015: Compl:0%->100. WID: SP-150030->SP-150252 / Impacted TSs and TRs: 23.401, 23.060, 23.682
- 898: 07/09/15: 0%->80; 7/12/15: 80%->100 / Impacted TSs and TRs: 29.274, 29.060, 29.281, 23.008, 29.272, 29.230, 29.002, 29.336, 29.xyz
- 899: Triggered by Rel-12 TR 36.888 Study on Provision of low-cost MTC UEs based on LTE (FS_LC_MTC_LTE) and Low cost & enhanced coverage MTC UE for LTE (LC_MTC_UE) / Impacted TSs and TRs: LTE
- 900: 3/3/15: WID: RP-141865; Stat Rep: -->RP-141785 1st Apr 15: Compl:10%->25% 1st Apr 15: WID: RP-141865->RP-150492 1st Apr 15: Stat Rep: RP-141785->RP-150495 03/07/15: Compl:25%->45% 03/07/15: Stat Rep: RP-150495->RP-150583 29/09/15: Compl:45%->65% 29/09/...; ; ; ; ; ; ; ; ; ; ; ; ; ; ; ; ; ; ; ; ; ; 22/3/16: Compl:90%->100% / Impacted TSs and TRs: 36.101, 36.104, 36.133, 36.201, 36.211, 36.212, 36.213, 36.214, 36.300, 36.302, 36.306, 36.321, 36.331
- 901: ; WID: RP-142043->RP-141865; Stat Rep: -->RP-141785 1st Apr 15: WID: RP-141865->RP-150492 1st Apr 15: Stat Rep: RP-141785->RP-150495 03/07/15: Stat Rep: RP-150495->RP-150583 29/09/15: Stat Rep: RP-150583->RP-151186 ......;...26/9/16: Compl:70%-... / Impacted TSs and TRs: 36.101, 36.104, 36.133
- 902: testing REL-13 LTE_MTCe2_L1-Core; 1/7/16: Compl:0%->6%...; 26/...
- 903: 7/12/15: 0%->5; 28/1/16: 33.420 added;; 7/3/16: 5%->80; 11/6/16: 80%->98; 19/9/16: 98%->99 / Impacted TSs and TRs: New 33.420
- 904: - / Impacted TSs and TRs: Stage 2
- 905: Dec.14: 20->70%. Mar15: 90%; June2015: Compl:90%->100 / Impacted TSs and TRs: New TR 23.769
- 906: Mar15: 0->20%; June2015: Compl:20%->100 / Impacted TSs and TRs: 23.682, TBD
- 907: TR 33.8xy will capture requirements, solution alternatives, evaluations and conclusions for the AESE, MONTE and GROUPE WIDs. 3/3/15: 5->10%.; June2015: Compl:10%->60; 11/12/15: 60%->100 / Impacted TSs and TRs: New TR 33.889
- 908: -; 11/12/15: 0%->100 / Impacted TSs and TRs: 33.187

| ID | WBS | Task | Duration | Start | Finish | Complete | Baseline start | Baseline finish | Baseline duration | Constraint | Resources | Work | Actual work | Acronym | PCG approved | WI rapporteur name | WI rapporteur e-mail | Release | TSG approved | Acronym_3GU_Export | Status Report | MCC resp | Special Focus Doc |
| --- | --- | --- | --- | --- | --- | --- | --- | --- | --- | --- | --- | --- | --- | --- | --- | --- | --- | --- | --- | --- | --- | --- | --- |
| 909 | 292.5 | **CT aspects of Group based Enhancements** | 133d? | 2015-06-15 A | 2015-12-16 A | 100% |  |  |  |  | C4 | 4256h | 4256h | GROUPE-CT | PCG-35 | Peter Schmitt, Huawei | Peter.Schmitt@huawei.com | Rel-13 | CP-68 |  |  |  |  |
| 910 | 292.5.1 | CT1 aspects of Group based Enhancements | 133d? | 2015-06-15 A | 2015-12-16 A | 100% |  |  |  | start no earlier than 2015-06-15 | C1 | 1064h | 1064h | GROUPE-CT | PCG-35 | Peter Schmitt, Huawei | Peter.Schmitt@huawei.com | Rel-13 | CP-68 |  |  |  |  |
| 911 | 292.5.2 | DELETED: CT3 aspects of Group based Enhancements | 133d? | 2015-06-15 A | 2015-12-16 A | 100% |  |  |  | start no earlier than 2015-06-15 | C3 | 1064h | 1064h | GROUPE-CT | PCG-35 | Peter Schmitt, Huawei | Peter.Schmitt@huawei.com | Rel-13 | CP-68 |  |  |  |  |
| 912 | 292.5.3 | CT4 aspects of Group based Enhancements | 133d? | 2015-06-15 A | 2015-12-16 A | 100% |  |  |  | start no earlier than 2015-06-15 | C4 | 1064h | 1064h | GROUPE-CT | PCG-35 | Peter Schmitt, Huawei | Peter.Schmitt@huawei.com | Rel-13 | CP-68 |  |  |  |  |
| 913 | 293 | **Monitoring Enhancements** | 456d? | 2014-06-18 A | 2016-03-11 A | 100% | 2014-06-18 | 2015-09-16 | 326d? |  | S2; S3 | 21684.8h | 21684.8h | MONTE | PCG-33 | Intel | puneet.jain@intel.com | Rel-13 | SP-64 | MONTE |  |  |  |
| 914 | 293.1 | TR for Monitoring Enhancements | 196d? | 2014-09-17 A | 2015-06-17 A | 100% | 2014-09-17 | 2015-06-17 | 196d? | finish no earlier than 2015-06-17 | S2 | 1568h | 1568h | MONTE | PCG-33 | Intel, Puneet Jain | puneet.jain@intel.com | Rel-13 | SP-64 |  |  |  |  |
| 915 | 293.2 | Stage 2 for Monitoring Enhancements | 261d? | 2014-06-23 A | 2015-06-17 A | 100% | 2014-06-18 | 2015-06-17 | 261d? | finish no earlier than 2015-06-17 | S2 | 2088h | 2088h | MONTE | PCG-33 | Intel, Puneet Jain | puneet.jain@intel.com | Rel-13 | SP-64 |  |  |  |  |
| 916 | 293.3 | TR on Security for Monitoring Enhancements | 231.6d? | 2014-06-18 A | 2015-06-12 A | 100% | 2014-06-18 | 2015-06-17 | 231.6d? | start no earlier than 2014-06-18 | S3 | 1852.8h | 1852.8h | MONTE | PCG-33 | Samsung | Rajavelsamy R (rajvel@samsung.com) | Rel-13 | SP-64 |  |  |  |  |
| 917 | 293.4 | Security for Monitoring Enhancements | 326d? | 2014-06-23 A | 2015-09-16 A | 100% | 2014-06-18 | 2015-09-16 | 326d? | finish no earlier than 2015-09-16 | S3 | 2608h | 2608h | MONTE | PCG-33 | Samsung | Rajavelsamy R (rajvel@samsung.com) | Rel-13 | SP-64 |  |  |  |  |
| 918 | 293.5 | Charging aspects of MONTE | 128d? | 2015-09-16 A | 2016-03-11 A | 100% | 2014-06-18 | 2015-09-16 | 326d? | finish no earlier than 2016-03-11 | S5 | 1024h | 1024h | MONTE-CH | PCG-35 | Huawei(Li Li, jasmine.li@huawei.com) | jasmine.li@huawei.com | Rel-13 | CP-69 |  |  |  |  |
| 919 | 293.6 | **Monitoring Enhancements CT aspects** | 195d? | 2015-06-15 A | 2016-03-11 A | 100% |  |  |  |  | C4 | 5248h | 5248h | MONTE-CT | PCG-35 | Peter Schmitt, Huawei | peter.schmitt@huawei.com | Rel-13 | CP-68 |  |  |  |  |
| 920 | 293.6.1 | CT1 aspects of Monitoring Enhancements | 133d? | 2015-06-15 A | 2015-12-16 A | 100% |  |  |  | start no earlier than 2015-06-15 | C1 | 1064h | 1064h | MONTE-CT | PCG-35 | Peter Schmitt, Huawei | peter.schmitt@huawei.com | Rel-13 | CP-68 |  |  |  |  |
| 921 | 293.6.2 | CT3 aspects of Monitoring Enhancements | 133d? | 2015-06-15 A | 2015-12-16 A | 100% |  |  |  | start no earlier than 2015-06-15 | C3 | 1064h | 1064h | MONTE-CT | PCG-35 | Peter Schmitt, Huawei | peter.schmitt@huawei.com | Rel-13 | CP-68 |  |  |  |  |
| 922 | 293.6.3 | CT4 aspects of Monitoring Enhancements | 195d? | 2015-06-15 A | 2016-03-11 A | 100% |  |  |  | finish no earlier than 2016-03-11 | C4 | 1560h | 1560h | MONTE-CT | PCG-35 | Peter Schmitt, Huawei | peter.schmitt@huawei.com | Rel-13 | CP-68 |  |  |  |  |
| 923 | 294 | **Dedicated Core Networks** | 456d? | 2014-06-18 A | 2016-03-11 A | 100% | 2014-06-18 | 2015-03-18 | 196d? |  | S2 | 11518.4h | 11518.4h | DECOR | PCG-33 | NTT DOCOMO | Daisuke Fujishima (fujishimad@nttdocomo.co.jp) | Rel-13 | SP-64 | DECOR |  |  |  |
| 924 | 294.1 | TR for Dedicated Core Networks | 128d? | 2014-06-18 A | 2014-12-12 A | 100% | 2014-06-18 | 2014-12-10 | 126d? | finish no earlier than 2014-12-12 | S2 | 1024h | 1024h | DECOR | PCG-33 | NTT DOCOMO | Daisuke Fujishima (fujishimad@nttdocomo.co.jp) | Rel-13 | SP-64 |  |  |  |  |
| 925 | 294.2 | Stage 2 for Dedicated Core Networks | 196d? | 2014-06-23 A | 2015-03-18 A | 100% | 2014-06-18 | 2015-03-18 | 196d? | finish no earlier than 2015-03-18 | S2 | 1568h | 1568h | DECOR | PCG-33 | NTT DOCOMO | Daisuke Fujishima (fujishimad@nttdocomo.co.jp) | Rel-13 | SP-64 |  |  |  |  |
| 926 | 294.3 | **CT aspects of Dedicated Core Networks** | 186.8d? | 2015-06-25 A | 2016-03-11 A | 100% |  |  |  |  | ct | 3166.4h | 3166.4h | DECOR-CT | PCG-35 | Huawei, Xiaoyan SHI (Sean.shixiaoyan@huawei.com) | Huawei, Xiaoyan SHI (Sean.shixiaoyan@huawei.com) | Rel-13 | CP-69 |  |  |  |  |
| 927 | 294.3.1 | CT1 aspects for Dedicated Core Networks CT aspects | 74d? | 2015-09-07 A | 2015-12-17 A | 100% |  |  |  | finish no earlier than 2015-12-17 | C1 | 592h | 592h | DECOR-CT | PCG-35 | Huawei |  | Rel-13 | CP-69 |  |  |  |  |
| 928 | 294.3.2 | CT4 aspects for Dedicated Core Networks CT aspects | 135d? | 2015-06-25 A | 2016-03-11 A | 100% |  |  |  | finish no earlier than 2016-03-11 | C4 | 1080h | 1080h | DECOR-CT | PCG-35 |  |  | Rel-13 | CP-69 |  |  |  |  |
| 929 | 294.4 | **Dedicated Core Networks RAN Aspects** | 132d? | 2015-06-15 A | 2015-12-15 A | 100% |  |  |  |  | R3 | 2112h | 2112h | DECOR-UTRA_LTE | PCG-35 | Ericsson |  | Rel-13 | TSG-68 |  |  |  |  |
| 930 | 294.4.1 | Core part: Dedicated Core Networks | 132d? | 2015-06-15 A | 2015-12-15 A | 100% |  |  |  | finish no earlier than 2015-12-15 | R3 | 1056h | 1056h | DECOR-UTRA_LTE-Core | PCG-35 | Ericsson |  | Rel-13 | TSG-68 |  | RP-151290 |  |  |
| 931 | 295 | **Service Exposure and Enablement Support** | 268d? | 2013-09-12 A | 2014-09-17 A | 100% | 2013-09-12 | 2014-09-17 | 267d? |  | S1 | 5880h | 5880h | SEES | PCG-31 | KPN | toon.norp@tno.nl | Rel-13 | SP-61 | SEES | S1-143301 | Alain | MTC, M2M |
| 932 | 295.1 | TR on Stage 1 for Service Exposure and Enablement Support | 202d? | 2013-09-12 A | 2014-06-18 A | 100% | 2013-09-12 | 2014-06-18 | 202d? | finish no earlier than 2014-06-18 | S1 | 1608h | 1608h | SEES | PCG-31 | KPN | toon.norp@tno.nl | Rel-13 | SP-61 |  | S1-143301 | Alain | MTC, M2M |
| 933 | 295.2 | Stage 1 for Service Exposure and Enablement Support | 266d? | 2013-09-12 A | 2014-09-17 A | 100% | 2013-09-12 | 2014-09-17 | 266d? | finish no earlier than 2014-09-17 | S1 | 2128h | 2128h | SEES | PCG-31 | KPN | toon.norp@tno.nl | Rel-13 | SP-61 |  | S1-143301 | Alain | MTC, M2M |

Notes:
- 909: 7/12/15: WID:CP-150240->CP-150816 / Impacted TSs and TRs: 24.008, 24.301, 29.468, 29.272, 23.008, 29.336, 29.303, 29.002, 29.230, 29.305, 23.003
- 910: 07/09/15: 0%->15; 7/12/15: 15%->100; 7/12/15: WID:CP-150240->CP-150816 / Impacted TSs and TRs: 24.008, 24.301
- 911: 7/12/15: WID:CP-150240->CP-150816. CT3 task removed / Impacted TSs and TRs: 29.468
- 912: 07/09/15: 0%->80; 7/12/15: 80%->100; 7/12/15: WID:CP-150240->CP-150816 / Impacted TSs and TRs: 29.272, 23.008, 29.336, 29.303, 29.002, 29.230, 29.305, 23.003
- 913: Linked to Rel-13 Feature Architecture Enhancements for Service Exposure (AESE). Although service requirements (TS 22.368 clause 7.2.8) are motivated by MTC, the solution may apply to normal UEs; 5/10/15: 32.278 added; / Impacted TSs and TRs: 32.278
- 914: Dec.14: 25->85%. Mar15: 100% / Impacted TSs and TRs: New TR 23.789
- 915: -; June2015: Compl:0%->100 / Impacted TSs and TRs: 23.682, TBD
- 916: TR 33.8xy will capture requirements, solution alternatives, evaluations and conclusions for the AESE, MONTE and GROUPE WIDs.3/3/15: 5->10%.; June2015: Compl:10%->15; 11/12/15: 15%->100 / Impacted TSs and TRs: New TR 33.889
- 917: -; 11/12/15: 0%->100 / Impacted TSs and TRs: 33.187
- 918: 7/10/15: acronym changed from "MONTE" to "MONTE-CH"; 7/12/15: 0%->50. ES in SP-150709 (wrong UID in the ES); 7/3/16: 25%->100 / Impacted TSs and TRs: 32.27x, 32.240, 32.299, 32.298
- 919: 14/09/15: WID:CP-150396->CP-150422
- 920: 07/09/15: 0%->95; 14/09/15: WID:CP-150396->CP-150422; 7/12/15: 95%->100 / Impacted TSs and TRs: 24.301, 24.008
- 921: 07/09/15: 0%->100; 14/09/15: WID:CP-150396->CP-150422 / Impacted TSs and TRs: 29.214, 29.213, 29.201
- 922: 61907/09/15: 0%->50; 14/09/15: WID:CP-150396->CP-150422; 7/12/15: 50%->85. FCD -> 03/16, ES in CP-150619; 7/3/16: 85%->100 / Impacted TSs and TRs: New TS 29.128, 29.272, 29.002, 29.336, 29.230, 23.008
- 923: 06/15: WID: SP-140707-> SP-150249 / Impacted TSs and TRs: Stage 2
- 924: Dec.14: 30->100%. 06/15: WID: SP-140707-> SP-150249 / Impacted TSs and TRs: New TR 23.707
- 925: Mar15: 0->70%; June2015: Compl:70%->100, WID: SP-140707-> SP-150249 / Impacted TSs and TRs: 23.060, 23.401, 23.236
- 927: 7/12/15: 0%->100 / Impacted TSs and TRs: 24.301, 24.008
- 928: 7/12/15: 70%->90. FCD -> 03/16, ES CP-150617; 7/3/16: 90%->100 / Impacted TSs and TRs: 29.274, 29.060, 23.003, 29.272, 29.002, 29.305, 23.008, 29.230, 29.303, 23.007
- 929: no Perf. part; note: DECOR is a REL-13 SA2 WI;
- 930: no Perf. part; note: DECOR is a REL-13 SA2 WI; 29/09/15: Compl:0%->30% 29/09/15: Stat Rep: -->RP-1512901/1/16: Compl:30%->100%
- 931: SP#62 completion 06/14=>09/14. Linked to Rel-12 Study TR 22.888 (FS_MTCe) and to Features Rel-11 SIMTC & Rel-12 MTCe and MOSAP / Impacted TSs and TRs: Stage 1
- 932: SP#64 completed. TR 22.853v200 for Approval. External requirements from oneM2M TR0001(oneM2M Use Case collection), TS0002 (M2M Requirements) / Impacted TSs and TRs: New TR 22.853
- 933: SP#65 completed / Impacted TSs and TRs: 22.101, 22.115, 22.368, TBD

| ID | WBS | Task | Duration | Start | Finish | Complete | Remaining | Baseline start | Baseline finish | Baseline duration | Total slack | Constraint | Resources | Work | Actual work | Acronym | PCG approved | WI rapporteur name | WI rapporteur e-mail | Release | TSG approved | Acronym_3GU_Export | MCC resp | Special Focus Doc | Status Report |
| --- | --- | --- | --- | --- | --- | --- | --- | --- | --- | --- | --- | --- | --- | --- | --- | --- | --- | --- | --- | --- | --- | --- | --- | --- | --- |
| 934 | 296 | **Architecture Enhancements for Service capability Exposure** | 456d? | 2014-06-18 A | 2016-03-11 | 100% | 0d? | 2014-06-18 | 2015-09-16 | 326d? | 0d |  | S2; S3 | 19675.2h | 16027.2h | AESE | PCG-33 | Intel | puneet.jain@intel.com | Rel-13 | SP-64 | AESE |  |  |  |
| 935 | 296.1 | TR for Architecture Enhancements for Service capability Exposure | 196d? | 2014-06-18 A | 2015-03-18 A | 100% |  | 2014-06-18 | 2015-03-18 | 196d? |  | finish no earlier than 2015-03-18 | S2 | 1568h | 1568h | AESE | PCG-33 | Intel, Puneet Jain | puneet.jain@intel.com | Rel-13 | SP-64 |  |  |  |  |
| 936 | 296.2 | Stage 2 for Architecture Enhancements for Service capability Exposure | 261d? | 2014-06-23 A | 2015-06-17 A | 100% |  | 2014-06-18 | 2015-06-17 | 261d? |  | finish no earlier than 2015-06-17 | S2 | 2088h | 2088h | AESE | PCG-33 | Intel, Puneet Jain | puneet.jain@intel.com | Rel-13 | SP-64 |  |  |  |  |
| 937 | 296.3 | TR on Security for Architecture Enhancements for Service capability Exposure | 241.4d? | 2014-06-23 A | 2015-06-17 A | 100% |  | 2014-06-18 | 2015-06-17 | 241.4d? |  | finish no earlier than 2015-06-17 | S3 | 1931.2h | 1931.2h | AESE | PCG-33 | Samsung | Rajavelsamy R (rajvel@samsung.com) | Rel-13 | SP-64 |  |  |  |  |
| 938 | 296.4 | Security for Architecture Enhancements for Service capability Exposure | 326d? | 2014-06-23 A | 2015-09-16 A | 100% |  | 2014-06-18 | 2015-09-16 | 326d? |  | finish no earlier than 2015-09-16 | S3 | 2608h | 2608h | AESE | PCG-33 | Samsung | Rajavelsamy R (rajvel@samsung.com) | Rel-13 | SP-64 |  |  |  |  |
| 939 | 296.5 | **CT aspects of Architecture Enhancements for Service capability Exposure** | 195d? | 2015-06-15 A | 2016-03-11 A | 100% |  |  |  |  |  |  | C3 | 4184h | 4184h | AESE-CT | PCG-35 | Yizhuang Wu, Huawei | wuyizhuang@huawei.com | Rel-13 | CP-68 |  |  |  |  |
| 940 | 296.5.1 | CT3 aspects of Architecture Enhancements for Service capability Exposure | 195d? | 2015-06-15 A | 2016-03-11 A | 100% |  |  |  |  |  | finish no earlier than 2016-03-11 | C3 | 1560h | 1560h | AESE-CT | PCG-35 | Yizhuang Wu, Huawei. FCD+3, ES in 642 | wuyizhuang@huawei.com | Rel-13 | CP-68 |  |  |  |  |
| 941 | 296.5.2 | CT4 aspects of Architecture Enhancements for Service capability Exposure | 133d? | 2015-06-15 A | 2015-12-16 A | 100% |  |  |  |  |  | start no earlier than 2015-06-15 | C4 | 1064h | 1064h | AESE-CT | PCG-35 | Yizhuang Wu, Huawei | wuyizhuang@huawei.com | Rel-13 | CP-68 |  |  |  |  |
| 942 | 297 | **Rel-13 LTE Carrier Aggregation** | 990d? | 2013-12-09 A | 2017-09-15 | 94% | 62.12d? | 2014-03-06 | 2015-06-12 | 332d? | 151d |  | R4 | 554048h | 498671h | LTE_CA_Rel13 | PCG-30 |  |  | Rel-13 | RP-58 | LTE_CA_Rel-13 | Issam | CA |  |
| 943 | 297.1 | **LTE Advanced 4 Band Carrier Aggregation (4DL/1UL) of Band 4, Band 4, Band 5 and Band 12** | 66d? | 2015-09-15 A | 2015-12-15 A | 100% |  |  |  |  |  |  | R4 | 1584h | 1584h | LTE_CA_B4_B4_B5_B12 | PCG-35 | US Cellular |  | Rel-13 | RP-69 |  |  |  |  |
| 944 | 297.1.1 | Core part: LTE Advanced 4 Band Carrier Aggregation (4DL/1UL) of Band 4, Band 4, Band 5 and Band 12 | 66d? | 2015-09-15 A | 2015-12-15 A | 100% |  |  |  |  |  | finish no earlier than 2016-03-15 | R4 | 528h | 528h | LTE_CA_B4_B4_B5_B12-Core | PCG-35 | US Cellular |  | Rel-13 | RP-69 |  |  |  |  |
| 945 | 297.1.2 | Perf. part: LTE Advanced 4 Band Carrier Aggregation (4DL/1UL) of Band 4, Band 4, Band 5 and Band 12 | 66d? | 2015-09-15 A | 2015-12-15 A | 100% |  |  |  |  |  | finish no earlier than 2016-03-15 | R4 | 528h | 528h | LTE_CA_B4_B4_B5_B12-Perf | PCG-35 | US Cellular |  | Rel-13 | RP-69 |  |  |  |  |
| 946 | 297.2 | **LTE Advanced 4 Band Carrier Aggregation (4DL/1UL) of Band 2, Band 4, Band 4 and Band 5** | 66d? | 2015-09-15 A | 2015-12-15 A | 100% |  |  |  |  |  |  | R4 | 1584h | 1584h | LTE_CA_B2_B4_B4_B5 | PCG-35 | US Cellular |  | Rel-13 | RP-69 |  |  |  |  |
| 947 | 297.2.1 | Core part: LTE Advanced 4 Band Carrier Aggregation (4DL/1UL) of Band 2, Band 4, Band 4 and Band 5 | 66d? | 2015-09-15 A | 2015-12-15 A | 100% |  |  |  |  |  | finish no earlier than 2016-03-15 | R4 | 528h | 528h | LTE_CA_B2_B4_B4_B5-Core | PCG-35 | US Cellular |  | Rel-13 | RP-69 |  |  |  |  |
| 948 | 297.2.2 | Perf. part: LTE Advanced 4 Band Carrier Aggregation (4DL/1UL) of Band 2, Band 4, Band 4 and Band 5 | 66d? | 2015-09-15 A | 2015-12-15 A | 100% |  |  |  |  |  | finish no earlier than 2016-03-15 | R4 | 528h | 528h | LTE_CA_B2_B4_B4_B5-Perf | PCG-35 | US Cellular |  | Rel-13 | RP-69 |  |  |  |  |
| 949 | 297.3 | **LTE Advanced inter-band Carrier Aggregation of Band 8 and Band 27** | 531d? | 2013-12-09 A | 2015-12-15 | 30% | 371.7d? | 2013-12-09 | 2014-12-11 | 265d? | 610d |  | R4 | 12696h | 2643.08h | LTE_CA_B8_B27 | PCG-32 | KT | ilwhan.kim@kt.com | Rel-13 | RP-62 | LTE_CA_B8_B27 | Issam | CA |  |
| 950 | 297.3.1 | Core part: LTE Advanced inter-band Carrier Aggregation of Band 8 and Band 27 | 528d? | 2013-12-09 A | 2015-12-15 | 30% | 369.6d? | 2013-12-09 | 2014-12-11 | 265d? | 610d | finish no earlier than 2015-12-15 | R4 | 4224h | 1267.2h | LTE_CA_B8_B27-Core | PCG-32 | KT | ilwhan.kim@kt.com | Rel-13 | RP-62 | LTE_CA_B8_B27-Core | Issam | CA | RP-151131 |
| 951 | 297.3.2 | Perf. part: LTE Advanced inter-band Carrier Aggregation of Band 8 and Band 27 | 528d? | 2013-12-09 A | 2015-12-15 | 30% | 369.6d? | 2013-12-09 | 2014-12-11 | 265d? | 610d | finish no earlier than 2015-12-15 | R4 | 4224h | 1267.2h | LTE_CA_B8_B27-Perf | PCG-32 | KT | ilwhan.kim@kt.com | Rel-13 | RP-62 | LTE_CA_B8_B27-Perf | Issam | CA | RP-151131 |
| 952 | 297.4 | **LTE Advanced 3 band Carrier Aggregation (3DL/1UL) for Band 3, Band 8 and Band 27** | 531d? | 2013-12-09 A | 2015-12-15 | 25% | 398.25d? | 2013-12-09 | 2014-12-05 | 261d? | 610d |  | R4 | 12696h | 2384h | LTE_CA_B3_B8_B27 | PCG-32 | KT | Chungwoo HWANG (cwhwang@kt.com) | Rel-13 | RP-62 | LTE_CA_B3_B8_B27 | Issam | CA |  |
| 953 | 297.4.1 | Core part: LTE Advanced 3 band Carrier Aggregation (3DL/1UL) for Band 3, Band 8 and Band 27 | 528d? | 2013-12-09 A | 2015-12-15 | 25% | 396d? | 2013-12-09 | 2014-12-05 | 261d? | 610d | finish no earlier than 2015-12-15 | R4 | 4224h | 1056h | LTE_CA_B3_B8_B27-Core | PCG-32 | KT | Chungwoo HWANG (cwhwang@kt.com) | Rel-13 | RP-62 | LTE_CA_B3_B8_B27-Core | Issam | CA | RP-151131 |
| 954 | 297.4.2 | Perf. part: LTE Advanced 3 band Carrier Aggregation (3DL/1UL) for Band 3, Band 8 and Band 27 | 528d? | 2013-12-09 A | 2015-12-15 | 25% | 396d? | 2013-12-09 | 2014-12-05 | 261d? | 610d | finish no earlier than 2015-12-15 | R4 | 4224h | 1056h | LTE_CA_B3_B8_B27-Perf | PCG-32 | KT | Chungwoo HWANG (cwhwang@kt.com) | Rel-13 | RP-62 | LTE_CA_B3_B8_B27-Perf | Issam | CA | RP-151131 |
| 955 | 297.5 | **LTE Advanced inter-band Carrier Aggregation of Band 7 and Band 22** | 336d? | 2014-03-06 A | 2015-06-15 A | 100% |  | 2014-03-06 | 2014-12-05 | 197d? |  |  | R4 | 8016h | 8016h | LTE_CA_B7_B22 | PCG-32 | Orange, Ericsson | erika.tejedor@ericsson.com | Rel-13 | RP-63 | LTE_CA_B7_B22 | Issam | CA |  |
| 956 | 297.5.1 | Core part: LTE Advanced inter-band Carrier Aggregation of Band 7 and Band 22 | 333d? | 2014-03-06 A | 2015-06-15 A | 100% |  | 2014-03-06 | 2014-12-05 | 197d? |  | finish no earlier than 2015-06-15 | R4 | 2664h | 2664h | LTE_CA_B7_B22-Core | PCG-32 | Orange, Ericsson | erika.tejedor@ericsson.com | Rel-13 | RP-63 | LTE_CA_B7_B22-Core | Issam | CA | RP-150536 |
| 957 | 297.5.2 | Perf. part: LTE Advanced inter-band Carrier Aggregation of Band 7 and Band 22 | 333d? | 2014-03-11 A | 2015-06-15 A | 100% |  | 2014-03-06 | 2014-12-05 | 197d? |  | finish no earlier than 2015-06-15 | R4 | 2664h | 2664h | LTE_CA_B7_B22-Perf | PCG-32 | Orange, Ericsson | erika.tejedor@ericsson.com | Rel-13 | RP-63 | LTE_CA_B7_B22-Perf | Issam | CA | RP-150536 |

Notes:
- 934: - / Impacted TSs and TRs: Stage 2
- 935: Dec.14: 30->65%. Mar15: 75%; June2015: Compl:75%->100 / Impacted TSs and TRs: New TR 23.708
- 936: -; June2015: Compl:0%->100 / Impacted TSs and TRs: TS 23.682, TS 33.187
- 937: TR 33.8xy will capture requirements, solution alternatives, evaluations and conclusions for the AESE, MONTE and GROUPE WIDs. Dec.14: 0->40%. 3/3/15: 45%.; June2015: Compl:45%->60; 11/12/15: 60%->100 / Impacted TSs and TRs: New TR 33.889
- 938: -; 11/12/15: 0%->100 / Impacted TSs and TRs: 33.187
- 939: 14/09/15: WID:CP-150402->CP-150487->CP-150576
- 940: 07/09/15: 0%->35; 14/09/15: WID:CP-150402->CP-150487->CP-150576; 7/12/15: 35%->90; 7/3/16: 90%->100 / Impacted TSs and TRs: 29.154
- 941: 07/09/15: 0%->40; 14/09/15: WID:CP-150402->CP-150487->CP-150576; 7/12/15: 40%->100 / Impacted TSs and TRs: 29.201, 29.336, 29.230, 29.272, 23.008
- 942: Acronym changed from "LTE_CA_Rel-13" to "LTE_CA_Rel13"
- 943: 13/6/16: moved from Rel-14 to Rel-13 (was a mistake)
- 944: 13/6/16: moved from Rel-14 to Rel-13 (was a mistake)
- 945: 13/6/16: moved from Rel-14 to Rel-13 (was a mistake)
- 946: 13/6/16: moved from Rel-14 to Rel-13 (was a mistake)
- 947: 13/6/16: moved from Rel-14 to Rel-13 (was a mistake)
- 948: 13/6/16: moved from Rel-14 to Rel-13 (was a mistake)
- 949: Inter-band CA 2DL/1UL / Impacted TSs and TRs: LTE
- 950: CD:Thu 18/06/15->Mon 15/06/15; Compl:10%->10%; Stat Rep: RP-141084->RP-141732 1st Apr 15: Compl:10%->15% 1st Apr 15: Stat Rep: RP-141732->RP-150013 03/07/15: Compl:15%->30% 03/07/15: CD:Mon 15/06/15->Tue 15/12/15 03/07/15: Stat Rep: RP-150013->RP-150536 29/09/15: Stat Rep: RP-150536->RP-151131 / Impacted TSs and TRs: 36.101, 36.104, 36.133, generic TR 36.851
- 951: CD:Thu 18/06/15->Mon 15/06/15; Compl:10%->10%; Stat Rep: RP-141084->RP-141732 1st Apr 15: Compl:10%->15% 1st Apr 15: Stat Rep: RP-141732->RP-150013 03/07/15: Compl:15%->30% 03/07/15: CD:Mon 15/06/15->Tue 15/12/15 03/07/15: Stat Rep: RP-150013->RP-150536 29/09/15: Stat Rep: RP-150536->RP-151131 / Impacted TSs and TRs: 36.141, 36.307
- 952: Inter-band CA 3DL / Impacted TSs and TRs: LTE
- 953: CD:Thu 18/06/15->Mon 15/06/15; Compl:25%->25%; Stat Rep: RP-141084->RP-141732 1st Apr 15: Compl:25%->30% 1st Apr 15: Stat Rep: RP-141732->RP-150013 03/07/15: Compl:30%->25% 03/07/15: CD:Mon 15/06/15->Tue 15/12/15 03/07/15: Stat Rep: RP-150013->RP-150536 29/09/15: Stat Rep: RP-150536->RP-151131 / Impacted TSs and TRs: 36.101, 36.104, 36.133, 36.141, 36.307, new generic TR 36.853 (3 Band CA with 1UL)
- 954: CD:Thu 18/06/15->Mon 15/06/15; Compl:25%->25%; Stat Rep: RP-141084->RP-141732 1st Apr 15: Compl:25%->30% 1st Apr 15: Stat Rep: RP-141732->RP-150013 03/07/15: Compl:30%->25% 03/07/15: CD:Mon 15/06/15->Tue 15/12/15 03/07/15: Stat Rep: RP-150013->RP-150536 29/09/15: Stat Rep: RP-150536->RP-151131 / Impacted TSs and TRs: 36.101, 36.104, 36.133, 36.141, 36.307
- 955: Inter-band CA 2DL / Impacted TSs and TRs: LTE
- 956: CD:Thu 11/12/14->Mon 15/06/15; Compl:10%->10%; Stat Rep: RP-141084->RP-141732 03/07/15: Compl:10%->100% 03/07/15: Stat Rep: RP-141732->RP-150536 / Impacted TSs and TRs: 36.101, 36.104, 36.133, generic TR 36.851 (2 Band CA with 1UL),
- 957: CD:Thu 11/12/14->Mon 15/06/15; Compl:0%->0%; Stat Rep: RP-141084->RP-141732 03/07/15: Compl:0%->100% 03/07/15: Stat Rep: RP-141732->RP-150536 / Impacted TSs and TRs: 36.141, 36.307

| ID | WBS | Task | Duration | Start | Finish | Complete | Baseline start | Baseline finish | Baseline duration | Constraint | Resources | Work | Actual work | Acronym | PCG approved | WI rapporteur name | WI rapporteur e-mail | Release | TSG approved | Special Focus Doc | Acronym_3GU_Export | Status Report |
| --- | --- | --- | --- | --- | --- | --- | --- | --- | --- | --- | --- | --- | --- | --- | --- | --- | --- | --- | --- | --- | --- | --- |
| 958 | 297.6 | **LTE Advanced 3 Band Carrier Aggregation (3DL/1UL) for Band 2, Band 2 and Band 12** | 262d? | 2014-06-18 A | 2015-06-15 A | 100% | 2014-06-13 | 2015-03-13 | 196d? |  | R4 | 6288h | 6288h | LTE_CA_B2_B2_B12 | PCG-33 | U.S. Cellular | sebastian.thalanany@uscellular.com | Rel-13 | RP-64 | CA | LTE_CA_B2_B2_B12 |  |
| 959 | 297.6.1 | Core part: LTE Advanced 3 Band Carrier Aggregation (3DL/1UL) for Band 2, Band 2 and Band 12 | 262d? | 2014-06-18 A | 2015-06-15 A | 100% | 2014-06-13 | 2014-12-05 | 126d? | finish no earlier than 2015-06-15 | R4 | 2096h | 2096h | LTE_CA_B2_B2_B12-Core | PCG-33 | U.S. Cellular | sebastian.thalanany@uscellular.com | Rel-13 | RP-64 | CA | LTE_CA_B2_B2_B12-Core | RP-150536 |
| 960 | 297.6.2 | Perf. Part: LTE Advanced 3 Band Carrier Aggregation (3DL/1UL) for Band 2, Band 2 and Band 12 | 262d? | 2014-06-18 A | 2015-06-15 A | 100% | 2014-06-13 | 2015-03-13 | 196d? | finish no earlier than 2015-06-15 | R4 | 2096h | 2096h | LTE_CA_B2_B2_B12-Perf | PCG-33 | U.S. Cellular | sebastian.thalanany@uscellular.com | Rel-13 | RP-64 | CA | LTE_CA_B2_B2_B12-Perf | RP-150536 |
| 961 | 297.7 | **LTE Advanced 3 Band Carrier Aggregation (3DL/1UL) of Band 3, Band 3 and Band 8** | 264d? | 2014-06-16 A | 2015-06-15 A | 100% | 2014-06-13 | 2015-06-12 | 261d? |  | R4 | 6304h | 6304h | LTE_CA_B3_B3_B8 | PCG-33 | CHTTL | Po-Han Hsieh (pohanhsieh@cht.com.tw) | Rel-13 | RP-64 | CA | LTE_CA_B3_B3_B8 |  |
| 962 | 297.7.1 | Core part: LTE Advanced 3 Band Carrier Aggregation (3DL/1UL) of Band 3, Band 3 and Band 8 | 262d? | 2014-06-16 A | 2015-06-15 A | 100% | 2014-06-13 | 2015-06-12 | 261d? | finish no earlier than 2015-06-15 | R4 | 2096h | 2096h | LTE_CA_B3_B3_B8-Core | PCG-33 | CHTTL | Po-Han Hsieh (pohanhsieh@cht.com.tw) | Rel-13 | RP-64 | CA | LTE_CA_B3_B3_B8-Core | RP-150536 |
| 963 | 297.7.2 | Perf. Part: LTE Advanced 3 Band Carrier Aggregation (3DL/1UL) of Band 3, Band 3 and Band 8 | 262d? | 2014-06-18 A | 2015-06-15 A | 100% | 2014-06-13 | 2015-06-12 | 261d? | finish no earlier than 2015-06-15 | R4 | 2096h | 2096h | LTE_CA_B3_B3_B8-Perf | PCG-33 | CHTTL | Po-Han Hsieh (pohanhsieh@cht.com.tw) | Rel-13 | RP-64 | CA | LTE_CA_B3_B3_B8-Perf | RP-150536 |
| 964 | 297.8 | **LTE Advanced 3 Band Carrier Aggregation (3DL/1UL) of Band 41, Band 42 and Band 42** | 264d? | 2014-06-16 A | 2015-06-15 A | 100% | 2014-06-13 | 2014-12-05 | 126d? |  | R4 | 6304h | 6304h | LTE_CA_B41_B42_B42 | PCG-33 | Huawei | leo.liuye@huawei.com | Rel-13 | RP-64 | CA | LTE_CA_B41_B42_B42 |  |
| 965 | 297.8.1 | Core part: LTE Advanced 3 Band Carrier Aggregation (3DL/1UL) of Band 41, Band 42 and Band 42 | 262d? | 2014-06-16 A | 2015-06-15 A | 100% | 2014-06-13 | 2014-12-05 | 126d? | finish no earlier than 2015-06-15 | R4 | 2096h | 2096h | LTE_CA_B41_B42_B42-Core | PCG-33 | Huawei | leo.liuye@huawei.com | Rel-13 | RP-64 | CA | LTE_CA_B41_B42_B42-Core | RP-150536 |
| 966 | 297.8.2 | Perf. Part: LTE Advanced 3 Band Carrier Aggregation (3DL/1UL) of Band 41, Band 42 and Band 42 | 262d? | 2014-06-18 A | 2015-06-15 A | 100% | 2014-06-13 | 2014-12-05 | 126d? | finish no earlier than 2015-06-15 | R4 | 2096h | 2096h | LTE_CA_B41_B42_B42-Perf | PCG-33 | Huawei | leo.liuye@huawei.com | Rel-13 | RP-64 | CA | LTE_CA_B41_B42_B42-Perf | RP-150536 |
| 967 | 297.9 | **LTE Advanced inter-band Carrier Aggregation of Band 3 and Band 38** | 198d? | 2014-09-15 A | 2015-06-15 A | 100% | 2014-06-13 | 2015-03-13 | 196d? |  | R4 | 4752h | 4752h | LTE_CA_B3_B38 | PCG-33 | Nokia Networks | iwajlo.angelow@nsn.com | Rel-13 | RP-65 | CA | LTE_CA_B3_B38 |  |
| 968 | 297.9.1 | Core part: LTE Advanced inter-band Carrier Aggregation of Band 3 and Band 38 | 198d? | 2014-09-15 A | 2015-06-15 A | 100% | 2014-06-13 | 2015-03-13 | 196d? | finish no earlier than 2015-06-15 | R4 | 1584h | 1584h | LTE_CA_B3_B38-Core | PCG-33 | Nokia Networks | iwajlo.angelow@nsn.com | Rel-13 | RP-65 | CA | LTE_CA_B3_B38-Core | RP-150536 |
| 969 | 297.9.2 | Perf. Part: LTE Advanced inter-band Carrier Aggregation of Band 3 and Band 38 | 198d? | 2014-09-15 A | 2015-06-15 A | 100% | 2014-06-13 | 2015-03-13 | 196d? | finish no earlier than 2015-06-15 | R4 | 1584h | 1584h | LTE_CA_B3_B38-Perf | PCG-33 | Nokia Networks | iwajlo.angelow@nsn.com | Rel-13 | RP-65 | CA | LTE_CA_B3_B38-Perf | RP-150536 |
| 970 | 297.10 | **LTE Advanced inter-band Carrier Aggregation of Band 2 and Band 28** | 198d? | 2014-09-15 A | 2015-06-15 A | 100% | 2014-06-13 | 2015-03-13 | 196d? |  | R4 | 4752h | 4752h | LTE_CA_B2_B28 | PCG-33 | Huawei | alf.ahlstrom@huawei.com | Rel-13 | RP-65 | CA | LTE_CA_B2_B28 |  |
| 971 | 297.10.1 | Core part: LTE Advanced inter-band Carrier Aggregation of Band 2 and Band 28 | 198d? | 2014-09-15 A | 2015-06-15 A | 100% | 2014-06-13 | 2015-03-13 | 196d? | finish no earlier than 2015-06-15 | R4 | 1584h | 1584h | LTE_CA_B2_B28-Core | PCG-33 | Huawei | alf.ahlstrom@huawei.com | Rel-13 | RP-65 | CA | LTE_CA_B2_B28-Core | RP-150536 |
| 972 | 297.10.2 | Perf. Part: LTE Advanced inter-band Carrier Aggregation of Band 2 and Band 28 | 198d? | 2014-09-15 A | 2015-06-15 A | 100% | 2014-06-13 | 2015-03-13 | 196d? | finish no earlier than 2015-06-15 | R4 | 1584h | 1584h | LTE_CA_B2_B28-Perf | PCG-33 | Huawei | alf.ahlstrom@huawei.com | Rel-13 | RP-65 | CA | LTE_CA_B2_B28-Perf | RP-150536 |
| 973 | 297.11 | **LTE Advanced inter-band Carrier Aggregation of Band 4 and Band 28** | 198d? | 2014-09-15 A | 2015-06-15 A | 100% | 2014-06-13 | 2015-03-13 | 196d? |  | R4 | 4752h | 4752h | LTE_CA_B4_B28 | PCG-33 | Huawei | alf.ahlstrom@huawei.com | Rel-13 | RP-65 | CA | LTE_CA_B4_B28 |  |
| 974 | 297.11.1 | Core part: LTE Advanced inter-band Carrier Aggregation of Band 4 and Band 28 | 198d? | 2014-09-15 A | 2015-06-15 A | 100% | 2014-06-13 | 2015-03-13 | 196d? | finish no earlier than 2015-06-15 | R4 | 1584h | 1584h | LTE_CA_B4_B28-Core | PCG-33 | Huawei | alf.ahlstrom@huawei.com | Rel-13 | RP-65 | CA | LTE_CA_B4_B28-Core | RP-150536 |
| 975 | 297.11.2 | Perf. Part: LTE Advanced inter-band Carrier Aggregation of Band 4 and Band 28 | 198d? | 2014-09-15 A | 2015-06-15 A | 100% | 2014-06-13 | 2015-03-13 | 196d? | finish no earlier than 2015-06-15 | R4 | 1584h | 1584h | LTE_CA_B4_B28-Perf | PCG-33 | Huawei | alf.ahlstrom@huawei.com | Rel-13 | RP-65 | CA | LTE_CA_B4_B28-Perf | RP-150536 |
| 976 | 297.12 | **LTE Advanced inter-band Carrier Aggregation of Band 20 and Band 40** | 330d? | 2014-09-12 A | 2015-12-15 A | 100% | 2014-06-13 | 2015-03-13 | 196d? |  | R4 | 7912h | 7912h | LTE_CA_B20_B40 | PCG-33 | Ericsson | imadur.rahman@ericsson.com | Rel-13 | RP-65 | CA | LTE_CA_B20_B40 |  |
| 977 | 297.12.1 | Core part: LTE Advanced inter-band Carrier Aggregation of Band 20 and Band 40 | 330d? | 2014-09-12 A | 2015-12-15 A | 100% | 2014-06-13 | 2015-03-13 | 196d? | finish no earlier than 2015-12-15 | R4 | 2640h | 2640h | LTE_CA_B20_B40-Core | PCG-33 | Ericsson | imadur.rahman@ericsson.com | Rel-13 | RP-65 | CA | LTE_CA_B20_B40-Core | RP-151131 |
| 978 | 297.12.2 | Perf. Part: LTE Advanced inter-band Carrier Aggregation of Band 20 and Band 40 | 329d? | 2014-09-15 A | 2015-12-15 A | 100% | 2014-06-13 | 2015-03-13 | 196d? | finish no earlier than 2015-12-15 | R4 | 2632h | 2632h | LTE_CA_B20_B40-Perf | PCG-33 | Ericsson | imadur.rahman@ericsson.com | Rel-13 | RP-65 | CA | LTE_CA_B20_B40-Perf | RP-151131 |
| 979 | 297.13 | **LTE Advanced inter-band Carrier Aggregation of Band 1 and Band 40** | 329d? | 2014-09-15 A | 2015-12-15 A | 100% | 2014-06-13 | 2015-03-13 | 196d? |  | R4 | 7896h | 7896h | LTE_CA_B1_B40 | PCG-33 | KT | ilwhan.kim@kt.com | Rel-13 | RP-65 | CA | LTE_CA_B1_B40 |  |
| 980 | 297.13.1 | Core part: LTE Advanced inter-band Carrier Aggregation of Band 1 and Band 40 | 329d? | 2014-09-15 A | 2015-12-15 A | 100% | 2014-06-13 | 2015-03-13 | 196d? | finish no earlier than 2015-12-15 | R4 | 2632h | 2632h | LTE_CA_B1_B40-Core | PCG-33 | KT | ilwhan.kim@kt.com | Rel-13 | RP-65 | CA | LTE_CA_B1_B40-Core | RP-151131 |
| 981 | 297.13.2 | Perf. Part: LTE Advanced inter-band Carrier Aggregation of Band 1 and Band 40 | 329d? | 2014-09-15 A | 2015-12-15 A | 100% | 2014-06-13 | 2015-03-13 | 196d? | finish no earlier than 2015-12-15 | R4 | 2632h | 2632h | LTE_CA_B1_B40-Perf | PCG-33 | KT | ilwhan.kim@kt.com | Rel-13 | RP-65 | CA | LTE_CA_B1_B40-Perf | RP-151131 |

Notes:
- 958: Inter-band CA 3DL/1UL / Impacted TSs and TRs: LTE
- 959: CD:Thu 12/03/15->Sun 15/03/15; Compl:0%->40%; Stat Rep: RP-141084->RP-141732 1st Apr 15: Compl:40%->99% 1st Apr 15: CD:Sun 15/03/15->Mon 15/06/15 1st Apr 15: Stat Rep: RP-141732->RP-150013 03/07/15: Compl:99%->100% 03/07/15: Stat Rep: RP-150013->RP-150536 / Impacted TSs and TRs: 36.101, 36.104, 36.133, 36.141, 36.307, generic new Rel-13 TR36.8xy [similar to Rel-12 TR 36.853 (3 Band CA with 1UL)]
- 960: CD:Thu 18/06/15->Mon 15/06/15; Compl:0%->10%; Stat Rep: RP-141084->RP-141732 1st Apr 15: Compl:10%->99% 1st Apr 15: Stat Rep: RP-141732->RP-150013 03/07/15: Compl:99%->100% 03/07/15: Stat Rep: RP-150013->RP-150536 / Impacted TSs and TRs: 36.101, 36.104, 36.133, 36.141, 36.307
- 961: Inter-band CA 3DL/1UL / Impacted TSs and TRs: LTE
- 962: ; WID: RP-142043->RP-141832; Stat Rep: RP-141084->RP-141732 1st Apr 15: Compl:60%->99% 1st Apr 15: Stat Rep: RP-141732->RP-150013 03/07/15: Compl:99%->100% 03/07/15: WID: RP-141832->RP-150874 03/07/15: Stat Rep: RP-150013->RP-150536 / Impacted TSs and TRs: 36.101, 36.133, generic TR 36.853 (3 Band CA with 1UL)
- 963: ; WID: RP-142043->RP-141832; Stat Rep: RP-141084->RP-141732 1st Apr 15: Compl:0%->99% 1st Apr 15: Stat Rep: RP-141732->RP-150013 03/07/15: Compl:99%->100% 03/07/15: WID: RP-141832->RP-150874 03/07/15: Stat Rep: RP-150013->RP-150536 / Impacted TSs and TRs: 36.307
- 964: Inter-band CA 3DL/1UL / Impacted TSs and TRs: LTE
- 965: CD:Thu 11/12/14->Sun 15/03/15; Compl:30%->50%; Stat Rep: RP-141084->RP-141732 1st Apr 15: Compl:50%->60% 1st Apr 15: CD:Sun 15/03/15->Mon 15/06/15 1st Apr 15: Stat Rep: RP-141732->RP-150013 03/07/15: Compl:60%->100% 03/07/15: Stat Rep: RP-150013->RP-150536 / Impacted TSs and TRs: 36.101, 36.104, 36.133, generic TR 36.853 (3 Band CA with 1UL)
- 966: CD:Thu 11/12/14->Sun 15/03/15; Compl:0%->0%; Stat Rep: RP-141084->RP-141732 1st Apr 15: Compl:0%->60% 1st Apr 15: CD:Sun 15/03/15->Mon 15/06/15 1st Apr 15: Stat Rep: RP-141732->RP-150013 03/07/15: Compl:60%->100% 03/07/15: Stat Rep: RP-150013->RP-150536 / Impacted TSs and TRs: 36.141, 36.307
- 967: Inter-band CA 2DL/1UL / Impacted TSs and TRs: LTE
- 968: CD:Thu 11/12/14->Sun 15/03/15; Compl:0%->90%; Stat Rep: -->RP-141732 1st Apr 15: CD:Sun 15/03/15->Mon 15/06/15 1st Apr 15: Stat Rep: RP-141732->RP-150013 03/07/15: Compl:90%->100% 03/07/15: WID: RP-141129->RP-150717 03/07/15: Stat Rep: RP-150013->RP-150536 / Impacted TSs and TRs: 36.101, 36.104, New TR 36.8xx
- 969: CD:Thu 11/12/14->Sun 15/03/15; Compl:0%->90%; Stat Rep: -->RP-141732 1st Apr 15: CD:Sun 15/03/15->Mon 15/06/15 1st Apr 15: Stat Rep: RP-141732->RP-150013 03/07/15: Compl:90%->100% 03/07/15: WID: RP-141129->RP-150717 03/07/15: Stat Rep: RP-150013->RP-150536 / Impacted TSs and TRs: 36.141, 36.307
- 970: Inter-band CA 2DL/1UL / Impacted TSs and TRs: LTE
- 971: CD:Fri 11/12/15->Sun 15/03/15; Compl:0%->50%; Stat Rep: -->RP-141732 1st Apr 15: Compl:50%->99% 1st Apr 15: CD:Sun 15/03/15->Mon 15/06/15 1st Apr 15: Stat Rep: RP-141732->RP-150013 03/07/15: Compl:99%->100% 03/07/15: Stat Rep: RP-150013->RP-150536 / Impacted TSs and TRs: 36.101, 36.104, New TR 36.8xx
- 972: CD:Thu 12/03/15->Sun 15/03/15; Compl:0%->0%; Stat Rep: -->RP-141732 1st Apr 15: Compl:0%->99% 1st Apr 15: CD:Sun 15/03/15->Mon 15/06/15 1st Apr 15: Stat Rep: RP-141732->RP-150013 03/07/15: Compl:99%->100% 03/07/15: Stat Rep: RP-150013->RP-150536 / Impacted TSs and TRs: 36.141, 36.307
- 973: Inter-band CA 2DL/1UL / Impacted TSs and TRs: LTE
- 974: CD:Fri 11/12/15->Sun 15/03/15; Compl:0%->35%; Stat Rep: -->RP-141732 1st Apr 15: Compl:35%->99% 1st Apr 15: CD:Sun 15/03/15->Mon 15/06/15 1st Apr 15: Stat Rep: RP-141732->RP-150013 03/07/15: Compl:99%->100% 03/07/15: Stat Rep: RP-150013->RP-150536 / Impacted TSs and TRs: 36.101, 36.104, New TR 36.8xx
- 975: CD:Thu 12/03/15->Sun 15/03/15; Compl:0%->0%; Stat Rep: -->RP-141732 1st Apr 15: Compl:0%->99% 1st Apr 15: CD:Sun 15/03/15->Mon 15/06/15 1st Apr 15: Stat Rep: RP-141732->RP-150013 03/07/15: Compl:99%->100% 03/07/15: Stat Rep: RP-150013->RP-150536 / Impacted TSs and TRs: 36.141, 36.307
- 976: Inter-band CA 2DL/1UL / Impacted TSs and TRs: LTE
- 977: CD:Wed 11/03/15->Sun 15/03/15; Compl:0%->30%; Stat Rep: -->RP-141732 1st Apr 15: Compl:30%->70% 1st Apr 15: CD:Sun 15/03/15->Mon 15/06/15 1st Apr 15: Stat Rep: RP-141732->RP-150013 03/07/15: CD:Mon 15/06/15->Tue 15/09/15 03/07/15: Stat Rep: RP-150013->...; ; ; ; ; ; ; ; ; ; ; ; ; ; ; ; ; ; ; ; ; ; ; ; ; ; ; ; ; ; ; ; ; ; ; ; ; ; ; ; ; ; ; ; ; ; ; ; ; ; ; ; ; ; ; ; ; ; ; ; ; ; ; ; ; ; ; ; ; ; ; ; 1/1/16: Compl:75%->100% / Impacted TSs and TRs: 36.101, 36.104, 36.133, New TR 36.8xx
- 978: CD:Thu 12/03/15->Sun 15/03/15; Compl:0%->0%; Stat Rep: -->RP-141732 1st Apr 15: CD:Sun 15/03/15->Mon 15/06/15 1st Apr 15: Stat Rep: RP-141732->RP-150013 03/07/15: Compl:0%->70% 03/07/15: CD:Mon 15/06/15->Tue 15/09/15 03/07/15: Stat Rep: RP-150013->RP-1...; ; ; ; ; ; ; ; ; ; ; ; ; ; ; ; ; ; ; ; ; ; ; ; ; ; ; ; ; ; ; ; ; ; ; ; ; ; ; ; ; ; ; ; ; ; ; ; ; ; ; ; ; ; ; ; ; ; ; ; ; ; ; ; ; ; ; ; ; ; ; ; ; 1/1/16: Compl:75%->100% / Impacted TSs and TRs: 36.141, 36.307
- 979: Inter-band CA 2DL/1UL / Impacted TSs and TRs: LTE
- 980: CD:Fri 12/06/15->Mon 15/06/15; Compl:0%->70%; Stat Rep: -->RP-141732 1st Apr 15: Compl:70%->80% 1st Apr 15: Stat Rep: RP-141732->RP-150013 03/07/15: Compl:80%->70% 03/07/15: CD:Mon 15/06/15->Tue 15/12/15 03/07/15: Stat Rep: RP-150013->RP-150536 29/09/1...; ; ; ; ; ; ; ; ; ; ; ; ; ; ; ; ; ; ; ; ; ; ; ; ; ; ; ; ; ; ; ; ; ; ; ; ; ; ; ; ; ; ; ; ; ; ; ; ; ; ; ; ; ; ; ; ; ; ; ; ; ; ; ; ; ; 1/1/16: Compl:80%->100% / Impacted TSs and TRs: 36.101, 36.104, 36.133, New TR 36.8xx
- 981: CD:Fri 11/12/15->Mon 15/06/15; Compl:0%->70%; Stat Rep: -->RP-141732 1st Apr 15: Compl:70%->80% 1st Apr 15: Stat Rep: RP-141732->RP-150013 03/07/15: Compl:80%->70% 03/07/15: CD:Mon 15/06/15->Tue 15/12/15 03/07/15: Stat Rep: RP-150013->RP-150536 29/09/1...; ; ; ; ; ; ; ; ; ; ; ; ; ; ; ; ; ; ; ; ; ; ; ; ; ; ; ; ; ; ; ; ; ; ; ; ; ; ; ; ; ; ; ; ; ; ; ; ; ; ; ; ; ; ; ; ; ; ; ; ; ; ; ; ; ; ; 1/1/16: Compl:80%->100% / Impacted TSs and TRs: 36.141, 36.307

| ID | WBS | Task | Duration | Start | Finish | Complete | Baseline start | Baseline finish | Baseline duration | Constraint | Resources | Work | Actual work | Acronym | PCG approved | WI rapporteur name | WI rapporteur e-mail | Release | TSG approved | Special Focus Doc | Acronym_3GU_Export | Status Report |
| --- | --- | --- | --- | --- | --- | --- | --- | --- | --- | --- | --- | --- | --- | --- | --- | --- | --- | --- | --- | --- | --- | --- |
| 982 | 297.14 | **LTE Advanced inter-band Carrier Aggregation of Band 3 and Band 40** | 198d? | 2014-09-15 A | 2015-06-15 A | 100% | 2014-06-13 | 2015-03-13 | 196d? |  | R4 | 4752h | 4752h | LTE_CA_B3_B40 | PCG-33 | KT | Chungwoo HWANG (cwhwang@kt.com) | Rel-13 | RP-65 | CA | LTE_CA_B3_B40 |  |
| 983 | 297.14.1 | Core part: LTE Advanced inter-band Carrier Aggregation of Band 3 and Band 40 | 198d? | 2014-09-15 A | 2015-06-15 A | 100% | 2014-06-13 | 2015-03-13 | 196d? | finish no earlier than 2015-06-15 | R4 | 1584h | 1584h | LTE_CA_B3_B40-Core | PCG-33 | KT | Chungwoo HWANG (cwhwang@kt.com) | Rel-13 | RP-65 | CA | LTE_CA_B3_B40-Core | RP-150536 |
| 984 | 297.14.2 | Perf. Part: LTE Advanced inter-band Carrier Aggregation of Band 3 and Band 40 | 198d? | 2014-09-15 A | 2015-06-15 A | 100% | 2014-06-13 | 2015-03-13 | 196d? | finish no earlier than 2015-06-15 | R4 | 1584h | 1584h | LTE_CA_B3_B40-Perf | PCG-33 | KT | Chungwoo HWANG (cwhwang@kt.com) | Rel-13 | RP-65 | CA | LTE_CA_B3_B40-Perf | RP-150536 |
| 985 | 297.15 | **LTE Advanced inter-band Carrier Aggregation of Band 20 and Band 31** | 198d? | 2014-09-15 A | 2015-06-15 A | 100% | 2014-06-13 | 2015-03-13 | 196d? |  | R4 | 4752h | 4752h | LTE_CA_B20_B31 | PCG-33 | Huawei | Liu Liehai (liuliehai@huawei.com) | Rel-13 | RP-65 | CA | LTE_CA_B20_B31 |  |
| 986 | 297.15.1 | Core part: LTE Advanced inter-band Carrier Aggregation of Band 20 and Band 31 | 198d? | 2014-09-15 A | 2015-06-15 A | 100% | 2014-06-13 | 2015-03-13 | 196d? | finish no earlier than 2015-06-15 | R4 | 1584h | 1584h | LTE_CA_B20_B31-Core | PCG-33 | Huawei | Liu Liehai (liuliehai@huawei.com) | Rel-13 | RP-65 | CA | LTE_CA_B20_B31-Core | RP-150536 |
| 987 | 297.15.2 | Perf. Part: LTE Advanced inter-band Carrier Aggregation of Band 20 and Band 31 | 198d? | 2014-09-15 A | 2015-06-15 A | 100% | 2014-06-13 | 2015-03-13 | 196d? | finish no earlier than 2015-06-15 | R4 | 1584h | 1584h | LTE_CA_B20_B31-Perf | PCG-33 | Huawei | Liu Liehai (liuliehai@huawei.com) | Rel-13 | RP-65 | CA | LTE_CA_B20_B31-Perf | RP-150536 |
| 988 | 297.16 | **LTE Advanced inter-band Carrier Aggregation of Band 3 and Band 31** | 198d? | 2014-09-15 A | 2015-06-15 A | 100% | 2014-06-13 | 2015-03-13 | 196d? |  | R4 | 4752h | 4752h | LTE_CA_B3_B31 | PCG-33 | Huawei | Liu Liehai (liuliehai@huawei.com) | Rel-13 | RP-65 | CA | LTE_CA_B3_B31 |  |
| 989 | 297.16.1 | Core part: LTE Advanced inter-band Carrier Aggregation of Band 3 and Band 31 | 198d? | 2014-09-15 A | 2015-06-15 A | 100% | 2014-06-13 | 2015-03-13 | 196d? | finish no earlier than 2015-06-15 | R4 | 1584h | 1584h | LTE_CA_B3_B31-Core | PCG-33 | Huawei | Liu Liehai (liuliehai@huawei.com) | Rel-13 | RP-65 | CA | LTE_CA_B3_B31-Core | RP-150536 |
| 990 | 297.16.2 | Perf. Part: LTE Advanced inter-band Carrier Aggregation of Band 3 and Band 31 | 198d? | 2014-09-15 A | 2015-06-15 A | 100% | 2014-06-13 | 2015-03-13 | 196d? | finish no earlier than 2015-06-15 | R4 | 1584h | 1584h | LTE_CA_B3_B31-Perf | PCG-33 | Huawei | Liu Liehai (liuliehai@huawei.com) | Rel-13 | RP-65 | CA | LTE_CA_B3_B31-Perf | RP-150536 |
| 991 | 297.17 | **LTE Advanced inter-band Carrier Aggregation of Band 5 and Band 40** | 199d? | 2014-09-12 A | 2015-06-15 A | 100% | 2014-06-13 | 2015-03-13 | 196d? |  | R4 | 4768h | 4768h | LTE_CA_B5_B40 | PCG-33 | SK Telecom | haesung.park@sk.com | Rel-13 | RP-65 | CA | LTE_CA_B5_B40 |  |
| 992 | 297.17.1 | Core part: LTE Advanced inter-band Carrier Aggregation of Band 5 and Band 40 | 199d? | 2014-09-12 A | 2015-06-15 A | 100% | 2014-06-13 | 2015-03-13 | 196d? | finish no earlier than 2015-06-15 | R4 | 1592h | 1592h | LTE_CA_B5_B40-Core | PCG-33 | SK Telecom | haesung.park@sk.com | Rel-13 | RP-65 | CA | LTE_CA_B5_B40-Core | RP-150536 |
| 993 | 297.17.2 | Perf. Part: LTE Advanced inter-band Carrier Aggregation of Band 5 and Band 40 | 198d? | 2014-09-15 A | 2015-06-15 A | 100% | 2014-06-13 | 2015-03-13 | 196d? | finish no earlier than 2015-06-15 | R4 | 1584h | 1584h | LTE_CA_B5_B40-Perf | PCG-33 | SK Telecom | haesung.park@sk.com | Rel-13 | RP-65 | CA | LTE_CA_B5_B40-Perf | RP-150536 |
| 994 | 297.18 | **LTE Advanced intra-band contiguous Carrier Aggregation in Band 42 for 3DL** | 198d? | 2014-09-15 A | 2015-06-15 A | 100% | 2014-06-13 | 2015-03-13 | 196d? |  | R4 | 4752h | 4752h | LTE_CA_C_B42_3DL | PCG-33 | CATT | Yuexia Song (songyuexia@catt.cn) | Rel-13 | RP-65 | CA | LTE_CA_C_B42_3DL |  |
| 995 | 297.18.1 | Core part: LTE Advanced intra-band contiguous Carrier Aggregation in Band 42 for 3DL | 198d? | 2014-09-15 A | 2015-06-15 A | 100% | 2014-06-13 | 2015-03-13 | 196d? | finish no earlier than 2015-06-15 | R4 | 1584h | 1584h | LTE_CA_C_B42_3DL-Core | PCG-33 | CATT | Yuexia Song (songyuexia@catt.cn) | Rel-13 | RP-65 | CA | LTE_CA_C_B42_3DL-Core | RP-150536 |
| 996 | 297.18.2 | Perf. Part: LTE Advanced intra-band contiguous Carrier Aggregation in Band 42 for 3DL | 198d? | 2014-09-15 A | 2015-06-15 A | 100% | 2014-06-13 | 2015-03-13 | 196d? | finish no earlier than 2015-06-15 | R4 | 1584h | 1584h | LTE_CA_C_B42_3DL-Perf | PCG-33 | CATT | Yuexia Song (songyuexia@catt.cn) | Rel-13 | RP-65 | CA | LTE_CA_C_B42_3DL-Perf | RP-150536 |
| 997 | 297.19 | **LTE Advanced 3 Band Carrier Aggregation (3DL/1UL) of Band 8, Band 41 and Band 41** | 199d? | 2014-09-12 A | 2015-06-15 A | 100% | 2014-06-13 | 2015-03-13 | 196d? |  | R4 | 4768h | 4768h | LTE_CA_B8_B41_B41 | PCG-33 | China Mobile | PAN, Qun (panqun@chinamobile.com) | Rel-13 | RP-65 | CA | LTE_CA_B8_B41_B41 |  |
| 998 | 297.19.1 | Core part: LTE Advanced 3 Band Carrier Aggregation (3DL/1UL) of Band 8, Band 41 and Band 41 | 198d? | 2014-09-15 A | 2015-06-15 A | 100% | 2014-06-13 | 2015-03-13 | 196d? | finish no earlier than 2015-06-15 | R4 | 1584h | 1584h | LTE_CA_B8_B41_B41-Core | PCG-33 | China Mobile | PAN, Qun (panqun@chinamobile.com) | Rel-13 | RP-65 | CA | LTE_CA_B8_B41_B41-Core | RP-150536 |
| 999 | 297.19.2 | Perf. Part: LTE Advanced 3 Band Carrier Aggregation (3DL/1UL) of Band 8, Band 41 and Band 41 | 199d? | 2014-09-12 A | 2015-06-15 A | 100% | 2014-06-13 | 2015-03-13 | 196d? | finish no earlier than 2015-06-15 | R4 | 1592h | 1592h | LTE_CA_B8_B41_B41-Perf | PCG-33 | China Mobile | PAN, Qun (panqun@chinamobile.com) | Rel-13 | RP-65 | CA | LTE_CA_B8_B41_B41-Perf | RP-150536 |
| 1000 | 297.20 | **LTE Advanced 3 Band Carrier Aggregation (3DL/1UL) of Band 38, Band 40 and Band 40** | 198d? | 2014-09-15 A | 2015-06-15 A | 100% | 2014-06-13 | 2015-03-13 | 196d? |  | R4 | 4752h | 4752h | LTE_CA_B38_B40_B40 | PCG-33 | Samsung | xutao.zhou@samsung.com | Rel-13 | RP-65 | CA | LTE_CA_B38_B40_B40 |  |
| 1001 | 297.20.1 | Core part: LTE Advanced 3 Band Carrier Aggregation (3DL/1UL) of Band 38, Band 40 and Band 40 | 198d? | 2014-09-15 A | 2015-06-15 A | 100% | 2014-06-13 | 2015-03-13 | 196d? | finish no earlier than 2015-06-15 | R4 | 1584h | 1584h | LTE_CA_B38_B40_B40-Core | PCG-33 | Samsung | xutao.zhou@samsung.com | Rel-13 | RP-65 | CA | LTE_CA_B38_B40_B40-Core | RP-150536 |
| 1002 | 297.20.2 | Perf. Part: LTE Advanced 3 Band Carrier Aggregation (3DL/1UL) of Band 38, Band 40 and Band 40 | 198d? | 2014-09-15 A | 2015-06-15 A | 100% | 2014-06-13 | 2015-03-13 | 196d? | finish no earlier than 2015-06-15 | R4 | 1584h | 1584h | LTE_CA_B38_B40_B40-Perf | PCG-33 | Samsung | xutao.zhou@samsung.com | Rel-13 | RP-65 | CA | LTE_CA_B38_B40_B40-Perf | RP-150536 |
| 1003 | 297.21 | **LTE Advanced 3 Band Carrier Aggregation (3DL/1UL) of Band 2, Band 5 and Band 29** | 198d? | 2014-09-15 A | 2015-06-15 A | 100% | 2014-06-13 | 2015-03-13 | 196d? |  | R4 | 4752h | 4752h | LTE_CA_B2_B5_B29 | PCG-33 | Huawei | SHAN Huiping (shanhuiping@huawei.com) | Rel-13 | RP-65 | CA | LTE_CA_B2_B5_B29 |  |
| 1004 | 297.21.1 | Core part: LTE Advanced 3 Band Carrier Aggregation (3DL/1UL) of Band 2, Band 5 and Band 29 | 198d? | 2014-09-15 A | 2015-06-15 A | 100% | 2014-06-13 | 2015-03-13 | 196d? | finish no earlier than 2015-06-15 | R4 | 1584h | 1584h | LTE_CA_B2_B5_B29-Core | PCG-33 | Huawei | SHAN Huiping (shanhuiping@huawei.com) | Rel-13 | RP-65 | CA | LTE_CA_B2_B5_B29-Core | RP-150536 |
| 1005 | 297.21.2 | Perf. Part: LTE Advanced 3 Band Carrier Aggregation (3DL/1UL) of Band 2, Band 5 and Band 29 | 198d? | 2014-09-15 A | 2015-06-15 A | 100% | 2014-06-13 | 2015-03-13 | 196d? | finish no earlier than 2015-06-15 | R4 | 1584h | 1584h | LTE_CA_B2_B5_B29-Perf | PCG-33 | Huawei | SHAN Huiping (shanhuiping@huawei.com) | Rel-13 | RP-65 | CA | LTE_CA_B2_B5_B29-Perf | RP-150536 |

Notes:
- 982: Inter-band CA 2DL/1UL / Impacted TSs and TRs: LTE
- 983: CD:Fri 11/12/15->Mon 15/06/15; Compl:0%->70%; Stat Rep: -->RP-141732 1st Apr 15: Compl:70%->80% 1st Apr 15: Stat Rep: RP-141732->RP-150013 03/07/15: Compl:80%->100% 03/07/15: WID: RP-141674->RP-150832 03/07/15: Stat Rep: RP-150013->RP-150536 / Impacted TSs and TRs: 36.101, 36.104, 36.133, New TR 36.8xx
- 984: CD:Fri 12/06/15->Mon 15/06/15; Compl:0%->70%; Stat Rep: -->RP-141732 1st Apr 15: Compl:70%->80% 1st Apr 15: Stat Rep: RP-141732->RP-150013 03/07/15: Compl:80%->100% 03/07/15: WID: RP-141674->RP-150832 03/07/15: Stat Rep: RP-150013->RP-150536 / Impacted TSs and TRs: 36.141, 36.307
- 985: Inter-band CA 2DL/1UL / Impacted TSs and TRs: LTE
- 986: ; WID: RP-142043->RP-142007; Stat Rep: -->RP-141732 1st Apr 15: Compl:75%->99% 1st Apr 15: CD:Sun 15/03/15->Mon 15/06/15 1st Apr 15: Stat Rep: RP-141732->RP-150013 03/07/15: Compl:99%->100% 03/07/15: Stat Rep: RP-150013->RP-150536 / Impacted TSs and TRs: 36.101, 36.104, New TR 36.8xx
- 987: ; WID: RP-142043->RP-142007; Stat Rep: -->RP-141732 1st Apr 15: Compl:0%->99% 1st Apr 15: CD:Sun 15/03/15->Mon 15/06/15 1st Apr 15: Stat Rep: RP-141732->RP-150013 03/07/15: Compl:99%->100% 03/07/15: Stat Rep: RP-150013->RP-150536 / Impacted TSs and TRs: 36.141, 36.307
- 988: Inter-band CA 2DL/1UL / Impacted TSs and TRs: LTE
- 989: CD:Fri 11/12/15->Sun 15/03/15; Compl:0%->50%; Stat Rep: -->RP-141732 1st Apr 15: Compl:50%->75% 1st Apr 15: CD:Sun 15/03/15->Mon 15/06/15 1st Apr 15: WID: RP-141337->RP-150318 1st Apr 15: Stat Rep: RP-141732->RP-150013 03/07/15: Compl:75%->100% 03/07/15: Stat Rep: RP-150013->RP-150536 / Impacted TSs and TRs: 36.101, 36.104, New TR 36.8xx
- 990: CD:Thu 12/03/15->Sun 15/03/15; Compl:0%->0%; Stat Rep: -->RP-141732 1st Apr 15: CD:Sun 15/03/15->Mon 15/06/15 1st Apr 15: WID: RP-141337->RP-150318 1st Apr 15: Stat Rep: RP-141732->RP-150013 03/07/15: Compl:0%->100% 03/07/15: Stat Rep: RP-150013->RP-150536 / Impacted TSs and TRs: 36.141, 36.307
- 991: Inter-band CA 2DL/1UL / Impacted TSs and TRs: LTE
- 992: ; WID: RP-142043->RP-141888; Stat Rep: -->RP-141732 1st Apr 15: Compl:0%->80% 1st Apr 15: WID: RP-141888->RP-150285 1st Apr 15: Stat Rep: RP-141732->RP-150013 03/07/15: Compl:80%->100% 03/07/15: Stat Rep: RP-150013->RP-150536 / Impacted TSs and TRs: 36.101, 36.104, New TR 36.8xx
- 993: ; WID: RP-142043->RP-141888; Stat Rep: -->RP-141732 1st Apr 15: Compl:0%->80% 1st Apr 15: WID: RP-141888->RP-150285 1st Apr 15: Stat Rep: RP-141732->RP-150013 03/07/15: Compl:80%->100% 03/07/15: Stat Rep: RP-150013->RP-150536 / Impacted TSs and TRs: 36.141, 36.307
- 994: Intra-band contig. CA 3DL / Impacted TSs and TRs: LTE
- 995: CD:Fri 12/06/15->Mon 15/06/15; Compl:0%->70%; Stat Rep: -->RP-141732 1st Apr 15: Compl:70%->99% 1st Apr 15: WID: RP-141677->RP-150319 1st Apr 15: Stat Rep: RP-141732->RP-150013 03/07/15: Compl:99%->100% 03/07/15: WID: RP-150319->RP-151027 03/07/15: Stat Rep: RP-150013->RP-150536 / Impacted TSs and TRs: 36.101, 36.104, 36.133, New TR 36.833-5-42
- 996: CD:Fri 12/06/15->Mon 15/06/15; Compl:0%->0%; Stat Rep: -->RP-141732 1st Apr 15: Compl:0%->99% 1st Apr 15: WID: RP-141677->RP-150319 1st Apr 15: Stat Rep: RP-141732->RP-150013 03/07/15: Compl:99%->100% 03/07/15: WID: RP-150319->RP-151027 03/07/15: Stat Rep: RP-150013->RP-150536 / Impacted TSs and TRs: 36.141, 36.307
- 997: Inter-band CA 3DL/1UL / Impacted TSs and TRs: LTE
- 998: ; WID: RP-142043->RP-141845; Stat Rep: -->RP-141732 1st Apr 15: Compl:80%->99% 1st Apr 15: CD:Sun 15/03/15->Mon 15/06/15 1st Apr 15: Stat Rep: RP-141732->RP-150013 03/07/15: Compl:99%->100% 03/07/15: Stat Rep: RP-150013->RP-150536 / Impacted TSs and TRs: 36.101, 36.104, 36.133, New TR 36.8xx
- 999: ; WID: RP-142043->RP-141845; Stat Rep: -->RP-141732 1st Apr 15: Compl:0%->99% 1st Apr 15: CD:Sun 15/03/15->Mon 15/06/15 1st Apr 15: Stat Rep: RP-141732->RP-150013 03/07/15: Compl:99%->100% 03/07/15: Stat Rep: RP-150013->RP-150536 / Impacted TSs and TRs: 36.141, 36.307
- 1000: Inter-band CA 3DL/1UL / Impacted TSs and TRs: LTE
- 1001: CD:Fri 12/06/15->Mon 15/06/15; Compl:0%->0%; Stat Rep: -->RP-141732 1st Apr 15: Compl:0%->70% 1st Apr 15: Stat Rep: RP-141732->RP-150013 03/07/15: Compl:70%->100% 03/07/15: Stat Rep: RP-150013->RP-150536 / Impacted TSs and TRs: 36.101, 36.104, 36.133, New TR 36.8xx
- 1002: CD:Fri 12/06/15->Mon 15/06/15; Compl:0%->0%; Stat Rep: -->RP-141732 1st Apr 15: Compl:0%->70% 1st Apr 15: Stat Rep: RP-141732->RP-150013 03/07/15: Compl:70%->100% 03/07/15: Stat Rep: RP-150013->RP-150536 / Impacted TSs and TRs: 36.141, 36.307
- 1003: Inter-band CA 3DL/1UL / Impacted TSs and TRs: LTE
- 1004: CD:Fri 11/12/15->Mon 15/06/15; Compl:0%->50%; Stat Rep: -->RP-141732 1st Apr 15: Compl:50%->99% 1st Apr 15: Stat Rep: RP-141732->RP-150013 03/07/15: Compl:99%->100% 03/07/15: Stat Rep: RP-150013->RP-150536 / Impacted TSs and TRs: 36.101, 36.104, 36.133, New TR 36.8xy (inter-band CA 2DL/1UL (introduce CA_B5-B29), New TR 36.8xz (inter-band CA 3DL/1UL)
- 1005: CD:Fri 12/06/15->Mon 15/06/15; Compl:0%->0%; Stat Rep: -->RP-141732 1st Apr 15: Compl:0%->99% 1st Apr 15: Stat Rep: RP-141732->RP-150013 03/07/15: Compl:99%->100% 03/07/15: Stat Rep: RP-150013->RP-150536 / Impacted TSs and TRs: 36.141, 36.307

| ID | WBS | Task | Duration | Start | Finish | Complete | Remaining | Total slack | Constraint | Resources | Work | Actual work | Acronym | PCG approved | WI rapporteur name | WI rapporteur e-mail | Release | TSG approved | Status Report |
| --- | --- | --- | --- | --- | --- | --- | --- | --- | --- | --- | --- | --- | --- | --- | --- | --- | --- | --- | --- |
| 1006 | 297.22 | **LTE Carrier Aggregation Enhancement Beyond 5 Carriers** | 721d? | 2014-12-15 A | 2017-09-15 | 71% | 206d? | 151d |  | R1 | 13104h | 8384h | LTE_CA_enh_b5C | PCG-34 | Nokia Networks | Nokia | Rel-13 | RP-66 |  |
| 1007 | 297.22.1 | Core part: LTE Carrier Aggregation Enhancement Beyond 5 Carriers | 262d? | 2014-12-15 A | 2015-12-15 A | 100% |  |  | finish no earlier than 2015-12-15 | R1 | 2096h | 2096h | LTE_CA_enh_b5C-Core | PCG-34 | Nokia Networks | Nokia | Rel-13 | RP-66 | RP-151285 |
| 1008 | 297.22.2 | Perf. part: LTE Carrier Aggregation Enhancement Beyond 5 Carriers | 393d? | 2014-12-15 A | 2016-06-15 A | 100% |  |  | finish no earlier than 2016-06-15 | R4 | 3144h | 3144h | LTE_CA_enh_b5C-Perf | PCG-34 | Nokia Networks | Nokia | Rel-13 | RP-66 | RP-151285 |
| 1009 | 297.22.3 | UE Conformance Test Aspects - LTE Carrier Aggregation Enhancement Beyond 5 Carriers: PUCCH on Scell | 262d? | 2016-09-15 | 2017-09-15 |  |  | 151d | finish no earlier than 2017-09-15 | R5 | 2096h |  | LTE_CA_enh_b5C_PUCCH-UEConTest |  | Huawei |  | Rel-13 | TSG-66 |  |
| 1010 | 297.23 | **HSPA Dual-Band UL carrier aggregation** | 327d? | 2014-12-15 A | 2016-03-15 A | 100% |  |  |  | R4 | 7328h | 7328h | HSUPA_DB_MC | PCG-34 | Qualcomm | Qualcomm | Rel-13 | RP-66 |  |
| 1011 | 297.23.1 | Core part: HSPA Dual-Band UL carrier aggregation | 262d? | 2014-12-15 A | 2015-12-15 A | 100% |  |  | finish no earlier than 2015-12-15 | R4 | 2096h | 2096h | HSUPA_DB_MC-Core | PCG-34 | Qualcomm | Qualcomm | Rel-13 | RP-66 | RP-151281 |
| 1012 | 297.23.2 | Perf. part: HSPA Dual-Band UL carrier aggregation | 327d? | 2014-12-15 A | 2016-03-15 A | 100% |  |  | finish no earlier than 2016-03-15 | R4 | 2616h | 2616h | HSUPA_DB_MC-Perf | PCG-34 | Qualcomm | Qualcomm | Rel-13 | RP-66 | RP-151281 |
| 1013 | 297.24 | **LTE Advanced inter-band Carrier Aggregation of Band 25 and Band 26** | 131d? | 2014-12-15 A | 2015-06-15 A | 100% |  |  |  | R4 | 3144h | 3144h | LTE_CA_B25_B26 | PCG-34 | Sprint | Sprint | Rel-13 | RP-66 |  |
| 1014 | 297.24.1 | Core part: LTE Advanced inter-band Carrier Aggregation of Band 25 and Band 26 | 131d? | 2014-12-15 A | 2015-06-15 A | 100% |  |  | finish no earlier than 2015-06-15 | R4 | 1048h | 1048h | LTE_CA_B25_B26-Core | PCG-34 | Sprint | Sprint | Rel-13 | RP-66 | RP-150536 |
| 1015 | 297.24.2 | Perf. part: LTE Advanced inter-band Carrier Aggregation of Band 25 and Band 26 | 131d? | 2014-12-15 A | 2015-06-15 A | 100% |  |  | finish no earlier than 2015-06-15 | R4 | 1048h | 1048h | LTE_CA_B25_B26-Perf | PCG-34 | Sprint | Sprint | Rel-13 | RP-66 | RP-150536 |
| 1016 | 297.25 | **LTE Advanced inter-band Carrier Aggregation of Band 3 and Band 41** | 262d? | 2014-12-15 A | 2015-12-15 A | 100% |  |  |  | R4 | 6288h | 6288h | LTE_CA_B3_B41 | PCG-34 | China Telecom | China Telecom | Rel-13 | RP-66 |  |
| 1017 | 297.25.1 | Core part: LTE Advanced inter-band Carrier Aggregation of Band 3 and Band 41 | 262d? | 2014-12-15 A | 2015-12-15 A | 100% |  |  | finish no earlier than 2015-12-15 | R4 | 2096h | 2096h | LTE_CA_B3_B41-Core | PCG-34 | China Telecom | China Telecom | Rel-13 | RP-66 | RP-151131 |
| 1018 | 297.25.2 | Perf. part: LTE Advanced inter-band Carrier Aggregation of Band 3 and Band 41 | 262d? | 2014-12-15 A | 2015-12-15 A | 100% |  |  | finish no earlier than 2015-12-15 | R4 | 2096h | 2096h | LTE_CA_B3_B41-Perf | PCG-34 | China Telecom | China Telecom | Rel-13 | RP-66 | RP-151131 |
| 1019 | 297.26 | **LTE Advanced 3 band Carrier Aggregation (3DL/1UL) of Band 1, Band 3 and Band 3** | 197d? | 2014-12-15 A | 2015-09-15 A | 100% |  |  |  | R4 | 4728h | 4728h | LTE_CA_B1_B3_B3 | PCG-34 | China Unicom | China Unicom | Rel-13 | RP-66 |  |
| 1020 | 297.26.1 | Core part: LTE Advanced 3 band Carrier Aggregation (3DL/1UL) of Band 1, Band 3 and Band 3 | 197d? | 2014-12-15 A | 2015-09-15 A | 100% |  |  | finish no earlier than 2015-09-15 | R4 | 1576h | 1576h | LTE_CA_B1_B3_B3-Core | PCG-34 | China Unicom | China Unicom | Rel-13 | RP-66 | RP-151131 |
| 1021 | 297.26.2 | Perf. part: LTE Advanced 3 band Carrier Aggregation (3DL/1UL) of Band 1, Band 3 and Band 3 | 197d? | 2014-12-15 A | 2015-09-15 A | 100% |  |  | finish no earlier than 2015-09-15 | R4 | 1576h | 1576h | LTE_CA_B1_B3_B3-Perf | PCG-34 | China Unicom | China Unicom | Rel-13 | RP-66 | RP-151131 |
| 1022 | 297.27 | **LTE Advanced 3 Band Carrier Aggregation (3DL/1UL) of Band 1, Band 19 and Band 28** | 197d? | 2014-12-15 A | 2015-09-15 A | 100% |  |  |  | R4 | 4728h | 4728h | LTE_CA_B1_B19_B28 | PCG-34 | NTT DOCOMO | NTT DOCOMO | Rel-13 | RP-66 |  |
| 1023 | 297.27.1 | Core part: LTE Advanced 3 Band Carrier Aggregation (3DL/1UL) of Band 1, Band 19 and Band 28 | 197d? | 2014-12-15 A | 2015-09-15 A | 100% |  |  | finish no earlier than 2015-09-15 | R4 | 1576h | 1576h | LTE_CA_B1_B19_B28-Core | PCG-34 | NTT DOCOMO | NTT DOCOMO | Rel-13 | RP-66 | RP-151131 |
| 1024 | 297.27.2 | Perf. part: LTE Advanced 3 Band Carrier Aggregation (3DL/1UL) of Band 1, Band 19 and Band 28 | 197d? | 2014-12-15 A | 2015-09-15 A | 100% |  |  | finish no earlier than 2015-09-15 | R4 | 1576h | 1576h | LTE_CA_B1_B19_B28-Perf | PCG-34 | NTT DOCOMO | NTT DOCOMO | Rel-13 | RP-66 | RP-151131 |
| 1025 | 297.28 | **LTE Advanced 3 Band Carrier Aggregation (3DL/1UL) of Band 21, Band 42 and Band 42** | 131d? | 2014-12-15 A | 2015-06-15 A | 100% |  |  |  | R4 | 3144h | 3144h | LTE_CA_B21_B42_B42 | PCG-34 | NTT DOCOMO | NTT DOCOMO | Rel-13 | RP-66 |  |
| 1026 | 297.28.1 | Core part: LTE Advanced 3 Band Carrier Aggregation (3DL/1UL) of Band 21, Band 42 and Band 42 | 131d? | 2014-12-15 A | 2015-06-15 A | 100% |  |  | finish no earlier than 2015-06-15 | R4 | 1048h | 1048h | LTE_CA_B21_B42_B42-Core | PCG-34 | NTT DOCOMO | NTT DOCOMO | Rel-13 | RP-66 | RP-150536 |
| 1027 | 297.28.2 | Perf. part: LTE Advanced 3 Band Carrier Aggregation (3DL/1UL) of Band 21, Band 42 and Band 42 | 131d? | 2014-12-15 A | 2015-06-15 A | 100% |  |  | finish no earlier than 2015-06-15 | R4 | 1048h | 1048h | LTE_CA_B21_B42_B42-Perf | PCG-34 | NTT DOCOMO | NTT DOCOMO | Rel-13 | RP-66 | RP-150536 |
| 1028 | 297.29 | **LTE Advanced 3 Band Carrier Aggregation (3DL/1UL) of Band 7, Band 40 and Band 40** | 197d? | 2014-12-15 A | 2015-09-15 A | 100% |  |  |  | R4 | 4728h | 4728h | LTE_CA_B7_B40_B40 | PCG-34 | ZTE | ZTE | Rel-13 | RP-66 |  |
| 1029 | 297.29.1 | Core part: LTE Advanced 3 Band Carrier Aggregation (3DL/1UL) of Band 7, Band 40 and Band 40 | 197d? | 2014-12-15 A | 2015-09-15 A | 100% |  |  | finish no earlier than 2015-09-15 | R4 | 1576h | 1576h | LTE_CA_B7_B40_B40-Core | PCG-34 | ZTE | ZTE | Rel-13 | RP-66 | RP-151131 |
| 1030 | 297.29.2 | Perf. part: LTE Advanced 3 Band Carrier Aggregation (3DL/1UL) of Band 7, Band 40 and Band 40 | 197d? | 2014-12-15 A | 2015-09-15 A | 100% |  |  | finish no earlier than 2015-09-15 | R4 | 1576h | 1576h | LTE_CA_B7_B40_B40-Perf | PCG-34 | ZTE | ZTE | Rel-13 | RP-66 | RP-151131 |

Notes:
- 1006: FCD: 06/16->12/15, Rel-14?->Rel-13
- 1007: FCD: 06/16->12/15, Rel-14?->Rel-13 1st Apr 15: Compl:0%->10% 1st Apr 15: WID: RP-142286->RP-150277 1st Apr 15: Stat Rep: ->RP-150272 03/07/15: Compl:10%->40% 03/07/15: WID: RP-150277->RP-150771 03/07/15: Stat Rep: RP-150272->RP-150769 29/09/15: Compl:4...; ; ; ; ; ; ; ; ; ; ; ; ; ; ; ; ; ; ; ; ; ; ; ; ; ; ; ; ; ; ; ; ; ; ; ; ; ; ; ; ; 1/1/16: Compl:60%->100%; ; ; ; ; ; ; ; ; ; ; ; ; ; ; ; ; ; ; ; ; ; ; ; ; ; ; ; ; ; ; ; ; ; ; ; ; ; ; ; ; 1/1/16: WID: RP-150771->RP-151984
- 1008: 1st Apr 15: WID: RP-142286->RP-150277 1st Apr 15: Stat Rep: ->RP-150272 03/07/15: WID: RP-150277->RP-150771 03/07/15: Stat Rep: RP-150272->RP-150769 29/09/15: Stat Rep: RP-150769->RP-151285; ...22/3/16: ...;...
- 1011: 1st Apr 15: Compl:0%->10% 1st Apr 15: WID: RP-142237->RP-150129 1st Apr 15: Stat Rep: ->RP-150127 03/07/15: Compl:10%->40% 03/07/15: Stat Rep: RP-150127->RP-150761 29/09/15: Compl:40%->50% 29/09/15: Stat Rep: RP-150761->RP-151281; ...
- 1012: 1st Apr 15: WID: RP-142237->RP-150129 1st Apr 15: Stat Rep: ->RP-150127 03/07/15: Stat Rep: RP-150127->RP-150761 29/09/15: Stat Rep: RP-150761->RP-1512811/1/16: Compl:0%->90% ; ...
- 1014: 1st Apr 15: Compl:0%->95% 1st Apr 15: CD:Tue 15/12/15->Mon 15/06/15 1st Apr 15: WID: RP-142020->RP-150115 1st Apr 15: Stat Rep: ->RP-150013 03/07/15: Compl:95%->100% 03/07/15: Stat Rep: RP-150013->RP-150536
- 1015: 1st Apr 15: Compl:0%->95% 1st Apr 15: CD:Tue 15/12/15->Mon 15/06/15 1st Apr 15: WID: RP-142020->RP-150115 1st Apr 15: Stat Rep: ->RP-150013 03/07/15: Compl:95%->100% 03/07/15: Stat Rep: RP-150013->RP-150536
- 1017: 1st Apr 15: Compl:0%->20% 1st Apr 15: Stat Rep: ->RP-150013 03/07/15: Compl:20%->65% 03/07/15: Stat Rep: RP-150013->RP-150536 29/09/15: CD:Tue 15/09/15->Tue 15/12/15 29/09/15: WID: RP-142239->RP-151446 29/09/15: Stat Rep: RP-150536->RP-151131; 29/09/1...; ; ; ; ; ; ; ; ; ; ; ; ; ; ; ; ; ; ; ; ; ; ; ; ; ; ; ; ; ; ; ; ; ; ; ; ; ; ; ; ; ; ; ; ; ; ; ; ; ; ; ; ; ; ; ; ; ; ; ; ; ; ; ; ; ; ; ; 1/1/16: Compl:95%->100%
- 1018: 1st Apr 15: Compl:0%->20% 1st Apr 15: Stat Rep: ->RP-150013 03/07/15: Compl:20%->65% 03/07/15: Stat Rep: RP-150013->RP-150536 29/09/15: CD:Tue 15/09/15->Tue 15/12/15 29/09/15: WID: RP-142239->RP-151446 29/09/15: Stat Rep: RP-150536->RP-151131; 29/09/1...; ; ; ; ; ; ; ; ; ; ; ; ; ; ; ; ; ; ; ; ; ; ; ; ; ; ; ; ; ; ; ; ; ; ; ; ; ; ; ; ; ; ; ; ; ; ; ; ; ; ; ; ; ; ; ; ; ; ; ; ; ; ; ; ; ; ; ; ; 1/1/16: Compl:95%->100%
- 1020: 1st Apr 15: Compl:0%->50% 1st Apr 15: Stat Rep: ->RP-150013 03/07/15: Compl:50%->90% 03/07/15: CD:Mon 15/06/15->Tue 15/09/15 03/07/15: Stat Rep: RP-150013->RP-150536 29/09/15: Compl:90%->100% 29/09/15: Stat Rep: RP-150536->RP-151131
- 1021: 03/07/15: Compl:0%->90% 03/07/15: CD:Mon 15/06/15->Tue 15/09/15 03/07/15: Stat Rep: ->RP-150536 29/09/15: Compl:90%->100% 29/09/15: Stat Rep: RP-150536->RP-151131
- 1023: 1st Apr 15: Compl:0%->50% 1st Apr 15: Stat Rep: ->RP-150013 03/07/15: Compl:50%->90% 03/07/15: CD:Mon 15/06/15->Tue 15/09/15 03/07/15: WID: RP-141791->RP-150639 03/07/15: Stat Rep: RP-150013->RP-150536 29/09/15: Compl:90%->100% 29/09/15: Stat Rep: RP-150536->RP-151131
- 1024: 03/07/15: CD:Mon 15/06/15->Tue 15/09/15 03/07/15: WID: RP-141791->RP-150639 03/07/15: Stat Rep: ->RP-150536 29/09/15: Compl:0%->100% 29/09/15: Stat Rep: RP-150536->RP-151131
- 1026: 1st Apr 15: Compl:0%->90% 1st Apr 15: Stat Rep: ->RP-150013 03/07/15: Compl:90%->100% 03/07/15: WID: RP-141792->RP-150640 03/07/15: Stat Rep: RP-150013->RP-150536
- 1027: 03/07/15: Compl:0%->100% 03/07/15: WID: RP-141792->RP-150640 03/07/15: Stat Rep: ->RP-150536
- 1029: 1st Apr 15: Compl:0%->40% 1st Apr 15: Stat Rep: ->RP-150013 03/07/15: Compl:40%->75% 03/07/15: CD:Mon 15/06/15->Tue 15/09/15 03/07/15: WID: RP-141802->RP-150614 03/07/15: Stat Rep: RP-150013->RP-150536 29/09/15: Compl:75%->100% 29/09/15: Stat Rep: RP-150536->RP-151131
- 1030: 1st Apr 15: Compl:0%->40% 1st Apr 15: Stat Rep: ->RP-150013 03/07/15: Compl:40%->75% 03/07/15: CD:Mon 15/06/15->Tue 15/09/15 03/07/15: WID: RP-141802->RP-150614 03/07/15: Stat Rep: RP-150013->RP-150536 29/09/15: Compl:75%->100% 29/09/15: Stat Rep: RP-150536->RP-151131

| ID | WBS | Task | Duration | Start | Finish | Complete | Remaining | Total slack | Constraint | Resources | Work | Actual work | Acronym | PCG approved | WI rapporteur name | WI rapporteur e-mail | Release | TSG approved | Status Report |
| --- | --- | --- | --- | --- | --- | --- | --- | --- | --- | --- | --- | --- | --- | --- | --- | --- | --- | --- | --- |
| 1031 | 297.30 | **LTE Advanced 3 band Carrier Aggregation (3DL/1UL) of Band 1, Band 8 and Band 28** | 327d? | 2014-12-15 A | 2016-03-15 | 40% | 196.2d? | 545d |  | R4 | 7848h | 2723.2h | LTE_CA_B1_B8_B28 | PCG-34 | Softbank Mobile | Softbank Mobile | Rel-13 | RP-66 |  |
| 1032 | 297.30.1 | Core part: LTE Advanced 3 band Carrier Aggregation (3DL/1UL) of Band 1, Band 8 and Band 28 | 327d? | 2014-12-15 A | 2016-03-15 | 40% | 196.2d? | 545d | finish no earlier than 2016-03-15 | R4 | 2616h | 1046.4h | LTE_CA_B1_B8_B28-Core | PCG-34 | Softbank Mobile | Softbank Mobile | Rel-13 | RP-66 | RP-151131 |
| 1033 | 297.30.2 | Perf. part: LTE Advanced 3 band Carrier Aggregation (3DL/1UL) of Band 1, Band 8 and Band 28 | 327d? | 2014-12-15 A | 2016-03-15 | 40% | 196.2d? | 545d | finish no earlier than 2016-03-15 | R4 | 2616h | 1046.4h | LTE_CA_B1_B8_B28-Perf | PCG-34 | Softbank Mobile | Softbank Mobile | Rel-13 | RP-66 | RP-151131 |
| 1034 | 297.31 | **LTE Advanced 3 Band Carrier Aggregation (3DL/1UL) of Band 3, Band 7 and Band 7** | 131d? | 2014-12-15 A | 2015-06-15 A | 100% |  |  |  | R4 | 3144h | 3144h | LTE_CA_B3_B7_B7_Bwset | PCG-34 | Ericsson | Ericsson | Rel-13 | RP-66 |  |
| 1035 | 297.31.1 | Core part: Additional bandwidth combination set for LTE Advanced 3 Band Carrier Aggregation (3DL/1UL) of Band 3, Band 7 and Band 7 | 131d? | 2014-12-15 A | 2015-06-15 A | 100% |  |  | finish no earlier than 2015-06-15 | R4 | 1048h | 1048h | LTE_CA_B3_B7_B7_Bwset-Core | PCG-34 | Ericsson | Ericsson | Rel-13 | RP-66 | RP-150536 |
| 1036 | 297.31.2 | Perf. Part: Additional bandwidth combination set for LTE Advanced 3 Band Carrier Aggregation (3DL/1UL) of Band 3, Band 7 and Band 7 | 131d? | 2014-12-15 A | 2015-06-15 A | 100% |  |  | finish no earlier than 2015-06-15 | R4 | 1048h | 1048h | LTE_CA_B3_B7_B7_BWset-Perf | PCG-34 | Ericsson | Ericsson | Rel-13 | RP-66 | RP-150536 |
| 1037 | 297.32 | **LTE Advanced 3 Band Carrier Aggregation (3DL/1UL) of Band 7, Band 7 and Band 28** | 131d? | 2014-12-15 A | 2015-06-15 A | 100% |  |  |  | R4 | 3144h | 3144h | LTE_CA_B7_B7_B28 | PCG-34 | Ericsson | Ericsson | Rel-13 | RP-66 |  |
| 1038 | 297.32.1 | Core part: LTE Advanced 3 Band Carrier Aggregation (3DL/1UL) of Band 7, Band 7 and Band 28 | 131d? | 2014-12-15 A | 2015-06-15 A | 100% |  |  | finish no earlier than 2015-06-15 | R4 | 1048h | 1048h | LTE_CA_B7_B7_B28-Core | PCG-34 | Ericsson | Ericsson | Rel-13 | RP-66 | RP-150536 |
| 1039 | 297.32.2 | Perf. part: LTE Advanced 3 Band Carrier Aggregation (3DL/1UL) of Band 7, Band 7 and Band 28 | 131d? | 2014-12-15 A | 2015-06-15 A | 100% |  |  | finish no earlier than 2015-06-15 | R4 | 1048h | 1048h | LTE_CA_B7_B7_B28-Perf | PCG-34 | Ericsson | Ericsson | Rel-13 | RP-66 | RP-150536 |
| 1040 | 297.33 | **LTE Advanced 3 band Carrier Aggregation (3DL/1UL) of Band 1, Band 3 and Band 40** | 262d? | 2014-12-15 A | 2015-12-15 A | 100% |  |  |  | R4 | 6288h | 6288h | LTE_CA_B1_B3_B40 | PCG-34 | KT | KT | Rel-13 | RP-66 |  |
| 1041 | 297.33.1 | Core part: LTE Advanced 3 band Carrier Aggregation (3DL/1UL) of Band 1, Band 3 and Band 40 | 262d? | 2014-12-15 A | 2015-12-15 A | 100% |  |  | finish no earlier than 2015-12-15 | R4 | 2096h | 2096h | LTE_CA_B1_B3_B40-Core | PCG-34 | KT | KT | Rel-13 | RP-66 | RP-151131 |
| 1042 | 297.33.2 | Perf. part: LTE Advanced 3 band Carrier Aggregation (3DL/1UL) of Band 1, Band 3 and Band 40 | 262d? | 2014-12-15 A | 2015-12-15 A | 100% |  |  | finish no earlier than 2015-12-15 | R4 | 2096h | 2096h | LTE_CA_B1_B3_B40-Perf | PCG-34 | KT | KT | Rel-13 | RP-66 | RP-151131 |
| 1043 | 297.34 | **LTE Advanced 3 band Carrier Aggregation (3DL/1UL) of Band 1, Band 8 and Band 40** | 262d? | 2014-12-15 A | 2015-12-15 A | 100% |  |  |  | R4 | 6288h | 6288h | LTE_CA_B1_B8_B40 | PCG-34 | KT | KT | Rel-13 | RP-66 |  |
| 1044 | 297.34.1 | Core part: LTE Advanced 3 band Carrier Aggregation (3DL/1UL) of Band 1, Band 8 and Band 40 | 262d? | 2014-12-15 A | 2015-12-15 A | 100% |  |  | finish no earlier than 2015-12-15 | R4 | 2096h | 2096h | LTE_CA_B1_B8_B40-Core | PCG-34 | KT | KT | Rel-13 | RP-66 | RP-151131 |
| 1045 | 297.34.2 | Perf. part: LTE Advanced 3 band Carrier Aggregation (3DL/1UL) of Band 1, Band 8 and Band 40 | 262d? | 2014-12-15 A | 2015-12-15 A | 100% |  |  | finish no earlier than 2015-12-15 | R4 | 2096h | 2096h | LTE_CA_B1_B8_B40-Perf | PCG-34 | KT | KT | Rel-13 | RP-66 | RP-151131 |
| 1046 | 297.35 | **LTE Advanced 3 band Carrier Aggregation (3DL/1UL) of Band 3, Band 8 and Band 40** | 262d? | 2014-12-15 A | 2015-12-15 A | 100% |  |  |  | R4 | 6288h | 6288h | LTE_CA_B3_B8_B40 | PCG-34 | KT | KT | Rel-13 | RP-66 |  |
| 1047 | 297.35.1 | Core part: LTE Advanced 3 band Carrier Aggregation (3DL/1UL) of Band 3, Band 8 and Band 40 | 262d? | 2014-12-15 A | 2015-12-15 A | 100% |  |  | finish no earlier than 2015-12-15 | R4 | 2096h | 2096h | LTE_CA_B3_B8_B40-Core | PCG-34 | KT | KT | Rel-13 | RP-66 | RP-151131 |
| 1048 | 297.35.2 | Perf. part: LTE Advanced 3 band Carrier Aggregation (3DL/1UL) of Band 3, Band 8 and Band 40 | 262d? | 2014-12-15 A | 2015-12-15 A | 100% |  |  | finish no earlier than 2015-12-15 | R4 | 2096h | 2096h | LTE_CA_B3_B8_B40-Perf | PCG-34 | KT | KT | Rel-13 | RP-66 | RP-151131 |
| 1049 | 297.36 | **LTE Advanced 3 Band Carrier Aggregation (3DL) of Band 3, Band 7 and Band 8** | 131d? | 2014-12-15 A | 2015-06-15 A | 100% |  |  |  | R4 | 3144h | 3144h | LTE_CA_B3_B7_B8 | PCG-34 | Ericsson | Ericsson | Rel-13 | RP-66 |  |
| 1050 | 297.36.1 | Core part: LTE Advanced 3 Band Carrier Aggregation (3DL) of Band 3, Band 7 and Band 8 | 131d? | 2014-12-15 A | 2015-06-15 A | 100% |  |  | finish no earlier than 2015-06-15 | R4 | 1048h | 1048h | LTE_CA_B3_B7_B8-Core | PCG-34 | Ericsson | Ericsson | Rel-13 | RP-66 | RP-150536 |
| 1051 | 297.36.2 | Perf. part: LTE Advanced 3 Band Carrier Aggregation (3DL) of Band 3, Band 7 and Band 8 | 131d? | 2014-12-15 A | 2015-06-15 A | 100% |  |  | finish no earlier than 2015-06-15 | R4 | 1048h | 1048h | LTE_CA_B3_B7_B8-Perf | PCG-34 | Ericsson | Ericsson | Rel-13 | RP-66 | RP-150536 |
| 1052 | 297.37 | **LTE Advanced 3 Band Carrier Aggregation (3DL/1UL) of Band 1, Band 3 and Band 28** | 131d? | 2014-12-15 A | 2015-06-15 A | 100% |  |  |  | R4 | 3144h | 3144h | LTE_CA_B1_B3_B28 | PCG-34 | Nokia Networks | Nokia Networks | Rel-13 | RP-66 |  |
| 1053 | 297.37.1 | Core part: LTE Advanced 3 Band Carrier Aggregation (3DL/1UL) of Band 1, Band 3 and Band 28 | 131d? | 2014-12-15 A | 2015-06-15 A | 100% |  |  | finish no earlier than 2015-06-15 | R4 | 1048h | 1048h | LTE_CA_B1_B3_B28-Core | PCG-34 | Nokia Networks | Nokia Networks | Rel-13 | RP-66 | RP-150536 |
| 1054 | 297.37.2 | Perf. part: LTE Advanced 3 Band Carrier Aggregation (3DL/1UL) of Band 1, Band 3 and Band 28 | 131d? | 2014-12-15 A | 2015-06-15 A | 100% |  |  | finish no earlier than 2015-06-15 | R4 | 1048h | 1048h | LTE_CA_B1_B3_B28-Perf | PCG-34 | Nokia Networks | Nokia Networks | Rel-13 | RP-66 | RP-150536 |

Notes:
- 1032: 1st Apr 15: Compl:0%->20% 1st Apr 15: WID: RP-141826->RP-150447 1st Apr 15: Stat Rep: ->RP-150013 03/07/15: Compl:20%->40% 03/07/15: Stat Rep: RP-150013->RP-150536 29/09/15: CD:Tue 15/09/15->Tue 15/12/15 29/09/15: Stat Rep: RP-150536->RP-151131
- 1033: 1st Apr 15: Compl:0%->20% 1st Apr 15: WID: RP-141826->RP-150447 1st Apr 15: Stat Rep: ->RP-150013 03/07/15: Compl:20%->40% 03/07/15: Stat Rep: RP-150013->RP-150536 29/09/15: CD:Tue 15/09/15->Tue 15/12/15 29/09/15: Stat Rep: RP-150536->RP-151131
- 1034: Acronym changed from LTE_CA_B3_B7_B7
- 1035: Acronym changed from LTE_CA_B3_B7_B7-Core 1st Apr 15: Compl:0%->99% 1st Apr 15: CD:Sun 15/03/15->Mon 15/06/15 1st Apr 15: Stat Rep: ->RP-150013 03/07/15: Compl:99%->100% 03/07/15: Stat Rep: RP-150013->RP-150536
- 1036: Acronym changed from LTE_CA_B3_B7_B7-Perf 1st Apr 15: Compl:0%->99% 1st Apr 15: CD:Sun 15/03/15->Mon 15/06/15 1st Apr 15: Stat Rep: ->RP-150013 03/07/15: Compl:99%->100% 03/07/15: Stat Rep: RP-150013->RP-150536
- 1038: 1st Apr 15: Compl:0%->99% 1st Apr 15: CD:Sun 15/03/15->Mon 15/06/15 1st Apr 15: Stat Rep: ->RP-150013 03/07/15: Compl:99%->100% 03/07/15: Stat Rep: RP-150013->RP-150536
- 1039: 1st Apr 15: Compl:0%->99% 1st Apr 15: CD:Sun 15/03/15->Mon 15/06/15 1st Apr 15: Stat Rep: ->RP-150013 03/07/15: Compl:99%->100% 03/07/15: Stat Rep: RP-150013->RP-150536
- 1041: 1st Apr 15: Compl:0%->10% 1st Apr 15: Stat Rep: ->RP-150013 03/07/15: Compl:10%->60% 03/07/15: CD:Tue 15/09/15->Tue 15/12/15 03/07/15: Stat Rep: RP-150013->RP-150536 29/09/15: Compl:60%->80% 29/09/15: WID: RP-141946->RP-151258 29/09/15: Stat Rep: RP-1...; ; ; ; ; ; ; ; ; ; ; ; ; ; ; ; ; ; ; ; ; ; ; ; ; ; ; ; ; ; ; ; ; ; ; ; ; ; ; ; ; ; ; ; ; ; ; ; ; ; ; ; ; ; ; ; ; ; ; ; ; ; ; ; ; ; ; ; ; ; ; ; ; ; ; ; ; ; 1/1/16: Compl:80%->100%
- 1042: 1st Apr 15: Compl:0%->10% 1st Apr 15: Stat Rep: ->RP-150013 03/07/15: Compl:10%->60% 03/07/15: CD:Tue 15/09/15->Tue 15/12/15 03/07/15: Stat Rep: RP-150013->RP-150536 29/09/15: Compl:60%->80% 29/09/15: WID: RP-141946->RP-151258 29/09/15: Stat Rep: RP-1...; ; ; ; ; ; ; ; ; ; ; ; ; ; ; ; ; ; ; ; ; ; ; ; ; ; ; ; ; ; ; ; ; ; ; ; ; ; ; ; ; ; ; ; ; ; ; ; ; ; ; ; ; ; ; ; ; ; ; ; ; ; ; ; ; ; ; ; ; ; ; ; ; ; ; ; ; ; ; 1/1/16: Compl:80%->100%
- 1044: 1st Apr 15: Compl:0%->10% 1st Apr 15: Stat Rep: ->RP-150013 03/07/15: Compl:10%->60% 03/07/15: CD:Tue 15/09/15->Tue 15/12/15 03/07/15: Stat Rep: RP-150013->RP-150536 29/09/15: Compl:60%->80% 29/09/15: WID: RP-141947->RP-151259 29/09/15: Stat Rep: RP-1...; ; ; ; ; ; ; ; ; ; ; ; ; ; ; ; ; ; ; ; ; ; ; ; ; ; ; ; ; ; ; ; ; ; ; ; ; ; ; ; ; ; ; ; ; ; ; ; ; ; ; ; ; ; ; ; ; ; ; ; ; ; ; ; ; ; ; ; ; ; ; ; ; ; ; ; ; ; ; ; ; ; 1/1/16: Compl:80%->100%
- 1045: 1st Apr 15: Compl:0%->10% 1st Apr 15: Stat Rep: ->RP-150013 03/07/15: Compl:10%->60% 03/07/15: CD:Tue 15/09/15->Tue 15/12/15 03/07/15: Stat Rep: RP-150013->RP-150536 29/09/15: Compl:60%->80% 29/09/15: WID: RP-141947->RP-151259 29/09/15: Stat Rep: RP-1...; ; ; ; ; ; ; ; ; ; ; ; ; ; ; ; ; ; ; ; ; ; ; ; ; ; ; ; ; ; ; ; ; ; ; ; ; ; ; ; ; ; ; ; ; ; ; ; ; ; ; ; ; ; ; ; ; ; ; ; ; ; ; ; ; ; ; ; ; ; ; ; ; ; ; ; ; ; ; ; ; ; ; 1/1/16: Compl:80%->100%
- 1047: 1st Apr 15: Compl:0%->10% 1st Apr 15: Stat Rep: ->RP-150013 03/07/15: Compl:10%->60% 03/07/15: CD:Tue 15/09/15->Tue 15/12/15 03/07/15: Stat Rep: RP-150013->RP-150536 29/09/15: Compl:60%->95% 29/09/15: WID: RP-141949->RP-151261 29/09/15: Stat Rep: RP-1...; ; ; ; ; ; ; ; ; ; ; ; ; ; ; ; ; ; ; ; ; ; ; ; ; ; ; ; ; ; ; ; ; ; ; ; ; ; ; ; ; ; ; ; ; ; ; ; ; ; ; ; ; ; ; ; ; ; ; ; ; ; ; ; ; ; ; ; ; ; ; ; ; ; ; ; ; ; ; ; ; ; ; ; ; ; ; ; ; ; ; ; ; ; 1/1/16: Compl:95%->100%
- 1048: 1st Apr 15: Compl:0%->10% 1st Apr 15: Stat Rep: ->RP-150013 03/07/15: Compl:10%->60% 03/07/15: CD:Tue 15/09/15->Tue 15/12/15 03/07/15: Stat Rep: RP-150013->RP-150536 29/09/15: Compl:60%->90% 29/09/15: WID: RP-141949->RP-151261 29/09/15: Stat Rep: RP-1...; ; ; ; ; ; ; ; ; ; ; ; ; ; ; ; ; ; ; ; ; ; ; ; ; ; ; ; ; ; ; ; ; ; ; ; ; ; ; ; ; ; ; ; ; ; ; ; ; ; ; ; ; ; ; ; ; ; ; ; ; ; ; ; ; ; ; ; ; ; ; ; ; ; ; ; ; ; ; ; ; ; ; ; ; ; ; ; ; ; ; ; ; ; ; 1/1/16: Compl:90%->100%
- 1050: 1st Apr 15: Compl:0%->95% 1st Apr 15: Stat Rep: ->RP-150013 03/07/15: Compl:95%->100% 03/07/15: Stat Rep: RP-150013->RP-150536
- 1051: 1st Apr 15: Compl:0%->99% 1st Apr 15: Stat Rep: ->RP-150013 03/07/15: Compl:99%->100% 03/07/15: Stat Rep: RP-150013->RP-150536
- 1053: 1st Apr 15: Compl:0%->99% 1st Apr 15: CD:Sun 15/03/15->Mon 15/06/15 1st Apr 15: Stat Rep: ->RP-150013 03/07/15: Compl:99%->100% 03/07/15: WID: RP-142038->RP-150719 03/07/15: Stat Rep: RP-150013->RP-150536
- 1054: 1st Apr 15: Compl:0%->99% 1st Apr 15: CD:Sun 15/03/15->Mon 15/06/15 1st Apr 15: Stat Rep: ->RP-150013 03/07/15: Compl:99%->100% 03/07/15: WID: RP-142038->RP-150719 03/07/15: Stat Rep: RP-150013->RP-150536

| ID | WBS | Task | Duration | Start | Finish | Complete | Remaining | Total slack | Constraint | Resources | Work | Actual work | Acronym | PCG approved | WI rapporteur name | WI rapporteur e-mail | Release | TSG approved | Status Report |
| --- | --- | --- | --- | --- | --- | --- | --- | --- | --- | --- | --- | --- | --- | --- | --- | --- | --- | --- | --- |
| 1055 | 297.38 | **LTE Advanced 3 band Carrier Aggregation (3DL/1UL) of Band 3, Band 8 and Band 28** | 327d? | 2014-12-15 A | 2016-03-15 | 40% | 196.2d? | 545d |  | R4 | 7848h | 2332.07h | LTE_CA_B3_B8_B28 | PCG-34 | Softbank Mobile | Softbank Mobile | Rel-13 | RP-66 |  |
| 1056 | 297.38.1 | Core part: LTE Advanced 3 band Carrier Aggregation (3DL/1UL) of Band 3, Band 8 and Band 28 | 327d? | 2014-12-15 A | 2016-03-15 | 40% | 196.2d? | 545d | finish no earlier than 2016-03-15 | R4 | 2616h | 1046.4h | LTE_CA_B3_B8_B28-Core | PCG-34 | Softbank Mobile | Softbank Mobile | Rel-13 | RP-66 | RP-151131 |
| 1057 | 297.38.2 | Perf. part: LTE Advanced 3 band Carrier Aggregation (3DL/1UL) of Band 3, Band 8 and Band 28 | 327d? | 2014-12-15 A | 2016-03-15 | 40% | 196.2d? | 545d | finish no earlier than 2016-03-15 | R4 | 2616h | 1046.4h | LTE_CA_B3_B8_B28-Perf | PCG-34 | Softbank Mobile | Softbank Mobile | Rel-13 | RP-66 | RP-151131 |
| 1058 | 297.39 | **LTE Advanced 3 Band Carrier Aggregation (3DL/1UL) of Band 8, Band 42 and Band 42** | 327d? | 2014-12-15 A | 2016-03-15 | 99% | 0d? | 0d |  | R4 | 7848h | 5511.46h | LTE_CA_B8_B42_B42 | PCG-34 | Softbank Mobile | Softbank Mobile | Rel-13 | RP-66 |  |
| 1059 | 297.39.1 | Core part: LTE Advanced 3 Band Carrier Aggregation (3DL/1UL) of Band 8, Band 42 and Band 42 | 327d? | 2014-12-15 A | 2016-03-15 A | 100% |  |  | finish no earlier than 2016-03-15 | R4 | 2616h | 2616h | LTE_CA_B8_B42_B42-Core | PCG-34 | Softbank Mobile | Softbank Mobile | Rel-13 | RP-66 | RP-151131 |
| 1060 | 297.39.2 | Perf. part: LTE Advanced 3 Band Carrier Aggregation (3DL/1UL) of Band 8, Band 42 and Band 42 | 327d? | 2014-12-15 A | 2016-03-15 A | 100% |  |  | finish no earlier than 2016-03-15 | R4 | 2616h | 2616h | LTE_CA_B8_B42_B42-Perf | PCG-34 | Softbank Mobile | Softbank Mobile | Rel-13 | RP-66 | RP-151131 |
| 1061 | 297.40 | **LTE Advanced 3 Band Carrier Aggregation (3DL/1UL) of Band 28, Band 40 and Band 40** | 262d? | 2014-12-15 A | 2015-12-15 A | 100% |  |  |  | R4 | 6288h | 6288h | LTE_CA_B28_B40_B40 | PCG-34 | Huawei | Huawei | Rel-13 | RP-66 |  |
| 1062 | 297.40.1 | Core part: LTE Advanced 3 Band Carrier Aggregation (3DL/1UL) of Band 28, Band 40 and Band 40 | 262d? | 2014-12-15 A | 2015-12-15 A | 100% |  |  | finish no earlier than 2015-12-15 | R4 | 2096h | 2096h | LTE_CA_B28_B40_B40-Core | PCG-34 | Huawei | Huawei | Rel-13 | RP-66 | RP-151131 |
| 1063 | 297.40.2 | Perf. part: LTE Advanced 3 Band Carrier Aggregation (3DL/1UL) of Band 28, Band 40 and Band 40 | 262d? | 2014-12-15 A | 2015-12-15 A | 100% |  |  | finish no earlier than 2015-12-15 | R4 | 2096h | 2096h | LTE_CA_B28_B40_B40-Perf | PCG-34 | Huawei | Huawei | Rel-13 | RP-66 | RP-151131 |
| 1064 | 297.41 | **LTE Advanced 3 Band Carrier Aggregation (3DL/1UL) of Band 3, Band 40 and Band 40** | 131d? | 2014-12-15 A | 2015-06-15 A | 100% |  |  |  | R4 | 3144h | 3144h | LTE_CA_B3_B40_B40 | PCG-34 | Huawei | Huawei | Rel-13 | RP-66 |  |
| 1065 | 297.41.1 | Core part: LTE Advanced 3 Band Carrier Aggregation (3DL/1UL) of Band 3, Band 40 and Band 40 | 131d? | 2014-12-15 A | 2015-06-15 A | 100% |  |  | finish no earlier than 2015-06-15 | R4 | 1048h | 1048h | LTE_CA_B3_B40_B40-Core | PCG-34 | Huawei | Huawei | Rel-13 | RP-66 | RP-150536 |
| 1066 | 297.41.2 | Perf. part: LTE Advanced 3 Band Carrier Aggregation (3DL/1UL) of Band 3, Band 40 and Band 40 | 131d? | 2014-12-15 A | 2015-06-15 A | 100% |  |  | finish no earlier than 2015-06-15 | R4 | 1048h | 1048h | LTE_CA_B3_B40_B40-Perf | PCG-34 | Huawei | Huawei | Rel-13 | RP-66 | RP-150536 |
| 1067 | 297.42 | **LTE Advanced 3 Band Carrier Aggregation (3DL/1UL) of Band 1, Band 7 and Band 28** | 131d? | 2014-12-15 A | 2015-06-15 A | 100% |  |  |  | R4 | 3144h | 3144h | LTE_CA_B1_B7_B28 | PCG-34 | Huawei | Huawei | Rel-13 | RP-66 |  |
| 1068 | 297.42.1 | Core part: LTE Advanced 3 Band Carrier Aggregation (3DL/1UL) of Band 1, Band 7 and Band 28 | 131d? | 2014-12-15 A | 2015-06-15 A | 100% |  |  | finish no earlier than 2015-06-15 | R4 | 1048h | 1048h | LTE_CA_B1_B7_B28-Core | PCG-34 | Huawei | Huawei | Rel-13 | RP-66 | RP-150536 |
| 1069 | 297.42.2 | Perf. part: LTE Advanced 3 Band Carrier Aggregation (3DL/1UL) of Band 1, Band 7 and Band 28 | 131d? | 2014-12-15 A | 2015-06-15 A | 100% |  |  | finish no earlier than 2015-06-15 | R4 | 1048h | 1048h | LTE_CA_B1_B7_B28-Perf | PCG-34 | Huawei | Huawei | Rel-13 | RP-66 | RP-150536 |
| 1070 | 297.43 | **LTE Advanced 3 Band Carrier Aggregation (3DL/1UL) of Band 1, Band 3 and Band 7** | 262d? | 2014-12-15 A | 2015-12-15 A | 100% |  |  |  | R4 | 6288h | 6288h | LTE_CA_B1_B3_B7 | PCG-34 | Huawei | Huawei | Rel-13 | RP-66 |  |
| 1071 | 297.43.1 | Core part: LTE Advanced 3 Band Carrier Aggregation (3DL/1UL) of Band 1, Band 3 and Band 7 | 262d? | 2014-12-15 A | 2015-12-15 A | 100% |  |  | finish no earlier than 2015-12-15 | R4 | 2096h | 2096h | LTE_CA_B1_B3_B7-Core | PCG-34 | Huawei | Huawei | Rel-13 | RP-66 | RP-151131 |
| 1072 | 297.43.2 | Perf. part: LTE Advanced 3 Band Carrier Aggregation (3DL/1UL) of Band 1, Band 3 and Band 7 | 262d? | 2014-12-15 A | 2015-12-15 A | 100% |  |  | finish no earlier than 2015-12-15 | R4 | 2096h | 2096h | LTE_CA_B1_B3_B7-Perf | PCG-34 | Huawei | Huawei | Rel-13 | RP-66 | RP-151131 |
| 1073 | 297.44 | **LTE Advanced 3 Band Carrier Aggregation (3DL/1UL) of Band 3, Band 3 and Band 5** | 131d? | 2014-12-15 A | 2015-06-15 A | 100% |  |  |  | R4 | 3144h | 3144h | LTE_CA_B3_B3_B5 | PCG-34 | Intel | Intel | Rel-13 | RP-66 |  |
| 1074 | 297.44.1 | Core part: LTE Advanced 3 Band Carrier Aggregation (3DL/1UL) of Band 3, Band 3 and Band 5 | 131d? | 2014-12-15 A | 2015-06-15 A | 100% |  |  | finish no earlier than 2015-09-15 | R4 | 1048h | 1048h | LTE_CA_B3_B3_B5-Core | PCG-34 | Intel | Intel | Rel-13 | RP-66 | RP-150536 |
| 1075 | 297.44.2 | Perf. part: LTE Advanced 3 Band Carrier Aggregation (3DL/1UL) of Band 3, Band 3 and Band 5 | 131d? | 2014-12-15 A | 2015-06-15 A | 100% |  |  | finish no earlier than 2015-09-15 | R4 | 1048h | 1048h | LTE_CA_B3_B3_B5-Perf | PCG-34 | Intel | Intel | Rel-13 | RP-66 | RP-150536 |
| 1076 | 297.45 | **LTE Advanced 3 Band Carrier Aggregation (3DL/1UL) of Band 3, Band 7 and Band 28** | 131d? | 2014-12-15 A | 2015-06-15 A | 100% |  |  |  | R4 | 3144h | 3144h | LTE_CA_B3_B7_B28 | PCG-34 | Ericsson | Ericsson | Rel-13 | RP-66 |  |
| 1077 | 297.45.1 | Core part: LTE Advanced 3 Band Carrier Aggregation (3DL/1UL) of Band 3, Band 7 and Band 28 | 131d? | 2014-12-15 A | 2015-06-15 A | 100% |  |  | finish no earlier than 2015-06-15 | R4 | 1048h | 1048h | LTE_CA_B3_B7_B28-Core | PCG-34 | Ericsson | Ericsson | Rel-13 | RP-66 | RP-150536 |
| 1078 | 297.45.2 | Perf. part: LTE Advanced 3 Band Carrier Aggregation (3DL/1UL) of Band 3, Band 7 and Band 28 | 131d? | 2014-12-15 A | 2015-06-15 A | 100% |  |  | finish no earlier than 2015-06-15 | R4 | 1048h | 1048h | LTE_CA_B3_B7_B28-Perf | PCG-34 | Ericsson | Ericsson | Rel-13 | RP-66 | RP-150536 |

Notes:
- 1056: 1st Apr 15: Compl:0%->20% 1st Apr 15: CD:Tue 15/12/15->Tue 15/09/15 1st Apr 15: Stat Rep: ->RP-150013 03/07/15: Compl:20%->40% 03/07/15: Stat Rep: RP-150013->RP-150536 29/09/15: CD:Tue 15/09/15->Tue 15/12/15 29/09/15: Stat Rep: RP-150536->RP-151131;
- 1057: 1st Apr 15: Compl:0%->20% 1st Apr 15: Stat Rep: ->RP-150013 03/07/15: Compl:20%->40% 03/07/15: Stat Rep: RP-150013->RP-150536 29/09/15: CD:Tue 15/09/15->Tue 15/12/15 29/09/15: Stat Rep: RP-150536->RP-151131
- 1059: 1st Apr 15: Compl:0%->20% 1st Apr 15: CD:Tue 15/12/15->Mon 15/06/15 1st Apr 15: Stat Rep: ->RP-150013 03/07/15: Compl:20%->40% 03/07/15: CD:Mon 15/06/15->Tue 15/09/15 03/07/15: Stat Rep: RP-150013->RP-150536 29/09/15: CD:Tue 15/09/15->Tue 15/12/15 29/...; ; ; ; ; ; ; ; ; ; ; ; ; ; ; ; ; ; ; ; ; ; ; ; ; ; ; ; ; ; ; ; ; ; ; ; ; ; ; ; ; ; ; ; ; ; ; ; 22/3/16: Compl:40%->100%
- 1060: 1st Apr 15: Compl:0%->20% 1st Apr 15: Stat Rep: ->RP-150013 03/07/15: Compl:20%->40% 03/07/15: CD:Mon 15/06/15->Tue 15/09/15 03/07/15: Stat Rep: RP-150013->RP-150536 29/09/15: CD:Tue 15/09/15->Tue 15/12/15 29/09/15: Stat Rep: RP-150536->RP-151131;...
- 1062: 1st Apr 15: Compl:0%->30% 1st Apr 15: CD:Tue 15/12/15->Mon 15/06/15 1st Apr 15: WID: RP-142206->RP-150233 1st Apr 15: Stat Rep: ->RP-150013 03/07/15: Compl:30%->60% 03/07/15: CD:Mon 15/06/15->Tue 15/12/15 03/07/15: WID: RP-150233->RP-150676 03/07/15: ...; ; ; ; ; ; ; ; ; ; ; ; ; ; ; ; ; ; ; ; ; ; ; ; ; ; ; ; ; ; ; ; ; ; ; ; ; ; ; ; ; ; ; ; ; ; ; ; ; ; ; ; ; ; ; ; ; ; ; ; ; ; ; ; ; ; ; ; ; ; ; ; ; ; ; ; ; ; ; ; ; ; ; ; ; ; ; ; ; ; ; ; ; ; ; ; ; ; ; ; ; ; ; ; ; ; ; ; ; ; ; ; ; ; 1/1/16: Compl:60%->100%
- 1063: 1st Apr 15: WID: RP-142206->RP-150233 1st Apr 15: Stat Rep: ->RP-150013 03/07/15: CD:Mon 15/06/15->Tue 15/12/15 03/07/15: WID: RP-150233->RP-150676 03/07/15: Stat Rep: RP-150013->RP-150536 29/09/15: Stat Rep: RP-150536->RP-151131; ...
- 1065: 1st Apr 15: Compl:0%->50% 1st Apr 15: CD:Tue 15/12/15->Mon 15/06/15 1st Apr 15: Stat Rep: ->RP-150013 03/07/15: Compl:50%->100% 03/07/15: WID: RP-142207->RP-151071 03/07/15: Stat Rep: RP-150013->RP-150536
- 1066: 03/07/15: Compl:0%->100% 03/07/15: WID: RP-142207->RP-151071 03/07/15: Stat Rep: ->RP-150536
- 1068: 1st Apr 15: Compl:0%->50% 1st Apr 15: CD:Tue 15/12/15->Mon 15/06/15 1st Apr 15: WID: RP-142208->RP-150234 1st Apr 15: Stat Rep: ->RP-150013 03/07/15: Compl:50%->100% 03/07/15: Stat Rep: RP-150013->RP-150536
- 1069: 1st Apr 15: WID: RP-142208->RP-150234 1st Apr 15: Stat Rep: ->RP-150013 03/07/15: Compl:0%->100% 03/07/15: Stat Rep: RP-150013->RP-150536
- 1071: 1st Apr 15: Compl:0%->30% 1st Apr 15: CD:Tue 15/12/15->Mon 15/06/15 1st Apr 15: Stat Rep: ->RP-150013 03/07/15: Compl:30%->40% 03/07/15: CD:Mon 15/06/15->Tue 15/09/15 03/07/15: Stat Rep: RP-150013->RP-150536 29/09/15: Compl:40%->50% 29/09/15: CD:Tue 1...; ; ; ; ; ; ; ; ; ; ; ; ; ; ; ; ; ; ; ; ; ; ; ; ; ; ; ; ; ; ; ; ; ; ; ; ; ; ; ; ; ; ; ; ; ; ; ; ; ; ; ; ; ; ; ; ; ; ; ; ; ; ; ; ; ; ; ; ; ; ; ; ; ; ; ; 1/1/16: Compl:50%->100%
- 1072: 03/07/15: CD:Mon 15/06/15->Tue 15/09/15 03/07/15: Stat Rep: ->RP-150536 29/09/15: CD:Tue 15/09/15->Tue 15/12/15 29/09/15: Stat Rep: RP-150536->RP-151131
- 1074: 1st Apr 15: Compl:0%->10% 1st Apr 15: Stat Rep: ->RP-150013 03/07/15: Compl:10%->100% 03/07/15: CD:Tue 15/09/15->Mon 15/06/15 03/07/15: Stat Rep: RP-150013->RP-150536
- 1075: 03/07/15: Compl:0%->100% 03/07/15: CD:Tue 15/09/15->Mon 15/06/15 03/07/15: Stat Rep: ->RP-150536
- 1077: 1st Apr 15: Compl:0%->99% 1st Apr 15: CD:Sun 15/03/15->Mon 15/06/15 1st Apr 15: Stat Rep: ->RP-150013 03/07/15: Compl:99%->100% 03/07/15: Stat Rep: RP-150013->RP-150536
- 1078: 1st Apr 15: Compl:0%->99% 1st Apr 15: CD:Sun 15/03/15->Mon 15/06/15 1st Apr 15: Stat Rep: ->RP-150013 03/07/15: Compl:99%->100% 03/07/15: Stat Rep: RP-150013->RP-150536

| ID | WBS | Task | Duration | Start | Finish | Complete | Constraint | Resources | Work | Actual work | Acronym | PCG approved | WI rapporteur name | WI rapporteur e-mail | Release | TSG approved | Status Report |
| --- | --- | --- | --- | --- | --- | --- | --- | --- | --- | --- | --- | --- | --- | --- | --- | --- | --- |
| 1079 | 297.46 | **LTE Advanced 4 Band Carrier Aggregation (4DL/1UL) of Band 2, Band 2, Band 12 and Band 30** | 262d? | 2014-12-15 A | 2015-12-15 A | 100% |  | R4 | 6288h | 6288h | LTE_CA_B2_B2_B12_B30 | PCG-34 | AT&T | AT&T | Rel-13 | RP-66 |  |
| 1080 | 297.46.1 | Core part: LTE Advanced 4 Band Carrier Aggregation (4DL/1UL) of Band 2, Band 2, Band 12 and Band 30 | 262d? | 2014-12-15 A | 2015-12-15 A | 100% | finish no earlier than 2015-12-15 | R4 | 2096h | 2096h | LTE_CA_B2_B2_B12_B30-Core | PCG-34 | AT&T | AT&T | Rel-13 | RP-66 | RP-151131 |
| 1081 | 297.46.2 | Perf. part: LTE Advanced 4 Band Carrier Aggregation (4DL/1UL) of Band 2, Band 2, Band 12 and Band 30 | 262d? | 2014-12-15 A | 2015-12-15 A | 100% | finish no earlier than 2015-12-15 | R4 | 2096h | 2096h | LTE_CA_B2_B2_B12_B30-Perf | PCG-34 | AT&T | AT&T | Rel-13 | RP-66 | RP-151131 |
| 1082 | 297.47 | **LTE Advanced 4 Band Carrier Aggregation (4DL/1UL) of Band 2, Band 2, Band 5 and Band 30** | 262d? | 2014-12-15 A | 2015-12-15 A | 100% |  | R4 | 6288h | 6288h | LTE_CA_B2_B2_B5_B30 | PCG-34 | AT&T | AT&T | Rel-13 | RP-66 |  |
| 1083 | 297.47.1 | Core part: LTE Advanced 4 Band Carrier Aggregation (4DL/1UL) of Band 2, Band 2, Band 5 and Band 30 | 262d? | 2014-12-15 A | 2015-12-15 A | 100% | finish no earlier than 2015-12-15 | R4 | 2096h | 2096h | LTE_CA_B2_B2_B5_B30-Core | PCG-34 | AT&T | AT&T | Rel-13 | RP-66 | RP-151131 |
| 1084 | 297.47.2 | Perf. part: LTE Advanced 4 Band Carrier Aggregation (4DL/1UL) of Band 2, Band 2, Band 5 and Band 30 | 262d? | 2014-12-15 A | 2015-12-15 A | 100% | finish no earlier than 2015-12-15 | R4 | 2096h | 2096h | LTE_CA_B2_B2_B5_B30-Perf | PCG-34 | AT&T | AT&T | Rel-13 | RP-66 | RP-151131 |
| 1085 | 297.48 | **LTE Advanced 4 Band Carrier Aggregation (4DL/1UL) of Band 2, Band 2 Band 29 and Band 30** | 262d? | 2014-12-15 A | 2015-12-15 A | 100% |  | R4 | 6288h | 6288h | LTE_CA_B2_B2_B29_B30 | PCG-34 | AT&T | AT&T | Rel-13 | RP-66 |  |
| 1086 | 297.48.1 | Core part: LTE Advanced 4 Band Carrier Aggregation (4DL/1UL) of Band 2, Band 2 Band 29 and Band 30 | 262d? | 2014-12-15 A | 2015-12-15 A | 100% | finish no earlier than 2015-12-15 | R4 | 2096h | 2096h | LTE_CA_B2_B2_B29_B30-Core | PCG-34 | AT&T | AT&T | Rel-13 | RP-66 | RP-151131 |
| 1087 | 297.48.2 | Perf. part: LTE Advanced 4 Band Carrier Aggregation (4DL/1UL) of Band 2, Band 2 Band 29 and Band 30 | 262d? | 2014-12-15 A | 2015-12-15 A | 100% | finish no earlier than 2015-12-15 | R4 | 2096h | 2096h | LTE_CA_B2_B2_B29_B30-Perf | PCG-34 | AT&T | AT&T | Rel-13 | RP-66 | RP-151131 |
| 1088 | 297.49 | **LTE Advanced 4 Band Carrier Aggregation (4DL/1UL) of Band 2, Band 4, Band 12 and Band 30** | 262d? | 2014-12-15 A | 2015-12-15 A | 100% |  | R4 | 6288h | 6288h | LTE_CA_B2_B4_B12_B30 | PCG-34 | AT&T | AT&T | Rel-13 | RP-66 |  |
| 1089 | 297.49.1 | Core part: LTE Advanced 4 Band Carrier Aggregation (4DL/1UL) of Band 2, Band 4, Band 12 and Band 30 | 262d? | 2014-12-15 A | 2015-12-15 A | 100% | finish no earlier than 2015-12-15 | R4 | 2096h | 2096h | LTE_CA_B2_B4_B12_B30-Core | PCG-34 | AT&T | AT&T | Rel-13 | RP-66 | RP-151131 |
| 1090 | 297.49.2 | Perf. part: LTE Advanced 4 Band Carrier Aggregation (4DL/1UL) of Band 2, Band 4, Band 12 and Band 30 | 262d? | 2014-12-15 A | 2015-12-15 A | 100% | finish no earlier than 2015-12-15 | R4 | 2096h | 2096h | LTE_CA_B2_B4_B12_B30-Perf | PCG-34 | AT&T | AT&T | Rel-13 | RP-66 | RP-151131 |
| 1091 | 297.50 | **LTE Advanced 4 Band Carrier Aggregation (4DL/1UL) of Band 2, Band 4, Band 5 and Band 30** | 262d? | 2014-12-15 A | 2015-12-15 A | 100% |  | R4 | 6288h | 6288h | LTE_CA_B2_B4_B5_B30 | PCG-34 | AT&T | AT&T | Rel-13 | RP-66 |  |
| 1092 | 297.50.1 | Core part: LTE Advanced 4 Band Carrier Aggregation (4DL/1UL) of Band 2, Band 4, Band 5 and Band 30 | 262d? | 2014-12-15 A | 2015-12-15 A | 100% | finish no earlier than 2015-12-15 | R4 | 2096h | 2096h | LTE_CA_B2_B4_B5_B30-Core | PCG-34 | AT&T | AT&T | Rel-13 | RP-66 | RP-151131 |
| 1093 | 297.50.2 | Perf. part: LTE Advanced 4 Band Carrier Aggregation (4DL/1UL) of Band 2, Band 4, Band 5 and Band 30 | 262d? | 2014-12-15 A | 2015-12-15 A | 100% | finish no earlier than 2015-12-15 | R4 | 2096h | 2096h | LTE_CA_B2_B4_B5_B30-Perf | PCG-34 | AT&T | AT&T | Rel-13 | RP-66 | RP-151131 |
| 1094 | 297.51 | **LTE Advanced 4 Band Carrier Aggregation (4DL/1UL) of Band 2, Band 4, Band 29 and Band 30** | 262d? | 2014-12-15 A | 2015-12-15 A | 100% |  | R4 | 6288h | 6288h | LTE_CA_B2_B4_B29_B30 | PCG-34 | AT&T | AT&T | Rel-13 | RP-66 |  |
| 1095 | 297.51.1 | Core part: LTE Advanced 4 Band Carrier Aggregation (4DL/1UL) of Band 2, Band 4, Band 29 and Band 30 | 262d? | 2014-12-15 A | 2015-12-15 A | 100% | finish no earlier than 2015-12-15 | R4 | 2096h | 2096h | LTE_CA_B2_B4_B29_B30-Core | PCG-34 | AT&T | AT&T | Rel-13 | RP-66 | RP-151131 |
| 1096 | 297.51.2 | Perf. part: LTE Advanced 4 Band Carrier Aggregation (4DL/1UL) of Band 2, Band 4, Band 29 and Band 30 | 262d? | 2014-12-15 A | 2015-12-15 A | 100% | finish no earlier than 2015-12-15 | R4 | 2096h | 2096h | LTE_CA_B2_B4_B29_B30-Perf | PCG-34 | AT&T | AT&T | Rel-13 | RP-66 | RP-151131 |
| 1097 | 297.52 | **LTE Advanced 4 Band Carrier Aggregation (4DL/1UL) of Band 25, Band 41, Band 41 and Band 41** | 262d? | 2014-12-15 A | 2015-12-15 A | 100% |  | R4 | 6288h | 6288h | LTE_CA_B25_B41_B41_B41 | PCG-34 | Alcatel-Lucent | Alcatel-Lucent | Rel-13 | RP-66 |  |
| 1098 | 297.52.1 | Core part: LTE Advanced 4 Band Carrier Aggregation (4DL/1UL) of Band 25, Band 41, Band 41 and Band 41 | 262d? | 2014-12-15 A | 2015-12-15 A | 100% | finish no earlier than 2015-12-15 | R4 | 2096h | 2096h | LTE_CA_B25_B41_B41_B41-Core | PCG-34 | Alcatel-Lucent | Alcatel-Lucent | Rel-13 | RP-66 | RP-151131 |
| 1099 | 297.52.2 | Perf. part: LTE Advanced 4 Band Carrier Aggregation (4DL/1UL) of Band 25, Band 41, Band 41 and Band 41 | 262d? | 2014-12-15 A | 2015-12-15 A | 100% | finish no earlier than 2015-12-15 | R4 | 2096h | 2096h | LTE_CA_B25_B41_B41_B41-Perf | PCG-34 | Alcatel-Lucent | Alcatel-Lucent | Rel-13 | RP-66 | RP-151131 |
| 1100 | 297.53 | **LTE Advanced dual uplink inter-band Carrier Aggregation Class A1 in REL-13** | 262d? | 2014-12-15 A | 2015-12-15 A | 100% |  | R4 | 6288h | 6288h | LTE_CA_2UL_R13-A1 | PCG-34 | Huawei | Huawei | Rel-13 | RP-66 |  |
| 1101 | 297.53.1 | Core part: LTE Advanced dual uplink inter-band Carrier Aggregation Class A1 in REL-13 | 262d? | 2014-12-15 A | 2015-12-15 A | 100% | finish no earlier than 2015-12-15 | R4 | 2096h | 2096h | LTE_CA_2UL_R13-A1-Core | PCG-34 | Huawei | Huawei | Rel-13 | RP-66 | RP-151131 |
| 1102 | 297.53.2 | Perf. part: LTE Advanced dual uplink inter-band Carrier Aggregation Class A1 in REL-13 | 262d? | 2014-12-15 A | 2015-12-15 A | 100% | finish no earlier than 2015-12-15 | R4 | 2096h | 2096h | LTE_CA_2UL_R13-A1-Perf | PCG-34 | Huawei | Huawei | Rel-13 | RP-66 | RP-151131 |

Notes:
- 1080: 1st Apr 15: Compl:0%->50% 1st Apr 15: WID: RP-142198->RP-150449 1st Apr 15: Stat Rep: ->RP-150013 03/07/15: Compl:50%->95% 03/07/15: Stat Rep: RP-150013->RP-150536 29/09/15: Stat Rep: RP-150536->RP-151131
- 1081: 1st Apr 15: Compl:0%->50% 1st Apr 15: WID: RP-142198->RP-150449 1st Apr 15: Stat Rep: ->RP-150013 03/07/15: Compl:50%->95% 03/07/15: Stat Rep: RP-150013->RP-150536 29/09/15: Stat Rep: RP-150536->RP-151131
- 1083: 1st Apr 15: Compl:0%->50% 1st Apr 15: CD:Tue 15/12/15->Tue 15/09/15 1st Apr 15: WID: RP-142199->RP-150448 1st Apr 15: Stat Rep: ->RP-150013 03/07/15: Compl:50%->95% 03/07/15: CD:Tue 15/09/15->Tue 15/12/15 03/07/15: Stat Rep: RP-150013->RP-150536 29/09...; ; ; ; ; ; ; ; ; ; ; ; ; ; ; ; ; ; ; ; ; ; ; ; ; ; ; ; ; ; ; ; ; ; ; ; ; ; ; ; ; ; ; ; ; ; ; ; ; ; ; ; ; ; ; ; ; ; ; ; ; ; ; ; ; ; ; ; ; ; ; ; ; ; ; ; ; ; ; ; ; ; ; ; ; ; ; ; ; ; ; ; ; ; ; ; ; ; ; ; ; ; ; ; ; ; ; ; ; ; ; ; ; ; ; ; ; ; ; ; ; ; ; ; ; ; ; ; ; ; ; ; ; ; ; ; ; ; ; ; ; ; ; ; 1/1/16: Compl:95%->100%
- 1084: 1st Apr 15: Compl:0%->50% 1st Apr 15: WID: RP-142199->RP-150448 1st Apr 15: Stat Rep: ->RP-150013 03/07/15: Compl:50%->95% 03/07/15: Stat Rep: RP-150013->RP-150536 29/09/15: Stat Rep: RP-150536->RP-151131
- 1086: 1st Apr 15: Compl:0%->50% 1st Apr 15: WID: RP-142200->RP-150450 1st Apr 15: Stat Rep: ->RP-150013 03/07/15: Compl:50%->95% 03/07/15: Stat Rep: RP-150013->RP-150536 29/09/15: Stat Rep: RP-150536->RP-151131
- 1087: 1st Apr 15: Compl:0%->50% 1st Apr 15: WID: RP-142200->RP-150450 1st Apr 15: Stat Rep: ->RP-150013 03/07/15: Compl:50%->95% 03/07/15: Stat Rep: RP-150013->RP-150536 29/09/15: Stat Rep: RP-150536->RP-151131
- 1089: 1st Apr 15: Compl:0%->50% 1st Apr 15: WID: RP-142201->RP-150452 1st Apr 15: Stat Rep: ->RP-150013 03/07/15: Compl:50%->95% 03/07/15: Stat Rep: RP-150013->RP-150536 29/09/15: Stat Rep: RP-150536->RP-151131
- 1090: 1st Apr 15: Compl:0%->50% 1st Apr 15: WID: RP-142201->RP-150452 1st Apr 15: Stat Rep: ->RP-150013 03/07/15: Compl:50%->95% 03/07/15: Stat Rep: RP-150013->RP-150536 29/09/15: Stat Rep: RP-150536->RP-151131
- 1092: 1st Apr 15: Compl:0%->50% 1st Apr 15: WID: RP-142202->RP-150451 1st Apr 15: Stat Rep: ->RP-150013 03/07/15: Compl:50%->95% 03/07/15: Stat Rep: RP-150013->RP-150536 29/09/15: Stat Rep: RP-150536->RP-151131
- 1093: 1st Apr 15: Compl:0%->50% 1st Apr 15: WID: RP-142202->RP-150451 1st Apr 15: Stat Rep: ->RP-150013 03/07/15: Compl:50%->95% 03/07/15: Stat Rep: RP-150013->RP-150536 29/09/15: Stat Rep: RP-150536->RP-151131
- 1095: 1st Apr 15: Compl:0%->50% 1st Apr 15: WID: RP-142203->RP-150453 1st Apr 15: Stat Rep: ->RP-150013 03/07/15: Compl:50%->95% 03/07/15: Stat Rep: RP-150013->RP-150536 29/09/15: Stat Rep: RP-150536->RP-151131
- 1096: 1st Apr 15: Compl:0%->50% 1st Apr 15: WID: RP-142203->RP-150453 1st Apr 15: Stat Rep: ->RP-150013 03/07/15: Compl:50%->95% 03/07/15: Stat Rep: RP-150013->RP-150536 29/09/15: Stat Rep: RP-150536->RP-151131
- 1098: 1st Apr 15: Compl:0%->50% 1st Apr 15: Stat Rep: ->RP-150013 03/07/15: Compl:50%->90% 03/07/15: Stat Rep: RP-150013->RP-150536 29/09/15: Compl:90%->95% 29/09/15: CD:Tue 15/09/15->Tue 15/12/15 29/09/15: Stat Rep: RP-150536->RP-151131...
- 1099: 1st Apr 15: Compl:0%->25% 1st Apr 15: Stat Rep: ->RP-150013 03/07/15: Compl:25%->75% 03/07/15: Stat Rep: RP-150013->RP-150536 29/09/15: Compl:75%->80% 29/09/15: Stat Rep: RP-150536->RP-151131...
- 1101: 1st Apr 15: Compl:0%->40% 1st Apr 15: WID: RP-141935->RP-150411 1st Apr 15: Stat Rep: ->RP-150013 03/07/15: Compl:40%->60% 03/07/15: WID: RP-150411->RP-150678 03/07/15: Stat Rep: RP-150013->RP-150536 29/09/15: Compl:60%->80% 29/09/15: Stat Rep: RP-150...; ; ; ; ; ; ; ; ; ; ; ; ; ; ; ; ; ; ; ; ; ; ; ; ; ; ; ; ; ; ; ; ; ; ; ; ; ; ; ; ; ; ; ; ; ; ; ; ; ; ; ; ; ; ; ; ; ; ; ; ; ; ; ; ; ; ; ; ; ; ; ; ; ; ; ; ; ; ; ; ; ; ; ; ; ; ; ; ; ; ; ; ; ; ; ; ; ; ; ; ; ; ; ; ; ; ; ; ; ; ; ; ; ; ; ; ; ; ; ; ; ; ; ; ; ; ; ; ; ; ; ; ; ; ; ; ; ; ; ; ; ; ; ; ; ; ; ; ; ; ; ; ; ; ; ; ; ; ; ; ; ; ; ; ; ; ; ; ; ; ; ; ; ; ; ; ; ; ; ; ; ; ; ; ; ; ; ; ; ; ; ; ; ; ; ; ; ; ; ; 1/1/16: Compl:80%->100%
- 1102: 1st Apr 15: Compl:0%->40% 1st Apr 15: WID: RP-141935->RP-150411 1st Apr 15: Stat Rep: ->RP-150013 03/07/15: Compl:40%->60% 03/07/15: WID: RP-150411->RP-150678 03/07/15: Stat Rep: RP-150013->RP-150536 29/09/15: Compl:60%->80% 29/09/15: Stat Rep: RP-150...; ; ; ; ; ; ; ; ; ; ; ; ; ; ; ; ; ; ; ; ; ; ; ; ; ; ; ; ; ; ; ; ; ; ; ; ; ; ; ; ; ; ; ; ; ; ; ; ; ; ; ; ; ; ; ; ; ; ; ; ; ; ; ; ; ; ; ; ; ; ; ; ; ; ; ; ; ; ; ; ; ; ; ; ; ; ; ; ; ; ; ; ; ; ; ; ; ; ; ; ; ; ; ; ; ; ; ; ; ; ; ; ; ; ; ; ; ; ; ; ; ; ; ; ; ; ; ; ; ; ; ; ; ; ; ; ; ; ; ; ; ; ; ; ; ; ; ; ; ; ; ; ; ; ; ; ; ; ; ; ; ; ; ; ; ; ; ; ; ; ; ; ; ; ; ; ; ; ; ; ; ; ; ; ; ; ; ; ; ; ; ; ; ; ; ; ; ; ; ; ; 1/1/16: Compl:80%->100%

| ID | WBS | Task | Duration | Start | Finish | Complete | Baseline start | Baseline finish | Baseline duration | Constraint | Resources | Work | Actual work | Acronym | PCG approved | WI rapporteur name | WI rapporteur e-mail | Release | TSG approved | Status Report | Acronym_3GU_Export |
| --- | --- | --- | --- | --- | --- | --- | --- | --- | --- | --- | --- | --- | --- | --- | --- | --- | --- | --- | --- | --- | --- |
| 1103 | 297.54 | **LTE Advanced dual uplink inter-band Carrier Aggregation Class A2 in REL-13** | 262d? | 2014-12-15 A | 2015-12-15 A | 100% |  |  |  |  | R4 | 6288h | 6288h | LTE_CA_2UL_R13-A2 | PCG-34 | Qualcomm | Qualcomm | Rel-13 | RP-66 |  |  |
| 1104 | 297.54.1 | Core part: LTE Advanced dual uplink inter-band Carrier Aggregation Class A2 in REL-13 | 262d? | 2014-12-15 A | 2015-12-15 A | 100% |  |  |  | finish no earlier than 2015-12-15 | R4 | 2096h | 2096h | LTE_CA_2UL_R13-A2-Core | PCG-34 | Qualcomm | Qualcomm | Rel-13 | RP-66 | RP-151131 |  |
| 1105 | 297.54.2 | Perf. part: LTE Advanced dual uplink inter-band Carrier Aggregation Class A2 in REL-13 | 262d? | 2014-12-15 A | 2015-12-15 A | 100% |  |  |  | finish no earlier than 2015-12-15 | R4 | 2096h | 2096h | LTE_CA_2UL_R13-A2-Perf | PCG-34 | Qualcomm | Qualcomm | Rel-13 | RP-66 | RP-151131 |  |
| 1106 | 297.55 | **LTE Advanced dual uplink inter-band Carrier Aggregation Class A3 in REL-13** | 262d? | 2014-12-15 A | 2015-12-15 A | 100% |  |  |  |  | R4 | 6288h | 6288h | LTE_CA_2UL_R13-A3 | PCG-34 | Ericsson | Ericsson | Rel-13 | RP-66 |  |  |
| 1107 | 297.55.1 | Core part: LTE Advanced dual uplink inter-band Carrier Aggregation Class A3 in REL-13 | 262d? | 2014-12-15 A | 2015-12-15 A | 100% |  |  |  | finish no earlier than 2015-12-15 | R4 | 2096h | 2096h | LTE_CA_2UL_R13-A3-Core | PCG-34 | Ericsson | Ericsson | Rel-13 | RP-66 | RP-151131 |  |
| 1108 | 297.55.2 | Perf. part: LTE Advanced dual uplink inter-band Carrier Aggregation Class A3 in REL-13 | 262d? | 2014-12-15 A | 2015-12-15 A | 100% |  |  |  | finish no earlier than 2015-12-15 | R4 | 2096h | 2096h | LTE_CA_2UL_R13-A3-Perf | PCG-34 | Ericsson | Ericsson | Rel-13 | RP-66 | RP-151131 |  |
| 1109 | 297.56 | **LTE Advanced intra-band non-contiguous Carrier Aggregation in Band 41 for 4 DL** | 262d? | 2014-12-15 A | 2015-12-15 A | 100% |  |  |  |  | R4 | 6288h | 6288h | LTE_CA_NC_B41_4DL | PCG-34 | Alcatel-Lucent | Alcatel-Lucent | Rel-13 | RP-66 |  |  |
| 1110 | 297.56.1 | Core part: LTE Advanced intra-band non-contiguous Carrier Aggregation in Band 41 for 4 DL | 262d? | 2014-12-15 A | 2015-12-15 A | 100% |  |  |  | finish no earlier than 2015-12-15 | R4 | 2096h | 2096h | LTE_CA_NC_B41_4DL-Core | PCG-34 | Alcatel-Lucent | Alcatel-Lucent | Rel-13 | RP-66 | RP-151131 |  |
| 1111 | 297.56.2 | Perf. part: LTE Advanced intra-band non-contiguous Carrier Aggregation in Band 41 for 4 DL | 262d? | 2014-12-15 A | 2015-12-15 A | 100% | 2013-09-18 | 2015-12-24 | 593d? | finish no earlier than 2015-12-15 | R4 | 2096h | 2096h | LTE_CA_NC_B41_4DL-Perf | PCG-31 | Alcatel-Lucent | Alcatel-Lucent | Rel-13 | RP-66 | RP-151131 | TEI13 |
| 1112 | 297.57 | **LTE Advanced 3 Band Carrier Aggregation (3DL/1UL) of Band 1, Band 3 and Band 42** | 66d? | 2015-03-16 A | 2015-06-15 A | 100% |  |  |  |  | R4 | 1584h | 1584h | LTE_CA_B1_B3_B42 | PCG-34 | NTT DOCOMO, INC. |  | Rel-13 | RP-67 |  |  |
| 1113 | 297.57.1 | Core part: LTE Advanced 3 Band Carrier Aggregation (3DL/1UL) of Band 1, Band 3 and Band 42 | 66d? | 2015-03-16 A | 2015-06-15 A | 100% |  |  |  | finish no earlier than 2015-09-15 | R4 | 528h | 528h | LTE_CA_B1_B3_B42-Core | PCG-34 | NTT DOCOMO, INC. |  | Rel-13 | RP-67 | RP-150536 |  |
| 1114 | 297.57.2 | Perf. part: LTE Advanced 3 Band Carrier Aggregation (3DL/1UL) of Band 1, Band 3 and Band 42 | 66d? | 2015-03-16 A | 2015-06-15 A | 100% |  |  |  | finish no earlier than 2015-09-15 | R4 | 528h | 528h | LTE_CA_B1_B3_B42-Perf | PCG-34 | NTT DOCOMO, INC. |  | Rel-13 | RP-67 | RP-150536 |  |
| 1115 | 297.58 | **LTE Advanced 3 Band Carrier Aggregation (3DL/1UL) of Band 1, Band 19 and Band 42** | 66d? | 2015-03-16 A | 2015-06-15 A | 100% |  |  |  |  | R4 | 1584h | 1584h | LTE_CA_B1_B19_B42 | PCG-34 | NTT DOCOMO, INC. |  | Rel-13 | RP-67 |  |  |
| 1116 | 297.58.1 | Core part: LTE Advanced 3 Band Carrier Aggregation (3DL/1UL) of Band 1, Band 19 and Band 42 | 66d? | 2015-03-16 A | 2015-06-15 A | 100% |  |  |  | finish no earlier than 2015-09-15 | R4 | 528h | 528h | LTE_CA_B1_B19_B42-Core | PCG-34 | NTT DOCOMO, INC. |  | Rel-13 | RP-67 | RP-150536 |  |
| 1117 | 297.58.2 | Perf. part: LTE Advanced 3 Band Carrier Aggregation (3DL/1UL) of Band 1, Band 19 and Band 42 | 66d? | 2015-03-16 A | 2015-06-15 A | 100% |  |  |  | finish no earlier than 2015-09-15 | R4 | 528h | 528h | LTE_CA_B1_B19_B42-Perf | PCG-34 | NTT DOCOMO, INC. |  | Rel-13 | RP-67 | RP-150536 |  |
| 1118 | 297.59 | **LTE Advanced 3 Band Carrier Aggregation (3DL/1UL) of Band 1, Band 21 and Band 42** | 66d? | 2015-03-16 A | 2015-06-15 A | 100% |  |  |  |  | R4 | 1584h | 1584h | LTE_CA_B1_B21_B42 | PCG-34 | NTT DOCOMO, INC. |  | Rel-13 | RP-67 |  |  |
| 1119 | 297.59.1 | Core part: LTE Advanced 3 Band Carrier Aggregation (3DL/1UL) of Band 1, Band 21 and Band 42 | 66d? | 2015-03-16 A | 2015-06-15 A | 100% |  |  |  | finish no earlier than 2015-09-15 | R4 | 528h | 528h | LTE_CA_B1_B21_B42-Core | PCG-34 | NTT DOCOMO, INC. |  | Rel-13 | RP-67 | RP-150536 |  |
| 1120 | 297.59.2 | Perf. part: LTE Advanced 3 Band Carrier Aggregation (3DL/1UL) of Band 1, Band 21 and Band 42 | 66d? | 2015-03-16 A | 2015-06-15 A | 100% |  |  |  | finish no earlier than 2015-09-15 | R4 | 528h | 528h | LTE_CA_B1_B21_B42-Perf | PCG-34 | NTT DOCOMO, INC. |  | Rel-13 | RP-67 | RP-150536 |  |
| 1121 | 297.60 | **LTE Advanced 3 Band Carrier Aggregation (3DL/1UL) of Band 3, Band 19 and Band 42** | 66d? | 2015-03-16 A | 2015-06-15 A | 100% |  |  |  |  | R4 | 1584h | 1584h | LTE_CA_B3_B19_B42 | PCG-34 | NTT DOCOMO, INC. |  | Rel-13 | RP-67 |  |  |
| 1122 | 297.60.1 | Core part: LTE Advanced 3 Band Carrier Aggregation (3DL/1UL) of Band 3, Band 19 and Band 42 | 66d? | 2015-03-16 A | 2015-06-15 A | 100% |  |  |  | finish no earlier than 2015-09-15 | R4 | 528h | 528h | LTE_CA_B3_B19_B42-Core | PCG-34 | NTT DOCOMO, INC. |  | Rel-13 | RP-67 | RP-150536 |  |
| 1123 | 297.60.2 | Perf. part: LTE Advanced 3 Band Carrier Aggregation (3DL/1UL) of Band 3, Band 19 and Band 42 | 66d? | 2015-03-16 A | 2015-06-15 A | 100% |  |  |  | finish no earlier than 2015-09-15 | R4 | 528h | 528h | LTE_CA_B3_B19_B42-Perf | PCG-34 | NTT DOCOMO, INC. |  | Rel-13 | RP-67 | RP-150536 |  |
| 1124 | 297.61 | **LTE Advanced 3 Band Carrier Aggregation (3DL/1UL) of Band 19, Band 21 and Band 42** | 66d? | 2015-03-16 A | 2015-06-15 A | 100% |  |  |  |  | R4 | 1584h | 1584h | LTE_CA_B19_B21_B42 | PCG-34 | NTT DOCOMO, INC. |  | Rel-13 | RP-67 |  |  |
| 1125 | 297.61.1 | Core part: LTE Advanced 3 Band Carrier Aggregation (3DL/1UL) of Band 19, Band 21 and Band 42 | 66d? | 2015-03-16 A | 2015-06-15 A | 100% |  |  |  | finish no earlier than 2015-09-15 | R4 | 528h | 528h | LTE_CA_B19_B21_B42-Core | PCG-34 | NTT DOCOMO, INC. |  | Rel-13 | RP-67 | RP-150536 |  |
| 1126 | 297.61.2 | Perf. part: LTE Advanced 3 Band Carrier Aggregation (3DL/1UL) of Band 19, Band 21 and Band 42 | 66d? | 2015-03-16 A | 2015-06-15 A | 100% |  |  |  | finish no earlier than 2015-09-15 | R4 | 528h | 528h | LTE_CA_B19_B21_B42-Perf | PCG-34 | NTT DOCOMO, INC. |  | Rel-13 | RP-67 | RP-150536 |  |

Notes:
- 1104: 1st Apr 15: Compl:0%->50% 1st Apr 15: WID: RP-141975->RP-150408 1st Apr 15: Stat Rep: ->RP-150013 03/07/15: Stat Rep: RP-150013->RP-150536 29/09/15: Stat Rep: RP-150536->RP-151131...
- 1105: 1st Apr 15: Compl:0%->50% 1st Apr 15: WID: RP-141975->RP-150408 1st Apr 15: Stat Rep: ->RP-150013 03/07/15: Stat Rep: RP-150013->RP-150536 29/09/15: Stat Rep: RP-150536->RP-151131...
- 1107: 1st Apr 15: Compl:0%->25% 1st Apr 15: WID: RP-142010->RP-150409 1st Apr 15: Stat Rep: ->RP-150013 03/07/15: Compl:25%->50% 03/07/15: Stat Rep: RP-150013->RP-150536 29/09/15: Compl:50%->75% 29/09/15: Stat Rep: RP-150536->RP-151131; ...
- 1108: 1st Apr 15: Compl:0%->25% 1st Apr 15: WID: RP-142010->RP-150409 1st Apr 15: Stat Rep: ->RP-150013 03/07/15: Compl:25%->50% 03/07/15: Stat Rep: RP-150013->RP-150536 29/09/15: Compl:50%->75% 29/09/15: Stat Rep: RP-150536->RP-151131; ...
- 1110: 1st Apr 15: Compl:0%->10% 1st Apr 15: CD:Tue 15/03/16->Tue 15/12/15 1st Apr 15: Stat Rep: ->RP-150013 03/07/15: Compl:10%->50% 03/07/15: Stat Rep: RP-150013->RP-150536 29/09/15: Compl:50%->80% 29/09/15: Stat Rep: RP-150536->RP-151131 ...
- 1111: 1st Apr 15: Compl:0%->10% 1st Apr 15: CD:Tue 18/12/18->Tue 15/12/15 1st Apr 15: Stat Rep: -->RP-150013 03/07/15: Compl:10%->25% 03/07/15: Stat Rep: RP-150013->RP-150536 29/09/15: Compl:25%->50% 29/09/15: Stat Rep: RP-150536->RP-151131 ;
- 1113: 03/07/15: Compl:0%->100% 03/07/15: CD:Tue 15/09/15->Mon 15/06/15 03/07/15: WID: RP-150121->RP-150641 03/07/15: Stat Rep: ->RP-150536
- 1114: 03/07/15: Compl:0%->100% 03/07/15: CD:Tue 15/09/15->Mon 15/06/15 03/07/15: WID: RP-150121->RP-150641 03/07/15: Stat Rep: ->RP-150536
- 1116: 03/07/15: Compl:0%->100% 03/07/15: CD:Tue 15/09/15->Mon 15/06/15 03/07/15: WID: RP-150122->RP-150642 03/07/15: Stat Rep: ->RP-150536
- 1117: 03/07/15: Compl:0%->100% 03/07/15: CD:Tue 15/09/15->Mon 15/06/15 03/07/15: WID: RP-150122->RP-150642 03/07/15: Stat Rep: ->RP-150536
- 1119: 03/07/15: Compl:0%->100% 03/07/15: CD:Tue 15/09/15->Mon 15/06/15 03/07/15: WID: RP-150123->RP-150643 03/07/15: Stat Rep: ->RP-150536
- 1120: 03/07/15: Compl:0%->100% 03/07/15: CD:Tue 15/09/15->Mon 15/06/15 03/07/15: WID: RP-150123->RP-150643 03/07/15: Stat Rep: ->RP-150536
- 1122: 03/07/15: Compl:0%->100% 03/07/15: CD:Tue 15/09/15->Mon 15/06/15 03/07/15: WID: RP-150124->RP-150644 03/07/15: Stat Rep: ->RP-150536
- 1123: 03/07/15: Compl:0%->100% 03/07/15: CD:Tue 15/09/15->Mon 15/06/15 03/07/15: WID: RP-150124->RP-150644 03/07/15: Stat Rep: ->RP-150536
- 1125: 03/07/15: Compl:0%->100% 03/07/15: CD:Tue 15/09/15->Mon 15/06/15 03/07/15: WID: RP-150125->RP-150645 03/07/15: Stat Rep: ->RP-150536
- 1126: 03/07/15: Compl:0%->100% 03/07/15: CD:Tue 15/09/15->Mon 15/06/15 03/07/15: WID: RP-150125->RP-150645 03/07/15: Stat Rep: ->RP-150536

| ID | WBS | Task | Duration | Start | Finish | Complete | Constraint | Resources | Work | Actual work | Acronym | PCG approved | WI rapporteur name | Release | TSG approved | Status Report |
| --- | --- | --- | --- | --- | --- | --- | --- | --- | --- | --- | --- | --- | --- | --- | --- | --- |
| 1127 | 297.62 | **Additional bandwidth combination set for LTE Advanced 3 Band Carrier Aggregation (3DL/1UL) of Band 4, Band 4 and Band 7** | 197d? | 2015-03-16 A | 2015-12-15 A | 100% |  | R4 | 4728h | 4728h | LTE_CA_B4_B4_B7_BWset | PCG-34 | Rogers Communications | Rel-13 | RP-67 |  |
| 1128 | 297.62.1 | Core part: Additional bandwidth combination set for LTE Advanced 3 Band Carrier Aggregation (3DL/1UL) of Band 4, Band 4 and Band 7 | 197d? | 2015-03-16 A | 2015-12-15 A | 100% | finish no earlier than 2015-12-15 | R4 | 1576h | 1576h | LTE_CA_B4_B4_B7_BWset-Core | PCG-34 | Rogers Communications | Rel-13 | RP-67 | RP-151131 |
| 1129 | 297.62.2 | Perf. part: Additional bandwidth combination set for LTE Advanced 3 Band Carrier Aggregation (3DL/1UL) of Band 4, Band 4 and Band 7 | 197d? | 2015-03-16 A | 2015-12-15 A | 100% | finish no earlier than 2015-12-15 | R4 | 1576h | 1576h | LTE_CA_B4_B4_B7_BWset-Perf | PCG-34 | Rogers Communications | Rel-13 | RP-67 | RP-151131 |
| 1130 | 297.63 | **Additional bandwidth combination set for LTE Advanced 3 Band Carrier Aggregation (3DL/1UL) of Band 4, Band 7 and Band 12** | 197d? | 2015-03-16 A | 2015-12-15 A | 100% |  | R4 | 4728h | 4728h | LTE_CA_B4_B7_B12_BWset | PCG-34 | Rogers Communications | Rel-13 | RP-67 |  |
| 1131 | 297.63.1 | Core part: Additional bandwidth combination set for LTE Advanced 3 Band Carrier Aggregation (3DL/1UL) of Band 4, Band 7 and Band 12 | 197d? | 2015-03-16 A | 2015-12-15 A | 100% | finish no earlier than 2015-12-15 | R4 | 1576h | 1576h | LTE_CA_B4_B7_B12_BWset-Core | PCG-34 | Rogers Communications | Rel-13 | RP-67 | RP-151131 |
| 1132 | 297.63.2 | Perf. part: Additional bandwidth combination set for LTE Advanced 3 Band Carrier Aggregation (3DL/1UL) of Band 4, Band 7 and Band 12 | 197d? | 2015-03-16 A | 2015-12-15 A | 100% | finish no earlier than 2015-12-15 | R4 | 1576h | 1576h | LTE_CA_B4_B7_B12_BWset-Perf | PCG-34 | Rogers Communications | Rel-13 | RP-67 | RP-151131 |
| 1133 | 297.64 | **LTE Advanced 3 Band Carrier Aggregation (3DL/1UL) of Band 2, Band 7 and Band 12** | 262d? | 2015-03-16 A | 2016-03-15 A | 100% |  | R4 | 6288h | 6288h | LTE_CA_B2_B7_B12 | PCG-34 | Rogers Communications | Rel-13 | RP-67 |  |
| 1134 | 297.64.1 | Core part: LTE Advanced 3 Band Carrier Aggregation (3DL/1UL) of Band 2, Band 7 and Band 12 | 262d? | 2015-03-16 A | 2016-03-15 A | 100% | finish no earlier than 2016-03-15 | R4 | 2096h | 2096h | LTE_CA_B2_B7_B12-Core | PCG-34 | Rogers Communications | Rel-13 | RP-67 | RP-151131 |
| 1135 | 297.64.2 | Perf. part: LTE Advanced 3 Band Carrier Aggregation (3DL/1UL) of Band 2, Band 7 and Band 12 | 262d? | 2015-03-16 A | 2016-03-15 A | 100% | finish no earlier than 2016-03-15 | R4 | 2096h | 2096h | LTE_CA_B2_B7_B12-Perf | PCG-34 | Rogers Communications | Rel-13 | RP-67 | RP-151131 |
| 1136 | 297.65 | **LTE Advanced 3 Band Carrier Aggregation (3DL/1UL) of Band 2, Band 4 and Band 7** | 262d? | 2015-03-16 A | 2016-03-15 A | 100% |  | R4 | 6288h | 6288h | LTE_CA_B2_B4_B7 | PCG-34 | Rogers Communications | Rel-13 | RP-67 |  |
| 1137 | 297.65.1 | Core part: LTE Advanced 3 Band Carrier Aggregation (3DL/1UL) of Band 2, Band 4 and Band 7 | 262d? | 2015-03-16 A | 2016-03-15 A | 100% | finish no earlier than 2016-03-15 | R4 | 2096h | 2096h | LTE_CA_B2_B4_B7-Core | PCG-34 | Rogers Communications | Rel-13 | RP-67 | RP-151131 |
| 1138 | 297.65.2 | Perf. part: LTE Advanced 3 Band Carrier Aggregation (3DL/1UL) of Band 2, Band 4 and Band 7 | 262d? | 2015-03-16 A | 2016-03-15 A | 100% | finish no earlier than 2016-03-15 | R4 | 2096h | 2096h | LTE_CA_B2_B4_B7-Perf | PCG-34 | Rogers Communications | Rel-13 | RP-67 | RP-151131 |
| 1139 | 297.66 | **LTE Advanced 3 Band Carrier Aggregation (3DL/1UL) of Band 7, Band 20 and Band 38** | 197d? | 2015-03-16 A | 2015-12-15 A | 100% |  | R4 | 4728h | 4728h | LTE_CA_B7_B20_B38 | PCG-34 | Nokia Networks | Rel-13 | RP-67 |  |
| 1140 | 297.66.1 | Core part: LTE Advanced 3 Band Carrier Aggregation (3DL/1UL) of Band 7, Band 20 and Band 38 | 197d? | 2015-03-16 A | 2015-12-15 A | 100% | finish no earlier than 2015-12-15 | R4 | 1576h | 1576h | LTE_CA_B7_B20_B38-Core | PCG-34 | Nokia Networks | Rel-13 | RP-67 | RP-151131 |
| 1141 | 297.66.2 | Perf. part: LTE Advanced 3 Band Carrier Aggregation (3DL/1UL) of Band 7, Band 20 and Band 38 | 197d? | 2015-03-16 A | 2015-12-15 A | 100% | finish no earlier than 2015-12-15 | R4 | 1576h | 1576h | LTE_CA_B7_B20_B38-Perf | PCG-34 | Nokia Networks | Rel-13 | RP-67 | RP-151131 |
| 1142 | 297.67 | **LTE Advanced 4 Band Carrier Aggregation (4DL/1UL) of Band 2, Band 4, Band 4 and Band 12** | 197d? | 2015-03-16 A | 2015-12-15 A | 100% |  | R4 | 4728h | 4728h | LTE_CA_B2_B4_B4_B12 | PCG-34 | Nokia Networks | Rel-13 | RP-67 |  |
| 1143 | 297.67.1 | Core part: LTE Advanced 4 Band Carrier Aggregation (4DL/1UL) of Band 2, Band 4, Band 4 and Band 12 | 197d? | 2015-03-16 A | 2015-12-15 A | 100% | finish no earlier than 2015-12-15 | R4 | 1576h | 1576h | LTE_CA_B2_B4_B4_B12-Core | PCG-34 | Nokia Networks | Rel-13 | RP-67 | RP-151131 |
| 1144 | 297.67.2 | Perf. part: LTE Advanced 4 Band Carrier Aggregation (4DL/1UL) of Band 2, Band 4, Band 4 and Band 12 | 197d? | 2015-03-16 A | 2015-12-15 A | 100% | finish no earlier than 2015-12-15 | R4 | 1576h | 1576h | LTE_CA_B2_B4_B4_B12-Perf | PCG-34 | Nokia Networks | Rel-13 | RP-67 | RP-151131 |
| 1145 | 297.68 | **LTE Advanced 4 Band Carrier Aggregation (4DL/1UL) of Band 2, Band 2, Band 4 and Band 12** | 197d? | 2015-03-16 A | 2015-12-15 A | 100% |  | R4 | 4728h | 4728h | LTE_CA_B2_B2_B4_B12 | PCG-34 | Nokia Networks | Rel-13 | RP-67 |  |
| 1146 | 297.68.1 | Core part: LTE Advanced 4 Band Carrier Aggregation (4DL/1UL) of Band 2, Band 2, Band 4 and Band 12 | 197d? | 2015-03-16 A | 2015-12-15 A | 100% | finish no earlier than 2015-12-15 | R4 | 1576h | 1576h | LTE_CA_B2_B2_B4_B12-Core | PCG-34 | Nokia Networks | Rel-13 | RP-67 | RP-151131 |
| 1147 | 297.68.2 | Perf. part: LTE Advanced 4 Band Carrier Aggregation (4DL/1UL) of Band 2, Band 2, Band 4 and Band 12 | 197d? | 2015-03-16 A | 2015-12-15 A | 100% | finish no earlier than 2015-12-15 | R4 | 1576h | 1576h | LTE_CA_B2_B2_B4_B12-Perf | PCG-34 | Nokia Networks | Rel-13 | RP-67 | RP-151131 |
| 1148 | 297.69 | **LTE Advanced 4 Band Carrier Aggregation (4DL/1UL) of Band 2, Band 2, Band 4 and Band 4** | 197d? | 2015-03-16 A | 2015-12-15 A | 100% |  | R4 | 4728h | 4728h | LTE_CA_B2_B2_B4_B4 | PCG-34 | Nokia Networks | Rel-13 | RP-67 |  |
| 1149 | 297.69.1 | Core part: LTE Advanced 4 Band Carrier Aggregation (4DL/1UL) of Band 2, Band 2, Band 4 and Band 4 | 197d? | 2015-03-16 A | 2015-12-15 A | 100% | finish no earlier than 2015-12-15 | R4 | 1576h | 1576h | LTE_CA_B2_B2_B4_B4-Core | PCG-34 | Nokia Networks | Rel-13 | RP-67 | RP-151131 |
| 1150 | 297.69.2 | Perf. part: LTE Advanced 4 Band Carrier Aggregation (4DL/1UL) of Band 2, Band 2, Band 4 and Band 4 | 197d? | 2015-03-16 A | 2015-12-15 A | 100% | finish no earlier than 2015-12-15 | R4 | 1576h | 1576h | LTE_CA_B2_B2_B4_B4-Perf | PCG-34 | Nokia Networks | Rel-13 | RP-67 | RP-151131 |

Notes:
- 1128: 03/07/15: CD:Tue 15/09/15->Tue 15/12/15 03/07/15: Stat Rep: ->RP-150536 29/09/15: Stat Rep: RP-150536->RP-151131
- 1129: 03/07/15: CD:Tue 15/09/15->Tue 15/12/15 03/07/15: Stat Rep: ->RP-150536 29/09/15: Stat Rep: RP-150536->RP-151131
- 1131: 03/07/15: CD:Tue 15/09/15->Tue 15/12/15 03/07/15: Stat Rep: ->RP-150536 29/09/15: Stat Rep: RP-150536->RP-151131
- 1132: 03/07/15: CD:Tue 15/09/15->Tue 15/12/15 03/07/15: Stat Rep: ->RP-150536 29/09/15: Stat Rep: RP-150536->RP-151131
- 1134: 03/07/15: Stat Rep: ->RP-150536 29/09/15: Stat Rep: RP-150536->RP-151131 ; 1/1...22/3/16: Compl:0%->100%
- 1135: 03/07/15: Stat Rep: ->RP-150536 29/09/15: Stat Rep: RP-150536->RP-151131 1...22/3/16: Compl:0%->100%
- 1137: 03/07/15: Stat Rep: ->RP-150536 29/09/15: Stat Rep: RP-150536->RP-1511311/1/16:...22/3/16: Compl:0%->100%
- 1138: 03/07/15: Stat Rep: ->RP-150536 29/09/15: Stat Rep: RP-150536->RP-151131 1/1/1...; 22/3/16: Compl:0%->100%
- 1140: 03/07/15: Compl:0%->30% 03/07/15: Stat Rep: ->RP-150536 29/09/15: Compl:30%->60% 29/09/15: Stat Rep: RP-150536->RP-151131...
- 1141: 03/07/15: Compl:0%->30% 03/07/15: Stat Rep: ->RP-150536 29/09/15: Compl:30%->60% 29/09/15: Stat Rep: RP-150536->RP-151131...
- 1143: 03/07/15: Compl:0%->95% 03/07/15: WID: RP-150073->RP-150660 03/07/15: Stat Rep: ->RP-150536 29/09/15: Stat Rep: RP-150536->RP-151131
- 1144: 03/07/15: Compl:0%->95% 03/07/15: WID: RP-150073->RP-150660 03/07/15: Stat Rep: ->RP-150536 29/09/15: Stat Rep: RP-150536->RP-151131
- 1146: 03/07/15: Compl:0%->95% 03/07/15: WID: RP-150074->RP-150659 03/07/15: Stat Rep: ->RP-150536 29/09/15: Stat Rep: RP-150536->RP-151131
- 1147: 03/07/15: Compl:0%->95% 03/07/15: WID: RP-150074->RP-150659 03/07/15: Stat Rep: ->RP-150536 29/09/15: Stat Rep: RP-150536->RP-151131
- 1149: 03/07/15: Compl:0%->95% 03/07/15: WID: RP-150075->RP-150658 03/07/15: Stat Rep: ->RP-150536 29/09/15: Stat Rep: RP-150536->RP-151131
- 1150: 03/07/15: Compl:0%->95% 03/07/15: WID: RP-150075->RP-150658 03/07/15: Stat Rep: ->RP-150536 29/09/15: Stat Rep: RP-150536->RP-151131

| ID | WBS | Task | Duration | Start | Finish | Complete | Constraint | Resources | Work | Actual work | Acronym | PCG approved | WI rapporteur name | Release | TSG approved | Status Report |
| --- | --- | --- | --- | --- | --- | --- | --- | --- | --- | --- | --- | --- | --- | --- | --- | --- |
| 1151 | 297.70 | **LTE Advanced 4 Band Carrier Aggregation (4DL/1UL) of Band 1, Band 3, Band 5 and Band 40** | 197d? | 2015-03-16 A | 2015-12-15 A | 100% |  | R4 | 4728h | 4728h | LTE_CA_B1_B3_B5_B40 | PCG-34 | SK Telecom | Rel-13 | RP-67 |  |
| 1152 | 297.70.1 | Core part: LTE Advanced 4 Band Carrier Aggregation (4DL/1UL) of Band 1, Band 3, Band 5 and Band 40 | 197d? | 2015-03-16 A | 2015-12-15 A | 100% | finish no earlier than 2015-12-15 | R4 | 1576h | 1576h | LTE_CA_B1_B3_B5_B40-Core | PCG-34 | SK Telecom | Rel-13 | RP-67 | RP-151131 |
| 1153 | 297.70.2 | Perf. part: LTE Advanced 4 Band Carrier Aggregation (4DL/1UL) of Band 1, Band 3, Band 5 and Band 40 | 197d? | 2015-03-16 A | 2015-12-15 A | 100% | finish no earlier than 2015-12-15 | R4 | 1576h | 1576h | LTE_CA_B1_B3_B5_B40-Perf | PCG-34 | SK Telecom | Rel-13 | RP-67 | RP-151131 |
| 1154 | 297.71 | **LTE Advanced 4 Band Carrier Aggregation (4DL/1UL) of Band 1, Band 3, Band 7 and Band 8** | 197d? | 2015-03-16 A | 2015-12-15 A | 100% |  | R4 | 4728h | 4728h | LTE_CA_B1_B3_B7_B8 | PCG-34 | Nokia Networks | Rel-13 | RP-67 |  |
| 1155 | 297.71.1 | Core part: LTE Advanced 4 Band Carrier Aggregation (4DL/1UL) of Band 1, Band 3, Band 7 and Band 8 | 197d? | 2015-03-16 A | 2015-12-15 A | 100% | finish no earlier than 2015-12-15 | R4 | 1576h | 1576h | LTE_CA_B1_B3_B7_B8-Core | PCG-34 | Nokia Networks | Rel-13 | RP-67 | RP-151131 |
| 1156 | 297.71.2 | Perf. part: LTE Advanced 4 Band Carrier Aggregation (4DL/1UL) of Band 1, Band 3, Band 7 and Band 8 | 197d? | 2015-03-16 A | 2015-12-15 A | 100% | finish no earlier than 2015-12-15 | R4 | 1576h | 1576h | LTE_CA_B1_B3_B7_B8-Perf | PCG-34 | Nokia Networks | Rel-13 | RP-67 | RP-151131 |
| 1157 | 297.72 | **LTE Advanced 4 Band Carrier Aggregation (4DL/1UL) of Band 2, Band 4, Band 5 and Band 29** | 197d? | 2015-03-16 A | 2015-12-15 A | 100% |  | R4 | 4728h | 4728h | LTE_CA_B2_B4_B5_B29 | PCG-34 | Huawei | Rel-13 | RP-67 |  |
| 1158 | 297.72.1 | Core part: LTE Advanced 4 Band Carrier Aggregation (4DL/1UL) of Band 2, Band 4, Band 5 and Band 29 | 197d? | 2015-03-16 A | 2015-12-15 A | 100% | finish no earlier than 2015-12-15 | R4 | 1576h | 1576h | LTE_CA_B2_B4_B5_B29-Core | PCG-34 | Huawei | Rel-13 | RP-67 | RP-151131 |
| 1159 | 297.72.2 | Perf. part: LTE Advanced 4 Band Carrier Aggregation (4DL/1UL) of Band 2, Band 4, Band 5 and Band 29 | 197d? | 2015-03-16 A | 2015-12-15 A | 100% | finish no earlier than 2015-12-15 | R4 | 1576h | 1576h | LTE_CA_B2_B4_B5_B29-Perf | PCG-34 | Huawei | Rel-13 | RP-67 | RP-151131 |
| 1160 | 297.73 | **LTE Advanced dual uplink inter-band Carrier Aggregation FDD-TDD** | 197d? | 2015-03-16 A | 2015-12-15 A | 100% |  | R4 | 4728h | 4728h | LTE_CA_2UL_FDD_TDD | PCG-34 | KDDI | Rel-13 | RP-67 |  |
| 1161 | 297.73.1 | Core part: LTE Advanced dual uplink inter-band Carrier Aggregation FDD-TDD | 197d? | 2015-03-16 A | 2015-12-15 A | 100% | finish no earlier than 2015-12-15 | R4 | 1576h | 1576h | LTE_CA_2UL_FDD_TDD-Core | PCG-34 | KDDI | Rel-13 | RP-67 | RP-151131 |
| 1162 | 297.73.2 | Perf. part: LTE Advanced dual uplink inter-band Carrier Aggregation FDD-TDD | 197d? | 2015-03-16 A | 2015-12-15 A | 100% | finish no earlier than 2015-12-15 | R4 | 1576h | 1576h | LTE_CA_2UL_FDD_TDD-Perf | PCG-34 | KDDI | Rel-13 | RP-67 | RP-151131 |
| 1163 | 297.74 | **LTE Advanced dual uplink inter-band Carrier Aggregation Class A4** | 197d? | 2015-03-16 A | 2015-12-15 A | 100% |  | R4 | 4728h | 4728h | LTE_CA_2UL_R13-A4 | PCG-34 | Nokia Networks | Rel-13 | RP-67 |  |
| 1164 | 297.74.1 | Core part: LTE Advanced dual uplink inter-band Carrier Aggregation Class A4 in REL-13 | 197d? | 2015-03-16 A | 2015-12-15 A | 100% | finish no earlier than 2015-12-15 | R4 | 1576h | 1576h | LTE_CA_2UL_R13-A4-Core | PCG-34 | Nokia Networks | Rel-13 | RP-67 | RP-151131 |
| 1165 | 297.74.2 | Perf. Part: LTE Advanced dual uplink inter-band Carrier Aggregation Class A4 in REL-13 | 197d? | 2015-03-16 A | 2015-12-15 A | 100% | finish no earlier than 2015-12-15 | R4 | 1576h | 1576h | LTE_CA_2UL_R13-A4-Perf | PCG-34 | Nokia Networks | Rel-13 | RP-67 | RP-151131 |
| 1166 | 297.75 | **LTE Advanced 3DL/2UL inter-band Carrier Aggregation** | 197d? | 2015-03-16 A | 2015-12-15 A | 100% |  | R4 | 4728h | 4728h | LTE_CA_3DL_2UL | PCG-34 | Nokia Corporation | Rel-13 | RP-67 |  |
| 1167 | 297.75.1 | Core part: LTE Advanced 3DL/2UL inter-band Carrier Aggregation | 197d? | 2015-03-16 A | 2015-12-15 A | 100% | finish no earlier than 2015-12-15 | R4 | 1576h | 1576h | LTE_CA_3DL_2UL-Core | PCG-34 | Nokia Corporation | Rel-13 | RP-67 | RP-151131 |
| 1168 | 297.75.2 | Perf. part: LTE Advanced 3DL/2UL inter-band Carrier Aggregation | 197d? | 2015-03-16 A | 2015-12-15 A | 100% | finish no earlier than 2015-12-15 | R4 | 1576h | 1576h | LTE_CA_3DL_2UL-Perf | PCG-34 | Nokia Corporation | Rel-13 | RP-67 | RP-151131 |
| 1169 | 297.76 | **LTE Advanced intra-band non-contiguous Carrier Aggregation in Band 42 for 3DL** | 66d? | 2015-03-16 A | 2015-06-15 A | 100% |  | R4 | 1584h | 1584h | LTE_CA_NC_B42_3DL | PCG-34 | Huawei | Rel-13 | RP-67 |  |
| 1170 | 297.76.1 | Core part: LTE Advanced intra-band non-contiguous Carrier Aggregation in Band 42 for 3DL | 66d? | 2015-03-16 A | 2015-06-15 A | 100% | finish no earlier than 2015-09-15 | R4 | 528h | 528h | LTE_CA_NC_B42_3DL-Core | PCG-34 | Huawei | Rel-13 | RP-67 | RP-150536 |
| 1171 | 297.76.2 | Perf. part: LTE Advanced intra-band non-contiguous Carrier Aggregation in Band 42 for 3DL | 66d? | 2015-03-16 A | 2015-06-15 A | 100% | finish no earlier than 2015-09-15 | R4 | 528h | 528h | LTE_CA_NC_B42_3DL-Perf | PCG-34 | Huawei | Rel-13 | RP-67 | RP-150536 |
| 1172 | 297.77 | **LTE Advanced intra-band contiguous Carrier Aggregation in Band 8** | 197d? | 2015-03-16 A | 2015-12-15 A | 100% |  | R4 | 4728h | 4728h | LTE_CA_C_B8 | PCG-34 | CMCC | Rel-13 | RP-67 |  |
| 1173 | 297.77.1 | Core part: LTE Advanced intra-band contiguous Carrier Aggregation in Band 8 | 197d? | 2015-03-16 A | 2015-12-15 A | 100% | finish no earlier than 2015-12-15 | R4 | 1576h | 1576h | LTE_CA_C_B8-Core | PCG-34 | CMCC | Rel-13 | RP-67 | RP-151131 |
| 1174 | 297.77.2 | Perf. part: LTE Advanced intra-band contiguous Carrier Aggregation in Band 8 | 197d? | 2015-03-16 A | 2015-12-15 A | 100% | finish no earlier than 2015-12-15 | R4 | 1576h | 1576h | LTE_CA_C_B8-Perf | PCG-34 | CMCC | Rel-13 | RP-67 | RP-151131 |

Notes:
- 1152: 03/07/15: Compl:0%->30% 03/07/15: WID: RP-150434->RP-150617 03/07/15: Stat Rep: ->RP-150536 29/09/15: Compl:30%->60% 29/09/15: CD:Tue 15/09/15->Tue 15/12/15 29/09/15: WID: RP-150617->RP-151216 29/09/15: Stat Rep: RP-150536->RP-151131 ...
- 1153: 03/07/15: WID: RP-150434->RP-150617 03/07/15: Stat Rep: ->RP-150536 29/09/15: CD:Tue 15/09/15->Tue 15/12/15 29/09/15: WID: RP-150617->RP-151216 29/09/15: Stat Rep: RP-150536->RP-151131
- 1155: 03/07/15: Compl:0%->40% 03/07/15: Stat Rep: ->RP-150536 29/09/15: Compl:40%->45% 29/09/15: Stat Rep: RP-150536->RP-151131...
- 1156: 03/07/15: Stat Rep: ->RP-150536 29/09/15: Stat Rep: RP-150536->RP-151131
- 1158: 03/07/15: Compl:0%->50% 03/07/15: Stat Rep: ->RP-150536 29/09/15: Compl:50%->95% 29/09/15: Stat Rep: RP-150536->RP-151131...
- 1159: 03/07/15: Stat Rep: ->RP-150536 29/09/15: Compl:0%->95% 29/09/15: Stat Rep: RP-150536->RP-151131
- 1161: 03/07/15: Compl:0%->70% 03/07/15: Stat Rep: ->RP-150536 29/09/15: Compl:70%->90% 29/09/15: Stat Rep: RP-150536->RP-151131...
- 1162: 03/07/15: CD:Tue 15/09/15->Tue 15/12/15 03/07/15: Stat Rep: ->RP-150536 29/09/15: Compl:0%->90% 29/09/15: Stat Rep: RP-150536->RP-151131
- 1164: 03/07/15: Compl:0%->25% 03/07/15: WID: RP-150410->RP-150616 03/07/15: Stat Rep: ->RP-150536 29/09/15: Compl:25%->75% 29/09/15: Stat Rep: RP-150536->RP-151131 ...
- 1165: 03/07/15: Compl:0%->25% 03/07/15: WID: RP-150410->RP-150616 03/07/15: Stat Rep: ->RP-150536 29/09/15: Compl:25%->75% 29/09/15: Stat Rep: RP-150536->RP-151131 ...
- 1167: 03/07/15: Compl:0%->25% 03/07/15: CD:Tue 15/03/16->Tue 15/12/15 03/07/15: Stat Rep: ->RP-150536 29/09/15: Compl:25%->75% 29/09/15: WID: RP-150479->RP-151230 29/09/15: Stat Rep: RP-150536->RP-151131 ...
- 1168: 03/07/15: Compl:0%->25% 03/07/15: Stat Rep: ->RP-150536 29/09/15: Compl:25%->75% 29/09/15: CD:Tue 15/03/16->Tue 15/12/15 29/09/15: WID: RP-150479->RP-151230 29/09/15: Stat Rep: RP-150536->RP-151131 ...
- 1170: 03/07/15: Compl:0%->100% 03/07/15: CD:Tue 15/09/15->Mon 15/06/15 03/07/15: Stat Rep: ->RP-150536
- 1171: 03/07/15: Compl:0%->100% 03/07/15: CD:Tue 15/09/15->Mon 15/06/15 03/07/15: Stat Rep: ->RP-150536
- 1173: 03/07/15: Compl:0%->60% 03/07/15: WID: RP-150437->RP-150809 03/07/15: Stat Rep: ->RP-150536 29/09/15: Compl:60%->90% 29/09/15: CD:Tue 15/09/15->Tue 15/12/15 29/09/15: WID: RP-150809->RP-151177 29/09/15: Stat Rep: RP-150536->RP-151131 ...
- 1174: 03/07/15: WID: RP-150437->RP-150809 03/07/15: Stat Rep: ->RP-150536 29/09/15: Compl:0%->50% 29/09/15: CD:Tue 15/09/15->Tue 15/12/15 29/09/15: WID: RP-150809->RP-151177 29/09/15: Stat Rep: RP-150536->RP-151131;

| ID | WBS | Task | Duration | Start | Finish | Complete | Remaining | Total slack | Constraint | Resources | Work | Actual work | Acronym | PCG approved | WI rapporteur name | Release | TSG approved | Status Report |
| --- | --- | --- | --- | --- | --- | --- | --- | --- | --- | --- | --- | --- | --- | --- | --- | --- | --- | --- |
| 1175 | 297.78 | **LTE Advanced intra-band contiguous Carrier Aggregation in Band 42 for 4DL** | 197d? | 2015-03-16 A | 2015-12-15 A | 100% |  |  |  | R4 | 4728h | 4728h | LTE_CA_C_B42_4DL | PCG-34 | CATT | Rel-13 | RP-67 |  |
| 1176 | 297.78.1 | Core part: LTE Advanced intra-band contiguous Carrier Aggregation in Band 42 for 4DL | 197d? | 2015-03-16 A | 2015-12-15 A | 100% |  |  | finish no earlier than 2015-12-15 | R4 | 1576h | 1576h | LTE_CA_C_B42_4DL-Core | PCG-34 | CATT | Rel-13 | RP-67 | RP-151131 |
| 1177 | 297.78.2 | Perf. part: LTE Advanced intra-band contiguous Carrier Aggregation in Band 42 for 4DL | 197d? | 2015-03-16 A | 2015-12-15 A | 100% |  |  | finish no earlier than 2015-12-15 | R4 | 1576h | 1576h | LTE_CA_C_B42_4DL-Perf | PCG-34 | CATT | Rel-13 | RP-67 | RP-151131 |
| 1178 | 297.79 | **LTE Advanced 3 Band Carrier Aggregation (3DL/1UL) of Band 1, Band 8 and Band 11** | 67d? | 2015-06-15 A | 2015-09-15 A | 100% |  |  |  | R4 | 1608h | 1608h | LTE_CA_B1_B8_B11 | PCG-35 | Softbank Mobile | Rel-13 | TSG-68 |  |
| 1179 | 297.79.1 | Core part: LTE Advanced 3 Band Carrier Aggregation (3DL/1UL) of Band 1, Band 8 and Band 11 | 67d? | 2015-06-15 A | 2015-09-15 A | 100% |  |  | finish no earlier than 2015-09-15 | R4 | 536h | 536h | LTE_CA_B1_B8_B11-Core | PCG-35 | Softbank Mobile | Rel-13 | TSG-68 | RP-151131 |
| 1180 | 297.79.2 | Perf. part: LTE Advanced 3 Band Carrier Aggregation (3DL/1UL) of Band 1, Band 8 and Band 11 | 67d? | 2015-06-15 A | 2015-09-15 A | 100% |  |  | finish no earlier than 2015-09-15 | R4 | 536h | 536h | LTE_CA_B1_B8_B11-Perf | PCG-35 | Softbank Mobile | Rel-13 | TSG-68 | RP-151131 |
| 1181 | 297.80 | **LTE Advanced 3 Band Carrier Aggregation (3DL/1UL) of Band 3, Band 20 and Band 32** | 197d? | 2015-06-15 A | 2016-03-15 | 90% | 19.69d? | 545d |  | R4 | 4728h | 3364.8h | LTE_CA_B3_B20_B32 | PCG-35 | Ericsson | Rel-13 | TSG-68 |  |
| 1182 | 297.80.1 | Core part: LTE Advanced 3 Band Carrier Aggregation (3DL/1UL) of Band 3, Band 20 and Band 32 | 197d? | 2015-06-15 A | 2016-03-15 | 90% | 19.7d? | 545d | finish no earlier than 2016-03-15 | R4 | 1576h | 1418.4h | LTE_CA_B3_B20_B32-Core | PCG-35 | Ericsson | Rel-14 | TSG-68 | RP-151131 |
| 1183 | 297.80.2 | Perf. part: LTE Advanced 3 Band Carrier Aggregation (3DL/1UL) of Band 3, Band 20 and Band 32 | 197d? | 2015-06-15 A | 2016-03-15 | 90% | 19.7d? | 545d | finish no earlier than 2016-03-15 | R4 | 1576h | 1418.4h | LTE_CA_B3_B20_B32-Perf | PCG-35 | Ericsson | Rel-14 | TSG-68 | RP-151131 |
| 1184 | 297.81 | **LTE Advanced 3 Band Carrier Aggregation (3DL/1UL) for Band 7, Band 42 and Band 42** | 132d? | 2015-06-15 A | 2015-12-15 A | 100% |  |  |  | R4 | 3168h | 3168h | LTE_CA_B7_B42_B42 | PCG-35 | Huawei | Rel-13 | TSG-68 |  |
| 1185 | 297.81.1 | Core part: LTE Advanced 3 Band Carrier Aggregation (3DL/1UL) for Band 7, Band 42 and Band 42 | 132d? | 2015-06-15 A | 2015-12-15 A | 100% |  |  | finish no earlier than 2015-12-15 | R4 | 1056h | 1056h | LTE_CA_B7_B42_B42-Core | PCG-35 | Huawei | Rel-13 | TSG-68 | RP-151131 |
| 1186 | 297.81.2 | Perf. part: LTE Advanced 3 Band Carrier Aggregation (3DL/1UL) for Band 7, Band 42 and Band 42 | 132d? | 2015-06-15 A | 2015-12-15 A | 100% |  |  | finish no earlier than 2015-12-15 | R4 | 1056h | 1056h | LTE_CA_B7_B42_B42-Perf | PCG-35 | Huawei | Rel-13 | TSG-68 | RP-151131 |
| 1187 | 297.82 | **LTE Advanced 3 Band Carrier Aggregation (3DL/1UL) for Band 20, Band 42 and Band 42** | 67d? | 2015-06-15 A | 2015-09-15 A | 100% |  |  |  | R4 | 1608h | 1608h | LTE_CA_B20_B42_B42 | PCG-35 | Huawei | Rel-13 | TSG-68 |  |
| 1188 | 297.82.1 | Core part: LTE Advanced 3 Band Carrier Aggregation (3DL/1UL) for Band 20, Band 42 and Band 42 | 67d? | 2015-06-15 A | 2015-09-15 A | 100% |  |  | finish no earlier than 2015-12-15 | R4 | 536h | 536h | LTE_CA_B20_B42_B42-Core | PCG-35 | Huawei | Rel-13 | TSG-68 | RP-151131 |
| 1189 | 297.82.2 | Perf. part: LTE Advanced 3 Band Carrier Aggregation (3DL/1UL) for Band 20, Band 42 and Band 42 | 67d? | 2015-06-15 A | 2015-09-15 A | 100% |  |  | finish no earlier than 2015-12-15 | R4 | 536h | 536h | LTE_CA_B20_B42_B42-Perf | PCG-35 | Huawei | Rel-13 | TSG-68 | RP-151131 |
| 1190 | 297.83 | **LTE Advanced 3 Band Carrier Aggregation (3DL/1UL) for Band 3, Band 7 and Band 38** | 132d? | 2015-06-15 A | 2015-12-15 A | 100% |  |  |  | R4 | 3168h | 3168h | LTE_CA_B3_B7_B38 | PCG-35 | Nokia Networks | Rel-13 | TSG-68 |  |
| 1191 | 297.83.1 | Core part: LTE Advanced 3 Band Carrier Aggregation (3DL/1UL) for Band 3, Band 7 and Band 38 | 132d? | 2015-06-15 A | 2015-12-15 A | 100% |  |  | finish no earlier than 2015-12-15 | R4 | 1056h | 1056h | LTE_CA_B3_B7_B38-Core | PCG-35 | Nokia Networks | Rel-13 | TSG-68 | RP-151131 |
| 1192 | 297.83.2 | Perf. part: LTE Advanced 3 Band Carrier Aggregation (3DL/1UL) for Band 3, Band 7 and Band 38 | 132d? | 2015-06-15 A | 2015-12-15 A | 100% |  |  | finish no earlier than 2015-12-15 | R4 | 1056h | 1056h | LTE_CA_B3_B7_B38-Perf | PCG-35 | Nokia Networks | Rel-13 | TSG-68 | RP-151131 |
| 1193 | 297.84 | **LTE Advanced 3 Band Carrier Aggregation (3DL/1UL) of Band 28, Band 41 and Band 41** | 132d? | 2015-06-15 A | 2015-12-15 A | 100% |  |  |  | R4 | 3168h | 3168h | LTE_CA_B28_B41_B41 | PCG-35 | KDDI | Rel-13 | TSG-68 |  |
| 1194 | 297.84.1 | Core part: LTE Advanced 3 Band Carrier Aggregation (3DL/1UL) of Band 28, Band 41 and Band 41 | 132d? | 2015-06-15 A | 2015-12-15 A | 100% |  |  | finish no earlier than 2015-12-15 | R4 | 1056h | 1056h | LTE_CA_B28_B41_B41-Core | PCG-35 | KDDI | Rel-13 | TSG-68 | RP-151131 |
| 1195 | 297.84.2 | Perf. part: LTE Advanced 3 Band Carrier Aggregation (3DL/1UL) of Band 28, Band 41 and Band 41 | 132d? | 2015-06-15 A | 2015-12-15 A | 100% |  |  | finish no earlier than 2015-12-15 | R4 | 1056h | 1056h | LTE_CA_B28_B41_B41-Perf | PCG-35 | KDDI | Rel-13 | TSG-68 | RP-151131 |
| 1196 | 297.85 | **LTE Advanced 3 Band Carrier Aggregation (3DL/1UL) of Band 28, Band 42 and Band 42** | 132d? | 2015-06-15 A | 2015-12-15 A | 100% |  |  |  | R4 | 3168h | 3168h | LTE_CA_B28_B42_B42 | PCG-35 | KDDI | Rel-13 | TSG-68 |  |
| 1197 | 297.85.1 | Core part: LTE Advanced 3 Band Carrier Aggregation (3DL/1UL) of Band 28, Band 42 and Band 42 | 132d? | 2015-06-15 A | 2015-12-15 A | 100% |  |  | finish no earlier than 2015-12-15 | R4 | 1056h | 1056h | LTE_CA_B28_B42_B42-Core | PCG-35 | KDDI | Rel-13 | TSG-68 | RP-151131 |
| 1198 | 297.85.2 | Perf. part: LTE Advanced 3 Band Carrier Aggregation (3DL/1UL) of Band 28, Band 42 and Band 42 | 132d? | 2015-06-15 A | 2015-12-15 A | 100% |  |  | finish no earlier than 2015-12-15 | R4 | 1056h | 1056h | LTE_CA_B28_B42_B42-Perf | PCG-35 | KDDI | Rel-13 | TSG-68 | RP-151131 |

Notes:
- 1176: 03/07/15: Compl:0%->50% 03/07/15: Stat Rep: ->RP-150536 29/09/15: Compl:50%->80% 29/09/15: Stat Rep: RP-150536->RP-151131...
- 1177: 03/07/15: Compl:0%->50% 03/07/15: Stat Rep: ->RP-150536 29/09/15: Compl:50%->80% 29/09/15: Stat Rep: RP-150536->RP-151131...
- 1179: 29/09/15: Compl:0%->100% 29/09/15: Stat Rep: -->RP-151131
- 1180: 29/09/15: Compl:0%->100% 29/09/15: Stat Rep: -->RP-151131
- 1182: 29/09/15: Compl:0%->50% 29/09/15: Stat Rep: -->RP-1511311/...22/3/16: Compl:50%->90%
- 1183: 29/09/15: Compl:0%->50% 29/09/15: Stat Rep: -->RP-151131 ...; 22/3/16: Compl:50%->90%
- 1185: 29/09/15: Compl:0%->70% 29/09/15: Stat Rep: -->RP-151131 ...
- 1186: 29/09/15: Compl:0%->70% 29/09/15: Stat Rep: -->RP-151131 ...
- 1188: 29/09/15: Compl:0%->100% 29/09/15: CD:Tue 15/12/15->Tue 15/09/15 29/09/15: Stat Rep: -->RP-151131
- 1189: 29/09/15: Compl:0%->100% 29/09/15: CD:Tue 15/12/15->Tue 15/09/15 29/09/15: Stat Rep: -->RP-151131
- 1191: 29/09/15: Compl:0%->60% 29/09/15: Stat Rep: -->RP-1511311/1/16: Compl:...
- 1192: 29/09/15: Compl:0%->60% 29/09/15: Stat Rep: -->RP-151131; 1/1/16: Comp...
- 1194: 29/09/15: Compl:0%->50% 29/09/15: Stat Rep: -->RP-151131 ...
- 1195: 29/09/15: Stat Rep: -->RP-151131 ...
- 1197: 29/09/15: Compl:0%->40% 29/09/15: WID: RP-151112->RP-151158 29/09/15: Stat Rep: -->RP-151131 ...
- 1198: 29/09/15: WID: RP-151112->RP-151158 29/09/15: Stat Rep: -->RP-151131; ...

| ID | WBS | Task | Duration | Start | Finish | Complete | Constraint | Resources | Work | Actual work | Acronym | PCG approved | WI rapporteur name | Release | TSG approved | Status Report |
| --- | --- | --- | --- | --- | --- | --- | --- | --- | --- | --- | --- | --- | --- | --- | --- | --- |
| 1199 | 297.86 | **LTE Advanced 4 Band Carrier Aggregation (4DL/1UL) of Band 2, Band 4, Band 7 and Band 12** | 197d? | 2015-06-15 A | 2016-03-15 A | 100% |  | R4 | 4728h | 4728h | LTE_CA_B2_B4_B7_B12 | PCG-35 | Rogers Communications | Rel-13 | TSG-68 |  |
| 1200 | 297.86.1 | Core part: LTE Advanced 4 Band Carrier Aggregation (4DL/1UL) of Band 2, Band 4, Band 7 and Band 12 | 197d? | 2015-06-15 A | 2016-03-15 A | 100% | finish no earlier than 2016-03-15 | R4 | 1576h | 1576h | LTE_CA_B2_B4_B7_B12-Core | PCG-35 | Rogers Communications | Rel-13 | TSG-68 | RP-151131 |
| 1201 | 297.86.2 | Perf. part: LTE Advanced 4 Band Carrier Aggregation (4DL/1UL) of Band 2, Band 4, Band 7 and Band 12 | 197d? | 2015-06-15 A | 2016-03-15 A | 100% | finish no earlier than 2016-03-15 | R4 | 1576h | 1576h | LTE_CA_B2_B4_B7_B12-Perf | PCG-35 | Rogers Communications | Rel-13 | TSG-68 | RP-151131 |
| 1202 | 297.87 | **LTE Advanced 4 Band Carrier Aggregation (4DL/1UL) of Band 1, Band 3, Band 19 and Band 42** | 132d? | 2015-06-15 A | 2015-12-15 A | 100% |  | R4 | 3168h | 3168h | LTE_CA_B1_B3_B19_B42 | PCG-35 | NTT DOCOMO, INC. | Rel-13 | TSG-68 |  |
| 1203 | 297.87.1 | Core part: LTE Advanced 4 Band Carrier Aggregation (4DL/1UL) of Band 1, Band 3, Band 19 and Band 42 | 132d? | 2015-06-15 A | 2015-12-15 A | 100% | finish no earlier than 2015-12-15 | R4 | 1056h | 1056h | LTE_CA_B1_B3_B19_B42-Core | PCG-35 | NTT DOCOMO, INC. | Rel-13 | TSG-68 | RP-151131 |
| 1204 | 297.87.2 | Perf. part: LTE Advanced 4 Band Carrier Aggregation (4DL/1UL) of Band 1, Band 3, Band 19 and Band 42 | 132d? | 2015-06-15 A | 2015-12-15 A | 100% | finish no earlier than 2015-12-15 | R4 | 1056h | 1056h | LTE_CA_B1_B3_B19_B42-Perf | PCG-35 | NTT DOCOMO, INC. | Rel-13 | TSG-68 | RP-151131 |
| 1205 | 297.88 | **LTE Advanced 4 Band Carrier Aggregation (4DL/1UL) of Band 1, Band 3, Band 42 and Band 42** | 132d? | 2015-06-15 A | 2015-12-15 A | 100% |  | R4 | 3168h | 3168h | LTE_CA_B1_B3_B42_B42 | PCG-35 | NTT DOCOMO, INC. | Rel-13 | TSG-68 |  |
| 1206 | 297.88.1 | Core part: LTE Advanced 4 Band Carrier Aggregation (4DL/1UL) of Band 1, Band 3, Band 42 and Band 42 | 132d? | 2015-06-15 A | 2015-12-15 A | 100% | finish no earlier than 2015-12-15 | R4 | 1056h | 1056h | LTE_CA_B1_B3_B42_B42-Core | PCG-35 | NTT DOCOMO, INC. | Rel-13 | TSG-68 | RP-151131 |
| 1207 | 297.88.2 | Perf. part: LTE Advanced 4 Band Carrier Aggregation (4DL/1UL) of Band 1, Band 3, Band 42 and Band 42 | 132d? | 2015-06-15 A | 2015-12-15 A | 100% | finish no earlier than 2015-12-15 | R4 | 1056h | 1056h | LTE_CA_B1_B3_B42_B42-Perf | PCG-35 | NTT DOCOMO, INC. | Rel-13 | TSG-68 | RP-151131 |
| 1208 | 297.89 | **LTE Advanced 4 Band Carrier Aggregation (4DL/1UL) of Band 1, Band 19, Band 42 and Band 42** | 132d? | 2015-06-15 A | 2015-12-15 A | 100% |  | R4 | 3168h | 3168h | LTE_CA_B1_B19_B42_B42 | PCG-35 | NTT DOCOMO, INC. | Rel-13 | TSG-68 |  |
| 1209 | 297.89.1 | Core part: LTE Advanced 4 Band Carrier Aggregation (4DL/1UL) of Band 1, Band 19, Band 42 and Band 42 | 132d? | 2015-06-15 A | 2015-12-15 A | 100% | finish no earlier than 2015-12-15 | R4 | 1056h | 1056h | LTE_CA_B1_B19_B42_B42-Core | PCG-35 | NTT DOCOMO, INC. | Rel-13 | TSG-68 | RP-151131 |
| 1210 | 297.89.2 | Perf. part: LTE Advanced 4 Band Carrier Aggregation (4DL/1UL) of Band 1, Band 19, Band 42 and Band 42 | 132d? | 2015-06-15 A | 2015-12-15 A | 100% | finish no earlier than 2015-12-15 | R4 | 1056h | 1056h | LTE_CA_B1_B19_B42_B42-Perf | PCG-35 | NTT DOCOMO, INC. | Rel-13 | TSG-68 | RP-151131 |
| 1211 | 297.90 | **LTE Advanced 4 Band Carrier Aggregation (4DL/1UL) of Band 3, Band 19, Band 42 and Band 42** | 132d? | 2015-06-15 A | 2015-12-15 A | 100% |  | R4 | 3168h | 3168h | LTE_CA_B3_B19_B42_B42 | PCG-35 | NTT DOCOMO, INC. | Rel-13 | TSG-68 |  |
| 1212 | 297.90.1 | Core part: LTE Advanced 4 Band Carrier Aggregation (4DL/1UL) of Band 3, Band 19, Band 42 and Band 42 | 132d? | 2015-06-15 A | 2015-12-15 A | 100% | finish no earlier than 2015-12-15 | R4 | 1056h | 1056h | LTE_CA_B3_B19_B42_B42-Core | PCG-35 | NTT DOCOMO, INC. | Rel-13 | TSG-68 | RP-151131 |
| 1213 | 297.90.2 | Perf. part: LTE Advanced 4 Band Carrier Aggregation (4DL/1UL) of Band 3, Band 19, Band 42 and Band 42 | 132d? | 2015-06-15 A | 2015-12-15 A | 100% | finish no earlier than 2015-12-15 | R4 | 1056h | 1056h | LTE_CA_B3_B19_B42_B42-Perf | PCG-35 | NTT DOCOMO, INC. | Rel-13 | TSG-68 | RP-151131 |
| 1214 | 297.91 | **LTE Advanced 4 Band Carrier Aggregation (4DL/1UL) of Band 1, Band 19, Band 21 and Band 42** | 132d? | 2015-06-15 A | 2015-12-15 A | 100% |  | R4 | 3168h | 3168h | LTE_CA_B1_B19_B21_B42 | PCG-35 | NTT DOCOMO, INC. | Rel-13 | TSG-68 |  |
| 1215 | 297.91.1 | Core part: LTE Advanced 4 Band Carrier Aggregation (4DL/1UL) of Band 1, Band 19, Band 21 and Band 42 | 132d? | 2015-06-15 A | 2015-12-15 A | 100% | finish no earlier than 2015-12-15 | R4 | 1056h | 1056h | LTE_CA_B1_B19_B21_B42-Core | PCG-35 | NTT DOCOMO, INC. | Rel-13 | TSG-68 | RP-151131 |
| 1216 | 297.91.2 | Perf. part: LTE Advanced 4 Band Carrier Aggregation (4DL/1UL) of Band 1, Band 19, Band 21 and Band 42 | 132d? | 2015-06-15 A | 2015-12-15 A | 100% | finish no earlier than 2015-12-15 | R4 | 1056h | 1056h | LTE_CA_B1_B19_B21_B42-Perf | PCG-35 | NTT DOCOMO, INC. | Rel-13 | TSG-68 | RP-151131 |
| 1217 | 297.92 | **LTE Advanced 4 Band Carrier Aggregation (4DL/1UL) of Band 1, Band 21, Band 42 and Band 42** | 132d? | 2015-06-15 A | 2015-12-15 A | 100% |  | R4 | 3168h | 3168h | LTE_CA_B1_B21_B42_B42 | PCG-35 | NTT DOCOMO, INC. | Rel-13 | TSG-68 |  |
| 1218 | 297.92.1 | Core part: LTE Advanced 4 Band Carrier Aggregation (4DL/1UL) of Band 1, Band 21, Band 42 and Band 42 | 132d? | 2015-06-15 A | 2015-12-15 A | 100% | finish no earlier than 2015-12-15 | R4 | 1056h | 1056h | LTE_CA_B1_B21_B42_B42-Core | PCG-35 | NTT DOCOMO, INC. | Rel-13 | TSG-68 | RP-151131 |
| 1219 | 297.92.2 | Perf. part: LTE Advanced 4 Band Carrier Aggregation (4DL/1UL) of Band 1, Band 21, Band 42 and Band 42 | 132d? | 2015-06-15 A | 2015-12-15 A | 100% | finish no earlier than 2015-12-15 | R4 | 1056h | 1056h | LTE_CA_B1_B21_B42_B42-Perf | PCG-35 | NTT DOCOMO, INC. | Rel-13 | TSG-68 | RP-151131 |
| 1220 | 297.93 | **LTE Advanced 4 Band Carrier Aggregation (4DL/1UL) of Band 19, Band 21, Band 42 and Band 42** | 132d? | 2015-06-15 A | 2015-12-15 A | 100% |  | R4 | 3168h | 3168h | LTE_CA_B19_B21_B42_B42 | PCG-35 | NTT DOCOMO, INC. | Rel-13 | TSG-68 |  |
| 1221 | 297.93.1 | Core part: LTE Advanced 4 Band Carrier Aggregation (4DL/1UL) of Band 19, Band 21, Band 42 and Band 42 | 132d? | 2015-06-15 A | 2015-12-15 A | 100% | finish no earlier than 2015-12-15 | R4 | 1056h | 1056h | LTE_CA_B19_B21_B42_B42-Core | PCG-35 | NTT DOCOMO, INC. | Rel-13 | TSG-68 | RP-151131 |
| 1222 | 297.93.2 | Perf. part: LTE Advanced 4 Band Carrier Aggregation (4DL/1UL) of Band 19, Band 21, Band 42 and Band 42 | 132d? | 2015-06-15 A | 2015-12-15 A | 100% | finish no earlier than 2015-12-15 | R4 | 1056h | 1056h | LTE_CA_B19_B21_B42_B42-Perf | PCG-35 | NTT DOCOMO, INC. | Rel-13 | TSG-68 | RP-151131 |

Notes:
- 1200: 29/09/15: Stat Rep: -->RP-151131 ...22/3/16: Compl:0%->100%
- 1201: 29/09/15: Stat Rep: -->RP-151131 ...; 22/3/16: Compl:0%->100%
- 1203: 29/09/15: Compl:0%->95% 29/09/15: CD:Tue 15/09/15->Tue 15/12/15 29/09/15: Stat Rep: -->RP-151131 ...
- 1204: 29/09/15: Compl:0%->95% 29/09/15: CD:Tue 15/09/15->Tue 15/12/15 29/09/15: Stat Rep: -->RP-151131 ...
- 1206: 29/09/15: Compl:0%->95% 29/09/15: CD:Tue 15/09/15->Tue 15/12/15 29/09/15: Stat Rep: -->RP-151131 ...
- 1207: 29/09/15: Compl:0%->95% 29/09/15: CD:Tue 15/09/15->Tue 15/12/15 29/09/15: Stat Rep: -->RP-151131 ...
- 1209: 29/09/15: Compl:0%->95% 29/09/15: CD:Tue 15/09/15->Tue 15/12/15 29/09/15: Stat Rep: -->RP-151131 ...
- 1210: 29/09/15: Compl:0%->95% 29/09/15: CD:Tue 15/09/15->Tue 15/12/15 29/09/15: Stat Rep: -->RP-151131 ...
- 1212: 29/09/15: Compl:0%->95% 29/09/15: CD:Tue 15/09/15->Tue 15/12/15 29/09/15: Stat Rep: -->RP-151131 ...
- 1213: 29/09/15: Compl:0%->95% 29/09/15: CD:Tue 15/09/15->Tue 15/12/15 29/09/15: Stat Rep: -->RP-151131 ...
- 1215: 29/09/15: Compl:0%->95% 29/09/15: CD:Tue 15/09/15->Tue 15/12/15 29/09/15: Stat Rep: -->RP-151131 ...
- 1216: 29/09/15: Compl:0%->95% 29/09/15: CD:Tue 15/09/15->Tue 15/12/15 29/09/15: Stat Rep: -->RP-151131 ...
- 1218: 29/09/15: Compl:0%->95% 29/09/15: CD:Tue 15/09/15->Tue 15/12/15 29/09/15: Stat Rep: -->RP-151131 ...
- 1219: 29/09/15: Compl:0%->95% 29/09/15: CD:Tue 15/09/15->Tue 15/12/15 29/09/15: Stat Rep: -->RP-151131 ...
- 1221: 29/09/15: Compl:0%->95% 29/09/15: CD:Tue 15/09/15->Tue 15/12/15 29/09/15: Stat Rep: -->RP-151131 ...
- 1222: 29/09/15: Compl:0%->95% 29/09/15: CD:Tue 15/09/15->Tue 15/12/15 29/09/15: Stat Rep: -->RP-151131 ...

| ID | WBS | Task | Duration | Start | Finish | Complete | Remaining | Total slack | Constraint | Resources | Work | Actual work | Acronym | PCG approved | WI rapporteur name | Release | TSG approved | Status Report |
| --- | --- | --- | --- | --- | --- | --- | --- | --- | --- | --- | --- | --- | --- | --- | --- | --- | --- | --- |
| 1223 | 297.94 | **LTE Advanced 4 Band Carrier Aggregation (4DL/1UL) of Band 2, Band 4, Band 5 and Band 12** | 132d? | 2015-06-15 A | 2015-12-15 A | 100% |  |  |  | R4 | 3168h | 3168h | LTE_CA_B2_B4_B5_B12 | PCG-35 | U.S. Cellular | Rel-13 | TSG-68 |  |
| 1224 | 297.94.1 | Core part: LTE Advanced 4 Band Carrier Aggregation (4DL/1UL) of Band 2, Band 4, Band 5 and Band 12 | 132d? | 2015-06-15 A | 2015-12-15 A | 100% |  |  | finish no earlier than 2015-12-15 | R4 | 1056h | 1056h | LTE_CA_B2_B4_B5_B12-Core | PCG-35 | U.S. Cellular | Rel-13 | TSG-68 | RP-151131 |
| 1225 | 297.94.2 | Perf. part: LTE Advanced 4 Band Carrier Aggregation (4DL/1UL) of Band 2, Band 4, Band 5 and Band 12 | 132d? | 2015-06-15 A | 2015-12-15 A | 100% |  |  | finish no earlier than 2015-12-15 | R4 | 1056h | 1056h | LTE_CA_B2_B4_B5_B12-Perf | PCG-35 | U.S. Cellular | Rel-13 | TSG-68 | RP-151131 |
| 1226 | 297.95 | **LTE Advanced 4 Band Carrier Aggregation (4DL/1UL) of Band 2, Band 2, Band 4 and Band 5** | 132d? | 2015-06-15 A | 2015-12-15 A | 100% |  |  |  | R4 | 3168h | 3168h | LTE_CA_B2_B2_B4_B5 | PCG-35 | U.S. Cellular | Rel-13 | TSG-68 |  |
| 1227 | 297.95.1 | Core part: LTE Advanced 4 Band Carrier Aggregation (4DL/1UL) of Band 2, Band 2, Band 4 and Band 5 | 132d? | 2015-06-15 A | 2015-12-15 A | 100% |  |  | finish no earlier than 2015-12-15 | R4 | 1056h | 1056h | LTE_CA_B2_B2_B4_B5-Core | PCG-35 | U.S. Cellular | Rel-13 | TSG-68 | RP-151131 |
| 1228 | 297.95.2 | Perf. part: LTE Advanced 4 Band Carrier Aggregation (4DL/1UL) of Band 2, Band 2, Band 4 and Band 5 | 132d? | 2015-06-15 A | 2015-12-15 A | 100% |  |  | finish no earlier than 2015-12-15 | R4 | 1056h | 1056h | LTE_CA_B2_B2_B4_B5-Perf | PCG-35 | U.S. Cellular | Rel-13 | TSG-68 | RP-151131 |
| 1229 | 297.96 | **LTE Advanced 4-Band Carrier Aggregation (4DL/1UL) of Band 2, Band 2, Band 12 and Band 12** | 132d? | 2015-06-15 A | 2015-12-15 A | 100% |  |  |  | R4 | 3168h | 3168h | LTE_CA_B2_B2_B12_B12 | PCG-35 | U.S. Cellular | Rel-13 | TSG-68 |  |
| 1230 | 297.96.1 | Core part: LTE Advanced 4-Band Carrier Aggregation (4DL/1UL) of Band 2, Band 2, Band 12 and Band 12 | 132d? | 2015-06-15 A | 2015-12-15 A | 100% |  |  | finish no earlier than 2015-12-15 | R4 | 1056h | 1056h | LTE_CA_B2_B2_B12_B12-Core | PCG-35 | U.S. Cellular | Rel-13 | TSG-68 | RP-151131 |
| 1231 | 297.96.2 | Perf. part: LTE Advanced 4-Band Carrier Aggregation (4DL/1UL) of Band 2, Band 2, Band 12 and Band 12 | 132d? | 2015-06-15 A | 2015-12-15 A | 100% |  |  | finish no earlier than 2015-12-15 | R4 | 1056h | 1056h | LTE_CA_B2_B2_B12_B12-Perf | PCG-35 | U.S. Cellular | Rel-13 | TSG-68 | RP-151131 |
| 1232 | 297.97 | **LTE Advanced 4 Band Carrier Aggregation (4DL/1UL) of Band 4, Band 4, Band 5 and Band 30** | 197d? | 2015-06-15 A | 2016-03-15 | 99% | 0d? | 0d |  | R4 | 4728h | 3416h | LTE_CA_B4_B4_B5_B30 | PCG-35 | AT&T | Rel-13 | TSG-68 |  |
| 1233 | 297.97.1 | Core part: LTE Advanced 4 Band Carrier Aggregation (4DL/1UL) of Band 4, Band 4, Band 5 and Band 30 | 197d? | 2015-06-15 A | 2016-03-15 A | 100% |  |  | finish no earlier than 2016-03-15 | R4 | 1576h | 1576h | LTE_CA_B4_B4_B5_B30-Core | PCG-35 | AT&T | Rel-13 | TSG-68 | RP-151131 |
| 1234 | 297.97.2 | Perf. part: LTE Advanced 4 Band Carrier Aggregation (4DL/1UL) of Band 4, Band 4, Band 5 and Band 30 | 197d? | 2015-06-15 A | 2016-03-15 A | 100% |  |  | finish no earlier than 2016-03-15 | R4 | 1576h | 1576h | LTE_CA_B4_B4_B5_B30-Perf | PCG-35 | AT&T | Rel-13 | TSG-68 | RP-151131 |
| 1235 | 297.98 | **LTE Advanced 4 Band Carrier Aggregation (4DL/1UL) of Band 4, Band 4, Band 12 and Band 30** | 197d? | 2015-06-15 A | 2016-03-15 | 99% | 0d? | 0d |  | R4 | 4728h | 3416h | LTE_CA_B4_B4_B12_B30 | PCG-35 | AT&T | Rel-13 | TSG-68 |  |
| 1236 | 297.98.1 | Core part: LTE Advanced 4 Band Carrier Aggregation (4DL/1UL) of Band 4, Band 4, Band 12 and Band 30 | 197d? | 2015-06-15 A | 2016-03-15 A | 100% |  |  | finish no earlier than 2016-03-15 | R4 | 1576h | 1576h | LTE_CA_B4_B4_B12_B30-Core | PCG-35 | AT&T | Rel-13 | TSG-68 | RP-151131 |
| 1237 | 297.98.2 | Perf. part: LTE Advanced 4 Band Carrier Aggregation (4DL/1UL) of Band 4, Band 4, Band 12 and Band 30 | 197d? | 2015-06-15 A | 2016-03-15 A | 100% |  |  | finish no earlier than 2016-03-15 | R4 | 1576h | 1576h | LTE_CA_B4_B4_B12_B30-Perf | PCG-35 | AT&T | Rel-13 | TSG-68 | RP-151131 |
| 1238 | 297.99 | **LTE Advanced 4 Band Carrier Aggregation (4DL/1UL) of Band 4, Band 4, Band 29 and Band 30** | 197d? | 2015-06-15 A | 2016-03-15 | 99% | 0d? | 0d |  | R4 | 4728h | 3416h | LTE_CA_B4_B4_B29_B30 | PCG-35 | AT&T | Rel-13 | TSG-68 |  |
| 1239 | 297.99.1 | Core part: LTE Advanced 4 Band Carrier Aggregation (4DL/1UL) of Band 4, Band 4, Band 29 and Band 30 | 197d? | 2015-06-15 A | 2016-03-15 A | 100% |  |  | finish no earlier than 2016-03-15 | R4 | 1576h | 1576h | LTE_CA_B4_B4_B29_B30-Core | PCG-35 | AT&T | Rel-13 | TSG-68 | RP-151131 |
| 1240 | 297.99.2 | Perf. part: LTE Advanced 4 Band Carrier Aggregation (4DL/1UL) of Band 4, Band 4, Band 29 and Band 30 | 197d? | 2015-06-15 A | 2016-03-15 A | 100% |  |  | finish no earlier than 2016-03-15 | R4 | 1576h | 1576h | LTE_CA_B4_B4_B29_B30-Perf | PCG-35 | AT&T | Rel-13 | TSG-68 | RP-151131 |
| 1241 | 297.100 | **LTE Advanced 4 Band Carrier Aggregation (4DL/1UL) of Band 2, Band 2, Band 5 and Band 12** | 132d? | 2015-06-15 A | 2015-12-15 A | 100% |  |  |  | R4 | 3168h | 3168h | LTE_CA_B2_B2_B5_B12 | PCG-35 | U.S. Cellular | Rel-13 | TSG-68 |  |
| 1242 | 297.100.1 | Core part: LTE Advanced 4 Band Carrier Aggregation (4DL/1UL) of Band 2, Band 2, Band 5 and Band 12 | 132d? | 2015-06-15 A | 2015-12-15 A | 100% |  |  | finish no earlier than 2015-12-15 | R4 | 1056h | 1056h | LTE_CA_B2_B2_B5_B12-Core | PCG-35 | U.S. Cellular | Rel-13 | TSG-68 | RP-151131 |
| 1243 | 297.100.2 | Perf. part: LTE Advanced 4 Band Carrier Aggregation (4DL/1UL) of Band 2, Band 2, Band 5 and Band 12 | 132d? | 2015-06-15 A | 2015-12-15 A | 100% |  |  | finish no earlier than 2015-12-15 | R4 | 1056h | 1056h | LTE_CA_B2_B2_B5_B12-Perf | PCG-35 | U.S. Cellular | Rel-13 | TSG-68 | RP-151131 |
| 1244 | 297.101 | **LTE Advanced 4 Band Carrier Aggregation (4DL/1UL) of Band 2, Band 5, Band 12 and Band 12** | 132d? | 2015-06-15 A | 2015-12-15 A | 100% |  |  |  | R4 | 3168h | 3168h | LTE_CA_B2_B5_B12_B12 | PCG-35 | U.S. Cellular | Rel-13 | TSG-68 |  |
| 1245 | 297.101.1 | Core part: LTE Advanced 4 Band Carrier Aggregation (4DL/1UL) of Band 2, Band 5, Band 12 and Band 12 | 132d? | 2015-06-15 A | 2015-12-15 A | 100% |  |  | finish no earlier than 2015-12-15 | R4 | 1056h | 1056h | LTE_CA_B2_B5_B12_B12-Core | PCG-35 | U.S. Cellular | Rel-13 | TSG-68 | RP-151131 |
| 1246 | 297.101.2 | Perf. part: LTE Advanced 4 Band Carrier Aggregation (4DL/1UL) of Band 2, Band 5, Band 12 and Band 12 | 132d? | 2015-06-15 A | 2015-12-15 A | 100% |  |  | finish no earlier than 2015-12-15 | R4 | 1056h | 1056h | LTE_CA_B2_B5_B12_B12-Perf | PCG-35 | U.S. Cellular | Rel-13 | TSG-68 | RP-151131 |

Notes:
- 1224: 29/09/15: Compl:0%->40% 29/09/15: Stat Rep: -->RP-151131 ...
- 1225: 29/09/15: Compl:0%->40% 29/09/15: Stat Rep: -->RP-151131 ...
- 1227: 29/09/15: Compl:0%->40% 29/09/15: Stat Rep: -->RP-151131 ...
- 1228: 29/09/15: Compl:0%->40% 29/09/15: Stat Rep: -->RP-151131 ...
- 1230: 29/09/15: Compl:0%->40% 29/09/15: Stat Rep: -->RP-151131 ...
- 1231: 29/09/15: Compl:0%->40% 29/09/15: Stat Rep: -->RP-151131 ...
- 1233: 29/09/15: Stat Rep: -->RP-151131 ...22/3/16: Compl:50%->100%
- 1234: 29/09/15: Stat Rep: -->RP-151131 ...; 22/3/16: Compl:50%->100%
- 1236: 29/09/15: Stat Rep: -->RP-151131 ...22/3/16: Compl:50%->100%
- 1237: 29/09/15: Stat Rep: -->RP-151131 ...22/3/16: Compl:50%->100%
- 1239: 29/09/15: Stat Rep: -->RP-151131 ...; 22/3/16: Compl:50%->100%
- 1240: 29/09/15: Stat Rep: -->RP-151131 ...22/3/16: Compl:50%->100%
- 1242: 29/09/15: Compl:0%->40% 29/09/15: Stat Rep: -->RP-151131 ...
- 1243: 29/09/15: Compl:0%->40% 29/09/15: Stat Rep: -->RP-151131 ...
- 1245: 29/09/15: Compl:0%->40% 29/09/15: Stat Rep: -->RP-151131 ...
- 1246: 29/09/15: Compl:0%->40% 29/09/15: Stat Rep: -->RP-151131 ...

| ID | WBS | Task | Duration | Start | Finish | Complete | Remaining | Total slack | Constraint | Resources | Work | Actual work | Acronym | PCG approved | WI rapporteur name | Release | TSG approved | Status Report | Impacted TSs and TRs |
| --- | --- | --- | --- | --- | --- | --- | --- | --- | --- | --- | --- | --- | --- | --- | --- | --- | --- | --- | --- |
| 1247 | 297.102 | **LTE Advanced 3DL/2UL mixed intra- and inter-band Carrier Aggregation** | 132d? | 2015-06-15 A | 2015-12-15 A | 100% |  |  |  | R4 | 3168h | 3168h | LTE_CA_3DL_2UL_inter_intra | PCG-35 | Nokia Networks | Rel-14 | TSG-68 |  |  |
| 1248 | 297.102.1 | Core part: LTE Advanced 3DL/2UL mixed intra- and inter-band Carrier Aggregation | 132d? | 2015-06-15 A | 2015-12-15 A | 100% |  |  | finish no earlier than 2015-12-15 | R4 | 1056h | 1056h | LTE_CA_3DL_2UL_inter_intra-Core | PCG-35 | Nokia Networks | Rel-13 | TSG-68 | RP-151131 |  |
| 1249 | 297.102.2 | Perf. part: LTE Advanced 3DL/2UL mixed intra- and inter-band Carrier Aggregation | 132d? | 2015-06-15 A | 2015-12-15 A | 100% |  |  | finish no earlier than 2015-12-15 | R4 | 1056h | 1056h | LTE_CA_3DL_2UL_inter_intra-Perf | PCG-35 | Nokia Networks | Rel-13 | TSG-68 | RP-151131 |  |
| 1250 | 297.103 | **LTE Advanced intra-band contiguous Carrier Aggregation in Band 5** | 132d? | 2015-06-15 A | 2015-12-15 A | 100% |  |  |  | R4 | 3168h | 3168h | LTE_CA_C_B5 | PCG-35 | Intel | Rel-13 | TSG-68 |  |  |
| 1251 | 297.103.1 | Core part: LTE Advanced intra-band contiguous Carrier Aggregation in Band 5 | 132d? | 2015-06-15 A | 2015-12-15 A | 100% |  |  | finish no earlier than 2015-12-15 | R4 | 1056h | 1056h | LTE_CA_C_B5-Core | PCG-35 | Intel | Rel-13 | TSG-68 | RP-151131 |  |
| 1252 | 297.103.2 | Perf. part: LTE Advanced intra-band contiguous Carrier Aggregation in Band 5 | 132d? | 2015-06-15 A | 2015-12-15 A | 100% |  |  | finish no earlier than 2015-12-15 | R4 | 1056h | 1056h | LTE_CA_C_B5-Perf | PCG-35 | Intel | Rel-13 | TSG-68 | RP-151131 |  |
| 1253 | 297.104 | **Additional bandwidth combination set for LTE Advanced intra-band non-contiguous Carrier Aggregation in Band 4** | 67d? | 2015-06-15 A | 2015-09-15 A | 100% |  |  |  | R4 | 1608h | 1608h | LTE_CA_NC_B4_BWset | PCG-35 | Nokia Networks | Rel-13 | TSG-68 |  |  |
| 1254 | 297.104.1 | Core part: Additional bandwidth combination set for LTE Advanced intra-band non-contiguous Carrier Aggregation in Band 4 | 67d? | 2015-06-15 A | 2015-09-15 A | 100% |  |  | finish no earlier than 2015-09-15 | R4 | 536h | 536h | LTE_CA_NC_B4_BWset-Core | PCG-35 | Nokia Networks | Rel-13 | TSG-68 | RP-151131 |  |
| 1255 | 297.104.2 | Perf. part: Additional bandwidth combination set for LTE Advanced intra-band non-contiguous Carrier Aggregation in Band 4 | 67d? | 2015-06-15 A | 2015-09-15 A | 100% |  |  | finish no earlier than 2015-09-15 | R4 | 536h | 536h | LTE_CA_NC_B4_BWset-Perf | PCG-35 | Nokia Networks | Rel-13 | TSG-68 | RP-151131 |  |
| 1256 | 297.105 | **LTE Advanced intra-band non-contiguous Carrier Aggregation in Band 5** | 132d? | 2015-06-15 A | 2015-12-15 A | 100% |  |  |  | R4 | 3168h | 3168h | LTE_CA_NC_B5 | PCG-35 | Intel | Rel-13 | TSG-68 |  |  |
| 1257 | 297.105.1 | Core part: LTE Advanced intra-band non-contiguous Carrier Aggregation in Band 5 | 132d? | 2015-06-15 A | 2015-12-15 A | 100% |  |  | finish no earlier than 2015-12-15 | R4 | 1056h | 1056h | LTE_CA_NC_B5-Core | PCG-35 | Intel | Rel-13 | TSG-68 | RP-151131 |  |
| 1258 | 297.105.2 | Perf. part: LTE Advanced intra-band non-contiguous Carrier Aggregation in Band 5 | 132d? | 2015-06-15 A | 2015-12-15 A | 100% |  |  | finish no earlier than 2015-12-15 | R4 | 1056h | 1056h | LTE_CA_NC_B5-Perf | PCG-35 | Intel | Rel-13 | TSG-68 | RP-151131 |  |
| 1259 | 297.106 | **LTE Advanced intra-band non-contiguous Carrier Aggregation in Band 42 for 4DL** | 132d? | 2015-06-15 A | 2015-12-15 A | 100% |  |  |  | R4 | 3168h | 3168h | LTE_CA_NC_B42_4DL | PCG-35 | Huawei | Rel-13 | TSG-68 |  |  |
| 1260 | 297.106.1 | Core part: LTE Advanced intra-band non-contiguous Carrier Aggregation in Band 42 for 4DL | 132d? | 2015-06-15 A | 2015-12-15 A | 100% |  |  | finish no earlier than 2015-12-15 | R4 | 1056h | 1056h | LTE_CA_NC_B42_4DL-Core | PCG-35 | Huawei | Rel-13 | TSG-68 | RP-151131 |  |
| 1261 | 297.106.2 | Perf. part: LTE Advanced intra-band non-contiguous Carrier Aggregation in Band 42 for 4DL | 132d? | 2015-06-15 A | 2015-12-15 A | 100% |  |  | finish no earlier than 2015-12-15 | R4 | 1056h | 1056h | LTE_CA_NC_B42_4DL-Perf | PCG-35 | Huawei | Rel-13 | TSG-68 | RP-151131 |  |
| 1262 | 297.107 | **Additional bandwidth combination set for LTE Advanced inter-band Carrier Aggregation of Band 2 and Band 12** | 67d? | 2015-06-15 A | 2015-09-15 A | 100% |  |  |  | R4 | 1608h | 1608h | LTE_CA_B2_B12_BWset | PCG-35 | Nokia Networks | Rel-13 | TSG-68 |  |  |
| 1263 | 297.107.1 | Core part: Additional bandwidth combination set for LTE Advanced inter-band Carrier Aggregation of Band 2 and Band 12 | 67d? | 2015-06-15 A | 2015-09-15 A | 100% |  |  | finish no earlier than 2015-09-15 | R4 | 536h | 536h | LTE_CA_B2_B12_BWset-Core | PCG-35 | Nokia Networks | Rel-13 | TSG-68 | RP-151131 |  |
| 1264 | 297.107.2 | Perf. part: Additional bandwidth combination set for LTE Advanced inter-band Carrier Aggregation of Band 2 and Band 12 | 67d? | 2015-06-15 A | 2015-09-15 A | 100% |  |  | finish no earlier than 2015-09-15 | R4 | 536h | 536h | LTE_CA_B2_B12_BWset-Perf | PCG-35 | Nokia Networks | Rel-13 | TSG-68 | RP-151131 |  |
| 1265 | 297.108 | **Additional bandwidth combination set 2 for LTE Advanced inter-band Carrier Aggregation of Band 4 and Band 12** | 67d? | 2015-06-15 A | 2015-09-15 A | 100% |  |  |  | R4 | 1608h | 1608h | LTE_CA_B4_B12_BWset2 | PCG-35 | Nokia Networks | Rel-13 | TSG-68 |  |  |
| 1266 | 297.108.1 | Core part: Additional bandwidth combination set 2 for LTE Advanced inter-band Carrier Aggregation of Band 4 and Band 12 | 67d? | 2015-06-15 A | 2015-09-15 A | 100% |  |  | finish no earlier than 2015-09-15 | R4 | 536h | 536h | LTE_CA_B4_B12_BWset2-Core | PCG-35 | Nokia Networks | Rel-13 | TSG-68 | RP-151131 |  |
| 1267 | 297.108.2 | Perf. part: Additional bandwidth combination set 2 for LTE Advanced inter-band Carrier Aggregation of Band 4 and Band 12 | 67d? | 2015-06-15 A | 2015-09-15 A | 100% |  |  | finish no earlier than 2015-09-15 | R4 | 536h | 536h | LTE_CA_B4_B12_BWset2-Perf | PCG-35 | Nokia Networks | Rel-13 | TSG-68 | RP-151131 |  |
| 1268 | 297.109 | **Introduction of 1447-1467MHz Band for TD-LTE in China** | 330d? | 2015-06-15 A | 2016-09-15 | 99% | 0d? | 0d |  | R4 | 5824h | 4240h | LTE_TDD_1447MHz_China | PCG-35 | Huawei | Rel-13 | TSG-68 |  |  |
| 1269 | 297.109.1 | Core part: Introduction of 1447-1467MHz Band for TD-LTE in China | 132d? | 2015-06-15 A | 2015-12-15 A | 100% |  |  | finish no earlier than 2015-12-15 | R4 | 1056h | 1056h | LTE_TDD_1447MHz_China-Core | PCG-35 | Huawei | Rel-13 | TSG-68 | RP-151242 | 36.892 |
| 1270 | 297.109.2 | Perf. part: Introduction of 1447-1467MHz Band for TD-LTE in China | 132d? | 2015-06-15 A | 2015-12-15 A | 100% |  |  | finish no earlier than 2016-03-15 | R4 | 1056h | 1056h | LTE_TDD_1447MHz_China-Perf | PCG-35 | Huawei | Rel-13 | TSG-68 | RP-151242 |  |
| 1271 | 297.109.3 | UE Conformance Test Aspects - Introduction of 1447-1467MHz Band for TD-LTE in China | 134d? | 2016-03-15 A | 2016-09-15 A | 100% |  |  | finish no earlier than 2016-09-15 | R5 | 1072h | 1072h | LTE_TDD_1447MHz_China-UEConTest | PCG-36 | Huawei | Rel-13 | TSG#71 |  |  |

Notes:
- 1247: covers combinations of contiguous intra-band CA and inter-band CA or combinations of non-contiguous intra-band CA and inter-band CA for LTE; pure intra-band CA combinations are also covered by this WI; note: There is already a REL-13 WI LTE_CA_3DL_2UL whi
- 1248: covers combinations of contiguous intra-band CA and inter-band CA or combinations of non-contiguous intra-band CA and inter-band CA for LTE; pure intra-band CA combinations are also covered by this WI; note: There is already a REL-13 WI LTE_CA_3DL_2UL ...; ; ; ; ; ; ; ; ; ; ; ; ; ; ; ; ; ; ; ; ; ; ; ; ; ; ; ; ; ; ; ; ; ; ; ; ; ; ; ; ; ; ; ; ; ; ; ; ; ; ; ; ; ; ; ; ; ; ; ; ; ; ; ; ; ; ; ; ; ; ; ; ; ; ; ; ; ; ; ; ; ; ; ; ; ; ; ; ; ; ; ; ; ; ; ; ; ; ; ; ; ; ; ; ; ; ; ; ; ; ; ; ; ; ; ; ; ; ; ; ; ; ; ; ; ; ; ; ; ; ; ; ; ; ; ; ; ; ; ; ; ; ; ; ; ; ; ; ; ; ; ; ; ; ; ; ; ; ; ; ; ; ; ; ; ; ; ; ; ; ; ; ; ; ; ; ; ; ; ; ; ; ; ; ; ; ; ; ; ; ; ; ; ; ; ; ; ; ; ; ; ; ; ; ; ; ; ; ; ; ; ; 1/1/16: Compl:25%->100%
- 1249: covers combinations of contiguous intra-band CA and inter-band CA or combinations of non-contiguous intra-band CA and inter-band CA for LTE; pure intra-band CA combinations are also covered by this WI; note: There is already a REL-13 WI LTE_CA_3DL_2UL ...; ; ; ; ; ; ; ; ; ; ; ; ; ; ; ; ; ; ; ; ; ; ; ; ; ; ; ; ; ; ; ; ; ; ; ; ; ; ; ; ; ; ; ; ; ; ; ; ; ; ; ; ; ; ; ; ; ; ; ; ; ; ; ; ; ; ; ; ; ; ; ; ; ; ; ; ; ; ; ; ; ; ; ; ; ; ; ; ; ; ; ; ; ; ; ; ; ; ; ; ; ; ; ; ; ; ; ; ; ; ; ; ; ; ; ; ; ; ; ; ; ; ; ; ; ; ; ; ; ; ; ; ; ; ; ; ; ; ; ; ; ; ; ; ; ; ; ; ; ; ; ; ; ; ; ; ; ; ; ; ; ; ; ; ; ; ; ; ; ; ; ; ; ; ; ; ; ; ; ; ; ; ; ; ; ; ; ; ; ; ; ; ; ; ; ; ; ; ; ; ; ; ; ; ; ; ; ; ; ; ; ; ; 1/1/16: Compl:0%->100%
- 1251: 29/09/15: Compl:0%->20% 29/09/15: Stat Rep: -->RP-151131 ...
- 1252: 29/09/15: Compl:0%->20% 29/09/15: Stat Rep: -->RP-151131 ...
- 1253: LTE_CA_NC_B4 was completed in REL-12
- 1254: LTE_CA_NC_B4 was completed in REL-12 29/09/15: Compl:0%->100% 29/09/15: Stat Rep: -->RP-151131
- 1255: LTE_CA_NC_B4 was completed in REL-12 29/09/15: Compl:0%->100% 29/09/15: Stat Rep: -->RP-151131
- 1257: 29/09/15: Compl:0%->20% 29/09/15: Stat Rep: -->RP-151131 ...
- 1258: 29/09/15: Compl:0%->20% 29/09/15: Stat Rep: -->RP-151131 ...
- 1260: 29/09/15: Compl:0%->50% 29/09/15: Stat Rep: -->RP-151131 ...
- 1261: 29/09/15: Stat Rep: -->RP-151131 ...
- 1262: LTE_CA_B2_B12 was completed as REL-12 WI
- 1263: LTE_CA_B2_B12 was completed as REL-12 WI 29/09/15: Compl:0%->100% 29/09/15: Stat Rep: -->RP-151131
- 1264: LTE_CA_B2_B12 was completed as REL-12 WI 29/09/15: Compl:0%->100% 29/09/15: Stat Rep: -->RP-151131
- 1265: LTE_CA_B4_B12 was completed in REL-11 and LTE_CA_B4_B12_BWset was completed in REL-12
- 1266: LTE_CA_B4_B12 was completed in REL-11 and LTE_CA_B4_B12_BWset was completed in REL-12 29/09/15: Compl:0%->100% 29/09/15: Stat Rep: -->RP-151131
- 1267: LTE_CA_B4_B12 was completed in REL-11 and LTE_CA_B4_B12_BWset was completed in REL-12 29/09/15: Compl:0%->100% 29/09/15: Stat Rep: -->RP-151131
- 1268: Aug 15: TR numb added
- 1269: Aug 15: TR numb added 29/09/15: Compl:0%->20% 29/09/15: Stat Rep: -->RP-151242...
- 1270: 29/09/15: Stat Rep: -->RP-151242 ...
- 1271: testing REL-13 LTE_TDD_1447MHz_China-Core; 1/7/16: C...; ;...

| ID | WBS | Task | Duration | Start | Finish | Complete | Constraint | Resources | Work | Actual work | Acronym | PCG approved | WI rapporteur name | Release | TSG approved | Status Report |
| --- | --- | --- | --- | --- | --- | --- | --- | --- | --- | --- | --- | --- | --- | --- | --- | --- |
| 1272 | 297.110 | **LTE Advanced 4 Band Carrier Aggregation (4DL/1UL) of Band 41, Band 41, Band 42 and Band 42** | 132d? | 2015-06-15 A | 2015-12-15 A | 100% |  | R4 | 3168h | 3168h | LTE_CA_B41_B41_B42_B42 | PCG-35 | ZTE | Rel-13 | TSG-68 |  |
| 1273 | 297.110.1 | Core part: LTE Advanced 4 Band Carrier Aggregation (4DL/1UL) of Band 41, Band 41, Band 42 and Band 42 | 132d? | 2015-06-15 A | 2015-12-15 A | 100% | finish no earlier than 2015-12-15 | R4 | 1056h | 1056h | LTE_CA_B41_B41_B42_B42-Core | PCG-35 | ZTE | Rel-13 | TSG-68 | RP-151131 |
| 1274 | 297.110.2 | Perf. part: LTE Advanced 4 Band Carrier Aggregation (4DL/1UL) of Band 41, Band 41, Band 42 and Band 42 | 132d? | 2015-06-15 A | 2015-12-15 A | 100% | finish no earlier than 2015-12-15 | R4 | 1056h | 1056h | LTE_CA_B41_B41_B42_B42-Perf | PCG-35 | ZTE | Rel-13 | TSG-68 | RP-151131 |
| 1275 | 297.111 | **LTE Advanced inter-band Carrier Aggregation for Band 5 and Band 38** | 66d? | 2015-09-15 A | 2015-12-15 A | 100% |  | R4 | 1584h | 1584h | LTE_CA_B5_B38 | PCG-35 | Huawei | Rel-13 | RP-69 |  |
| 1276 | 297.111.1 | Core part: LTE Advanced inter-band Carrier Aggregation for Band 5 and Band 38 | 66d? | 2015-09-15 A | 2015-12-15 A | 100% | finish no earlier than 2015-12-15 | R4 | 528h | 528h | LTE_CA_B5_B38-Core | PCG-35 | Huawei | Rel-13 | RP-69 |  |
| 1277 | 297.111.2 | Perf. part: LTE Advanced inter-band Carrier Aggregation for Band 5 and Band 38 | 66d? | 2015-09-15 A | 2015-12-15 A | 100% | finish no earlier than 2015-12-15 | R4 | 528h | 528h | LTE_CA_B5_B38-Perf | PCG-35 | Huawei | Rel-13 | RP-69 |  |
| 1278 | 297.112 | **LTE Advanced 3 Band Carrier Aggregation (3DL/1UL) of Band 1, Band 11 and Band 18** | 66d? | 2015-09-15 A | 2015-12-15 A | 100% |  | R4 | 1584h | 1584h | LTE_CA_B1_B11_B18 | PCG-35 | KDDI | Rel-13 | RP-69 |  |
| 1279 | 297.112.1 | Core part: LTE Advanced 3 Band Carrier Aggregation (3DL/1UL) of Band 1, Band 11 and Band 18 | 66d? | 2015-09-15 A | 2015-12-15 A | 100% | finish no earlier than 2015-12-15 | R4 | 528h | 528h | LTE_CA_B1_B11_B18-Core | PCG-35 | KDDI | Rel-13 | RP-69 |  |
| 1280 | 297.112.2 | Perf. part: LTE Advanced 3 Band Carrier Aggregation (3DL/1UL) of Band 1, Band 11 and Band 18 | 66d? | 2015-09-15 A | 2015-12-15 A | 100% | finish no earlier than 2015-12-15 | R4 | 528h | 528h | LTE_CA_B1_B11_B18-Perf | PCG-35 | KDDI | Rel-13 | RP-69 |  |
| 1281 | 297.113 | **LTE Advanced 3 Band Carrier Aggregation (3DL/1UL) of Band 5, Band 40, and Band 40** | 66d? | 2015-09-15 A | 2015-12-15 A | 100% |  | R4 | 1584h | 1584h | LTE_CA_B5_B40_B40 | PCG-35 | ZTE | Rel-13 | RP-69 |  |
| 1282 | 297.113.1 | Core part: LTE Advanced 3 Band Carrier Aggregation (3DL/1UL) of Band 5, Band 40, and Band 40 | 66d? | 2015-09-15 A | 2015-12-15 A | 100% | finish no earlier than 2015-12-15 | R4 | 528h | 528h | LTE_CA_B5_B40_B40-Core | PCG-35 | ZTE | Rel-13 | RP-69 |  |
| 1283 | 297.113.2 | Perf. part: LTE Advanced 3 Band Carrier Aggregation (3DL/1UL) of Band 5, Band 40, and Band 40 | 66d? | 2015-09-15 A | 2015-12-15 A | 100% | finish no earlier than 2015-12-15 | R4 | 528h | 528h | LTE_CA_B5_B40_B40-Perf | PCG-35 | ZTE | Rel-13 | RP-69 |  |
| 1284 | 297.114 | **LTE Advanced 3 Band Carrier Aggregation (3DL/1UL) for Band 3, Band 41 and Band 42** | 66d? | 2015-09-15 A | 2015-12-15 A | 100% |  | R4 | 1584h | 1584h | LTE_CA_B3_B41_B42 | PCG-35 | Huawei | Rel-13 | RP-69 |  |
| 1285 | 297.114.1 | Core part: LTE Advanced 3 Band Carrier Aggregation (3DL/1UL) for Band 3, Band 41 and Band 42 | 66d? | 2015-09-15 A | 2015-12-15 A | 100% | finish no earlier than 2015-12-15 | R4 | 528h | 528h | LTE_CA_B3_B41_B42-Core | PCG-35 | Huawei | Rel-13 | RP-69 |  |
| 1286 | 297.114.2 | Perf. part: LTE Advanced 3 Band Carrier Aggregation (3DL/1UL) for Band 3, Band 41 and Band 42 | 66d? | 2015-09-15 A | 2015-12-15 A | 100% | finish no earlier than 2015-12-15 | R4 | 528h | 528h | LTE_CA_B3_B41_B42-Perf | PCG-35 | Huawei | Rel-13 | RP-69 |  |
| 1287 | 297.115 | **LTE Advanced 3 Band Carrier Aggregation (3DL/1UL) of Band 3, Band 41, and Band 41** | 66d? | 2015-09-15 A | 2015-12-15 A | 100% |  | R4 | 1584h | 1584h | LTE_CA_B3_B41_B41 | PCG-35 | ZTE | Rel-13 | RP-69 |  |
| 1288 | 297.115.1 | Core part: LTE Advanced 3 Band Carrier Aggregation (3DL/1UL) of Band 3, Band 41, and Band 41 | 66d? | 2015-09-15 A | 2015-12-15 A | 100% | finish no earlier than 2015-12-15 | R4 | 528h | 528h | LTE_CA_B3_B41_B41-Core | PCG-35 | ZTE | Rel-13 | RP-69 |  |
| 1289 | 297.115.2 | Perf. part: LTE Advanced 3 Band Carrier Aggregation (3DL/1UL) of Band 3, Band 41, and Band 41 | 66d? | 2015-09-15 A | 2015-12-15 A | 100% | finish no earlier than 2015-12-15 | R4 | 528h | 528h | LTE_CA_B3_B41_B41-Perf | PCG-35 | ZTE | Rel-13 | RP-69 |  |
| 1290 | 297.116 | **LTE Advanced 4 Band Carrier Aggregation (4DL1UL) of Band 39, Band 41, Band 41 and Band 41** | 66d? | 2015-09-15 A | 2015-12-15 A | 100% |  | R4 | 1584h | 1584h | LTE_CA_B39_B41_B41_B41 | PCG-35 | CMCC | Rel-13 | RP-69 |  |
| 1291 | 297.116.1 | Core part: LTE Advanced 4 Band Carrier Aggregation (4DL1UL) of Band 39, Band 41, Band 41 and Band 41 | 66d? | 2015-09-15 A | 2015-12-15 A | 100% | finish no earlier than 2015-12-15 | R4 | 528h | 528h | LTE_CA_B39_B41_B41_B41-Core | PCG-35 | CMCC | Rel-13 | RP-69 |  |
| 1292 | 297.116.2 | Perf. part: LTE Advanced 4 Band Carrier Aggregation (4DL1UL) of Band 39, Band 41, Band 41 and Band 41 | 66d? | 2015-09-15 A | 2015-12-15 A | 100% | finish no earlier than 2015-12-15 | R4 | 528h | 528h | LTE_CA_B39_B41_B41_B41-Perf | PCG-35 | CMCC | Rel-13 | RP-69 |  |
| 1293 | 297.117 | **LTE Advanced 4 Band Carrier Aggregation (4DL1UL) of Band 39, Band 39, Band 41 and Band 41** | 66d? | 2015-09-15 A | 2015-12-15 A | 100% |  | R4 | 1584h | 1584h | LTE_CA_B39_B39_B41_B41 | PCG-35 | CMCC | Rel-13 | RP-69 |  |
| 1294 | 297.117.1 | Core part: LTE Advanced 4 Band Carrier Aggregation (4DL1UL) of Band 39, Band 39, Band 41 and Band 41 | 66d? | 2015-09-15 A | 2015-12-15 A | 100% | finish no earlier than 2015-12-15 | R4 | 528h | 528h | LTE_CA_B39_B39_B41_B41-Core | PCG-35 | CMCC | Rel-13 | RP-69 |  |
| 1295 | 297.117.2 | Perf. part: LTE Advanced 4 Band Carrier Aggregation (4DL1UL) of Band 39, Band 39, Band 41 and Band 41 | 66d? | 2015-09-15 A | 2015-12-15 A | 100% | finish no earlier than 2015-12-15 | R4 | 528h | 528h | LTE_CA_B39_B39_B41_B41-Perf | PCG-35 | CMCC | Rel-13 | RP-69 |  |

Notes:
- 1273: 29/09/15: Compl:0%->40% 29/09/15: WID: RP-150627->RP-151562 29/09/15: Stat Rep: ->RP-151131...
- 1274: 29/09/15: Compl:0%->40% 29/09/15: WID: RP-150627->RP-151562 29/09/15: Stat Rep: ->RP-151131...
- 1276: 1/1/16: Compl:0%->100%
- 1277: ; 1/1/16: Compl:0%->100%
- 1279: ; 1/1/16: Compl:0%->100%
- 1280: 1/1/16: Compl:0%->100%
- 1282: 1/1/16: Compl:0%->100%
- 1283: 1/1/16: Compl:0%->100%
- 1285: 1/1/16: Compl:0%->100%
- 1286: ; 1/1/16: Compl:0%->100%
- 1288: ; 1/1/16: Compl:0%->100%
- 1289: 1/1/16: Compl:0%->100%

| ID | WBS | Task | Duration | Start | Finish | Complete | Remaining | Total slack | Constraint | Resources | Work | Actual work | Acronym | PCG approved | WI rapporteur name | Release | TSG approved | Impacted TSs and TRs |
| --- | --- | --- | --- | --- | --- | --- | --- | --- | --- | --- | --- | --- | --- | --- | --- | --- | --- | --- |
| 1296 | 297.118 | **LTE Advanced 4 Band Carrier Aggregation (4DL/1UL) of Band 1, Band 3, Band 8 and Band 40** | 66d? | 2015-09-15 A | 2015-12-15 A | 100% |  |  |  | R4 | 1584h | 1584h | LTE_CA_B1_B3_B8_B40 | PCG-35 | KT | Rel-13 | RP-69 |  |
| 1297 | 297.118.1 | Core part: LTE Advanced 4 Band Carrier Aggregation (4DL/1UL) of Band 1, Band 3, Band 8 and Band 40 | 66d? | 2015-09-15 A | 2015-12-15 A | 100% |  |  | finish no earlier than 2015-12-15 | R4 | 528h | 528h | LTE_CA_B1_B3_B8_B40-Core | PCG-35 | KT | Rel-13 | RP-69 |  |
| 1298 | 297.118.2 | Perf. part: LTE Advanced 4 Band Carrier Aggregation (4DL/1UL) of Band 1, Band 3, Band 8 and Band 40 | 66d? | 2015-09-15 A | 2015-12-15 A | 100% |  |  | finish no earlier than 2015-12-15 | R4 | 528h | 528h | LTE_CA_B1_B3_B8_B40-Perf | PCG-35 | KT | Rel-13 | RP-69 |  |
| 1299 | 297.119 | **LTE Advanced 4 Band Carrier Aggregation (4DL/1UL) for Band 3, Band 28, Band 40 and Band 40** | 66d? | 2015-09-15 A | 2015-12-15 A | 100% |  |  |  | R4 | 1584h | 1584h | LTE_CA_B3_B28_B40_B40 | PCG-35 | Huawei | Rel-13 | RP-69 |  |
| 1300 | 297.119.1 | Core part: LTE Advanced 4 Band Carrier Aggregation (4DL/1UL) for Band 3, Band 28, Band 40 and Band 40 | 66d? | 2015-09-15 A | 2015-12-15 A | 100% |  |  | finish no earlier than 2015-12-15 | R4 | 528h | 528h | LTE_CA_B3_B28_B40_B40-Core | PCG-35 | Huawei | Rel-13 | RP-69 |  |
| 1301 | 297.119.2 | Perf. part: LTE Advanced 4 Band Carrier Aggregation (4DL/1UL) for Band 3, Band 28, Band 40 and Band 40 | 66d? | 2015-09-15 A | 2015-12-15 A | 100% |  |  | finish no earlier than 2015-12-15 | R4 | 528h | 528h | LTE_CA_B3_B28_B40_B40-Perf | PCG-35 | Huawei | Rel-13 | RP-69 |  |
| 1302 | 297.120 | **LTE Advanced 4 Band Carrier Aggregation (4DL/1UL) for Band 28, Band 40, Band 40 and Band 40** | 66d? | 2015-09-15 A | 2015-12-15 A | 100% |  |  |  | R4 | 1584h | 1584h | LTE_CA_B28_B40_B40_B40 | PCG-35 | Huawei | Rel-13 | RP-69 |  |
| 1303 | 297.120.1 | Core part: LTE Advanced 4 Band Carrier Aggregation (4DL/1UL) for Band 28, Band 40, Band 40 and Band 40 | 66d? | 2015-09-15 A | 2015-12-15 A | 100% |  |  | finish no earlier than 2015-12-15 | R4 | 528h | 528h | LTE_CA_B28_B40_B40_B40-Core | PCG-35 | Huawei | Rel-13 | RP-69 |  |
| 1304 | 297.120.2 | Perf. part: LTE Advanced 4 Band Carrier Aggregation (4DL/1UL) for Band 28, Band 40, Band 40 and Band 40 | 66d? | 2015-09-15 A | 2015-12-15 A | 100% |  |  | finish no earlier than 2015-12-15 | R4 | 528h | 528h | LTE_CA_B28_B40_B40_B40-Perf | PCG-35 | Huawei | Rel-13 | RP-69 |  |
| 1305 | 297.121 | **LTE Advanced 4 Band Carrier Aggregation (4DL/1UL) of Band 3, Band 7, Band 7 and Band 28** | 66d? | 2015-09-15 A | 2015-12-15 A | 100% |  |  |  | R4 | 1584h | 1584h | LTE_CA_B3_B7_B7_B28 | PCG-35 | Telstra | Rel-13 | RP-69 |  |
| 1306 | 297.121.1 | Core part: LTE Advanced 4 Band Carrier Aggregation (4DL/1UL) of Band 3, Band 7, Band 7 and Band 28 | 66d? | 2015-09-15 A | 2015-12-15 A | 100% |  |  | finish no earlier than 2015-12-15 | R4 | 528h | 528h | LTE_CA_B3_B7_B7_B28-Core | PCG-35 | Telstra | Rel-13 | RP-69 |  |
| 1307 | 297.121.2 | Perf. part: LTE Advanced 4 Band Carrier Aggregation (4DL/1UL) of Band 3, Band 7, Band 7 and Band 28 | 66d? | 2015-09-15 A | 2015-12-15 A | 100% |  |  | finish no earlier than 2015-12-15 | R4 | 528h | 528h | LTE_CA_B3_B7_B7_B28-Perf | PCG-35 | Telstra | Rel-13 | RP-69 |  |
| 1308 | 297.122 | **LTE Advanced 5 Band Carrier Aggregation (5DL/1UL) of Band 1, Band 3, Band 19, Band 42 and Band 42** | 66d? | 2015-09-15 A | 2015-12-15 A | 100% |  |  |  | R4 | 1584h | 1584h | LTE_CA_B1_B3_B19_B42_B42 | PCG-35 | NTT DOCOMO | Rel-13 | RP-69 | 36.857-13 |
| 1309 | 297.122.1 | Core part: LTE Advanced 5 Band Carrier Aggregation (5DL/1UL) of Band 1, Band 3, Band 19, Band 42 and Band 42 | 66d? | 2015-09-15 A | 2015-12-15 A | 100% |  |  | finish no earlier than 2015-12-15 | R4 | 528h | 528h | LTE_CA_B1_B3_B19_B42_B42-Core | PCG-35 | NTT DOCOMO | Rel-13 | RP-69 | 36.857-13 |
| 1310 | 297.122.2 | Perf. part: LTE Advanced 5 Band Carrier Aggregation (5DL/1UL) of Band 1, Band 3, Band 19, Band 42 and Band 42 | 66d? | 2015-09-15 A | 2015-12-15 A | 100% |  |  | finish no earlier than 2015-12-15 | R4 | 528h | 528h | LTE_CA_B1_B3_B19_B42_B42-Perf | PCG-35 | NTT DOCOMO | Rel-13 | RP-69 | 36.857-13 |
| 1311 | 297.123 | **LTE Advanced 5 Band Carrier Aggregation (5DL/1UL) of Band 1, Band 19, Band 21, Band 42 and Band 42** | 66d? | 2015-09-15 A | 2015-12-15 A | 100% |  |  |  | R4 | 1584h | 1584h | LTE_CA_B1_B19_B21_B42_B42 | PCG-35 | NTT DOCOMO | Rel-13 | RP-69 |  |
| 1312 | 297.123.1 | Core part: LTE Advanced 5 Band Carrier Aggregation (5DL/1UL) of Band 1, Band 19, Band 21, Band 42 and Band 42 | 66d? | 2015-09-15 A | 2015-12-15 A | 100% |  |  | finish no earlier than 2015-12-15 | R4 | 528h | 528h | LTE_CA_B1_B19_B21_B42_B42-Core | PCG-35 | NTT DOCOMO | Rel-13 | RP-69 |  |
| 1313 | 297.123.2 | Perf. part: LTE Advanced 5 Band Carrier Aggregation (5DL/1UL) of Band 1, Band 19, Band 21, Band 42 and Band 42 | 66d? | 2015-09-15 A | 2015-12-15 A | 100% |  |  | finish no earlier than 2015-12-15 | R4 | 528h | 528h | LTE_CA_B1_B19_B21_B42_B42-Perf | PCG-35 | NTT DOCOMO | Rel-13 | RP-69 |  |
| 1314 | 297.124 | **LTE Advanced 5 Band Carrier Aggregation (5DL/1UL) of Band 1, Band 3, Band 7, Band 7 and Band 28** | 131d? | 2015-09-15 A | 2016-03-15 | 99% | 0d? | 0d |  | R4 | 3144h | 2346.79h | LTE_CA_B1_B3_B7_B7_B28 | PCG-35 | Telstra | Rel-13 | RP-69 |  |
| 1315 | 297.124.1 | Core part: LTE Advanced 5 Band Carrier Aggregation (5DL/1UL) of Band 1, Band 3, Band 7, Band 7 and Band 28 | 131d? | 2015-09-15 A | 2016-03-15 A | 100% |  |  | finish no earlier than 2016-03-15 | R4 | 1048h | 1048h | LTE_CA_B1_B3_B7_B7_B28-Core | PCG-35 | Telstra | Rel-13 | RP-69 |  |
| 1316 | 297.124.2 | Perf. part: LTE Advanced 5 Band Carrier Aggregation (5DL/1UL) of Band 1, Band 3, Band 7, Band 7 and Band 28 | 131d? | 2015-09-15 A | 2016-03-15 A | 100% |  |  | finish no earlier than 2016-03-15 | R4 | 1048h | 1048h | LTE_CA_B1_B3_B7_B7_B28-Perf | PCG-35 | Telstra | Rel-13 | RP-69 |  |
| 1317 | 297.125 | **LTE Advanced 5 Band Carrier Aggregation (5DL/1UL) of Band 3, Band 3, Band 7, Band 7 and Band 28** | 131d? | 2015-09-15 A | 2016-03-15 | 99% | 0d? | 0d |  | R4 | 3144h | 2346.79h | LTE_CA_B3_B3_B7_B7_B28 | PCG-35 | Telstra | Rel-13 | RP-69 |  |
| 1318 | 297.125.1 | Core part: LTE Advanced 5 Band Carrier Aggregation (5DL/1UL) of Band 3, Band 3, Band 7, Band 7 and Band 28 | 131d? | 2015-09-15 A | 2016-03-15 A | 100% |  |  | finish no earlier than 2016-03-15 | R4 | 1048h | 1048h | LTE_CA_B3_B3_B7_B7_B28-Core | PCG-35 | Telstra | Rel-13 | RP-69 |  |
| 1319 | 297.125.2 | Perf. part: LTE Advanced 5 Band Carrier Aggregation (5DL/1UL) of Band 3, Band 3, Band 7, Band 7 and Band 28 | 131d? | 2015-09-15 A | 2016-03-15 A | 100% |  |  | finish no earlier than 2016-03-15 | R4 | 1048h | 1048h | LTE_CA_B3_B3_B7_B7_B28-Perf | PCG-35 | Telstra | Rel-13 | RP-69 |  |

Notes:
- 1297: ; 1/1...
- 1298: 1...
- 1315: ; 22/3/16: Compl:95%->100%;...
- 1316: 22/3/16: Compl:95%->100%;...
- 1318: 22/3/16: Compl:95%->100%
- 1319: ; 22/3/16: Compl:95%->100%

| ID | WBS | Task | Duration | Start | Finish | Complete | Remaining | Baseline start | Baseline finish | Baseline duration | Total slack | Constraint | Resources | Work | Actual work | Acronym | PCG approved | WI rapporteur name | Release | TSG approved | Impacted TSs and TRs | Status Report | WI rapporteur e-mail | Acronym_3GU_Export | Special Focus Doc | MCC resp |
| --- | --- | --- | --- | --- | --- | --- | --- | --- | --- | --- | --- | --- | --- | --- | --- | --- | --- | --- | --- | --- | --- | --- | --- | --- | --- | --- |
| 1320 | 297.126 | **LTE Advanced 3 Band Carrier Aggregation (3DL/3UL) of Band 39, Band 41 and Band 41** | 66d? | 2015-09-15 A | 2015-12-15 A | 100% |  |  |  |  |  |  | R4 | 1584h | 1584h | LTE_CA_3DL3UL_B39_B41_B41 | PCG-35 | CATT | Rel-13 | RP-69 |  |  |  |  |  |  |
| 1321 | 297.126.1 | Core part: LTE Advanced 3 Band Carrier Aggregation (3DL/3UL) of Band 39, Band 41 and Band 41 | 66d? | 2015-09-15 A | 2015-12-15 A | 100% |  |  |  |  |  | finish no earlier than 2015-12-15 | R4 | 528h | 528h | LTE_CA_3DL3UL_B39_B41_B41-Core | PCG-35 | CATT | Rel-13 | RP-69 |  |  |  |  |  |  |
| 1322 | 297.126.2 | Perf. part: LTE Advanced 3 Band Carrier Aggregation (3DL/3UL) of Band 39, Band 41 and Band 41 | 66d? | 2015-09-15 A | 2015-12-15 A | 100% |  |  |  |  |  | finish no earlier than 2015-12-15 | R4 | 528h | 528h | LTE_CA_3DL3UL_B39_B41_B41-Perf | PCG-35 | CATT | Rel-13 | RP-69 |  |  |  |  |  |  |
| 1323 | 297.127 | **LTE Advanced 3 Band Carrier Aggregation (3DL/3UL) of Band 39, Band 39 and Band 41** | 66d? | 2015-09-15 A | 2015-12-15 A | 100% |  |  |  |  |  |  | R4 | 1584h | 1584h | LTE_CA_3DL3UL_B39_B39_B41 | PCG-35 | CATT | Rel-13 | RP-69 | 36.899-13 |  |  |  |  |  |
| 1324 | 297.127.1 | Core part: LTE Advanced 3 Band Carrier Aggregation (3DL/3UL) of Band 39, Band 39 and Band 41 | 66d? | 2015-09-15 A | 2015-12-15 A | 100% |  |  |  |  |  | finish no earlier than 2015-12-15 | R4 | 528h | 528h | LTE_CA_3DL3UL_B39_B39_B41-Core | PCG-35 | CATT | Rel-13 | RP-69 |  |  |  |  |  |  |
| 1325 | 297.127.2 | Perf. part: LTE Advanced 3 Band Carrier Aggregation (3DL/3UL) of Band 39, Band 39 and Band 41 | 66d? | 2015-09-15 A | 2015-12-15 A | 100% |  |  |  |  |  | finish no earlier than 2015-12-15 | R4 | 528h | 528h | LTE_CA_3DL3UL_B39_B39_B41-Perf | PCG-35 | CATT | Rel-13 | RP-69 |  |  |  |  |  |  |
| 1326 | 297.128 | **Additional bandwidth combination set for LTE Advanced intra-band non-contiguous Carrier Aggregation in Band 7** | 66d? | 2015-09-15 A | 2015-12-15 A | 100% |  |  |  |  |  |  | R4 | 1584h | 1584h | LTE_CA_NC_B7_BWset | PCG-35 | Huawei | Rel-13 | RP-69 |  |  |  |  |  |  |
| 1327 | 297.128.1 | Core part: Additional bandwidth combination set for LTE Advanced intra-band non-contiguous Carrier Aggregation in Band 7 | 66d? | 2015-09-15 A | 2015-12-15 A | 100% |  |  |  |  |  | finish no earlier than 2015-12-15 | R4 | 528h | 528h | LTE_CA_NC_B7_BWset-Core | PCG-35 | Huawei | Rel-13 | RP-69 |  |  |  |  |  |  |
| 1328 | 297.128.2 | Perf. part: Additional bandwidth combination set for LTE Advanced intra-band non-contiguous Carrier Aggregation in Band 7 | 66d? | 2015-09-15 A | 2015-12-15 A | 100% |  |  |  |  |  | finish no earlier than 2015-12-15 | R4 | 528h | 528h | LTE_CA_NC_B7_BWset-Perf | PCG-35 | Huawei | Rel-13 | RP-69 |  |  |  |  |  |  |
| 1329 | 297.129 | UE Conformance Test Aspects - Rel-13 LTE CA configurations | 328d? | 2015-12-15 A | 2017-03-15 | 30% | 229.6d? |  |  |  | 283d | finish no earlier than 2017-03-15 | R5 | 2624h | 787.2h | LTE_CA_Rel13-UEConTest | PCG-36 | Ericsson | Rel-13 | RP-70 |  |  |  |  |  |  |
| 1330 | 298 | (Small) Technical Enhancements and Improvements for Rel-13 | 593d? | 2013-09-18 A | 2015-12-21 A | 100% |  |  |  |  |  | finish no earlier than 2015-12-21 | SP; CP; RP; GP | 18976h | 18976h | TEI13 | PCG-31 |  | Rel-13 | SP-61 |  | PCG-31 |  |  |  |  |
| 1331 | 299 | (Small) Test Technical Enhancements and Improvements for Rel-13 | 593d? | 2013-09-18 A | 2015-12-21 A | 100% |  |  |  |  |  | finish no earlier than 2015-12-21 | SP; CP; RP; GP | 18976h | 18976h | TEI13_Test | PCG-31 |  | Rel-13 | SP-61 |  | PCG-31 |  |  |  |  |
| 1332 | 300 | Awaiting formal work item | 593d? | 2013-09-18 A | 2015-12-21 A | 100% |  |  |  |  |  | start no earlier than 2013-09-18 | SP; CP; RP; GP | 18976h | 18976h | DUMMY | PCG-35 |  | Rel-13 | SP-69 |  |  |  |  |  |  |
| 1333 | 301 | (Small) Security Enhancements and Improvements for Rel-13 | 2372d? | 2006-12-12 A | 2015-12-21 A | 100% |  |  |  |  |  | finish no earlier than 2015-12-21 | S3 | 18976h | 18976h | SEC13 | PCG-31 |  | Rel-13 | SP-61 |  | PCG-31 |  |  |  |  |
| 1334 | 302 | Release 13 IoT related Studies | 602d? | 2013-09-12 A | 2015-12-25 A | 100% |  | 2014-07-31 | 2015-12-25 | 366.5d? |  | start no earlier than 2013-09-12 | SP; R2 | 9632h | 9632h |  |  |  | Rel-13 |  |  |  |  |  |  |  |
| 1335 | 303 | Study on Power saving for Machine-Type Communications (MTC) devices | 266.6d? | 2014-08-12 A | 2015-08-14 A | 100% |  | 2014-06-18 | 2015-02-20 | 160.5d? |  | finish no earlier than 2015-08-14 | G2; G1 | 4000.8h | 4000.8h | FS_uPoD | PCG-32 | China Mobile | Rel-13 | GP-60 | 43.869 |  | Jing Han (hanjing@chinamobile.com) | FS_uPoD |  |  |
| 1336 | 304 | Study on Cellular system support for ultra Low Complexity and low throughput Internet of Things | 329d? | 2014-05-30 A | 2015-08-28 A | 100% |  | 2015-01-14 | 2015-08-28 | 163d? |  | finish no earlier than 2015-08-28 | G1; G2 | 5264h | 5264h | FS_IoT_LC | PCG-33 | Vodafone | Rel-13 | GP-66 | 45.8xy |  | chris.pudney@vodafone.com | FS_IoT_LC | MTC, M2M |  |
| 1337 | 305 | Study on architecture enhancements of cellular systems for ultra low complexity and low throughput Internet of Things | 196d? | 2015-03-13 A | 2015-12-11 A | 100% |  |  |  |  |  | finish no earlier than 2015-12-11 | S2 | 1568h | 1568h | FS_AE_CIoT | PCG-34 | puneet.jain@intel.com | Rel-13 | SP-67 | New TR 23.8xx |  | puneet.jain@intel.com |  |  |  |
| 1338 | 306 | Study on Battery Efficient Security for very low Throughput Machine Type Communication Devices | 196d? | 2015-03-13 A | 2015-12-11 A | 100% |  |  |  |  |  | finish no earlier than 2015-12-11 | S3 | 1568h | 1568h | FS_BEST_MTC_Sec | PCG-34 | Barry, Aguibou, VODAFONE Group Plc | Rel-13 | SP-67 | 32.863; 33.163 |  | Barry, Aguibou, VODAFONE Group Plc |  |  |  |
| 1339 | 307 | Study on Small data transmission enhancements for UMTS | 197d? | 2014-09-16 A | 2015-06-15 A | 100% |  |  |  |  |  | finish no earlier than 2015-06-15 | R1; R3 | 3152h | 3152h | FS_UTRA_SDATA | PCG-33 | Ericsson | Rel-13 | RP-65 | 25.705 | RP-150843 | gerardo.agni.medina.acosta@ericsson.com | FS_UTRA_SDATA |  |  |
| 1340 | 308 | Study on Application specific Congestion control for Data Communication | 531.29d? | 2012-09-17 A | 2014-09-17 A | 100% |  | 2012-09-13 | 2014-09-17 | 532d? |  | finish no earlier than 2014-09-17 | S1 | 4250.28h | 4250.28h | FS_ACDC | PCG-29 | NTT DOCOMO | Rel-13 | SP-57 | 22.806 | S1-143305 | Atsushi Minokuchi (minokuchi@nttdocomo.co.jp) | FS_ACDC |  | Alain |
| 1341 | 309 | Study on enhancements for Infrastructure based data Communication Between Devices | 266d? | 2013-09-14 A | 2014-09-17 A | 100% |  | 2013-09-12 | 2014-09-17 | 266d? |  | finish no earlier than 2014-09-17 | S1 | 2128h | 2128h | FS_eICBD | PCG-31 | KPN | Rel-13 | SP-61 | 22.807 | S1-143309 | toon.norp@tno.nl | FS_eICBD | MTC, M2M | Alain |
| 1342 | 310 | Release 13 other Studies | 602d? | 2013-09-12 A | 2015-12-25 A | 100% |  | 2014-07-31 | 2015-12-25 | 366.5d? |  | start no earlier than 2013-09-12 | SP; R2 | 9632h | 9632h |  |  |  | Rel-13 |  |  |  |  |  |  |  |
| 1343 | 311 | Study on Isolated E-UTRAN Operation for Public Safety | 261d? | 2013-06-25 A | 2014-06-18 A | 100% |  | 2013-06-21 | 2014-06-18 | 262d? |  | finish no earlier than 2014-06-18 | S1 | 2088h | 2088h | FS_IOPS | PCG-31 | General Dynamics | Rel-13 | SP-60 | 22.897 |  | paul.piggin@gd-broadband.com | FS_IOPS | Public Safety (A-A) | Alain |
| 1344 | 312 | Study on architecture enhancements for Public Safety | 131d? | 2014-12-12 A | 2015-06-12 A | 100% |  |  |  |  |  | finish no earlier than 2015-06-12 | S2 | 1048h | 1048h | FS_IOPS_St2 | PCG-34 |  | Rel-13 | SP-66 |  |  | phil.young@gd-broadband.com |  |  |  |
| 1345 | 313 | Study on Security Aspects of Isolated E-UTRAN Operation for Public Safety | 137d? | 2015-03-12 A | 2015-09-18 A | 100% |  |  |  |  |  | finish no earlier than 2015-09-18 | S3 | 1096h | 1096h | FS_IOPS_Sec | PCG-34 | Paul Piggin, General Dynamics UK | Rel-13 | SP-67 | New TR 33.897 |  | paul.piggin@gd-broadband.com |  |  |  |
| 1346 | 314 | (SA66: on hold) Study on Co-ordinated packet data network gateway (P-GW) change for SIPTO | 201d? | 2013-09-13 A | 2014-06-18 A | 100% |  | 2013-09-12 | 2014-06-18 | 202d? |  | finish no earlier than 2014-06-18 | S1 | 1608h | 1608h | FS_CSIPTO | PCG-31 | Intel | Rel-13 | SP-61 | 22.828 |  | Eric.siow@intel.com | FS_CSIPTO |  | Alain |
| 1347 | 315 | Study on Flexible Mobile Service Steering | 201d? | 2013-12-13 A | 2014-09-17 A | 100% |  | 2013-12-11 | 2014-09-17 | 202d? |  | finish no earlier than 2014-09-17 | S1 | 1608h | 1608h | FS_FMSS | PCG-32 | China Mobile | Rel-13 | SP-62 | 22.808 | S1-143310 | Lu Lu (lulu@chinamobile.com) | FS_FMSS |  | Alain |
| 1348 | 316 | Study on Enhanced Calling Information Presentation | 201d? | 2013-12-13 A | 2014-09-17 A | 100% |  | 2013-12-11 | 2014-09-17 | 201d? |  | finish no earlier than 2014-09-17 | S1 | 1608h | 1608h | FS_ECIP | PCG-32 | China Mobile | Rel-13 | SP-62 | 22.810 | S1-143311 | LI Xiaofan (lixiaofan@chinamobile.com | FS_ECIP |  | Alain |
| 1349 | 317 | Study on RAN Sharing Enhancements on GERAN and UTRAN | 140d? | 2014-03-07 A | 2014-09-17 A | 100% |  | 2014-03-07 | 2014-09-17 | 139d? |  | finish no earlier than 2014-09-17 | S1 | 1120h | 1120h | FS_GUSH | PCG-32 | Telefónica | Rel-13 | SP-63 | 22.852 updates |  | chris.friel@telefonica.com | FS_GUSH |  | Alain |

Notes:
- 1320: TDD case
- 1321: TDD case...
- 1322: TDD case...
- 1323: TDD case; 5/10/15: 36.899-13 added;
- 1324: TDD case...
- 1325: TDD case...
- 1326: LTE_CA_NC_B7 was completed in REL-12
- 1327: LTE_CA_NC_B7 was completed in REL-12 ; ...
- 1328: LTE_CA_NC_B7 was completed in REL-12 ; ...
- 1329: ; 22/3/16: Compl:0%->5%;...1/7/16: Compl:5%->22%26/9/16: Compl:22%->...
- 1330: -
- 1331: Created upon demand of RAN5
- 1333: -
- 1334: -
- 1335: GP#65 completion 02/15=>05/15. GP#60 approved WID. Linked to Rel-12 Feature MTCe, Stage 2 BB3: UE Power Consumptions Optimizations (UEPCOP). Dec.14: 30->40%; June2015: Compl:40%->75; 07/09/15: 75%->100
- 1336: GP#62 approved WID. Dec.14: 15->40%; June2015: Compl:40%->75; 07/09/15: 75%->100; 14/09/15: WID:GP-140421->GP-150354
- 1337: 07/09/15: 0%->20; 07/09/15: 20%->65; 7/12/15: 65%->95; 7/3/16: 95%->100
- 1338: TR number added; June2015: Compl:0%->10; 7/12/15: 10%->50; 11/12/15: 50%->75; 7/3/16: 75%->95; 19/9/16: 95%->100; 6/10/16: 33.163 added;
- 1339: 3/3/15: WID: RP-141861; Stat Rep: -->RP-141859. Impacted TR number added. 1st Apr 15: Compl:30%->55% 1st Apr 15: Stat Rep: RP-141859->RP-150196 03/07/15: Compl:55%->100% 03/07/15: Stat Rep: RP-150196->RP-150843
- 1340: SP#65 completed. SP#64 TR 22.806v200 for Approval. ACDC is applicable to UTRAN and E-UTRAN. Possible overlap with RAN2 TR 36.848 Study on smart congestion mitigation in E-UTRAN (prioritising MMTEL voice over other traffic during congestion)
- 1341: SP#65 completed. TR 22.807v200 for Approval
- 1342: -
- 1343: SP#64 completed. TR 22.897v200 for Approval. Linked to Rel-12 TR 22.803 (FS_ProSe) and FeaturES in CP-150ProSe, GCSE_LTE
- 1344: June2015: Compl:0%->100
- 1345: TR added; June2015: Compl:0%->30; 7/12/15: 30%->100
- 1346: SP#64 completed. TR 22.828v200 for Approval. Linked to FeaturES in CP-150Rel-10 LIPA_SIPTO & Rel-12 LIMONET
- 1347: SP#65 completed. TR 22.808v200 for Approval. Study supporting traffic classification and service chain selection capabilities per operators policy in order to realize efficient and flexible mobile service steering in the Gi-LAN network
- 1348: SP#65 completed. TR 22.810v200 for Approval. Linked to Multimedia Telephony Service for IMS (UID_7038), Customized Alerting Tone (CAT) UID_370028, Customized Ringing Signal (CRS) UID_380067
- 1349: SP#65 completed. Update on GERAN and UTRAN of Rel-12 TR 22.852 Study on RAN Sharing Enhancements (FS_RSE)

| ID | WBS | Task | Duration | Start | Finish | Complete | Remaining | Baseline start | Baseline finish | Baseline duration | Total slack | Constraint | Resources | Work | Actual work | Acronym | PCG approved | WI rapporteur name | Release | TSG approved | MCC resp | Acronym_3GU_Export | PCG stopped | TSG stopped | Special Focus Doc | Status Report |
| --- | --- | --- | --- | --- | --- | --- | --- | --- | --- | --- | --- | --- | --- | --- | --- | --- | --- | --- | --- | --- | --- | --- | --- | --- | --- | --- |
| 1350 | 318 | **Study on Usage Monitoring Enhancements for Service, Application and Subscriber Group** | 934d? | 2011-06-08 A | 2014-12-12 A | 100% |  | 2011-06-08 | 2014-12-10 | 929d? |  |  | S2 | 13978.1h | 13978.1h | FS_UMONC_sas | PCG-27 | China Telecom | Rel-13 | SP-52 | Maurice | FS_UMONC_sas |  |  |  |  |
| 1351 | 318.1 | Deleted - SA1 part of Study on Usage Monitoring Control PCC Enhancement | 275d? | 2011-06-08 A | 2012-06-20 A | 100% |  | 2011-06-08 | 2012-06-20 | 275d? |  | finish no earlier than 2012-06-20 | S1 | 2200h | 2200h |  | PCG-27 | ZTE |  | SP-52 | Maurice | FS_UMONC | PCG-31 | SP-58 |  |  |
| 1352 | 318.2 | SA2 part of Study on Usage Monitoring Control PCC Enhancement | 397.26d? | 2013-06-14 A | 2014-12-12 A | 100% |  | 2013-06-02 | 2014-12-10 | 403d? |  | finish no earlier than 2014-12-12 | S2 | 3178.08h | 3178.08h | FS_UMONC_sas | PCG-27 | China Telecom | Rel-13 | SP-52 | Maurice |  |  |  |  |  |
| 1353 | 318.3 | Deleted - SA5 part of Study on Usage Monitoring Control enhancement | 141d? | 2012-03-02 A | 2012-09-12 A | 100% |  | 2012-03-02 | 2012-09-12 | 141d? |  | finish no earlier than 2012-09-12 | S5 | 1128h | 1128h |  | PCG-27 | Huawei |  | SP-52 | Mirko |  | PCG-29 | SP-57 |  |  |
| 1354 | 319 | Study on Security aspects of Integration of Single Sign-On (SSO) frameworks with 3GPP networks | 1180d? | 2010-12-28 A | 2015-06-12 A | 100% |  | 2010-12-16 | 2014-09-17 | 988d? |  | finish no earlier than 2015-06-12 | S3 | 9440h | 9440h | FS_SSO_Int_Sec | PCG-26 | Ericsson | Rel-13 | SP-50 | Mirko | FS_SSO_Int_Sec |  |  |  |  |
| 1355 | 320 | Study on Subscriber Privacy Impact in 3GPP | 591d? | 2013-09-17 A | 2015-12-16 A | 100% |  | 2013-09-12 | 2014-09-17 | 266d? |  | finish no earlier than 2015-12-16 | S3 | 4728h | 4728h | FS_SPI | PCG-31 | China Unicom | Rel-13 | SP-61 | Mirko | FS_SPI |  |  |  |  |
| 1356 | 321 | Study on IMS Enhanced Spoofed Call Prevention and Detection | 261d? | 2014-09-19 A | 2015-09-16 | 30% | 182.7d? |  |  |  | 674d | finish no earlier than 2015-09-16 | S3 | 2088h | 626.4h | FS_ESCAPADES | PCG-33 | Sprint | Rel-13 | SP-64 |  | FS_ESCAPADES |  |  |  |  |
| 1357 | 322 | Study on Compliance of 3GPP SA5 specifications to the NGMN NGCOR | 981d? | 2012-06-26 A | 2016-03-11 | 60% | 392.4d? | 2012-06-20 | 2015-09-16 | 854d? | 547d | finish no earlier than 2016-03-11 | S5 | 7848h | 4708.8h | FS_OAM_NGMN_NGCOR | PCG-29 | Huawei | Rel-13 | SP-56 | Mirko | FS_OAM_NGMN_NGCOR |  |  |  |  |
| 1358 | 323 | Study on Enhancements of OAM aspects of Distributed Mobility Load Balancing (MLB) SON function | 458d? | 2014-09-15 A | 2016-06-13 A | 100% |  | 2013-09-12 | 2014-12-10 | 326d? |  | finish no earlier than 2016-06-13 | S5 | 3664h | 3664h | FS_D_MLB_SON_OAM | PCG-31 | Cisco | Rel-13 | SP-61 | Mirko | FS_D_MLB_SON_OAM |  |  | SON |  |
| 1359 | 324 | Study on Application and Partitioning of Itf-N | 458d? | 2013-12-17 A | 2015-09-11 A | 100% |  | 2013-12-11 | 2014-12-10 | 261d? |  | finish no earlier than 2015-09-11 | S5 | 3664h | 3664h | FS_OAM_AP_Itf-N | PCG-32 | China Mobile | Rel-13 | SP-62 | Mirko | FS_OAM_AP_Itf-N |  |  |  |  |
| 1360 | 325 | Study on Charging aspects on Roaming End-to-end scenarios with VoLTE IMS and interconnecting networks | 393d? | 2013-12-17 A | 2015-06-12 A | 100% |  | 2013-12-11 | 2014-12-10 | 261d? |  | finish no earlier than 2015-06-12 | S5 | 3144h | 3144h | FS_REVOLTE_IMS_CH | PCG-32 | Deutsche Telekom | Rel-13 | SP-62 | Mirko | FS_REVOLTE_IMS_CH |  |  |  |  |
| 1361 | 326 | Study on Network Management of Virtualized Networks | 269d? | 2014-06-11 A | 2015-06-17 A | 100% |  | 2014-06-06 | 2015-06-17 | 269d? |  | finish no earlier than 2015-06-17 | S5 | 2152h | 2152h | FS_OAM_VIRNET | PCG-33 | China Mobile, Huawei | Rel-13 | SP-64 |  | FS_OAM_VIRNET |  |  |  |  |
| 1362 | 327 | Study on Review of dedicated 3GPP UICC features | 729d? | 2013-03-13 A | 2015-12-16 A | 100% |  | 2013-03-04 | 2014-09-12 | 401d? |  | finish no earlier than 2015-12-16 | C6 | 5832h | 5832h | FS_Red_UCe | PCG-30 | BlackBerry | Rel-13 | CP-59 | Xavier | FS_Red_UCe |  |  |  |  |
| 1363 | 328 | Study on Solutions for GSM/EDGE BTS Energy Saving | 458.8d? | 2011-08-30 A | 2015-11-20 A | 100% |  | 2009-03-10 | 2014-08-29 | 557d? |  | finish no earlier than 2015-11-20 | G1; G2 | 3670.4h | 3670.4h | FS_Energy_BTS | PCG-25 | Nokia Networks | Rel-13 | GP-47 | Paolo | FS_Energy_BTS |  |  |  |  |
| 1364 | 329 | Study on Downlink MIMO | 459d? | 2014-08-14 A | 2016-05-12 | 75% | 114.75d? | 2013-08-20 | 2015-02-20 | 396d? | 503d | finish no earlier than 2016-05-12 | G1; G2 | 4004.8h | 3086.8h | FS_DOMIMO | PCG-30 | Nokia Networks | Rel-13 | GP-57 | Paolo | FS_DOMIMO |  |  |  |  |
| 1365 | 330 | Study on MIMO OTA antenna test function for LTE | 462d? | 2013-03-18 A | 2014-12-15 A | 100% |  | 2013-03-15 | 2014-12-05 | 456d? |  | finish no earlier than 2014-12-15 | R4 | 3696h | 3696h | FS_LTE_MIMO_OTA_ATF | PCG-33 | Keysight | Rel-13 | RP-64 |  | FS_LTE_MIMO_OTA_ATF |  |  |  | RP-142045 |
| 1366 | 331 | Stopped at 20% - Study on UpLink MultiUser Multiple-Input Multiple-Output (UL MU-MIMO) | 481.6d? | 2014-04-17 A | 2016-02-19 A | 100% |  | 2014-04-17 | 2015-02-20 | 195.5d? |  | finish no earlier than 2016-02-19 | G1; G2 | 5688h | 5688h | FS_UL_MU_MIMO | PCG-32 | Huawei | Rel-13 | GP-60 |  | FS_UL_MU_MIMO |  | SP#71 |  |  |
| 1367 | 332 | Study on LTE FDD in the bands 1980-2010 MHz and 2170-2200 MHz | 854d? | 2012-09-11 A | 2015-12-15 A | 100% |  | 2012-09-11 | 2014-09-12 | 527d? |  | finish no earlier than 2015-12-15 | R4 | 6832h | 6832h | FS_LTE_1980_2170_Korea | PCG-29 | KT | Rel-13 | RP-57 | Issam | FS_LTE_1980_2170_Korea |  |  |  | RP-151274 |
| 1368 | 333 | Study on Positioning enhancements for E-UTRA | 524d? | 2012-05-01 A | 2014-12-15 A | 100% |  | 2013-04-25 | 2014-12-05 | 256d? |  | finish no earlier than 2014-12-15 | R4 | 4192h | 4192h | FS_LCSenh_LTE | PCG-31 | Huawei | Rel-13 | RP-60 | Issam | FS_LCSenh_LTE |  |  |  | RP-142224 |
| 1369 | 334 | Study on Multi-RAT joint coordination | 397d? | 2013-12-06 A | 2015-06-15 A | 100% |  | 2013-12-06 | 2014-12-05 | 261d? |  | finish no earlier than 2015-06-15 | R4 | 3176h | 3176h | FS_MultiRAT_JC | PCG-32 | China Mobile | Rel-13 | RP-62 | Juha | FS_MultiRAT_JC |  |  | WLAN | RP-150807 |
| 1370 | 335 | Study on Advanced Wireless Services (AWS) - Extension band for LTE | 265d? | 2013-12-16 A | 2014-12-15 A | 100% |  | 2013-12-09 | 2014-12-05 | 261d? |  | finish no earlier than 2014-12-15 | R4 | 2120h | 2120h | FS_LTE_AWS_EXT | PCG-33 | Qualcomm | Rel-13 | RP-64 |  | FS_LTE_AWS_EXT |  |  |  | RP-141968 |
| 1371 | 336 | Study on Indoor Positioning Enhancements for UTRA and LTE | 328d? | 2014-06-18 A | 2015-09-15 A | 100% |  | 2014-06-13 | 2015-09-17 | 330d? |  | finish no earlier than 2015-09-15 | R1; R4 | 5248h | 5248h | FS_UTRA_LTE_iPos_enh | PCG-33 | NextNav | Rel-13 | RP-64 |  | FS_UTRA_LTE_iPos_enh |  |  |  | RP-151178 |
| 1372 | 337 | Study on Downlink enhancements for UMTS | 199d? | 2014-09-12 A | 2015-06-15 A | 100% |  |  |  |  |  | finish no earlier than 2015-06-15 | R2; R1 | 3184h | 3184h | FS_UTRA_EDL | PCG-33 | Huawei | Rel-13 | RP-65 |  | FS_UTRA_EDL |  |  |  | RP-150681 |
| 1373 | 338 | Study on Elevation Beamforming/Full-Dimension (FD) MIMO for LTE | 199d? | 2014-09-12 A | 2015-06-15 A | 100% |  |  |  |  |  | finish no earlier than 2015-06-15 | R1 | 1592h | 1592h | FS_LTE_EBF_FDMIMO | PCG-33 | Nokia Networks (DL), Samsung (UL) | Rel-13 | RP-65 |  | FS_LTE_EBF_FDMIMO |  |  |  | RP-150734 |
| 1374 | 339 | Study on Licensed-Assisted Access using LTE | 197d? | 2014-09-16 A | 2015-06-15 A | 100% |  |  |  |  |  | finish no earlier than 2015-06-15 | R1; R2; R4 | 4728h | 4728h | FS_LTE_LAA | PCG-33 | Ericsson, Huawei | Rel-13 | RP-65 |  | FS_LTE_LAA |  |  |  | RP-150624 |
| 1375 | 340 | Study on EPC Signalling Improvement for Race Scenarios | 203d? | 2014-12-03 A | 2015-09-11 A | 100% |  |  |  |  |  | finish no earlier than 2015-09-11 | C4 | 1624h | 1624h | FS_EPC_SIG_RACE | PCG-34 | Huawei | Rel-13 | CT-66 |  |  |  |  |  |  |
| 1376 | 341 | Study on Video Enhancements in 3GPP Multimedia Services | 261d? | 2014-12-12 A | 2015-12-11 A | 100% |  |  |  |  |  | finish no earlier than 2015-12-11 | S4 | 2088h | 2088h | FS_VE_3MS | PCG-34 | Ye-Kui Wang, Qualcomm Incorporated | Rel-13 | SP-66 |  |  |  |  |  |  |
| 1377 | 342 | Study on possible additional configuration for LTE TDD | 197d? | 2014-12-15 A | 2015-09-15 A | 100% |  |  |  |  |  | finish no earlier than 2015-09-15 | R4 | 1576h | 1576h | FS_LTE_TDD_add_config | PCG-34 | NTT DOCOMO, Hideaki Takahashi | Rel-13 | RP-66 |  |  |  |  |  | RP-151283 |
| 1378 | 343 | Study on Network-Assisted Interference Cancellation and Suppression for UMTS | 197d? | 2014-12-15 A | 2015-09-15 A | 100% |  |  |  |  |  | finish no earlier than 2015-09-15 | R1 | 1576h | 1576h | FS_UTRA_NAICS | PCG-34 | Huawei | Rel-13 | RP-66 |  |  |  |  |  | RP-151235 |
| 1379 | 344 | Study on Enhanced Multiuser Transmissions and Network Assisted Interference Cancellation for LTE | 65d? | 2014-12-15 | 2015-03-15 |  |  |  |  |  | 807d | finish no earlier than 2015-03-15 | R1 | 520h |  | FS_LTE_MUTX_NAIC | PCG-34 | MediaTek | Rel-13 | RP-66 |  |  |  |  |  | RP-150213 |
| 1380 | 345 | Study on Support of single-cell point-to-multipoint transmission in LTE | 131d? | 2014-12-15 A | 2015-06-15 A | 100% |  |  |  |  |  | finish no earlier than 2015-06-15 | R4 | 1048h | 1048h | FS_LTE_SC_PTM | PCG-34 | Jeff GAO | Rel-13 | RP-66 |  |  |  |  |  | RP-150695 |
| 1381 | 346 | Study on Extension of Dual Connectivity in E-UTRAN | 131d? | 2014-12-15 A | 2015-06-15 A | 100% |  |  |  |  |  | finish no earlier than 2015-06-15 | R3 | 1048h | 1048h | FS_LTE_dualC_ext | PCG-34 | Samsung | Rel-13 | RP-66 |  |  |  |  |  | RP-150849 |
| 1382 | 347 | Study on further enhancements of small cell higher layer aspects for LTE | 197d? | 2014-12-15 A | 2015-09-15 A | 100% |  |  |  |  |  | finish no earlier than 2015-09-15 | R3 | 1576h | 1576h | FS_LTE_SC_enh2_hilayer | PCG-34 | Huawei | Rel-13 | RP-66 |  |  |  |  |  | RP-151243 |
| 1383 | 348 | Study on RAN sharing enhancements for UMTS | 131d? | 2014-12-15 A | 2015-06-15 A | 100% |  |  |  |  |  | finish no earlier than 2015-06-15 | R3 | 1048h | 1048h | FS_RSE_UTRA_GUSH | PCG-34 | Huawei | Rel-13 | RP-66 |  |  |  |  |  | RP-150684 |
| 1384 | 349 | Study on LTE DL 4 Rx antenna ports | 65d? | 2014-12-15 A | 2015-03-15 A | 100% |  |  |  |  |  | finish no earlier than 2015-03-15 | R4 | 520h | 520h | FS_LTE_4Rx_AP_DL | PCG-34 | Ericsson | Rel-13 | RP-66 |  |  |  |  |  | RP-150138 |
| 1385 | 350 | Study on performance enhancements for high speed scenario in LTE | 262d? | 2014-12-15 A | 2015-12-15 A | 100% |  |  |  |  |  | finish no earlier than 2015-12-15 | R4 | 2096h | 2096h | FS_LTE_high_speed | PCG-34 | NTTDoCoMo | Rel-13 | RP-66 |  |  |  |  |  | RP-151313 |
| 1386 | 351 | Study on Enhanced Multiuser Transmissions and Network | 261d? | 2014-12-12 | 2015-12-11 |  |  |  |  |  | 612d | finish no earlier than 2015-12-11 | R1 | 2088h |  | FS_MUIC_LTE | PCG-34 | Pei-Kai Liao | Rel-13 | SP-67 |  |  |  |  |  |  |
| 1387 | 352 | Study on regulatory aspects for flexible duplex for E-UTRAN | 133d? | 2016-06-15 A | 2016-12-15 | 99% | 1d? |  |  |  | 347d |  | RP | 1064h | 1056h | FS_LTE_flex_duplex_reg | PCG-34 | LG Electronics Inc. | Rel-13 | RP-67 |  |  |  |  |  | RP-151307 |
| 1388 | 353 | Study on Downlink Multiuser Superposition Transmission for LTE | 197d? | 2015-03-16 A | 2015-12-15 A | 100% |  |  |  |  |  | finish no earlier than 2015-12-15 | R1 | 1576h | 1576h | FS_LTE_MUST | PCG-34 | Mediatek | Rel-13 | RP-67 |  |  |  |  |  | RP-151345 |
| 1389 | 354 | Study on Measurement gap enhancement for LTE | 197d? | 2015-03-16 A | 2015-12-15 A | 100% |  |  |  |  |  | finish no earlier than 2015-12-15 | R4 | 1576h | 1576h | FS_LTE_meas_gap |  |  | Rel-13 | TSG-67 |  |  |  |  |  | RP-151317 |
| 1390 | 355 | Study on Phase 1 of the Support of Emergency services over WLAN | 71d? | 2015-03-12 A | 2015-06-18 A | 100% |  |  |  |  |  | finish no earlier than 2015-06-18 | S2 | 568h | 568h | FS_SEW | PCG-34 | Laurent Thiebaut, Alcatel Lucent | Rel-13 | SP-67 |  |  |  |  |  |  |
| 1391 | 356 | Study on EGPRS Access Security Enhancements with relation to cellular IoT | 197d? | 2015-03-12 A | 2015-12-11 A | 100% |  |  |  |  |  | finish no earlier than 2015-12-11 | S3 | 1576h | 1576h | FS_EASE_IoT | PCG-34 | Vesa Torvinen, Ericsson | Rel-13 | SP-67 |  |  |  |  |  |  |
| 1392 | 357 | Study on SCC AS Restoration | 1d? | 2015-06-15 A | 2015-06-15 A | 100% |  |  |  |  |  | start no earlier than 2015-06-15 | C4 | 8h | 8h | FS_SCCAS_RES | PCG-35 | Hao Zhang,, China Mobile | Rel-13 | CP-68 |  |  |  |  |  |  |
| 1393 | 358 | Study on S6a/S6d Shared Data Update | 130d? | 2015-06-15 A | 2015-12-11 A | 100% |  |  |  |  |  | finish no earlier than 2015-12-11 | C4 | 1040h | 1040h | FS_eSDU | PCG-35 | Ulrich Wiehe, Nokia Networks | Rel-13 | CP-68 |  |  |  |  |  |  |
| 1394 | 359 | Study on Network Assistance for Network Synchronization in LTE | 395d? | 2015-06-15 A | 2016-12-15 | 95% | 19.75d? |  |  |  | 347d | finish no earlier than 2016-12-15 | R3 | 3160h | 3002h | FS_LTE_NW_SYNC | PCG-35 | Huawei | Rel-14 | TSG-68 |  |  |  |  |  | RP-151240 |
| 1395 | 360 | Study on LTE Advanced inter-band Carrier Aggregation of Band 20 and Band 28 | 132d? | 2015-06-15 A | 2015-12-15 A | 100% |  |  |  |  |  | finish no earlier than 2015-12-15 | R4 | 1056h | 1056h | FS_LTE_CA_B20_B28 | PCG-35 | TeliaSonera | Rel-13 | TSG-68 |  |  |  |  |  | RP-151231 |
| 1396 | 361 | Study on Impacts of the Diameter Base Protocol Specification Update | 75d? | 2015-09-07 A | 2015-12-18 A | 100% |  |  |  |  |  | finish no earlier than 2015-12-18 | C4 | 600h | 600h | FS_DBPU | PCG-35 | Huawei, Peter Schmitt | Rel-13 | SP-69 |  |  |  |  |  |  |
| 1397 | 362 | Study on new AWS-3/4 Band for LTE | 66d? | 2015-09-15 A | 2015-12-15 A | 100% |  |  |  |  |  | finish no earlier than 2015-12-15 | R4 | 528h | 528h | FS_LTE_AWS_3_4 | PCG-35 | Dish Network | Rel-13 | RP-69 |  |  |  |  |  |  |
| 1398 | 363 | Study on multi-node testing for LAA | 133d? | 2016-06-15 A | 2016-12-15 | 10% | 119.7d? |  |  |  | 347d | finish no earlier than 2016-12-15 | R4 | 1064h | 106.4h | FS_LTE_LAA_multinode_test | PCG-37 | Huawei | Rel-13 | TSG#72 |  |  |  |  |  |  |
| 1399 | 364 | Release 12 Features | 306d? | 2013-10-14 A | 2014-12-12 A | 100% |  | 2013-10-14 | 2014-12-10 | 304d? |  | finish no earlier than 2014-12-12 | SP; CP; RP; GP | 9792h | 9792h |  |  |  | Rel-12 |  |  |  |  |  |  |  |
| 1400 | 365 | Stage 1 - ONLY Features | 647d? | 2011-09-27 A | 2014-03-05 A | 100% |  | 2011-09-27 | 2014-03-05 | 647d? |  | start no earlier than 2011-09-27 | SP; CP | 10352h | 10352h |  | PCG-30 |  | Rel-12 | SP-58 |  |  |  |  |  |  |

Notes:
- 1350: SP#64 revived. Added to the Title "for Service, Application and Subscriber Group", Changed Acronym: FS_UMONC=>FS_UMONC_sas / Impacted TSs and TRs: 23.858 / WI rapporteur e-mail: Jinyan Li (lijy@ctbri.com.cn)
- 1351: SP#56 completed / Impacted TSs and TRs: 23.858 / WI rapporteur e-mail: Li.Mian@zte.com.cn
- 1352: SP#64 revived. Updated WID SP-120554=>SP-140403. Changed Justification/objectives/Rapporteut ZTE=>China Unciom. SP#58 SA2 stopped (at 70% completion). Dec.14: 80->100%. Mar 15: WID SP-140403->SP-150029 / Impacted TSs and TRs: 23.858 / WI rapporteur e-mail: Jinyan Li (lijy@ctbri.com.cn)
- 1353: SP#57 stopped / Impacted TSs and TRs: 32.858 / WI rapporteur e-mail: Hui Cai (Sarah.Cai@huawei.com)
- 1354: SP#65 moved to Rel-13. Updated WID SP-100734=>SP-140576. Completion 09/14=>06/15. Dec.14: 60->65%; June2015: Compl:65%->100; June2015: WID:SP-140576->SP-150368 / Impacted TSs and TRs: 33.895 / WI rapporteur e-mail: vesa.lehtovirta@ericsson.com
- 1355: SP#65 moved to Rel-13. Completion 09/14=>12/15. Related to SA1 TR 22.949 Rel-6 Study on Privacy Capability (PrivCap) UID_31030 studied generalized privacy capability (protection of personal data and non-disclosure of identity). Dec.14: 80->85; June2015...; 7/3/16: 92%->100 / Impacted TSs and TRs: 33.849 / WI rapporteur e-mail: Feng Gao (gaofeng149@chinaunicom.cn)
- 1356: Dec.14: TR number added. 3/3/15: 0->5%; June2015: Compl:5%->25; 9/12/15: 25%->30 / Impacted TSs and TRs: 33.832 / WI rapporteur e-mail: Gregory.schumacher@sprint.com
- 1357: SP#65 updated WID SP-140349=>SP-140539. Dec.14: 35->45, 12/14: 28.821 added. Mar 15: 45->50%; June2015: Compl:50%->60. 07/09/15: FCD: 09/15->12/15; 7/12/15: FCD:12/15->03/16 / Impacted TSs and TRs: TR 32.837, TR 28.821 / WI rapporteur e-mail: zoulan@huawei.com
- 1358: SP#64 completion 06/14=>12/14. Dec.14: 20->25%, CD: 12/14->06/15; June2015: Compl:25%->30; 7/12/15: 30%->45; 7/3/16: 45%->50; 13/6/16: 50%->100 / Impacted TSs and TRs: 32.860 / WI rapporteur e-mail: Vladimir Yanover (vyanover@cisco.com)
- 1359: -Dec.14: 15->30%, CD: 12/14->09/15; June2015: Compl:30%->60; 07/09/15: 60%->100 / Impacted TSs and TRs: 32.861 / WI rapporteur e-mail: Li Jian (lijian@chinamobile.com), Hu Yaxi (huyaxi@cmdi.chinamobile.com)
- 1360: SP#64 moved to Rel-13. Completion 06/14=>12/14. Dec.14: 35->55, CD: 12/14->06/15. Mar 15: 55->75%; June2015: Compl:75%->100 / Impacted TSs and TRs: 32.849 / WI rapporteur e-mail: Roland Jesske (r.jesske@telekom.de)
- 1361: Dec.14: 10->25%. Mar 15: 25->60%; June2015: Compl:60%->85; 07/09/15: 85%->100 / Impacted TSs and TRs: 32.842 / WI rapporteur e-mail: Liu Jinglei (liujinglei@chinamobile.com), zoulan@huawei.com
- 1362: CP#65 TR 31.901v100 for Information. Moved to Rel-13. Completion 09/14=>12/15. Waiting for feedback from external organizations (PTCRB/PVG). Dec.14: 65->100% / Impacted TSs and TRs: 31.901 / WI rapporteur e-mail: Adrian Buckley (abuckley@blackberry.com)
- 1363: GP#63 moved to Rel-13. Completion 08/14=>11/14. GP#55 TR 45.926v100 for Information. GP#47 approved WID. Dec.14: 90->95%. 3/3/15: start date corrected (was 03/09). 7/9/15: FCD: 8/15->11/15; 7/12/15: 95%->100 / Impacted TSs and TRs: 45.926 / WI rapporteur e-mail: juergen.hofmann@nokia.com
- 1364: GP#62 completion 08/14=>02/15. Moved to Rel-13. GP#57 approved WID. Dec.14: 50->65%, CD: 02/15->05/15. 7/9/15: FCD: 11/15->02/16; 2/3/16: 65%->75, FCD: 02/16->05/16 / Impacted TSs and TRs: 45.8xy / WI rapporteur e-mail: juergen.hofmann@nokia.com
- 1365: CD:Thu 11/12/14->Mon 15/12/14; Compl:60%->100%; Stat Rep: RP-141124->RP-142045 / Impacted TSs and TRs: 36.509, new TR 37.978 / WI rapporteur e-mail: Moray_Rumney@keysight.com
- 1366: GP#62 completion 11/14=>02/15. GP#60 approved WID. Dec.14: 02/15->05/15. 02/03/16: stopped at 20% / Impacted TSs and TRs: 45.876 / WI rapporteur e-mail: Chao Luo (chluo@huawei.com)
- 1367: CD:Thu 11/12/14->Sun 15/03/15; Compl:85%->90%; Stat Rep: RP-141153->RP-141851 1st Apr 15: CD:Sun 15/03/15->Mon 15/06/15 1st Apr 15: WID: RP-141154->RP-150119 1st Apr 15: Stat Rep: RP-141851->RP-150120 03/07/15: CD:Mon 15/06/15->Tue 15/09/15 03/07/15: S...; ; ; ; ; ; ; ; ; ; ; ; ; ; ; ; ; ; ; ; ; ; ; ; ; ; ; ; ; ; ; ; ; ; ; ; ; ; ; ; ; ; ; ; ; ; ; ; ; ; ; ; ; ; ; ; ; ; ; ; ; ; ; ; ; ; ; ; ; ; ; ; ; ; ; ; ; ; ; ; ; ; ; ; ; ; ; ; ; ; ; ; ; ; ; ; ; ; ; ; ; ; ; ; ; ; ; ; ; ; ; ; ; ; ; ; ; ; ; ; ; ; ; ; ; ; ; ; ; ; ; ; ; ; ; ; ; ; ; ; ; ; ; ; ; ; ; ; ; ; ; ; ; ; ; ; ; ; ; ; ; ; ; ; ; ; ; ; ; ; ; ; ; ; ; ; ; ; ; ; ; ; ; ; ; ; ; ; ; ; ; ; ; ; ; ; ; ; ; ; ; ; ; ; ; ; ; ; ; ; ; ; ; ; ; ; ; ; ; ; ; ; ; ; ; ; ; ; ; ; ; ; ; ; ; ; ; ; ; ; ; ; ; ; ; ; ; ; ; ; 1/1/16: Compl:95%->100%; ; ; ; ; ; ; ; ; ; ; ; ; ; ; ; ; ; ; ; ; ; ; ; ; ; ; ; ; ; ; ; ; ; ; ; ; ; ; ; ; ; ; ; ; ; ; ; ; ; ; ; ; ; ; ; ; ; ; ; ; ; ; ; ; ; ; ; ; ; ; ; ; ; ; ; ; ; ; ; ; ; ; ; ; ; ; ; ; ; ; ; ; ; ; ; ; ; ; ; ; ; ; ; ; ; ; ; ; ; ; ; ; ; ; ; ; ; ; ; ; ; ; ; ; ; ; ; ; ; ; ; ; ; ; ; ; ; ; ; ; ; ; ; ; ; ; ; ; ; ; ; ; ; ; ; ; ; ; ; ; ; ; ; ; ; ; ; ; ; ; ; ; ; ; ; ; ; ; ; ; ; ; ; ; ; ; ; ; ; ; ; ; ; ; ; ; ; ; ; ; ; ; ; ; ; ; ; ; ; ; ; ; ; ; ; ; ; ; ; ; ; ; ; ; ; ; ; ; ; ; ; ; ; ; ; ; ; ; ; ; ; ; ; ; ; ; ; ; ; 1/1/16: WID: RP-150119->RP-151855 / Impacted TSs and TRs: LTE 36.861 / WI rapporteur e-mail: Chungwoo HWANG (cwhwang@kt.com)
- 1368: WID: RP-140667->RP-130680; Stat Rep: RP-140639->RP-142224. 3/3/15: R1 removed as 2nd responsible WG / Impacted TSs and TRs: LTE 36.855 / WI rapporteur e-mail: Jie Cui (cuijie@huawei.com)
- 1369: ; WID: RP-142043->RP-132086; Stat Rep: RP-141301->RP-141838 1st Apr 15: Compl:55%->85% 1st Apr 15: WID: RP-132086->RP-150417 1st Apr 15: Stat Rep: RP-141838->RP-150187 03/07/15: Compl:85%->100% 03/07/15: Stat Rep: RP-150187->RP-150807 / Impacted TSs and TRs: UTRA, LTE 37.870 / WI rapporteur e-mail: Kimba Dit Adamou, Boubacar (jinba@chinamobile.com)
- 1370: CD:Thu 11/12/14->Mon 15/12/14; Compl:10%->100%; Stat Rep: RP-141429->RP-141968. 5/5/15: 2nd TR number added (to be clarified why two TR for a same topic) / Impacted TSs and TRs: 36.849, 36.869 / WI rapporteur e-mail: Gene Fong (gfong@qti.qualcomm.com)
- 1371: CD:Thu 17/09/15->Tue 15/09/15; Compl:0%->8%; Stat Rep: RP-141101->RP-141818 1st Apr 15: Compl:8%->30% 1st Apr 15: Stat Rep: RP-141818->RP-150080 03/07/15: Compl:30%->75% 03/07/15: Stat Rep: RP-150080->RP-150595 29/09/15: Compl:75%->100% 29/09/15: Stat Rep: RP-150595->RP-151178 / Impacted TSs and TRs: UTRA, LTE 37.857 / WI rapporteur e-mail: Vogedes Jerome (jvogedes@NextNav.com)
- 1372: WID: RP-141901; Stat Rep: -->RP-142233 1st Apr 15: Compl:40%->80% 1st Apr 15: WID: RP-141901->RP-150224 1st Apr 15: Stat Rep: RP-142233->RP-150223. 5/5/15: R4 replaced by R1 (correction mistake) 03/07/15: Compl:80%->100% 03/07/15: Stat Rep: RP-150223->RP-150681 / Impacted TSs and TRs: UTRA TR 25.706 / WI rapporteur e-mail: jun.chen@huawei.com
- 1373: 3/3/15: WID: RP-141831; Stat Rep: -->RP-141822, impacted TR number added. 1st Apr 15: Compl:30%->45% 1st Apr 15: Stat Rep: RP-141822->RP-150346. 5/5/15: "R4" replaced by "R1" (correction mistake) 03/07/15: Compl:45%->100% 03/07/15: WID: RP-141831->RP-150930 03/07/15: Stat Rep: RP-150346->RP-150734 / Impacted TSs and TRs: 36.897 / WI rapporteur e-mail: bishwarup.mondal@nsn.com, hyoungju.ji@samsung.com
- 1374: 3/3/15: WID: RP-141817; Stat Rep: -->RP-141816. Impacted TR number added. 1st Apr 15: Compl:30%->40% 1st Apr 15: Stat Rep: RP-141816->RP-150414 03/07/15: Compl:40%->100% 03/07/15: Stat Rep: RP-150414->RP-150624 / Impacted TSs and TRs: 36.889 / WI rapporteur e-mail: havish.koorapaty@ericsson.com, david.mazzarese@huawei.com
- 1375: Mar15: 0->20%; June2015: Compl:20%->80; 07/09/15: 80%->95; 7/12/15: 95%->100 / Impacted TSs and TRs: New TR 29.811
- 1376: Mar. 15: 0->20%; June2015: Compl:20%->40; 07/09/15: 40%->80; 7/12/15: 80%->100 / WI rapporteur e-mail: yekuiw@qti.qualcomm.com
- 1377: TR 36.825 rapporteur: CATT. TR number added. 1st Apr 15: Compl:0%->5% 1st Apr 15: Stat Rep: ->RP-150151 03/07/15: Compl:5%->35% 03/07/15: WID: RP-142248->RP-150652 03/07/15: Stat Rep: RP-150151->RP-150805 29/09/15: Compl:35%->100% 29/09/15: Stat Rep: RP-150805->RP-151283 / Impacted TSs and TRs: 36.825 / WI rapporteur e-mail: NTT DOCOMO
- 1378: TS number added 1st Apr 15: Compl:0%->20% 1st Apr 15: WID: RP-142250->RP-150174 1st Apr 15: Stat Rep: ->RP-150175. 5/5/15: "R4" replaced by "R1" (correction mistake) 03/07/15: Compl:20%->65% 03/07/15: Stat Rep: RP-150175->RP-150679 29/09/15: Compl:65%->100% 29/09/15: Stat Rep: RP-150679->RP-151235 / Impacted TSs and TRs: 25.766 / WI rapporteur e-mail: Huawei
- 1379: 1st Apr 15: CD:Tue 15/12/15->Sun 15/03/15 1st Apr 15: Stat Rep: ->RP-150213. 5/5/15: "R4" replaced by "R1" (correction mistake) / WI rapporteur e-mail: MediaTek
- 1380: deleted 660062 (duplicated). 29/1: TR number added 1st Apr 15: Compl:0%->25% 1st Apr 15: WID: RP-142205->RP-150177 1st Apr 15: Stat Rep: ->RP-150176 03/07/15: Compl:25%->100% 03/07/15: Stat Rep: RP-150176->RP-150695 / Impacted TSs and TRs: TR 36.890 / WI rapporteur e-mail: gaoyongqiang@huawei.com
- 1381: 1st Apr 15: WID: RP-142257->RP-150170 1st Apr 15: Stat Rep: ->RP-150163 03/07/15: Compl:85%->100% 03/07/15: Stat Rep: RP-150163->RP-150849. 7/10/15: responsible group corrected (R4->R3) / Impacted TSs and TRs: 36.875 / WI rapporteur e-mail: Samsung
- 1382: 03/07/15: Compl:10%->30% 03/07/15: Stat Rep: RP-150226->RP-150683 29/09/15: Compl:30%->100% 29/09/15: Stat Rep: RP-150683->RP-151243. 7/10/15: responsible group corrected (R4->R3) and TS (37.876->36.876) / Impacted TSs and TRs: 36.876 / WI rapporteur e-mail: Huawei
- 1383: 03/07/15: Compl:10%->100% 03/07/15: WID: RP-142284->RP-150686 03/07/15: Stat Rep: RP-150227->RP-150684. 7/10/15: responsible group corrected (R4->R3) / Impacted TSs and TRs: 25.756 / WI rapporteur e-mail: Huawei
- 1384: 1st Apr 15: Compl:0%->100% 1st Apr 15: WID: RP-142299->RP-150457 1st Apr 15: Stat Rep: ->RP-150138 / WI rapporteur e-mail: Ericsson
- 1385: TR Rapporteur is Huawei 1st Apr 15: Compl:0%->5% 1st Apr 15: WID: RP-142307->RP-150159 1st Apr 15: Stat Rep: ->RP-150517 03/07/15: Compl:5%->40% 03/07/15: Stat Rep: RP-150517->RP-150793 29/09/15: Compl:40%->80% 29/09/15: CD:Tue 15/09/15->Tue 15/12/15 2...; ; ; ; ; ; ; ; ; ; ; ; ; ; ; ; ; ; ; ; ; ; ; ; ; ; ; ; ; ; ; ; ; ; ; ; ; ; ; ; ; ; ; ; ; ; ; ; ; ; ; ; ; ; ; ; ; ; ; ; ; ; ; ; ; ; ; ; ; ; ; ; ; ; ; ; ; ; ; ; ; ; ; ; ; ; ; ; ; ; ; ; ; ; ; ; ; ; ; ; ; ; ; ; ; ; ; ; ; ; ; ; ; ; ; ; ; ; ; ; ; ; ; ; ; ; ; ; ; ; ; ; ; ; ; ; ; ; ; ; ; ; ; ; ; ; ; ; ; ; ; ; ; ; ; ; ; ; ; ; ; ; ; ; ; ; ; ; ; ; ; ; ; ; ; ; ; ; ; ; ; ; ; ; ; ; ; ; ; ; ; ; ; ; ; ; ; ; ; ; ; ; ; ; ; ; ; ; ; ; ; ; ; ; ; ; ; ; ; ; ; ; ; ; ; ; ; ; ; ; ; ; ; ; ; ; ; ; ; ; ; ; ; ; ; ; ; ; ; ; ; ; ; 1/1/16: Compl:80%->100% / WI rapporteur e-mail: NTTDoCoMo
- 1386: TR added / Impacted TSs and TRs: 36.891 / WI rapporteur e-mail: pk.liao@mediatek.com
- 1387: TR added 03/07/15: Compl:0%->5% 03/07/15: Stat Rep: -->RP-150770 29/09/15: Compl:5%->100% 29/09/15: Stat Rep: RP-150770->RP-151307 / Impacted TSs and TRs: 36.882
- 1388: TR added 03/07/15: Compl:0%->30% 03/07/15: WID: RP-150496->RP-151100 03/07/15: Stat Rep: -->RP-150857 29/09/15: Compl:30%->50% 29/09/15: Stat Rep: RP-150857->RP-151345 / Impacted TSs and TRs: 36.859
- 1389: 03/07/15: Compl:0%->15% 03/07/15: CD:Thu 10/12/15->Tue 15/12/15 03/07/15: Stat Rep: ->RP-150754 03/07/15: Release: REL-13->Rel-13. Aug 15: TR numb added 29/09/15: Compl:15%->65% 29/09/15: Stat Rep: RP-150754->RP-151317... / Impacted TSs and TRs: 36.894
- 1390: June2015: Compl:0%->100, SP-150151->SP-150251 / Impacted TSs and TRs: new 23.771 / WI rapporteur e-mail: Laurent.thiebaut@alcatel-lucent.com
- 1391: TR added; June2015: Compl:0%->25; 7/12/15: 25%->70; 28/1/16: 33.420 added;; 7/3/16: 70%->100 / Impacted TSs and TRs: New 33.860; 33.420
- 1392: 07/09/15: 5%->20; 7/12/15: 20%->100 / Impacted TSs and TRs: New 29.812 / WI rapporteur e-mail: zhanghao@chinamobile.com
- 1393: 07/09/15: 0%->20; 7/12/15: 20%->100 / Impacted TSs and TRs: New 29.813 / WI rapporteur e-mail: ulrich.wiehe@nokia.com
- 1394: Aug 15: TR numb added 29/09/15: Compl:0%->15% 29/09/15: WID: RP-151084->RP-151252 29/09/15: Stat Rep: -->RP-151240 22/3/16: Compl:60%->80%; 22/3/16: CD:Tue 15/03/16->Wed 15/06/16; ;...; ;... / Impacted TSs and TRs: New 36.898
- 1395: 29/09/15: Compl:0%->20% 29/09/15: WID: RP-151101->RP-151515 29/09/15: Stat Rep: -->RP-151231 ...
- 1396: 7/3/16: 0%->79; 13/6/16: 79%->99; 2/12/16: 99%->100 / Impacted TSs and TRs: 29.274, 29.060, 23.003, 29.272, 29.002, 29.305, 23.008, 29.230, 29.303, 23.007, 24.301, 24.008
- 1397: Impacted TSs and TRs: 36.870
- 1398: coexistence testing for REL-13 WI LTE_LAA26/9/16: Compl:0%->10%26/9/16: WID: RP-161197->RP-161672
- 1399: -
- 1400: -

| ID | WBS | Task | Duration | Start | Finish | Complete | Baseline start | Baseline finish | Baseline duration | Constraint | Resources | Work | Actual work | Acronym | PCG approved | Impacted TSs and TRs | WI rapporteur name | WI rapporteur e-mail | Release | TSG approved | MCC resp | Special Focus Doc | Acronym_3GU_Export | PCG stopped | TSG stopped |
| --- | --- | --- | --- | --- | --- | --- | --- | --- | --- | --- | --- | --- | --- | --- | --- | --- | --- | --- | --- | --- | --- | --- | --- | --- | --- |
| 1401 | 366 | **SIPTO Service Continuity of IP Data Session** | 262d? | 2010-09-23 A | 2011-09-21 A | 100% | 2010-09-23 | 2011-09-21 | 262d? |  | S1 | 4176h | 4176h | SIPTO_SC | PCG-25 | Stage 1 | Vodafone | mona.mustapha@vodafone.com | Rel-12 | SP-49 | Alain | HNB | SIPTO_SC |  |  |
| 1402 | 366.1 | Stage 1 for SIPTO Service Continuity of IP Data Session | 262d? | 2010-09-23 A | 2011-09-21 A | 100% | 2010-09-23 | 2011-09-21 | 262d? | finish no earlier than 2011-09-21 | S1 | 2080h | 2080h | SIPTO_SC-SA1 | PCG-25 | 22.101, 22.220 | Vodafone | mona.mustapha@vodafone.com | Rel-12 | SP-49 | Alain | HNB |  |  |  |
| 1403 | 367 | **Interworking between Mobile Operators using the Evolved Packet System and Data Application Providers** | 792d? | 2010-12-16 A | 2013-12-11 A | 100% | 2010-12-16 | 2013-12-11 | 792d? |  | S1; S2 | 22794.7h | 22794.7h | MOSAP | PCG-26 | Stage 1 | Cisco | Vojislav Vucetic (vvucetic@cisco.com) | Rel-12 | SP-50 | Alain |  | MOSAP |  |  |
| 1404 | 367.1 | Stage 1 for MOSAP | 202d? | 2010-12-16 A | 2011-09-21 A | 100% | 2010-12-16 | 2011-09-21 | 202d? | finish no earlier than 2011-09-21 | S1 | 1600h | 1600h | MOSAP-SA1 | PCG-26 | 22.278 | Cisco | Vojislav Vucetic (vvucetic@cisco.com) | Rel-12 | SP-50 | Alain |  |  |  |  |
| 1405 | 367.2 | TR on Stage 2 for MOSAP | 669d? | 2011-06-06 A | 2013-12-11 A | 100% | 2011-06-06 | 2013-12-11 | 669d? | finish no earlier than 2012-12-12 | S2 | 5338.74h | 5338.74h | MOSAP-SA2TR | PCG-27 | new TR 23.862 | Intel | chang.hong.shan@intel.com | Rel-12 | SP-52 | Maurice |  |  |  |  |
| 1406 | 367.3 | Deleted - Stage 2 for MOSAP | 399d? | 2011-06-14 A | 2012-12-12 A | 100% | 2011-06-14 | 2012-12-12 | 399d? | finish no earlier than 2012-12-12 | S2 | 3184h | 3184h | MOSAP-SA2Del | PCG-27 | TBD | Intel | chang.hong.shan@intel.com | Rel-12 | SP-52 | Maurice |  |  | PCG-30 | SP-58 |
| 1407 | 368 | **IMS Network-Independent Public User Identities** | 275d? | 2011-06-08 A | 2012-06-20 A | 100% | 2011-06-08 | 2012-06-20 | 275d? |  | S1 | 4390.4h | 4390.4h | INIPUI | PCG-27 | Stage 1 | Vodafone | mona.mustapha@vodafone.com | Rel-12 | SP-52 | Alain |  | INIPUI |  |  |
| 1408 | 368.1 | Stage 1 for IMS Network-Independent Public User Identities | 275d? | 2011-06-08 A | 2012-06-20 A | 100% | 2011-06-08 | 2012-06-20 | 275d? | finish no earlier than 2012-06-20 | S1 | 2190.4h | 2190.4h | INIPUI-SA1 | PCG-27 | 22.115, 22.228 | Vodafone | mona.mustapha@vodafone.com | Rel-12 | SP-52 | Alain |  |  |  |  |
| 1409 | 369 | **Service and Media Reachability for Users over Restrictive Firewalls** | 198d? | 2011-09-21 A | 2012-06-20 A | 100% | 2011-09-21 | 2012-06-20 | 198d? |  | S1 | 3161.67h | 3161.67h | SMURFs | PCG-27 | Stage 1 | Vodafone | mona.mustapha@vodafone.com | Rel-12 | SP-53 | Alain |  | SMURFs |  |  |
| 1410 | 369.1 | Stage 1 for Service and Media Reachability for Users over Restrictive Firewalls | 198d? | 2011-09-21 A | 2012-06-20 A | 100% | 2011-09-21 | 2012-06-20 | 198d? | finish no earlier than 2012-06-08 | S1 | 1577.67h | 1577.67h | SMURFs-SA1 | PCG-27 | 22.278 | Vodafone | mona.mustapha@vodafone.com | Rel-12 | SP-53 | Alain |  |  |  |  |
| 1411 | 370 | **Advanced IP Interconnection of Services (IPXS) for national interconnect** | 139d? | 2012-03-06 A | 2012-09-12 A | 100% | 2012-03-06 | 2012-09-12 | 139d? |  | S1 | 2208h | 2208h | IPXSNAT | PCG-28 | Stage 1 | KPN | toon.norp@tno.nl | Rel-12 | SP-55 | Alain |  | IPXSNAT |  |  |
| 1412 | 370.1 | Stage 1 for Advanced IP Interconnection of Services (IPXS) for national interconnect | 139d? | 2012-03-06 A | 2012-09-12 A | 100% | 2012-03-06 | 2012-09-12 | 139d? | finish no earlier than 2012-09-12 | S1 | 1096h | 1096h | IPXSNAT-SA1 | PCG-28 | 22.228 CR#0161 | KPN | toon.norp@tno.nl | Rel-12 | SP-55 | Alain |  |  |  |  |
| 1413 | 371 | **Integration of Single Sign-On (SSO) frameworks with 3GPP networks** | 137d? | 2012-03-08 A | 2012-09-12 A | 100% | 2012-03-08 | 2012-09-12 | 137d? |  | S1 | 2184h | 2184h | SSO_Int | PCG-28 | Stage 1 | InterDigital | christopher.wallace@interdigital.com | Rel-12 | SP-55 | Alain |  | SSO_Int |  |  |
| 1414 | 371.1 | Stage 1 for Integration of Single Sign-On (SSO) frameworks with 3GPP networks | 137d? | 2012-03-08 A | 2012-09-12 A | 100% | 2012-03-08 | 2012-09-12 | 137d? | finish no earlier than 2012-09-12 | S1 | 1088h | 1088h | SSO_Int-SA1 | PCG-28 | 22.101 | InterDigital | christopher.wallace@interdigital.com | Rel-12 | SP-55 | Alain |  |  |  |  |
| 1415 | 372 | **Explicit Communication Transfer Blind (ECT Blind) service interactions** | 3d? | 2012-06-18 A | 2012-06-20 A | 100% | 2012-06-18 | 2012-06-20 | 3d? |  | S1 | 48h | 48h | ECTB | PCG-29 | Stage 1 | Orange | philippe.lottin@orange.com | Rel-12 | SP-56 | Alain |  | ECTB |  |  |
| 1416 | 372.1 | Stage 1 for Explicit Communication Transfer Blind (ECT Blind) service interactions | 3d? | 2012-06-18 A | 2012-06-20 A | 100% | 2012-06-18 | 2012-06-20 | 3d? | finish no earlier than 2012-06-20 | S1 | 24h | 24h | ECTB-SA1 | PCG-29 | 22.173 | Orange | philippe.lottin@orange.com | Rel-12 | SP-56 | Alain |  |  |  |  |
| 1417 | 373 | **IMS access via Digital Video Broadcast - Return Channel via Satellite (DVB-RCS2)** | 162d? | 2012-02-02 A | 2012-09-12 A | 100% | 2012-02-02 | 2012-09-12 | 162d? |  | S1 | 2584h | 2584h | IMSSat | PCG-29 | Stage 1 | KPN | toon.norp@tno.nl | Rel-12 | SP-57 | Alain |  | IMSSat |  |  |
| 1418 | 373.1 | Stage 1 for IMS access via DVB-RCS2 | 162d? | 2012-02-02 A | 2012-09-12 A | 100% | 2012-02-02 | 2012-09-12 | 162d? | finish no earlier than 2012-09-12 | S1 | 1288h | 1288h | IMSSat-SA1 | PCG-29 | 22.228 | KPN | toon.norp@tno.nl | Rel-12 | SP-57 | Alain |  |  |  |  |
| 1419 | 374 | **Sequential Flexible Alerting** | 3d? | 2012-12-10 A | 2012-12-12 A | 100% | 2012-12-10 | 2012-12-12 | 3d? |  | S1 | 48h | 48h | SEQ_FA | PCG-30 | Stage 1 | Orange | bruno.tossou@orange-ftgroup.com | Rel-12 | SP-58 | Alain |  | IMSSat |  |  |
| 1420 | 374.1 | Stage 1 for Sequential Flexible Alerting | 3d? | 2012-12-10 A | 2012-12-12 A | 100% | 2012-12-10 | 2012-12-12 | 3d? | finish no earlier than 2012-12-12 | S1 | 24h | 24h | SEQ_FA | PCG-30 | 22.173 | Orange | bruno.tossou@orange-ftgroup.com | Rel-12 | SP-58 | Alain |  |  |  |  |
| 1421 | 375 | **Language and Modality Information for communications** | 63d? | 2012-12-11 A | 2013-03-06 A | 100% | 2012-12-11 | 2013-03-06 | 63d? |  | S1 | 1008h | 1008h | LangInfo | PCG-30 | Stage 1 | Orange | philippe.lottin@orange.com | Rel-12 | SP-58 | Alain |  | LangInfo |  |  |
| 1422 | 375.1 | Stage 1 for Language and Modality Information for communications | 63d? | 2012-12-11 A | 2013-03-06 A | 100% | 2012-12-11 | 2013-03-06 | 63d? | finish no earlier than 2013-03-06 | S1 | 504h | 504h | LangInfo-SA1 | PCG-30 | 22.228 | Orange | philippe.lottin@orange.com | Rel-12 | SP-58 | Alain |  |  |  |  |
| 1423 | 376 | **Emergency Session Identification** | 3d? | 2013-03-04 A | 2013-03-06 A | 100% | 2013-03-04 | 2013-03-06 | 3d? |  | S1 | 48h | 48h | ESID | PCG-30 | Stage 1 | Telecom Italia | carmen.catalano@telecomitalia.it | Rel-12 | SP-59 | Alain |  | ESID |  |  |
| 1424 | 376.1 | Stage 1 for Emergency Session Identification | 3d? | 2013-03-04 A | 2013-03-06 A | 100% | 2013-03-04 | 2013-03-06 | 3d? | finish no earlier than 2013-03-06 | S1 | 24h | 24h | ESID-SA1 | PCG-30 | 22.101 | Telecom Italia | carmen.catalano@telecomitalia.it | Rel-12 | SP-59 | Alain |  |  |  |  |

Notes:
- 1401: SP#57 moved to Rel-12 (Reason: Stage 2 for requirements in TS 22.101 clause 4.3.5 have not been implemented in Rel-11). Linked to Rel-10 Local IP Access and Selected Internet IP Traffic Offload (LIPA_SIPTO)
- 1402: SP#57 moved to Rel-12. SP#53 completed
- 1403: SP#58 Stage 2 stopped (TR only, no normative work done)
- 1404: SP#53 completed
- 1405: SP#62 completed. TR 23.862v200 for Approval. SP#58 frozen as v100.
- 1406: SP#58 stopped (no normative work done)
- 1407: Triggered by Rel-11 TR 22.894 (FS_INIPUI)
- 1408: SP#56 re-completed. Updated WID SP-110381=>SP-120425 (Re-opened & moved to Rel-12 by adding new reqs & removing reqs from Rel-11). SP#53 Rel-11 Stage 1 completed
- 1409: SP#56 Stage 1 completed
- 1410: SP#56 completed
- 1411: SP#57 Stage 1 completed. Linked to Rel-11 Feature Advanced IP Interconnection of Services (IPXS) UID_470051.
- 1412: SP#57 completed
- 1413: SP#57 Stage 1 completed. Triggered by Rel-12 TR 22.895. Linked to SA3 33.8xy (Study on Security aspects of SSO_Int), 33.914 (SSO application security for common IMS based on SIP Digest), 33.924 (i/w GBA and OpenID), 33.980 (i/w GBA and Liberty Alliance)
- 1414: SP#57 completed
- 1415: SP#56 WID approved & Stage 1 completed
- 1416: SP#56 new WID approved & work completed. Clarify the service interactions between ECT Blind and other MMTEL Supplementary Services
- 1417: SP#57 Stage 1 completed. Integrate Satcom access with IMS. Specify DVB-RCS2 as an IP Connectivity Access Network for IMS
- 1418: SP#57 completed. Definition of DVB-RCS2 as a non-3GPP IP Connectivity Access Network for IMS
- 1419: SP#58 approved WID & Stage 1 completed. Currently Flexible Alerting (FA) group members are simultaneously alerted by the incoming call. Add the possibility to alert FA group members sequentially. 22/01: acronym modified
- 1420: SP#58 approved WID & Stage 1 completed
- 1421: SP#59 Stage 1 completed. Triggered by Rel-11 Study on Non Voice Emergency Services (FS_NOVES) TR 22.871 use case 10
- 1422: SP#59 completed. Updated WID SP-120937=>SP-130108
- 1423: SP#59 Stage 1 completed.
- 1424: SP#59 completed (22.101 CR#0445)

| ID | WBS | Task | Duration | Start | Finish | Complete | Baseline start | Baseline finish | Baseline duration | Constraint | Resources | Work | Actual work | Acronym | PCG approved | WI rapporteur name | WI rapporteur e-mail | Release | TSG approved | MCC resp | PCG stopped | TSG stopped | Acronym_3GU_Export | Special Focus Doc | Status Report |
| --- | --- | --- | --- | --- | --- | --- | --- | --- | --- | --- | --- | --- | --- | --- | --- | --- | --- | --- | --- | --- | --- | --- | --- | --- | --- |
| 1425 | 377 | **Deleted - Application and Service Access Control** | 77d? | 2013-03-06 A | 2013-06-19 A | 100% | 2013-03-06 | 2013-06-19 | 77d? |  | S1 | 1224h | 1224h | ASAC | PCG-30 | NTT DOCOMO | Atsushi Minokuchi (minokuchi@nttdocomo.co.jp) | Rel-12 | SP-59 | Alain | PCG-31 | SP-60 | ASAC |  |  |
| 1426 | 377.1 | Deleted - Stage 1 for Application and Service Access Control | 77d? | 2013-03-06 A | 2013-06-19 A | 100% | 2013-03-06 | 2013-06-19 | 77d? | finish no earlier than 2013-06-19 | S1 | 608h | 608h | ASAC-SA1del | PCG-30 | NTT DOCOMO | Atsushi Minokuchi (minokuchi@nttdocomo.co.jp) | Rel-12 | SP-59 | Alain | PCG-31 | SP-60 |  |  |  |
| 1427 | 378 | **Prevention of Mobile-Originating signalling and/or data traffic of UE in Connected mode** | 3d? | 2013-03-04 A | 2013-03-06 A | 100% | 2013-03-04 | 2013-03-06 | 3d? |  | S1 | 48h | 48h | PMOC | PCG-30 | NTT DOCOMO | Atsushi Minokuchi (minokuchi@nttdocomo.co.jp) | Rel-12 | SP-59 | Alain |  |  | PMOC |  |  |
| 1428 | 378.1 | Stage 1 for Prevention of Mobile-Originating signalling and/or data traffic of UE in Connected mode | 3d? | 2013-03-04 A | 2013-03-06 A | 100% | 2013-03-04 | 2013-03-06 | 3d? | finish no earlier than 2013-03-06 | S1 | 24h | 24h | PMOC-SA1 | PCG-30 | NTT DOCOMO | Atsushi Minokuchi (minokuchi@nttdocomo.co.jp) | Rel-12 | SP-59 | Alain |  |  |  |  |  |
| 1429 | 379 | SA1/SA2 Features | 216d? | 2013-05-17 A | 2014-03-07 A | 100% | 2013-05-17 | 2014-03-07 | 216d? | finish no earlier than 2014-03-07 | SP; CP; RP | 5184h | 5184h |  | PCG-30 |  |  | Rel-12 | SP-58 |  |  |  |  |  |  |
| 1430 | 380 | **LIPA Mobility and SIPTO at the Local Network** | 898d? | 2010-10-15 A | 2014-03-06 A | 100% | 2010-10-15 | 2014-03-06 | 898d? |  | S2; C4; C1; R3 | 87994h | 87994h | LIMONET | PCG-26 | Huawei | zhufenqin@huawei.com | Rel-12 | SP-50 | Maurice |  |  | LIMONET | HNB |  |
| 1431 | 380.1 | TR on Stage 2 for LIPA Mobility and SIPTO at the Local Network | 580.85d? | 2010-10-15 A | 2013-03-06 A | 100% | 2010-10-15 | 2013-03-06 | 580.85d? | finish no earlier than 2013-03-06 | S2 | 4646.8h | 4646.8h | LIMONET-SA3 | PCG-26 | Huawei | zhufenqin@huawei.com | Rel-12 | SP-50 | Maurice |  |  |  | HNB |  |
| 1432 | 380.2 | **BB1: SIPTO at the Local Network** | 892d? | 2010-10-22 A | 2014-03-05 A | 100% | 2010-10-22 | 2014-03-05 | 892d? |  | S2 | 31685.6h | 31685.6h | LIMONET-SIPTO | PCG-26 | Huawei | zhufenqin@huawei.com | Rel-12 | SP-50 | Maurice |  |  | LIMONET-SIPTO | HNB |  |
| 1433 | 380.2.1 | Stage 2 for SIPTO at the Local Network | 655.85d? | 2010-10-22 A | 2013-06-19 A | 100% | 2010-10-22 | 2013-06-19 | 655.85d? | finish no earlier than 2013-06-19 | S2 | 5246.8h | 5246.8h | LIMONET-SIPTO-SA2 | PCG-26 | Huawei | zhufenqin@huawei.com | Rel-12 | SP-50 | Maurice |  |  |  | HNB |  |
| 1434 | 380.2.2 | **Stage 3 CN aspects of SIPTO at the Local Network** | 649d? | 2011-09-24 A | 2014-03-05 A | 100% | 2011-09-24 | 2014-03-05 | 649d? |  | C4; C1 | 19680h | 19680h | LIMONET-SIPTO | PCG-27 | Huawei | peter.schmitt@huawei.com | Rel-12 | CP-53 | Kimmo |  |  |  | HNB |  |
| 1435 | 380.2.2.1 | CT4 part of Stage 3 CN aspects of SIPTO at the Local Network | 518d? | 2011-09-24 A | 2013-09-06 A | 100% | 2011-09-24 | 2013-09-06 | 518d? | finish no earlier than 2013-09-06 | C4 | 4136h | 4136h | LIMONET-SIPTO-CT4 | PCG-27 | Huawei | peter.schmitt@huawei.com | Rel-12 | CP-53 | Kimmo |  |  |  | HNB |  |
| 1436 | 380.2.2.2 | CT1 part of Stage 3 CN aspects of SIPTO at the Local Network | 646d? | 2011-09-24 A | 2014-03-05 A | 100% | 2011-09-24 | 2014-03-05 | 646d? | finish no earlier than 2014-01-29 | C1 | 5160h | 5160h | LIMONET-SIPTO-CT1 | PCG-27 | Huawei | peter.schmitt@huawei.com | Rel-12 | CP-53 | Frederic |  |  |  | HNB |  |
| 1437 | 380.3 | **RAN aspects for SIPTO at the Local Network** | 269d? | 2013-03-04 A | 2014-03-06 A | 100% | 2013-03-04 | 2014-03-06 | 269d? |  | R3 | 4272h | 4272h | LIMONET-RAN | PCG-30 | Huawei | zheng.zhou@huawei.com | Rel-12 | RP-59 | Juha |  |  | LIMONET-RAN | HNB |  |
| 1438 | 380.3.1 | Core part: RAN aspects for SIPTO at the Local Network | 266d? | 2013-03-04 A | 2014-03-06 A | 100% | 2013-03-04 | 2014-03-06 | 266d? | finish no earlier than 2014-03-06 | R3 | 2120h | 2120h | LIMONET-RAN-Core | PCG-30 | Huawei | zheng.zhou@huawei.com | Rel-12 | RP-59 | Juha |  |  | LIMONET-RAN-Core | HNB | RP-131512 |
| 1439 | 380.4 | **Deleted - BB2: Stand-alone L-GW and associated Mobility for LIPA and SIPTO at the Local Network** | 566d? | 2010-10-22 A | 2012-12-12 A | 100% | 2010-10-22 | 2012-12-12 | 566d? |  | S2 | 18653.6h | 18653.6h | LIMONET-LIPA | PCG-26 | Huawei | zhufenqin@huawei.com | Rel-12 | SP-50 | Maurice | PCG-30 | SP-58 | LIMONET-LIPA | HNB |  |
| 1440 | 380.4.1 | Deleted - Stage 2 for stand-alone L-GW and associated Mobility for LIPA and SIPTO at the Local Network | 519.85d? | 2010-10-22 A | 2012-12-12 A | 100% | 2010-10-22 | 2012-12-12 | 519.85d? | finish no earlier than 2012-12-12 | S2 | 4158.8h | 4158.8h | LIMONET-LIPA-del1 | PCG-26 | Huawei | zhufenqin@huawei.com | Rel-12 | SP-50 | Maurice | PCG-30 | SP-58 |  | HNB |  |
| 1441 | 380.4.2 | **Deleted - Stage 3 CN aspects of LIPA Mobility** | 323d? | 2011-09-24 A | 2012-12-12 A | 100% | 2011-09-24 | 2012-12-12 | 323d? |  | C1; C4 | 10336h | 10336h | LIMONET-LIPA-del2 | PCG-27 | Huawei | christian.herrero@huawei.com | Rel-12 | CP-53 | Frederic | PCG-30 | SP-58 |  | HNB |  |
| 1442 | 380.4.2.1 | Deleted - CT1 part of CN aspects of LIPA Mobility | 323d? | 2011-09-24 A | 2012-12-12 A | 100% | 2011-09-24 | 2012-12-12 | 323d? | finish no earlier than 2012-12-12 | C1 | 2584h | 2584h | LIMONET-LIPA-del3 | PCG-27 | Huawei | christian.herrero@huawei.com | Rel-12 | CP-53 | Frederic | PCG-30 | SP-58 |  | HNB |  |
| 1443 | 380.4.2.2 | Deleted - CT4 part of CN aspects of LIPA Mobility | 323d? | 2011-09-24 A | 2012-12-12 A | 100% | 2011-09-24 | 2012-12-12 | 323d? | finish no earlier than 2012-12-12 | C4 | 2584h | 2584h | LIMONET-LIPA-del4 | PCG-27 | Huawei | christian.herrero@huawei.com | Rel-12 | CP-53 | Kimmo | PCG-30 | SP-58 |  | HNB |  |
| 1444 | 381 | **Operator Policies for IP Interface Selection** | 720d? | 2011-03-23 A | 2013-12-06 A | 100% | 2011-03-23 | 2013-12-06 | 720d? |  | S2; C1 | 20256h | 20256h | OPIIS | PCG-26 | LG Electronics | taehyeon.kim@lge.com | Rel-12 | SP-51 | Maurice |  |  | OPIIS |  |  |
| 1445 | 381.1 | TR on Stage 2 for Operator Policies for IP Interface Selection | 457d? | 2011-03-23 A | 2012-12-12 A | 100% | 2011-03-23 | 2012-12-12 | 457d? | finish no earlier than 2012-12-12 | S2 | 3640h | 3640h | OPIIS | PCG-26 | LG Electronics | taehyeon.kim@lge.com | Rel-12 | SP-51 | Maurice |  |  |  |  |  |
| 1446 | 381.2 | Stage 2 for Operator Policies for IP Interface Selection | 511d? | 2011-04-04 A | 2013-03-06 A | 100% | 2011-04-04 | 2013-03-06 | 511d? | finish no earlier than 2013-03-06 | S2 | 4088h | 4088h | OPIIS | PCG-26 | LG Electronics | taehyeon.kim@lge.com | Rel-12 | SP-51 | Maurice |  |  |  |  |  |
| 1447 | 381.3 | Stage 3 for Operator Policies for IP Interface Selection | 126d? | 2013-06-14 A | 2013-12-06 A | 100% | 2013-06-14 | 2013-12-06 | 126d? | finish no earlier than 2013-12-06 | C1 | 1008h | 1008h | OPIIS-CT | PCG-31 | LG Electronics | Jaehyun Kim (jaehyun7.kim@lge.com) | Rel-12 | CP-60 | Frederic |  |  | OPIIS-CT |  |  |
| 1448 | 382 | **Short Message Service (SMS) submit and delivery without MSISDN in IMS** | 665d? | 2011-06-08 A | 2013-12-06 A | 100% | 2011-06-08 | 2013-12-06 | 665d? |  | S2; C1; C4 | 28336.3h | 28336.3h | SMSMI | PCG-27 | Nokia Siemens Networks | curt.wong@nsn.com | Rel-12 | SP-52 | Maurice |  |  | SMSMI |  |  |
| 1449 | 382.1 | TR on Stage 2 for SMS submit and delivery without MSISDN in IMS | 402d? | 2011-06-08 A | 2012-12-12 A | 100% | 2011-06-08 | 2012-12-12 | 402d? | finish no earlier than 2012-12-12 | S2 | 3192.32h | 3192.32h | SMSMI-SA2TR | PCG-27 | Nokia Siemens Networks | curt.wong@nsn.com | Rel-12 | SP-52 | Maurice |  |  |  |  |  |
| 1450 | 382.2 | Stage 2 for SMS submit and delivery without MSISDN in IMS | 400d? | 2011-06-13 A | 2012-12-12 A | 100% | 2011-06-13 | 2012-12-12 | 400d? | finish no earlier than 2012-12-12 | S2 | 3192h | 3192h | SMSMI-SA2 | PCG-27 | Nokia Siemens Networks | curt.wong@nsn.com | Rel-12 | SP-52 | Maurice |  |  |  |  |  |

Notes:
- 1425: SP#60 stopped and Rel-13 FS_ACDC continues. Triggered by TR 22.806 Study on Application specific Congestion control for Data Communication (FS_ACDC) UID_570034 / Impacted TSs and TRs: Stage 1
- 1426: SP#60 stopped and Rel-13 FS_ACDC contd. Allow/prohibit for E-UTRAN idle mode UE initiation of particular applications defined by operator and subject to regional regulations. Prevent/mitigate overload of AN/CN defined by operator (congestion or disaster) / Impacted TSs and TRs: 22.011
- 1427: SP#59 Stage 1 completed / Impacted TSs and TRs: Stage 1
- 1428: SP#59 completed / Impacted TSs and TRs: 22.011
- 1429: -
- 1430: CP#63 completed. SP#58 updated WID SP-120256=>SP-120926 (stopped BB2 LIMONET-LIPA on Mobility). Linked to UID_450035 Local IP Access and Selected IP Traffic Offload (LIPA_SIPTO) / Impacted TSs and TRs: Stage 2/3
- 1431: SP#59 completed. TR 23.859 v100 for Information and Approval / Impacted TSs and TRs: new TR 23.859
- 1432: SP#60 completed / Impacted TSs and TRs: 23.060, 23.401
- 1433: SP#60 completed / Impacted TSs and TRs: 23.060, 23.401
- 1434: CP#63 completed / Impacted TSs and TRs: Stage 3
- 1435: CP#61 completed / Impacted TSs and TRs: 23.003, 23.008, 29.002, 29.060, 29.230, 29.272, 29.274, 29.303
- 1436: CP#63 completed / Impacted TSs and TRs: 24.008, 24.301
- 1437: - / Impacted TSs and TRs: UTRA, LTE
- 1438: RP#62 completed / Impacted TSs and TRs: 25.401, 25.413, 25.423, 25.467, 25.469, 36.300, 36.413, 36.423
- 1439: SP#58 updated WID SP-120256=>SP-120926 (stopped BB2 LIMONET-LIPA on Mobility) / Impacted TSs and TRs: 23.060, 23.401
- 1440: SP#58 updated WID SP-120256=>SP-120926 (stopped BB2 LIMONET-LIPA on Mobility) / Impacted TSs and TRs: 23.060, 23.401
- 1441: SP#58 CT Stage 3 part stopped because of SA stopping Stage 2 for BB2 LIMONET-LIPA on Mobility) / Impacted TSs and TRs: Stage 3
- 1442: SP#58 CT Stage 3 part stopped because of SA stopping Stage 2 for BB2 LIMONET-LIPA on Mobility) / Impacted TSs and TRs: 24.008, 24.301
- 1443: SP#58 CT Stage 3 part stopped because of SA stopping Stage 2 for BB2 LIMONET-LIPA on Mobility) / Impacted TSs and TRs: 29.060, 29.274, 29.281, 29.303, 29.002, 29.272, 29.275, 29.282, 29.305
- 1444: Linked to Rel-10 IFOM IP Flow Mobility and seamless WLAN offload (non-seamless WLAN offload aspects) & Rel-11 LIMONET (support traffic offload at local network) / Impacted TSs and TRs: Stage 2/3
- 1445: SP#58 completed / Impacted TSs and TRs: new TR 23.853
- 1446: SP#59 completed (23.402 CR#152: Introduction of Inter-APN Routing Policies) / Impacted TSs and TRs: 23.402
- 1447: CP#62 completed. Specify Inter-APN Routing Policies for selecting an IP interface to route IP flows among a choice of available interfacES in CP-150both 3GPP and non-3GPP accesses / Impacted TSs and TRs: 24.302, 24.312
- 1448: Linked to Rel-7 SMSIP (Support of SMS over generic 3GPP IP access), Rel-11 SIMTC, Rel-12 TR 22.988 SA1 Study on alternatives to E.164 for MTC / Impacted TSs and TRs: Stage 2/3
- 1449: SP#58 completed / Impacted TSs and TRs: new TR 23.863
- 1450: SP#58 completed / Impacted TSs and TRs: 23.204, 23.682

| ID | WBS | Task | Duration | Start | Finish | Complete | Remaining | Baseline start | Baseline finish | Baseline duration | Total slack | Constraint | Resources | Work | Actual work | Acronym | PCG approved | Impacted TSs and TRs | WI rapporteur name | WI rapporteur e-mail | Release | TSG approved | MCC resp | Acronym_3GU_Export | Status Report | Special Focus Doc |
| --- | --- | --- | --- | --- | --- | --- | --- | --- | --- | --- | --- | --- | --- | --- | --- | --- | --- | --- | --- | --- | --- | --- | --- | --- | --- | --- |
| 1451 | 382.3 | **Stage 3 for SMS submit and delivery without MSISDN in IMS** | 205d? | 2013-03-01 A | 2013-12-06 A | 100% |  | 2013-03-01 | 2013-12-06 | 205d? |  |  | C1; C4 | 5992h | 5992h | SMSMI-CT | PCG-30 | Stage 3 | NSN | peter.leis@nsn.com | Rel-12 | CP-59 | Frederic | SMSMI-CT |  |  |
| 1452 | 382.3.1 | CT1 part of Stage 3 for SMS submit and delivery without MSISDN in IMS | 205d? | 2013-03-01 A | 2013-12-06 A | 100% |  | 2013-03-01 | 2013-12-06 | 205d? |  | finish no earlier than 2013-12-06 | C1 | 1608h | 1608h | SMSMI-CT | PCG-30 | 23.040, 24.341 | NSN | peter.leis@nsn.com | Rel-12 | CP-59 | Frederic |  |  |  |
| 1453 | 382.3.2 | CT4 part of Stage 3 for SMS submit and delivery without MSISDN in IMS | 139d? | 2013-03-01 A | 2013-09-06 A | 100% |  | 2013-03-01 | 2013-09-06 | 139d? |  | finish no earlier than 2013-09-06 | C4 | 1104h | 1104h | SMSMI-CT | PCG-30 | 23.008, 29.002, 29.305, 29.328, 29.338 | NSN | peter.leis@nsn.com | Rel-12 | CP-59 | Kimmo |  |  |  |
| 1454 | 383 | **IMS-based Telepresence** | 1247.5d? | 2010-03-22 A | 2014-12-09 | 66% | 430.02d? | 2010-03-19 | 2014-12-05 | 1243.5d? | 875d |  | S1; C1; C3; C4; IETF | 122882h | 38645.9h | IMS_TELEP | PCG-27 | Stage 1/2/3 | Orange | bruno.tossou@orange-ftgroup.com | Rel-12 | SP-53 | Alain | IMS_TELEP |  |  |
| 1455 | 383.1 | Stage 1 for IMS-based Telepresence | 197d? | 2011-09-22 A | 2012-06-20 A | 100% |  | 2011-09-22 | 2012-06-20 | 197d? |  | finish no earlier than 2012-06-08 | S1 | 1569.86h | 1569.86h | IMS_TELEP | PCG-27 | 22.228 | Orange | bruno.tossou@orange-ftgroup.com | Rel-12 | SP-53 | Alain |  |  |  |
| 1456 | 383.2 | **CT part for IMS Telepresence (Stage 2/3)** | 1247.5d? | 2010-03-22 A | 2014-12-09 | 64% | 444.19d? | 2010-03-19 | 2014-12-05 | 1243.5d? | 875d |  | C1; C3; C4; IETF | 87712h | 30772h | IMS_TELEP | PCG-30 | Stage 2/3 | Huawei | Weiwei(Tommy) Yang (tommy@huawei.com) | Rel-12 | CP-58 | Frederic |  |  |  |
| 1457 | 383.2.1 | TR on CT part of IMS Telepresence (Stage 2/3) | 399d? | 2012-12-07 A | 2014-06-13 A | 100% |  | 2012-12-07 | 2014-06-13 | 399d? |  | finish no earlier than 2014-06-13 | C1 | 3184h | 3184h | IMS_TELEP | PCG-30 | New TR 24.803 | Huawei | Weiwei(Tommy) Yang (tommy@huawei.com) | Rel-12 | CP-58 | Frederic |  |  |  |
| 1458 | 383.2.2 | CT1 part of IMS Telepresence (Stage 3) | 526d? | 2012-12-07 A | 2014-12-09 A | 100% |  | 2012-12-07 | 2014-09-12 | 464d? |  | finish no earlier than 2014-12-09 | C1 | 4208h | 4208h | IMS_TELEP | PCG-30 | 24.147, 24.166, 24.229, New TS 24.103 | Huawei | Weiwei(Tommy) Yang (tommy@huawei.com) | Rel-12 | CP-58 | Frederic |  | CP-140616 |  |
| 1459 | 383.2.3 | (IETF) CT1 part of IMS Telepresence (mmusic-sctp-sdp) | 851d? | 2010-03-22 A | 2014-12-09 | 50% | 425.5d? | 2010-03-19 | 2014-12-05 | 849d? | 875d | finish no earlier than 2014-12-09 | C1-IETF | 6808h | 3404h | IMS_TELEP | PCG-33 | draft-ietf-mmusic-sctp-sdp | christer.holmberg@ericsson.com | christer.holmberg@ericsson.com | Rel-12 | CP-64 |  |  |  |  |
| 1460 | 383.2.4 | (IETF) CT1 part of IMS Telepresence (clue-framework ) | 851d? | 2010-03-22 A | 2014-12-09 | 50% | 425.5d? | 2010-03-19 | 2014-12-05 | 849d? | 875d | finish no earlier than 2014-12-09 | C1-IETF | 6808h | 3404h | IMS_TELEP | PCG-33 | draft-ietf-clue-framework | christer.holmberg@ericsson.com | christer.holmberg@ericsson.com | Rel-12 | CP-64 |  |  |  |  |
| 1461 | 383.2.5 | (IETF) CT1 part of IMS Telepresence (clue-datachannel) | 851d? | 2010-03-22 A | 2014-12-09 | 50% | 425.5d? | 2010-03-19 | 2014-12-05 | 849d? | 875d | finish no earlier than 2014-12-09 | C1-IETF | 6808h | 3404h | IMS_TELEP | PCG-33 | draft-ietf-clue-datachannel | christer.holmberg@ericsson.com | christer.holmberg@ericsson.com | Rel-12 | CP-64 |  |  |  |  |
| 1462 | 383.2.6 | (IETF) CT1 part of IMS Telepresence (clue-signaling) | 851d? | 2010-03-22 A | 2014-12-09 | 50% | 425.5d? | 2010-03-19 | 2014-12-05 | 849d? | 875d | finish no earlier than 2014-12-09 | C1-IETF | 6808h | 3404h | IMS_TELEP | PCG-33 | draft-ietf-clue-signaling | christer.holmberg@ericsson.com | christer.holmberg@ericsson.com | Rel-12 | CP-64 |  |  |  |  |
| 1463 | 383.2.7 | (IETF) CT1 part of IMS Telepresence (clue-data-model-schema) | 851d? | 2010-03-22 A | 2014-12-09 | 50% | 425.5d? | 2010-03-19 | 2014-12-05 | 849d? | 875d | finish no earlier than 2014-12-09 | C1-IETF | 6808h | 3404h | IMS_TELEP | PCG-33 | draft-ietf-clue-data-model-schema | christer.holmberg@ericsson.com | christer.holmberg@ericsson.com | Rel-12 | CP-64 |  |  |  |  |
| 1464 | 383.2.8 | CT3 part of IMS Telepresence (Stage 3) | 467d? | 2012-12-07 A | 2014-09-11 A | 100% |  | 2012-12-07 | 2014-09-12 | 467d? |  | finish no earlier than 2014-09-12 | C3 | 3736h | 3736h | IMS_TELEP | PCG-30 | 29.165 | Huawei | Weiwei(Tommy) Yang (tommy@huawei.com) | Rel-12 | CP-58 | Adrian |  |  |  |
| 1465 | 383.2.9 | CT4 part of IMS Telepresence (Stage 2/3) | 328d? | 2013-09-13 A | 2014-12-09 A | 100% |  | 2013-09-10 | 2014-09-12 | 266d? |  | finish no earlier than 2014-12-09 | C4 | 2624h | 2624h | IMS_TELEP | PCG-31 | 23.333, 29.333 | Huawei | Weiwei(Tommy) Yang (tommy@huawei.com) | Rel-12 | CP-61 | Kimmo |  | CP-140477 |  |
| 1466 | 384 | **Group Communication System Enablers for LTE** | 727d? | 2012-06-18 A | 2015-03-15 | 99% | 0d? | 2012-06-18 | 2014-09-17 | 597d? | 0d |  | S1; S2; S3; C3; C4; R3; C1 | 59744h | 58696h | GCSE_LTE | PCG-29 | Stage 1/2/3 | Nokia Networks | Juergen.Merkel@nsn.com | Rel-12 | SP-56 | Alain | GCSE_LTE |  | Public Safety (A-A) |
| 1467 | 384.1 | Stage 1 for Group Communication System Enablers for LTE | 267d? | 2012-06-18 A | 2013-06-19 A | 100% |  | 2012-06-18 | 2013-06-19 | 267d? |  | finish no earlier than 2013-06-19 | S1 | 2128h | 2128h | GCSE_LTE | PCG-29 | New TS 22.468 | Nokia Networks | Juergen.Merkel@nsn.com | Rel-12 | SP-56 | Alain |  |  | Public Safety (A-A) |
| 1468 | 384.2 | TR on Architecture enhancements to support Group Communication System Enablers for LTE | 267d? | 2013-03-07 A | 2014-03-07 A | 100% |  | 2013-03-07 | 2014-03-07 | 267d? |  | finish no earlier than 2014-03-07 | S2 | 2128h | 2128h | GCSE_LTE | PCG-30 | New TR 23.768 | Nokia Networks | rainer.liebhart@nsn.com | Rel-12 | SP-59 | Maurice |  |  | Public Safety (A-A) |
| 1469 | 384.3 | Stage 2 for Group Communication System Enablers for LTE | 402d? | 2013-03-12 A | 2014-09-16 A | 100% |  | 2013-03-12 | 2014-09-17 | 402d? |  | finish no earlier than 2014-09-17 | S2 | 3208h | 3208h | GCSE_LTE | PCG-30 | New TS 23.468 | Nokia Networks | rainer.liebhart@nsn.com | Rel-12 | SP-59 | Maurice |  |  | Public Safety (A-A) |
| 1470 | 384.4 | TR on Security for Group Communication System Enablers for LTE (Stage 2) | 201d? | 2013-09-12 A | 2014-06-18 A | 100% |  | 2013-09-12 | 2014-06-18 | 201d? |  | finish no earlier than 2014-06-18 | S3 | 1608h | 1608h | GCSE_LTE | PCG-31 | New TR 33.888 | Nokia Networks | anja.jerichow@nsn.com | Rel-12 | SP-61 | Mirko |  |  | Public Safety (A-A) |
| 1471 | 384.5 | Security for Group Communication System Enablers for LTE (Stage 2) | 201d? | 2013-09-13 A | 2014-06-18 A | 100% |  | 2013-09-13 | 2014-06-18 | 201d? |  | finish no earlier than 2014-06-18 | S3 | 1608h | 1608h | GCSE_LTE | PCG-31 | 33.246 | Nokia Networks | anja.jerichow@nsn.com | Rel-12 | SP-61 | Mirko |  |  | Public Safety (A-A) |
| 1472 | 384.6 | **CT aspects of Group Communication System Enablers for LTE** | 131d? | 2014-06-13 A | 2014-12-09 | 100% | 0d? | 2014-06-13 | 2014-09-12 | 66d? | 0d |  | C3; C4; C1 | 5200h | 4152h | GCSE_LTE-CT | PCG-33 | Stage 3 | Nokia Networks | thomas.belling@nsn.com | Rel-12 | CP-64 |  | GCSE_LTE-CT |  | Public Safety (A-A) |
| 1473 | 384.6.1 | CT3 part of Group Communication System Enablers for LTE | 66d? | 2014-06-13 A | 2014-09-11 A | 100% |  | 2014-06-13 | 2014-09-12 | 66d? |  | finish no earlier than 2014-09-12 | C3 | 528h | 528h | GCSE_LTE-CT | PCG-33 | 29.212, 29.213, 29.214, 29.274, New TS 29.468 | Nokia Networks | thomas.belling@nsn.com | Rel-12 | CP-64 |  |  |  | Public Safety (A-A) |
| 1474 | 384.6.2 | CT4 part of Group Communication System Enablers for LTE | 128d? | 2014-06-13 A | 2014-12-09 A | 100% |  | 2014-06-13 | 2014-09-12 | 66d? |  | finish no earlier than 2014-12-09 | C4 | 1024h | 1024h | GCSE_LTE-CT | PCG-33 | 23.007, 23.008 | Nokia Networks | thomas.belling@nsn.com | Rel-12 | CP-64 |  |  | CP-140725 | Public Safety (A-A) |
| 1475 | 384.6.3 | CT1 part of Group Communication System Enablers for LTE | 63d? | 2014-09-12 A | 2014-12-09 A | 100% |  |  |  |  |  | finish no earlier than 2014-12-09 | C1 | 504h | 504h | GCSE_LTE-CT | PCG-33 | 24.301 | Nokia Networks | thomas.belling@nsn.com | Rel-12 | CP-65 |  |  | CP-140614 | Public Safety (A-A) |

Notes:
- 1451: CP#62 completed. Address scenario IMS client to IMS client SMS (comprises SMS receive and send SMS without requiring an MSISDN associated as part of their subscription record in HSS
- 1452: CP#62 completed
- 1453: CP#61 completed
- 1454: This feature does not introduce any changes to the IMS architecture, and no stage 2 impacts are identified
- 1455: SP#56 completed. 2/4/15: acronym changed to IMS_TELEP
- 1456: CP#65 updated WID CP-140196=>CP-140624. 2/4/15: acronym changed to IMS_TELEP
- 1457: CP#64 completed. 2/4/15: acronym changed to IMS_TELEP
- 1458: CP#65 TS 24.103v100 for Information. Updated WID CP-140196=>CP-140624. Completion 09/14=>12/14. Exception in CP-140616. Dec.14: 90->100%. 2/4/15: acronym changed to IMS_TELEP
- 1459: work in progress. 2/4/15: acronym changed to IMS_TELEP
- 1460: work in progress. 2/4/15: acronym changed to IMS_TELEP
- 1461: work in progress. 2/4/15: acronym changed to IMS_TELEP
- 1462: work in progress. 2/4/15: acronym changed to IMS_TELEP
- 1463: work in progress. 2/4/15: acronym changed to IMS_TELEP
- 1464: CP#65 completed. 2/4/15: acronym changed to IMS_TELEP
- 1465: CP#65 updated WID CP-140196=>CP-140624. Completion 09/14=>12/14. Exception in CP-140477. Mar.15: 0->100%. 2/4/15: acronym changed to IMS_TELEP
- 1466: Linked to Rel-12 FS_ProSe TR 22.803 Study on Proximity-based Services. External requirements: NIST, MESA, APCO Global Alliance, TCCA. Specify 3GPP system enablers to support group communication over LTE for Public Safety
- 1467: SP#60 completed. TS 22.468 v100 for 1-step Approval
- 1468: SP#63 completed. TR 23.768v200 for Approval
- 1469: SP#65 completed. Updated WID SP-140113=>SP-140433. SP#63 TS 23.468v100 for 1-step Approval
- 1470: SP#64 completed. TR 33.888v100 for 1-step Approval
- 1471: SP#64 completed
- 1472: CP#65 updated WID CP-140452=>C3-143199 (added CT1 part)
- 1473: CP#65 completed. TS 29.468v200 for Approval
- 1474: CP#65 completion 09/14=>12/14. Exception in CP-140725. Dec.14: 35->100
- 1475: CP#65 updated WID CP-140452=>CP-140559 (added CT1 part). Exception in CP-140614. Dec.14: 90->100%

| ID | WBS | Task | Duration | Start | Finish | Complete | Remaining | Baseline start | Baseline finish | Baseline duration | Total slack | Constraint | Resources | Work | Actual work | Acronym | PCG approved | Impacted TSs and TRs | WI rapporteur name | WI rapporteur e-mail | Release | TSG approved | Special Focus Doc | Acronym_3GU_Export | Status Report | MCC resp | PCG stopped | TSG stopped |
| --- | --- | --- | --- | --- | --- | --- | --- | --- | --- | --- | --- | --- | --- | --- | --- | --- | --- | --- | --- | --- | --- | --- | --- | --- | --- | --- | --- | --- |
| 1476 | 384.7 | **Group Call eMBMS congestion management for LTE** | 198d? | 2014-06-16 A | 2015-03-15 A | 100% |  | 2014-06-13 | 2014-09-12 | 66d? |  |  | R3 | 3152h | 3152h | GCSE_LTE-MBMS_CM | PCG-33 | LTE | Alcatel-Lucent | hakon.helmers@alcatel-lucent.com | Rel-12 | RP-64 | Public Safety (A-A) | GCSE_LTE-MBMS_CM |  |  |  |  |
| 1477 | 384.7.1 | Core part: Group Call eMBMS congestion management for LTE | 196d? | 2014-06-16 A | 2015-03-15 A | 100% |  | 2014-06-13 | 2014-09-12 | 66d? |  | finish no earlier than 2015-03-15 | R3 | 1568h | 1568h | GCSE_LTE-MBMS_CM-Core | PCG-33 | 36.413 | Alcatel-Lucent | hakon.helmers@alcatel-lucent.com | Rel-12 | RP-64 | Public Safety (A-A) | GCSE_LTE-MBMS_CM-Core | RP-150081 |  |  |  |
| 1478 | 385 | **Machine-Type and other mobile data applications Communications enhancements** | 1692d? | 2009-12-10 A | 2016-05-12 | 98% | 40.3d? | 2009-12-10 | 2014-09-12 | 1255d? | 503d |  | S2; S1; S3; C1; C3; C4; C6; R2; R3; G1 | 223392h | 180648h | MTCe | PCG-29 | Stage 1/2/3 | Intel | puneet.jain@intel.com | Rel-12 | SP-56 | MTC, M2M | MTCe |  | Maurice |  |  |
| 1479 | 385.1 | Stage 1 for Support for Interworking with M2M Service Enablement | 189d? | 2012-06-18 A | 2013-03-06 A | 100% |  | 2012-06-18 | 2013-03-06 | 189d? |  | finish no earlier than 2013-03-06 | S1 | 1504h | 1504h | MTCe-SIMSE | PCG-29 | 22.368 | KPN | toon.norp@tno.nl | Rel-12 | SP-56 | MTC, M2M | MTCe-SIMSE |  | Alain |  |  |
| 1480 | 385.2 | Stage 1 for Machine-Type and other mobile data applications Communications – Service Requirement Maintenance | 127d? | 2012-09-13 A | 2013-03-06 A | 100% |  | 2012-09-13 | 2013-03-06 | 127d? |  | finish no earlier than 2013-03-06 | S1 | 1008h | 1008h | MTCe-SRM | PCG-29 | 22.101, 22.368 | KPN | toon.norp@tno.nl | Rel-12 | SP-57 | MTC, M2M | MTCe-SRM |  | Alain |  |  |
| 1481 | 385.3 | TR on Security aspects of Machine-Type Communications | 1113d? | 2009-12-10 A | 2014-03-07 A | 100% |  | 2009-12-10 | 2014-03-07 | 1113d? |  | finish no earlier than 2014-03-07 | S3 | 8896h | 8896h | MTCe-SA3TR | PCG-29 | New TR 33.868 | Samsung | Rajavelsamy R (rajvel@samsung.com) | Rel-12 | SP-56 | MTC, M2M |  |  | Mirko |  |  |
| 1482 | 385.4 | Security and Privacy aspects for Machine-Type and other mobile data applications Communications enhancements (Stage 2) | 452d? | 2012-06-22 A | 2014-03-07 A | 100% |  | 2012-06-22 | 2014-03-07 | 452d? |  | finish no earlier than 2014-03-07 | S3 | 3608h | 3608h | MTCe-SA3 | PCG-29 | New TS 33.187 | Samsung | Rajavelsamy R (rajvel@samsung.com) | Rel-12 | SP-56 | MTC, M2M |  |  | Mirko |  |  |
| 1483 | 385.5 | **BB1: Small Data and Device Triggering Enhancements (SDDTE)** | 594d? | 2012-06-18 A | 2014-09-11 A | 100% |  | 2012-06-18 | 2014-09-12 | 594d? |  |  | S2; C4; C3 | 24400h | 24400h | MTCe-SDDTE | PCG-29 |  | Intel | puneet.jain@intel.com | Rel-12 | SP-56 | MTC, M2M | MTCe-SDDTE |  | Maurice |  |  |
| 1484 | 385.5.1 | TR on Stage 2 BB1: Small Data and Device Triggering Enhancements | 394d? | 2012-06-18 A | 2013-12-11 A | 100% |  | 2012-06-18 | 2013-12-11 | 394d? |  | finish no earlier than 2013-12-11 | S2 | 3128h | 3128h | MTCe-SDDTE | PCG-29 | New TR 23.887 | Intel | puneet.jain@intel.com | Rel-12 | SP-56 | MTC, M2M |  |  | Maurice |  |  |
| 1485 | 385.5.2 | Stage 2 for BB1: Small Data and Device Triggering Enhancements | 390d? | 2012-06-26 A | 2013-12-11 A | 100% |  | 2012-06-26 | 2013-12-11 | 390d? |  | finish no earlier than 2013-12-11 | S2 | 3120h | 3120h | MTCe-SDDTE | PCG-29 | 23.682 | Intel | puneet.jain@intel.com | Rel-12 | SP-56 | MTC, M2M |  |  | Maurice |  |  |
| 1486 | 385.5.3 | **Stage 3 for BB1: Small Data and Device Triggering Enhancements** | 138d? | 2014-03-05 A | 2014-09-11 A | 100% |  | 2014-03-05 | 2014-09-12 | 138d? |  |  | C4; C3 | 3896h | 3896h | MTCe-SDDTE-CT | PCG-32 | Stage 3 | Huawei | peter.schmitt@huawei.com | Rel-12 | CP-63 | MTC, M2M | MTCe-SDDTE-CT |  | Kimmo |  |  |
| 1487 | 385.5.3.1 | CT4 part of Stage 3 for BB1: Small Data and Device Triggering Enhancement | 138d? | 2014-03-05 A | 2014-09-11 A | 100% |  | 2014-03-05 | 2014-09-12 | 138d? |  | finish no earlier than 2014-09-12 | C4 | 1104h | 1104h | MTCe-SDDTE-CT | PCG-32 | 29.002, 29.336, 23.008, 29.337, 29.338, 29.230 | Huawei | peter.schmitt@huawei.com | Rel-12 | CP-63 | MTC, M2M |  |  | Kimmo |  |  |
| 1488 | 385.5.3.2 | CT3 part of Stage 3 for BB1: Small Data and Device Triggering Enhancement | 73d? | 2014-03-05 A | 2014-06-13 A | 100% |  | 2014-03-05 | 2014-06-13 | 73d? |  | finish no earlier than 2014-06-13 | C3 | 584h | 584h | MTCe-SDDTE-CT | PCG-32 | 29.368 | Huawei | peter.schmitt@huawei.com | Rel-12 | CP-63 | MTC, M2M |  |  | Adrian |  |  |
| 1489 | 385.6 | Deleted - BB2: Monitoring Enhancements (MONTE) | 131d? | 2012-06-18 A | 2012-12-12 A | 100% |  | 2012-06-18 | 2012-12-12 | 131d? |  | finish no earlier than 2012-12-12 | S2 | 1048h | 1048h | MTCe-MONTE | PCG-29 | 23.682 | Intel | puneet.jain@intel.com | Rel-12 | SP-56 | MTC, M2M | MTCe-MONTE |  | Maurice | PCG-30 | SP-58 |
| 1490 | 385.7 | **BB3: UE Power Consumptions Optimizations (UEPCOP)** | 1031d? | 2012-06-18 A | 2016-05-12 | 93% | 71.29d? | 2012-06-18 | 2014-09-12 | 594d? | 503d |  | S2; C1; C4; C6; G1 | 49221.3h | 36237h | MTCe-UEPCOP | PCG-29 |  | Ericsson | peter.hedman@ericsson.com | Rel-12 | SP-56 | MTC, M2M | MTCe-UEPCOP |  | Maurice |  |  |
| 1491 | 385.7.1 | TR on Stage 2 BB3: UE Power Consumptions Optimizations (UEPCOP) | 394d? | 2012-06-18 A | 2013-12-11 A | 100% |  | 2012-06-18 | 2013-12-11 | 394d? |  | finish no earlier than 2013-12-11 | S2 | 3128h | 3128h | MTCe-UEPCOP | PCG-29 | New TR 23.887 | Ericsson | peter.hedman@ericsson.com | Rel-12 | SP-56 | MTC, M2M |  |  | Maurice |  |  |
| 1492 | 385.7.2 | Stage 2 for BB3: UE Power Consumptions Optimizations (UEPCOP) | 390d? | 2012-06-26 A | 2013-12-11 A | 100% |  | 2012-06-26 | 2013-12-11 | 390d? |  | finish no earlier than 2013-12-11 | S2 | 3120h | 3120h | MTCe-UEPCOP | PCG-29 | 23.060, 23.401, 23.682 | Ericsson | peter.hedman@ericsson.com | Rel-12 | SP-56 | MTC, M2M |  |  | Maurice |  |  |
| 1493 | 385.7.3 | **Stage 3 for BB3: UE Power Consumptions Optimizations (UEPCOP)** | 597d? | 2013-12-06 A | 2016-03-15 | 99% | 0d? | 2013-12-06 | 2014-09-12 | 202d? | 0d |  | C1; C4; C6 | 20696h | 12776h | MTCe-UEPCOP-CT | PCG-32 | Stage 3 | Ericsson | mikael.wass@ericsson.com | Rel-12 | CP-62 | MTC, M2M | MTCe-UEPCOP-CT |  | Frederic |  |  |
| 1494 | 385.7.3.1 | CT1 part of Stage 3 for BB3: UE Power Consumptions Optimizations (UEPCOP) | 202d? | 2013-12-06 A | 2014-09-11 A | 100% |  | 2013-12-06 | 2014-09-12 | 202d? |  | finish no earlier than 2014-09-12 | C1 | 1608h | 1608h | MTCe-UEPCOP-CT1 | PCG-32 | 24.008, 24.301 | Ericsson | mikael.wass@ericsson.com | Rel-12 | CP-62 | MTC, M2M |  |  | Frederic |  |  |
| 1495 | 385.7.3.2 | Deleted - CT4 part of Stage 3 for BB3: UE Power Consumptions Optimizations (UEPCOP) | 201d? | 2013-12-09 A | 2014-09-11 A | 100% |  | 2013-12-09 | 2014-09-12 | 201d? |  | finish no earlier than 2014-09-12 | C4 | 1608h | 1608h | MTCe-UEPCOP-CT4 | PCG-32 | 29.274, 29.060, 23.008 | Ericsson | mikael.wass@ericsson.com | Rel-12 | CP-62 | MTC, M2M |  |  | Kimmo | PCG-33 | CP-65 |
| 1496 | 385.7.3.3 | CT6 part of Stage 3 for BB3: UE Power Consumptions Optimizations (UEPCOP) | 263d? | 2013-12-09 A | 2014-12-09 A | 100% |  | 2013-12-09 | 2014-09-12 | 201d? |  | finish no earlier than 2014-12-09 | C6 | 2104h | 2104h | MTCe-UEPCOP-CT6 | PCG-32 | 31.101, 31.102, 31.111 | Ericsson | mikael.wass@ericsson.com | Rel-12 | CP-62 | MTC, M2M |  | CP-140697 | Xavier |  |  |
| 1497 | 385.7.3.4 | UE Conformance Test Aspects - UE Power Consumptions Optimizations (UEPCOP) | 131d? | 2015-09-15 A | 2016-03-15 A | 100% |  |  |  |  |  | finish no earlier than 2016-03-15 | R5 | 1048h | 1048h | MTCe-UEPCOP-UEConTest | PCG-35 |  | Ericsson |  | Rel-12 | RP-69 |  |  |  |  |  |  |
| 1498 | 385.7.4 | Support of Power Saving Mode in GERAN | 5d? | 2014-08-25 A | 2014-08-29 A | 100% |  |  |  |  |  | finish no earlier than 2014-08-29 | G1 | 40h | 40h | MTCe-UEPCOP-GERAN | PCG-33 | 43.022 | Ericsson | sajal.kumar.das@ericsson.com | Rel-12 | GP-63 |  | MTCe-UEPCOP-GERAN |  |  |  |  |
| 1499 | 385.7.5 | Testing of Support of Power Saving Mode in GERAN | 132d? | 2015-11-11 A | 2016-05-12 | 10% | 118.8d? |  |  |  | 503d | finish no earlier than 2016-05-12 | G3 | 1056h | 105.6h | MTCe-UEPCOP_GERAN3new | PCG-36 |  | Ericsson | sajal.kumar.das@ericsson.com | Rel-12 | SP-70 |  | MTCe-UEPCOP-GERAN |  |  |  |  |
| 1500 | 385.8 | Deleted - BB4: Group based MTC feature (GROUP) | 129d? | 2012-06-20 A | 2012-12-12 A | 100% |  | 2012-06-20 | 2012-12-12 | 129d? |  | finish no earlier than 2012-12-12 | S2 | 1032h | 1032h | MTCe-GROUP | PCG-29 | 23.682 | KPN | Annemieke Kips | Rel-12 | SP-56 | MTC, M2M | MTCe-GROUP |  | Maurice | PCG-30 | SP-58 |

Notes:
- 1476: -
- 1477: CD:Thu 11/12/14->Sun 15/03/15; Compl:25%->80%; Stat Rep: RP-141327->RP-141863 1st Apr 15: Compl:80%->100% 1st Apr 15: Stat Rep: RP-141863->RP-150081
- 1478: -
- 1479: SP#59 completed. Define requirements for interworking with M2M service enablement layer specified by ETSI TC M2M in TS 102 689 ( specification for Service Enablement layer)
- 1480: SP#59 completed. Updated WID SP-120541=>SP-130105
- 1481: SP#63 completed. TR 33.868v100 for 1-step Approval. Was Rel-10 UID_460023 (Security for NIMTC). Was Rel-11 UID_490028 (TR on Security aspects of MTC). SP#56 activity transferred to Rel-12 Feature MTCe
- 1482: SP#63 completed. TS 33.187v100 for 1-step Approval
- 1483: -
- 1484: SP#62 completed. TR 23.887v200 for Approval
- 1485: SP#62 completed
- 1486: CP#65 updated WID CP-140272=>CP-140489
- 1487: CP#65 completed. Updated WID CP-140272=>CP-140489
- 1488: CP#64 completed
- 1489: SP#58 stopped (at 20% completion)
- 1490: -
- 1491: SP#62 completed. TR 23.887v200 for Approval
- 1492: SP#62 completed
- 1493: -
- 1494: CP#65 completed
- 1495: CP#65 stopped (no inpact on CT4)
- 1496: CP#65 completion 09/14=>12/14. Exception in CP-140697; June2015: Compl:90%->100
- 1497: tested: MTCe-UEPCOP was a REL-12 SA2 WI; NAS over LTE and UTRA;1/1/16: Compl:0%->25%22/3/16: C...
- 1498: GP#63 approved WID and completed
- 1499: 7/12/15: created.02/3/16: acronym: MTCe-UEPCOP-GERAN_test->MTCe-UEPCOP_GERAN3new; 2/3/16: 0%->10
- 1500: SP#58 stopped (at 25% completion)

| ID | WBS | Task | Duration | Start | Finish | Complete | Baseline start | Baseline finish | Baseline duration | Constraint | Resources | Work | Actual work | Acronym | PCG approved | Impacted TSs and TRs | WI rapporteur name | WI rapporteur e-mail | Release | TSG approved | MCC resp | Special Focus Doc | Acronym_3GU_Export | Status Report | PCG stopped | TSG stopped |
| --- | --- | --- | --- | --- | --- | --- | --- | --- | --- | --- | --- | --- | --- | --- | --- | --- | --- | --- | --- | --- | --- | --- | --- | --- | --- | --- |
| 1501 | 385.9 | **RAN enhancements for Machine-Type and other mobile data applications Communications** | 161.2d? | 2014-02-03 A | 2014-09-12 A | 100% | 2014-02-03 | 2014-09-12 | 160.2d? |  | R2; R3 | 3651h | 3651h | MTCe-RAN | PCG-32 | UTRA, LTE | ZTE | sergio.parolari@zte.com.cn | Rel-12 | RP-62 | Yong-Jun | MTC, M2M | MTCe-RAN |  |  |  |
| 1502 | 385.9.1 | Core part: RAN enhancements for Machine-Type and other mobile data applications Communications | 133d? | 2014-02-03 A | 2014-09-12 A | 100% | 2014-02-03 | 2014-09-12 | 133d? | finish no earlier than 2014-09-12 | R2; R3 | 2128h | 2128h | MTCe-RAN-Core | PCG-32 | 25.300, 25.304, 25.413, 36.300, 36.304, 36.413, 36.423 | ZTE | sergio.parolari@zte.com.cn | Rel-12 | RP-62 | Yong-Jun | MTC, M2M | MTCe-RAN-Core | RP-141096 |  |  |
| 1503 | 386 | **Policy and Charging Control for supporting fixed broadband access networks** | 660d? | 2012-06-20 A | 2014-12-12 A | 100% | 2012-06-20 | 2014-09-17 | 595d? |  | S2; S1; S5; C3; C1; C4 | 84075.4h | 84075.4h | P4C | PCG-29 | Stage 1/2/3 | Huawei | marco.spini@huawei.com | Rel-12 | SP-56 | Maurice |  | P4C |  |  |  |
| 1504 | 386.1 | Stage 1 for Policy and Charging Support for Fixed Mobile Convergence | 3d? | 2012-09-10 A | 2012-09-12 A | 100% | 2012-09-10 | 2012-09-12 | 3d? | finish no earlier than 2012-09-12 | S1 | 24h | 24h | P4C-FMC | PCG-29 | 22.278 | Huawei | amar.deol@huawei.com | Rel-12 | SP-57 | Alain |  | P4C-FMC |  |  |  |
| 1505 | 386.2 | **BB1: Policy and Charging Control for supporting traffic from fixed terminals and NSWO (Non Seamless WLAN Offload) traffic from 3GPP UEs in fixed broadband access networks (P4C-F)** | 660d? | 2012-06-20 A | 2014-12-12 A | 100% | 2012-06-20 | 2014-09-17 | 595d? |  | S2; S5; C3; C1; C4 | 45657.3h | 45657.3h | P4C-F | PCG-29 |  | Huawei | marco.spini@huawei.com | Rel-12 | SP-56 | Maurice | WLAN | P4C-F |  |  |  |
| 1506 | 386.2.1 | TR on Stage 2 for BB1: Policy and Charging Control for supporting traffic from fixed terminals and NSWO traffic from 3GPP UEs in fixed broadband access networks (P4C-F) | 539.9d? | 2012-06-20 A | 2014-12-12 A | 100% | 2012-06-20 | 2014-09-17 | 476.9d? | finish no earlier than 2014-12-12 | S2 | 4290.1h | 4290.1h | P4C-F-SA2TR | PCG-29 | new TR 23.896 | Huawei | marco.spini@huawei.com | Rel-12 | SP-56 | Maurice | WLAN |  |  |  |  |
| 1507 | 386.2.2 | Stage 2 for BB1: Policy and Charging Control for supporting traffic from fixed terminals and NSWO traffic from 3GPP UEs in fixed broadband access networks (P4C-F) | 272.9d? | 2012-06-20 A | 2013-12-11 A | 100% | 2012-06-20 | 2013-12-11 | 272.9d? | finish no earlier than 2013-12-11 | S2 | 2183.2h | 2183.2h | P4C-F-SA2 | PCG-29 | 23.139, 23.203 | Huawei | marco.spini@huawei.com | Rel-12 | SP-56 | Maurice | WLAN |  |  |  |  |
| 1508 | 386.2.3 | **Stage 3 for BB1: Policy and Charging Control for supporting traffic from fixed terminals and NSWO traffic from 3GPP UEs in fixed broadband access networks** | 203d? | 2013-09-06 A | 2014-06-13 A | 100% | 2013-09-06 | 2014-06-13 | 203d? |  | C3; C1; C4 | 8088h | 8088h | P4C-F-CT3 | PCG-31 | Stage 3 | Huawei | Xia Haitao (xiahaitao@huawei.com) | Rel-12 | CP-61 | Adrian | WLAN | P4C-F-CT3 |  |  |  |
| 1509 | 386.2.3.1 | CT3 part of Stage 3 for BB1: Policy and Charging Control for supporting traffic from fixed terminals and NSWO traffic from 3GPP UEs in fixed broadband access networks | 203d? | 2013-09-06 A | 2014-06-13 A | 100% | 2013-09-06 | 2014-06-13 | 203d? | finish no earlier than 2014-06-13 | C3 | 1608h | 1608h | P4C-F-CT3 | PCG-31 | 29.212, 29.213, 29.215, 29.219 | Huawei | Xia Haitao (xiahaitao@huawei.com) | Rel-12 | CP-61 | Adrian | WLAN |  |  |  |  |
| 1510 | 386.2.3.2 | CT1 part of Stage 3 for BB1: Policy and Charging Control for supporting traffic from fixed terminals and NSWO traffic from 3GPP UEs in fixed broadband access networks | 65d? | 2013-12-06 A | 2014-03-05 A | 100% | 2013-12-06 | 2014-03-05 | 65d? | finish no earlier than 2014-03-05 | C1 | 512h | 512h | P4C-F-CT3 | PCG-32 | 24.302 | Huawei | Xia Haitao (xiahaitao@huawei.com) | Rel-12 | CP-62 | Frederic | WLAN |  |  |  |  |
| 1511 | 386.2.3.3 | CT4 part of Stage 3 for BB1: Policy and Charging Control for supporting traffic from fixed terminals and NSWO traffic from 3GPP UEs in fixed broadband access networks | 137d? | 2013-12-06 A | 2014-06-13 A | 100% | 2013-12-06 | 2014-06-13 | 137d? | finish no earlier than 2014-06-13 | C4 | 1096h | 1096h | P4C-F-CT3 | PCG-32 | 29.273 | Huawei | Xia Haitao (xiahaitao@huawei.com) | Rel-12 | CP-62 | Kimmo | WLAN |  |  |  |  |
| 1512 | 386.2.4 | Policy and Charging Enforcement Function (PCEF) based Charging for traffic from fixed terminals and NSWO traffic from 3GPP UEs in fixed broadband access networks (Stage 2/3) | 326d? | 2013-06-21 A | 2014-09-17 A | 100% | 2013-06-21 | 2014-09-17 | 326d? | finish no earlier than 2014-09-17 | S5 | 2608h | 2608h | P4C-F-CH_P | PCG-31 | Stage 2 (32.240, 32.251), Stage 3 (32.298, 32.299) | Alcatel-Lucent | maryse.gardella@alcatel-lucent.com | Rel-12 | SP-60 | Mirko | WLAN | P4C-F-CH_P |  |  |  |
| 1513 | 386.2.5 | Traffic Detection Function (TDF) based Charging for traffic from fixed terminals and NSWO traffic from 3GPP UEs in fixed broadband access networks (Stage 2/3) | 261d? | 2013-06-24 A | 2014-06-18 A | 100% | 2013-06-24 | 2014-06-18 | 261d? | finish no earlier than 2014-06-18 | S5 | 2088h | 2088h | P4C-F-CH_T | PCG-31 | Stage 2 (32.240, 32.251), Stage 3 (32.298, 32.299) | Openet Telecom | alan.mcnamee@openet.com | Rel-12 | SP-60 | Mirko | WLAN | P4C-F-CH_T |  |  |  |
| 1514 | 386.3 | **BB2: Policy and Charging Control for 3GPP UEs connected to BroadBand Forum access network as Trusted network in Interworking scenario (P4C-TI)** | 266d? | 2012-06-20 A | 2013-06-19 A | 100% | 2012-06-20 | 2013-06-19 | 266d? |  | S2 | 2610.07h | 2610.07h | P4C-TI | PCG-29 |  | Alcatel-Lucent | konstantin.livanos@alcatel-lucent.com | Rel-12 | SP-56 | Maurice |  | P4C-TI |  |  |  |
| 1515 | 386.3.1 | TR on Stage 2 for BB2: Policy and Charging Control for 3GPP UEs connected to BroadBand Forum access network as Trusted network in Interworking scenario (P4C-TI) | 109.2d? | 2012-06-20 A | 2013-06-19 A | 100% | 2012-06-20 | 2013-06-19 | 109.2d? | finish no earlier than 2013-06-06 | S2 | 862.87h | 862.87h | P4C-TI-SA2TR | PCG-29 | new TR 23.839 | Alcatel-Lucent | konstantin.livanos@alcatel-lucent.com | Rel-12 | SP-56 | Maurice |  |  |  |  |  |
| 1516 | 386.3.2 | Stage 2 for BB2: Policy and Charging Control for 3GPP UEs connected to BroadBand Forum access network as Trusted network in Interworking scenario (P4C-TI) | 109.2d? | 2012-06-20 A | 2013-06-19 A | 100% | 2012-06-20 | 2013-06-19 | 109.2d? | finish no earlier than 2013-06-19 | S2 | 873.6h | 873.6h | P4C-TI-SA2 | PCG-29 | 23.139, 23.203 | Alcatel-Lucent | konstantin.livanos@alcatel-lucent.com | Rel-12 | SP-56 | Maurice |  |  |  |  |  |
| 1517 | 386.4 | Deleted - BB3: Policy and Charging Control for 3GPP UEs connected to fixed broadband access network via S2b and S2c reference points for EPC routed traffic (P4C-S2bc) | 128d? | 2012-06-21 A | 2012-12-12 A | 100% | 2012-06-21 | 2012-12-12 | 128d? | finish no earlier than 2012-12-12 | S2 | 1024h | 1024h | P4C-S2bc | PCG-29 | 23.139, 23.203, new TR 23.896 | ZTE | Tricci So (tso@zteusa.com) | Rel-12 | SP-56 | Maurice |  | P4C-S2bc |  | PCG-30 | SP-58 |
| 1518 | 386.5 | Deleted - BB4: Policy and Charging Control for EPC routed traffic over fixed broadband access networks of 3GPP UEs connected via H(e)NB in convergent scenarios (P4C-HeNB) | 128d? | 2012-06-21 A | 2012-12-12 A | 100% | 2012-06-21 | 2012-12-12 | 128d? | finish no earlier than 2012-12-12 | S2 | 1024h | 1024h | P4C-HeNB | PCG-29 | 23.139, 23.203, new TR 23.896 | NEC | Stefan.Schmid@neclab.eu | Rel-12 | SP-56 | Maurice |  | P4C-HeNB |  | PCG-30 | SP-58 |
| 1519 | 386.6 | Deleted - BB5: Policy and Charging Control for supporting Layer 2 traffic in fixed broadband access network (P4C-FL2) | 128d? | 2012-06-21 A | 2012-12-12 A | 100% | 2012-06-21 | 2012-12-12 | 128d? | finish no earlier than 2012-12-12 | S2 | 1024h | 1024h | P4C-FL2 | PCG-29 | 23.139, 23.203, new TR 23.896 | Huawei | marco.spini@huawei.com | Rel-12 | SP-56 | Maurice |  | P4C-FL2 |  | PCG-30 | SP-58 |
| 1520 | 386.7 | Deleted - BB6: Policy and Charging Control for 3GPP UEs connected to fixed broadband access networks via S2a reference point for EPC routed traffic in convergence (P4C-TC) | 129d? | 2012-06-20 A | 2012-12-12 A | 100% | 2012-06-20 | 2012-12-12 | 129d? | finish no earlier than 2012-12-12 | S2 | 1032h | 1032h | P4C-TC | PCG-29 | 23.139, 23.203, new TR 23.896 | ZTE | Tricci So (tso@zteusa.com) | Rel-12 | SP-56 | Maurice |  | P4C-TC |  | PCG-30 | SP-58 |
| 1521 | 387 | **IMS Business Trunking for IP-PBX in Static Mode of Operation** | 847.1d? | 2011-09-28 A | 2014-12-09 A | 100% | 2011-09-28 | 2014-09-12 | 782.1d? |  | S2; S1; C1; C3 | 43555.2h | 43555.2h | BusTI | PCG-29 | Stage 1/2/3 | Deutsche Telekom | michele.zarri@telekom.com | Rel-12 | SP-56 | Maurice |  | BusTI |  |  |  |
| 1522 | 387.1 | Stage 1 for IMS Business Trunking for IP-PBX in Static Mode of Operation | 64d? | 2011-09-28 A | 2012-09-12 A | 100% | 2011-09-28 | 2012-09-12 | 64d? | finish no earlier than 2012-08-30 | S1 | 504h | 504h | BusTI-SA1 | PCG-29 | 22.228 | Deutsche Telekom | kurt.bischinger@t-mobile.at | Rel-12 | SP-56 | Alain |  |  |  |  |  |
| 1523 | 387.2 | TR on IMS Business Trunking for IP-PBX in Static Mode of Operation | 268d? | 2012-06-18 A | 2013-06-19 A | 100% | 2012-06-18 | 2013-06-19 | 268d? | finish no earlier than 2013-06-19 | S2; S1 | 4288h | 4288h | BusTI-SATR | PCG-29 | new TR 23.897 | Deutsche Telekom | michele.zarri@telekom.com | Rel-12 | SP-56 | Maurice |  |  |  |  |  |
| 1524 | 387.3 | Stage 2 for IMS Business Trunking for IP-PBX in Static Mode of Operation | 263d? | 2012-06-25 A | 2013-06-19 A | 100% | 2012-06-25 | 2013-06-19 | 263d? | finish no earlier than 2013-06-19 | S2 | 2104h | 2104h | BusTI-SA2 | PCG-29 | 23.228 | Deutsche Telekom | michele.zarri@telekom.com | Rel-12 | SP-56 | Maurice |  |  |  |  |  |

Notes:
- 1501: Triggered by TR 23.887 Machine Type and other mobile data applications Communications Enhancements (MTCe), TR 37.869 Study on Enhancements MTC and other Mobile Data Applications; RAN aspects (FS_MTCe_RAN), Rel-11 TR 23.888 SIMTC
- 1502: RP#65 completed
- 1503: Linked to BBF, IETF work. SP#58 stopped BB3 to BB6. Split BB1 and BB2 into TR and Stage 2 work
- 1504: SP#57 completed
- 1505: -
- 1506: SP#64 TR 23.896 was never sent for approval due to incomplete P4C BBs. SP#61 TR 23.896v100 for Information. Dec.14: 90->100%. Mar15: 23.896 for approval.
- 1507: SP#62 completed
- 1508: -
- 1509: CP#64 completed
- 1510: CP#63 completed
- 1511: CP#64 completed
- 1512: SP#65 completed. Introduce Charging Characteristics in Convergent scenario, Include missing fixed user location information for NSWO
- 1513: SP#64 completed
- 1514: -
- 1515: SP#60 completed
- 1516: SP#60 completed
- 1517: SP#58 stopped (at 0% completion)
- 1518: SP#58 stopped (at 0% completion)
- 1519: SP#58 stopped (at 0% completion)
- 1520: SP#58 stopped (at 30% completion)
- 1521: Linked to Rel-11 IPXS Feature UID_470051 Advanced IP Interconnection of Services. This WI defines a generic framework for interconnecting with any type of IMS based network including IP-PBXs.
- 1522: SP#57 completed. 22.228CR#0171
- 1523: SP#60 completed
- 1524: SP#60 completed

| ID | WBS | Task | Duration | Start | Finish | Complete | Remaining | Baseline start | Baseline finish | Baseline duration | Total slack | Constraint | Resources | Work | Actual work | Acronym | PCG approved | Impacted TSs and TRs | WI rapporteur name | WI rapporteur e-mail | Release | TSG approved | MCC resp | Acronym_3GU_Export | Status Report | Special Focus Doc | PCG stopped | TSG stopped |
| --- | --- | --- | --- | --- | --- | --- | --- | --- | --- | --- | --- | --- | --- | --- | --- | --- | --- | --- | --- | --- | --- | --- | --- | --- | --- | --- | --- | --- |
| 1525 | 387.4 | **CT aspects of IMS Business Trunking for IP-PBX in Static Mode of Operation (Stage 3)** | 333d? | 2013-09-06 A | 2014-12-09 A | 100% |  | 2013-09-06 | 2014-09-12 | 268d? |  |  | C1; C3 | 9552h | 9552h | BusTI-CT | PCG-31 | Stage 3 | Deutsche Telekom | michael.kreipl@telekom.de | Rel-12 | CP-61 | Frederic | BusTI-CT |  |  |  |  |
| 1526 | 387.4.1 | CT1 part of CT aspects of IMS Business Trunking for IP-PBX in Static Mode of Operation (Stage 3) | 329d? | 2013-09-06 A | 2014-12-09 A | 100% |  | 2013-09-06 | 2014-09-12 | 267d? |  | finish no earlier than 2014-12-09 | C1 | 2632h | 2632h | BusTI-CT | PCG-31 | 23.218, 24.229, 24.525 (transfer of ETSI TS 182 025) | Deutsche Telekom | michael.kreipl@telekom.de | Rel-12 | CP-61 | Frederic |  | CP-140607 |  |  |  |
| 1527 | 387.4.2 | CT3 part of CT aspects of IMS Business Trunking for IP-PBX in Static Mode of Operation (Stage 3) | 201d? | 2013-09-06 A | 2014-06-11 A | 100% |  | 2013-09-06 | 2014-06-13 | 201d? |  | finish no earlier than 2014-06-13 | C3 | 1608h | 1608h | BusTI-CT | PCG-31 | 29.165 | Deutsche Telekom | michael.kreipl@telekom.de | Rel-12 | CP-61 | Adrian |  |  |  |  |  |
| 1528 | 388 | **WLAN Network Selection for 3GPP Terminals** | 659d? | 2012-06-18 A | 2014-12-09 A | 100% |  | 2012-06-18 | 2014-09-12 | 594d? |  |  | S2; S1; S3; C1 | 35272h | 35272h | WLAN_NS | PCG-29 | Stage 1/2/3 | Intel | vivek.g.gupta@intel.com | Rel-12 | SP-56 | Maurice | WLAN_NS |  | WLAN |  |  |
| 1529 | 388.1 | TR on Stage 2 for WLAN Network Selection for 3GPP Terminals | 396d? | 2012-06-18 A | 2013-12-11 A | 100% |  | 2012-06-18 | 2013-12-11 | 396d? |  | finish no earlier than 2013-12-11 | S2; S1 | 6336h | 6336h | WLAN_NS-SATR | PCG-29 | New TR 23.865 | Intel | vivek.g.gupta@intel.com | Rel-12 | SP-56 | Maurice |  |  | WLAN |  |  |
| 1530 | 388.2 | Stage 2 for WLAN Network Selection for 3GPP Terminals | 392d? | 2012-06-22 A | 2013-12-11 A | 100% |  | 2012-06-22 | 2013-12-11 | 392d? |  | finish no earlier than 2013-12-11 | S2 | 3136h | 3136h | WLAN_NS-SA2 | PCG-29 | 23.402, 23.865 | Intel | vivek.g.gupta@intel.com | Rel-12 | SP-56 | Maurice |  |  | WLAN |  |  |
| 1531 | 388.3 | Deleted - TR on Security Aspects of WLAN Network Selection for 3GPP Terminals | 326d? | 2012-12-13 A | 2014-03-07 A | 100% |  | 2012-12-13 | 2014-03-07 | 326d? |  | finish no earlier than 2014-03-07 | S3 | 2608h | 2608h | WLAN_Nsdel | PCG-30 | New TR 33.865 | Huawei | Lydia Xu (xuyixian@huawei.com) | Rel-12 | SP-58 | Mirko |  |  | WLAN | PCG-32 | CP-63 |
| 1532 | 388.4 | CT aspects of WLAN Network Selection for 3GPP Terminals (Stage 3) | 263d? | 2013-12-06 A | 2014-12-09 A | 100% |  | 2013-12-06 | 2014-09-12 | 201d? |  | finish no earlier than 2014-12-09 | C1 | 2104h | 2104h | WLAN_NS-CT | PCG-32 | 24.302, 24.312 | Qualcomm | Amer Catovic, amerc@qualcomm.com | Rel-12 | CP-62 | Frederic | WLAN_NS-CT | CP-140622 | WLAN |  |  |
| 1533 | 389 | **Deleted - IMS Registration Control** | 496d? | 2012-01-31 A | 2013-12-11 A | 100% |  | 2012-01-31 | 2013-12-11 | 496d? |  |  | S1; S2; C1; C4 | 23400h | 23400h | IMS_RegCon | PCG-29 | Stage 1/2/3 | China Mobile | lulu@chinamobile.com | Rel-12 | SP-57 | Alain | IMS_RegCon |  |  | PCG-32 | SP-62 |
| 1534 | 389.1 | Deleted - Stage 1 for IMS Registration Control | 164d? | 2012-01-31 A | 2012-09-12 A | 100% |  | 2012-01-31 | 2012-09-12 | 164d? |  | finish no earlier than 2012-09-12 | S1 | 1304h | 1304h | IMS_RegCon-del1 | PCG-29 | 22.228 | China Mobile | lulu@chinamobile.com | Rel-12 | SP-57 | Alain |  |  |  | PCG-32 | SP-62 |
| 1535 | 389.2 | Deleted - Stage 2 for IMS Registration Control | 262d? | 2012-12-13 A | 2013-12-11 A | 100% |  | 2012-12-13 | 2013-12-11 | 262d? |  | finish no earlier than 2013-12-11 | S2 | 2096h | 2096h | IMS_RegCon-del2 | PCG-30 | 23.228 | China Mobile | Jiang Yi (jiangyi@chinamobile.com) | Rel-12 | SP-58 | Maurice |  |  |  | PCG-32 | SP-62 |
| 1536 | 389.3 | **Deleted - CT aspects of IMS registration control** | 129d? | 2013-06-19 A | 2013-12-11 A | 100% |  | 2013-06-19 | 2013-12-11 | 129d? |  |  | C1; C4 | 4128h | 4128h | IMS_RegCon-CT | PCG-31 | Stage 2/3 | China Mobile | Jiang Yi (jiangyi@chinamobile.com) | Rel-12 | CP-60 | Frederic | IMS_RegCon-CT |  |  | PCG-32 | SP-62 |
| 1537 | 389.3.1 | Deleted - CT1 aspects of CT aspects of IMS registration control (Stage 2/3) | 129d? | 2013-06-19 A | 2013-12-11 A | 100% |  | 2013-06-19 | 2013-12-11 | 129d? |  | finish no earlier than 2013-12-11 | C1 | 1032h | 1032h | IMS_RegCon-CT1 | PCG-31 | 23.218, 24.229 | China Mobile | Jiang Yi (jiangyi@chinamobile.com) | Rel-12 | CP-60 | Frederic |  |  |  | PCG-32 | SP-62 |
| 1538 | 389.3.2 | Deleted - CT4 aspects of CT aspects of IMS registration control (Stage 3) | 129d? | 2013-06-19 A | 2013-12-11 A | 100% |  | 2013-06-19 | 2013-12-11 | 129d? |  | finish no earlier than 2013-12-11 | C4 | 1032h | 1032h | IMS_RegCon-CT4 | PCG-31 | 29.228, 29.229, 23.008 | China Mobile | Jiang Yi (jiangyi@chinamobile.com) | Rel-12 | CP-60 | Kimmo |  |  |  | PCG-32 | SP-62 |
| 1539 | 390 | **Proximity-based Services** | 1056d? | 2012-12-13 A | 2016-12-15 | 98% | 26.26d? | 2012-12-13 | 2015-03-13 | 593d? | 347d |  | S1; S2; S3; C1; C3; C4; C6; R1; R2; R4; S5; IETF | 158465h | 47863.8h | ProSe | PCG-30 | Stage 1/2 | Qualcomm | Rich Hovey (rhovey@qualcomm.com) | Rel-12 | SP-58 | Alain | ProSe |  | Public Safety (A-A) |  |  |
| 1540 | 390.1 | Stage 1 for Proximity-based Services | 137d? | 2012-12-13 A | 2013-06-19 A | 100% |  | 2012-12-13 | 2013-06-19 | 137d? |  | finish no earlier than 2013-06-19 | S1 | 1088h | 1088h | ProSe-SA1 | PCG-30 | 22.115, 22.278 | Qualcomm | Rich Hovey (rhovey@qualcomm.com) | Rel-12 | SP-58 | Alain |  |  | Public Safety (A-A) |  |  |
| 1541 | 390.2 | TR on Stage 2 for Proximity-based Services | 327d? | 2012-12-13 A | 2014-03-07 A | 100% |  | 2012-12-13 | 2014-03-07 | 327d? |  | finish no earlier than 2014-03-07 | S2 | 2608h | 2608h | ProSe-SA2TR | PCG-30 | New TR 23.703 | Qualcomm | Haris Zisimopoulos (harisz@qti.qualcomm.com) | Rel-12 | SP-58 | Maurice |  |  | Public Safety (A-A) |  |  |
| 1542 | 390.3 | Stage 2 for Proximity-based Services | 397d? | 2012-12-19 A | 2014-06-18 A | 100% |  | 2012-12-19 | 2014-06-18 | 397d? |  | finish no earlier than 2014-06-18 | S2 | 3168.8h | 3168.8h | ProSe-SA2 | PCG-30 | New TS 23.303 | Qualcomm | Haris Zisimopoulos (harisz@qti.qualcomm.com) | Rel-12 | SP-58 | Maurice |  |  | Public Safety (A-A) |  |  |
| 1543 | 390.4 | Security for Proximity-based Services | 464d? | 2013-03-13 A | 2014-12-12 A | 100% |  | 2013-03-13 | 2014-06-18 | 336d? |  | finish no earlier than 2014-12-12 | S3 | 3712h | 3712h | ProSe-SA3 | PCG-30 | 33.220, New TS 33.303 | Qualcomm | Adrian Escott (aescott@qti.qualcomm.com) | Rel-12 | SP-59 | Mirko |  | SP-140584 | Public Safety (A-A) |  |  |
| 1544 | 390.5 | (IETF) Security for Proximity-based Services (ietf-avtcore-srtp-aes-gcm) | 63d? | 2014-09-12 A | 2014-12-09 A | 100% |  |  |  |  |  | finish no earlier than 2014-12-09 | S3-IETF | 504h | 504h | ProSe | PCG-33 | RFC 7714 (was ietf-avtcore-srtp-aes-gcm) | Atle Monrad | atle.monrad@ericsson.com | Rel-12 | SP-65 |  |  |  | Public Safety (A-A) |  |  |
| 1545 | 390.6 | **Charging Aspects of Proximity-based Services** | 195d? | 2014-06-19 A | 2015-03-13 A | 100% |  | 2014-06-18 | 2014-09-17 | 66d? |  |  | S5 | 4160h | 4160h | ProSe-CH | PCG-33 | Stage 2/3 | Qualcomm | Cheng Hong (hongc@qti.qualcomm.com) | Rel-12 | SP-64 |  | ProSe-CH | SP-140543 | Public Safety (A-A) |  |  |
| 1546 | 390.6.1 | Study on Charging support for ProSe one-to-many Direct Communication for Public Safety use | 130d? | 2014-06-19 A | 2014-12-12 A | 100% |  | 2014-06-18 | 2014-09-17 | 66d? |  | finish no earlier than 2014-12-12 | S5 | 1040h | 1040h | ProSe-CH-SA5TR | PCG-33 | New TR 32.844 | Qualcomm | Cheng Hong (hongc@qti.qualcomm.com) | Rel-12 | SP-64 |  |  | SP-140543 | Public Safety (A-A) |  |  |
| 1547 | 390.6.2 | Specification of Charging Aspects of Proximity-based Services | 195d? | 2014-06-19 A | 2015-03-13 A | 100% |  | 2014-06-18 | 2014-09-17 | 66d? |  | finish no earlier than 2015-03-13 | S5 | 1560h | 1560h | ProSe-CH-SA5 | PCG-33 | 32.240, 32.297, 32.298, 32.299, New TS 32.277 | Qualcomm | Cheng Hong (hongc@qti.qualcomm.com) | Rel-12 | SP-64 |  |  | SP-140543 | Public Safety (A-A) |  |  |
| 1548 | 390.7 | **CT aspects of Proximity-based Services (Stage 3)** | 203d? | 2014-03-05 A | 2014-12-09 A | 100% |  | 2014-03-05 | 2014-09-12 | 138d? |  |  | C1; C3; C4; C6 | 12888h | 12888h | ProSe-CT | PCG-32 | Stage 3 | Qualcomm | Lena Chaponniere (lguellec@qti.qualcomm.com) | Rel-12 | CP-63 | Frederic | ProSe-CT |  | Public Safety (A-A) |  |  |
| 1549 | 390.7.1 | CT1 part of CT aspects of Proximity-based Services | 200d? | 2014-03-05 A | 2014-12-09 A | 100% |  | 2014-03-05 | 2014-09-12 | 138d? |  | finish no earlier than 2014-12-09 | C1 | 1600h | 1600h | ProSe-CT | PCG-32 | 24.301, 23.122, New TSs (24.333, 24.334) | Qualcomm | Lena Chaponniere (lguellec@qti.qualcomm.com) | Rel-12 | CP-63 | Frederic |  | CP-140615 | Public Safety (A-A) |  |  |
| 1550 | 390.7.2 | CT3 part of CT aspects of Proximity-based Services | 200d? | 2014-03-05 A | 2014-12-09 A | 100% |  | 2014-03-05 | 2014-09-12 | 138d? |  | finish no earlier than 2014-12-09 | C3 | 1600h | 1600h | ProSe-CT | PCG-32 | New TS 29.343 | Qualcomm | Lena Chaponniere (lguellec@qti.qualcomm.com) | Rel-12 | CP-63 | Adrian |  | CP-140568 | Public Safety (A-A) |  |  |
| 1551 | 390.7.3 | CT4 part of CT aspects of Proximity-based Services | 200d? | 2014-03-05 A | 2014-12-09 A | 100% |  | 2014-03-05 | 2014-09-12 | 138d? |  | finish no earlier than 2014-12-09 | C4 | 1600h | 1600h | ProSe-CT | PCG-32 | 29.272, 23.008, 23.003, New TSs (29.344, 29.345) | Qualcomm | Lena Chaponniere (lguellec@qti.qualcomm.com) | Rel-12 | CP-63 | Kimmo |  | CP-140484 | Public Safety (A-A) |  |  |
| 1552 | 390.7.4 | CT6 part of CT aspects of Proximity-based Services | 199d? | 2014-03-06 A | 2014-12-09 A | 100% |  | 2014-03-06 | 2014-09-12 | 137d? |  | finish no earlier than 2014-12-09 | C6 | 1592h | 1592h | ProSe-CT | PCG-32 | 31.102 | Qualcomm | Lena Chaponniere (lguellec@qti.qualcomm.com) | Rel-12 | CP-63 | Xavier |  | CP-140695 | Public Safety (A-A) |  |  |

Notes:
- 1525: -
- 1526: CP#65 completion 09/14=>12/14. Exception in CP-140607. Dec.14: 85->100%
- 1527: CP#64 completed
- 1528: Evaluate and if needed enhance existing 3GPP solutions for WLAN network selection taking into account WFA Hotspot 2.0 solutions
- 1529: SP#62 completed
- 1530: SP#62 completed
- 1531: SP#63 stopped (84% complete)
- 1532: CP#65 completion 09/14=>12/14. CP#65 exception CP-140622. Dec.14: 95->100%
- 1533: SP#62 stopped. Specify for fixed line the requirement of controlling user registration to IMS based on network information related to user location (e.g. IP address, DSLAM information)
- 1534: SP#57 completed
- 1535: SP#62 stopped at 50% completion
- 1536: SP#62 no CT/Stage 3 work is needed (stopped at 0% completion)
- 1537: SP#62 no CT/Stage 3 work is needed (stopped at 0% completion)
- 1538: SP#62 no CT/Stage 3 work is needed (stopped at 0% completion)
- 1539: SP#65 SA3 updated the SA-wide WID SP-140300=>SP-140574 (Moved the TR phase to Rel-13 as a stand-alone Study). Triggered by Rel-12 TR 22.803 Study on Proximity-based Services (FS_ProSe) UID_530044
- 1540: SP#60 completed
- 1541: SP#63 completed. TR 23.703v200 for Approval
- 1542: SP#64 completed open issue/alignment to RAN/SA3 decisions. SP#63 TS 23.303v100 for 1-step Approval
- 1543: SP#65 re-opened. Completion 06/14=>12/14. Exception in SP-140584. Updated WID SP-140300=>SP-140574 (Moved the TR phase to Rel-13 as a stand-alone Study). SP#64 completed. TS 33.303 v100 for 1-step Approval; Aug2015: 90%->100
- 1544: Submitted to IESG for publication; 7/3/16: 75%->100
- 1545: SP#65 exception in SP-140543. Mar15: 85->100%
- 1546: SP#65 completion 09/14=>12/14. Exception in SP-140543. TR 32.844v100 for Information. Dec.14: CD: 09/14->12/14, 60->100%
- 1547: SP#65 completion 09/14=>12/14. Exception in SP-140543. SP#65 TR 32.277v100 for Information. Dec.14: CD: 09/14->03/15, 40->75%. Mar15: 75->100%
- 1548: CP#64 updated WID CP-140194=>CP-140290
- 1549: CP#65 completion 09/14=>12/14. Exception in CP-140615. TS 24.333/4v200 for Approval. Dec.14: 90->100%
- 1550: CP#65 completion 09/14=>12/14. TS 29.343v100 for 1-step Approval. Exception in CP-140568. Dec.14: 90->100
- 1551: CP#65 completion 09/14=>12/14. TS 29.344/5v100 for 1-step Approval. Exception in CP-140484. Dec.14: 90->100
- 1552: CP#65 completion 09/14=>12/14. Exception in CP-140695. Dec.14: 60->100%

| ID | WBS | Task | Duration | Start | Finish | Complete | Remaining | Baseline start | Baseline finish | Baseline duration | Total slack | Constraint | Resources | Work | Actual work | Acronym | PCG approved | WI rapporteur name | WI rapporteur e-mail | Release | TSG approved | MCC resp | Special Focus Doc | Acronym_3GU_Export | Status Report |
| --- | --- | --- | --- | --- | --- | --- | --- | --- | --- | --- | --- | --- | --- | --- | --- | --- | --- | --- | --- | --- | --- | --- | --- | --- | --- |
| 1553 | 390.8 | **LTE Device to Device Proximity Services** | 727d? | 2014-03-11 A | 2016-12-15 | 92% | 56.35d? | 2014-03-06 | 2015-03-13 | 267d? | 347d |  | R1; R2; R4 | 31152h | 14535h | LTE_D2D_Prox | PCG-32 | Qualcomm | Shailesh Patil (patil@qti.qualcomm.com) | Rel-12 | RP-63 | Patrick | Public Safety (A-A) | LTE_D2D_Prox |  |
| 1554 | 390.8.1 | Core part: LTE Device to Device Proximity Services | 263d? | 2014-03-15 A | 2015-03-15 A | 100% |  | 2014-07-11 | 2014-09-12 | 45.67d? |  | finish no earlier than 2015-03-15 | R1; R2; R4 | 6312h | 6312h | LTE_D2D_Prox-Core | PCG-32 | Qualcomm | Shailesh Patil (patil@qti.qualcomm.com) | Rel-12 | RP-63 | Patrick | Public Safety (A-A) | LTE_D2D_Prox-Core | RP-150094 |
| 1555 | 390.8.2 | Perf. part: LTE Device to Device Proximity Services | 464d? | 2014-03-11 A | 2015-12-15 A | 100% |  | 2014-03-06 | 2015-03-13 | 267d? |  | finish no earlier than 2015-12-15 | R4 | 3712h | 3712h | LTE_D2D_Prox-Perf | PCG-32 | Qualcomm | Shailesh Patil (patil@qti.qualcomm.com) | Rel-12 | RP-63 | Issam | Public Safety (A-A) | LTE_D2D_Prox-Perf | RP-151276 |
| 1556 | 390.8.3 | UE Conformance Test Aspects – LTE Device-to-Device Proximity Services | 460d? | 2015-03-16 A | 2016-12-15 | 80% | 92d? |  |  |  | 347d | finish no earlier than 2016-12-15 | R5 | 3680h | 2944h | LTE_D2D_Prox-UEConTest | PCG-34 | Qualcomm | svora@qti.qualcomm.com | Rel-12 | RP-67 |  |  |  | RP-151280 |
| 1557 | 391 | **Web Real Time Communication access to IMS** | 530d? | 2012-12-14 A | 2014-12-12 | 88% | 63.97d? | 2012-12-14 | 2014-12-10 | 525d? | 872d |  | S1; S2; S3 | 34985.8h | 22067h | IMS_WebRTC | PCG-30 | China Mobile | lulu@chinamobile.com | Rel-12 | SP-58 | Alain |  | IMS_WebRTC |  |
| 1558 | 391.1 | Stage 1 for Web Real Time Communication access to IMS | 136d? | 2012-12-14 A | 2013-06-19 A | 100% |  | 2012-12-14 | 2013-06-19 | 136d? |  | finish no earlier than 2013-06-19 | S1 | 1088h | 1088h | IMS_WebRTC | PCG-30 | China Mobile | lulu@chinamobile.com | Rel-12 | SP-58 | Alain |  |  |  |
| 1559 | 391.2 | TR on Stage 2 for Web Real Time Communication access to IMS | 126d? | 2013-06-19 A | 2013-12-11 A | 100% |  | 2013-06-19 | 2013-12-11 | 126d? |  | finish no earlier than 2013-12-11 | S2 | 1008h | 1008h | IMS_WebRTC | PCG-31 | China Mobile | Yu Qing (yuqing@chinamobile.com) | Rel-12 | SP-60 | Maurice |  |  |  |
| 1560 | 391.3 | Stage 2 for Web Real Time Communication access to IMS | 192d? | 2013-06-19 A | 2014-03-07 A | 100% |  | 2013-06-19 | 2014-03-07 | 192d? |  | finish no earlier than 2014-03-07 | S2 | 1528h | 1528h | IMS_WebRTC | PCG-31 | China Mobile | Yu Qing (yuqing@chinamobile.com) | Rel-12 | SP-60 | Maurice |  |  |  |
| 1561 | 391.4 | (IETF) Web Real Time Communication access to IMS (rtcweb-overview) | 391d? | 2013-06-25 A | 2014-12-12 | 50% | 195.5d? | 2013-06-19 | 2014-12-10 | 389d? | 872d | finish no earlier than 2014-12-12 | C1-IETF | 3128h | 1564h | IMS_WebRTC | PCG-32 | Uwe Rauschenbach | Uwe Rauschenbach | Rel-12 | SP-63 |  |  |  |  |
| 1562 | 391.5 | TR on Security for Web Real Time Communication access to IMS | 202d? | 2013-12-11 A | 2014-09-17 A | 100% |  | 2013-12-11 | 2014-09-17 | 202d? |  | finish no earlier than 2014-09-17 | S3 | 1608h | 1608h | IMS_WebRTC | PCG-32 | Ericsson | oscar.ohlsson@ericsson.com | Rel-12 | SP-62 | Mirko |  |  |  |
| 1563 | 391.6 | Security for Web Real Time Communication access to IMS | 202d? | 2013-09-12 A | 2014-06-18 A | 100% |  | 2013-09-12 | 2014-06-18 | 202d? |  | finish no earlier than 2014-06-18 | S3 | 1609.85h | 1609.85h | IMS_WebRTC | PCG-31 | Ericsson | oscar.ohlsson@ericsson.com | Rel-12 | SP-61 | Mirko |  |  |  |
| 1564 | 391.7 | **CT aspects of Web Real Time Communication (WebRTC) Access to IMS** | 203d? | 2014-03-05 A | 2014-12-09 | 93% | 14.71d? | 2014-03-05 | 2014-12-05 | 198d? | 875d |  | C1; C4; IETF | 12296h | 10397.2h | IMS_WebRTC-CT | PCG-32 | China Mobile | Jiang Yi (jiangyi@chinamobile.com) | Rel-12 | CP-63 | Frederic |  | IMS_WebRTC-CT |  |
| 1565 | 391.7.1 | CT1 part of CT aspects of Web Real Time Communication (WebRTC) Access to IMS | 200d? | 2014-03-05 A | 2014-12-09 A | 100% |  | 2014-03-05 | 2014-09-12 | 138d? |  | finish no earlier than 2014-12-09 | C1 | 1600h | 1600h | IMS_WebRTC-CT1 | PCG-32 | China Mobile | Jiang Yi (jiangyi@chinamobile.com) | Rel-12 | CP-63 | Frederic |  |  | CP-140621 |
| 1566 | 391.7.2 | (IETF) Web Real Time Communication access to IMS (rtcweb-data-channel) | 200d? | 2014-03-06 A | 2014-12-09 | 90% | 20d? | 2014-03-05 | 2014-12-05 | 198d? | 875d | finish no earlier than 2014-12-09 | C1-IETF | 1600h | 1440h | IMS_WebRTC-data | PCG-33 | christer.holmberg@ericsson.com | christer.holmberg@ericsson.com | Rel-12 | CP-64 |  |  |  |  |
| 1567 | 391.7.3 | (IETF) Web Real Time Communication access to IMS (rtcweb-stun-consent-freshness) | 200d? | 2014-03-06 A | 2014-12-09 A | 100% |  | 2014-03-05 | 2014-12-05 | 198d? |  | finish no earlier than 2014-12-09 | C1-IETF | 1600h | 1600h | IMS_WebRTC-stun | PCG-33 | christer.holmberg@ericsson.com | christer.holmberg@ericsson.com | Rel-12 | CP-64 |  |  |  |  |
| 1568 | 391.7.4 | (IETF) Web Real Time Communication access to IMS (draft-yusef-sipcore-sip-oauth) | 63d? | 2014-09-12 A | 2014-12-09 | 25% | 47.25d? |  |  |  | 875d | finish no earlier than 2014-12-09 | C1-IETF | 504h | 126h | IMS_WebRTC-yusef | PCG-33 | christer.holmberg@ericsson.com | christer.holmberg@ericsson.com | Rel-12 | CP-65 |  |  |  |  |
| 1569 | 391.7.5 | Deleted - (IETF) Web Real Time Communication access to IMS (draft-holmberg-sipcore-auth-id) | 65d? | 2014-09-12 A | 2014-12-09 A | 100% |  |  |  |  |  | start no earlier than 2014-09-12 | C1-IETF | 520h | 520h | IMS_WebRTC-holmb | PCG-34 | christer.holmberg@ericsson.com |  | Rel-12 | CP-66 |  |  |  |  |
| 1570 | 391.7.6 | CT4 part of CT aspects of Web Real Time Communication (WebRTC) Access to IMS | 200d? | 2014-03-05 A | 2014-12-09 A | 100% |  | 2014-03-05 | 2014-09-19 | 143d? |  | finish no earlier than 2014-12-09 | C4 | 1600h | 1600h | IMS_WebRTC-CT4 | PCG-32 | China Mobile | Jiang Yi (jiangyi@chinamobile.com) | Rel-12 | CP-63 | Kimmo |  |  | CP-140732 |
| 1571 | 392 | **Usage Monitoring Control PCC enhancement** | 196d? | 2012-12-13 A | 2013-09-06 A | 100% |  | 2012-12-13 | 2013-09-06 | 196d? |  |  | S2; C3 | 4112h | 4112h | UMONC | PCG-30 | ZTE | bi.yifeng@zte.com.cn | Rel-12 | SP-58 | Maurice |  | UMONC |  |
| 1572 | 392.1 | Stage 2 for Usage Monitoring Control PCC enhancement | 61d? | 2012-12-13 A | 2013-03-06 A | 100% |  | 2012-12-13 | 2013-03-06 | 61d? |  | finish no earlier than 2013-03-06 | S2 | 488h | 488h | UMONC | PCG-30 | ZTE | bi.yifeng@zte.com.cn | Rel-12 | SP-58 | Maurice |  |  |  |
| 1573 | 392.2 | CT3 aspects of Usage Monitoring Control PCC enhancement (Stage 3) | 63d? | 2013-06-14 A | 2013-09-06 A | 100% |  | 2013-06-14 | 2013-09-06 | 63d? |  | finish no earlier than 2013-09-06 | C3 | 488h | 488h | UMONC-CT3 | PCG-31 | ZTE | zhou.xiaoyun@zte.com.cn | Rel-12 | CP-60 | Adrian |  | UMONC-CT3 |  |
| 1574 | 393 | **Application Based Charging** | 340d? | 2013-03-07 A | 2014-06-18 A | 100% |  | 2013-03-07 | 2014-06-18 | 340d? |  |  | S2; S5; C3 | 11612h | 11612h | ABC | PCG-30 | Allot | Alla Goldner (agoldner@allot.com) | Rel-12 | SP-59 | Maurice |  | ABC |  |
| 1575 | 393.1 | Stage 2 for Application Based Charging | 76d? | 2013-03-07 A | 2013-06-19 A | 100% |  | 2013-03-07 | 2013-06-19 | 76d? |  | finish no earlier than 2013-12-11 | S2 | 608h | 608h | ABC-SA2 | PCG-30 | Allot | Alla Goldner (agoldner@allot.com) | Rel-12 | SP-59 | Maurice |  |  |  |
| 1576 | 393.2 | Charging for Application Based Charging | 232.5d? | 2013-06-19 A | 2014-06-18 A | 100% |  | 2013-06-19 | 2014-06-18 | 232.5d? |  | finish no earlier than 2014-06-18 | S5 | 1836h | 1836h | ABC-CT5 | PCG-31 | Openet Telecom | alan.mcnamee@openet.com | Rel-12 | SP-60 | Mirko |  |  |  |
| 1577 | 393.3 | CT3 aspects of Application Based Charging (Stage 3) | 127d? | 2013-06-14 A | 2013-12-06 A | 100% |  | 2013-06-14 | 2013-12-06 | 127d? |  | finish no earlier than 2013-12-06 | C3 | 1008h | 1008h | ABC-CT3 | PCG-31 | Allot | Alla Goldner (agoldner@allot.com) | Rel-12 | CP-60 | Adrian |  | ABC-CT3 |  |

Notes:
- 1553: follow-up of TR 36.843 FS_LTE_D2D_Prox / Impacted TSs and TRs: LTE
- 1554: ; CD:Sat 15/03/14->Sun 15/03/15Compl:0%->95%; CD:Fri 13/03/15->Sun 15/03/15; Stat Rep: RP-141244->RP-141894 1st Apr 15: Compl:95%->100% 1st Apr 15: Stat Rep: RP-141894->RP-150094 / Impacted TSs and TRs: 36.101, 36.133, 36.211, 36.212, 36.213, 36.214, 36.300, 36.304, 36.306, 36.321, 36.322, 36.323, 36.331, 36.413, 36.423, New TR 36.877
- 1555: ; CD:Sat 15/03/14->Sun 15/03/15; Stat Rep: RP-141244->RP-141894 1st Apr 15: Compl:10%->25% 1st Apr 15: Stat Rep: RP-141894->RP-150094 03/07/15: Compl:25%->70% 03/07/15: Stat Rep: RP-150094->RP-150760 29/09/15: Compl:70%->95% 29/09/15: CD:Tue 15/09/15->...; ; ; ; ; ; ; ; ; ; ; ; ; ; ; ; ; ; 1/1/16: Compl:95%->100% / Impacted TSs and TRs: 36.101, 36.133
- 1556: rapporteur e-mail added 03/07/15: Compl:0%->10% 03/07/15: Stat Rep: ->RP-150765 29/09/15: Compl:10%->30% 29/09/15: CD:Tue 15/12/15->Wed 15/06/16 29/09/15: Stat Rep: RP-150765->RP-151280 1/1/16: Compl:30%->45% 1/1/16: WID: RP-1...; ;...; ;...;...
- 1557: IETF RTCWEB and W3C WEBRTC groups are specifying a browser-based client to support communication services. Interoperability for WebRTC clients to access 3GPP IMS is needed. / Impacted TSs and TRs: Stage 1/2
- 1558: SP#60 completed / Impacted TSs and TRs: 22.101, 22.228
- 1559: SP#62 completed. TR 23.701v100 for Information & Approval / Impacted TSs and TRs: New TR 23.701
- 1560: SP#63 completed / Impacted TSs and TRs: 23.228
- 1561: In WGLC. Mar15: responsible WG changed from S2-IETF / Impacted TSs and TRs: draft-ietf-rtcweb-overview
- 1562: SP#65 completed. TR 33.871v200 for Approval / Impacted TSs and TRs: New TR 33.871
- 1563: SP#64 completed / Impacted TSs and TRs: 33.203, 33.328
- 1564: - / Impacted TSs and TRs: Stage 3
- 1565: CP#65 TS 24.371v100 for Information. Completion 09/14=>12/14. Exception in CP-140621. Dec.14: 70->90%. 3/3/15: 100% cpltd. / Impacted TSs and TRs: 24.229, New TS 24.371
- 1566: Submitted to IESG for publication. Mar15: In RFC-Editors queue / Impacted TSs and TRs: draft-ietf-rtcweb-data-channel
- 1567: Mar15: Publication requested; 7/3/16: 50%->100 / Impacted TSs and TRs: draft-ietf-rtcweb-stun-consent-freshness
- 1568: work in progress / Impacted TSs and TRs: draft-yusef-sipcore-sip-oaut
- 1569: 7/3/16: 25%->100 since deleted (draft no longer needed). / Impacted TSs and TRs: draft-holmberg-sipcore-auth-id
- 1570: CP#65 completion 09/14=>12/14. Exception in CP-140732. Dec.14: 30->80%. Mar. 15: 100% / Impacted TSs and TRs: 23.334, 29.334
- 1571: SP#59 Stage 2 completed. Triggered by Rel-12 TR 23.858 Study on Usage Monitoring Control enhancement (UID_520035) / Impacted TSs and TRs: Stage 2/3
- 1572: SP#59 completed. 23.203 CR#0782 (Time Based Usage Monitoring), CR#0784 (Usage Monitoring via Online Charging System) / Impacted TSs and TRs: 23.203
- 1573: CP#61 completed. 2/4/15: acronym changed to "UMONC-CT3" / Impacted TSs and TRs: 29.212, 29.214, 29.215
- 1574: Triggered by TR 23.800 Study on Application Based Charging (FS_ABC) UID_560038 / Impacted TSs and TRs: Stage 2/3
- 1575: SP#60 completed / Impacted TSs and TRs: 23.203
- 1576: SP#64 completed / Impacted TSs and TRs: 32.240, 32.251, 32.296, 32.298, 32.299
- 1577: CP#62 completed / Impacted TSs and TRs: 29.212, 29.213, 29.214, 29.215, 29.219

| ID | WBS | Task | Duration | Start | Finish | Complete | Baseline start | Baseline finish | Baseline duration | Constraint | Resources | Work | Actual work | Acronym | PCG approved | WI rapporteur name | WI rapporteur e-mail | Release | TSG approved | MCC resp | Special Focus Doc | Acronym_3GU_Export | Status Report | PCG stopped | TSG stopped |
| --- | --- | --- | --- | --- | --- | --- | --- | --- | --- | --- | --- | --- | --- | --- | --- | --- | --- | --- | --- | --- | --- | --- | --- | --- | --- |
| 1578 | 394 | **Enhanced S2a Mobility Over trusted WLAN access to EPC** | 332d? | 2013-09-09 A | 2014-12-09 A | 100% | 2013-09-09 | 2014-09-12 | 267d? |  | S2; C1; C4 | 19024h | 19024h | eSaMOG | PCG-31 | ZTE | Tricci So (tso@zteusa.com) | Rel-12 | SP-61 | Maurice | WLAN | eSaMOG |  |  |  |
| 1579 | 394.1 | Stage 2 for Enhanced S2a Mobility Over trusted WLAN access to EPC | 130d? | 2013-09-11 A | 2014-03-07 A | 100% | 2013-09-11 | 2014-03-07 | 130d? | finish no earlier than 2014-03-07 | S2 | 1032h | 1032h | eSaMOG-SA2 | PCG-31 | ZTE | Tricci So (tso@zteusa.com) | Rel-12 | SP-61 | Maurice | WLAN |  |  |  |  |
| 1580 | 394.2 | **Stage 3 for Enhanced S2a Mobility Over trusted WLAN access to EPC** | 332d? | 2013-09-09 A | 2014-12-09 A | 100% | 2013-09-09 | 2014-09-12 | 267d? |  | C1; C4 | 10048h | 10048h | eSaMOG-St3 | PCG-31 | ZTE | Joy Zhou (zhou.xingyue@zte.com.cn) | Rel-12 | CP-61 | Frederic | WLAN | eSaMOG-St3 |  |  |  |
| 1581 | 394.2.1 | CT1 part of Stage 3 for Enhanced S2a Mobility Over trusted WLAN access to EPC | 329d? | 2013-09-09 A | 2014-12-09 A | 100% | 2013-09-09 | 2014-09-12 | 267d? | finish no earlier than 2014-12-09 | C1 | 2624h | 2624h | eSaMOG-St3 | PCG-31 | ZTE | Joy Zhou (zhou.xingyue@zte.com.cn) | Rel-12 | CP-61 | Frederic | WLAN |  | CP-140608 |  |  |
| 1582 | 394.2.2 | CT4 part of Stage 3 for Enhanced S2a Mobility Over trusted WLAN access to EPC | 266d? | 2013-09-09 A | 2014-09-11 A | 100% | 2013-09-09 | 2014-09-12 | 266d? | finish no earlier than 2014-09-12 | C4 | 2128h | 2128h | eSaMOG-St3 | PCG-31 | ZTE | Joy Zhou (zhou.xingyue@zte.com.cn) | Rel-12 | CP-61 | Kimmo | WLAN |  |  |  |  |
| 1583 | 395 | **Optimized Offloading to WLAN in 3GPP-RAT Mobility** | 199d? | 2013-09-12 A | 2014-06-13 A | 100% | 2013-09-12 | 2014-06-13 | 199d? |  | S2; C1 | 4800h | 4800h | WORM | PCG-31 | BlackBerry | Steve Barrett (sbarrett@blackberry.com) | Rel-12 | SP-61 | Maurice | WLAN | WORM |  |  |  |
| 1584 | 395.1 | Stage 2 for Optimized Offloading to WLAN in 3GPP-RAT Mobility | 66d? | 2013-09-12 A | 2013-12-11 A | 100% | 2013-09-12 | 2013-12-11 | 66d? | finish no earlier than 2013-12-11 | S2 | 528h | 528h | WORM-SA2 | PCG-31 | BlackBerry | Steve Barrett (sbarrett@blackberry.com) | Rel-12 | SP-61 | Maurice | WLAN |  |  |  |  |
| 1585 | 395.2 | CT aspects of Optimized Offloading to WLAN in 3GPP-RAT Mobility (Stage 3) | 136d? | 2013-12-06 A | 2014-06-13 A | 100% | 2013-12-06 | 2014-06-13 | 136d? | finish no earlier than 2014-06-13 | C1 | 1088h | 1088h | WORM-CT | PCG-32 | Intel | Chen-ho Chin (chen-hox.chin@intel.com) | Rel-12 | CP-62 | Frederic | WLAN | WORM-CT |  |  |  |
| 1586 | 396 | **Network-provided Location information for IMS Trusted WLAN Access Network (TWAN) case** | 264d? | 2013-09-12 A | 2014-09-11 A | 100% | 2013-09-12 | 2014-09-12 | 264d? |  | S2; C3; C1; C4 | 18624h | 18624h | NETLOC_TWAN | PCG-31 | Alcatel-Lucent | Laurent.thiebaut@alcatel-lucent.com | Rel-12 | SP-61 | Maurice | WLAN | NETLOC_TWAN |  |  |  |
| 1587 | 396.1 | Stage 2 for Network-provided Location information for IMS Trusted WLAN Access Network (TWAN) case | 129d? | 2013-09-12 A | 2014-03-07 A | 100% | 2013-09-12 | 2014-03-07 | 129d? | finish no earlier than 2014-03-07 | S2 | 1024h | 1024h | NETLOC_TWAN-SA2 | PCG-31 | Alcatel-Lucent | Laurent.thiebaut@alcatel-lucent.com | Rel-12 | SP-61 | Maurice |  |  |  |  |  |
| 1588 | 396.2 | **CT aspects of Network-provided Location information for IMS Trusted WLAN Access Network (TWAN) case (Stage 3)** | 202d? | 2013-12-06 A | 2014-09-11 A | 100% | 2013-12-06 | 2014-09-12 | 202d? |  | C3; C1; C4 | 9152h | 9152h | NETLOC_TWAN-CT | PCG-32 | China Telecom | Xia Xu (xiaxu@ctbri.com.cn) | Rel-12 | CP-62 | Adrian |  | NETLOC_TWAN-CT |  |  |  |
| 1589 | 396.2.1 | CT3 part of Network-provided Location information for IMS Trusted WLAN Access Network (TWAN) case | 137d? | 2013-12-06 A | 2014-06-13 A | 100% | 2013-12-06 | 2014-06-13 | 137d? | finish no earlier than 2014-06-13 | C3 | 1088h | 1088h | NETLOC_TWAN-CT | PCG-32 | China Telecom | Xia Xu (xiaxu@ctbri.com.cn) | Rel-12 | CP-62 | Adrian |  |  |  |  |  |
| 1590 | 396.2.2 | CT1 part of Network-provided Location information for IMS Trusted WLAN Access Network (TWAN) case | 201d? | 2013-12-09 A | 2014-09-11 A | 100% | 2013-12-09 | 2014-09-12 | 201d? | finish no earlier than 2014-09-12 | C1 | 1608h | 1608h | NETLOC_TWAN-CT | PCG-32 | China Telecom | Xia Xu (xiaxu@ctbri.com.cn) | Rel-12 | CP-62 | Frederic |  |  |  |  |  |
| 1591 | 396.2.3 | CT4 part of Network-provided Location information for IMS Trusted WLAN Access Network (TWAN) case | 201d? | 2013-12-06 A | 2014-09-11 A | 100% | 2013-12-06 | 2014-09-12 | 201d? | finish no earlier than 2014-09-12 | C4 | 1608h | 1608h | NETLOC_TWAN-CT | PCG-32 | China Telecom | Xia Xu (xiaxu@ctbri.com.cn) | Rel-12 | CP-62 | Kimmo |  |  |  |  |  |
| 1592 | 397 | **Core Network Overload - User Location Information reporting improvement** | 203d? | 2013-12-11 A | 2014-09-17 A | 100% | 2013-12-11 | 2014-09-12 | 199d? |  | S2; C3; C4; S5 | 10920h | 10920h | CNO_ULI | PCG-32 | Alcatel-Lucent | nicolas.drevon@alcatel-lucent.com | Rel-12 | SP-62 | Maurice |  | CNO_ULI |  |  |  |
| 1593 | 397.1 | Stage 2 for Core Network Overload - User Location Information reporting improvement | 64d? | 2013-12-11 A | 2014-03-07 A | 100% | 2013-12-11 | 2014-03-07 | 64d? | finish no earlier than 2014-03-07 | S2 | 504h | 504h | CNO_ULI-SA2 | PCG-32 | Alcatel-Lucent | nicolas.drevon@alcatel-lucent.com | Rel-12 | SP-62 | Maurice |  |  |  |  |  |
| 1594 | 397.2 | Charging aspects of Core Network Overload – User Location Information reporting improvements | 3d? | 2014-09-15 A | 2014-09-17 A | 100% |  |  |  | finish no earlier than 2014-09-17 | S5 | 24h | 24h | CNO_ULI-CH | PCG-33 | Alcatel-Lucent | maryse.gardella@alcatel-lucent.com | Rel-12 | SP-65 |  |  | CNO_ULI-CH |  |  |  |
| 1595 | 397.3 | **CT aspects of Core Network Overload – User Location Information reporting improvements** | 138d? | 2014-03-05 A | 2014-09-11 A | 100% | 2014-03-05 | 2014-09-12 | 138d? |  | C3; C4 | 3896h | 3896h | CNO_ULI-CT | PCG-32 | Alcatel-Lucent | horst.brinkmann@alcatel-lucent.com | Rel-12 | CP-63 | Adrian |  | CNO_ULI-CT |  |  |  |
| 1596 | 397.3.1 | CT3 part of CT aspects of Core Network Overload – User Location Information reporting improvements | 73d? | 2014-03-05 A | 2014-06-13 A | 100% | 2014-03-05 | 2014-06-13 | 73d? | finish no earlier than 2014-06-13 | C3 | 584h | 584h | CNO_ULI-CT | PCG-32 | Alcatel-Lucent | horst.brinkmann@alcatel-lucent.com | Rel-12 | CP-63 | Adrian |  |  |  |  |  |
| 1597 | 397.3.2 | CT4 part of CT aspects of Core Network Overload – User Location Information reporting improvements | 138d? | 2014-03-05 A | 2014-09-11 A | 100% | 2014-03-05 | 2014-09-12 | 138d? | finish no earlier than 2014-09-12 | C4 | 1104h | 1104h | CNO_ULI-CT | PCG-32 | Alcatel-Lucent | horst.brinkmann@alcatel-lucent.com | Rel-12 | CP-63 | Kimmo |  |  |  |  |  |
| 1598 | 398 | Rel-12 Security small Enhancements | 923d? | 2011-03-23 A | 2014-09-17 A | 100% | 2011-03-23 | 2014-06-18 | 859d? | finish no earlier than 2014-09-17 | S3 | 7384h | 7384h | SEC12 | PCG-29 |  |  | Rel-12 | SP-56 | Mirko |  | SEC12 |  |  |  |
| 1599 | 399 | **Security aspects of Public Warning System** | 925d? | 2011-03-23 A | 2014-09-17 A | 100% | 2011-03-23 | 2014-09-17 | 924d? |  | S3; S1 | 36832h | 36832h | PWS_Sec | PCG-26 | ST-Ericsson | john.mattsson@ericsson.com | Rel-12 | SP-51 | Mirko | Public Safety (I-A) | PWS_Sec |  |  |  |
| 1600 | 399.1 | Stage 1 for Protection against false PWS Warning Notifications | 65d? | 2012-06-15 A | 2012-09-12 A | 100% | 2012-06-15 | 2012-09-12 | 65d? | finish no earlier than 2012-09-12 | S1 | 512h | 512h | PWS_Sec-SA1 | PCG-29 | Vodafone | adrian.neal@vodafone.com | Rel-12 | SP-56 | Alain | Public Safety (I-A) |  |  |  |  |
| 1601 | 399.2 | TR on SA3 part for Security aspects of Public Warning System | 921d? | 2011-03-23 A | 2014-09-17 A | 100% | 2011-03-23 | 2014-09-17 | 921d? | finish no earlier than 2014-09-17 | S3 | 7360h | 7360h | PWS_Sec-SA3TR | PCG-26 | ST-Ericsson | john.mattsson@ericsson.com | Rel-12 | SP-51 | Mirko | Public Safety (I-A) |  |  |  |  |
| 1602 | 399.3 | Deleted - SA3 part for Security aspects of Public Warning System | 852d? | 2011-03-30 A | 2014-06-18 A | 100% | 2011-03-30 | 2014-06-18 | 852d? | finish no earlier than 2014-06-18 | S3 | 6808h | 6808h | PWS_Sec-del1 | PCG-26 | ST-Ericsson | john.mattsson@ericsson.com | Rel-12 | SP-51 | Mirko | Public Safety (I-A) |  |  | PCG-33 | SP-64 |
| 1603 | 399.4 | Deleted - Stage 1 for Security aspects of Public Warning System | 330d? | 2011-03-23 A | 2012-06-20 A | 100% | 2011-03-23 | 2012-06-20 | 330d? | start no earlier than 2011-03-23 | S1 | 2640h | 2640h | PWS_Sec-del2 | PCG-26 | ST-Ericsson | john.mattsson@ericsson.com | Rel-12 | SP-51 | Alain | Public Safety (I-A) |  |  | PCG-29 | SP-56 |
| 1604 | 399.5 | Deleted - Stage 2 for Security aspects of Public Warning System | 133d? | 2011-03-23 A | 2011-09-21 A | 100% | 2011-03-23 | 2011-09-21 | 133d? | start no earlier than 2011-03-23 | S2 | 1064h | 1064h | PWS_Sec-del3 | PCG-26 | ST-Ericsson | john.mattsson@ericsson.com | Rel-12 | SP-51 | Maurice | Public Safety (I-A) |  |  | PCG-27 | SP-53 |
| 1605 | 399.6 | Deleted - CT1 part for Security aspects of Public Warning System | 328d? | 2011-03-25 A | 2012-06-20 A | 100% | 2011-03-25 | 2012-06-20 | 328d? | finish no earlier than 2012-06-20 | C1 | 2624h | 2624h | PWS_Sec-del4 | PCG-26 | ST-Ericsson | mikael.wass@ericsson.com | Rel-12 | SP-51 | Frederic | Public Safety (I-A) |  |  | PCG-29 | SP-56 |
| 1606 | 399.7 | Deleted - RAN2 part for Security aspects of Public Warning System | 128d? | 2011-03-25 A | 2011-09-16 A | 100% | 2011-03-25 | 2011-09-16 | 128d? | start no earlier than 2011-03-25 | R2 | 1024h | 1024h | PWS_Sec-del5 | PCG-26 | ST-Ericsson | john.mattsson@ericsson.com | Rel-12 | SP-51 | Yong-Jun | Public Safety (I-A) |  |  | PCG-27 | RP-53 |
| 1607 | 400 | Security enhancements for usage of Generic Bootstrapping Architecture (GBA) from the browser (Stage 2) | 536d? | 2011-06-08 A | 2013-06-20 A | 100% | 2011-06-08 | 2013-06-19 | 536d? | finish no earlier than 2013-06-19 | S3 | 4256h | 4256h | Web_GBA | PCG-27 | Nokia | Silke.Holtmanns@nokia.com | Rel-12 | SP-52 | Mirko |  | Web_GBA |  |  |  |

Notes:
- 1578: - / Impacted TSs and TRs: Stage 2/3
- 1579: SP#63 completed / Impacted TSs and TRs: 23.402
- 1580: CP#62 updated WID CP-130580=>CP-130715 / Impacted TSs and TRs: Stage 3
- 1581: CP#65 completion 09/14=>12/14. Exception in CP-140608. TS 24.244 v200 for Approval. Dec.14: 95->100% / Impacted TSs and TRs: 24.302, New TS 24.244 (WLAN control plane protocol for trusted WLAN access to EPC)
- 1582: CP#65 completed / Impacted TSs and TRs: 29.273, 29.274, 29.275
- 1583: Linked to TR 23.890 Study on Optimized Offloading to WLAN in 3GPP-RAT mobility (FS_WORM), SAE for support for non-3GPP accesses, Multi-Access PDN Connectivity (MAPCON), IP Flow Mobility and Seamless WLAN Offload (IFOM), CS Fallback in EPS (SAES-CSFB) / Impacted TSs and TRs: Stage 2/3
- 1584: SP#62 completed / Impacted TSs and TRs: 23.272, 23.401, 23.402
- 1585: CP#64 completed. Stage 3 enabling differentiation/prioritization of 3GPP RATs relative to WLAN for traffic flow routing based on Inter-System Routing Policies / Impacted TSs and TRs: 24.302, 24.312
- 1586: Rel-11 Network Provided Location Information for IMS (NWK-PL2IMS) covers the case where UE is served by a 3GPP RAN. This WI covers the case where the UE is served by a TWAN / Impacted TSs and TRs: Stage 2/3
- 1587: SP#63 completed / Impacted TSs and TRs: 23.203, 23.228, 23.402
- 1588: - / Impacted TSs and TRs: Stage 3
- 1589: CP#64 completed / Impacted TSs and TRs: 29.212, 29.214
- 1590: CP#65 completed / Impacted TSs and TRs: 24.229
- 1591: CP#65 completed / Impacted TSs and TRs: 29.273, 29.274, 29.275, 29.328, 29.329
- 1592: - / Impacted TSs and TRs: Stage 2/3
- 1593: SP#63 completed / Impacted TSs and TRs: 23.060, 23.203, 23.401
- 1594: SP#65 New WID approved & completed. Introduction of Presence Reporting Areas for Charging / Impacted TSs and TRs: 32.251, 32.298, 32.299
- 1595: Specify Stage 3 procedures to support the ULI signalling optimizations / Impacted TSs and TRs: Stage 3
- 1596: CP#64 completed / Impacted TSs and TRs: 29.212, 29.213
- 1597: CP#65 completed / Impacted TSs and TRs: 23.008, 29.060, 29.274
- 1598: SEC12 is an umbrella Feature for Security related TEI12 type of changes that are not part of any other dedicated feature / Impacted TSs and TRs: Stage 2/3
- 1599: -
- 1600: SP#57 completed. Specify reqs to protect against false PWS Warning Notifications (Optional as not all regions/countries require this functionality). WID covers all objectivES in CP-150SA3 PWS_Sec Feature-level WID replacing the original Stage 1 UID_510154 / Impacted TSs and TRs: 22.268
- 1601: SP#65 completed. TR 33.969v100 for 1-step Approval. Former TR 33.869 changed to 33.969. / Impacted TSs and TRs: New TR 33.869 changed to 33.969
- 1602: SP#64 stopped / Impacted TSs and TRs: New TS 33.269
- 1603: Completed in Rel-9 under PWS. SP#55 stopped, Stage 1 requirements removed from Rel-9 onwards (SP-120172). AP 55/1: SA1 to align Stage 1 PWS security for Rel-12. SA1 new WID PWS Security UID_560029. / Impacted TSs and TRs: 22.268
- 1604: SP#53 work stopped as already done in previous releases / Impacted TSs and TRs: 23.401
- 1605: TSG#56 work stopped. SP#56 updated WID SP-110223=>SP-120334 (removed all but SA3 impacted specs) / Impacted TSs and TRs: 23.041
- 1606: RP#53 work stopped as no WI in RAN / Impacted TSs and TRs: 36.331
- 1607: SP#60 completed / Impacted TSs and TRs: 33.220, 33.222, New TR 33.823

| ID | WBS | Task | Duration | Start | Finish | Complete | Remaining | Baseline start | Baseline finish | Baseline duration | Total slack | Constraint | Resources | Work | Actual work | Acronym | PCG approved | WI rapporteur name | Release | TSG approved | MCC resp | Acronym_3GU_Export | Status Report |
| --- | --- | --- | --- | --- | --- | --- | --- | --- | --- | --- | --- | --- | --- | --- | --- | --- | --- | --- | --- | --- | --- | --- | --- |
| 1608 | 401 | **Extended IMS media plane security features** | 657d? | 2012-06-20 A | 2014-12-09 A | 100% |  | 2012-06-20 | 2014-12-10 | 655d? |  |  | S3; C4; C1; C3; IETF | 73585.2h | 73585.2h | eMEDIASEC | PCG-29 | Vodafone | Rel-12 | SP-56 | Mirko | eMEDIASEC |  |
| 1609 | 401.1 | SA3 part of Extended IMS media plane security features (Stage 2) | 530d? | 2012-06-20 A | 2014-06-18 A | 100% |  | 2012-06-20 | 2014-06-18 | 530d? |  | finish no earlier than 2014-06-18 | S3 | 4185.2h | 4185.2h | eMEDIASEC-SA3 | PCG-29 | Vodafone | Rel-12 | SP-56 | Mirko |  |  |
| 1610 | 401.2 | (IETF) SA3 part of Extended IMS media plane security features (RFC 7345) | 591d? | 2012-06-20 A | 2014-09-12 A | 100% |  | 2012-06-20 | 2014-12-10 | 654d? |  | finish no earlier than 2014-09-12 | S3-IETF | 4728h | 4728h | eMEDIASECSA3IETF | PCG-31 | christer.holmberg@ericsson.com | Rel-12 | SP-61 |  |  |  |
| 1611 | 401.3 | **CT aspects of Extended IMS media plane security features (Stage 2/3)** | 528d? | 2012-12-13 A | 2014-12-09 A | 100% |  | 2012-12-13 | 2014-12-05 | 523d? |  |  | C4; C1; C3; IETF | 38392h | 38392h | eMEDIASEC-CT | PCG-30 | Alcatel-Lucent | Rel-12 | CP-58 | Kimmo | eMEDIASEC-CT |  |
| 1612 | 401.3.1 | TR on Extended IMS media plane security features and TCP related NAT traversal support; IMS H.248 profiles aspects | 461d? | 2012-12-13 A | 2014-09-11 A | 100% |  | 2012-12-13 | 2014-09-12 | 461d? |  | finish no earlier than 2014-09-12 | C4 | 3688h | 3688h | eMEDIASEC-CT | PCG-30 | Alcatel-Lucent | Rel-12 | CP-58 | Kimmo |  |  |
| 1613 | 401.3.2 | CT4 part of CT aspects of Extended IMS media plane security features | 520d? | 2012-12-19 A | 2014-12-09 A | 100% |  | 2012-12-19 | 2014-09-12 | 458d? |  | finish no earlier than 2014-12-09 | C4 | 4160h | 4160h | eMEDIASEC-CT | PCG-30 | Alcatel-Lucent | Rel-12 | CP-58 | Kimmo |  | CP-140479 |
| 1614 | 401.3.3 | (IETF) CT4 part of Extended IMS media plane security features (RFC 7345) | 457d? | 2012-12-18 A | 2014-09-11 A | 100% |  | 2012-12-18 | 2014-12-05 | 519d? |  | finish no earlier than 2014-09-11 | C4-IETF | 3656h | 3656h | eMEDIASEC-CT | PCG-32 | christer.holmberg@ericsson.com | Rel-12 | CP-62 |  |  |  |
| 1615 | 401.3.4 | (IETF) CT4 part of Extended IMS media plane security features (draft-schwarz-mmusic-sdp-for-gw) | 129d? | 2014-06-12 A | 2014-12-09 A | 100% |  | 2014-06-12 | 2014-12-05 | 127d? |  | finish no earlier than 2014-12-09 | C4-IETF | 1032h | 1032h | eMEDIASEC-CT | PCG-33 | christer.holmberg@ericsson.com | Rel-12 | CP-64 |  |  |  |
| 1616 | 401.3.5 | CT1 part of CT aspects of Extended IMS media plane security features | 463d? | 2012-12-13 A | 2014-09-11 A | 100% |  | 2012-12-13 | 2014-09-12 | 463d? |  | finish no earlier than 2014-09-12 | C1 | 3696h | 3696h | eMEDIASEC-CT | PCG-30 | Alcatel-Lucent | Rel-12 | CP-58 | Frederic |  |  |
| 1617 | 401.3.6 | (IETF) CT1 part of Extended IMS media plane security features (RFC 7345) | 137d? | 2014-03-06 A | 2014-09-11 A | 100% |  | 2014-03-06 | 2014-12-05 | 197d? |  | finish no earlier than 2014-09-11 | C1-IETF | 1096h | 1096h | eMEDIASEC-CT | PCG-32 | christer.holmberg@ericsson.com | Rel-12 | CP-62 |  |  |  |
| 1618 | 401.3.7 | CT3 part of CT aspects of Extended IMS media plane security features | 521d? | 2012-12-19 A | 2014-12-09 A | 100% |  | 2012-12-19 | 2014-06-13 | 394d? |  | finish no earlier than 2014-12-09 | C3 | 4168h | 4168h | eMEDIASEC-CT | PCG-30 | Alcatel-Lucent | Rel-12 | CP-58 | Adrian |  | CP-140569 |
| 1619 | 402 | Lawful Interception in the 3GPP Rel-12 | 592d? | 2012-09-17 A | 2014-12-12 A | 100% |  | 2012-09-17 | 2014-09-12 | 526d? |  | finish no earlier than 2014-12-12 | S3 | 4736h | 4736h | LI12 | PCG-29 | PIDS, Alcatel-Lucent | Rel-12 | SP-57 | Mirko | LI12 |  |
| 1620 | 403 | **Tunneling of UE Services over Restrictive Access Networks (Stage 2/3)** | 401d? | 2012-12-13 A | 2014-06-18 A | 100% |  | 2012-12-13 | 2014-06-18 | 401d? |  |  | S3; C1 | 11662.5h | 11662.5h | TURAN | PCG-30 | Acme Packet | Rel-12 | SP-58 | Mirko | TURAN |  |
| 1621 | 403.1 | SA3 part of Tunneling of UE Services over Restrictive Access Networks (Stage 2/3) | 400d? | 2012-12-13 A | 2014-06-18 A | 100% |  | 2012-12-13 | 2014-06-18 | 400d? |  | finish no earlier than 2014-06-18 | S3 | 3168h | 3168h | TURAN-SA3 | PCG-30 | Acme Packet | Rel-12 | SP-58 | Mirko |  |  |
| 1622 | 403.2 | CT aspects of Tunneling of UE Services over Restrictive Access Networks (Stage 3) | 264d? | 2013-06-14 A | 2014-06-13 A | 100% |  | 2013-06-14 | 2014-06-13 | 264d? |  | finish no earlier than 2014-06-13 | C1 | 2094.45h | 2094.45h | TURAN-CT | PCG-31 | Huawei | Rel-12 | CP-60 | Frederic | TURAN-CT |  |
| 1623 | 404 | Specification of the TUAK Algorithm Set | 139d? | 2013-12-09 A | 2014-06-18 A | 100% |  | 2013-12-09 | 2014-06-18 | 139d? |  | finish no earlier than 2014-06-18 | S3 | 1112h | 1112h | STAS | PCG-32 | Vodafone | Rel-12 | SP-62 | Mirko | STAS |  |
| 1624 | 405 | **Codec for Enhanced Voice Services** | 1575d? | 2010-03-25 A | 2016-03-15 | 99% | 0d? | 2010-03-25 | 2014-12-12 | 1245d? | 0d |  | S4; S1; C4; C1; C3 | 87912h | 24952h | EVS_codec | PCG-24 | Huawei | Rel-12 | SP-47 | Paolo | EVS_codec |  |
| 1625 | 405.1 | Stage 1 for Codec for Enhanced Voice Services | 1d? | 2010-03-25 A | 2010-03-25 A | 100% |  | 2010-03-25 | 2010-03-25 | 1d? |  | start no earlier than 2010-03-25 | S1 | 8h | 8h | EVS_codec-SA1 | PCG-24 | Huawei | Rel-12 | SP-47 | Paolo |  |  |
| 1626 | 405.2 | Stage 2/3 for Codec for Enhanced Voice Services | 1240d? | 2010-03-25 A | 2014-12-12 A | 100% |  | 2010-03-25 | 2014-09-17 | 1178d? |  | finish no earlier than 2014-12-12 | S4 | 9896h | 9896h | EVS_codec-SA4 | PCG-24 | Huawei | Rel-12 | SP-47 | Paolo |  | SP-140467 |
| 1627 | 405.3 | TR on Performance characterization of Codec for Enhanced Voice Services | 1239d? | 2010-03-25 A | 2014-12-12 A | 100% |  | 2010-03-25 | 2014-12-12 | 1239d? |  | finish no earlier than 2014-12-12 | S4 | 9888h | 9888h | EVS_codec-SA4TR | PCG-24 | Huawei | Rel-12 | SP-47 | Paolo |  | SP-140467 |
| 1628 | 405.4 | **CT impacts of codec for Enhanced Voice Services** | 63d? | 2014-09-16 A | 2014-12-09 A | 100% |  |  |  |  |  |  | C4; C1; C3 | 3024h | 3024h | EVS_codec-CT | PCG-33 | Nokia Networks | Rel-12 | CP-65 |  | EVS_codec-CT |  |
| 1629 | 405.4.1 | CT4 part of CT impacts of codec for Enhanced Voice Services | 63d? | 2014-09-16 A | 2014-12-09 A | 100% |  |  |  |  |  | finish no earlier than 2014-12-09 | C4 | 504h | 504h | EVS_codec-CT | PCG-33 | Nokia Networks | Rel-12 | CP-65 |  |  | CP-140478 |
| 1630 | 405.4.2 | CT1 part of CT impacts of codec for Enhanced Voice Services | 63d? | 2014-09-16 A | 2014-12-09 A | 100% |  |  |  |  |  | finish no earlier than 2014-12-09 | C1 | 504h | 504h | EVS_codec-CT | PCG-33 | Nokia Networks | Rel-12 | CP-65 |  |  | CP-140618 |
| 1631 | 405.4.3 | CT3 part of CT impacts of codec for Enhanced Voice Services | 63d? | 2014-09-16 A | 2014-12-09 A | 100% |  |  |  |  |  | finish no earlier than 2014-12-09 | C3 | 504h | 504h | EVS_codec-CT | PCG-33 | Nokia Networks | Rel-12 | CP-65 |  |  | CP-140560 |
| 1632 | 405.5 | UE Conformance Test Aspects - Codec for Enhanced Voice Services (EVS) | 262d? | 2015-03-16 A | 2016-03-15 A | 100% |  |  |  |  |  | finish no earlier than 2016-03-15 | R5 | 2096h | 2096h | EVS_codec-UEConTest | PCG-34 | Ericsson | Rel-12 | RP-67 |  |  | RP-151164 |

Notes:
- 1608: Triggered by Rel-11 TR 33.829 Study on Extended IMS media plane security features (FS_eMEDIASEC) / Impacted TSs and TRs: Stage 2/3 / WI rapporteur e-mail: Aguibou.Barry@vodafone.com
- 1609: SP#64 completed / Impacted TSs and TRs: 33.328 / WI rapporteur e-mail: Aguibou.Barry@vodafone.com
- 1610: SP#65 completed / Impacted TSs and TRs: RFC 7345 (was draft-ietf-mmusic-udptl-dtls) / WI rapporteur e-mail: christer.holmberg@ericsson.com
- 1611: - / Impacted TSs and TRs: Stage 2/3 / WI rapporteur e-mail: bruno.landais@alcatel-lucent.com
- 1612: CP#65 completed. TR 29.828v200 for Approval. 2/4/15: acronym changed to eMEDIASEC-CT / Impacted TSs and TRs: New TR 29.828 / WI rapporteur e-mail: bruno.landais@alcatel-lucent.com
- 1613: CP#65 completion 09/14=>12/14. Exception in CP-140479. Dec.14: 90->100. 2/4/15: acronym changed to eMEDIASEC-CT / Impacted TSs and TRs: 23.334, 29.334, 29.238, 23.333, 29.333 / WI rapporteur e-mail: bruno.landais@alcatel-lucent.com
- 1614: CP#65 completed. 2/4/15: acronym changed to eMEDIASEC-CT / Impacted TSs and TRs: RFC 7345 (was draft-ietf-mmusic-udptl-dtls) / WI rapporteur e-mail: christer.holmberg@ericsson.com
- 1615: Work in progress. 2/4/15: acronym changed to eMEDIASEC-CT / Impacted TSs and TRs: draft-schwarz-mmusic-sdp-for-gw / WI rapporteur e-mail: christer.holmberg@ericsson.com
- 1616: CP#65 completed. 2/4/15: acronym changed to eMEDIASEC-CT / Impacted TSs and TRs: 23.218, 24.147, 24.229, 24.247 / WI rapporteur e-mail: bruno.landais@alcatel-lucent.com
- 1617: CP#65 completed. 2/4/15: acronym changed to eMEDIASEC-CT / Impacted TSs and TRs: RFC 7345 (was draft-ietf-mmusic-udptl-dtls) / WI rapporteur e-mail: christer.holmberg@ericsson.com
- 1618: CP#65 completion 06/14=>12/14. Level 100%=>80%. Exception in CP-140569. CP#64 completed. Dec.14: 80->100. 2/4/15: acronym changed to eMEDIASEC-CT / Impacted TSs and TRs: 29.162 / WI rapporteur e-mail: bruno.landais@alcatel-lucent.com
- 1619: 3/3/15: 75->100% / Impacted TSs and TRs: 33.106, 33.107, 33.108 / WI rapporteur e-mail: Koen Jaspers (k.b.jaspers@minjus.nl), terry.jacobson@alcatel-lucent.com
- 1620: Linked to Rel-12 SMURFs. Related to TS 22.278 (EPS) cl.7.1.8 Service Reachability (Firewall traversal for IP based services for non-3GPP access), TS 22.228 (IMS) cl.5 (support Firewall traversal), TR 33.830 (Study on Firewall traversal) / Impacted TSs and TRs: Stage 2/3 / WI rapporteur e-mail: Prashant Kumar (PKumar@acmepacket.com)
- 1621: SP#64 completed / Impacted TSs and TRs: 33.203, 33.402 / WI rapporteur e-mail: Prashant Kumar (PKumar@acmepacket.com)
- 1622: CP#64 completed. Stage 3 for 2 new SA3 solutions for firewall traversal: 1) UE access to PLMN IP-based services via restrictive non-3GPP Ans, 2) UE access to IMS services via restrictive ANs / Impacted TSs and TRs: 24.229, 24.302, New TS 24.322 / WI rapporteur e-mail: Haitao Wei (weihaitao@huawei.com)
- 1623: SP#64 completed. Triggered by SP-130602 LS from ETSI SAGE (TUAK as alternative to Milenage). 12/14: new TS added / Impacted TSs and TRs: New TSs: 35.231, 35.232, 35.233, TR 35.9nn, TR 35.9nn, TR 35.9nn / WI rapporteur e-mail: aguibou.barry@vodafone.com
- 1624: Triggered by UID_370045 Study on enhanced voice service requirements for EPS (TR 22.813) / WI rapporteur e-mail: lei.miao@huawei.com
- 1625: SP#47 completed / Impacted TSs and TRs: 22.173 / WI rapporteur e-mail: lei.miao@huawei.com
- 1626: SP#65 completion 09/14=>12/14. Exception in SP-140467. TS 26.441v200 for Approval. TSs 26.442/44/45/46/47/48/49/50/51v100 for 1-step Approval. Ongoing TS 26.443 EVS Codec ANSI C code (floating point). Dec.14: 90->95 / Impacted TSs and TRs: 26.114, New TS (26.441, 26.442, 26.443, 26.444, 26.445, 26.446, 26.447, 26.448, 26.449, 26.450, 26.451) / WI rapporteur e-mail: lei.miao@huawei.com
- 1627: SP#65 completion 09/14=>12/14. Ongoing TR 26.952 EVS Codec Performance Characterization. Exception in SP-140467 / Impacted TSs and TRs: New TR 26.952 / WI rapporteur e-mail: lei.miao@huawei.com
- 1628: Stage 3; WID: CP-140492-> CP-140800 / WI rapporteur e-mail: Jan.Kall@nsn.com
- 1629: CP#65 exception in CP-140478. Dec.14: 0->100; WID: CP-140492-> CP-140800 / Impacted TSs and TRs: 23.334, 29.232, 29.238, 29.332, 29.333, 29.334 / WI rapporteur e-mail: Jan.Kall@nsn.com
- 1630: CP#65 exception in CP-140618. Dec.14: 0->100%; WID: CP-140492-> CP-140800 / Impacted TSs and TRs: 24.229 / WI rapporteur e-mail: Jan.Kall@nsn.com
- 1631: CP#65 exception in CP-140560. Dec.14: 20->100; WID: CP-140492-> CP-140800 / Impacted TSs and TRs: 29.163, 29.292 / WI rapporteur e-mail: Jan.Kall@nsn.com
- 1632: 03/07/15: Compl:0%->25% 03/07/15: WID: RP-150137->RP-150836 03/07/15: Stat Rep: ->RP-150831 29/09/15: Compl:25%->75% 29/09/15: Stat Rep: RP-150831->RP-1511641/1/16: Compl:75%->95%1/1/16: CD:Tue 15/12/15->Tue 15/03/16;...

| ID | WBS | Task | Duration | Start | Finish | Complete | Remaining | Baseline start | Baseline finish | Baseline duration | Total slack | Constraint | Resources | Work | Actual work | Acronym | PCG approved | WI rapporteur name | WI rapporteur e-mail | Release | TSG approved | MCC resp | Acronym_3GU_Export | Impacted TSs and TRs | Status Report |
| --- | --- | --- | --- | --- | --- | --- | --- | --- | --- | --- | --- | --- | --- | --- | --- | --- | --- | --- | --- | --- | --- | --- | --- | --- | --- |
| 1633 | 406 | **Coordination of Video Orientation** | 400d? | 2012-06-07 A | 2013-12-06 A | 100% |  | 2012-06-07 | 2013-12-06 | 400d? |  |  | S4; C4; C1; C3 | 20496.8h | 20496.8h | CVO | PCG-29 | Ericsson | frederic.gabin@ericsson.com | Rel-12 | SP-56 | Paolo | CVO |  |  |
| 1634 | 406.1 | SA4 part of Coordination of Video Orientation | 196d? | 2012-06-07 A | 2013-03-06 A | 100% |  | 2012-06-07 | 2013-03-06 | 196d? |  | finish no earlier than 2013-03-06 | S4 | 1560h | 1560h | CVO-SA4 | PCG-29 | Ericsson | frederic.gabin@ericsson.com | Rel-12 | SP-56 | Paolo |  | 26.114, 26.141, 26.234, 26.346 |  |
| 1635 | 406.2 | **CT aspects of Coordination of Video Orientation** | 129d? | 2013-06-14 A | 2013-12-06 A | 100% |  | 2013-06-14 | 2013-12-06 | 129d? |  |  | C4; C1; C3 | 6136.8h | 6136.8h | CVO-CT | PCG-31 | Ericsson | nevenka.biondic@ericsson.com | Rel-12 | CP-60 | Kimmo | CVO-CT | Stage 2/3 |  |
| 1636 | 406.2.1 | CT4 part of CT aspects of Coordination of Video Orientation | 128.05d? | 2013-06-14 A | 2013-12-06 A | 100% |  | 2013-06-14 | 2013-12-06 | 128.05d? |  | finish no earlier than 2013-12-06 | C4 | 1008.4h | 1008.4h | CVO-CT | PCG-31 | Ericsson | nevenka.biondic@ericsson.com | Rel-12 | CP-60 | Kimmo |  | 23.333, 23.334, 29.238, 29.332, 29.333, 29.334 |  |
| 1637 | 406.2.2 | CT1 part of CT aspects of Coordination of Video Orientation | 129d? | 2013-06-14 A | 2013-12-06 A | 100% |  | 2013-06-14 | 2013-12-06 | 129d? |  | finish no earlier than 2013-12-06 | C1 | 1016h | 1016h | CVO-CT | PCG-31 | Ericsson | nevenka.biondic@ericsson.com | Rel-12 | CP-60 | Frederic |  | 24.229 |  |
| 1638 | 406.2.3 | CT3 part of CT aspects of Coordination of Video Orientation | 127.05d? | 2013-06-14 A | 2013-12-06 A | 100% |  | 2013-06-14 | 2013-12-06 | 127.05d? |  | finish no earlier than 2013-12-06 | C3 | 1016.4h | 1016.4h | CVO-CT | PCG-31 | Ericsson | nevenka.biondic@ericsson.com | Rel-12 | CP-60 | Adrian |  | 29.162, 29.163 |  |
| 1639 | 407 | **High Efficiency Video Coding** | 594d? | 2012-09-12 A | 2014-12-05 | 99% | 0d? | 2012-09-12 | 2014-12-05 | 591d? | 0d |  | S4; IETF | 21576h | 15856h | HEVC | PCG-29 | Qualcomm | Ye-Kui Wang (yekuiw@qti.qualcomm.com) | Rel-12 | SP-57 | Paolo | HEVC |  |  |
| 1640 | 407.1 | TR on Evaluation of High Efficiency Video Coding for 3GPP Services | 464d? | 2012-09-12 A | 2014-06-19 A | 100% |  | 2012-09-12 | 2014-06-19 | 464d? |  | finish no earlier than 2014-06-18 | S4 | 3704h | 3704h | HEVC-SA4TR | PCG-29 | Qualcomm | Ye-Kui Wang (yekuiw@qti.qualcomm.com) | Rel-12 | SP-57 | Paolo |  | New TR 26.906 |  |
| 1641 | 407.2 | High Efficiency Video Coding in 3GPP services PSS, MBMS, DASH, MMS, MTSI, IMS Messaging and Presence | 462d? | 2012-09-17 A | 2014-06-18 A | 100% |  | 2012-09-17 | 2014-06-18 | 462d? |  | finish no earlier than 2014-06-18 | S4 | 3688h | 3688h | HEVC-SA4 | PCG-29 | Qualcomm | Ye-Kui Wang (yekuiw@qti.qualcomm.com) | Rel-12 | SP-57 | Paolo |  | 26.114, 26.140, 26.141, 26.234, 26.244, 26.247, 26.346 |  |
| 1642 | 407.3 | (IETF) High Efficiency Video Coding | 587d? | 2012-09-17 A | 2014-12-05 A | 100% |  | 2012-09-17 | 2014-12-05 | 587d? |  | finish no earlier than 2014-12-05 | S4-IETF | 4696h | 4696h | HEVC-SA4IETF | PCG-32 | Thomas Stockhammer, Qualcomm Incorporated | tsto@qti.qualcomm.com | Rel-12 | CP-63 |  |  | draft-ietf-payload-rtp-h265 |  |
| 1643 | 408 | Mobile stereoscopic 3D services extensions | 200d? | 2012-12-12 A | 2013-09-11 A | 100% |  | 2012-12-12 | 2013-09-11 | 200d? |  | finish no earlier than 2013-09-11 | S4 | 1568h | 1568h | M3DV_Ext | PCG-30 | Huawei | lukasz.kondrad@huawei.com | Rel-12 | SP-58 | Paolo | M3DV_Ext | 26.114, 26.245, 26.247, 26.430 |  |
| 1644 | 409 | **IMS-based Streaming and Download Delivery Enhancements** | 329d? | 2012-12-12 A | 2014-03-07 A | 100% |  | 2012-12-12 | 2014-03-07 | 329d? |  |  | S4 | 7800h | 7800h | IMS_SDE | PCG-30 | Intel | ozgur.oyman@intel.com | Rel-12 | SP-58 | Paolo | IMS_SDE |  |  |
| 1645 | 409.1 | TR on IMS-based Streaming and Download Delivery Enhancements | 326d? | 2012-12-12 A | 2014-03-07 A | 100% |  | 2012-12-12 | 2014-03-07 | 326d? |  | finish no earlier than 2014-03-07 | S4 | 2584h | 2584h | IMS_SDE-SA4TR | PCG-30 | Intel | ozgur.oyman@intel.com | Rel-12 | SP-58 | Paolo |  | new TR 26.827 |  |
| 1646 | 409.2 | Specification on IMS-based Streaming and Download Delivery Enhancements | 327d? | 2012-12-13 A | 2014-03-07 A | 100% |  | 2012-12-13 | 2014-03-07 | 327d? |  | finish no earlier than 2014-03-07 | S4 | 2584h | 2584h | IMS_SDE-SA4 | PCG-30 | Intel | ozgur.oyman@intel.com | Rel-12 | SP-58 | Paolo |  | 26.237 |  |
| 1647 | 410 | **Acoustic Requirements and Test methods for IMS-based conversational speech services over LTE** | 532d? | 2012-12-12 A | 2014-12-12 A | 100% |  | 2012-12-12 | 2014-09-17 | 467d? |  |  | S4 | 14224h | 14224h | ART_LTE | PCG-30 | Qualcomm | Andre Schevciw (aschevci@qualcomm.com) | Rel-12 | SP-58 | Paolo | ART_LTE | Stage 3 |  |
| 1648 | 410.1 | Acoustic Requirements and Test methods for IMS-based conversational speech services over LTE - NarrowBand and WideBand aspects | 265d? | 2012-12-12 A | 2013-12-11 A | 100% |  | 2012-12-12 | 2013-12-11 | 265d? |  | finish no earlier than 2013-12-11 | S4 | 2088h | 2088h | ART_LTE-NBWB | PCG-30 | Sony Mobile Communications | peter.isberg@sonymobile.com | Rel-12 | SP-58 | Paolo | ART_LTE-NBWB | 26.131, 26.132 |  |
| 1649 | 410.2 | Acoustic Requirements and Test methods for IMS-based conversational speech services over LTE - UE Delay aspects | 462d? | 2012-12-12 A | 2014-09-17 A | 100% |  | 2012-12-12 | 2014-09-17 | 461d? |  | finish no earlier than 2014-09-17 | S4 | 3696h | 3696h | ART_LTE-UED | PCG-30 | AT&T, Orange | luisa.marchetto@att.com, stephane.ragot@orange.com | Rel-12 | SP-58 | Paolo | ART_LTE-UED | 26.131, 26.132 |  |
| 1650 | 410.3 | Acoustic Requirements and Test methods for IMS-based conversational speech services over LTE - Super wideband and fullband aspects | 523d? | 2012-12-12 A | 2014-12-12 A | 100% |  | 2012-12-12 | 2014-09-17 | 461d? |  | finish no earlier than 2014-12-12 | S4 | 4184h | 4184h | ART_LTE-SUPER | PCG-30 | Sony Mobile Communications | peter.isberg@sonymobile.com | Rel-12 | SP-58 | Paolo | ART_LTE-SUPER | 26.131, 26.132 | SP-140470 |
| 1651 | 411 | **MBMS Improvements** | 471d? | 2013-03-06 A | 2014-12-12 A | 100% |  | 2013-03-06 | 2014-09-17 | 406d? |  |  | S4 | 18584h | 18584h | MI | PCG-30 | Ericsson | eric.turcotte@ericsson.com | Rel-12 | SP-59 | Paolo | MI |  | SP-140471 |
| 1652 | 411.1 | TR on Enhanced MBMS Operation | 463d? | 2013-03-06 A | 2014-12-12 A | 100% |  | 2013-03-06 | 2014-09-17 | 401d? |  | finish no earlier than 2014-12-12 | S4 | 3704h | 3704h | MI-EMOTR | PCG-30 | Huawei | Zhiming Li (lizhiming@huawei.com) | Rel-12 | SP-59 | Paolo |  | New TR 26.848 | SP-140471 |
| 1653 | 411.2 | Enhanced MBMS Operation | 463d? | 2013-03-06 A | 2014-12-12 A | 100% |  | 2013-03-06 | 2014-09-17 | 401d? |  | finish no earlier than 2014-12-12 | S4 | 3704h | 3704h | MI-EMO | PCG-30 | Huawei | Zhiming Li (lizhiming@huawei.com) | Rel-12 | SP-59 | Paolo | MI-EMO | 26.247, 26.346 | SP-140471 |
| 1654 | 411.3 | TR on MBMS operation on Demand | 463d? | 2013-03-06 A | 2014-12-12 A | 100% |  | 2013-03-06 | 2014-09-17 | 401d? |  | finish no earlier than 2014-12-12 | S4 | 3704h | 3704h | MI-MooDTR | PCG-30 | Qualcomm | Charles Lo (clo@qti.qualcomm.com) | Rel-12 | SP-59 | Paolo |  | New TR 26.849 | SP-140471 |
| 1655 | 411.4 | MBMS operation on Demand | 463d? | 2013-03-06 A | 2014-12-12 A | 100% |  | 2013-03-06 | 2014-09-17 | 401d? |  | finish no earlier than 2014-12-12 | S4 | 3704h | 3704h | MI-MooD | PCG-30 | Qualcomm | Charles Lo (clo@qti.qualcomm.com) | Rel-12 | SP-59 | Paolo | MI-MooD | 26.346 | SP-140471 |
| 1656 | 412 | **End-to-End Multimedia Telephony Service for IMS (MTSI) extensions** | 667d? | 2013-03-06 A | 2015-09-14 A | 100% |  | 2013-03-06 | 2015-03-13 | 533d? |  |  | S4 | 32648h | 32648h | E2EMTSI | PCG-30 | Ericsson | tomas.frankkila@ericsson.com | Rel-12 | SP-59 | Paolo | E2EMTSI | 26.114 |  |
| 1657 | 412.1 | S4 aspects of End-to-End Multimedia Telephony Service for IMS (MTSI) extensions | 406d? | 2013-03-06 A | 2014-09-16 A | 100% |  | 2013-03-06 | 2015-03-13 | 533d? |  | finish no earlier than 2014-09-17 | S4 | 3248h | 3248h | E2EMTSI | PCG-30 | Ericsson | tomas.frankkila@ericsson.com | Rel-12 | SP-59 | Paolo | E2EMTSI | 26.114 |  |

Notes:
- 1633: CP#62 completed. Resolve backward compatible video orientation mis-alignment in MTSI real-time video communication via interaction between MTSI video clients at call setup & during mid-call of the video orientation for correct local rendering
- 1634: SP#59 completed. Resolve backward compatible video orientation mis-alignment in MTSI real-time video communication via interaction between MTSI video clients at call setup & during mid-call of the video orientation for correct local rendering
- 1635: Complete CVO support (both, basic 2 bit orientation and additional option for extra 6 bit granularity) within CN protocols/procedures for IMS nodes, e.g. IMS ALG/AGW,IBCF/TrGW,MRFC/MRFP & add support of CVO-related SDP attributes to be negotiated by UE
- 1636: CP#62 completed
- 1637: CP#62 completed
- 1638: CP#62 completed
- 1639: Specify the support of HEVC in 3GPP services (PSS, DASH, MTSI, MMS, MBMS, IMS Messaging and Presence)
- 1640: SP#64 completed. TR 26.906v200 for Approval
- 1641: SP#64 completed
- 1642: Submitted to IESG for publication. 7/10/15: Rapporteur added; 7/3/16: 50%->95; 13/6/16: 95%->100
- 1643: SP#61 completed. Related to Rel-11 Study On Mobile 3D Video Coding (FS_M3DVC) TR 26.905 and Rel-11 Mobile 3D Video Coding (M3DVC)
- 1644: Provide an extension of IMS based PSS and MBMS user services
- 1645: SP#63 completed. Identify use cases and requirements based on Rel-10/11 PSS and MBMS functionality to be addressed for IMS-based streaming and download enhancements
- 1646: SP#63 completed. Develop procedures towards enabling the IMS-based extensions of the identified use casES in CP-150TS 26.237. Refine existing MBMS download procedures to enable IMS-based MBMS file repair with the use of conventional HTTP web servers.
- 1647: Triggered by Rel-12 Feature Codec for Enhanced Voice Services (EVS_codec) UID_470030. Need for super wideband acoustic requirements and test methods
- 1648: SP#62 completed
- 1649: SP#65 completed
- 1650: SP#65 completion 09/14=>12/14. Exception in SP-140470. Dec.14: 65->100
- 1651: Stage 3 based on existing Stage 2 in TS 23.246 MBMS Architecture and functional description
- 1652: SP#65 completion 09/14=>12/14. Exception in SP-140471. SP#63 TR 26.848v100 for Information. Dec.14: 85->100.
- 1653: SP#65 completion 09/14=>12/14. Exception in SP-140471. Dec.14: 85->100
- 1654: SP#65 completion 09/14=>12/14. Exception in SP-140471. SP#63 TR 26.849v100 for Information. Dec.14: 75->100
- 1655: SP#65 completion 09/14=>12/14. Exception in SP-140471. Dec.14: 75->100
- 1656: SP#65 completed. Updated WID SP-130670=>SP-140594. Reduced Scope & Objectives. Moved work on new TR 26.924, etc. to Rel-13. Co-ordinate with CT1/3/4. Linked to SA4 Rel-7 Media handling and interaction in MTSI (MTSI-MHI) UID_7040
- 1657: SP#65 completed. Updated WID SP-130670=>SP-140594. Reduced Scope & Objectives. Moved work on new TR 26.924, etc. to Rel-13. Co-ordinate with CT1/3/4. Linked to SA4 Rel-7 Media handling and interaction in MTSI (MTSI-MHI) UID_7040

| ID | WBS | Task | Duration | Start | Finish | Complete | Baseline start | Baseline finish | Baseline duration | Constraint | Resources | Work | Actual work | Acronym | PCG approved | WI rapporteur name | WI rapporteur e-mail | Release | TSG approved | MCC resp | Acronym_3GU_Export | Special Focus Doc | Status Report | TSG stopped |
| --- | --- | --- | --- | --- | --- | --- | --- | --- | --- | --- | --- | --- | --- | --- | --- | --- | --- | --- | --- | --- | --- | --- | --- | --- |
| 1658 | 412.2 | **CT aspects of End-to-End Multimedia Telephony Service for IMS (MTSI) extensions** | 589d? | 2013-06-21 A | 2015-09-14 A | 100% | 2013-06-20 | 2014-09-12 | 326d? |  | C3; C1; C4 | 24064h | 24064h | E2EMTSI-CT | PCG-31 | Ericsson | susana.fernandez@ericsson.com | Rel-12 | CP-60 | Adrian |  |  |  |  |
| 1659 | 412.2.1 | CT3 part of CT aspects of End-to-End Multimedia Telephony Service for IMS (MTSI) extensions | 589d? | 2013-06-21 A | 2015-09-14 A | 100% | 2013-06-20 | 2014-09-12 | 326d? | finish no earlier than 2015-09-14 | C3 | 4712h | 4712h | E2EMTSI-CT | PCG-31 | Ericsson | susana.fernandez@ericsson.com | Rel-12 | CP-60 | Adrian |  |  |  |  |
| 1660 | 412.2.2 | CT1 part of CT aspects of End-to-End Multimedia Telephony Service for IMS (MTSI) extensions | 326d? | 2013-06-21 A | 2014-09-12 A | 100% | 2013-06-20 | 2014-09-12 | 326d? | finish no earlier than 2014-09-12 | C1 | 2608h | 2608h | E2EMTSI-CT | PCG-31 | Ericsson | susana.fernandez@ericsson.com | Rel-12 | CP-60 | Frederic |  |  |  |  |
| 1661 | 412.2.3 | CT4 part of CT aspects of End-to-End Multimedia Telephony Service for IMS (MTSI) extensions | 326d? | 2013-06-21 A | 2014-09-12 A | 100% | 2013-06-20 | 2014-09-12 | 326d? | finish no earlier than 2014-09-12 | C4 | 2608h | 2608h | E2EMTSI-CT | PCG-31 | Ericsson | susana.fernandez@ericsson.com | Rel-12 | CP-60 | Kimmo |  |  |  |  |
| 1662 | 413 | Video Coding Enhancements in IMS Messaging and Presence | 64d? | 2013-12-11 A | 2014-03-07 A | 100% | 2013-12-11 | 2014-03-07 | 64d? | finish no earlier than 2014-03-07 | S4 | 504h | 504h | VCEIMP | PCG-32 | Ericsson | frederic.gabin@ericsson.com | Rel-12 | SP-62 | Paolo | VCEIMP |  |  |  |
| 1663 | 414 | Video Telephony Robustness Improvements | 66d? | 2014-06-18 A | 2014-09-16 A | 100% | 2014-06-18 | 2014-09-17 | 66d? | finish no earlier than 2014-09-17 | S4 | 528h | 528h | VTRI | PCG-33 | Qualcomm | Muhammed Coban (mcoban@qti.qualcomm.com) | Rel-12 | SP-64 |  | VTRI |  |  |  |
| 1664 | 415 | **Rel-12 Operations, Administration, Maintenance and Provisioning (OAM&P)** | 857d? | 2011-09-21 A | 2014-12-12 A | 100% | 2011-09-21 | 2014-09-17 | 792d? |  | S5 | 58352.5h | 58352.5h | OAM12 | PCG-29 |  |  | Rel-12 | SP-56 | Mirko | OAM12 |  |  |  |
| 1665 | 415.1 | **Rel-12 Self-Organizing Networks (SON) - OAM aspects** | 591d? | 2011-09-21 A | 2013-12-11 A | 100% | 2011-09-21 | 2013-12-11 | 591d? |  | S5 | 9408h | 9408h | OAM12-SON | PCG-29 |  |  | Rel-12 | SP-56 | Mirko | OAM12-SON | HNB, SON |  |  |
| 1666 | 415.1.1 | Multi-vendor Plug and Play eNB connection to the network | 586d? | 2011-09-21 A | 2013-12-11 A | 100% | 2011-09-21 | 2013-12-11 | 586d? | finish no earlier than 2013-12-11 | S5 | 4680h | 4680h | SON-NM-MUPPET | PCG-29 | NSN | anatoly.andrianov@nsn.com | Rel-12 | SP-56 | Mirko | SON-NM-MUPPET | HNB, SON |  |  |
| 1667 | 415.2 | **Compliance of 3GPP SA5 specifications to the NGMN Next Generation Converged Operations Requirements (NGCOR)** | 596d? | 2012-06-20 A | 2014-09-17 A | 100% | 2012-06-20 | 2014-09-17 | 595d? |  | S5 | 11616.5h | 11616.5h | OAM-NGMN_NGCOR | PCG-29 | Huawei | christian.toche@huawei.com | Rel-12 | SP-56 | Mirko | OAM-NGMN_NGCOR |  |  |  |
| 1668 | 415.2.1 | Converged Management Model Alignment (Phase 2) | 593d? | 2012-06-20 A | 2014-09-17 A | 100% | 2012-06-20 | 2014-09-17 | 593d? | finish no earlier than 2014-09-17 | S5 | 4744h | 4744h | OAM-MODAL | PCG-29 | NSN | olaf.pollakowski@nsn.com | Rel-12 | SP-56 | Mirko | OAM-MODAL |  |  |  |
| 1669 | 415.2.2 | 3GPP Fault Management Solution Profile for NGMN NGCOR | 266d? | 2012-06-20 A | 2013-06-19 A | 100% | 2012-06-20 | 2013-06-19 | 266d? | finish no earlier than 2013-06-19 | S5 | 2104.53h | 2104.53h | OAM-FMSP | PCG-29 | Ericsson | thomas.tovinger@ericsson.com | Rel-12 | SP-56 | Mirko | OAM-FMSP |  |  |  |
| 1670 | 415.3 | **Network Management for 3GPP Interworking WLAN** | 793d? | 2011-09-21 A | 2014-09-17 A | 100% | 2011-09-21 | 2014-06-18 | 727d? |  | S5 | 17232h | 17232h | OAM-IWLAN | PCG-27 | China Mobile | Chengang@chinamobile.com, lijian@chinamobile.com | Rel-12 | SP-53 | Mirko | OAM-IWLAN | WLAN |  |  |
| 1671 | 415.3.1 | Performance measurements part Network Management for 3GPP Interworking WLAN | 785d? | 2011-09-22 A | 2014-09-17 A | 100% | 2011-09-22 | 2014-06-18 | 720d? | finish no earlier than 2014-09-17 | S5 | 6272h | 6272h | OAM-IWLAN-SA5P | PCG-27 | China Mobile | Chengang@chinamobile.com, lijian@chinamobile.com | Rel-12 | SP-53 | Mirko |  | WLAN |  |  |
| 1672 | 415.3.2 | NIM part Network Management for 3GPP Interworking WLAN | 585d? | 2011-09-21 A | 2013-12-11 A | 100% | 2011-09-21 | 2013-12-11 | 585d? | finish no earlier than 2013-12-11 | S5 | 4672h | 4672h | OAM-IWLAN-SA5NM | PCG-27 | China Mobile | Chengang@chinamobile.com, lijian@chinamobile.com | Rel-12 | SP-53 | Mirko |  | WLAN |  |  |
| 1673 | 415.4 | **Rel-12 Network Infrastructure Management** | 267d? | 2013-12-11 A | 2014-12-12 A | 100% | 2013-12-11 | 2014-09-17 | 202d? |  | S5 | 5848h | 5848h | OAM12-NIM | PCG-30 |  |  | Rel-12 | SP-58 | Mirko | OAM12-NIM |  |  |  |
| 1674 | 415.4.1 | Alarm quality improvements | 263d? | 2013-12-11 A | 2014-12-12 A | 100% | 2013-12-11 | 2014-09-17 | 201d? | finish no earlier than 2014-12-12 | S5 | 2104h | 2104h | OAM-AMI-SA5 | PCG-32 | TeliaSonera | tommy.berggren@teliasonera.com | Rel-12 | SP-62 | Mirko | OAM-AMI |  | SP-140544 |  |
| 1675 | 415.4.2 | Radio Planning Tool (RPT) interface | 201d? | 2014-03-07 A | 2014-12-12 A | 100% | 2014-03-07 | 2014-09-17 | 139d? | finish no earlier than 2014-12-12 | S5 | 1608h | 1608h | OAM-RPTi-SA5 | PCG-32 | Nokia Networks | olaf.pollakowski@nsn.com | Rel-12 | SP-63 | Mirko | OAM-RPTi |  | SP-140546 |  |
| 1676 | 415.5 | Deleted - Rel-12 Performance Management | 328d? | 2013-06-21 A | 2014-09-16 A | 100% | 2013-06-21 | 2014-09-17 | 328d? |  | S5 | 2624h | 2624h | OAM12-PM | PCG-30 |  |  | Rel-12 | SP-58 | Mirko | OAM12-PM |  |  | SP-69 |
| 1677 | 415.6 | **OAM aspects of Network Sharing** | 267d? | 2013-12-11 A | 2014-12-12 A | 100% | 2013-12-11 | 2014-09-17 | 202d? |  | S5 | 6344h | 6344h | OAM-SHARE | PCG-32 | Orange | jeanmichel.cornily@orange.com | Rel-12 | SP-62 | Mirko | OAM-SHARE |  | SP-140545 |  |
| 1678 | 415.6.1 | OAM aspects of Network Sharing - Concepts and high-level requirements | 263d? | 2013-12-11 A | 2014-12-12 A | 100% | 2013-12-11 | 2014-09-17 | 201d? | finish no earlier than 2014-12-12 | S5 | 2104h | 2104h | OAM-SHARE-SA5c | PCG-32 | Orange | jeanmichel.cornily@orange.com | Rel-12 | SP-62 | Mirko |  |  | SP-140545 |  |
| 1679 | 415.6.2 | OAM aspects of Network Sharing - Impacts on existing specifications | 263d? | 2013-12-12 A | 2014-12-12 A | 100% | 2013-12-12 | 2014-09-17 | 201d? | finish no earlier than 2014-12-12 | S5 | 2104h | 2104h | OAM-SHARE-SA5imp | PCG-32 | Orange | jeanmichel.cornily@orange.com | Rel-12 | SP-62 | Mirko |  |  | SP-140545 |  |
| 1680 | 416 | **Rel-12 Charging** | 402d? | 2012-12-12 A | 2014-06-18 A | 100% | 2012-12-12 | 2014-06-18 | 402d? |  | S5 | 10112h | 10112h | CH12 | PCG-29 |  |  | Rel-12 | SP-57 | Mirko | CH12 |  |  |  |
| 1681 | 416.1 | Short Message Service - Service Center (SMS-SC) Offline Charging | 325d? | 2012-12-12 A | 2014-03-10 A | 100% | 2012-12-12 | 2014-03-07 | 325d? | finish no earlier than 2014-03-07 | S5 | 2592h | 2592h | SMS-SC-CH | PCG-30 | Alcatel-Lucent | maryse.gardella@alcatel-lucent.com | Rel-12 | SP-58 | Mirko | SMS-SC-CH |  |  |  |
| 1682 | 416.2 | Charging per IP - Connectivity Access Network (IP-CAN) Session (Stage 2/3) | 201d? | 2013-09-12 A | 2014-06-18 A | 100% | 2013-09-12 | 2014-06-18 | 201d? | finish no earlier than 2014-06-18 | S5 | 1608h | 1608h | CHIPS | PCG-31 | Ericsson | david.shrader@ericsson.com | Rel-12 | SP-61 | Mirko | CHIPS |  |  |  |
| 1683 | 416.3 | Charging using an Alternative Roaming Provider (Stage 2/3) | 202d? | 2013-09-12 A | 2014-06-18 A | 100% | 2013-09-12 | 2014-06-18 | 202d? | finish no earlier than 2014-06-18 | S5 | 1608h | 1608h | CHARP | PCG-31 | Ericsson | david.shrader@ericsson.com | Rel-12 | SP-61 | Mirko | CHARP |  |  |  |
| 1684 | 416.4 | Charging for IMS centralized service (ICS) control (Stage 2/3) | 137d? | 2013-12-11 A | 2014-06-18 A | 100% | 2013-12-11 | 2014-06-18 | 137d? | finish no earlier than 2014-06-18 | S5 | 1088h | 1088h | CHICS | PCG-32 | NSN | Gerald.Goermer@nsn.com | Rel-12 | SP-62 | Mirko | CHICS |  |  |  |

Notes:
- 1658: Stage 2/3. 5/5/15: corrected to be Rel-12. Nothing to be done in the end (covered by Rel-13 QOSE2EMTSI-CT), so 100% / Impacted TSs and TRs: Stage 2/3
- 1659: Dec.14: CD: 09/14->09/15. 5/5/15: corrected to be Rel-12. Nothing to be done in the end (covered by Rel-13 QOSE2EMTSI-CT), so 100% / Impacted TSs and TRs: 29.162, 29.163, 29.213, 29.214
- 1660: CP#64 completion 06/14=>09/14. 5/5/15: corrected to be Rel-12. Nothing to be done in the end (covered by Rel-13 QOSE2EMTSI-CT), so 100% / Impacted TSs and TRs: 24.229
- 1661: CP#64 completion 06/14=>09/14. 5/5/15: corrected to be Rel-12. Nothing to be done in the end (covered by Rel-13 QOSE2EMTSI-CT), so 100% / Impacted TSs and TRs: 23.333, 23.334, 29.238, 29.332, 29.333, 29.334
- 1662: SP#63 completed. Linked to Rel-6 Media Codecs and Formats for IMS Messaging and Presence (PRESNC-COFIMP) UID_34025. Work item which gave rise to TS 26.141 / Impacted TSs and TRs: 26.141
- 1663: SP#65 completed. Linked to E2EMTSI (End-to-End Multimedia Telephony Service for IMS extensions). Add Reqs&guidelines for video telephony robustness to improve service perf. for PLI, Generic NACK, and FIR messages within overall bitrate limit / Impacted TSs and TRs: 26.114
- 1664: OAM12 is an umbrella Feature for changes that are not part of any other dedicated feature/WI
- 1665: OAM12-SON is an umbrella BB also for SON related TEI12 type of changes that are not part of any other dedicated feature/WI
- 1666: SP#62 completed. TS 32.508v200 for Approval, TS 32.509v100 for 1-step Approval / Impacted TSs and TRs: 32.501, New TSs (32.508, 32.509)
- 1667: SP#65 moved to Rel-13 OAM-PMID (Converged management Performance Management Interface Definition) UID_560235
- 1668: SP#65 completed. TR 28.280v100 for 1-step Approval / Impacted TSs and TRs: 32.156, new TR 28.820
- 1669: SP#60 completed. TS 28.390v200 for Approval / Impacted TSs and TRs: new TS 28.390
- 1670: SP#65 updated WID SP-120779=>SP-140542 (removed parts on CN and non-3GPP access). Discontinue I-WLAN spec.
- 1671: SP#65 completed. TS 28.402v100 for 1-step Approval, withdraw New TS 28.401 (CN and non-3GPP access i/w PMs). Moved PMs for EPC and non-3GPP access i/w from 28.401=>28.402 / Impacted TSs and TRs: new TS 28.401, withdrawn new TS 28.402
- 1672: SP#65 discontinue I-WLAN specs: Move parts (e.g. IOCs) applicable for EPC and non-3GPP access interworking NRMs from 28.601/2/6 to 28.611/2/6. Withdraw 28.601/2/6 (CN and non-3GPP access i/w NRMs). SP#62 completed. TSs 28.601/2/6/11/12/16 for Approval / Impacted TSs and TRs: 32.632, 32.636, 32.752, 32.756, new TS (28.611, 28.612, 28.616, withdrawn 28.601, 28.602, 28.606)
- 1673: -
- 1674: SP#65 completion 09/14=>12/14. Exception in SP-140544. Triggered by Rel-12 TR 32.859 Study on Alarm Management (FS_OAM_AM) . Dec.14: 50->100 / Impacted TSs and TRs: 32.111-1, 32.111-2, 32.111-6
- 1675: SP#65 completion 09/14=>12/14. Exception in SP-140546. SP#65 v100 TS 28.667/8 for Information. Dec.14: 60->100 / Impacted TSs and TRs: 32.101, New TSs (28.667, 28.668, 28.669)
- 1676: OAM12-PM is an umbrella BB also for PM related TEI12 type of changes that are not part of any other dedicated feature/WI
- 1677: SP#65 completion 09/14=>12/14. Exception in SP-140545. Triggered by Rel-12 TR 32.851 Study on OAM aspects of Network Sharing (FS_OAM_SHARE), Rel-6 Network Sharing (NTShar) UID_31018 / Impacted TSs and TRs: Stage 1/2/3
- 1678: SP#65 completion 09/14=>12/14. Exception in SP-140545. LM 80->100 / Impacted TSs and TRs: new TS 32.130
- 1679: SP#65 completion 09/14=>12/14. Exception in SP-140545. Dec.14: 60->100 / Impacted TSs and TRs: 28.401,28.621/2/3,28.651/2/3,28.654/5/6,28.657/8/9,28.701/2/3,28.731/2/3,28.734/5/6,32.101/2,32.111-1/2/3/6,32.121/2/6,32.155,32.171/2/6,32.300/1/2/6,32.311/2/6,32.321/2/6,32.331/2/6,32.341/2/6,32.351/352/6,32.361/2/6,32.381/2/6,32.405/6/7/8/9/10/11/12/41
- 1680: CH12 is an umbrella Feature for changes that are not part of any other dedicated feature/WI
- 1681: Stage 2/3. SP#63 completed. Updated WID SP-120775=>SP-140027 / Impacted TSs and TRs: 32.240, 32.274, 32.297, 32.298, 32.299
- 1682: SP#64 completed. 12/15: Acronym reverted back from CHIPCAN to CHIPS / Impacted TSs and TRs: 32.251, 32.298, 32.299
- 1683: SP#64 completed. TS 32.276v200 for Approval, 32.293v100 for 1-step Approval / Impacted TSs and TRs: 32.240, 32.299, New TSs [32.276 (Voice Call Service Charging), 32.293 (Proxy Function)]
- 1684: SP#64 completed. Align SA5 Charging specifications with Rel-8 Feature IMS Centralized Service control (ICSRA) and subsequent enhancements under TEIx (SA2 23.292 ICSRA Stage 2, CT3 29.292, CT1 24.607, 24.611) / Impacted TSs and TRs: 32.250, 32.298

| ID | WBS | Task | Duration | Start | Finish | Complete | Remaining | Baseline start | Baseline finish | Baseline duration | Total slack | Constraint | Resources | Work | Actual work | Acronym | PCG approved | WI rapporteur name | Release | TSG approved | MCC resp | Special Focus Doc | Acronym_3GU_Export | Status Report |
| --- | --- | --- | --- | --- | --- | --- | --- | --- | --- | --- | --- | --- | --- | --- | --- | --- | --- | --- | --- | --- | --- | --- | --- | --- |
| 1685 | 417 | **IMS Emergency PSAP Callback (Stage 3)** | 724d? | 2011-09-21 A | 2014-06-13 A | 100% |  | 2011-09-21 | 2014-06-13 | 724d? |  |  | C1; C3; IETF | 38848h | 38848h | EMC_PC | PCG-27 | Ericsson | Rel-12 | CP-53 | Frederic | Public Safety (I-A) | EMC_PC |  |
| 1686 | 417.1 | CT1 part of IMS Emergency PSAP Callback | 721d? | 2011-09-22 A | 2014-06-13 A | 100% |  | 2011-09-22 | 2014-06-13 | 721d? |  | finish no earlier than 2014-06-13 | C1 | 5760h | 5760h | EMC_PC | PCG-27 | Ericsson | Rel-12 | CP-53 | Frederic | Public Safety (I-A) |  |  |
| 1687 | 417.2 | (IETF) CT1 part of IMS Emergency PSAP Callback (RFC 7090) | 723d? | 2011-09-21 A | 2014-06-13 A | 100% |  | 2011-09-21 | 2014-06-13 | 723d? |  | finish no earlier than 2014-06-13 | C1-IETF | 5776h | 5776h | EMC_PC | PCG-27 | christer.holmberg@ericsson.com | Rel-12 | CP-53 | Frederic | Public Safety (I-A) |  |  |
| 1688 | 417.3 | CT3 part of IMS Emergency PSAP Callback | 519d? | 2011-09-24 A | 2013-09-06 A | 100% |  | 2011-09-24 | 2013-09-06 | 519d? |  | finish no earlier than 2013-09-06 | C3 | 4152h | 4152h | EMC_PC | PCG-27 | Ericsson | Rel-12 | CP-53 | Adrian | Public Safety (I-A) |  |  |
| 1689 | 417.4 | (IETF) CT3 part of IMS Emergency PSAP Callback (RFC 7090) | 724d? | 2011-09-21 A | 2014-06-13 A | 100% |  | 2011-09-21 | 2014-06-13 | 724d? |  | finish no earlier than 2014-06-13 | C3-IETF | 5784h | 5784h | EMC_PC | PCG-31 | christer.holmberg@ericsson.com | Rel-12 | CP-60 | Adrian | Public Safety (I-A) |  |  |
| 1690 | 418 | Interworking between a PLMN with WLAN to access the EPC and a PDN (Stage 3) | 265d? | 2012-09-10 A | 2013-09-06 A | 100% |  | 2012-09-10 | 2013-09-06 | 265d? |  | finish no earlier than 2013-08-12 | C3 | 2091.72h | 2091.72h | SAES_WLAN_EPC_intwk | PCG-29 | Huawei | Rel-12 | CP-57 | Adrian | WLAN | SAES_WLAN_EPC_intwk |  |
| 1691 | 419 | **Reporting Enhancements in Warning Message Delivery (Stage 2/3)** | 402d? | 2012-12-07 A | 2014-06-13 A | 100% |  | 2012-12-07 | 2014-06-13 | 402d? |  |  | C1; C4; R3 | 20832.2h | 20832.2h | REP_WMD | PCG-30 | one2many | Rel-12 | CP-58 | Frederic | Public Safety (I-A) | REP_WMD |  |
| 1692 | 419.1 | CT1 part of Reporting Enhancements in Warning Message Delivery (Stage 2) | 329d? | 2012-12-07 A | 2014-03-04 A | 100% |  | 2012-12-07 | 2014-03-04 | 329d? |  | finish no earlier than 2014-03-06 | C1 | 2592.18h | 2592.18h | REP_WMD-CT1 | PCG-30 | one2many | Rel-12 | CP-58 | Frederic | Public Safety (I-A) |  |  |
| 1693 | 419.2 | CT4 part of Reporting Enhancements in Warning Message Delivery (Stage 2/3) | 400d? | 2012-12-10 A | 2014-06-13 A | 100% |  | 2012-12-10 | 2014-06-13 | 400d? |  | finish no earlier than 2014-06-13 | C4 | 3168h | 3168h | REP_WMD-CT4 | PCG-30 | one2many | Rel-12 | CP-58 | Kimmo | Public Safety (I-A) |  |  |
| 1694 | 419.3 | **Public Warning System - Reset/Failure/Restart in Warning Message Delivery in LTE** | 340d? | 2013-03-04 A | 2014-06-13 A | 100% |  | 2013-03-04 | 2014-06-13 | 340d? |  |  | R3 | 5424h | 5424h | REP_WMD-RFR_PWS | PCG-30 | one2many, Huawei | Rel-12 | RP-59 | Juha | Public Safety (I-A) | REP_WMD-RFR_PWS |  |
| 1695 | 419.3.1 | Core part: PWS - Reset/Failure/Restart in Warning Message Delivery in LTE | 338d? | 2013-03-04 A | 2014-06-13 A | 100% |  | 2013-03-04 | 2014-06-13 | 338d? |  | finish no earlier than 2014-06-13 | R3 | 2704h | 2704h | REP_WMD-RFR_PWS-Core | PCG-30 | one2many, Huawei | Rel-12 | RP-59 | Juha | Public Safety (I-A) | REP_WMD-RFR_PWS-Core | RP-140637 |
| 1696 | 420 | **Single Radio Voice Call Continuity (SRVCC) before ringing (Stage 3)** | 331d? | 2012-12-07 A | 2014-03-06 A | 100% |  | 2012-12-07 | 2014-03-06 | 331d? |  |  | C1; C3; R5 | 9584h | 9584h | bSRVCC | PCG-30 | NTT DOCOMO | Rel-12 | CP-58 | Frederic |  | bSRVCC |  |
| 1697 | 420.1 | CT1 part of Single Radio Voice Call Continuity (SRVCC) before ringing | 138d? | 2012-12-07 A | 2013-06-14 A | 100% |  | 2012-12-07 | 2013-06-14 | 138d? |  | finish no earlier than 2013-06-14 | C1 | 1096h | 1096h | bSRVCC | PCG-30 | NTT DOCOMO | Rel-12 | CP-58 | Frederic |  |  |  |
| 1698 | 420.2 | CT3 part of Single Radio Voice Call Continuity (SRVCC) before ringing | 3d? | 2013-06-12 A | 2013-06-14 A | 100% |  | 2013-06-12 | 2013-06-14 | 3d? |  | finish no earlier than 2013-06-14 | C3 | 24h | 24h | bSRVCC | PCG-31 | NTT DOCOMO | Rel-12 | CP-60 | Adrian |  |  |  |
| 1699 | 420.3 | Test part: Single Radio Voice Call Continuity (SRVCC) before ringing | 65d? | 2013-12-06 A | 2014-03-06 A | 100% |  | 2013-12-06 | 2014-03-06 | 65d? |  | finish no earlier than 2014-03-06 | R5 | 520h | 520h | bSRVCC-UEConTest | PCG-32 | NTT DOCOMO | Rel-12 | CP-62 | Ingbert |  | bSRVCC-UEConTest | RP-140422 |
| 1700 | 421 | **IMS Stage 3 IETF Protocol Alignment - phase 6** | 532d? | 2012-12-07 A | 2014-12-09 | 67% | 176.89d? | 2012-12-07 | 2014-12-05 | 527d? | 875d |  | C1; C3; IETF | 20640.6h | 13665.2h | IMSProtoc6 | PCG-30 | Alcatel-Lucent | Rel-12 | CP-58 | Frederic |  | IMSProtoc6 |  |
| 1701 | 421.1 | CT1 part of IMS Stage 3 IETF Protocol Alignment - phase 6 | 464d? | 2012-12-07 A | 2014-09-11 A | 100% |  | 2012-12-07 | 2014-09-12 | 464d? |  | finish no earlier than 2014-09-12 | C1 | 3712h | 3712h | IMSProtoc6 | PCG-30 | Alcatel-Lucent | Rel-12 | CP-58 | Frederic |  |  |  |
| 1702 | 421.2 | (IETF) CT1 part of IMS Stage 3 IETF Protocol Alignment - phase 6 (holmberg-sipcore-received-realm) | 410d? | 2013-05-21 A | 2014-12-09 | 50% | 206d? | 2013-05-21 | 2014-12-05 | 408d? | 875d | finish no earlier than 2014-12-09 | C1-IETF | 3256.25h | 1608.25h | IMSProtoc6 | PCG-31 | christer.holmberg@ericsson.com | Rel-12 | CP-60 | Frederic |  |  |  |
| 1703 | 421.3 | (IETF) CT1 part of IMS Stage 3 IETF Protocol Alignment - phase 6 (allen-sipcore-sip-tree-cap-indicators) | 63d? | 2014-09-12 A | 2014-12-09 | 25% | 47.25d? |  |  |  | 875d | finish no earlier than 2014-12-09 | C1-IETF | 504h | 126h | IMSProtoc6 | PCG-33 | christer.holmberg@ericsson.com | Rel-12 | CP-65 |  |  |  |  |
| 1704 | 421.4 | (IETF) CT1 part of IMS Stage 3 IETF Protocol Alignment - phase 6 (draft-ietf-insipid-session-id) | 65d? | 2014-09-12 A | 2014-12-09 | 25% | 48.75d? |  |  |  | 875d | start no earlier than 2014-09-12 | C1-IETF | 520h | 130h | IMSProtoc6 | PCG-34 | christer.holmberg@ericsson.com | Rel-12 | CP-65 |  |  |  |  |
| 1705 | 421.5 | CT3 part of IMS Stage 3 IETF Protocol Alignment - phase 6 | 71d? | 2014-06-06 A | 2014-09-11 A | 100% |  | 2014-06-06 | 2014-09-12 | 71d? |  | finish no earlier than 2014-09-12 | C3 | 568h | 568h | IMSProtoc6 | PCG-30 | Alcatel-Lucent | Rel-12 | CP-58 | Adrian |  |  |  |
| 1706 | 421.6 | (IETF) CT3 part of IMS Stage 3 IETF Protocol Alignment - phase 6 (holmberg-sipcore-received-realm) | 327d? | 2013-09-06 A | 2014-12-05 | 50% | 163.5d? | 2013-09-06 | 2014-12-05 | 327d? | 877d | finish no earlier than 2014-12-05 | C3-IETF | 2608h | 1300h | IMSProtoc6 | PCG-31 | christer.holmberg@ericsson.com | Rel-12 | CP-61 |  |  |  |  |
| 1707 | 422 | **SAE Protocol Development - Phase 3** | 467d? | 2012-12-07 A | 2014-09-11 A | 100% |  | 2012-12-07 | 2014-09-12 | 467d? |  |  | C1 | 14920h | 14920h | SAES3 | PCG-30 | InterDigital | Rel-12 | CP-58 | Frederic |  | SAES3 |  |
| 1708 | 422.1 | SAE Protocol Development (Stage 3) - Phase 3 | 466d? | 2012-12-07 A | 2014-09-11 A | 100% |  | 2012-12-07 | 2014-09-12 | 466d? |  | finish no earlier than 2014-09-12 | C1 | 3728h | 3728h | SAES3-CT1 | PCG-30 | InterDigital | Rel-12 | CP-58 | Frederic |  |  |  |
| 1709 | 422.2 | CS Fallback in EPS - Phase 3 | 466d? | 2012-12-07 A | 2014-09-11 A | 100% |  | 2012-12-07 | 2014-09-12 | 466d? |  | finish no earlier than 2014-09-12 | C1 | 3728h | 3728h | SAES3-CSFB | PCG-30 | InterDigital | Rel-12 | CP-58 | Frederic |  | SAES3-CSFB |  |
| 1710 | 422.3 | SAE for support for non-3GPP accesses - Phase 3 | 466d? | 2012-12-07 A | 2014-09-11 A | 100% |  | 2012-12-07 | 2014-09-12 | 466d? |  | finish no earlier than 2014-09-12 | C1 | 3728h | 3728h | SAES3-non3GPP | PCG-30 | InterDigital | Rel-12 | CP-58 | Frederic |  | SAES3-non3GPP |  |

Notes:
- 1685: Dep. IETF ECRIT on PSAP call back. Fulfill SA1/2 Rel-7 EMC1 reqs UID_32045 PS domain and IMS impacts for supporting IMS Emergency calls (related to BB UID_1653 Emergency Call Enhancements for IP& PS Based Calls / Impacted TSs and TRs: Stage 3 / WI rapporteur e-mail: christer.holmberg@ericsson.com
- 1686: CP#64 completed. 2/4/15: acronym changed to EMC_PC / Impacted TSs and TRs: 24.229, tied to completion of IETF dependencies: 24.604, 24.605, 24.610, 24.611, 24.629 / WI rapporteur e-mail: christer.holmberg@ericsson.com
- 1687: CP#64 completed. 2/4/15: acronym changed to EMC_PC / Impacted TSs and TRs: RFC 7090 (was draft-ietf-ecrit-psap-callback / WI rapporteur e-mail: christer.holmberg@ericsson.com
- 1688: CP#61 completed. 2/4/15: acronym changed to EMC_PC / Impacted TSs and TRs: 29.163, 29.165 / WI rapporteur e-mail: christer.holmberg@ericsson.com
- 1689: CP#64 completed. 2/4/15: acronym changed to EMC_PC / Impacted TSs and TRs: RFC 7090 (was draft-ietf-ecrit-psap-callback) / WI rapporteur e-mail: christer.holmberg@ericsson.com
- 1690: CP#61 completed. Linked to Rel-8 Feature SAES in CP-150System Architecture Evolution specification - Evolved Packet System (non RAN aspects) UID_320005 / Impacted TSs and TRs: 29.061 / WI rapporteur e-mail: Christian.Herrero@huawei.com
- 1691: Stage 1 for Cell Broadcast does not exist. This WID enhances the reporting capabilities of Warning Message Delivery. Introduce LTE functionality requested by regulators, equivalent to existing 2G/3G functionality. / Impacted TSs and TRs: Stage 2/3 / WI rapporteur e-mail: peter.sanders@one2many.eu
- 1692: CP#63 completed / Impacted TSs and TRs: 23.041 / WI rapporteur e-mail: peter.sanders@one2many.eu
- 1693: CP#64 completed / Impacted TSs and TRs: 23.007, 29.168 / WI rapporteur e-mail: peter.sanders@one2many.eu
- 1694: - / Impacted TSs and TRs: LTE / WI rapporteur e-mail: peter.sanders@one2many.eu, Dai Mingzeng (daimingzeng@huawei.com)
- 1695: RP#64 completed / Impacted TSs and TRs: 36.413 / WI rapporteur e-mail: peter.sanders@one2many.eu, Dai Mingzeng (daimingzeng@huawei.com)
- 1696: Linked to Rel-8 Feature IMS Service Continuity (IMS-Cont) UID_390056. TS 23.237 Rel-12 CR#0444 under TEI12 / Impacted TSs and TRs: GERAN, UTRA, LTE / WI rapporteur e-mail: keisuke.sasada.kx@nttdocomo.com
- 1697: CP#60 completed. 2/4/15: acronym changed to bSRVCC / Impacted TSs and TRs: 24.008, 24.237 / WI rapporteur e-mail: keisuke.sasada.kx@nttdocomo.com
- 1698: CP#60 completedbSRVCC / Impacted TSs and TRs: 29.165 / WI rapporteur e-mail: keisuke.sasada.kx@nttdocomo.com
- 1699: RP#63 completed. Testing for CT1 TS 24.237 (IMS service continuity Stage 3) / Impacted TSs and TRs: 34.229-1, 34.229-2, 36.523-1, 36.523-2 / WI rapporteur e-mail: Masahiro.Tamaoki.eu@nttdocomo.com
- 1700: - / Impacted TSs and TRs: Stage 3 / WI rapporteur e-mail: keith.drage@alcatel-lucent.com
- 1701: CP#65 completed. 4/2/15: acronym changed to IMSProtoc6 / Impacted TSs and TRs: 23.218, 24.229, 24.930 / WI rapporteur e-mail: keith.drage@alcatel-lucent.com
- 1702: Not completed internet-draft. 4/2/15: acronym changed to IMSProtoc6 / Impacted TSs and TRs: draft-holmberg-sipcore-received-realm / WI rapporteur e-mail: christer.holmberg@ericsson.com
- 1703: Not completed internet-draft. 4/2/15: acronym changed to IMSProtoc6 / Impacted TSs and TRs: draft-allen-sipcore-sip-tree-cap-indicators / WI rapporteur e-mail: christer.holmberg@ericsson.com
- 1704: work in progress. 4/2/15: acronym changed to IMSProtoc6 / Impacted TSs and TRs: draft-ietf-insipid-session-id
- 1705: CP#65 completed. 4/2/15: acronym changed to IMSProtoc6 / Impacted TSs and TRs: 29.163, 29.165 / WI rapporteur e-mail: keith.drage@alcatel-lucent.com
- 1706: Not completed internet-draft. 4/2/15: acronym changed to IMSProtoc6 / Impacted TSs and TRs: draft-holmberg-sipcore-received-realm / WI rapporteur e-mail: christer.holmberg@ericsson.com
- 1707: Stage 3 continuation of Rel-8 Feature SAES (3GPP System Architecture Evolution Specification - Evolved Packet System) UID_320005 / Impacted TSs and TRs: Stage 2/3 / WI rapporteur e-mail: behrouz.aghili@interdigital.com
- 1708: CP#65 completed / Impacted TSs and TRs: 23.122, 24.008, 24.167, 24.229, 24.301, 24.302, 24.303, 24.304, 24.305, 24.312, 29.018, 29.118 / WI rapporteur e-mail: behrouz.aghili@interdigital.com
- 1709: CP#65 completed / Impacted TSs and TRs: 23.122, 24.008, 24.167, 24.229, 24.301, 24.302, 24.303, 24.304, 24.305, 24.312, 29.018, 29.118 / WI rapporteur e-mail: behrouz.aghili@interdigital.com
- 1710: CP#65 completed / Impacted TSs and TRs: 23.122, 24.008, 24.167, 24.229, 24.301, 24.302, 24.303, 24.304, 24.305, 24.312, 29.018, 29.118 / WI rapporteur e-mail: behrouz.aghili@interdigital.com

| ID | WBS | Task | Duration | Start | Finish | Complete | Baseline start | Baseline finish | Baseline duration | Constraint | Resources | Work | Actual work | Acronym | PCG approved | Impacted TSs and TRs | WI rapporteur name | WI rapporteur e-mail | Release | TSG approved | MCC resp | Acronym_3GU_Export | Status Report |
| --- | --- | --- | --- | --- | --- | --- | --- | --- | --- | --- | --- | --- | --- | --- | --- | --- | --- | --- | --- | --- | --- | --- | --- |
| 1711 | 423 | **IM-SSF Application Server Service Data Descriptions (Stage 2/3)** | 138d? | 2012-12-07 A | 2013-06-14 A | 100% | 2012-12-07 | 2013-06-14 | 138d? |  | C4; C1 | 3780h | 3780h | IMS_SSFDD | PCG-30 | Stage 2/3 | Huawei | susan.shishufeng@huawei.com | Rel-12 | CP-58 | Kimmo | IMS_SSFDD |  |
| 1712 | 423.1 | Stage 2 for IM-SSF Application Server Service Data Descriptions | 62d? | 2012-12-07 A | 2013-03-01 A | 100% | 2012-12-07 | 2013-03-01 | 62d? | finish no earlier than 2013-06-14 | C1 | 488h | 488h | IMS_SSFDD | PCG-30 | 23.218 | Huawei | susan.shishufeng@huawei.com | Rel-12 | CP-58 | Frederic |  |  |
| 1713 | 423.2 | Stage 3 for IM-SSF Application Server Service Data Descriptions | 136.5d? | 2012-12-10 A | 2013-06-14 A | 100% | 2012-12-10 | 2013-06-14 | 136.5d? | finish no earlier than 2013-06-14 | C4 | 1084h | 1084h | IMS_SSFDD | PCG-30 | 29.328, 29.329, 29.364 | Huawei | susan.shishufeng@huawei.com | Rel-12 | CP-58 | Kimmo |  |  |
| 1714 | 424 | **Diameter based interface between SGSN and SMS central functions (Stage 2/3)** | 265d? | 2012-12-10 A | 2013-12-06 A | 100% | 2012-12-10 | 2013-12-06 | 265d? |  | C4; C1 | 7952h | 7952h | Dia_SGSN_SMS | PCG-30 | Stage 2/3 | Alcatel-Lucent | jean-jacques.trottin@alcatel-lucent.com | Rel-12 | CP-58 | Kimmo | Dia_SGSN_SMS |  |
| 1715 | 424.1 | Stage 2 for Diameter based interface between SGSN and SMS central functions | 201d? | 2013-03-07 A | 2013-12-06 A | 100% | 2013-03-07 | 2013-12-06 | 201d? | finish no earlier than 2013-12-06 | C1 | 1608h | 1608h | Dia_SGSN_SMS | PCG-30 | 23.040 | Alcatel-Lucent | jean-jacques.trottin@alcatel-lucent.com | Rel-12 | CP-59 | Frederic |  |  |
| 1716 | 424.2 | Stage 3 for Diameter based interface between SGSN and SMS central functions | 265d? | 2012-12-10 A | 2013-12-06 A | 100% | 2012-12-10 | 2013-12-06 | 265d? | finish no earlier than 2013-12-06 | C4 | 2104h | 2104h | Dia_SGSN_SMS | PCG-30 | 29.002, 29.230, 29.272, 29.305, 29.336, 29.337, 29.338 | Alcatel-Lucent | jean-jacques.trottin@alcatel-lucent.com | Rel-12 | CP-58 | Kimmo |  |  |
| 1717 | 425 | Diameter based interface between SGSN-GMLC (Stage 3) | 265d? | 2012-12-10 A | 2013-12-06 A | 100% | 2012-12-10 | 2013-12-06 | 265d? | finish no earlier than 2013-12-06 | C4 | 2096h | 2096h | Dia_SGSN_GMLC | PCG-30 | 29.002, 29.172, 29.173, 29.230, 29.272 | Cisco | Nirav Salot (nsalot@cisco.com) | Rel-12 | CP-58 | Kimmo | Dia_SGSN_GMLC |  |
| 1718 | 426 | IMS impacts on UICC Application Aspects (Stage 3) | 465d? | 2013-03-04 A | 2014-12-09 A | 100% | 2013-03-04 | 2014-09-12 | 403d? | finish no earlier than 2014-12-09 | C6 | 3720h | 3720h | IMS_UApAs | PCG-30 | 31.102, 31.103, 31.111, 31.130 | Giesecke & Devrient | sergi.espi@gi-de.com | Rel-12 | CP-59 | Xavier | IMS_UApAs | CP-140696 |
| 1719 | 427 | **eMBMS restoration procedures** | 406d? | 2013-03-01 A | 2014-09-11 A | 100% | 2013-03-01 | 2014-06-13 | 341d? |  | C4; C3 | 10272h | 10272h | eMBMS_Rest | PCG-30 | Stage 3 | Alcatel-Lucent | bruno.landais@alcatel-lucent.com | Rel-12 | CP-59 | Kimmo | eMBMS_Rest |  |
| 1720 | 427.1 | CT4 part of eMBMS restoration procedures | 205d? | 2013-03-01 A | 2013-12-06 A | 100% | 2013-03-01 | 2013-12-06 | 205d? | finish no earlier than 2013-12-06 | C4 | 1616h | 1616h | eMBMS_Rest | PCG-30 | 23.007, 23.008, 29.274 | Alcatel-Lucent | bruno.landais@alcatel-lucent.com | Rel-12 | CP-59 | Kimmo |  |  |
| 1721 | 427.2 | CT3 part of eMBMS restoration procedures | 270d? | 2013-09-04 A | 2014-09-11 A | 100% | 2013-09-04 | 2014-06-13 | 205d? | finish no earlier than 2014-09-12 | C3 | 2160h | 2160h | eMBMS_Rest | PCG-31 | 29.061 | Alcatel-Lucent | bruno.landais@alcatel-lucent.com | Rel-12 | CP-61 | Kimmo |  |  |
| 1722 | 428 | **Dual Radio VCC enhancements (Stage 2/3)** | 325d? | 2012-09-19 A | 2013-12-06 A | 100% | 2012-09-19 | 2013-12-06 | 325d? |  | C1; C3.S2 | 10866.2h | 10866.2h | eDRVCC | PCG-30 | Stage 2/3 | Ericsson | Jan.Holm@ericsson.com | Rel-12 | CP-59 | Maurice | eDRVCC |  |
| 1723 | 428.1 | Stage 2 for Dual Radio VCC enhancements | 57.55d? | 2012-09-19 A | 2013-03-01 A | 100% | 2012-09-19 | 2013-03-01 | 57.55d? | finish no earlier than 2013-03-01 | S2 | 460.4h | 460.4h | eDRVCC | PCG-30 | 23.237 | Ericsson | Jan.Holm@ericsson.com | Rel-12 | CP-59 | Maurice |  |  |
| 1724 | 428.2 | **Stage 3 for Dual Radio VCC enhancements** | 205d? | 2013-03-01 A | 2013-12-06 A | 100% | 2013-03-01 | 2013-12-06 | 205d? |  | C1; C3 | 5205.8h | 5205.8h | eDRVCC | PCG-30 | Stage 3 | Ericsson | Jan.Holm@ericsson.com | Rel-12 | CP-59 | Frederic |  |  |
| 1725 | 428.2.1 | CT1 part of Stage 3 for Dual Radio VCC enhancements | 205d? | 2013-03-01 A | 2013-12-06 A | 100% | 2013-03-01 | 2013-12-06 | 205d? | finish no earlier than 2013-12-06 | C1 | 1608h | 1608h | eDRVCC | PCG-30 | 24.237, 24.292 | Ericsson | Jan.Holm@ericsson.com | Rel-12 | CP-59 | Frederic |  |  |
| 1726 | 428.2.2 | CT3 part of Stage 3 for Dual Radio VCC enhancements | 41.7d? | 2013-03-01 A | 2013-09-06 A | 100% | 2013-03-01 | 2013-09-06 | 41.7d? | finish no earlier than 2013-09-06 | C3 | 317.8h | 317.8h | eDRVCC | PCG-30 | 29.165 | Ericsson | Jan.Holm@ericsson.com | Rel-12 | CP-59 | Adrian |  |  |
| 1727 | 429 | **CT aspects of Signalling of Image Size (Stage 2/3)** | 129d? | 2013-06-14 A | 2013-12-06 A | 100% | 2013-06-14 | 2013-12-06 | 129d? |  | C4; C1; C3 | 6136.8h | 6136.8h | SIS_CT | PCG-31 | Stage 2/3 | Ericsson | nevenka.biondic@ericsson.com | Rel-12 | CP-60 | Kimmo | SIS_CT |  |
| 1728 | 429.1 | CT4 part of Signalling of Image Size | 128.05d? | 2013-06-14 A | 2013-12-06 A | 100% | 2013-06-14 | 2013-12-06 | 128.05d? | finish no earlier than 2013-12-06 | C4 | 1008.4h | 1008.4h | SIS_CT | PCG-31 | 23.333, 23.334, 29.238, 29.332, 29.333, 29.334 | Ericsson | nevenka.biondic@ericsson.com | Rel-12 | CP-60 | Kimmo |  |  |
| 1729 | 429.2 | CT1 part of CT Aspects of Signalling of Image Size | 129d? | 2013-06-14 A | 2013-12-06 A | 100% | 2013-06-14 | 2013-12-06 | 129d? | finish no earlier than 2013-12-06 | C1 | 1016h | 1016h | SIS_CT | PCG-31 | 24.229 | Ericsson | nevenka.biondic@ericsson.com | Rel-12 | CP-60 | Frederic |  |  |
| 1730 | 429.3 | CT3 part of CT Aspects of Signalling of Image Size | 128.05d? | 2013-06-14 A | 2013-12-06 A | 100% | 2013-06-14 | 2013-12-06 | 128.05d? | finish no earlier than 2013-12-06 | C3 | 1016.4h | 1016.4h | SIS_CT | PCG-31 | 29.162, 29.163 | Ericsson | nevenka.biondic@ericsson.com | Rel-12 | CP-60 | Adrian |  |  |
| 1731 | 430 | IMS Centralized Services (ICS) InterWorking Enhancement in Mobile Switching Center Server (MSC-S) | 129d? | 2013-06-14 A | 2013-12-06 A | 100% | 2013-06-14 | 2013-12-06 | 129d? | finish no earlier than 2013-12-06 | C3 | 1008h | 1008h | ICS_IWE | PCG-31 | 29.292 | Orange | marianne.mohali@orange.com | Rel-12 | CP-60 | Adrian | ICS_IWE |  |
| 1732 | 431 | GPRS Tunnelling Protocol for the Control plane (GTP-C) Overload Control Mechanisms | 267d? | 2013-09-06 A | 2014-09-11 A | 100% | 2013-09-06 | 2014-09-12 | 267d? | finish no earlier than 2014-09-12 | C4 | 2136h | 2136h | GOCMe | PCG-31 | 23.008, 29.230, 29.273, 29.274, 29.303, New TR 29.807 | Cisco | Nirav Salot (nsalot@cisco.com) | Rel-12 | CP-61 | Kimmo | GOCMe |  |
| 1733 | 432 | **Proxy Call Session Control Function (P-CSCF) restoration enhancements (Stage 2/3)** | 447.1d? | 2013-04-03 A | 2014-12-09 A | 100% | 2013-04-03 | 2014-12-05 | 442.1d? |  | C4; C3; C1 | 54903.2h | 54903.2h | PCSCF_RES | PCG-31 | Stage 2/3 | Ericsson | maria.cruz.bartolome@ericsson.com | Rel-12 | CP-61 | Kimmo | PCSCF_RES |  |
| 1734 | 432.1 | TR on Proxy Call Session Control Function (P-CSCF) restoration enhancements | 266d? | 2013-09-06 A | 2014-09-11 A | 100% | 2013-09-06 | 2014-09-12 | 266d? | finish no earlier than 2014-09-12 | C4 | 2128h | 2128h | PCSCF_RES | PCG-31 | New TR 29.806 | Ericsson | maria.cruz.bartolome@ericsson.com | Rel-12 | CP-61 | Kimmo |  |  |

Notes:
- 1711: CP#60 completed
- 1712: CP#59 completed
- 1713: CP#60 completed
- 1714: CP#62 completed
- 1715: CP#62 completed
- 1716: CP#62 completed
- 1717: CP#62 completed. Updated WID CP-130273=>CP-130598. No Stage 2 impact. Define a Diameter variant for the protocol used over existing reference points between SGSN and GMLC for LCS (replace the use of MAP by Diameter protocol)
- 1718: CP#65 completion 09/14=>12/14. Exception in CP-140696. Dec.14: 85->100%
- 1719: CP#62 completed. Linked to Rel-9 MBMS support in EPS (MBMS_EPS). Rel-10 CT Features EPC Node Restoration with/out Idle mode Signalling Reduction (ISR) activated (EPC_NR/EPC_NR_ISR)
- 1720: CP#62 completed
- 1721: CP#65 completed
- 1722: CP#62 completed. Stage 2 in Rel-12 TEI12 TS 23.237 CR#0431, CR#0440, CR#0441, CR#0453 (pre-alerting). Stage 3 linked to Rel-8 Feature IMS Service Continuity (IMS-Cont) UID_390056 (Stage 2 in TS 23.237). 2/4/15: acronym changed to eDRVCC
- 1723: Stage 2 in Rel-12 TEI12 TS 23.237 CR#0431, CR#0440, CR#0441, CR#0453 (pre-alerting). 2/4/15: acronym changed to eDRVCC
- 1724: CP#62 completed
- 1725: CP#62 completed. 2/4/15: acronym changed to eDRVCC
- 1726: CP#61 completed. 2/4/15: acronym changed to eDRVCC
- 1727: CP#62 completed. SA4 Rel-8 MTSI Video: Dynamic Rate Adaptation/Signalling of Image Size UID_34041 has included service aspects to support image attribute (a=imageattr) in TS 26.114 as in RFC 6236. But associated CN aspects were not included
- 1728: CP#62 completed
- 1729: CP#62 completed
- 1730: CP#62 completed
- 1731: CP#62 completed. Stage 3 enhancement interworking between IMS and MSC-S for IMS Centralized Services (ICS)
- 1732: CP#65 completed. Updated WID CP-130433=>CP-140488
- 1733: CP#65 updated WID CP-140443=>CP-140490. Based TR 29.806, solutions B and D are selected for standardization. Dec.14: 95->100
- 1734: CP#65 completed. TR 29.806v200 for Approval

| ID | WBS | Task | Duration | Start | Finish | Complete | Baseline start | Baseline finish | Baseline duration | Constraint | Resources | Work | Actual work | Acronym | PCG approved | WI rapporteur name | WI rapporteur e-mail | Release | TSG approved | MCC resp | Status Report | Acronym_3GU_Export |
| --- | --- | --- | --- | --- | --- | --- | --- | --- | --- | --- | --- | --- | --- | --- | --- | --- | --- | --- | --- | --- | --- | --- |
| 1735 | 432.2 | **Common for HSS & PCRF solutions** | 447.1d? | 2013-04-03 A | 2014-12-09 A | 100% |  |  |  |  | C4; C3; C1 | 18602.4h | 18602.4h | PCSCF_RES | PCG-33 | Ericsson | maria.cruz.bartolome@ericsson.com | Rel-12 | CP-64 |  |  |  |
| 1736 | 432.2.1 | CT4 part of Common for HSS & PCRF solutions | 328d? | 2013-09-06 A | 2014-12-09 A | 100% | 2013-09-06 | 2014-12-05 | 326d? | finish no earlier than 2014-12-09 | C4 | 2624h | 2624h | PCSCF_RES | PCG-31 | Ericsson | maria.cruz.bartolome@ericsson.com | Rel-12 | CP-61 | Kimmo | CP-140481 |  |
| 1737 | 432.2.2 | CT1 part of Common for HSS & PCRF solutions | 328d? | 2013-04-03 A | 2014-12-05 A | 100% | 2013-04-03 | 2014-12-05 | 326d? | finish no earlier than 2014-12-09 | C1 | 2624h | 2624h | PCSCF_RES | PCG-33 | Ericsson | maria.cruz.bartolome@ericsson.com | Rel-12 | CP-64 | Kimmo |  |  |
| 1738 | 432.2.3 | CT3 part of Common for HSS & PCRF solutions | 328d? | 2013-05-03 A | 2014-12-09 A | 100% | 2013-05-03 | 2014-12-05 | 326d? | finish no earlier than 2014-12-09 | C3 | 2624h | 2624h | PCSCF_RES | PCG-33 | Huawei | susan.shishufeng@huawei.com | Rel-12 | CP-65 | Kimmo | CP-140687 |  |
| 1739 | 432.3 | **HSS based solution** | 447.1d? | 2013-04-03 A | 2014-12-09 A | 100% |  |  |  |  | C4; C1 | 12401.6h | 12401.6h | PCSCF_RES | PCG-33 | Ericsson | maria.cruz.bartolome@ericsson.com | Rel-12 | CP-64 |  |  |  |
| 1740 | 432.3.1 | CT4 part of HSS based solution | 328d? | 2013-09-06 A | 2014-12-09 A | 100% | 2013-09-06 | 2014-12-05 | 326d? | finish no earlier than 2014-12-09 | C4 | 2624h | 2624h | PCSCF_RES | PCG-31 | Ericsson | maria.cruz.bartolome@ericsson.com | Rel-12 | CP-61 | Kimmo | CP-140481 |  |
| 1741 | 432.3.2 | CT1 part of HSS based solution | 328d? | 2013-04-03 A | 2014-12-09 A | 100% | 2013-04-03 | 2014-12-05 | 326d? | finish no earlier than 2014-12-09 | C1 | 2624h | 2624h | PCSCF_RES | PCG-33 | Ericsson | maria.cruz.bartolome@ericsson.com | Rel-12 | CP-64 | Kimmo | CP-140605 |  |
| 1742 | 432.4 | **PCRF based solution** | 447.1d? | 2013-04-03 A | 2014-12-09 A | 100% |  |  |  |  | C3; C1 | 12401.6h | 12401.6h | PCSCF_RES | PCG-33 | Huawei | susan.shishufeng@huawei.com | Rel-12 | CP-64 |  |  |  |
| 1743 | 432.4.1 | CT3 part of PCRF based solution | 328d? | 2013-05-03 A | 2014-12-09 A | 100% | 2013-05-03 | 2014-12-05 | 326d? | finish no earlier than 2014-12-09 | C3 | 2624h | 2624h | PCSCF_RES | PCG-33 | Huawei | susan.shishufeng@huawei.com | Rel-12 | CP-64 | Kimmo | CP-140687 |  |
| 1744 | 432.4.2 | CT1 part of PCRF based solution | 328d? | 2013-04-03 A | 2014-12-09 A | 100% | 2013-04-03 | 2014-12-05 | 326d? | finish no earlier than 2014-12-09 | C1 | 2624h | 2624h | PCSCF_RES | PCG-33 | Huawei | susan.shishufeng@huawei.com | Rel-12 | CP-64 | Kimmo | CP-140605 |  |
| 1745 | 433 | **Updating IMS to conform to RFC 6665 (Stage 3)** | 400d? | 2013-09-09 A | 2015-03-13 A | 100% | 2013-09-09 | 2014-09-12 | 267d? |  | C1; C3 | 9576h | 9576h | UP6665 | PCG-31 | BlackBerry | Andrew Allen (aallen@blackberry.com) | Rel-12 | CP-61 | Frederic |  | UP6665 |
| 1746 | 433.1 | CT1 part of Updating IMS to conform to RFC 6665 | 329d? | 2013-09-09 A | 2014-12-09 A | 100% | 2013-09-09 | 2014-09-12 | 267d? | finish no earlier than 2014-12-09 | C1 | 2624h | 2624h | UP6665 | PCG-31 | BlackBerry | Andrew Allen (aallen@blackberry.com) | Rel-12 | CP-61 | Frederic | CP-140620 |  |
| 1747 | 433.2 | CT3 part of Updating IMS to conform to RFC 6665 | 66d? | 2013-09-09 A | 2013-12-06 A | 100% | 2013-09-09 | 2013-12-06 | 66d? | finish no earlier than 2013-12-06 | C3 | 528h | 528h | UP6665 | PCG-31 | BlackBerry | Andrew Allen (aallen@blackberry.com) | Rel-12 | CP-61 | Maurice |  |  |
| 1748 | 433.3 | (IETF) CT1 part of Updating IMS to conform to RFC 6665 (draft-ietf-sipcore-refer-clarifications) | 1d? | 2015-03-13 A | 2015-03-13 A | 100% |  |  |  |  | C1-IETF | 8h | 8h | UP6665 | PCG-34 | BlackBerry | Andrew Allen (aallen@blackberry.com) | Rel-12 | CT-67 |  |  |  |
| 1749 | 433.4 | (IETF) CT1 part of Updating IMS to conform to RFC 6665 (draft-ietf-sipcore-refer-explicit-subscription) | 1d? | 2015-03-13 A | 2015-03-13 A | 100% |  |  |  |  | C1-IETF | 8h | 8h | UP6665 | PCG-34 | BlackBerry | Andrew Allen (aallen@blackberry.com) | Rel-12 | CT-67 |  |  |  |
| 1750 | 433.5 | (IETF) CT1 part of Updating IMS to conform to RFC 6665 (draft-roach-sipcore-6665-clarifications) | 1d? | 2015-03-13 A | 2015-03-13 A | 100% |  |  |  |  | C1-IETF | 8h | 8h | UP6665 | PCG-34 | BlackBerry | Andrew Allen (aallen@blackberry.com) | Rel-12 | CT-67 |  |  |  |
| 1751 | 434 | **IMS Operator Determined Call Barring enhancements (Stage 3)** | 202d? | 2013-12-06 A | 2014-09-11 A | 100% | 2013-12-06 | 2014-06-13 | 137d? |  | C1; C3 | 5928h | 5928h | eIODB | PCG-32 | Ericsson | Jorgen.Axell@ericsson.com | Rel-12 | CP-62 | Frederic |  | eIODB |
| 1752 | 434.1 | CT1 part of IMS Operator Determined Call Barring enhancements | 136d? | 2013-12-06 A | 2014-06-13 A | 100% | 2013-12-06 | 2014-06-13 | 136d? | finish no earlier than 2014-06-13 | C1 | 1088h | 1088h | eIODB | PCG-32 | Ericsson | Jorgen.Axell@ericsson.com | Rel-12 | CP-62 | Frederic |  |  |
| 1753 | 434.2 | CT3 part of IMS Operator Determined Call Barring enhancements | 201d? | 2013-12-09 A | 2014-09-11 A | 100% | 2013-12-09 | 2014-06-13 | 136d? | finish no earlier than 2014-09-12 | C3 | 1608h | 1608h | eIODB | PCG-32 | Ericsson | Jorgen.Axell@ericsson.com | Rel-12 | CP-62 | Adrian |  |  |
| 1754 | 435 | Signalling Improvements for Network Efficiency (Stage 3) | 264d? | 2013-12-06 A | 2014-12-09 A | 100% | 2013-12-06 | 2014-09-12 | 202d? | finish no earlier than 2014-12-09 | C1 | 2112h | 2112h | SINE | PCG-32 | Huawei | Lin Shu (shulin@huawei.com) | Rel-12 | CP-62 | Frederic | CP-140617 | SINE |
| 1755 | 436 | **Interactive Connectivity Establishment (ICE, IETF RFC 5245) impacts on IMS H.248 profiles** | 138d? | 2014-03-05 A | 2014-09-11 A | 100% | 2014-03-05 | 2014-09-12 | 138d? |  | C4; C3 | 3896h | 3896h | ICEH248 | PCG-32 | NSN | Jan.Kall@nsn.com | Rel-12 | CP-63 | Kimmo |  | ICEH248 |
| 1756 | 436.1 | CT4 part of ICE impacts on IMS H.248 profiles (Stage 2/3) | 138d? | 2014-03-05 A | 2014-09-11 A | 100% | 2014-03-05 | 2014-09-12 | 138d? | finish no earlier than 2014-09-12 | C4 | 1104h | 1104h | ICEH248 | PCG-32 | NSN | Jan.Kall@nsn.com | Rel-12 | CP-63 | Kimmo |  |  |
| 1757 | 436.2 | CT3 part of ICE impacts on IMS H.248 profiles (Stage 2) | 73d? | 2014-03-05 A | 2014-06-13 A | 100% | 2014-03-05 | 2014-06-13 | 73d? | finish no earlier than 2014-06-13 | C3 | 584h | 584h | ICEH248 | PCG-32 | NSN | Jan.Kall@nsn.com | Rel-12 | CP-63 | Adrian |  |  |
| 1758 | 437 | **Transfer of ETSI business trunking specifications** | 203d? | 2014-03-05 A | 2014-12-09 A | 100% | 2014-03-05 | 2014-09-17 | 141d? |  | C1; S1 | 5976h | 5976h | IMS_Corp2 | PCG-32 | Alcatel-Lucent | keith.drage@alcatel-lucent.com, Youssef Chadli | Rel-12 | CP-63 | Frederic |  | IMS_Corp2 |
| 1759 | 437.1 | SA1 part of Transfer of ETSI business trunking specifications | 141d? | 2014-03-05 A | 2014-09-17 A | 100% | 2014-03-05 | 2014-09-17 | 141d? | finish no earlier than 2014-09-17 | S1 | 1128h | 1128h | IMS_Corp2 | PCG-32 | Alcatel-Lucent | betsy.covell@alcatel-lucent.com | Rel-12 | SP-63 | Alain | S1-143300 |  |
| 1760 | 437.2 | CT1 part of Transfer of ETSI business trunking specifications | 200d? | 2014-03-05 A | 2014-12-09 A | 100% | 2014-03-05 | 2014-09-12 | 138d? | finish no earlier than 2014-12-09 | C1 | 1600h | 1600h | IMS_Corp2 | PCG-32 | Alcatel-Lucent | keith.drage@alcatel-lucent.com, Youssef Chadli | Rel-12 | CP-63 | Frederic | CP-140619 |  |

Notes:
- 1735: -
- 1736: CP#65 completion 09/14=>12/14. Exception in CP-140481. Dec.14: 90->100 / Impacted TSs and TRs: 23.380, 29.060, 29.274
- 1737: CP#65 completed / Impacted TSs and TRs: 24.008
- 1738: CP#65 updated WID CP-140443=>CP-140490 (added CT3 part). Exception in CP-140687 / Impacted TSs and TRs: 29.061, 29.165
- 1739: -
- 1740: CP#65 completion 09/14=>12/14. Exception in CP-140481. Dec.14: 90->100 / Impacted TSs and TRs: 29.002, 29.228, 29.229, 29.272, 29.305
- 1741: CP#65 completion 09/14=>12/14. Exception in CP-140605. Dec.14: 65->100% / Impacted TSs and TRs: 24.229
- 1742: -
- 1743: CP#65 updated WID CP-140443=>CP-140490 (added CT3 part). Exception in CP-140687 / Impacted TSs and TRs: 29.212, 29.213, 29.214, 29.215
- 1744: CP#65 completion 09/14=>12/14. Exception in CP-140605. Dec.14: 65->100 / Impacted TSs and TRs: 24.229
- 1745: Stage 3. Review the references related to RFC 3265 in the 3GPP IMS specifications and determine the impact of the RFC 6665 changes / Impacted TSs and TRs: Stage 3
- 1746: CP#65 completion 09/14=>12/14. Exception in CP-140620. 3/3/15: 100% cpltd. / Impacted TSs and TRs: 23.218, 24.141, 24.147, 24.229, 24.237, 24.292, 24.337, 24.341, 24.604, 24.606, 24.623, 24.628, 24.629, 24.642
- 1747: CP#62 completed / Impacted TSs and TRs: 29.163, 29.165
- 1748: Added as per CT chair indications on 12th March 2015, no WID, no end date / Impacted TSs and TRs: draft-ietf-sipcore-refer-clarification
- 1749: Added as per CT chair indications on 12th March 2015, no WID, no end date; 14/09/15: 50%->100 / Impacted TSs and TRs: draft-ietf-sipcore-refer-explicit-subscription
- 1750: Added as per CT chair indications on 12th March 2015, no WID, no end date; 14/09/15: 50%->100 / Impacted TSs and TRs: draft-roach-sipcore-6665-clarification
- 1751: Handling of premium rate numbers remained OPEN in Rel-11 (shifted to Rel-12). CP-130384 LS_out sent to SA1 / GSMA informing this TSG CP#60 decision / Impacted TSs and TRs: Stage 3
- 1752: CP#64 completed / Impacted TSs and TRs: 24.229, 24.315
- 1753: CP#65 completed / Impacted TSs and TRs: 29.165
- 1754: CP#65 completion 09/14=>12/14. Exception in CP-140617.Dec.14: 80->85%. 3/3/15: 100% cpltd. / Impacted TSs and TRs: 24.008, 24.301
- 1755: Add optional ICE support as defined in Rel-8 TS (23.228, 24.229) to Iq, Ix, Mn, Mp, Mc interfaces. SA2 Rel-12 TS 23.228 requires support for ICE in eP-CSCF, eIMS-AGW for WebRTC / Impacted TSs and TRs: Stage 2/3
- 1756: CP#65 completed / Impacted TSs and TRs: 23.333, 23.334, 29.232, 29.238, 29.332, 29.333, 29.334
- 1757: CP#64 completed / Impacted TSs and TRs: 29.162, 29.163, 29.292
- 1758: Rel-12 enhancements to business trunking (BusTI). ETSI E2NA(14)000019 asked 3GPP to take responsibility of business communications over IMS: TS 181 019, TS 182 023, TS 182 024, TS 182 025, TR 183 060
- 1759: SP#65 completed. TS 22.519v200 for Approval / Impacted TSs and TRs: New TS 22.519 (ETSI TS 181 019)
- 1760: CP#65 TS 24.525v200 for Approval. TR 24.969v100 for Information. Completion 09/14=>12/14. Exception in CP-140619. Dec.14: 90->100 / Impacted TSs and TRs: New TSs [24.523 (TS 182 023), 24.524 (TS 182 024), 24.525 (TS 182 025)], New TR 24.969 (TR 183 069)

| ID | WBS | Task | Duration | Start | Finish | Complete | Remaining | Baseline start | Baseline finish | Baseline duration | Total slack | Constraint | Resources | Work | Actual work | Acronym | PCG approved | WI rapporteur name | Release | TSG approved | MCC resp | Acronym_3GU_Export | Status Report |
| --- | --- | --- | --- | --- | --- | --- | --- | --- | --- | --- | --- | --- | --- | --- | --- | --- | --- | --- | --- | --- | --- | --- | --- |
| 1761 | 438 | **Support of ALT-C attribute** | 200d? | 2014-03-10 A | 2014-12-09 A | 100% |  | 2014-03-05 | 2014-09-12 | 138d? |  |  | C4; C1; C3 | 9600h | 9600h | ALTC | PCG-32 | Orange | Rel-12 | CP-63 | Kimmo | ALTC |  |
| 1762 | 438.1 | CT4 part of Support of ALT-C attribute | 200d? | 2014-03-10 A | 2014-12-09 A | 100% |  | 2014-03-05 | 2014-09-12 | 138d? |  | finish no earlier than 2014-12-09 | C4 | 1600h | 1600h | ALTC | PCG-32 | Orange | Rel-12 | CP-63 | Kimmo |  | CP-140485 |
| 1763 | 438.2 | CT1 part of Support of ALT-C attribute | 200d? | 2014-03-10 A | 2014-12-09 A | 100% |  | 2014-03-05 | 2014-09-12 | 138d? |  | finish no earlier than 2014-12-09 | C1 | 1600h | 1600h | ALTC | PCG-32 | Orange | Rel-12 | CP-63 | Frederic |  | CP-140611 |
| 1764 | 438.3 | CT3 part of Support of ALT-C attribute | 200d? | 2014-03-10 A | 2014-12-09 A | 100% |  | 2014-03-05 | 2014-06-13 | 73d? |  | finish no earlier than 2014-12-09 | C3 | 1600h | 1600h | ALTC | PCG-32 | Orange | Rel-12 | CP-63 | Adrian |  | CP-140563 |
| 1765 | 439 | **Diameter Overload Control Mechanisms** | 131d? | 2014-06-13 A | 2014-12-09 A | 100% |  | 2014-06-13 | 2014-12-05 | 126d? |  |  | C4; IETF | 4144h | 4144h | DOCME | PCG-33 | Orange | Rel-12 | CP-64 |  | DOCME |  |
| 1766 | 439.1 | CT4 part of Diameter Overload Control Mechanisms | 128d? | 2014-06-13 A | 2014-12-09 A | 100% |  | 2014-06-13 | 2014-09-12 | 66d? |  | finish no earlier than 2014-12-09 | C4 | 1024h | 1024h | DOCME | PCG-33 | Orange | Rel-12 | CP-64 |  |  | CP-140486 |
| 1767 | 439.2 | (IETF) Diameter Overload Control Mechanisms | 128d? | 2014-06-13 A | 2014-12-09 A | 100% |  | 2014-06-13 | 2014-12-05 | 126d? |  | finish no earlier than 2014-12-09 | C4-IETF | 1024h | 1024h | DOCME | PCG-33 | christer.holmberg@ericsson.com | Rel-12 | CP-64 |  |  |  |
| 1768 | 440 | **Impacts of RFC7044 for introduction of the new History-Info header field** | 131d? | 2014-06-13 A | 2014-12-09 A | 100% |  | 2014-06-13 | 2014-09-12 | 66d? |  |  | C1; C3 | 3648h | 3648h | HISTORY_CT | PCG-33 | Deutsche Telekom | Rel-12 | CP-64 |  | HISTORY_CT |  |
| 1769 | 440.1 | CT1 part of Impacts of RFC7044 for introduction of the new History-Info header field | 128d? | 2014-06-13 A | 2014-12-09 A | 100% |  | 2014-06-13 | 2014-09-12 | 66d? |  | finish no earlier than 2014-12-09 | C1 | 1024h | 1024h | HISTORY_CT | PCG-33 | Deutsche Telekom | Rel-12 | CP-64 |  |  | CP-140609 |
| 1770 | 440.2 | CT3 part of Impacts of RFC7044 for introduction of the new History-Info header field | 66d? | 2014-06-13 A | 2014-09-11 A | 100% |  | 2014-06-13 | 2014-09-12 | 66d? |  | finish no earlier than 2014-09-12 | C3 | 528h | 528h | HISTORY_CT | PCG-33 | Deutsche Telekom | Rel-12 | CP-64 |  |  |  |
| 1771 | 441 | **Indication of NNI Routeing scenarios in SIP requests** | 131d? | 2014-06-13 A | 2014-12-09 | 100% | 0d? | 2014-06-13 | 2014-12-05 | 126d? | 0d |  | C1; C3; IETF | 5456h | 4408h | NNI_RS | PCG-33 | Ericsson | Rel-12 | CP-64 |  | NNI_RS |  |
| 1772 | 441.1 | CT1 part of Indication of NNI Routeing scenarios in SIP requests | 128d? | 2014-06-13 A | 2014-12-09 A | 100% |  | 2014-06-13 | 2014-09-12 | 66d? |  | finish no earlier than 2014-12-09 | C1 | 1024h | 1024h | NNI_RS | PCG-33 | Ericsson | Rel-12 | CP-64 |  |  | CP-140613 |
| 1773 | 441.2 | (IETF) CT1 part of Indication of NNI Routeing scenarios in SIP requests (holmberg-dispatch-iotl) | 95d? | 2014-06-13 A | 2014-12-09 A | 100% |  | 2014-06-13 | 2014-12-05 | 93d? |  | finish no earlier than 2014-12-09 | C1-IETF | 760h | 760h | NNI_RS | PCG-33 | christer.holmberg@ericsson.com | Rel-12 | CP-64 |  |  |  |
| 1774 | 441.3 | CT3 part of Indication of NNI Routeing scenarios in SIP requests | 66d? | 2014-06-13 A | 2014-09-11 A | 100% |  | 2014-06-13 | 2014-09-12 | 66d? |  | finish no earlier than 2014-09-12 | C3 | 528h | 528h | NNI_RS | PCG-33 | Ericsson | Rel-12 | CP-64 |  |  |  |
| 1775 | 442 | Unstructured Supplementary Service Data (USSD) method selection (Stage 3) | 3d? | 2014-06-11 A | 2014-06-13 A | 100% |  | 2014-06-11 | 2014-06-13 | 3d? |  | finish no earlier than 2014-06-13 | C1 | 24h | 24h | USSD_MS | PCG-33 | Ericsson | Rel-12 | CP-64 |  | USSD_MS |  |
| 1776 | 443 | Representational State Transfer (REST) reference point between Application Function (AF) and Protocol Converter (PC) | 128d? | 2014-06-13 A | 2014-12-09 A | 100% |  | 2014-06-13 | 2014-09-12 | 66d? |  | finish no earlier than 2014-12-09 | C3 | 1024h | 1024h | REST_AF_PC | PCG-33 | Alcatel-Lucent | Rel-12 | CP-64 |  | REST_AF_PC | CP-140561 |
| 1777 | 444 | **Overload Control for PCC based Diameter applications** | 131d? | 2014-06-13 A | 2014-12-09 A | 100% |  | 2014-06-13 | 2014-12-05 | 126d? |  |  | C3; IETF | 3648h | 3648h | DOCME-PCC | PCG-33 | Huawei | Rel-12 | CP-64 |  | DOCME-PCC |  |
| 1778 | 444.1 | CT3 part of Overload Control for PCC based Diameter applications | 66d? | 2014-06-13 A | 2014-09-11 A | 100% |  | 2014-06-13 | 2014-09-12 | 66d? |  | finish no earlier than 2014-09-12 | C3 | 528h | 528h | DOCME-PCC | PCG-33 | Huawei | Rel-12 | CP-64 |  |  |  |
| 1779 | 444.2 | (IETF) Overload Control for PCC based Diameter applications | 128d? | 2014-06-13 A | 2014-12-09 A | 100% |  | 2014-06-13 | 2014-12-05 | 126d? |  | finish no earlier than 2014-12-09 | C3-IETF | 1024h | 1024h | DOCME-PCC | PCG-33 | christer.holmberg@ericsson.com | Rel-12 | CP-64 |  |  |  |
| 1780 | 445 | Network Initiated USSD Simulation Services in IMS | 63d? | 2014-09-12 A | 2014-12-09 A | 100% |  |  |  |  |  | finish no earlier than 2014-12-09 | C1 | 504h | 504h | USSI-NET | PCG-33 | AT&T | Rel-12 | CP-65 |  | USSI-NET | CP-140610 |
| 1781 | 446 | **Introduction of ER-GSM band for GSM-R** | 651d? | 2011-09-16 A | 2014-02-28 A | 100% |  | 2011-09-16 | 2014-02-28 | 651d? |  |  | G1; C1; G3new | 26496h | 26496h | RT_ERGSM | PCG-27 | Kapsch Carriercom, Sierra Wireless | Rel-12 | GP-51 | Paolo | RT_ERGSM |  |
| 1782 | 446.1 | GERAN1 part of Introduction of ER-GSM band for GSM-R | 647d? | 2011-09-16 A | 2014-02-28 A | 100% |  | 2011-09-16 | 2014-02-28 | 647d? |  | finish no earlier than 2014-02-28 | G1 | 5168h | 5168h | RT_ERGSM | PCG-27 | Kapsch Carriercom, Sierra Wireless | Rel-12 | GP-51 | Paolo |  |  |
| 1783 | 446.2 | Test part: Introduction of ER-GSM band for GSM-R | 131d? | 2013-09-02 A | 2014-02-28 A | 100% |  | 2013-09-02 | 2014-02-28 | 131d? |  | finish no earlier than 2014-02-28 | G3new | 1048h | 1048h | RT_ERGSM | PCG-31 | Kapsch Carriercom, Sierra Wireless | Rel-12 | GP-59 | Ingbert |  |  |
| 1784 | 446.3 | CT1 part of Introduction of ER-GSM band for GSM-R | 582d? | 2011-09-28 A | 2013-12-06 A | 100% |  | 2011-09-28 | 2013-12-06 | 582d? |  | finish no earlier than 2013-12-06 | C1 | 4656h | 4656h | RT_ERGSM | PCG-27 | Kapsch Carriercom, Sierra Wireless | Rel-12 | CP-53 | Frederic |  |  |

Notes:
- 1761: SA2 TS 23.228 requires UEs supporting IPv4, IPv6 or both IPv4 and IPv6 IP address formats shall be supported by IMS. Specify procedures to support altc SDP attribute within IMS for terminating communications destined to an enterprise network. / WI rapporteur e-mail: lionel.morand@orange.com
- 1762: CP#65 completion 09/14=>12/14. Exception in CP-140485. Dec.14: 0->100 / Impacted TSs and TRs: 23.334, 29.238, 29.334 / WI rapporteur e-mail: lionel.morand@orange.com
- 1763: CP#65 completion 09/14=>12/14. Exception in CP-140611. Dec.14: 0->100 / Impacted TSs and TRs: 24.229 / WI rapporteur e-mail: lionel.morand@orange.com
- 1764: CP#65 completion 09/14=>12/14. Exception in CP-140563. Dec.14: 0->100 / Impacted TSs and TRs: 29.162 / WI rapporteur e-mail: lionel.morand@orange.com
- 1765: Triggered by TR 29.809 Study on Diameter overload control mechanism (FS_DOCME) / WI rapporteur e-mail: lionel.morand@orange.com
- 1766: CP#65 completion 09/14=>12/14. Exception in CP-140486. Dec.14: 70->100 / Impacted TSs and TRs: 29.228, 29.229, 29.272, 29.273, 29.328, 29.329, 29.336, 29.337, 29.344, 29.345 / WI rapporteur e-mail: lionel.morand@orange.com
- 1767: Mar15: In WGLC; 7/3/16: 50%->100 / Impacted TSs and TRs: draft-ietf-dime-ovli / WI rapporteur e-mail: christer.holmberg@ericsson.com
- 1768: IETF updated RFC4244 for History-Info header field to RFC7044. IETF introduced new features which could be useful for 3GPP use cases. / WI rapporteur e-mail: Roland Jesske (r.jesske@telekom.de)
- 1769: CP#65 completion 09/14=>12/14. Exception in CP-140609. Dec.14: 85->100 / Impacted TSs and TRs: 24.229, 24.259, 24.604 / WI rapporteur e-mail: Roland Jesske (r.jesske@telekom.de)
- 1770: CP#65 completed / Impacted TSs and TRs: 29.163, 29.165, 29.292 / WI rapporteur e-mail: Roland Jesske (r.jesske@telekom.de)
- 1771: Triggered by TR 24.802 Study on Indication of Network to Network Interface (NNI) Routeing scenarios in SIP requests UID_580025 / WI rapporteur e-mail: Jan.Holm@ericsson.com
- 1772: CP#65 completion 09/14=>12/14. Exception in CP-140613. Dec.14: 95->100 / Impacted TSs and TRs: 24.229 / WI rapporteur e-mail: Jan.Holm@ericsson.com
- 1773: Publication requested; 7/3/16: 50%->100 / Impacted TSs and TRs: draft-holmberg-dispatch-iotl / WI rapporteur e-mail: christer.holmberg@ericsson.com
- 1774: CP#65 completed / Impacted TSs and TRs: 29.079, 29.165 / WI rapporteur e-mail: Jan.Holm@ericsson.com
- 1775: CP#64 approved WID & completed. Related to R11 USSD simulation service in IMS (delivery of UE originating USSD request using IMS, I.e. introduce 2nd method for delivery of UE originating USSD request to network (additional to USSD using CS domain) / Impacted TSs and TRs: 24.173, 24.390, New TS 24.391 / WI rapporteur e-mail: ivo.sedlacek@ericsson.com
- 1776: CP#65 completion 09/14=>12/14. TS 29.201v200 for Approval. Exception in CP-140561. Dec.14: 80->100 / Impacted TSs and TRs: 29.213, 29.214, new TS 29.201 / WI rapporteur e-mail: horst.brinkmann@alcatel-lucent.com
- 1777: Triggered by TR 29.809 Study on Diameter overload control mechanism (FS_DOCME) / WI rapporteur e-mail: Xia Haitao (xiahaitao@huawei.com)
- 1778: CP#65 completed / Impacted TSs and TRs: 29.212, 29.213, 29.214 / WI rapporteur e-mail: Xia Haitao (xiahaitao@huawei.com)
- 1779: work in progress; 7/3/16: 50%->100 / Impacted TSs and TRs: draft-ietf-dime-ovli / WI rapporteur e-mail: christer.holmberg@ericsson.com
- 1780: CP#65 exception in CP-140610. Dec.14: 75->100 / Impacted TSs and TRs: 24.390 / WI rapporteur e-mail: Martin Dolly (md3135@att.com)
- 1781: Use of band 870-876/915-921 MHz for land mobile service on national possibilities/market demand - as per ECC/DEC/(04)06. Introduction of ERGSM band, Performance requirements and Deployment scenarios. / Impacted TSs and TRs: GERAN / WI rapporteur e-mail: thomas.chatelet@kapsch.net, Rémi Lascoux (rlascoux@sierrawireless.com)
- 1782: GP#61 completed. GP#51 approved WID / Impacted TSs and TRs: 45.001, 45.005, 45.008, 45.050 / WI rapporteur e-mail: thomas.chatelet@kapsch.net, Rémi Lascoux (rlascoux@sierrawireless.com)
- 1783: GP#61 completed / Impacted TSs and TRs: 51.010, 51.021 / WI rapporteur e-mail: thomas.chatelet@kapsch.net, Rémi Lascoux (rlascoux@sierrawireless.com)
- 1784: CP#62 completed. Added ERGSM capability indication (24.008 CR#2469R1) / Impacted TSs and TRs: 24.008 / WI rapporteur e-mail: thomas.chatelet@kapsch.net, Rémi Lascoux (rlascoux@sierrawireless.com)

| ID | WBS | Task | Duration | Start | Finish | Complete | Remaining | Baseline start | Baseline finish | Baseline duration | Total slack | Constraint | Resources | Work | Actual work | Acronym | PCG approved | WI rapporteur name | Release | TSG approved | MCC resp | Acronym_3GU_Export | Status Report | Special Focus Doc | PCG stopped | TSG stopped |
| --- | --- | --- | --- | --- | --- | --- | --- | --- | --- | --- | --- | --- | --- | --- | --- | --- | --- | --- | --- | --- | --- | --- | --- | --- | --- | --- |
| 1785 | 447 | **Downlink Multi Carrier GERAN** | 666d? | 2012-09-10 A | 2015-03-13 | 91% | 61.92d? | 2012-09-10 | 2014-09-12 | 533d? | 807d |  | G2; G1; C1; G3new | 34536h | 12164.8h | DMCG | PCG-29 | Ericsson | Rel-12 | GP-55 | Gert | DMCG |  |  |  |  |
| 1786 | 447.1 | Core part: Downlink Multi Carrier GERAN | 229d? | 2013-07-22 A | 2014-05-30 A | 100% |  | 2013-07-22 | 2014-05-30 | 229d? |  | finish no earlier than 2014-05-30 | G2; G1 | 3664h | 3664h | DMCG | PCG-29 | Ericsson | Rel-12 | GP-55 | Gert |  |  |  |  |  |
| 1787 | 447.2 | CT part: Downlink Multi Carrier GERAN | 533d? | 2012-09-10 A | 2014-09-11 A | 100% |  | 2012-09-10 | 2014-09-12 | 533d? |  | finish no earlier than 2014-09-12 | C1 | 4264h | 4264h | DMCG | PCG-29 | Ericsson | Rel-12 | GP-55 | Frederic |  |  |  |  |  |
| 1788 | 447.3 | Test part: Downlink Multi Carrier GERAN | 662d? | 2012-09-10 A | 2015-03-13 | 80% | 132.4d? | 2012-09-10 | 2014-08-29 | 522d? | 807d | finish no earlier than 2015-03-13 | G3new | 5296h | 4236.8h | DMCG-MStest | PCG-29 | ST-Ericsson | Rel-12 | GP-55 | Ingbert | DMCG-MStest |  |  |  |  |
| 1789 | 448 | **Mobile Station Receive Diversity (MSRD) for Voice Services over Adaptive Multi-user channels on One Slot (VAMOS)** | 459d? | 2013-03-01 A | 2014-11-21 A | 100% |  | 2013-03-01 | 2014-08-29 | 396d? |  |  | G1; G2; C1; G3new | 24064h | 24064h | MSRD_VAMOS | PCG-30 | Nokia Networks, Microsoft | Rel-12 | GP-57 | Paolo | MSRD_VAMOS | GP-140579 |  |  |  |
| 1790 | 448.1 | CT1 introduction of MS capability support for MS supporting MSRD for VAMOS | 205d? | 2013-03-01 A | 2013-12-06 A | 100% |  | 2013-03-01 | 2013-12-06 | 205d? |  | finish no earlier than 2013-12-06 | C1 | 1640h | 1640h | MSRD_VAMOS | PCG-30 | Nokia Networks, Microsoft | Rel-12 | GP-57 | Frederic |  |  |  |  |  |
| 1791 | 448.2 | MSRD for VAMOS - Performance Requirements | 257.5d? | 2013-11-28 A | 2014-11-21 A | 100% |  | 2013-11-28 | 2014-08-29 | 197.5d? |  | finish no earlier than 2014-11-21 | G1; G2 | 4120h | 4120h | MSRD_VAMOS-PerfReq | PCG-30 | Nokia Networks, Microsoft | Rel-12 | GP-57 | Paolo | MSRD_VAMOS-PerfReq | GP-140579 |  |  |  |
| 1792 | 448.3 | MSRD for VAMOS - MS Conformance Test | 453d? | 2013-03-06 A | 2014-11-21 A | 100% |  | 2013-03-06 | 2014-08-29 | 393d? |  | finish no earlier than 2014-11-21 | G3new | 3616h | 3616h | MSRD_VAMOS-Test | PCG-30 | Nokia Networks, Microsoft | Rel-12 | GP-57 | Ingbert | MSRD_VAMOS-Test | GP-140579 |  |  |  |
| 1793 | 449 | **New Training Sequence Codes (TSC) for GERAN** | 277d? | 2013-11-22 A | 2014-12-09 | 93% | 18.18d? | 2013-11-22 | 2014-08-29 | 202d? | 875d |  | G1; G2; C1 | 11184h | 10449.7h | NewToN | PCG-32 | Ericsson | Rel-12 | GP-60 | Paolo | NewToN | GP-140542 |  |  |  |
| 1794 | 449.1 | GERAN1 part of New Training Sequence Codes (TSC) for GERAN | 261d? | 2013-11-22 A | 2014-11-21 A | 100% |  | 2013-11-22 | 2014-08-29 | 201d? |  | finish no earlier than 2014-11-21 | G1 | 2088h | 2088h | NewToN | PCG-32 | Ericsson | Rel-12 | GP-60 | Paolo |  | GP-140542 |  |  |  |
| 1795 | 449.2 | GERAN2 part of New Training Sequence Codes (TSC) for GERAN | 261d? | 2013-11-22 A | 2014-11-21 | 80% | 52.2d? | 2013-11-22 | 2014-08-29 | 201d? | 887d | finish no earlier than 2014-11-21 | G2 | 2088h | 1670.4h | NewToN | PCG-32 | Ericsson | Rel-12 | GP-60 | Gert |  | GP-140542 |  |  |  |
| 1796 | 449.3 | CT1 part of New Training Sequence Codes (TSC) for GERAN (Stage 3) | 273d? | 2013-11-22 A | 2014-12-09 A | 100% |  | 2013-11-22 | 2014-08-29 | 201d? |  | finish no earlier than 2014-12-09 | C1 | 2184h | 2184h | NewToN | PCG-32 | Ericsson | Rel-12 | GP-60 | Frederic |  | CP-140604 |  |  |  |
| 1797 | 450 | **Verification of radiated multi-antenna reception performance of UEs in LTE/UMTS** | 469d? | 2012-03-05 A | 2013-12-06 A | 100% |  | 2012-03-05 | 2013-12-06 | 469d? |  |  | R4 | 7464h | 7464h | HSPA_LTE_measRP_MIMO | PCG-28 | Vodafone | Rel-12 | RP-55 | Issam | HSPA_LTE_measRP_MIMO |  |  |  |  |
| 1798 | 450.1 | Perf. Part: Verification of radiated multi-antenna reception performance of UEs in LTE/UMTS | 464d? | 2012-03-05 A | 2013-12-06 A | 100% |  | 2012-03-05 | 2013-12-06 | 464d? |  | finish no earlier than 2013-12-06 | R4 | 3712h | 3712h | HSPA_LTE_measRP_MIMO-Perf | PCG-28 | Vodafone | Rel-12 | RP-55 | Issam | HSPA_LTE_measRP_MIMO-Perf | RP-131507 |  |  |  |
| 1799 | 451 | **Further enhancements to H(e)NB mobility - Part 3 (Stage 2/3)** | 330d? | 2012-09-12 A | 2013-12-06 A | 100% |  | 2012-09-12 | 2013-12-06 | 330d? |  |  | R3; R2 | 10560h | 10560h | EHNB_enh3 | PCG-29 | Alcatel-Lucent | Rel-12 | RP-57 | Juha | EHNB_enh3 |  | HNB |  |  |
| 1800 | 451.1 | Core part: Further enhancements to H(e)NB mobility - Part 3 | 330d? | 2012-09-12 A | 2013-12-06 A | 100% |  | 2012-09-12 | 2013-12-06 | 330d? |  | finish no earlier than 2013-12-06 | R3; R2 | 5280h | 5280h | EHNB_enh3-Core | PCG-29 | Alcatel-Lucent | Rel-12 | RP-57 | Juha | EHNB_enh3-Core | RP-131508 | HNB |  |  |
| 1801 | 452 | **Support for BeiDou Navigation Satellite System (BDS) for UTRA and LTE** | 604d? | 2013-03-04 A | 2015-06-15 A | 100% |  | 2013-03-04 | 2015-06-12 | 600d? |  |  | R2; R3; R4; R5 | 31680h | 31680h | LCS_BDS | PCG-30 | CATR | Rel-12 | RP-59 | Yong-Jun | LCS_BDS |  |  |  |  |
| 1802 | 452.1 | Core part: Support for BeiDou Navigation Satellite System (BDS) for UTRA | 204d? | 2013-06-02 A | 2014-03-06 A | 100% |  | 2013-06-02 | 2014-03-06 | 204d? |  | finish no earlier than 2014-03-06 | R2; R3 | 3264h | 3264h | LCS_BDS-UTRA-Core | PCG-30 | ZTE | Rel-12 | RP-59 | Yong-Jun | LCS_BDS-UTRA-Core | RP-131500 |  |  |  |
| 1803 | 452.2 | Perf. part: Support for BeiDou Navigation Satellite System (BDS) for UTRA | 336d? | 2013-03-07 A | 2014-06-13 A | 100% |  | 2013-03-07 | 2014-06-13 | 336d? |  | finish no earlier than 2014-06-13 | R4 | 2688h | 2688h | LCS_BDS-UTRA-Perf | PCG-30 | ZTE | Rel-12 | RP-59 | Issam | LCS_BDS-UTRA-Perf | RP-140714 |  |  |  |
| 1804 | 452.3 | Core part: Support for BeiDou Navigation Satellite System (BDS) for LTE | 202d? | 2013-03-04 A | 2013-12-06 A | 100% |  | 2013-03-04 | 2013-12-06 | 202d? |  | finish no earlier than 2013-12-06 | R2 | 1616h | 1616h | LCS_BDS-LTE-Core | PCG-30 | CATR | Rel-12 | RP-59 | Yong-Jun | LCS_BDS-LTE-Core | RP-131525 |  |  |  |
| 1805 | 452.4 | Perf. part: Support for BeiDou Navigation Satellite System (BDS) for LTE | 336d? | 2013-03-07 A | 2014-06-13 A | 100% |  | 2013-03-07 | 2014-06-13 | 336d? |  | finish no earlier than 2014-06-13 | R4 | 2688h | 2688h | LCS_BDS-LTE-Perf | PCG-30 | ZTE | Rel-12 | RP-59 | Issam | LCS_BDS-LTE-Perf | RP-140713 |  |  |  |
| 1806 | 452.5 | Test part: BeiDou Navigation Satellite System (BDS) Positioning Support for LTE and UMTS | 262d? | 2014-06-15 A | 2015-06-15 A | 100% |  | 2014-06-13 | 2015-06-12 | 261d? |  | finish no earlier than 2015-06-15 | R5 | 2096h | 2096h | LCS_BDS-UEConTest | PCG-33 | CATT | Rel-12 | RP-64 |  | LCS_BDS-UEConTest | RP-150656 |  |  |  |
| 1807 | 453 | **Support for BeiDou Navigation Satellite System (BDS) for LCS in GERAN** | 345d? | 2013-11-22 A | 2015-03-13 | 93% | 25.19d? | 2013-11-22 | 2014-11-21 | 262d? | 807d |  | G2; G1; G3new | 14213.2h | 5848.39h | LCS_BDS_GERAN | PCG-32 | ZTE | Rel-12 | GP-60 | Gert | LCS_BDS_GERAN |  |  |  |  |
| 1808 | 453.1 | GERAN2 part of Support for BeiDou Navigation Satellite System (BDS) for LCS in GERAN | 201d? | 2013-11-22 A | 2014-08-29 A | 100% |  | 2013-11-22 | 2014-08-29 | 201d? |  | finish no earlier than 2014-08-29 | G2 | 1608h | 1608h | LCS_BDS_GERAN | PCG-32 | ZTE | Rel-12 | GP-60 | Gert |  |  |  |  |  |
| 1809 | 453.2 | GERAN1 part of Support for BeiDou Navigation Satellite System (BDS) for LCS in GERAN | 201d? | 2013-11-22 A | 2014-08-29 A | 100% |  | 2013-11-22 | 2014-08-29 | 201d? |  | finish no earlier than 2014-08-29 | G1 | 1608h | 1608h | LCS_BDS_GERAN | PCG-32 | ZTE | Rel-12 | GP-60 | Paolo |  |  |  |  |  |
| 1810 | 453.3 | Support for BeiDou Navigation Satellite System (BDS) for LCS in GERAN3new | 272d? | 2014-03-01 A | 2015-03-13 | 80% | 54.4d? | 2014-02-28 | 2014-11-21 | 192d? | 807d | finish no earlier than 2015-03-13 | G3new | 2176h | 1740.8h | LCS_BDS_GERAN-GERAN3new | PCG-32 | CATR | Rel-12 | GP-61 | Ingbert | LCS_BDS_GERAN-GERAN3new |  |  |  |  |
| 1811 | 453.4 | Deleted - Test part: Support for BeiDou Navigation Satellite System (BDS) for LCS in GERAN | 71d? | 2013-11-22 A | 2014-02-28 A | 100% |  | 2013-11-22 | 2014-02-28 | 71d? |  | finish no earlier than 2014-08-29 | G3new | 565.19h | 565.19h | LCS_BDS_GERAN-MStest | PCG-32 | ZTE | Rel-12 | GP-60 | Ingbert | LCS_BDS_GERAN-MStest |  |  | PCG-32 | GP-61 |

Notes:
- 1785: Linked to Rel-7 Downlink Dual Carrier UID_50579 (Previous work on multiple carriers on the downlink was limited to two). Ref: TR 45.912 Feasibility study for evolved GERAN, TS 43.064 GPRS Stage 2 / Impacted TSs and TRs: GERAN / WI rapporteur e-mail: paul.schliwa-bertling@ericsson.com
- 1786: GP#62 completed. GP#55 approved WID / Impacted TSs and TRs: 43.064, 44.004, 44.018, 44.060, 45.002, 45.003, 45.005, 45.008, 48.018 / WI rapporteur e-mail: paul.schliwa-bertling@ericsson.com
- 1787: CP#65 completed / Impacted TSs and TRs: 24.008 / WI rapporteur e-mail: paul.schliwa-bertling@ericsson.com
- 1788: GP#63 completion 08/14=>11/14. Dec.14: 35->80%, CD:11/14->03/15 / Impacted TSs and TRs: 51.010-1, 51.010-2 / WI rapporteur e-mail: hakan.e.grunditz@stericsson.com
- 1789: GP#63 completion 08/14=>11/14. Exception in GP-140579. Linked to Rel-7 Mobile Station Receive Diversity (DARP Phase II) UID_50569, Rel-9 Voice Services over Adaptive Multiuser channels on One Slot (VAMOS) UID_420002 / Impacted TSs and TRs: GERAN / WI rapporteur e-mail: Khairul Hasan (Nokia Networks), Markku Tarkiainen (Nokia=>Microsoft)
- 1790: CP#62 completed / Impacted TSs and TRs: 24.008 / WI rapporteur e-mail: Khairul Hasan (Nokia Networks), Markku Tarkiainen (Nokia=>Microsoft)
- 1791: GP#63 completion 08/14=>11/14. Exception in GP-140579. Dec.14: 95->100 / Impacted TSs and TRs: 44.018, 45.001, 45.002, 45.005, 45.008, 45.009 / WI rapporteur e-mail: Khairul Hasan (Nokia Networks), Markku Tarkiainen (Nokia=>Microsoft)
- 1792: GP#63 completion 08/14=>11/14. Exception in GP-140579. Dec.14: 85->100 / Impacted TSs and TRs: 51.010-1, 51.010-2 / WI rapporteur e-mail: Khairul Hasan (Nokia Networks), Markku Tarkiainen (Nokia=>Microsoft)
- 1793: GP#63 completion 08/14=>11/14. Exception in GP-140542. GP#60 approved WID. Triggered by GP-131041, GP#40 GP-081949 (WID VAMOS). Linked to Rel-9 VAMOS (Previous work where new TSCs were defined for GMSK modulation) UID_420002 / Impacted TSs and TRs: GERAN / WI rapporteur e-mail: Mårten Sundberg
- 1794: GP#63 completion 08/14=>11/14. Exception in GP-140542. Dec.14: 80->100% / Impacted TSs and TRs: 45.001, 45.002, 45.008, 45.009, 45.050 / WI rapporteur e-mail: Mårten Sundberg
- 1795: GP#63 completion 08/14=>11/14. Exception in GP-140542. / Impacted TSs and TRs: 44.018, 44.060 / WI rapporteur e-mail: Mårten Sundberg
- 1796: CP#65 completion 09/14=>12/14. CP#65 exception in CP-140604. 3/3/15: 100% cpltd. / Impacted TSs and TRs: 24.008 / WI rapporteur e-mail: Mårten Sundberg
- 1797: RP#59 moved to Rel-12. Triggered by FS_HSPA_LTE_measRP_MIMO_multi-antenna. Core functionality exists since Rel-6 & Rel-7 (MIMO). Adds a very generic test method to test UEs with 2 or more Rx antennas / Impacted TSs and TRs: UTRA, LTE / WI rapporteur e-mail: Luis Anaya
- 1798: RP#62 completed. Rx diversity (defined as Rel-6 HSDPA RAN4 enhanced type 1 req.) & MIMO (defined as Rel-7 HSDPA MIMO for HSPA). Rx diversity & MIMO (defined as part of Rel-8 basic LTE WI) / Impacted TSs and TRs: new TR 37.977 / WI rapporteur e-mail: luis.anaya@vodafone.com
- 1799: Triggered by FS_EHNB_enh (TR 37.803) / Impacted TSs and TRs: UTRA, LTE / WI rapporteur e-mail: Martin.Warner@alcatel-lucent.com
- 1800: RP#62 completed / Impacted TSs and TRs: 25.304, 25.331, 25.367, 25.467, 25.469, 36.300, 36.331 / WI rapporteur e-mail: Martin.Warner@alcatel-lucent.com
- 1801: BeiDou = Chinese Navigation Satellite System. Location Services (LCS) TS 22.071 Stage 1, TS 23.271 Stage 2 / Impacted TSs and TRs: UTRA, LTE / WI rapporteur e-mail: Ying Du (duying1@catr.cn)
- 1802: RP#62 completed / Impacted TSs and TRs: 25.305, 25.306, 25.331, 25.453, 25.413, 25.423, 25.433 / WI rapporteur e-mail: Huang He (huang.he4@zte.com.cn)
- 1803: RP#64 completed. TS 25.173v100 for 1-step Approval / Impacted TSs and TRs: 25.172 (FDD), new TS 25.173 (TDD) / WI rapporteur e-mail: Ling Soonleh (soonleh.ling@zte.com.cn)
- 1804: RP#62 completed / Impacted TSs and TRs: 36.305, 36.355 / WI rapporteur e-mail: Ying Du (duying1@catr.cn)
- 1805: RP#64 completed / Impacted TSs and TRs: 36.171 / WI rapporteur e-mail: Ling Soonleh (soonleh.ling@zte.com.cn)
- 1806: ; Stat Rep: RP-141350->RP-141950 1st Apr 15: Compl:80%->90% 1st Apr 15: Stat Rep: RP-141950->RP-150357 03/07/15: Compl:90%->100% 03/07/15: Stat Rep: RP-150357->RP-150656 / Impacted TSs and TRs: 34.108, 36.508, 37.571-1, 37.571-2, 37.571-3, 37.571-4, 37.571-5 / WI rapporteur e-mail: Chen Xiaiozhong (chenxiaozhong@catt.cn)
- 1807: GP#60 approved WID. Based on the same framework used in Rel-8 Support for Additional Navigation Satellite Systems (ANSS) for LCS UID_38001 / Impacted TSs and TRs: GERAN / WI rapporteur e-mail: Wang Xinhui (wangxinhui@zte.com.cn)
- 1808: GP#63 completed / Impacted TSs and TRs: 44.031, 49.031, 44.071, 48.031 / WI rapporteur e-mail: Wang Xinhui (wangxinhui@zte.com.cn)
- 1809: GP#63 completed / Impacted TSs and TRs: 43.059, 45.005 / WI rapporteur e-mail: Wang Xinhui (wangxinhui@zte.com.cn)
- 1810: Dec.14: 25->80%, CD: 11/14->03/15 / Impacted TSs and TRs: 51010-1, 51.010-2, 51.010-7 / WI rapporteur e-mail: Zhou DaiWei, China Academy of Telecommunication Research, zhoudaiwei@catr.cn
- 1811: GP#61 stopped / Impacted TSs and TRs: 51.010-1 / WI rapporteur e-mail: Wang Xinhui (wangxinhui@zte.com.cn)

| ID | WBS | Task | Duration | Start | Finish | Complete | Remaining | Baseline start | Baseline finish | Baseline duration | Total slack | Constraint | Resources | Work | Actual work | Acronym | PCG approved | WI rapporteur name | WI rapporteur e-mail | Release | TSG approved | MCC resp | PCG stopped | TSG stopped | Acronym_3GU_Export | Status Report | Special Focus Doc |
| --- | --- | --- | --- | --- | --- | --- | --- | --- | --- | --- | --- | --- | --- | --- | --- | --- | --- | --- | --- | --- | --- | --- | --- | --- | --- | --- | --- |
| 1812 | 454 | **Deleted - New Base Station specification structure** | 127d? | 2013-06-18 A | 2013-12-06 A | 100% |  | 2013-06-18 | 2013-12-06 | 127d? |  |  | R4 | 3024h | 3024h | BSspec_struc | PCG-31 | Ericsson | johan.skold@ericsson.com | Rel-12 | RP-60 | Issam | PCG-32 | RP-62 | BSspec_struc |  |  |
| 1813 | 454.1 | Deleted - Core part: New Base Station specification structure | 126d? | 2013-06-18 A | 2013-12-06 A | 100% |  | 2013-06-18 | 2013-12-06 | 126d? |  | finish no earlier than 2013-12-06 | R4 | 1008h | 1008h | BSspec_struc-Core | PCG-31 | Ericsson | johan.skold@ericsson.com | Rel-12 | RP-60 | Issam | PCG-32 | RP-62 | BSspec_struc-Core | RP-131513 |  |
| 1814 | 454.2 | Deleted - Perf. part: New Base Station specification structure | 125d? | 2013-06-20 A | 2013-12-06 A | 100% |  | 2013-06-20 | 2013-12-06 | 125d? |  | finish no earlier than 2013-12-06 | R4 | 1000h | 1000h | BSspec_struc-Perf | PCG-31 | Ericsson | johan.skold@ericsson.com | Rel-12 | RP-60 | Issam | PCG-32 | RP-62 | BSspec_struc-Perf | RP-131514 |  |
| 1815 | 455 | **L-band for Supplemental Downlink in E-UTRA and UTRA** | 659d? | 2013-06-17 A | 2015-12-15 A | 100% |  | 2013-06-17 | 2014-06-13 | 264d? |  |  | R4; R2; R3 | 21600h | 21600h | LTE_UTRA_SDL_BandL | PCG-31 | Orange | olfa.benhaddada@orange.com | Rel-12 | RP-60 | Issam |  |  | LTE_UTRA_SDL_BandL |  |  |
| 1816 | 455.1 | Core part: L-band for Supplemental Downlink in E-UTRA and UTRA | 87.33d? | 2014-02-13 A | 2014-06-13 A | 100% |  | 2014-02-13 | 2014-06-13 | 87.33d? |  | finish no earlier than 2014-06-13 | R4; R2; R3 | 2096h | 2096h | LTE_UTRA_SDL_BandL-Core | PCG-31 | Orange | olfa.benhaddada@orange.com | Rel-12 | RP-60 | Issam |  |  | LTE_UTRA_SDL_BandL-Core | RP-140633 |  |
| 1817 | 455.2 | Perf. part: L-band for Supplemental Downlink in E-UTRA and UTRA | 264d? | 2013-06-17 A | 2014-06-13 A | 100% |  | 2013-06-17 | 2014-06-13 | 264d? |  | finish no earlier than 2014-06-13 | R4 | 2112h | 2112h | LTE_UTRA_SDL_BandL-Perf | PCG-31 | Orange | olfa.benhaddada@orange.com | Rel-12 | RP-60 | Issam |  |  | LTE_UTRA_SDL_BandL-Perf | RP-140633 |  |
| 1818 | 455.3 | UE Conformance Test Aspects - L-band for Supplemental Downlink in E-UTRA and UTRA | 197d? | 2015-03-16 A | 2015-12-15 A | 100% |  |  |  |  |  | finish no earlier than 2015-12-15 | R5 | 1576h | 1576h | LTE_UTRA_SDL_BandL-UEConTest | PCG-34 | Ericsson |  | Rel-12 | RP-67 |  |  |  |  | RP-151163 |  |
| 1819 | 456 | **LTE-HRPD (High Rate Packet Data in 3GPP2) inter-RAT SON** | 263d? | 2013-06-18 A | 2014-06-13 A | 100% |  | 2013-06-18 | 2014-06-13 | 263d? |  |  | R3; S2; C4; G2 | 11096h | 11096h | LTE_HRPD_SON | PCG-31 | China Telecom | Jinlian_wu@189.cn | Rel-12 | RP-60 | Juha |  |  | LTE_HRPD_SON |  | SON |
| 1820 | 456.1 | Stage 2 for LTE-HRPD (High Rate Packet Data in 3GPP2) inter-RAT SON | 67d? | 2013-09-11 A | 2013-12-11 A | 100% |  | 2013-09-11 | 2013-12-11 | 67d? |  | finish no earlier than 2013-09-11 | S2 | 528h | 528h | LTE_HRPD_SON | PCG-31 | Huawei | Huan Li (ivy.lihuan@huawei.com) | Rel-12 | SP-61 | Maurice |  |  |  |  |  |
| 1821 | 456.2 | Core part: LTE-HRPD (High Rate Packet Data in 3GPP2) inter-RAT SON | 263d? | 2013-06-18 A | 2014-06-13 A | 100% |  | 2013-06-18 | 2014-06-13 | 263d? |  | finish no earlier than 2014-06-13 | R3 | 2088h | 2088h | LTE_HRPD_SON-Core | PCG-31 | China Telecom | Jinlian_wu@189.cn | Rel-12 | RP-60 | Juha |  |  | LTE_HRPD_SON-Core | RP-140745 |  |
| 1822 | 456.3 | CT aspects for LTE-HRPD (High Rate Packet Data in 3GPP2) inter-RAT SON (Stage 3) | 3d? | 2013-09-04 A | 2013-09-06 A | 100% |  | 2013-09-04 | 2013-09-06 | 3d? |  | finish no earlier than 2013-09-06 | C4 | 24h | 24h | LTE_HRPD_SON-CT | PCG-31 | Huawei | Xiaoyan SHI (sean.shixiaoyan@huawei.com | Rel-12 | CP-61 | Kimmo |  |  | LTE_HRPD_SON-CT |  |  |
| 1823 | 456.4 | GERAN aspects for LTE-HRPD inter-RAT SON, RAN Information Management (RIM) - Stage 3 | 5d? | 2013-08-26 A | 2013-08-30 A | 100% |  | 2013-08-26 | 2013-08-30 | 5d? |  | finish no earlier than 2013-09-06 | G2 | 40h | 40h | LTE_HRPD_SON-RIM | PCG-31 | Alcatel-Lucent | marguerite.woch@alcatel-lucent.com | Rel-12 | GP-59 | Gert |  |  | LTE_HRPD_SON-RIM |  |  |
| 1824 | 457 | **Increasing the minimum number of carriers for UE monitoring in UTRA and E-UTRA** | 789d? | 2013-12-15 A | 2016-12-15 | 71% | 230.09d? | 2013-12-09 | 2015-03-13 | 331d? | 347d |  | R4; R2 | 16588.4h | 8270h | LTE_UTRA_IncMon | PCG-32 | Ericsson | christopher.callender@ericsson.com | Rel-12 | RP-62 | Issam |  |  | LTE_UTRA_IncMon |  |  |
| 1825 | 457.1 | Core part: Increasing the minimum number of carriers for UE monitoring in UTRA and E-UTRA | 201d? | 2013-12-15 A | 2014-12-15 A | 100% |  | 2014-01-06 | 2014-09-12 | 133d? |  | finish no earlier than 2014-12-15 | R4; R2 | 1844.4h | 1844.4h | LTE_UTRA_IncMon-Core | PCG-32 | Ericsson | christopher.callender@ericsson.com | Rel-12 | RP-62 | Issam |  |  | LTE_UTRA_IncMon-Core | RP-141787 |  |
| 1826 | 457.2 | Perf. part: Increasing the minimum number of carriers for UE monitoring in UTRA and E-UTRA | 395d? | 2013-12-15 A | 2015-06-15 A | 100% |  | 2013-12-09 | 2015-03-13 | 331d? |  | finish no earlier than 2015-06-15 | R4 | 3160h | 3160h | LTE_UTRA_IncMon-Perf | PCG-32 | Ericsson | christopher.callender@ericsson.com | Rel-12 | RP-62 | Issam |  |  | LTE_UTRA_IncMon-Perf | RP-150596 |  |
| 1827 | 457.3 | UE Conformance Test Aspects - Increasing the minimum number of carriers for UE monitoring in UTRA and E-UTRA | 264d? | 2015-12-15 A | 2016-12-15 | 5% | 250.8d? |  |  |  | 347d | finish no earlier than 2016-12-15 | R5 | 2112h | 105.6h | LTE_UTRA_IncMon-UEConTest | PCG-36 | Ericsson |  | Rel-12 | RP-70 |  |  |  |  |  |  |
| 1828 | 458 | **WLAN/3GPP Radio Interworking** | 267d? | 2013-12-06 A | 2014-12-09 A | 100% |  | 2013-12-06 | 2014-09-17 | 205d? |  |  | R2; S2; C1; C4 | 11021h | 11021h | UTRA_LTE_WLAN_interw | PCG-32 | Intel | sasha.sirotkin@intel.com | Rel-12 | RP-62 | Yong-Jun |  |  | UTRA_LTE_WLAN_interw |  | WLAN |
| 1829 | 458.1 | Core part: WLAN/3GPP Radio Interworking | 202d? | 2013-12-06 A | 2014-09-12 A | 100% |  | 2013-12-06 | 2014-09-12 | 202d? |  | finish no earlier than 2014-09-12 | R2 | 1616h | 1616h | UTRA_LTE_WLAN_interw-Core | PCG-32 | Intel | sasha.sirotkin@intel.com | Rel-12 | RP-62 | Yong-Jun |  |  | UTRA_LTE_WLAN_interw-Core | RP-141310 | WLAN |
| 1830 | 458.2 | SA2 aspects of WLAN/3GPP Radio Interworking | 140d? | 2014-03-07 A | 2014-09-17 A | 100% |  | 2014-03-07 | 2014-09-17 | 139d? |  | finish no earlier than 2014-09-17 | S2 | 1120h | 1120h | UTRA_LTE_WLAN_interw-SA2 | PCG-32 | Alcatel-Lucent | nicolas.drevon@alcatel-lucent.com | Rel-12 | SP-63 | Maurice |  |  | UTRA_LTE_WLAN_interw-SA2 |  | WLAN |
| 1831 | 458.3 | **CT aspects of WLAN/3GPP Radio Interworking (Stage 2/3)** | 68d? | 2014-09-09 A | 2014-12-09 A | 100% |  | 2014-06-13 | 2014-09-12 | 66d? |  |  | C1; C4 | 1665.6h | 1665.6h | UTRA_LTE_WLAN_interw-CT | PCG-33 | Alcatel-Lucent | jennifer.liu@alcatel-lucent.com | Rel-12 | CP-64 |  |  |  | UTRA_LTE_WLAN_interw-CT |  | WLAN |
| 1832 | 458.3.1 | CT1 part of CT aspects of WLAN/3GPP Radio Interworking (Stage 3) | 68d? | 2014-09-09 A | 2014-12-09 A | 100% |  | 2014-06-13 | 2014-09-12 | 66d? |  | finish no earlier than 2014-12-09 | C1 | 528h | 528h | UTRA_LTE_WLAN_interw-CT | PCG-33 | Alcatel-Lucent | jennifer.liu@alcatel-lucent.com | Rel-12 | CP-64 |  |  |  |  | CP-140720 | WLAN |
| 1833 | 458.3.2 | CT4 part of CT aspects of WLAN/3GPP Radio Interworking (Stage 2/3) | 63d? | 2014-09-12 A | 2014-12-09 A | 100% |  |  |  |  |  | finish no earlier than 2014-12-09 | C4 | 504h | 504h | UTRA_LTE_WLAN_interw-CT | PCG-33 | Alcatel-Lucent | jennifer.liu@alcatel-lucent.com | Rel-12 | CP-65 |  |  |  |  | CP-140482 | WLAN |
| 1834 | 459 | UE Conformance Test Aspects – WLAN/3GPP Radio Interworking | 327d? | 2014-12-15 A | 2016-03-15 A | 100% |  |  |  |  |  | finish no earlier than 2016-03-15 | R5 | 2616h | 2616h | UTRA_LTE_WLAN_interw-UEConTest | PCG-34 | Intel | Intel | Rel-12 | RP-66 |  |  |  |  | RP-151264 |  |
| 1835 | 460 | **Rel-12 LTE Carrier Aggregation** | 1384d? | 2011-09-19 A | 2016-12-15 | 99% | 12.27d? | 2011-09-19 | 2014-12-11 | 855d? | 347d |  | R4 | 567982h | 555246h | LTE_CA_Rel-12 | PCG-30 |  |  | Rel-12 | RP-58 | Issam |  |  | LTE_CA_Rel-12 |  | CA |
| 1836 | 460.1 | **LTE Advanced inter-band Carrier Aggregation of Band 1 and Band 7** | 792d? | 2011-09-19 A | 2014-09-12 A | 100% |  | 2011-09-19 | 2014-09-12 | 791d? |  |  | R4 | 18896h | 18896h | LTE_CA_B1_B7 | PCG-27 | Ericsson | christian.bergljung@ericsson.com | Rel-12 | RP-53 | Issam |  |  | LTE_CA_B1_B7 |  | CA |
| 1837 | 460.1.1 | Core part: LTE Advanced inter-band Carrier Aggregation of Band 1 and Band 7 | 790d? | 2011-09-19 A | 2014-09-12 A | 100% |  | 2011-09-19 | 2014-09-12 | 790d? |  | finish no earlier than 2014-09-12 | R4 | 6312h | 6312h | LTE_CA_B1_B7-Core | PCG-27 | Ericsson | christian.bergljung@ericsson.com | Rel-12 | RP-53 | Issam |  |  | LTE_CA_B1_B7-Core | RP-141084 | CA |
| 1838 | 460.1.2 | Perf. part: LTE Advanced inter-band Carrier Aggregation of Band 1 and Band 7 | 781d? | 2011-10-03 A | 2014-09-12 A | 100% |  | 2011-09-30 | 2014-09-12 | 781d? |  | finish no earlier than 2014-09-12 | R4 | 6248h | 6248h | LTE_CA_B1_B7-Perf | PCG-27 | Ericsson | christian.bergljung@ericsson.com | Rel-12 | RP-53 | Issam |  |  | LTE_CA_B1_B7-Perf | RP-141084 | CA |

Notes:
- 1812: Triggered by Rel-12 TR 37.810 Study on Base Station specification structure (FS_BSspec_struc) / Impacted TSs and TRs: UTRA, LTE, MSR
- 1813: RP#62 stopped (at 20% completion) / Impacted TSs and TRs: 25.104, 25.105, 36.104, 37.104, 37.810, New TR 37.811 (New BS specification structure), New TS 37.xya (New RF core specification)
- 1814: RP#62 stopped (at 0% completion) / Impacted TSs and TRs: 25.113, 25.141, 25.142, 36.113, 36.141, 37.113, 37.141, 37.810, New TS 37.xyz (New RF test specification, New TS 37.xyw (ew EMC specification)
- 1815: ECC(12)052 CEPT decision to harmonize 1452-1492 MHz (L-band) for mobile communications Supplemental Downlink (SDL) => standardize L-band and corresponding E-UTRA and UTRA requirements for SDL operation in Region 1 / Impacted TSs and TRs: UTRA, LTE
- 1816: RP#64 completed. RP#65 forgotten TR 37.814 v100 for 1-step Approval / Impacted TSs and TRs: 25.101, 25.104, 25.113, 25.133, 25.307, 25.327, 25.461, 25.466, 34.124, 36.101, 36.104, 36.113, 36.124, 36.133, 36.307, 36.331, 37.104, 37.113, new TR 37.814
- 1817: RP#64 completed / Impacted TSs and TRs: 25.133, 25.141, 25.307, 25.327, 36.133, 36.141, 36.307, 37.141
- 1818: 03/07/15: Compl:0%->85% 03/07/15: CD:Mon 15/06/15->Tue 15/09/15 03/07/15: WID: RP-150134->RP-150835 03/07/15: Stat Rep: ->RP-150830 29/09/15: Compl:85%->90% 29/09/15: CD:Tue 15/09/15->Tue 15/12/15 29/09/15: Stat Rep: RP-150830->RP-151163; 1/1/16...
- 1819: Triggered by Rel-12 TR 37.813 (FS_LTE_HRPD_SON). SA2 should verify the architecture solution in TR 37.813 for inter-RAT load balancing between LTE-HRPD. CT4 should specify the RIM extension to support the feature. / Impacted TSs and TRs: UTRA, LTE
- 1820: SP#62 completed / Impacted TSs and TRs: 23.402
- 1821: RP#64 completed / Impacted TSs and TRs: 36.300, 36.413
- 1822: CP#61 WID approved & Completed / Impacted TSs and TRs: 29.274, 29.276, 29.280
- 1823: GP#59 WID approved & Completed / Impacted TSs and TRs: 48.018
- 1824: - / Impacted TSs and TRs: UTRA, LTE
- 1825: ; CD:Thu 18/12/14->Mon 15/12/14; WID: RP-141966->RP-142235; Stat Rep: RP-141600->RP-141787 / Impacted TSs and TRs: 25.133, 25.331, 36.133
- 1826: ; CD:Fri 12/06/15->Mon 15/06/15; WID: RP-141966->RP-142235; Stat Rep: RP-141600->RP-141787 1st Apr 15: Compl:5%->40% 1st Apr 15: Stat Rep: RP-141787->RP-150063 03/07/15: Compl:40%->100% 03/07/15: Stat Rep: RP-150063->RP-150596 / Impacted TSs and TRs: 25.133, 36.133
- 1827: 22/3/16: Compl:0%->4%1/7/16: CD:Thu 15/09/16->Thu 15/12/16; 26/9/16: Com...
- 1828: Triggered by Rel-12 TR 37.834 Study on WLAN/3GPP Radio Interworking (FS_UTRA_LTE_WLAN_interw) / Impacted TSs and TRs: UTRA, LTE
- 1829: SP#65 completed / Impacted TSs and TRs: 25.304, 25.306, 25.331, 36.304, 36.306, 36.331
- 1830: SP#65 completed / Impacted TSs and TRs: 23.402, 23.401, 23.060, 23.251
- 1831: CP#65 revised WID CP-140287=>CP-140623 (added CT4 part) / Impacted TSs and TRs: Stage 2/3
- 1832: CP#65 completion 09/14=>12/14. Exception in CP-140720. 78%->95%. 12/12: 95->78%. 3/3/15: 100% cpltd. / Impacted TSs and TRs: 24.008, 24.301, 24.302, 24.312
- 1833: CP#65 revised WID CP-140287=>CP-140623 (added CT4 part). Exception in CP-140482. Dec.14: 50->100 / Impacted TSs and TRs: 23.008, 29.002, 29.272, 29.274, 29.305
- 1834: Rel13->Rel-12; Moved at appropriate place 1st Apr 15: Compl:0%->5% 1st Apr 15: Stat Rep: ->RP-150098 03/07/15: Compl:5%->20% 03/07/15: Stat Rep: RP-150098->RP-150929 29/09/15: Compl:20%->60% 29/09/15: WID: RP-141879->RP-151270 29/09/15: Stat Rep: RP-15...; ; ; ; ; ; ; ; ; ; ; ; ; ; ; ; ; ; ; ; ; ; ; ; ; ; ; ; ; ; ; ; ; ; ; ; ; ; ; ; ; ; ; ; ; ; ; ; ; ; ; ; ; ; ; ; ; ; ; ; ; ; ; ; ; ; ; ; ; ; 22/3/16: Compl:90%->100%
- 1835: LTE_CA_Rel-12 / Impacted TSs and TRs: LTE
- 1836: Inter-band CA 2DL / Impacted TSs and TRs: LTE
- 1837: RP#65 completed. Updated WID RP-132042=>RP-141487 / Impacted TSs and TRs: 36.101, 36.104, new generic TR 36.851
- 1838: RP#65 completed / Impacted TSs and TRs: 36.141, 36.307

| ID | WBS | Task | Duration | Start | Finish | Complete | Remaining | Baseline start | Baseline finish | Baseline duration | Total slack | Constraint | Resources | Work | Actual work | Acronym | PCG approved | Impacted TSs and TRs | WI rapporteur name | WI rapporteur e-mail | Release | TSG approved | MCC resp | Special Focus Doc | Acronym_3GU_Export | Status Report | PCG stopped | TSG stopped |
| --- | --- | --- | --- | --- | --- | --- | --- | --- | --- | --- | --- | --- | --- | --- | --- | --- | --- | --- | --- | --- | --- | --- | --- | --- | --- | --- | --- | --- |
| 1839 | 460.2 | **LTE Advanced intra-band non-contiguous Carrier Aggregation in Band 25** | 462d? | 2011-09-19 A | 2013-06-14 A | 100% |  | 2011-09-19 | 2013-06-14 | 462d? |  |  | R4 | 11056h | 11056h | LTE_CA_NC_B25 | PCG-27 | LTE | Sprint | George.Cummings@sprint.com | Rel-12 | RP-53 | Issam | CA | LTE_CA_NC_B25 |  |  |  |
| 1840 | 460.2.1 | Core part: LTE Advanced intra-band non-contiguous Carrier Aggregation in Band 25 | 459d? | 2011-09-19 A | 2013-06-14 A | 100% |  | 2011-09-19 | 2013-06-14 | 459d? |  | finish no earlier than 2013-06-14 | R4 | 3672h | 3672h | LTE_CA_NC_B25-Core | PCG-27 | 36.101, 36.104, 36.133, new TR 36.833-2-25 | Sprint | George.Cummings@sprint.com | Rel-12 | RP-53 | Issam | CA | LTE_CA_NC_B25-Core | RP-130563 |  |  |
| 1841 | 460.2.2 | Perf. part: LTE Advanced intra-band non-contiguous Carrier Aggregation in Band 25 | 461d? | 2011-09-19 A | 2013-06-14 A | 100% |  | 2011-09-19 | 2013-06-14 | 461d? |  | finish no earlier than 2013-06-14 | R4 | 3688h | 3688h | LTE_CA_NC_B25-Perf | PCG-27 | 36.141, 36.307 | Sprint | George.Cummings@sprint.com | Rel-12 | RP-53 | Issam | CA | LTE_CA_NC_B25-Perf | RP-130759 |  |  |
| 1842 | 460.3 | **Deleted - LTE Advanced inter-band Carrier Aggregation of Band 3 and Band 5 with 2UL** | 265d? | 2012-03-05 A | 2013-03-01 A | 100% |  | 2012-03-05 | 2013-03-01 | 265d? |  |  | R4 | 6296h | 6296h | LTE_CA_B3_B5_2UL | PCG-28 | LTE | SK Telecom | Seungpyo Hong | Rel-12 | RP-55 | Issam | CA | LTE_CA_B3_B5_2UL |  | PCG-30 | RP-59 |
| 1843 | 460.3.1 | Deleted - Core part: LTE Advanced inter-band Carrier Aggregation of Band 3 and Band 5 with 2UL | 262d? | 2012-03-05 A | 2013-03-01 A | 100% |  | 2012-03-05 | 2013-03-01 | 262d? |  | finish no earlier than 2013-03-01 | R4 | 2096h | 2096h | LTE_CA_B3_B5_2UL-Core | PCG-28 | 36.101, 36.104, 36.133, 36.307, new generic TR 36.851 | SK Telecom | Seungpyo Hong | Rel-12 | RP-55 | Issam | CA | LTE_CA_B3_B5_2UL-Core | RP-130098 | PCG-30 | RP-59 |
| 1844 | 460.3.2 | Deleted - Perf. part: LTE Advanced inter-band Carrier Aggregation of Band 3 and Band 5 with 2UL | 260d? | 2012-03-12 A | 2013-03-01 A | 100% |  | 2012-03-12 | 2013-03-01 | 260d? |  | finish no earlier than 2013-03-01 | R4 | 2080h | 2080h | LTE_CA_B3_B5_2UL-Perf | PCG-28 | 36.133, 36.141 | SK Telecom | Seungpyo Hong | Rel-12 | RP-55 | Issam | CA | LTE_CA_B3_B5_2UL-Perf | RP-130099 | PCG-30 | RP-59 |
| 1845 | 460.4 | UE Conformance Test Aspects - Further Rel-12 configurations for LTE Advanced Carrier Aggregation with 2UL | 460d? | 2015-03-16 A | 2016-12-15 | 99% | 4.6d? |  |  |  | 347d | finish no earlier than 2016-12-15 | R5 | 3680h | 3643.2h | LTE_CA_Rel12_2UL-UEConTest | PCG-34 |  | Ericsson | NA | Rel-12 | RP-67 |  |  |  | RP-151166 |  |  |
| 1846 | 460.5 | **LTE Advanced intra-band non-contiguous Carrier Aggregation in Band 3** | 469d? | 2012-03-05 A | 2013-12-06 A | 100% |  | 2012-03-05 | 2013-12-06 | 469d? |  |  | R4 | 11136h | 11136h | LTE_CA_NC_B3 | PCG-28 | LTE | SK Telecom | haesung.park@sk.com | Rel-12 | RP-55 | Issam | CA | LTE_CA_NC_B3 |  |  |  |
| 1847 | 460.5.1 | Core part: LTE Advanced intra-band non-contiguous Carrier Aggregation in Band 3 | 462d? | 2012-03-05 A | 2013-12-06 A | 100% |  | 2012-03-05 | 2013-12-06 | 462d? |  | finish no earlier than 2013-12-06 | R4 | 3696h | 3696h | LTE_CA_NC_B3-Core | PCG-28 | 36.101, 36.104, 36.133, new TR 36.833-2-03 | SK Telecom | haesung.park@sk.com | Rel-12 | RP-55 | Issam | CA | LTE_CA_NC_B3-Core | RP-131573 |  |  |
| 1848 | 460.5.2 | Perf. part: LTE Advanced intra-band non-contiguous Carrier Aggregation in Band 3 | 461d? | 2012-03-15 A | 2013-12-06 A | 100% |  | 2012-03-15 | 2013-12-06 | 461d? |  | finish no earlier than 2013-12-06 | R4 | 3688h | 3688h | LTE_CA_NC_B3-Perf | PCG-28 | 36.101, 36.104, 36.133, 36.141, 36.307 | SK Telecom | haesung.park@sk.com | Rel-12 | RP-55 | Issam | CA | LTE_CA_NC_B3-Perf | RP-131574 |  |  |
| 1849 | 460.6 | **Deleted - LTE Advanced intra-band contiguous Carrier Aggregation in Band 1** | 265d? | 2012-06-18 A | 2013-06-14 A | 100% |  | 2012-06-18 | 2013-06-14 | 265d? |  |  | R4 | 6328h | 6328h | LTE_CA_C_B1 | PCG-29 | LTE | KDDI | Masaaki Obara (ms-obara@kddi.com) | Rel-12 | RP-56 | Issam | CA | LTE_CA_C_B1 |  | PCG-31 | RP-60 |
| 1850 | 460.6.1 | Deleted - Core part: LTE Advanced intra-band contiguous Carrier Aggregation in Band 1 | 265d? | 2012-06-18 A | 2013-06-14 A | 100% |  | 2012-06-18 | 2013-06-14 | 265d? |  | finish no earlier than 2013-06-14 | R4 | 2120h | 2120h | LTE_CA_C_B1-Core | PCG-29 | 36.101, 36.104, 36.133, 36.141, 36.307, new TR 36.835 | KDDI | Masaaki Obara (ms-obara@kddi.com) | Rel-12 | RP-56 | Issam | CA | LTE_CA_C_B1-Core | RP-130549 | PCG-31 | RP-60 |
| 1851 | 460.6.2 | Deleted - Perf. part: LTE Advanced intra-band contiguous Carrier Aggregation in Band 1 | 261d? | 2012-06-22 A | 2013-06-14 A | 100% |  | 2012-06-22 | 2013-06-14 | 261d? |  | finish no earlier than 2013-06-14 | R4 | 2088h | 2088h | LTE_CA_C_B1-Perf | PCG-29 | 36.101, 36.104, 36.133, 36.141, 36.307 | KDDI | Masaaki Obara (ms-obara@kddi.com) | Rel-12 | RP-56 | Issam | CA | LTE_CA_C_B1-Perf | RP-130550 | PCG-31 | RP-60 |
| 1852 | 460.7 | **LTE Advanced intra-band non-contiguous Carrier Aggregation in Band 4** | 327d? | 2012-06-18 A | 2013-09-06 A | 100% |  | 2012-06-18 | 2013-09-06 | 327d? |  |  | R4 | 7752h | 7752h | LTE_CA_NC_B4 | PCG-29 | LTE | T-Mobile USA | nelson.ueng@t-mobile.com | Rel-12 | RP-56 | Issam | CA | LTE_CA_NC_B4 |  |  |  |
| 1853 | 460.7.1 | Core part: LTE Advanced intra-band non-contiguous Carrier Aggregation in Band 4 | 323d? | 2012-06-18 A | 2013-09-06 A | 100% |  | 2012-06-18 | 2013-09-06 | 323d? |  | finish no earlier than 2013-09-06 | R4 | 2568h | 2568h | LTE_CA_NC_B4-Core | PCG-29 | 36.101, 36.104, 36.133, new TR 36.833-2-04 | T-Mobile USA | nelson.ueng@t-mobile.com | Rel-12 | RP-56 | Issam | CA | LTE_CA_NC_B4-Core | RP-131039 |  |  |
| 1854 | 460.7.2 | Perf. part: LTE Advanced intra-band non-contiguous Carrier Aggregation in Band 4 | 323d? | 2012-06-22 A | 2013-09-06 A | 100% |  | 2012-06-22 | 2013-09-06 | 323d? |  | finish no earlier than 2013-09-06 | R4 | 2568h | 2568h | LTE_CA_NC_B4-Perf | PCG-29 | 36.101, 36.104, 36.133, 36.141, 36.307 | T-Mobile USA | nelson.ueng@t-mobile.com | Rel-12 | RP-56 | Issam | CA | LTE_CA_NC_B4-Perf | RP-131040 |  |  |
| 1855 | 460.8 | **LTE Advanced inter-band Carrier Aggregation of Band 2 and Band 4** | 327d? | 2012-06-18 A | 2013-09-06 A | 100% |  | 2012-06-18 | 2013-09-06 | 327d? |  |  | R4 | 7752h | 7752h | LTE_CA_B2_B4 | PCG-29 | LTE | T-Mobile USA | nelson.ueng@t-mobile.com | Rel-12 | RP-56 | Issam | CA | LTE_CA_B2_B4 |  |  |  |
| 1856 | 460.8.1 | Core part: LTE Advanced inter-band Carrier Aggregation of Band 2 and Band 4 | 321d? | 2012-06-18 A | 2013-09-06 A | 100% |  | 2012-06-18 | 2013-09-06 | 321d? |  | finish no earlier than 2013-09-06 | R4 | 2568h | 2568h | LTE_CA_B2_B4-Core | PCG-29 | 36.101, 36.104, 36.133, new generic TR 36.851 | T-Mobile USA | nelson.ueng@t-mobile.com | Rel-12 | RP-56 | Issam | CA | LTE_CA_B2_B4-Core | RP-131007 |  |  |
| 1857 | 460.8.2 | Perf. part: LTE Advanced inter-band Carrier Aggregation of Band 2 and Band 4 | 321d? | 2012-06-22 A | 2013-09-06 A | 100% |  | 2012-06-22 | 2013-09-06 | 321d? |  | finish no earlier than 2013-09-06 | R4 | 2568h | 2568h | LTE_CA_B2_B4-Perf | PCG-29 | 36.101, 36.104, 36.133, 36.141, 36.307 | T-Mobile USA | nelson.ueng@t-mobile.com | Rel-12 | RP-56 | Issam | CA | LTE_CA_B2_B4-Perf | RP-131376 |  |  |
| 1858 | 460.9 | **LTE Advanced inter-band Carrier Aggregation of Band 23 and Band 29** | 202d? | 2012-09-12 A | 2013-06-14 A | 100% |  | 2012-09-12 | 2013-06-14 | 202d? |  |  | R4 | 4832h | 4832h | LTE_CA_B23_B29 | PCG-29 | LTE | DISH Network | mariam.sorond@dish.com, johny.kim@dish.com | Rel-12 | RP-57 | Issam | CA | LTE_CA_B23_B29 |  |  |  |
| 1859 | 460.9.1 | Core part: LTE Advanced inter-band Carrier Aggregation of Band 23 and Band 29 | 201d? | 2012-09-12 A | 2013-06-14 A | 100% |  | 2012-09-12 | 2013-06-14 | 201d? |  | finish no earlier than 2013-06-14 | R4 | 1608h | 1608h | LTE_CA_B23_B29-Core | PCG-29 | 36.101, 36.104, 36.133, new generic TR 36.851 | DISH Network | mariam.sorond@dish.com, johny.kim@dish.com | Rel-12 | RP-57 | Issam | CA | LTE_CA_B23_B29-Core | RP-130535 |  |  |
| 1860 | 460.9.2 | Perf. part: LTE Advanced inter-band Carrier Aggregation of Band 23 and Band 29 | 201d? | 2012-09-12 A | 2013-06-14 A | 100% |  | 2012-09-12 | 2013-06-14 | 201d? |  | finish no earlier than 2013-06-14 | R4 | 1608h | 1608h | LTE_CA_B23_B29-Perf | PCG-29 | 36.141, 36.307 | DISH Network | mariam.sorond@dish.com, johny.kim@dish.com | Rel-12 | RP-57 | Issam | CA | LTE_CA_B23_B29-Perf | RP-130536 |  |  |
| 1861 | 460.10 | **LTE Advanced inter-band Carrier Aggregation of Band 3 and Band 26** | 203d? | 2012-09-11 A | 2013-06-14 A | 100% |  | 2012-09-11 | 2013-06-14 | 203d? |  |  | R4 | 4840h | 4840h | LTE_CA_B3_B26 | PCG-29 | LTE | KT | Chungwoo HWANG (cwhwang@kt.com) | Rel-12 | RP-57 | Issam | CA | LTE_CA_B3_B26 |  |  |  |
| 1862 | 460.10.1 | Core part: LTE Advanced inter-band Carrier Aggregation of Band 3 and Band 26 | 202d? | 2012-09-11 A | 2013-06-14 A | 100% |  | 2012-09-11 | 2013-06-14 | 202d? |  | finish no earlier than 2013-06-14 | R4 | 1608h | 1608h | LTE_CA_B3_B26-Core | PCG-29 | 36.101, 36.104, 36.133, 36.307, new generic TR 36.851 | KT | Chungwoo HWANG (cwhwang@kt.com) | Rel-12 | RP-57 | Issam | CA | LTE_CA_B3_B26-Core | RP-130527 |  |  |
| 1863 | 460.10.2 | Perf. part: LTE Advanced inter-band Carrier Aggregation of Band 3 and Band 26 | 202d? | 2012-09-11 A | 2013-06-14 A | 100% |  | 2012-09-11 | 2013-06-14 | 202d? |  | finish no earlier than 2013-06-14 | R4 | 1608h | 1608h | LTE_CA_B3_B26-Perf | PCG-29 | 36.101, 36.104, 36.133, 36.141, 36.307 | KT | Chungwoo HWANG (cwhwang@kt.com) | Rel-12 | RP-57 | Issam | CA | LTE_CA_B3_B26-Perf | RP-130528 |  |  |

Notes:
- 1839: Intra-band NC
- 1840: RP#60 completed. TR 36.841 for 1-step Approval
- 1841: RP#60 completed
- 1842: Inter-band 2UL
- 1843: RP#59 stopped (covered by new WI LTE_CA_2UL-A4)
- 1844: RP#59 stopped (covered by new WI LTE_CA_2UL-A4)
- 1845: 03/07/15: Compl:0%->29% 03/07/15: Stat Rep: ->RP-150834 29/09/15: Compl:29%->55% 29/09/15: Stat Rep: RP-150834->RP-151166 1/1/16: Compl:55%->70% 1/1/16: CD:Tue 15/12/15->Tue 15/03/16 1/1/16: WID: RP-1......;...;...
- 1846: Intra-band NC
- 1847: RP#62 completed
- 1848: RP#62 completed
- 1849: Intra-band C
- 1850: RP#60 stopped at 10% completion (rationale in RP-130670)
- 1851: RP#60 stopped at 0% completion
- 1852: Intra-band NC
- 1853: RP#61 completed. Updated WID RP-130842=>RP-131135
- 1854: RP#61 completed. Updated WID RP-130842=>RP-131135
- 1855: Inter-band 1 UL
- 1856: RP#61 completed
- 1857: RP#61 completed
- 1858: Inter-band 1 UL
- 1859: RP#60 completed
- 1860: RP#60 completed
- 1861: Inter-band 1 UL
- 1862: RP#60 completed. Updated WID RP-130199=>RP-130658
- 1863: RP#60 completed. Updated WID RP-130199=>RP-130658

| ID | WBS | Task | Duration | Start | Finish | Complete | Baseline start | Baseline finish | Baseline duration | Constraint | Resources | Work | Actual work | Acronym | PCG approved | WI rapporteur name | WI rapporteur e-mail | Release | TSG approved | MCC resp | Special Focus Doc | Acronym_3GU_Export | Status Report | PCG stopped | TSG stopped |
| --- | --- | --- | --- | --- | --- | --- | --- | --- | --- | --- | --- | --- | --- | --- | --- | --- | --- | --- | --- | --- | --- | --- | --- | --- | --- |
| 1864 | 460.11 | **LTE Advanced inter-band Carrier Aggregation of Band 3 and Band 19** | 203d? | 2012-09-11 A | 2013-06-14 A | 100% | 2012-09-11 | 2013-06-14 | 203d? |  | R4 | 4840h | 4840h | LTE_CA_B3_B19 | PCG-29 | NTT DOCOMO | Kei ANDO | Rel-12 | RP-57 | Issam | CA | LTE_CA_B3_B19 |  |  |  |
| 1865 | 460.11.1 | Core part: LTE Advanced inter-band Carrier Aggregation of Band 3 and Band 19 | 201d? | 2012-09-11 A | 2013-06-14 A | 100% | 2012-09-11 | 2013-06-14 | 201d? | finish no earlier than 2013-06-14 | R4 | 1608h | 1608h | LTE_CA_B3_B19-Core | PCG-29 | NTT DOCOMO | Kei ANDO | Rel-12 | RP-57 | Issam | CA | LTE_CA_B3_B19-Core | RP-130525 |  |  |
| 1866 | 460.11.2 | Perf. part: LTE Advanced inter-band Carrier Aggregation of Band 3 and Band 19 | 201d? | 2012-09-13 A | 2013-06-14 A | 100% | 2012-09-13 | 2013-06-14 | 201d? | finish no earlier than 2013-06-14 | R4 | 1608h | 1608h | LTE_CA_B3_B19-Perf | PCG-29 | NTT DOCOMO | Kei ANDO | Rel-12 | RP-57 | Issam | CA | LTE_CA_B3_B19-Perf | RP-130526 |  |  |
| 1867 | 460.12 | **Deleted - LTE Advanced inter-band Carrier Aggregation of Band 38 and Band 39** | 66d? | 2012-09-11 A | 2012-12-07 A | 100% | 2012-09-11 | 2012-12-07 | 66d? |  | R4 | 1584h | 1584h | LTE_CA_B38_B39 | PCG-29 | China Mobile | Pan Qun (panqun@chinamobile.com) | Rel-12 | RP-57 | Issam | CA | LTE_CA_B38_B39 |  | PCG-30 | RP-58 |
| 1868 | 460.12.1 | Deleted - Core part: LTE Advanced inter-band Carrier Aggregation of Band 38 and Band 39 | 66d? | 2012-09-11 A | 2012-12-07 A | 100% | 2012-09-11 | 2012-12-07 | 66d? | finish no earlier than 2012-12-07 | R4 | 528h | 528h | LTE_CA_B38_B39-Core | PCG-29 | China Mobile | Pan Qun (panqun@chinamobile.com) | Rel-12 | RP-57 | Issam | CA | LTE_CA_B38_B39-Core | RP-121624 | PCG-30 | RP-58 |
| 1869 | 460.12.2 | Deleted - Perf. part: LTE Advanced inter-band Carrier Aggregation of Band 38 and Band 39 | 66d? | 2012-09-11 A | 2012-12-07 A | 100% | 2012-09-11 | 2012-12-07 | 66d? | finish no earlier than 2012-12-07 | R4 | 528h | 528h | LTE_CA_B38_B39-Perf | PCG-29 | China Mobile | Pan Qun (panqun@chinamobile.com) | Rel-12 | RP-57 | Issam | CA | LTE_CA_B38_B39-Perf | RP-121625 | PCG-30 | RP-58 |
| 1870 | 460.13 | **LTE Advanced intra-band contiguous Carrier Aggregation in Band 3** | 265d? | 2012-09-11 A | 2013-09-06 A | 100% | 2012-09-11 | 2013-09-06 | 265d? |  | R4 | 6312h | 6312h | LTE_CA_C_B3 | PCG-29 | China Unicom | Fei CUI (cuifei1@chinaunicom.cn) | Rel-12 | RP-57 | Issam | CA | LTE_CA_C_B3 |  |  |  |
| 1871 | 460.13.1 | Core part: LTE Advanced intra-band contiguous Carrier Aggregation in Band 3 | 263d? | 2012-09-11 A | 2013-09-06 A | 100% | 2012-09-11 | 2013-09-06 | 263d? | finish no earlier than 2013-09-06 | R4 | 2096h | 2096h | LTE_CA_C_B3-Core | PCG-29 | China Unicom | Fei CUI (cuifei1@chinaunicom.cn) | Rel-12 | RP-57 | Issam | CA | LTE_CA_C_B3-Core | RP-131029 |  |  |
| 1872 | 460.13.2 | Perf. part: LTE Advanced intra-band contiguous Carrier Aggregation in Band 3 | 263d? | 2012-09-11 A | 2013-09-06 A | 100% | 2012-09-11 | 2013-09-06 | 263d? | finish no earlier than 2013-09-06 | R4 | 2096h | 2096h | LTE_CA_C_B3-Perf | PCG-29 | China Unicom | Fei CUI (cuifei1@chinaunicom.cn) | Rel-12 | RP-57 | Issam | CA | LTE_CA_C_B3-Perf | RP-131030 |  |  |
| 1873 | 460.14 | **LTE Advanced inter-band Carrier Aggregation of Band 1 and Band 8** | 362.8d? | 2012-02-02 A | 2013-06-14 A | 100% | 2012-02-02 | 2013-06-14 | 362.8d? |  | R4 | 6118.4h | 6118.4h | LTE_CA_B1_B8 | PCG-29 | Softbank Mobile | Kenichi Kihara | Rel-12 | RP-57 | Issam | CA | LTE_CA_B1_B8 |  |  |  |
| 1874 | 460.14.1 | Core part: LTE Advanced inter-band Carrier Aggregation of Band 1 and Band 8 | 201d? | 2012-02-02 A | 2013-06-14 A | 100% | 2012-02-02 | 2013-06-14 | 201d? | finish no earlier than 2013-06-14 | R4 | 1608h | 1608h | LTE_CA_B1_B8-Core | PCG-29 | Softbank Mobile | Kenichi Kihara | Rel-12 | RP-57 | Issam | CA | LTE_CA_B1_B8-Core | RP-130515 |  |  |
| 1875 | 460.14.2 | Perf. part: LTE Advanced inter-band Carrier Aggregation of Band 1 and Band 8 | 202d? | 2012-09-11 A | 2013-06-14 A | 100% | 2012-09-11 | 2013-06-14 | 202d? | finish no earlier than 2013-06-14 | R4 | 1608h | 1608h | LTE_CA_B1_B8-Perf | PCG-29 | Softbank Mobile | Kenichi Kihara | Rel-12 | RP-57 | Issam | CA | LTE_CA_B1_B8-Perf | RP-130516 |  |  |
| 1876 | 460.15 | **LTE Advanced inter-band Carrier Aggregation of Band 3 and Band 28** | 203d? | 2012-09-11 A | 2013-06-14 A | 100% | 2012-09-11 | 2013-06-14 | 203d? |  | R4 | 4840h | 4840h | LTE_CA_B3_B28 | PCG-29 | eAccess | FukumotoShiro@eaccess.net | Rel-12 | RP-57 | Issam | CA | LTE_CA_B3_B28 |  |  |  |
| 1877 | 460.15.1 | Core part: LTE Advanced inter-band Carrier Aggregation of Band 3 and Band 28 | 202d? | 2012-09-11 A | 2013-06-14 A | 100% | 2012-09-11 | 2013-06-14 | 202d? | finish no earlier than 2013-06-14 | R4 | 1608h | 1608h | LTE_CA_B3_B28-Core | PCG-29 | eAccess | FukumotoShiro@eaccess.net | Rel-12 | RP-57 | Issam | CA | LTE_CA_B3_B28-Core | RP-130529 |  |  |
| 1878 | 460.15.2 | Perf. part: LTE Advanced inter-band Carrier Aggregation of Band 3 and Band 28 | 201d? | 2012-09-12 A | 2013-06-14 A | 100% | 2012-09-12 | 2013-06-14 | 201d? | finish no earlier than 2013-06-14 | R4 | 1608h | 1608h | LTE_CA_B3_B28-Perf | PCG-29 | eAccess | FukumotoShiro@eaccess.net | Rel-12 | RP-57 | Issam | CA | LTE_CA_B3_B28-Perf | RP-130530 |  |  |
| 1879 | 460.16 | **LTE Advanced inter-band Carrier Aggregation of Band 1 and Band 26** | 200d? | 2012-12-07 A | 2013-09-06 A | 100% | 2012-12-07 | 2013-09-06 | 200d? |  | R4 | 4768h | 4768h | LTE_CA_B1_B26 | PCG-30 | KDDI | Masaaki Obara (ms-obara@kddi.com) | Rel-12 | RP-58 | Issam | CA | LTE_CA_B1_B26 |  |  |  |
| 1880 | 460.16.1 | Core part: LTE Advanced inter-band Carrier Aggregation of Band 1 and Band 26 | 200d? | 2012-12-07 A | 2013-09-06 A | 100% | 2012-12-07 | 2013-09-06 | 200d? | finish no earlier than 2013-09-06 | R4 | 1576h | 1576h | LTE_CA_B1_B26-Core | PCG-30 | KDDI | Masaaki Obara (ms-obara@kddi.com) | Rel-12 | RP-58 | Issam | CA | LTE_CA_B1_B26-Core | RP-131005 |  |  |
| 1881 | 460.16.2 | Perf. part: LTE Advanced inter-band Carrier Aggregation of Band 1 and Band 26 | 200d? | 2012-12-07 A | 2013-09-06 A | 100% | 2012-12-07 | 2013-09-06 | 200d? | finish no earlier than 2013-09-06 | R4 | 1600h | 1600h | LTE_CA_B1_B26-Perf | PCG-30 | KDDI | Masaaki Obara (ms-obara@kddi.com) | Rel-12 | RP-58 | Issam | CA | LTE_CA_B1_B26-Perf | RP-131006 |  |  |
| 1882 | 460.17 | **LTE Advanced inter-band Carrier Aggregation of Band 39 and Band 41** | 330d? | 2012-12-10 A | 2014-03-06 A | 100% | 2012-12-10 | 2014-03-06 | 330d? |  | R4 | 7848h | 7848h | LTE_CA_B39_B41 | PCG-30 | China Mobile | Pan Qun (panqun@chinamobile.com) | Rel-12 | RP-58 | Issam | CA | LTE_CA_B39_B41 | RP-140428 |  |  |
| 1883 | 460.17.1 | Core part: LTE Advanced inter-band Carrier Aggregation of Band 39 and Band 41 | 326d? | 2012-12-10 A | 2014-03-06 A | 100% | 2012-12-10 | 2014-03-06 | 326d? | finish no earlier than 2014-03-06 | R4 | 2608h | 2608h | LTE_CA_B39_B41-Core | PCG-30 | China Mobile | Pan Qun (panqun@chinamobile.com) | Rel-12 | RP-58 | Issam | CA | LTE_CA_B39_B41-Core | RP-140428 |  |  |
| 1884 | 460.17.2 | Perf. part: LTE Advanced inter-band Carrier Aggregation of Band 39 and Band 41 | 325d? | 2012-12-14 A | 2014-03-06 A | 100% | 2012-12-14 | 2014-03-06 | 325d? | finish no earlier than 2014-03-06 | R4 | 2600h | 2600h | LTE_CA_B39_B41-Perf | PCG-30 | China Mobile | Pan Qun (panqun@chinamobile.com) | Rel-12 | RP-58 | Issam | CA | LTE_CA_B39_B41-Perf | RP-140428 |  |  |
| 1885 | 460.18 | **LTE Advanced inter-band Carrier Aggregation of Band 2 and Band 12** | 467d? | 2012-12-10 A | 2014-09-12 A | 100% | 2012-12-10 | 2014-09-12 | 466d? |  | R4 | 10040h | 10040h | LTE_CA_B2_B12 | PCG-30 | US Cellular | sebastian.thalanany@uscellular.com | Rel-12 | RP-58 | Issam | CA | LTE_CA_B2_B12 |  |  |  |
| 1886 | 460.18.1 | Core part: LTE Advanced inter-band Carrier Aggregation of Band 2 and Band 12 | 464d? | 2012-12-10 A | 2014-09-12 A | 100% | 2012-12-10 | 2014-09-12 | 464d? | finish no earlier than 2014-09-12 | R4 | 3704h | 3704h | LTE_CA_B2_B12-Core | PCG-30 | US Cellular | sebastian.thalanany@uscellular.com | Rel-12 | RP-58 | Issam | CA | LTE_CA_B2_B12-Core | RP-141084 |  |  |
| 1887 | 460.18.2 | Perf. part: LTE Advanced inter-band Carrier Aggregation of Band 2 and Band 12 | 325d? | 2012-12-14 A | 2014-03-06 A | 100% | 2012-12-14 | 2014-03-06 | 325d? | finish no earlier than 2014-06-13 | R4 | 2600h | 2600h | LTE_CA_B2_B12-Perf | PCG-30 | US Cellular | sebastian.thalanany@uscellular.com | Rel-12 | RP-58 | Issam | CA | LTE_CA_B2_B12-Perf | RP-140428 |  |  |

Notes:
- 1864: Inter-band 1 UL / Impacted TSs and TRs: LTE
- 1865: RP#60 completed / Impacted TSs and TRs: 36.101, 36.104, 36.133, new generic TR 36.851
- 1866: RP#60 completed / Impacted TSs and TRs: 36.141, 36.307
- 1867: Inter-band 1 UL / Impacted TSs and TRs: LTE
- 1868: RP#58 stopped at 10% completion following regulatory decisions (see instead new WI LTE_CA_B39_B41) / Impacted TSs and TRs: 36.101, 36.104, 36.307, new generic TR 36.851
- 1869: RP#58 stopped at 0% completion following regulatory decisions (see instead new WI LTE_CA_B39_B41) / Impacted TSs and TRs: 36.133, 36.141
- 1870: Intra-band NC / Impacted TSs and TRs: LTE
- 1871: RP#61 completed. Updated WID RP-130294=>RP-131184 (impacted specs) / Impacted TSs and TRs: 36.101, 36.104, 36.133, new TR 36.833-1-03
- 1872: RP#61 completed / Impacted TSs and TRs: 36.141, 36.307
- 1873: Inter-band 1 UL / Impacted TSs and TRs: LTE
- 1874: RP#60 completed / Impacted TSs and TRs: 36.101, 36.104, new generic TR 36.851
- 1875: RP#60 completed / Impacted TSs and TRs: 36.141, 36.307
- 1876: Inter-band 1 UL / Impacted TSs and TRs: LTE
- 1877: RP#60 completed / Impacted TSs and TRs: 36.101, 36.104, new generic TR 36.851
- 1878: RP#60 completed / Impacted TSs and TRs: 36.141, 36.307
- 1879: Inter-band 1UL/2DL / Impacted TSs and TRs: LTE
- 1880: RP#61 completed / Impacted TSs and TRs: 36.101, 36.104, 36.133, new generic TR 36.851
- 1881: RP#61 completed / Impacted TSs and TRs: 36.141, 36.307
- 1882: Inter-band 2DL / Impacted TSs and TRs: LTE
- 1883: RP#63 completed. Replaces the Stopped WI - LTE Advanced inter-band Carrier Aggregation of Band 38 and Band 39 (LTE_CA_B38_B39) UID_570015 / Impacted TSs and TRs: 36.101, 36.104, 36.307, new generic TR 36.851
- 1884: RP#63 completed / Impacted TSs and TRs: 36.133, 36.141
- 1885: Inter-band CA 2DL / Impacted TSs and TRs: LTE
- 1886: RP#65 completed / Impacted TSs and TRs: 36.101, 36.104, 36.133, 36.141, 36.307, new generic TR 36.851
- 1887: RP#63 completed / Impacted TSs and TRs: 36.101, 36.104, 36.133, 36.141, 36.307

| ID | WBS | Task | Duration | Start | Finish | Complete | Baseline start | Baseline finish | Baseline duration | Constraint | Resources | Work | Actual work | Acronym | PCG approved | Impacted TSs and TRs | WI rapporteur name | WI rapporteur e-mail | Release | TSG approved | MCC resp | Special Focus Doc | Acronym_3GU_Export | Status Report | PCG stopped | TSG stopped |
| --- | --- | --- | --- | --- | --- | --- | --- | --- | --- | --- | --- | --- | --- | --- | --- | --- | --- | --- | --- | --- | --- | --- | --- | --- | --- | --- |
| 1888 | 460.19 | **LTE Advanced intra-band non-contiguous Carrier Aggregation in Band 7** | 265d? | 2012-12-10 A | 2013-12-06 A | 100% | 2012-12-10 | 2013-12-06 | 265d? |  | R4 | 6296h | 6296h | LTE_CA_NC_B7 | PCG-30 | LTE | Ericsson | christian.bergljung@ericsson.com | Rel-12 | RP-58 | Issam | CA | LTE_CA_NC_B7 |  |  |  |
| 1889 | 460.19.1 | Core part: LTE Advanced intra-band non-contiguous Carrier Aggregation in Band 7 | 261d? | 2012-12-10 A | 2013-12-06 A | 100% | 2012-12-10 | 2013-12-06 | 261d? | finish no earlier than 2013-12-06 | R4 | 2088h | 2088h | LTE_CA_NC_B7-Core | PCG-30 | 36.101, 36.104, 36.133, new TR 36.833-2-07 | Ericsson | christian.bergljung@ericsson.com | Rel-12 | RP-58 | Issam | CA | LTE_CA_NC_B7-Core | RP-131575 |  |  |
| 1890 | 460.19.2 | Perf. part: LTE Advanced intra-band non-contiguous Carrier Aggregation in Band 7 | 261d? | 2012-12-14 A | 2013-12-06 A | 100% | 2012-12-14 | 2013-12-06 | 261d? | finish no earlier than 2013-12-06 | R4 | 2088h | 2088h | LTE_CA_NC_B7-Perf | PCG-30 | 36.141, 36.307 | Ericsson | christian.bergljung@ericsson.com | Rel-12 | RP-58 | Issam | CA | LTE_CA_NC_B7-Perf | RP-131576 |  |  |
| 1891 | 460.20 | **LTE Advanced intra-band contiguous Carrier Aggregation in Band 27** | 401d? | 2012-12-10 A | 2014-06-13 A | 100% | 2012-12-10 | 2014-06-13 | 401d? |  | R4 | 8472h | 8472h | LTE_CA_C_B27 | PCG-30 | LTE | NII Holdings | bill.shvodian@nii.com | Rel-12 | RP-58 | Issam | CA | LTE_CA_C_B27 |  |  |  |
| 1892 | 460.20.1 | Core part: LTE Advanced intra-band contiguous Carrier Aggregation in Band 27 | 261d? | 2012-12-10 A | 2013-12-06 A | 100% | 2012-12-10 | 2013-12-06 | 261d? | finish no earlier than 2013-12-06 | R4 | 2088h | 2088h | LTE_CA_C_B27-Core | PCG-30 | 36.101, 36.104, new TR 36.833-1-27 | NII Holdings | bill.shvodian@nii.com | Rel-12 | RP-58 | Issam | CA | LTE_CA_C_B27-Core | RP-131567 |  |  |
| 1893 | 460.20.2 | Perf part: LTE Advanced intra-band contiguous Carrier Aggregation in Band 27 | 397d? | 2012-12-14 A | 2014-06-13 A | 100% | 2012-12-14 | 2014-06-13 | 397d? | finish no earlier than 2014-06-13 | R4 | 3176h | 3176h | LTE_CA_C_B27-Perf | PCG-30 | 36.101, 36.133, 36.141, 36.307, new TR 36.833-1-27 | NII Holdings | bill.shvodian@nii.com | Rel-12 | RP-58 | Issam | CA | LTE_CA_C_B27-Perf | RP-140569 |  |  |
| 1894 | 460.21 | **LTE Advanced inter-band Carrier Aggregation of Band 2 and Band 13** | 76d? | 2013-03-04 A | 2013-06-14 A | 100% | 2013-03-04 | 2013-06-14 | 76d? |  | R4 | 1824h | 1824h | LTE_CA_B2_B13 | PCG-30 | LTE | Ericsson | christian.bergljung@ericsson.com | Rel-12 | RP-59 | Issam | CA | LTE_CA_B2_B13 |  |  |  |
| 1895 | 460.21.1 | Core part: LTE Advanced inter-band Carrier Aggregation of Band 2 and Band 13 | 76d? | 2013-03-04 A | 2013-06-14 A | 100% | 2013-03-04 | 2013-06-14 | 76d? | finish no earlier than 2013-06-14 | R4 | 608h | 608h | LTE_CA_B2_B13-Core | PCG-30 | 36.101, 36.104, 36.133, new generic TR 36.851 | Ericsson | christian.bergljung@ericsson.com | Rel-12 | RP-59 | Issam | CA | LTE_CA_B2_B13-Core | RP-130523 |  |  |
| 1896 | 460.21.2 | Perf. part: LTE Advanced inter-band Carrier Aggregation of Band 2 and Band 13 | 76d? | 2013-03-04 A | 2013-06-14 A | 100% | 2013-03-04 | 2013-06-14 | 76d? | finish no earlier than 2013-06-14 | R4 | 608h | 608h | LTE_CA_B2_B13-Perf | PCG-30 | 36.101, 36.104, 36.133, 36.141, 36.307 | Ericsson | christian.bergljung@ericsson.com | Rel-12 | RP-59 | Issam | CA | LTE_CA_B2_B13-Perf | RP-130524 |  |  |
| 1897 | 460.22 | **LTE Advanced inter-band Carrier Aggregation of Band 19 and Band 21** | 76d? | 2013-03-04 A | 2013-06-14 A | 100% | 2013-03-04 | 2013-06-14 | 76d? |  | R4 | 1824h | 1824h | LTE_CA_B19_B21 | PCG-30 | LTE | NTT DOCOMO | Kei ANDO | Rel-12 | RP-59 | Issam | CA | LTE_CA_B19_B21 |  |  |  |
| 1898 | 460.22.1 | Core part: LTE Advanced inter-band Carrier Aggregation of Band 19 and Band 21 | 76d? | 2013-03-04 A | 2013-06-14 A | 100% | 2013-03-04 | 2013-06-14 | 76d? | finish no earlier than 2013-06-14 | R4 | 608h | 608h | LTE_CA_B19_B21-Core | PCG-30 | 36.101, 36.104, 36.133, new generic TR 36.851 | NTT DOCOMO | Kei ANDO | Rel-12 | RP-59 | Issam | CA | LTE_CA_B19_B21-Core | RP-130533 |  |  |
| 1899 | 460.22.2 | Perf. part: LTE Advanced inter-band Carrier Aggregation of Band 19 and Band 21 | 76d? | 2013-03-04 A | 2013-06-14 A | 100% | 2013-03-04 | 2013-06-14 | 76d? | finish no earlier than 2013-06-14 | R4 | 608h | 608h | LTE_CA_B19_B21-Perf | PCG-30 | 36.141, 36.307 | NTT DOCOMO | Kei ANDO | Rel-12 | RP-59 | Issam | CA | LTE_CA_B19_B21-Perf | RP-130534 |  |  |
| 1900 | 460.23 | **Deleted - LTE Advanced inter-band Carrier Aggregation of Band 8 and Band 26** | 204d? | 2013-03-04 A | 2013-12-06 A | 100% | 2013-03-04 | 2013-12-06 | 204d? |  | R4 | 4848h | 4848h | LTE_CA_B8_B26 | PCG-30 | LTE | KT | Chungwoo HWANG (cwhwang@kt.com) | Rel-12 | RP-59 | Issam | CA | LTE_CA_B8_B26 |  | PCG-32 | RP-62 |
| 1901 | 460.23.1 | Deleted - Core part: LTE Advanced inter-band Carrier Aggregation of Band 8 and Band 26 | 201d? | 2013-03-04 A | 2013-12-06 A | 100% | 2013-03-04 | 2013-12-06 | 201d? | finish no earlier than 2013-12-06 | R4 | 1608h | 1608h | LTE_CA_B8_B26-Core | PCG-30 | 36.101, 36.104, 36.133, new generic TR 36.851 | KT | Chungwoo HWANG (cwhwang@kt.com) | Rel-12 | RP-59 | Issam | CA | LTE_CA_B8_B26-Core | RP-131549 | PCG-32 | RP-62 |
| 1902 | 460.23.2 | Deleted - Perf. part: LTE Advanced inter-band Carrier Aggregation of Band 8 and Band 26 | 201d? | 2013-03-04 A | 2013-12-06 A | 100% | 2013-03-04 | 2013-12-06 | 201d? | finish no earlier than 2013-12-06 | R4 | 1608h | 1608h | LTE_CA_B8_B26-Perf | PCG-30 | 36.141, 36.307 | KT | Chungwoo HWANG (cwhwang@kt.com) | Rel-12 | RP-59 | Issam | CA | LTE_CA_B8_B26-Perf | RP-131550 | PCG-32 | RP-62 |
| 1903 | 460.24 | **LTE Advanced dual uplink inter-band Carrier Aggregation Class A1** | 474d? | 2013-03-04 A | 2014-12-15 A | 100% | 2013-03-04 | 2014-09-12 | 405d? |  | R4 | 11272h | 11272h | LTE_CA_2UL-A1 | PCG-30 | LTE | Huawei | Liu Ye (leo.liuye@huawei.com) | Rel-12 | RP-59 | Issam | CA | LTE_CA_2UL-A1 |  |  |  |
| 1904 | 460.24.1 | Core part: LTE Advanced dual uplink inter-band Carrier Aggregation Class A1 | 468d? | 2013-03-04 A | 2014-12-15 A | 100% | 2013-03-04 | 2014-09-12 | 402d? | finish no earlier than 2014-12-15 | R4 | 3744h | 3744h | LTE_CA_2UL-A1-Core | PCG-30 | 36.101, 36.104, New generic TR 36.860 | Huawei | Liu Ye (leo.liuye@huawei.com) | Rel-12 | RP-59 | Issam | CA | LTE_CA_2UL-A1-Core | RP-141732 |  |  |
| 1905 | 460.24.2 | Perf. part: LTE Advanced dual uplink inter-band Carrier Aggregation Class A1 | 467d? | 2013-03-13 A | 2014-12-15 A | 100% | 2013-03-08 | 2014-09-12 | 401d? | finish no earlier than 2014-12-15 | R4 | 3736h | 3736h | LTE_CA_2UL-A1-Perf | PCG-30 | 36.133 | Huawei | Liu Ye (leo.liuye@huawei.com) | Rel-12 | RP-59 | Issam | CA | LTE_CA_2UL-A1-Perf | RP-141732 |  |  |
| 1906 | 460.25 | **LTE Advanced dual uplink inter-band Carrier Aggregation Class A2** | 474d? | 2013-03-04 A | 2014-12-15 A | 100% | 2013-03-04 | 2014-09-12 | 405d? |  | R4 | 11272h | 11272h | LTE_CA_2UL-A2 | PCG-30 | LTE | Qualcomm | Gene Fong (gfong@qti.qualcomm.com) | Rel-12 | RP-59 | Issam | CA | LTE_CA_2UL-A2 |  |  |  |
| 1907 | 460.25.1 | Core part: LTE Advanced dual uplink inter-band Carrier Aggregation Class A2 | 468d? | 2013-03-04 A | 2014-12-15 A | 100% | 2013-03-04 | 2014-09-12 | 402d? | finish no earlier than 2014-12-15 | R4 | 3744h | 3744h | LTE_CA_2UL-A2-Core | PCG-30 | 36.101, 36.104, 36.133, New generic TR 36.860 | Qualcomm | Gene Fong (gfong@qti.qualcomm.com) | Rel-12 | RP-59 | Issam | CA | LTE_CA_2UL-A2-Core | RP-141732 |  |  |
| 1908 | 460.25.2 | Perf. part: LTE Advanced dual uplink inter-band Carrier Aggregation Class A2 | 467d? | 2013-03-13 A | 2014-12-15 A | 100% | 2013-03-08 | 2014-09-12 | 401d? | finish no earlier than 2014-12-15 | R4 | 3736h | 3736h | LTE_CA_2UL-A2-Perf | PCG-30 | 36.141, 36.307 | Qualcomm | Gene Fong (gfong@qti.qualcomm.com) | Rel-12 | RP-59 | Issam | CA | LTE_CA_2UL-A2-Perf | RP-141732 |  |  |
| 1909 | 460.26 | **LTE Advanced dual uplink inter-band Carrier Aggregation Class A3** | 474d? | 2013-03-04 A | 2014-12-15 A | 100% | 2013-03-04 | 2014-09-12 | 405d? |  | R4 | 11264h | 11264h | LTE_CA_2UL-A3 | PCG-30 | LTE | Ericsson | christian.bergljung@ericsson.com | Rel-12 | RP-59 | Issam | CA | LTE_CA_2UL-A3 |  |  |  |
| 1910 | 460.26.1 | Core part: LTE Advanced dual uplink inter-band Carrier Aggregation Class A3 | 467d? | 2013-03-04 A | 2014-12-15 A | 100% | 2013-03-04 | 2014-09-12 | 401d? | finish no earlier than 2014-12-15 | R4 | 3736h | 3736h | LTE_CA_2UL-A3-Core | PCG-30 | 36.101, 36.104, 36.133, New generic TR 36.860 | Ericsson | christian.bergljung@ericsson.com | Rel-12 | RP-59 | Issam | CA | LTE_CA_2UL-A3-Core | RP-141732 |  |  |
| 1911 | 460.26.2 | Perf. part: LTE Advanced dual uplink inter-band Carrier Aggregation Class A3 | 467d? | 2013-03-13 A | 2014-12-15 A | 100% | 2013-03-08 | 2014-09-12 | 401d? | finish no earlier than 2014-12-15 | R4 | 3736h | 3736h | LTE_CA_2UL-A3-Perf | PCG-30 | 36.141, 36.307 | Ericsson | christian.bergljung@ericsson.com | Rel-12 | RP-59 | Issam | CA | LTE_CA_2UL-A3-Perf | RP-141732 |  |  |

Notes:
- 1888: Intra-band NC
- 1889: RP#62 completed
- 1890: RP#62 completed
- 1891: Intra-band contig. CA 2DL/1UL
- 1892: RP#62 completed
- 1893: RP#64 completed. TR 36.833-1-27v200 for Approval
- 1894: Inter-band 1 UL
- 1895: RP#60 completed
- 1896: RP#60 completed
- 1897: Inter-band 1 UL
- 1898: RP#60 completed
- 1899: RP#60 completed
- 1900: Inter-band 1 UL
- 1901: RP#62 stopped (at 20%)
- 1902: RP#62 stopped (at 20%)
- 1903: Inter-band CA 2UL
- 1904: ; WID: RP-142043->RP-141941; Stat Rep: RP-141084->RP-141732
- 1905: ; WID: RP-142043->RP-141941; Stat Rep: RP-141084->RP-141732
- 1906: Inter-band CA 2UL
- 1907: ; Stat Rep: RP-141084->RP-141732
- 1908: ; Stat Rep: RP-141084->RP-141732
- 1909: Inter-band CA 2UL
- 1910: ; Stat Rep: RP-141084->RP-141732
- 1911: ; Stat Rep: RP-141084->RP-141732

| ID | WBS | Task | Duration | Start | Finish | Complete | Baseline start | Baseline finish | Baseline duration | Constraint | Resources | Work | Actual work | Acronym | PCG approved | WI rapporteur name | WI rapporteur e-mail | Release | TSG approved | MCC resp | Special Focus Doc | Acronym_3GU_Export | Status Report | PCG stopped | TSG stopped |
| --- | --- | --- | --- | --- | --- | --- | --- | --- | --- | --- | --- | --- | --- | --- | --- | --- | --- | --- | --- | --- | --- | --- | --- | --- | --- |
| 1912 | 460.27 | **LTE Advanced dual uplink inter-band Carrier Aggregation Class A4** | 474d? | 2013-03-04 A | 2014-12-15 A | 100% | 2013-03-04 | 2014-09-12 | 405d? |  | R4 | 11272h | 11272h | LTE_CA_2UL-A4 | PCG-30 | Nokia | petri.j.vasenkari@nokia.com | Rel-12 | RP-59 | Issam | CA | LTE_CA_2UL-A4 |  |  |  |
| 1913 | 460.27.1 | Core part: LTE Advanced dual uplink inter-band Carrier Aggregation Class A4 | 468d? | 2013-03-04 A | 2014-12-15 A | 100% | 2013-03-04 | 2014-09-12 | 402d? | finish no earlier than 2014-12-15 | R4 | 3744h | 3744h | LTE_CA_2UL-A4-Core | PCG-30 | Nokia | petri.j.vasenkari@nokia.com | Rel-12 | RP-59 | Issam | CA | LTE_CA_2UL-A4-Core | RP-141732 |  |  |
| 1914 | 460.27.2 | Perf. part: LTE Advanced dual uplink inter-band Carrier Aggregation Class A4 | 467d? | 2013-03-13 A | 2014-12-15 A | 100% | 2013-03-08 | 2014-09-12 | 401d? | finish no earlier than 2014-12-15 | R4 | 3736h | 3736h | LTE_CA_2UL-A4-Perf | PCG-30 | Nokia | petri.j.vasenkari@nokia.com | Rel-12 | RP-59 | Issam | CA | LTE_CA_2UL-A4-Perf | RP-141732 |  |  |
| 1915 | 460.28 | **LTE Advanced dual uplink inter-band Carrier Aggregation Class A5** | 474d? | 2013-03-04 A | 2014-12-15 A | 100% | 2013-03-04 | 2014-09-12 | 405d? |  | R4 | 11264h | 11264h | LTE_CA_2UL-A5 | PCG-30 | NTT DOCOMO | kei.andou.ye@nttdocomo.com | Rel-12 | RP-59 | Issam | CA | LTE_CA_2UL-A5 |  |  |  |
| 1916 | 460.28.1 | Core part: LTE Advanced dual uplink inter-band Carrier Aggregation Class A5 | 467d? | 2013-03-04 A | 2014-12-15 A | 100% | 2013-03-04 | 2014-09-12 | 401d? | finish no earlier than 2014-12-15 | R4 | 3736h | 3736h | LTE_CA_2UL-A5-Core | PCG-30 | NTT DOCOMO | kei.andou.ye@nttdocomo.com | Rel-12 | RP-59 | Issam | CA | LTE_CA_2UL-A5-Core | RP-141732 |  |  |
| 1917 | 460.28.2 | Perf. part: LTE Advanced dual uplink inter-band Carrier Aggregation Class A5 | 467d? | 2013-03-13 A | 2014-12-15 A | 100% | 2013-03-08 | 2014-09-12 | 401d? | finish no earlier than 2014-12-15 | R4 | 3736h | 3736h | LTE_CA_2UL-A5-Perf | PCG-30 | NTT DOCOMO | kei.andou.ye@nttdocomo.com | Rel-12 | RP-59 | Issam | CA | LTE_CA_2UL-A5-Perf | RP-141732 |  |  |
| 1918 | 460.29 | **LTE Advanced intra-band contiguous Carrier Aggregation in Band 39** | 269d? | 2013-03-04 A | 2014-03-06 A | 100% | 2013-03-04 | 2014-03-06 | 269d? |  | R4 | 6400h | 6400h | LTE_CA_C_B39 | PCG-30 | China Mobile | Li Nan (linan@chinamobile.com) | Rel-12 | RP-59 | Issam | CA | LTE_CA_C_B39 |  |  |  |
| 1919 | 460.29.1 | Core part: LTE Advanced intra-band contiguous Carrier Aggregation in Band 39 | 266d? | 2013-03-04 A | 2014-03-06 A | 100% | 2013-03-04 | 2014-03-06 | 266d? | finish no earlier than 2014-03-06 | R4 | 2128h | 2128h | LTE_CA_C_B39-Core | PCG-30 | China Mobile | Li Nan (linan@chinamobile.com) | Rel-12 | RP-59 | Issam | CA | LTE_CA_C_B39-Core | RP-140428 |  |  |
| 1920 | 460.29.2 | Perf. part: LTE Advanced intra-band contiguous Carrier Aggregation in Band 39 | 265d? | 2013-03-07 A | 2014-03-06 A | 100% | 2013-03-07 | 2014-03-06 | 265d? | finish no earlier than 2014-03-06 | R4 | 2120h | 2120h | LTE_CA_C_B39-Perf | PCG-30 | China Mobile | Li Nan (linan@chinamobile.com) | Rel-12 | RP-59 | Issam | CA | LTE_CA_C_B39-Perf | RP-140428 |  |  |
| 1921 | 460.30 | **LTE Advanced intra-band non-contiguous Carrier Aggregation: framework requirements for 2UL** | 397d? | 2013-06-18 A | 2014-12-15 A | 100% | 2013-06-18 | 2014-09-12 | 328d? |  | R4 | 6328h | 6328h | LTE_CA_NC_2UL | PCG-31 | Nokia | petri.j.vasenkari@nokia.com | Rel-12 | RP-60 | Issam | CA | LTE_CA_NC_2UL |  |  |  |
| 1922 | 460.30.1 | Core part: LTE Advanced intra-band non-contiguous Carrier Aggregation: framework requirements for 2UL | 394d? | 2013-06-18 A | 2014-12-15 A | 100% | 2013-06-18 | 2014-09-12 | 328d? | finish no earlier than 2014-12-15 | R4 | 3152h | 3152h | LTE_CA_NC_2UL-Core | PCG-31 | Nokia | petri.j.vasenkari@nokia.com | Rel-12 | RP-60 | Issam | CA | LTE_CA_NC_2UL-Core | RP-141732 |  |  |
| 1923 | 460.31 | **Deleted - LTE Advanced intra-band non-contiguous Carrier Aggregation in Band 41 for 2UL** | 191d? | 2013-06-19 A | 2014-03-06 A | 100% | 2013-06-19 | 2014-03-06 | 191d? |  | R4 | 4576h | 4576h | LTE_CA_NC_B41_2UL | PCG-31 | Sprint | yang.xu@clearwire.com | Rel-12 | RP-60 | Issam | CA | LTE_CA_NC_B41_2UL | RP-140428 | PCG-32 | RP-63 |
| 1924 | 460.31.1 | Deleted - Core part: LTE Advanced intra-band non-contiguous Carrier Aggregation in Band 41 for 2UL | 191d? | 2013-06-19 A | 2014-03-06 A | 100% | 2013-06-19 | 2014-03-06 | 191d? | finish no earlier than 2014-03-06 | R4 | 1528h | 1528h | LTE_CA_NC_B41_2UL-Core | PCG-31 | Sprint | yang.xu@clearwire.com | Rel-12 | RP-60 | Issam | CA | LTE_CA_NC_B41_2UL-Core | RP-140428 | PCG-32 | RP-63 |
| 1925 | 460.31.2 | Deleted - Perf. part: LTE Advanced intra-band non-contiguous Carrier Aggregation in Band 41 for 2UL | 190d? | 2013-06-20 A | 2014-03-06 A | 100% | 2013-06-20 | 2014-03-06 | 190d? | finish no earlier than 2014-03-06 | R4 | 1520h | 1520h | LTE_CA_NC_B41_2UL-Perf | PCG-31 | Sprint | yang.xu@clearwire.com | Rel-12 | RP-60 | Issam | CA | LTE_CA_NC_B41_2UL-Perf | RP-140428 | PCG-32 | RP-63 |
| 1926 | 460.32 | **LTE Advanced intra-band non-contiguous Carrier Aggregation in Band 4 for 2UL** | 396d? | 2013-06-19 A | 2014-12-15 A | 100% | 2013-06-19 | 2014-09-12 | 327d? |  | R4 | 9448h | 9448h | LTE_CA_NC_B4_2UL | PCG-31 | T-Mobile USA | nelson.ueng@t-mobile.com | Rel-12 | RP-60 | Issam | CA | LTE_CA_NC_B4_2UL |  |  |  |
| 1927 | 460.32.1 | Core part: LTE Advanced intra-band non-contiguous Carrier Aggregation in Band 4 for 2UL | 393d? | 2013-06-19 A | 2014-12-15 A | 100% | 2013-06-19 | 2014-09-12 | 327d? | finish no earlier than 2014-12-15 | R4 | 3144h | 3144h | LTE_CA_NC_B4_2UL-Core | PCG-31 | T-Mobile USA | nelson.ueng@t-mobile.com | Rel-12 | RP-60 | Issam | CA | LTE_CA_NC_B4_2UL-Core | RP-141732 |  |  |
| 1928 | 460.32.2 | Perf. part: LTE Advanced intra-band non-contiguous Carrier Aggregation in Band 4 for 2UL | 392d? | 2013-06-25 A | 2014-12-15 A | 100% | 2013-06-20 | 2014-09-12 | 326d? | finish no earlier than 2014-12-15 | R4 | 3136h | 3136h | LTE_CA_NC_B4_2UL-Perf | PCG-31 | T-Mobile USA | nelson.ueng@t-mobile.com | Rel-12 | RP-60 | Issam | CA | LTE_CA_NC_B4_2UL-Perf | RP-141732 |  |  |
| 1929 | 460.33 | **LTE Advanced intra-band contiguous Carrier Aggregation in Band 23** | 127d? | 2013-06-18 A | 2013-12-06 A | 100% | 2013-06-18 | 2013-12-06 | 127d? |  | R4 | 3032h | 3032h | LTE_CA_C_B23 | PCG-31 | Dish Network | mariam.sorond@dish.com, johny.kim@dish.com | Rel-12 | RP-60 | Issam | CA | LTE_CA_C_B23 |  |  |  |
| 1930 | 460.33.1 | Core part: LTE Advanced intra-band contiguous Carrier Aggregation in Band 23 | 126d? | 2013-06-18 A | 2013-12-06 A | 100% | 2013-06-18 | 2013-12-06 | 126d? | finish no earlier than 2013-12-06 | R4 | 1008h | 1008h | LTE_CA_C_B23-Core | PCG-31 | Dish Network | mariam.sorond@dish.com, johny.kim@dish.com | Rel-12 | RP-60 | Issam | CA | LTE_CA_C_B23-Core | RP-131565 |  |  |
| 1931 | 460.33.2 | Perf. part: LTE Advanced intra-band contiguous Carrier Aggregation in Band 23 | 126d? | 2013-06-18 A | 2013-12-06 A | 100% | 2013-06-18 | 2013-12-06 | 126d? | finish no earlier than 2013-12-06 | R4 | 1008h | 1008h | LTE_CA_C_B23-Perf | PCG-31 | Dish Network | mariam.sorond@dish.com, johny.kim@dish.com | Rel-12 | RP-60 | Issam | CA | LTE_CA_C_B23-Perf | RP-131566 |  |  |
| 1932 | 460.34 | **LTE Advanced intra-band non-contiguous Carrier Aggregation in Band 23** | 263d? | 2013-06-18 A | 2014-06-13 A | 100% | 2013-06-18 | 2014-06-13 | 263d? |  | R4 | 5216h | 5216h | LTE_CA_NC_B23 | PCG-31 | Dish Network | mariam.sorond@dish.com, johny.kim@dish.com | Rel-12 | RP-60 | Issam | CA | LTE_CA_NC_B23 |  |  |  |
| 1933 | 460.34.1 | Core part: LTE Advanced intra-band non-contiguous Carrier Aggregation in Band 23 | 126d? | 2013-06-18 A | 2013-12-06 A | 100% | 2013-06-18 | 2013-12-06 | 126d? | finish no earlier than 2013-12-06 | R4 | 1008h | 1008h | LTE_CA_NC_B23-Core | PCG-31 | Dish Network | mariam.sorond@dish.com, johny.kim@dish.com | Rel-12 | RP-60 | Issam | CA | LTE_CA_NC_B23-Core | RP-131577 |  |  |
| 1934 | 460.34.2 | Perf. part: LTE Advanced intra-band non-contiguous Carrier Aggregation in Band 23 | 263d? | 2013-06-18 A | 2014-06-13 A | 100% | 2013-06-18 | 2014-06-13 | 263d? | finish no earlier than 2014-06-13 | R4 | 2104h | 2104h | LTE_CA_NC_B23-Perf | PCG-31 | Dish Network | mariam.sorond@dish.com, johny.kim@dish.com | Rel-12 | RP-60 | Issam | CA | LTE_CA_NC_B23-Perf | RP-140569 |  |  |
| 1935 | 460.35 | **LTE Advanced inter-band Carrier Aggregation of Band 12 and Band 25** | 127d? | 2013-06-18 A | 2013-12-06 A | 100% | 2013-06-18 | 2013-12-06 | 127d? |  | R4 | 3032h | 3032h | LTE_CA_B12_B25 | PCG-31 | US Cellular | sebastian.thalanany@uscellular.com | Rel-12 | RP-60 | Issam | CA | LTE_CA_B12_B25 |  |  |  |
| 1936 | 460.35.1 | Core part: LTE Advanced inter-band Carrier Aggregation of Band 12 and Band 25 | 126d? | 2013-06-18 A | 2013-12-06 A | 100% | 2013-06-18 | 2013-12-06 | 126d? | finish no earlier than 2013-12-06 | R4 | 1008h | 1008h | LTE_CA_B12_B25-Core | PCG-31 | US Cellular | sebastian.thalanany@uscellular.com | Rel-12 | RP-60 | Issam | CA | LTE_CA_B12_B25-Core | RP-131705 |  |  |
| 1937 | 460.35.2 | Perf. part: LTE Advanced inter-band Carrier Aggregation of Band 12 and Band 25 | 126d? | 2013-06-19 A | 2013-12-06 A | 100% | 2013-06-19 | 2013-12-06 | 126d? | finish no earlier than 2013-12-06 | R4 | 1008h | 1008h | LTE_CA_B12_B25-Perf | PCG-31 | US Cellular | sebastian.thalanany@uscellular.com | Rel-12 | RP-60 | Issam | CA | LTE_CA_B12_B25-Perf | RP-131706 |  |  |

Notes:
- 1912: Inter-band CA 2UL. RP#65 updated WID RP-140476=>RP-141160. / Impacted TSs and TRs: LTE
- 1913: ; WID: RP-142043->RP-141967; Stat Rep: RP-141084->RP-141732 / Impacted TSs and TRs: 36.101, 36.104, 36.133, New generic TR 36.860
- 1914: ; WID: RP-142043->RP-141967; Stat Rep: RP-141084->RP-141732 / Impacted TSs and TRs: 36.141, 36.307
- 1915: Inter-band CA 2UL. RP#65 updated WID RP-131146=>RP-141195. Changed Rapp Renesas=>Broadcom=>NTT DOCOMO / Impacted TSs and TRs: LTE
- 1916: ; Stat Rep: RP-141084->RP-141732 / Impacted TSs and TRs: 36.101, 36.104, 36.133, New generic TR 36.860
- 1917: ; Stat Rep: RP-141084->RP-141732 / Impacted TSs and TRs: 36.141, 36.307
- 1918: Intra-band C 2DL/2UL / Impacted TSs and TRs: LTE
- 1919: RP#63 completed / Impacted TSs and TRs: 36.101, 36.104, 36.133, New TR 36.833-1-39 [instead of 36.845]
- 1920: RP#63 completed / Impacted TSs and TRs: 36.141, 36.307
- 1921: Intra-band non-contig. CA 2DL / Impacted TSs and TRs: LTE
- 1922: ; WID: RP-142043->RP-141962; Stat Rep: RP-141084->RP-141732 / Impacted TSs and TRs: 36.101, 36.104, 36.133, 36.306, 36.331, New TR 36.833-4
- 1923: Intra-band NC 2UL / Impacted TSs and TRs: LTE
- 1924: RP#63 stopped (5% complete). Reason: Market conditions have eliminated the need for this feature, at least for the foreseeable future / Impacted TSs and TRs: 36.101, 36.104, 36.133, new TR 36.833-3-41
- 1925: RP#63 stopped (0% complete). / Impacted TSs and TRs: 36.101, 36.104, 36.133, 36.141, 36.307
- 1926: Intra-band non-contig. CA 2DL / Impacted TSs and TRs: LTE
- 1927: ; WID: RP-142043->RP-141784; Stat Rep: RP-141084->RP-141732 / Impacted TSs and TRs: 36.101, 36.104, 36.133, new TR 36.833-4-04
- 1928: ; WID: RP-142043->RP-141784; Stat Rep: RP-141084->RP-141732 / Impacted TSs and TRs: 36.101, 36.104, 36.133, 36.141, 36.307
- 1929: Intra-band C CA / Impacted TSs and TRs: LTE
- 1930: RP#62 completed / Impacted TSs and TRs: 36.101, 36.104, 36.133, new TR 36.833-1-23 [instead of 36.864]
- 1931: RP#62 completed / Impacted TSs and TRs: 36.141, 36.307
- 1932: Intra-band non-contig. CA 2DL / Impacted TSs and TRs: LTE
- 1933: RP#62 completed / Impacted TSs and TRs: 36.101, 36.104, 36.133, new TR 36.833-2-23
- 1934: RP#64 completed. TR 36.833-2-23v200 for Approval / Impacted TSs and TRs: 36.101, 36.133, 36.141, 36.307, new TR 36.833-2-23
- 1935: Inter-band 1UL/2DL / Impacted TSs and TRs: LTE
- 1936: RP#62 completed / Impacted TSs and TRs: 36.101, 36.104, 36.133, new generic TR 36.851
- 1937: RP#62 completed / Impacted TSs and TRs: 36.141, 36.307

| ID | WBS | Task | Duration | Start | Finish | Complete | Baseline start | Baseline finish | Baseline duration | Constraint | Resources | Work | Actual work | Acronym | PCG approved | WI rapporteur name | WI rapporteur e-mail | Release | TSG approved | MCC resp | Special Focus Doc | Acronym_3GU_Export | Status Report | PCG stopped | TSG stopped |
| --- | --- | --- | --- | --- | --- | --- | --- | --- | --- | --- | --- | --- | --- | --- | --- | --- | --- | --- | --- | --- | --- | --- | --- | --- | --- |
| 1938 | 460.36 | **LTE Advanced inter-band Carrier Aggregation of Band 1 and Band 18 - Additional bandwidth combination set** | 61d? | 2013-06-18 A | 2013-09-06 A | 100% | 2013-06-18 | 2013-09-06 | 61d? |  | R4 | 1464h | 1464h | LTE_CA_B1_B18_BWset | PCG-31 | KDDI | Masaaki Obara (ms-obara@kddi.com) | Rel-12 | RP-60 | Issam | CA | LTE_CA_B1_B18_BWset |  |  |  |
| 1939 | 460.36.1 | Core part: LTE Advanced inter-band Carrier Aggregation of Band 1 and Band 18 - Additional bandwidth combination set | 61d? | 2013-06-18 A | 2013-09-06 A | 100% | 2013-06-18 | 2013-09-06 | 61d? | finish no earlier than 2013-09-06 | R4 | 488h | 488h | LTE_CA_B1_B18_BWset-Core | PCG-31 | KDDI | Masaaki Obara (ms-obara@kddi.com) | Rel-12 | RP-60 | Issam | CA | LTE_CA_B1_B18_BWset-Core | RP-131003 |  |  |
| 1940 | 460.36.2 | Perf. part: LTE Advanced inter-band Carrier Aggregation of Band 1 and Band 18 - Additional bandwidth combination set | 61d? | 2013-06-18 A | 2013-09-06 A | 100% | 2013-06-18 | 2013-09-06 | 61d? | finish no earlier than 2013-09-06 | R4 | 488h | 488h | LTE_CA_B1_B18_BWset-Perf | PCG-31 | KDDI | Masaaki Obara (ms-obara@kddi.com) | Rel-12 | RP-60 | Issam | CA | LTE_CA_B1_B18_BWset-Perf | RP-131004 |  |  |
| 1941 | 460.37 | **LTE Advanced inter-band Carrier Aggregation of Band 2 and Band 5** | 61d? | 2013-06-18 A | 2013-09-06 A | 100% | 2013-06-18 | 2013-09-06 | 61d? |  | R4 | 1464h | 1464h | LTE_CA_B2_B5 | PCG-31 | AT&T | marc.grant@att.com | Rel-12 | RP-60 | Issam | CA | LTE_CA_B2_B5 |  |  |  |
| 1942 | 460.37.1 | Core part: LTE Advanced inter-band Carrier Aggregation of Band 2 and Band 5 | 61d? | 2013-06-18 A | 2013-09-06 A | 100% | 2013-06-18 | 2013-09-06 | 61d? | finish no earlier than 2013-09-06 | R4 | 488h | 488h | LTE_CA_B2_B5-Core | PCG-31 | AT&T | marc.grant@att.com | Rel-12 | RP-60 | Issam | CA | LTE_CA_B2_B5-Core | RP-131009 |  |  |
| 1943 | 460.37.2 | Perf. part: LTE Advanced inter-band Carrier Aggregation of Band 2 and Band 5 | 61d? | 2013-06-18 A | 2013-09-06 A | 100% | 2013-06-18 | 2013-09-06 | 61d? | finish no earlier than 2013-12-06 | R4 | 488h | 488h | LTE_CA_B2_B5-Perf | PCG-31 | AT&T | marc.grant@att.com | Rel-12 | RP-60 | Issam | CA | LTE_CA_B2_B5-Perf | RP-131010 |  |  |
| 1944 | 460.38 | **LTE Advanced 3 Band Carrier Aggregation (3DL/1UL) of Band 2, Band 5 and Band 30** | 329d? | 2013-06-18 A | 2014-09-12 A | 100% | 2013-06-18 | 2014-09-12 | 328d? |  | R4 | 7872h | 7872h | LTE_CA_B2_B5_B30 | PCG-31 | AT&T | marc.grant@att.com | Rel-12 | RP-60 | Issam | CA | LTE_CA_B2_B5_B30 |  |  |  |
| 1945 | 460.38.1 | Core part: LTE Advanced 3 Band Carrier Aggregation (3DL/1UL) of Band 2, Band 5 and Band 30 | 328d? | 2013-06-18 A | 2014-09-12 A | 100% | 2013-06-18 | 2014-09-12 | 328d? | finish no earlier than 2014-09-12 | R4 | 2624h | 2624h | LTE_CA_B2_B5_B30-Core | PCG-31 | AT&T | marc.grant@att.com | Rel-12 | RP-60 | Issam | CA | LTE_CA_B2_B5_B30-Core | RP-141084 |  |  |
| 1946 | 460.38.2 | Perf. part: LTE Advanced 3 Band Carrier Aggregation (3DL/1UL) of Band 2, Band 5 and Band 30 | 327d? | 2013-06-18 A | 2014-09-12 A | 100% | 2013-06-18 | 2014-09-12 | 327d? | finish no earlier than 2014-09-12 | R4 | 2616h | 2616h | LTE_CA_B2_B5_B30-Perf | PCG-31 | AT&T | marc.grant@att.com | Rel-12 | RP-60 | Issam | CA | LTE_CA_B2_B5_B30-Perf | RP-141084 |  |  |
| 1947 | 460.39 | **Deleted - LTE Advanced 3 Band Carrier Aggregation (3DL/1UL) of Band 2, Band 17 and Band 30** | 127d? | 2013-06-18 A | 2013-12-06 A | 100% | 2013-06-18 | 2013-12-06 | 127d? |  | R4 | 3024h | 3024h | LTE_CA_B2_B17_B30 | PCG-31 | AT&T | marc.grant@att.com | Rel-12 | RP-60 | Issam | CA | LTE_CA_B2_B17_B30 |  | PCG-32 | RP-62 |
| 1948 | 460.39.1 | Deleted - Core part: LTE Advanced 3 Band Carrier Aggregation (3DL/1UL) of Band 2, Band 17 and Band 30 | 126d? | 2013-06-18 A | 2013-12-06 A | 100% | 2013-06-18 | 2013-12-06 | 126d? | finish no earlier than 2014-06-13 | R4 | 1008h | 1008h | LTE_CA_B2_B17_B30-Core | PCG-31 | AT&T | marc.grant@att.com | Rel-12 | RP-60 | Issam | CA | LTE_CA_B2_B17_B30-Core | RP-131590 | PCG-32 | RP-62 |
| 1949 | 460.39.2 | Deleted - Perf. part: LTE Advanced 3 Band Carrier Aggregation (3DL/1UL) of Band 2, Band 17 and Band 30 | 125d? | 2013-06-19 A | 2013-12-06 A | 100% | 2013-06-19 | 2013-12-06 | 125d? | finish no earlier than 2014-09-12 | R4 | 1000h | 1000h | LTE_CA_B2_B17_B30-Perf | PCG-31 | AT&T | marc.grant@att.com | Rel-12 | RP-60 | Issam | CA | LTE_CA_B2_B17_B30-Perf | RP-131591 | PCG-32 | RP-62 |
| 1950 | 460.40 | **LTE Advanced 3 Band Carrier Aggregation (3DL/1UL) of Band 2, Band 29 and Band 30** | 328d? | 2013-06-19 A | 2014-09-12 A | 100% | 2013-06-19 | 2014-09-12 | 327d? |  | R4 | 7856h | 7856h | LTE_CA_B2_B29_B30 | PCG-31 | AT&T | marc.grant@att.com | Rel-12 | RP-60 | Issam | CA | LTE_CA_B2_B29_B30 |  |  |  |
| 1951 | 460.40.1 | Core part: LTE Advanced 3 Band Carrier Aggregation (3DL/1UL) of Band 2, Band 29 and Band 30 | 327d? | 2013-06-19 A | 2014-09-12 A | 100% | 2013-06-19 | 2014-06-13 | 262d? | finish no earlier than 2014-09-12 | R4 | 2616h | 2616h | LTE_CA_B2_B29_B30-Core | PCG-31 | AT&T | marc.grant@att.com | Rel-12 | RP-60 | Issam | CA | LTE_CA_B2_B29_B30-Core | RP-141084 |  |  |
| 1952 | 460.40.2 | Perf. part: LTE Advanced 3 Band Carrier Aggregation (3DL/1UL) of Band 2, Band 29 and Band 30 | 327d? | 2013-06-19 A | 2014-09-12 A | 100% | 2013-06-19 | 2014-09-12 | 327d? | finish no earlier than 2014-09-12 | R4 | 2616h | 2616h | LTE_CA_B2_B29_B30-Perf | PCG-31 | AT&T | marc.grant@att.com | Rel-12 | RP-60 | Issam | CA | LTE_CA_B2_B29_B30-Perf | RP-141084 |  |  |
| 1953 | 460.41 | **LTE Advanced 3 Band Carrier Aggregation (3DL/1UL) of Band 4, Band 5 and Band 30** | 331d? | 2013-06-14 A | 2014-09-12 A | 100% | 2013-06-14 | 2014-09-12 | 330d? |  | R4 | 7904h | 7904h | LTE_CA_B4_B5_B30 | PCG-31 | AT&T | marc.grant@att.com | Rel-12 | RP-60 | Issam | CA | LTE_CA_B4_B5_B30 |  |  |  |
| 1954 | 460.41.1 | Core part: LTE Advanced 3 Band Carrier Aggregation (3DL/1UL) of Band 4, Band 5 and Band 30 | 330d? | 2013-06-14 A | 2014-09-12 A | 100% | 2013-06-14 | 2014-09-12 | 330d? | finish no earlier than 2014-09-12 | R4 | 2640h | 2640h | LTE_CA_B4_B5_B30-Core | PCG-31 | AT&T | marc.grant@att.com | Rel-12 | RP-60 | Issam | CA | LTE_CA_B4_B5_B30-Core | RP-141084 |  |  |
| 1955 | 460.41.2 | Perf. part: LTE Advanced 3 Band Carrier Aggregation (3DL/1UL) of Band 4, Band 5 and Band 30 | 327d? | 2013-06-19 A | 2014-09-12 A | 100% | 2013-06-19 | 2014-09-12 | 327d? | finish no earlier than 2014-09-12 | R4 | 2616h | 2616h | LTE_CA_B4_B5_B30-Perf | PCG-31 | AT&T | marc.grant@att.com | Rel-12 | RP-60 | Issam | CA | LTE_CA_B4_B5_B30-Perf | RP-141084 |  |  |
| 1956 | 460.42 | **Deleted - LTE Advanced 3 Band Carrier Aggregation (3DL/1UL) of Band 4, Band 17 and Band 30** | 127d? | 2013-06-18 A | 2013-12-06 A | 100% | 2013-06-18 | 2013-12-06 | 127d? |  | R4 | 3040h | 3040h | LTE_CA_B4_B17_B30 | PCG-31 | AT&T | marc.grant@att.com | Rel-12 | RP-60 | Issam | CA | LTE_CA_B4_B17_B30 |  | PCG-32 | RP-62 |
| 1957 | 460.42.1 | Deleted - Core part: LTE Advanced 3 Band Carrier Aggregation (3DL/1UL) of Band 4, Band 17 and Band 30 | 127d? | 2013-06-18 A | 2013-12-06 A | 100% | 2013-06-18 | 2013-12-06 | 127d? | finish no earlier than 2013-12-06 | R4 | 1016h | 1016h | LTE_CA_B4_B17_B30-Core | PCG-31 | AT&T | marc.grant@att.com | Rel-12 | RP-60 | Issam | CA | LTE_CA_B4_B17_B30-Core | RP-131598 | PCG-32 | RP-62 |
| 1958 | 460.42.2 | Deleted - Perf. part: LTE Advanced 3 Band Carrier Aggregation (3DL/1UL) of Band 4, Band 17 and Band 30 | 126d? | 2013-06-19 A | 2013-12-06 A | 100% | 2013-06-19 | 2013-12-06 | 126d? | finish no earlier than 2013-12-06 | R4 | 1008h | 1008h | LTE_CA_B4_B17_B30-Perf | PCG-31 | AT&T | marc.grant@att.com | Rel-12 | RP-60 | Issam | CA | LTE_CA_B4_B17_B30-Perf | RP-131599 | PCG-32 | RP-62 |
| 1959 | 460.43 | **LTE Advanced 3 Band Carrier Aggregation (3DL/1UL) of Band 4, Band 29 and Band 30** | 331d? | 2013-06-14 A | 2014-09-12 A | 100% | 2013-06-14 | 2014-09-12 | 330d? |  | R4 | 7904h | 7904h | LTE_CA_B4_B29_B30 | PCG-31 | AT&T | marc.grant@att.com | Rel-12 | RP-60 | Issam | CA | LTE_CA_B4_B29_B30 |  |  |  |
| 1960 | 460.43.1 | Core part: LTE Advanced 3 Band Carrier Aggregation (3DL/1UL) of Band 4, Band 29 and Band 30 | 330d? | 2013-06-14 A | 2014-09-12 A | 100% | 2013-06-14 | 2014-09-12 | 330d? | finish no earlier than 2014-09-12 | R4 | 2640h | 2640h | LTE_CA_B4_B29_B30-Core | PCG-31 | AT&T | marc.grant@att.com | Rel-12 | RP-60 | Issam | CA | LTE_CA_B4_B29_B30-Core | RP-141084 |  |  |
| 1961 | 460.43.2 | Perf. part: LTE Advanced 3 Band Carrier Aggregation (3DL/1UL) of Band 4, Band 29 and Band 30 | 327d? | 2013-06-19 A | 2014-09-12 A | 100% | 2013-06-19 | 2014-09-12 | 327d? | finish no earlier than 2014-09-12 | R4 | 2616h | 2616h | LTE_CA_B4_B29_B30-Perf | PCG-31 | AT&T | marc.grant@att.com | Rel-12 | RP-60 | Issam | CA | LTE_CA_B4_B29_B30-Perf | RP-141084 |  |  |

Notes:
- 1938: Inter-band 1UL/2DL / Impacted TSs and TRs: LTE
- 1939: RP#61 completed / Impacted TSs and TRs: 36.101, new generic TR 36.851
- 1940: RP#61 completed / Impacted TSs and TRs: 36.307
- 1941: Inter-band 2DL / Impacted TSs and TRs: LTE
- 1942: RP#61 completed / Impacted TSs and TRs: 36.101, 36.104, 36.307
- 1943: RP#61 completed / Impacted TSs and TRs: 36.101, 36.104, 36.133, 36.141, 36.307
- 1944: Inter-band 3DL / Impacted TSs and TRs: LTE
- 1945: RP#65 completed. TR 36.853v200 for Approval / Impacted TSs and TRs: 36.101, 36.104, 36.133, 36.141, 36.307, new generic TR 36.853 (3 Band CA with 1UL)
- 1946: RP#65 completed / Impacted TSs and TRs: 36.101, 36.104, 36.133, 36.141, 36.307
- 1947: Inter-band 3DL / Impacted TSs and TRs: LTE
- 1948: RP#62 stopped (25% complete) following RP-131652 discussion / Impacted TSs and TRs: 36.101, 36.104, 36.133, 36.141, 36.307, new generic TR 36.853 (3 Band CA with 1UL)
- 1949: RP#62 stopped (25% complete) following RP-131652 discussion / Impacted TSs and TRs: 36.101, 36.104, 36.133, 36.141, 36.307
- 1950: Inter-band 3DL / Impacted TSs and TRs: LTE
- 1951: RP#65 completed. Updated WID RP-131697=>RP-141212 / Impacted TSs and TRs: 36.101, 36.104, 36.133, 36.141, 36.307, new generic TR 36.853 (3 Band CA with 1UL)
- 1952: RP#65 completed / Impacted TSs and TRs: 36.101, 36.104, 36.133, 36.141, 36.307
- 1953: Inter-band CA 3DL / Impacted TSs and TRs: LTE
- 1954: RP#65 completed. Updated WID RP-131698=>RP-141213 / Impacted TSs and TRs: 36.101, 36.104, 36.133, 36.141, 36.307, new generic TR 36.853 (3 Band CA with 1UL)
- 1955: RP#65 completed / Impacted TSs and TRs: 36.101, 36.104, 36.133, 36.141, 36.307
- 1956: Inter-band 3DL / Impacted TSs and TRs: LTE
- 1957: RP#62 stopped (25% complete) following RP-131653 discussion / Impacted TSs and TRs: 36.101, 36.104, 36.133, 36.141, 36.307, new generic TR 36.853 (3 Band CA with 1UL)
- 1958: RP#62 stopped (25% complete) following RP-131653 discussion / Impacted TSs and TRs: 36.101, 36.104, 36.133, 36.141, 36.307
- 1959: Inter-band CA 3DL / Impacted TSs and TRs: LTE
- 1960: RP#65 completed. Updated WID RP-131699=>RP- 141215 / Impacted TSs and TRs: 36.101, 36.104, 36.133, 36.141, 36.307, new generic TR 36.853 (3 Band CA with 1UL)
- 1961: RP#65 completed / Impacted TSs and TRs: 36.101, 36.104, 36.133, 36.141, 36.307

| ID | WBS | Task | Duration | Start | Finish | Complete | Baseline start | Baseline finish | Baseline duration | Constraint | Resources | Work | Actual work | Acronym | PCG approved | WI rapporteur name | WI rapporteur e-mail | Release | TSG approved | MCC resp | Special Focus Doc | Acronym_3GU_Export | Status Report |
| --- | --- | --- | --- | --- | --- | --- | --- | --- | --- | --- | --- | --- | --- | --- | --- | --- | --- | --- | --- | --- | --- | --- | --- |
| 1962 | 460.44 | **LTE Advanced 3 Band Carrier Aggregation (3DL/1UL) of Band 2, Band 4 and Band 13** | 331d? | 2013-06-14 A | 2014-09-12 A | 100% | 2013-06-14 | 2014-09-12 | 330d? |  | R4 | 7904h | 7904h | LTE_CA_B2_B4_B13 | PCG-31 | Verizon | zheng.zhao@verizonwireless.com | Rel-12 | RP-60 | Issam | CA | LTE_CA_B2_B4_B13 |  |
| 1963 | 460.44.1 | Core part: LTE Advanced 3 Band Carrier Aggregation (3DL/1UL) of Band 2, Band 4 and Band 13 | 330d? | 2013-06-14 A | 2014-09-12 A | 100% | 2013-06-14 | 2014-09-12 | 330d? | finish no earlier than 2014-09-12 | R4 | 2640h | 2640h | LTE_CA_B2_B4_B13-Core | PCG-31 | Verizon | zheng.zhao@verizonwireless.com | Rel-12 | RP-60 | Issam | CA | LTE_CA_B2_B4_B13-Core | RP-141084 |
| 1964 | 460.44.2 | Perf. part: LTE Advanced 3 Band Carrier Aggregation (3DL/1UL) of Band 2, Band 4 and Band 13 | 327d? | 2013-06-19 A | 2014-09-12 A | 100% | 2013-06-19 | 2014-09-12 | 327d? | finish no earlier than 2014-09-12 | R4 | 2616h | 2616h | LTE_CA_B2_B4_B13-Perf | PCG-31 | Verizon | zheng.zhao@verizonwireless.com | Rel-12 | RP-60 | Issam | CA | LTE_CA_B2_B4_B13-Perf | RP-141084 |
| 1965 | 460.45 | **LTE Advanced 3 Band Carrier Aggregation (3DL/1UL) of Band 2, Band 2 and Band 13** | 329d? | 2013-06-18 A | 2014-09-12 A | 100% | 2013-06-18 | 2014-09-12 | 328d? |  | R4 | 7864h | 7864h | LTE_CA_B2_B2_B13 | PCG-31 | Verizon | zheng.zhao@verizonwireless.com | Rel-12 | RP-60 | Issam | CA | LTE_CA_B2_B2_B13 |  |
| 1966 | 460.45.1 | Core part: LTE Advanced 3 Band Carrier Aggregation (3DL/1UL) of Band 2, Band 2 and Band 13 | 327d? | 2013-06-18 A | 2014-09-12 A | 100% | 2013-06-18 | 2014-09-12 | 327d? | finish no earlier than 2014-09-12 | R4 | 2616h | 2616h | LTE_CA_B2_B2_B13-Core | PCG-31 | Verizon | zheng.zhao@verizonwireless.com | Rel-12 | RP-60 | Issam | CA | LTE_CA_B2_B2_B13-Core | RP-141084 |
| 1967 | 460.45.2 | Perf. part: LTE Advanced 3 Band Carrier Aggregation (3DL/1UL) of Band 2, Band 2 and Band 13 | 327d? | 2013-06-19 A | 2014-09-12 A | 100% | 2013-06-19 | 2014-09-12 | 327d? | finish no earlier than 2014-09-12 | R4 | 2616h | 2616h | LTE_CA_B2_B2_B13-Perf | PCG-31 | Verizon | zheng.zhao@verizonwireless.com | Rel-12 | RP-60 | Issam | CA | LTE_CA_B2_B2_B13-Perf | RP-141084 |
| 1968 | 460.46 | **LTE Advanced 3 Band Carrier Aggregation (3DL/1UL) of Band 4, Band 4 and Band 13** | 331d? | 2013-06-14 A | 2014-09-12 A | 100% | 2013-06-14 | 2014-09-12 | 330d? |  | R4 | 7928h | 7928h | LTE_CA_B4_B4_B13 | PCG-31 | Verizon | zheng.zhao@verizonwireless.com | Rel-12 | RP-60 | Issam | CA | LTE_CA_B4_B4_B13 |  |
| 1969 | 460.46.1 | Core part: LTE Advanced 3 Band Carrier Aggregation (3DL/1UL) of Band 4, Band 4 and Band 13 | 330d? | 2013-06-14 A | 2014-09-12 A | 100% | 2013-06-14 | 2014-09-12 | 330d? | finish no earlier than 2014-09-12 | R4 | 2640h | 2640h | LTE_CA_B4_B4_B13-Core | PCG-31 | Verizon | zheng.zhao@verizonwireless.com | Rel-12 | RP-60 | Issam | CA | LTE_CA_B4_B4_B13-Core | RP-141084 |
| 1970 | 460.46.2 | Perf. part: LTE Advanced 3 Band Carrier Aggregation (3DL/1UL) of Band 4, Band 4 and Band 13 | 330d? | 2013-06-14 A | 2014-09-12 A | 100% | 2013-06-14 | 2014-09-12 | 330d? | finish no earlier than 2014-09-12 | R4 | 2640h | 2640h | LTE_CA_B4_B4_B13-Perf | PCG-31 | Verizon | zheng.zhao@verizonwireless.com | Rel-12 | RP-60 | Issam | CA | LTE_CA_B4_B4_B13-Perf | RP-141084 |
| 1971 | 460.47 | **LTE Advanced inter-band Carrier Aggregation of Band 7 and Band 28** | 66d? | 2013-09-09 A | 2013-12-06 A | 100% | 2013-09-09 | 2013-12-06 | 66d? |  | R4 | 1584h | 1584h | LTE_CA_B7_B28 | PCG-31 | Huawei | Liehai Liu (liuliehai@huawei.com) | Rel-12 | RP-61 | Issam | CA | LTE_CA_B7_B28 |  |
| 1972 | 460.47.1 | Core part: LTE Advanced inter-band Carrier Aggregation of Band 7 and Band 28 | 66d? | 2013-09-09 A | 2013-12-06 A | 100% | 2013-09-09 | 2013-12-06 | 66d? | finish no earlier than 2013-12-06 | R4 | 528h | 528h | LTE_CA_B7_B28-Core | PCG-31 | Huawei | Liehai Liu (liuliehai@huawei.com) | Rel-12 | RP-61 | Issam | CA | LTE_CA_B7_B28-Core | RP-131545 |
| 1973 | 460.47.2 | Perf. part: LTE Advanced inter-band Carrier Aggregation of Band 7 and Band 28 | 66d? | 2013-09-09 A | 2013-12-06 A | 100% | 2013-09-09 | 2013-12-06 | 66d? | finish no earlier than 2013-12-06 | R4 | 528h | 528h | LTE_CA_B7_B28-Perf | PCG-31 | Huawei | Liehai Liu (liuliehai@huawei.com) | Rel-12 | RP-61 | Issam | CA | LTE_CA_B7_B28-Perf | RP-131546 |
| 1974 | 460.48 | **LTE Advanced inter-band Carrier Aggregation of Band 5 and Band 25** | 66d? | 2013-09-09 A | 2013-12-06 A | 100% | 2013-09-09 | 2013-12-06 | 66d? |  | R4 | 1584h | 1584h | LTE_CA_B5_B25 | PCG-31 | U.S. Cellular | sebastian.thalanany@uscellular.com | Rel-12 | RP-61 | Issam | CA | LTE_CA_B5_B25 |  |
| 1975 | 460.48.1 | Core part: LTE Advanced inter-band Carrier Aggregation of Band 5 and Band 25 | 66d? | 2013-09-09 A | 2013-12-06 A | 100% | 2013-09-09 | 2013-12-06 | 66d? | finish no earlier than 2013-12-06 | R4 | 528h | 528h | LTE_CA_B5_B25-Core | PCG-31 | U.S. Cellular | sebastian.thalanany@uscellular.com | Rel-12 | RP-61 | Issam | CA | LTE_CA_B5_B25-Core | RP-131543 |
| 1976 | 460.48.2 | Perf. part: LTE Advanced inter-band Carrier Aggregation of Band 5 and Band 25 | 66d? | 2013-09-09 A | 2013-12-06 A | 100% | 2013-09-09 | 2013-12-06 | 66d? | finish no earlier than 2013-12-06 | R4 | 528h | 528h | LTE_CA_B5_B25-Perf | PCG-31 | U.S. Cellular | sebastian.thalanany@uscellular.com | Rel-12 | RP-61 | Issam | CA | LTE_CA_B5_B25-Perf | RP-131705 |
| 1977 | 460.49 | **LTE Advanced inter-band Carrier Aggregation of Band 1 and Band 11** | 202d? | 2013-09-09 A | 2014-06-13 A | 100% | 2013-09-09 | 2014-06-13 | 202d? |  | R4 | 4848h | 4848h | LTE_CA_B1_B11 | PCG-31 | SoftBank Mobile | kenichi.kihara@g.softbank.co.jp | Rel-12 | RP-61 | Issam | CA | LTE_CA_B1_B11 |  |
| 1978 | 460.49.1 | Core part: LTE Advanced inter-band Carrier Aggregation of Band 1 and Band 11 | 202d? | 2013-09-09 A | 2014-06-13 A | 100% | 2013-09-09 | 2014-06-13 | 202d? | finish no earlier than 2014-06-13 | R4 | 1616h | 1616h | LTE_CA_B1_B11-Core | PCG-31 | SoftBank Mobile | kenichi.kihara@g.softbank.co.jp | Rel-12 | RP-61 | Issam | CA | LTE_CA_B1_B11-Core | RP-140569 |
| 1979 | 460.49.2 | Perf. part: LTE Advanced inter-band Carrier Aggregation of Band 1 and Band 11 | 202d? | 2013-09-09 A | 2014-06-13 A | 100% | 2013-09-09 | 2014-06-13 | 202d? | finish no earlier than 2014-06-13 | R4 | 1616h | 1616h | LTE_CA_B1_B11-Perf | PCG-31 | SoftBank Mobile | kenichi.kihara@g.softbank.co.jp | Rel-12 | RP-61 | Issam | CA | LTE_CA_B1_B11-Perf | RP-140569 |
| 1980 | 460.50 | **LTE Advanced inter-band Carrier Aggregation of Band 8 and Band 11** | 268d? | 2013-09-09 A | 2014-09-12 A | 100% | 2013-09-09 | 2014-09-12 | 267d? |  | R4 | 6416h | 6416h | LTE_CA_B8_B11 | PCG-31 | SoftBank Mobile | kenichi.kihara@g.softbank.co.jp | Rel-12 | RP-61 | Issam | CA | LTE_CA_B8_B11 |  |
| 1981 | 460.50.1 | Core part: LTE Advanced inter-band Carrier Aggregation of Band 8 and Band 11 | 267d? | 2013-09-09 A | 2014-09-12 A | 100% | 2013-09-09 | 2014-09-12 | 267d? | finish no earlier than 2014-09-12 | R4 | 2136h | 2136h | LTE_CA_B8_B11-Core | PCG-31 | SoftBank Mobile | kenichi.kihara@g.softbank.co.jp | Rel-12 | RP-61 | Issam | CA | LTE_CA_B8_B11-Core | RP-141084 |
| 1982 | 460.50.2 | Perf. part: LTE Advanced inter-band Carrier Aggregation of Band 8 and Band 11 | 267d? | 2013-09-09 A | 2014-09-12 A | 100% | 2013-09-09 | 2014-09-12 | 267d? | finish no earlier than 2014-09-12 | R4 | 2136h | 2136h | LTE_CA_B8_B11-Perf | PCG-31 | SoftBank Mobile | kenichi.kihara@g.softbank.co.jp | Rel-12 | RP-61 | Issam | CA | LTE_CA_B8_B11-Perf | RP-141084 |
| 1983 | 460.51 | **LTE Advanced inter-band Carrier Aggregation of Band 5 and Band 7** | 62d? | 2013-09-09 A | 2013-12-02 A | 100% | 2013-09-09 | 2013-12-02 | 62d? |  | R4 | 1488h | 1488h | LTE_CA_B5_B7 | PCG-31 | LG Uplus | Yeonsang KOO (yskoo@lguplus.co.kr) | Rel-12 | RP-61 | Issam | CA | LTE_CA_B5_B7 |  |
| 1984 | 460.51.1 | Core part: LTE Advanced inter-band Carrier Aggregation of Band 5 and Band 7 | 62d? | 2013-09-09 A | 2013-12-02 A | 100% | 2013-09-09 | 2013-12-02 | 62d? | finish no earlier than 2013-12-02 | R4 | 496h | 496h | LTE_CA_B5_B7-Core | PCG-31 | LG Uplus | Yeonsang KOO (yskoo@lguplus.co.kr) | Rel-12 | RP-61 | Issam | CA | LTE_CA_B5_B7-Core | RP-131541 |
| 1985 | 460.51.2 | Perf. part: LTE Advanced inter-band Carrier Aggregation of Band 5 and Band 7 | 62d? | 2013-09-09 A | 2013-12-02 A | 100% | 2013-09-09 | 2013-12-02 | 62d? | finish no earlier than 2013-12-02 | R4 | 496h | 496h | LTE_CA_B5_B7-Perf | PCG-31 | LG Uplus | Yeonsang KOO (yskoo@lguplus.co.kr) | Rel-12 | RP-61 | Issam | CA | LTE_CA_B5_B7-Perf | RP-131542 |

Notes:
- 1962: Inter-band CA 3DL / Impacted TSs and TRs: LTE
- 1963: RP#65 completed. Updated RP-131684=>RP-141434 / Impacted TSs and TRs: 36.101, 36.104, 36.133, new generic TR 36.853 (3 Band CA with 1UL)
- 1964: RP#65 completed / Impacted TSs and TRs: 36.101, 36.133, 36.141, 36.307
- 1965: Inter-band CA 3DL / Impacted TSs and TRs: LTE
- 1966: RP#65 completed. Updated WID RP-131682=>RP-141435 / Impacted TSs and TRs: 36.101, 36.104, 36.133, new generic TR 36.853 (3 Band CA with 1UL)
- 1967: RP#65 completed / Impacted TSs and TRs: 36.101, 36.133, 36.141, 36.307
- 1968: Inter-band CA 3DL / Impacted TSs and TRs: LTE
- 1969: RP#65 completed. Updated WID RP-131683=>RP-141433 / Impacted TSs and TRs: 36.101, 36.104, 36.133, new generic TR 36.853 (3 Band CA with 1UL)
- 1970: RP#65 completed / Impacted TSs and TRs: 36.101, 36.133, 36.141, 36.307
- 1971: Inter-band 1UL/2DL / Impacted TSs and TRs: LTE
- 1972: RP#62 completed / Impacted TSs and TRs: 36.101, 36.104, 36.307
- 1973: RP#62 completed / Impacted TSs and TRs: 36.141
- 1974: Inter-band 1UL/2DL / Impacted TSs and TRs: LTE
- 1975: RP#62 completed / Impacted TSs and TRs: 36.101, 36.104, 36.133, new generic TR 36.851
- 1976: RP#62 completed / Impacted TSs and TRs: 36.141, 36.307
- 1977: Inter-band CA 2DL / Impacted TSs and TRs: LTE
- 1978: RP#64 completed / Impacted TSs and TRs: 36.101, 36.104, new generic TR 36.851
- 1979: RP#64 completed / Impacted TSs and TRs: 36.141, 36.307
- 1980: Inter-band CA 2DL / Impacted TSs and TRs: LTE
- 1981: RP#65 completed / Impacted TSs and TRs: 36.101, 36.104, new generic TR 36.851
- 1982: RP#65 completed / Impacted TSs and TRs: 36.141, 36.307
- 1983: Inter-band 1UL/2DL / Impacted TSs and TRs: LTE
- 1984: RP#62 completed / Impacted TSs and TRs: 36.101, 36.104, 36.133, new generic TR 36.851
- 1985: RP#62 completed / Impacted TSs and TRs: 36.141, 36.307

| ID | WBS | Task | Duration | Start | Finish | Complete | Baseline start | Baseline finish | Baseline duration | Constraint | Resources | Work | Actual work | Acronym | PCG approved | Impacted TSs and TRs | WI rapporteur name | WI rapporteur e-mail | Release | TSG approved | MCC resp | Special Focus Doc | Acronym_3GU_Export | Status Report |
| --- | --- | --- | --- | --- | --- | --- | --- | --- | --- | --- | --- | --- | --- | --- | --- | --- | --- | --- | --- | --- | --- | --- | --- | --- |
| 1986 | 460.52 | **LTE Advanced intra-band contiguous Carrier Aggregation in Band 41 for 3DL** | 400d? | 2013-09-09 A | 2015-03-15 A | 100% | 2013-09-09 | 2014-09-12 | 267d? |  | R4 | 8512h | 8512h | LTE_CA_C_B41_3DL | PCG-31 | LTE | Alcatel-Lucent | man-hung.ng@alcatel-lucent.com | Rel-12 | RP-61 | Issam | CA | LTE_CA_C_B41_3DL |  |
| 1987 | 460.52.1 | Core part: LTE Advanced intra-band contiguous Carrier Aggregation in Band 41 for 3DL | 267d? | 2013-09-09 A | 2014-09-12 A | 100% | 2013-09-09 | 2014-09-12 | 267d? | finish no earlier than 2014-09-12 | R4 | 2136h | 2136h | LTE_CA_C_B41_3DL-Core | PCG-31 | 36.101, 36.104, 36.133, 36.307, New TR 36.833-5-41 | Alcatel-Lucent | man-hung.ng@alcatel-lucent.com | Rel-12 | RP-61 | Issam | CA | LTE_CA_C_B41_3DL-Core | RP-141084 |
| 1988 | 460.52.2 | Perf. part: LTE Advanced intra-band contiguous Carrier Aggregation in Band 41 for 3DL | 397d? | 2013-09-09 A | 2015-03-15 A | 100% | 2013-09-09 | 2014-09-12 | 267d? | finish no earlier than 2015-03-15 | R4 | 3176h | 3176h | LTE_CA_C_B41_3DL-Perf | PCG-31 | 36.141 | Alcatel-Lucent | man-hung.ng@alcatel-lucent.com | Rel-12 | RP-61 | Issam | CA | LTE_CA_C_B41_3DL-Perf | RP-150013 |
| 1989 | 460.53 | **LTE Advanced intra-band non-contiguous Carrier Aggregation in Band 2** | 202d? | 2013-09-09 A | 2014-06-13 A | 100% | 2013-09-09 | 2014-06-13 | 202d? |  | R4 | 4840h | 4840h | LTE_CA_NC_B2 | PCG-31 | LTE | Ericsson | imadur.rahman@ericsson.com | Rel-12 | RP-61 | Issam | CA | LTE_CA_NC_B2 |  |
| 1990 | 460.53.1 | Core part: LTE Advanced intra-band non-contiguous Carrier Aggregation in Band 2 | 202d? | 2013-09-09 A | 2014-06-13 A | 100% | 2013-09-09 | 2014-06-13 | 202d? | finish no earlier than 2014-06-13 | R4 | 1616h | 1616h | LTE_CA_NC_B2-Core | PCG-31 | 36.101, 36.104, 36.133, New TR 36.833-2-02 | Ericsson | imadur.rahman@ericsson.com | Rel-12 | RP-61 | Issam | CA | LTE_CA_NC_B2-Core | RP-140569 |
| 1991 | 460.53.2 | Perf. part: LTE Advanced intra-band non-contiguous Carrier Aggregation in Band 2 | 201d? | 2013-09-10 A | 2014-06-13 A | 100% | 2013-09-10 | 2014-06-13 | 201d? | finish no earlier than 2014-06-13 | R4 | 1608h | 1608h | LTE_CA_NC_B2-Perf | PCG-31 | 36.141, 36.307 | Ericsson | imadur.rahman@ericsson.com | Rel-12 | RP-61 | Issam | CA | LTE_CA_NC_B2-Perf | RP-140569 |
| 1992 | 460.54 | **LTE Advanced inter-band Carrier Aggregation of Band 1 and Band 3** | 202d? | 2013-12-09 A | 2014-09-12 A | 100% | 2013-12-09 | 2014-09-12 | 201d? |  | R4 | 4832h | 4832h | LTE_CA_B1_B3 | PCG-32 | LTE | China Unicom | Hao Chen (chenhao49@chinaunicom.cn) | Rel-12 | RP-62 | Issam | CA | LTE_CA_B1_B3 |  |
| 1993 | 460.54.1 | Core part: LTE Advanced inter-band Carrier Aggregation of Band 1 and Band 3 | 201d? | 2013-12-09 A | 2014-09-12 A | 100% | 2013-12-09 | 2014-09-12 | 201d? | finish no earlier than 2014-09-12 | R4 | 1608h | 1608h | LTE_CA_B1_B3-Core | PCG-32 | 36.101, 36.104, 36.133, new generic TR 36.851 | China Unicom | Hao Chen (chenhao49@chinaunicom.cn) | Rel-12 | RP-62 | Issam | CA | LTE_CA_B1_B3-Core | RP-141084 |
| 1994 | 460.54.2 | Perf. part: LTE Advanced inter-band Carrier Aggregation of Band 1 and Band 3 | 201d? | 2013-12-09 A | 2014-09-12 A | 100% | 2013-12-09 | 2014-09-12 | 201d? | finish no earlier than 2014-09-12 | R4 | 1608h | 1608h | LTE_CA_B1_B3-Perf | PCG-32 | 36.141, 36.307 | China Unicom | Hao Chen (chenhao49@chinaunicom.cn) | Rel-12 | RP-62 | Issam | CA | LTE_CA_B1_B3-Perf | RP-141084 |
| 1995 | 460.55 | **LTE Advanced inter-band Carrier Aggregation of Band 1 and Band 28** | 270d? | 2013-12-09 A | 2014-12-15 A | 100% | 2013-12-09 | 2014-09-12 | 201d? |  | R4 | 6432h | 6432h | LTE_CA_B1_B28 | PCG-32 | LTE | KDDI | Masaaki Obara (ms-obara@kddi.com) | Rel-12 | RP-62 | Issam | CA | LTE_CA_B1_B28 |  |
| 1996 | 460.55.1 | Core part: LTE Advanced inter-band Carrier Aggregation of Band 1 and Band 28 | 267d? | 2013-12-09 A | 2014-12-15 A | 100% | 2013-12-09 | 2014-09-12 | 201d? | finish no earlier than 2014-12-15 | R4 | 2136h | 2136h | LTE_CA_B1_B28-Core | PCG-32 | 36.101, 36.104, 36.133, 36.307, new generic TR 36.851 | KDDI | Masaaki Obara (ms-obara@kddi.com) | Rel-12 | RP-62 | Issam | CA | LTE_CA_B1_B28-Core | RP-141732 |
| 1997 | 460.55.2 | Perf. part: LTE Advanced inter-band Carrier Aggregation of Band 1 and Band 28 | 267d? | 2013-12-12 A | 2014-12-15 A | 100% | 2013-12-09 | 2014-09-12 | 201d? | finish no earlier than 2014-12-15 | R4 | 2136h | 2136h | LTE_CA_B1_B28-Perf | PCG-32 | 36.133, 36.141 | KDDI | Masaaki Obara (ms-obara@kddi.com) | Rel-12 | RP-62 | Issam | CA | LTE_CA_B1_B28-Perf | RP-141732 |
| 1998 | 460.56 | **LTE Advanced inter-band Carrier Aggregation of Band 2 and Band 4 - Additional bandwidth combination set** | 65d? | 2013-12-09 A | 2014-03-06 A | 100% | 2013-12-09 | 2014-03-06 | 65d? |  | R4 | 1560h | 1560h | LTE_CA_B2_B4_BWset | PCG-32 | LTE | T-Mobile USA | nelson.ueng@t-mobile.com | Rel-12 | RP-62 | Issam | CA | LTE_CA_B2_B4_BWset |  |
| 1999 | 460.56.1 | Core part: LTE Advanced inter-band Carrier Aggregation of Band 2 and Band 4 - Additional bandwidth combination set | 65d? | 2013-12-09 A | 2014-03-06 A | 100% | 2013-12-09 | 2014-03-06 | 65d? | finish no earlier than 2014-03-06 | R4 | 520h | 520h | LTE_CA_B2_B4_BWset-Core | PCG-32 | 36.101, new generic TR 36.851 | T-Mobile USA | nelson.ueng@t-mobile.com | Rel-12 | RP-62 | Issam | CA | LTE_CA_B2_B4_BWset-Core | RP-140428 |
| 2000 | 460.56.2 | Perf. part: LTE Advanced inter-band Carrier Aggregation of Band 2 and Band 4 - Additional bandwidth combination set | 65d? | 2013-12-09 A | 2014-03-06 A | 100% | 2013-12-09 | 2014-03-06 | 65d? | finish no earlier than 2014-03-06 | R4 | 520h | 520h | LTE_CA_B2_B4_BWset-Perf | PCG-32 | 36.307 | T-Mobile USA | nelson.ueng@t-mobile.com | Rel-12 | RP-62 | Issam | CA | LTE_CA_B2_B4_BWset-Perf | RP-140428 |
| 2001 | 460.57 | **LTE Advanced inter-band Carrier Aggregation of Band 4 and Band 27** | 136d? | 2013-12-09 A | 2014-06-13 A | 100% | 2013-12-09 | 2014-06-13 | 136d? |  | R4 | 3264h | 3264h | LTE_CA_B4_B27 | PCG-32 | LTE | NII Holdings | bill.shvodian@nii.com | Rel-12 | RP-62 | Issam | CA | LTE_CA_B4_B27 |  |
| 2002 | 460.57.1 | Core part: LTE Advanced inter-band Carrier Aggregation of Band 4 and Band 27 | 136d? | 2013-12-09 A | 2014-06-13 A | 100% | 2013-12-09 | 2014-06-13 | 136d? | finish no earlier than 2014-06-13 | R4 | 1088h | 1088h | LTE_CA_B4_B27-Core | PCG-32 | 36.101, 36.104, 36.133, new generic TR 36.851 | NII Holdings | bill.shvodian@nii.com | Rel-12 | RP-62 | Issam | CA | LTE_CA_B4_B27-Core | RP-140569 |
| 2003 | 460.57.2 | Perf. part: LTE Advanced inter-band Carrier Aggregation of Band 4 and Band 27 | 136d? | 2013-12-09 A | 2014-06-13 A | 100% | 2013-12-09 | 2014-06-13 | 136d? | finish no earlier than 2014-06-13 | R4 | 1088h | 1088h | LTE_CA_B4_B27-Perf | PCG-32 | 36.141, 36.307 | NII Holdings | bill.shvodian@nii.com | Rel-12 | RP-62 | Issam | CA | LTE_CA_B4_B27-Perf | RP-140569 |
| 2004 | 460.58 | **LTE Advanced inter-band Carrier Aggregation of Band 3 and Band 27** | 65d? | 2013-12-09 A | 2014-03-06 A | 100% | 2013-12-09 | 2014-03-06 | 65d? |  | R4 | 1560h | 1560h | LTE_CA_B3_B27 | PCG-32 | LTE | KT | Chungwoo HWANG (cwhwang@kt.com) | Rel-12 | RP-62 | Issam | CA | LTE_CA_B3_B27 | RP-140428 |
| 2005 | 460.58.1 | Core part: LTE Advanced inter-band Carrier Aggregation of Band 3 and Band 27 | 65d? | 2013-12-09 A | 2014-03-06 A | 100% | 2013-12-09 | 2014-03-06 | 65d? | finish no earlier than 2014-03-06 | R4 | 520h | 520h | LTE_CA_B3_B27-Core | PCG-32 | 36.101, 36.104, 36.133, 36.307, New generic TR 36.851 | KT | Chungwoo HWANG (cwhwang@kt.com) | Rel-12 | RP-62 | Issam | CA | LTE_CA_B3_B27-Core | RP-140428 |
| 2006 | 460.58.2 | Perf. part: LTE Advanced inter-band Carrier Aggregation of Band 3 and Band 27 | 65d? | 2013-12-09 A | 2014-03-06 A | 100% | 2013-12-09 | 2014-03-06 | 65d? | finish no earlier than 2014-03-06 | R4 | 520h | 520h | LTE_CA_B3_B27-Perf | PCG-32 | 36.101, 36.104, 36.133, 36.141 | KT | Chungwoo HWANG (cwhwang@kt.com) | Rel-12 | RP-62 | Issam | CA | LTE_CA_B3_B27-Perf | RP-140428 |
| 2007 | 460.59 | **LTE Advanced inter-band Carrier Aggregation in Band 8 and Band 20 - Additional channel bandwidth** | 65d? | 2013-12-09 A | 2014-03-06 A | 100% | 2013-12-09 | 2014-03-06 | 65d? |  | R4 | 1560h | 1560h | LTE_CA_B8_B20_BW | PCG-32 | LTE | Vodafone | luis.anaya@vodafone.com | Rel-12 | RP-62 | Issam | CA | LTE_CA_B8_B20_BW | RP-140428 |
| 2008 | 460.59.1 | Core part: LTE Advanced inter-band Carrier Aggregation in Band 8 and Band 20 - Additional channel bandwidth | 65d? | 2013-12-09 A | 2014-03-06 A | 100% | 2013-12-09 | 2014-03-06 | 65d? | finish no earlier than 2014-03-06 | R4 | 520h | 520h | LTE_CA_B8_B20_BW-Core | PCG-32 | 36.101, 36.104, 36.307 | Vodafone | luis.anaya@vodafone.com | Rel-12 | RP-62 | Issam | CA | LTE_CA_B8_B20_BW-Core | RP-140428 |
| 2009 | 460.59.2 | Perf. part: LTE Advanced inter-band Carrier Aggregation in Band 8 and Band 20 - Additional channel bandwidth | 65d? | 2013-12-09 A | 2014-03-06 A | 100% | 2013-12-09 | 2014-03-06 | 65d? | finish no earlier than 2014-03-06 | R4 | 520h | 520h | LTE_CA_B8_B20_BW-Perf | PCG-32 | 36.141 | Vodafone | luis.anaya@vodafone.com | Rel-12 | RP-62 | Issam | CA | LTE_CA_B8_B20_BW-Perf | RP-140428 |

Notes:
- 1986: Intra-band contig. CA 3DL
- 1987: RP#65 completed
- 1988: ; WID: RP-142043->RP-142017; Stat Rep: RP-141084->RP-141732 1st Apr 15: Compl:70%->100% 1st Apr 15: Stat Rep: RP-141732->RP-150013
- 1989: Intra-band non-contig. CA 2DL
- 1990: RP#64 completed. TR 36.833-2-02v100 for 1-step Approval
- 1991: RP#64 completed
- 1992: Inter-band CA 2DL
- 1993: RP#65 completed
- 1994: RP#65 completed
- 1995: Inter-band CA 2DL
- 1996: ; WID: RP-142043->RP-141803; Stat Rep: RP-141084->RP-141732
- 1997: ; WID: RP-142043->RP-141803; Stat Rep: RP-141084->RP-141732
- 1998: Inter-band 2DL
- 1999: RP#63 completed
- 2000: RP#63 completed
- 2001: Inter-band CA 2DL
- 2002: RP#64 completed
- 2003: RP#64 completed
- 2004: Inter-band CA 2DL/1UL
- 2005: RP#63 completed. Updated WID RP-131752=>RP-140119
- 2006: RP#63 completed. Updated WID RP-131752=>RP-140119
- 2007: Inter-band 2DL
- 2008: RP#63 completed
- 2009: RP#63 completed

| ID | WBS | Task | Duration | Start | Finish | Complete | Remaining | Baseline start | Baseline finish | Baseline duration | Total slack | Constraint | Resources | Work | Actual work | Acronym | PCG approved | WI rapporteur name | WI rapporteur e-mail | Release | TSG approved | MCC resp | Special Focus Doc | Acronym_3GU_Export | Status Report |
| --- | --- | --- | --- | --- | --- | --- | --- | --- | --- | --- | --- | --- | --- | --- | --- | --- | --- | --- | --- | --- | --- | --- | --- | --- | --- |
| 2010 | 460.60 | **LTE Advanced 3 Band Carrier Aggregation (3DL/1UL) for Band 1, Band 3 and Band 8** | 202d? | 2013-12-09 A | 2014-09-12 A | 100% |  | 2013-12-09 | 2014-09-12 | 201d? |  |  | R4 | 4832h | 4832h | LTE_CA_B1_B3_B8 | PCG-32 | KT | Ilwhan Kim (ilwhan.kim@kt.com) | Rel-12 | RP-62 | Issam | CA | LTE_CA_B1_B3_B8 |  |
| 2011 | 460.60.1 | Core part: LTE Advanced 3 Band Carrier Aggregation (3DL/1UL) for Band 1, Band 3 and Band 8 | 201d? | 2013-12-09 A | 2014-09-12 A | 100% |  | 2013-12-09 | 2014-09-12 | 201d? |  | finish no earlier than 2014-09-12 | R4 | 1608h | 1608h | LTE_CA_B1_B3_B8-Core | PCG-32 | KT | Ilwhan Kim (ilwhan.kim@kt.com) | Rel-12 | RP-62 | Issam | CA | LTE_CA_B1_B3_B8-Core | RP-141084 |
| 2012 | 460.60.2 | Perf. part: LTE Advanced 3 Band Carrier Aggregation (3DL/1UL) for Band 1, Band 3 and Band 8 | 201d? | 2013-12-09 A | 2014-09-12 A | 100% |  | 2013-12-09 | 2014-09-12 | 201d? |  | finish no earlier than 2014-09-12 | R4 | 1608h | 1608h | LTE_CA_B1_B3_B8-Perf | PCG-32 | KT | Ilwhan Kim (ilwhan.kim@kt.com) | Rel-12 | RP-62 | Issam | CA | LTE_CA_B1_B3_B8-Perf | RP-141084 |
| 2013 | 460.61 | **LTE Advanced 3 Band Carrier Aggregation (3DL/1UL) for Band 1, Band 5 and Band 7** | 202d? | 2013-12-09 A | 2014-09-12 A | 100% |  | 2013-12-09 | 2014-09-12 | 201d? |  |  | R4 | 4832h | 4832h | LTE_CA_B1_B5_B7 | PCG-32 | LG Uplus | Yeonsang KOO (yskoo@lguplus.co.kr) | Rel-12 | RP-62 | Issam | CA | LTE_CA_B1_B5_B7 |  |
| 2014 | 460.61.1 | Core part: LTE Advanced 3 Band Carrier Aggregation (3DL/1UL) for Band 1, Band 5 and Band 7 | 201d? | 2013-12-09 A | 2014-09-12 A | 100% |  | 2013-12-09 | 2014-09-12 | 201d? |  | finish no earlier than 2014-09-12 | R4 | 1608h | 1608h | LTE_CA_B1_B5_B7-Core | PCG-32 | LG Uplus | Yeonsang KOO (yskoo@lguplus.co.kr) | Rel-12 | RP-62 | Issam | CA | LTE_CA_B1_B5_B7-Core | RP-141084 |
| 2015 | 460.61.2 | Perf. part: LTE Advanced 3 Band Carrier Aggregation (3DL/1UL) for Band 1, Band 5 and Band 7 | 201d? | 2013-12-09 A | 2014-09-12 A | 100% |  | 2013-12-09 | 2014-09-12 | 201d? |  | finish no earlier than 2014-09-12 | R4 | 1608h | 1608h | LTE_CA_B1_B5_B7-Perf | PCG-32 | LG Uplus | Yeonsang KOO (yskoo@lguplus.co.kr) | Rel-12 | RP-62 | Issam | CA | LTE_CA_B1_B5_B7-Perf | RP-141084 |
| 2016 | 460.62 | **LTE Advanced 3 Band Carrier Aggregation (3DL/1UL) for Band 2, Band 4 and Band 5** | 202d? | 2013-12-09 A | 2014-09-12 A | 100% |  | 2013-12-09 | 2014-09-12 | 201d? |  |  | R4 | 4832h | 4832h | LTE_CA_B2_B4_B5 | PCG-32 | U.S. Cellular | sebastian.thalanany@uscellular.com | Rel-12 | RP-62 | Issam | CA | LTE_CA_B2_B4_B5 |  |
| 2017 | 460.62.1 | Core part: LTE Advanced 3 Band Carrier Aggregation (3DL/1UL) for Band 2, Band 4 and Band 5 | 201d? | 2013-12-09 A | 2014-09-12 A | 100% |  | 2013-12-09 | 2014-09-12 | 201d? |  | finish no earlier than 2014-09-12 | R4 | 1608h | 1608h | LTE_CA_B2_B4_B5-Core | PCG-32 | U.S. Cellular | sebastian.thalanany@uscellular.com | Rel-12 | RP-62 | Issam | CA | LTE_CA_B2_B4_B5-Core | RP-141084 |
| 2018 | 460.62.2 | Perf. part: LTE Advanced 3 Band Carrier Aggregation (3DL/1UL) for Band 2, Band 4 and Band 5 | 201d? | 2013-12-09 A | 2014-09-12 A | 100% |  | 2013-12-09 | 2014-09-12 | 201d? |  | finish no earlier than 2014-09-12 | R4 | 1608h | 1608h | LTE_CA_B2_B4_B5-Perf | PCG-32 | U.S. Cellular | sebastian.thalanany@uscellular.com | Rel-12 | RP-62 | Issam | CA | LTE_CA_B2_B4_B5-Perf | RP-141084 |
| 2019 | 460.63 | **LTE Advanced 3 Band Carrier Aggregation (3DL/1UL) for Band 2, Band 4 and Band 12** | 268d? | 2013-12-09 A | 2014-12-11 | 99% | 3.04d? | 2013-12-09 | 2014-09-12 | 201d? | 873d |  | R4 | 5872h | 5204.78h | LTE_CA_B2_B4_B12 | PCG-32 | U.S. Cellular | sebastian.thalanany@uscellular.com | Rel-12 | RP-62 | Issam | CA | LTE_CA_B2_B4_B12 |  |
| 2020 | 460.63.1 | Core part: LTE Advanced 3 Band Carrier Aggregation (3DL/1UL) for Band 2, Band 4 and Band 12 | 201d? | 2013-12-09 A | 2014-09-12 A | 100% |  | 2013-12-09 | 2014-09-12 | 201d? |  | finish no earlier than 2014-09-12 | R4 | 1608h | 1608h | LTE_CA_B2_B4_B12-Core | PCG-32 | U.S. Cellular | sebastian.thalanany@uscellular.com | Rel-12 | RP-62 | Issam | CA | LTE_CA_B2_B4_B12-Core | RP-141084 |
| 2021 | 460.63.2 | Perf. part: LTE Advanced 3 Band Carrier Aggregation (3DL/1UL) for Band 2, Band 4 and Band 12 | 265d? | 2013-12-09 A | 2014-12-11 | 98% | 5.3d? | 2013-12-09 | 2014-09-12 | 201d? | 873d | finish no earlier than 2014-12-11 | R4 | 2120h | 2077.6h | LTE_CA_B2_B4_B12-Perf | PCG-32 | U.S. Cellular | sebastian.thalanany@uscellular.com | Rel-12 | RP-62 | Issam | CA | LTE_CA_B2_B4_B12-Perf | RP-141084 |
| 2022 | 460.64 | **LTE Advanced 3 Band Carrier Aggregation (3DL/1UL) for Band 2, Band 5 and Band 12** | 202d? | 2013-12-09 A | 2014-09-12 A | 100% |  | 2013-12-09 | 2014-09-12 | 201d? |  |  | R4 | 4832h | 4832h | LTE_CA_B2_B5_B12 | PCG-32 | U.S. Cellular | sebastian.thalanany@uscellular.com | Rel-12 | RP-62 | Issam | CA | LTE_CA_B2_B5_B12 |  |
| 2023 | 460.64.1 | Core part: LTE Advanced 3 Band Carrier Aggregation (3DL/1UL) for Band 2, Band 5 and Band 12 | 201d? | 2013-12-09 A | 2014-09-12 A | 100% |  | 2013-12-09 | 2014-09-12 | 201d? |  | finish no earlier than 2014-09-12 | R4 | 1608h | 1608h | LTE_CA_B2_B5_B12-Core | PCG-32 | U.S. Cellular | sebastian.thalanany@uscellular.com | Rel-12 | RP-62 | Issam | CA | LTE_CA_B2_B5_B12-Core | RP-141084 |
| 2024 | 460.64.2 | Perf. part: LTE Advanced 3 Band Carrier Aggregation (3DL/1UL) for Band 2, Band 5 and Band 12 | 201d? | 2013-12-10 A | 2014-09-12 A | 100% |  | 2013-12-09 | 2014-09-12 | 201d? |  | finish no earlier than 2014-09-12 | R4 | 1608h | 1608h | LTE_CA_B2_B5_B12-Perf | PCG-32 | U.S. Cellular | sebastian.thalanany@uscellular.com | Rel-12 | RP-62 | Issam | CA | LTE_CA_B2_B5_B12-Perf | RP-141084 |
| 2025 | 460.65 | **LTE Advanced 3 Band Carrier Aggregation (3DL/1UL) for Band 2, Band 12 and Band 12** | 202d? | 2013-12-09 A | 2014-09-12 A | 100% |  | 2013-12-09 | 2014-09-12 | 201d? |  |  | R4 | 4832h | 4832h | LTE_CA_B2_B12_B12 | PCG-32 | AT&T | marc.grant@att.com | Rel-12 | RP-62 | Issam | CA | LTE_CA_B2_B12_B12 |  |
| 2026 | 460.65.1 | Core part: LTE Advanced 3 Band Carrier Aggregation (3DL/1UL) for Band 2, Band 12 and Band 12 | 201d? | 2013-12-09 A | 2014-09-12 A | 100% |  | 2013-12-09 | 2014-09-12 | 201d? |  | finish no earlier than 2014-09-12 | R4 | 1608h | 1608h | LTE_CA_B2_B12_B12-Core | PCG-32 | AT&T | marc.grant@att.com | Rel-12 | RP-62 | Issam | CA | LTE_CA_B2_B12_B12-Core | RP-141084 |
| 2027 | 460.65.2 | Perf. part: LTE Advanced 3 Band Carrier Aggregation (3DL/1UL) for Band 2, Band 12 and Band 12 | 201d? | 2013-12-09 A | 2014-09-12 A | 100% |  | 2013-12-09 | 2014-09-12 | 201d? |  | finish no earlier than 2014-09-12 | R4 | 1608h | 1608h | LTE_CA_B2_B12_B12-Perf | PCG-32 | AT&T | marc.grant@att.com | Rel-12 | RP-62 | Issam | CA | LTE_CA_B2_B12_B12-Perf | RP-141084 |
| 2028 | 460.66 | **LTE Advanced 3 Band Carrier Aggregation (3DL/1UL) for Band 2, Band 12 and Band 30** | 202d? | 2013-12-09 A | 2014-09-12 A | 100% |  | 2013-12-09 | 2014-09-12 | 201d? |  |  | R4 | 4832h | 4832h | LTE_CA_B2_B12_B30 | PCG-32 | AT&T | marc.grant@att.com | Rel-12 | RP-62 | Issam | CA | LTE_CA_B2_B12_B30 |  |
| 2029 | 460.66.1 | Core part: LTE Advanced 3 Band Carrier Aggregation (3DL/1UL) for Band 2, Band 12 and Band 30 | 201d? | 2013-12-09 A | 2014-09-12 A | 100% |  | 2013-12-09 | 2014-09-12 | 201d? |  | finish no earlier than 2014-09-12 | R4 | 1608h | 1608h | LTE_CA_B2_B12_B30-Core | PCG-32 | AT&T | marc.grant@att.com | Rel-12 | RP-62 | Issam | CA | LTE_CA_B2_B12_B30-Core | RP-141084 |
| 2030 | 460.66.2 | Perf. part: LTE Advanced 3 Band Carrier Aggregation (3DL/1UL) for Band 2, Band 12 and Band 30 | 201d? | 2013-12-09 A | 2014-09-12 A | 100% |  | 2013-12-09 | 2014-09-12 | 201d? |  | finish no earlier than 2014-09-12 | R4 | 1608h | 1608h | LTE_CA_B2_B12_B30-Perf | PCG-32 | AT&T | marc.grant@att.com | Rel-12 | RP-62 | Issam | CA | LTE_CA_B2_B12_B30-Perf | RP-141084 |
| 2031 | 460.67 | **LTE Advanced 3 Band Carrier Aggregation (3DL/1UL) for Band 3, Band 7 and Band 20** | 202d? | 2013-12-09 A | 2014-09-12 A | 100% |  | 2013-12-09 | 2014-09-12 | 201d? |  |  | R4 | 4832h | 4832h | LTE_CA_B3_B7_B20 | PCG-32 | Vodafone | luis.anaya@vodafone.com | Rel-12 | RP-62 | Issam | CA | LTE_CA_B3_B7_B20 |  |
| 2032 | 460.67.1 | Core part: LTE Advanced 3 Band Carrier Aggregation (3DL/1UL) for Band 3, Band 7 and Band 20 | 201d? | 2013-12-09 A | 2014-09-12 A | 100% |  | 2013-12-09 | 2014-09-12 | 201d? |  | finish no earlier than 2014-09-12 | R4 | 1608h | 1608h | LTE_CA_B3_B7_B20-Core | PCG-32 | Vodafone | luis.anaya@vodafone.com | Rel-12 | RP-62 | Issam | CA | LTE_CA_B3_B7_B20-Core | RP-141084 |
| 2033 | 460.67.2 | Perf. part: LTE Advanced 3 Band Carrier Aggregation (3DL/1UL) for Band 3, Band 7 and Band 20 | 201d? | 2013-12-10 A | 2014-09-12 A | 100% |  | 2013-12-09 | 2014-09-12 | 201d? |  | finish no earlier than 2014-09-12 | R4 | 1608h | 1608h | LTE_CA_B3_B7_B20-Perf | PCG-32 | Vodafone | luis.anaya@vodafone.com | Rel-12 | RP-62 | Issam | CA | LTE_CA_B3_B7_B20-Perf | RP-141084 |

Notes:
- 2010: Inter-band CA 3DL / Impacted TSs and TRs: LTE
- 2011: RP#65 completed. Updated WID RP-131753=>RP-141654 / Impacted TSs and TRs: 36.101, 36.104, 36.133, 36.141, 36.307, new generic TR 36.853 (3 Band CA with 1UL)
- 2012: RP#65 completed / Impacted TSs and TRs: 36.101, 36.104, 36.133, 36.141, 36.307
- 2013: Inter-band CA 3DL / Impacted TSs and TRs: LTE
- 2014: RP#65 completed. Updated WID RP-140209=>RP-141462 / Impacted TSs and TRs: 36.101, 36.104, 36.133, new generic TR 36.853 (3 Band CA with 1UL)
- 2015: RP#65 completed / Impacted TSs and TRs: 36.141, 36.307
- 2016: Inter-band CA 3DL / Impacted TSs and TRs: LTE
- 2017: RP#65 completed / Impacted TSs and TRs: 36.101, 36.104, 36.133, new generic TR 36.853 (3 Band CA with 1UL)
- 2018: RP#65 completed / Impacted TSs and TRs: 36.141, 36.307
- 2019: Inter-band CA 3DL / Impacted TSs and TRs: LTE
- 2020: RP#65 completed / Impacted TSs and TRs: 36.101, 36.104, 36.133, new generic TR 36.853 (3 Band CA with 1UL)
- 2021: RP#65 completion 09/14=>12/14 / Impacted TSs and TRs: 36.141, 36.307
- 2022: Inter-band CA 3DL / Impacted TSs and TRs: LTE
- 2023: RP#65 completed / Impacted TSs and TRs: 36.101, 36.104, 36.133, new generic TR 36.853 (3 Band CA with 1UL)
- 2024: RP#65 completed / Impacted TSs and TRs: 36.141, 36.307
- 2025: Inter-band CA 3DL / Impacted TSs and TRs: LTE
- 2026: RP#65 completed / Impacted TSs and TRs: 36.101, 36.104, 36.133, 36.141, 36.307, new generic TR 36.853
- 2027: RP#65 completed / Impacted TSs and TRs: 36.101, 36.104, 36.133, 36.141, 36.307
- 2028: Inter-band CA 3DL / Impacted TSs and TRs: LTE
- 2029: RP#65 completed. Updated WID RP-131652=>RP-141211. / Impacted TSs and TRs: 36.101, 36.104, 36.133, 36.141, 36.307, new generic TR 36.853 (3 Band CA with 1UL)
- 2030: RP#65 completed / Impacted TSs and TRs: 36.101, 36.104, 36.133, 36.141, 36.307
- 2031: Inter-band CA 3DL / Impacted TSs and TRs: LTE
- 2032: RP#65 completed. Updated WID RP-140244=>RP-141224 / Impacted TSs and TRs: 36.101, 36.104, 36.133, new generic TR 36.853 (3 Band CA with 1UL)
- 2033: RP#65 completed / Impacted TSs and TRs: 36.101, 36.133, 36.141, 36.307

| ID | WBS | Task | Duration | Start | Finish | Complete | Baseline start | Baseline finish | Baseline duration | Constraint | Resources | Work | Actual work | Acronym | PCG approved | WI rapporteur name | WI rapporteur e-mail | Release | TSG approved | MCC resp | Special Focus Doc | Acronym_3GU_Export | Status Report |
| --- | --- | --- | --- | --- | --- | --- | --- | --- | --- | --- | --- | --- | --- | --- | --- | --- | --- | --- | --- | --- | --- | --- | --- |
| 2034 | 460.68 | **LTE Advanced 3 Band Carrier Aggregation (3DL/1UL) for Band 4, Band 5 and Band 12** | 202d? | 2013-12-09 A | 2014-09-12 A | 100% | 2013-12-09 | 2014-09-12 | 201d? |  | R4 | 4832h | 4832h | LTE_CA_B4_B5_B12 | PCG-32 | U.S. Cellular | sebastian.thalanany@uscellular.com | Rel-12 | RP-62 | Issam | CA | LTE_CA_B4_B5_B12 |  |
| 2035 | 460.68.1 | Core part: LTE Advanced 3 Band Carrier Aggregation (3DL/1UL) for Band 4, Band 5 and Band 12 | 201d? | 2013-12-09 A | 2014-09-12 A | 100% | 2013-12-09 | 2014-09-12 | 201d? | finish no earlier than 2014-09-12 | R4 | 1608h | 1608h | LTE_CA_B4_B5_B12-Core | PCG-32 | U.S. Cellular | sebastian.thalanany@uscellular.com | Rel-12 | RP-62 | Issam | CA | LTE_CA_B4_B5_B12-Core | RP-141084 |
| 2036 | 460.68.2 | Perf. part: LTE Advanced 3 Band Carrier Aggregation (3DL/1UL) for Band 4, Band 5 and Band 12 | 201d? | 2013-12-09 A | 2014-09-12 A | 100% | 2013-12-09 | 2014-09-12 | 201d? | finish no earlier than 2014-09-12 | R4 | 1608h | 1608h | LTE_CA_B4_B5_B12-Perf | PCG-32 | U.S. Cellular | sebastian.thalanany@uscellular.com | Rel-12 | RP-62 | Issam | CA | LTE_CA_B4_B5_B12-Perf | RP-141084 |
| 2037 | 460.69 | **LTE Advanced 3 Band Carrier Aggregation (3DL/1UL) for Band 4, Band 12 and Band 12** | 202d? | 2013-12-09 A | 2014-09-12 A | 100% | 2013-12-09 | 2014-09-12 | 201d? |  | R4 | 4832h | 4832h | LTE_CA_B4_B12_B12 | PCG-32 | AT&T | marc.grant@att.com | Rel-12 | RP-62 | Issam | CA | LTE_CA_B4_B12_B12 |  |
| 2038 | 460.69.1 | Core part: LTE Advanced 3 Band Carrier Aggregation (3DL/1UL) for Band 4, Band 12 and Band 12 | 201d? | 2013-12-09 A | 2014-09-12 A | 100% | 2013-12-09 | 2014-09-12 | 201d? | finish no earlier than 2014-09-12 | R4 | 1608h | 1608h | LTE_CA_B4_B12_B12-Core | PCG-32 | AT&T | marc.grant@att.com | Rel-12 | RP-62 | Issam | CA | LTE_CA_B4_B12_B12-Core | RP-141084 |
| 2039 | 460.69.2 | Perf. part: LTE Advanced 3 Band Carrier Aggregation (3DL/1UL) for Band 4, Band 12 and Band 12 | 201d? | 2013-12-09 A | 2014-09-12 A | 100% | 2013-12-09 | 2014-09-12 | 201d? | finish no earlier than 2014-09-12 | R4 | 1608h | 1608h | LTE_CA_B4_B12_B12-Perf | PCG-32 | AT&T | marc.grant@att.com | Rel-12 | RP-62 | Issam | CA | LTE_CA_B4_B12_B12-Perf | RP-141084 |
| 2040 | 460.70 | **LTE Advanced 3 Band Carrier Aggregation (3DL/1UL) for Band 4, Band 12 and Band 30** | 202d? | 2013-12-09 A | 2014-09-12 A | 100% | 2013-12-09 | 2014-09-12 | 201d? |  | R4 | 4832h | 4832h | LTE_CA_B4_B12_B30 | PCG-32 | AT&T | marc.grant@att.com | Rel-12 | RP-62 | Issam | CA | LTE_CA_B4_B12_B30 |  |
| 2041 | 460.70.1 | Core part: LTE Advanced 3 Band Carrier Aggregation (3DL/1UL) for Band 4, Band 12 and Band 30 | 201d? | 2013-12-09 A | 2014-09-12 A | 100% | 2013-12-09 | 2014-09-12 | 201d? | finish no earlier than 2014-09-12 | R4 | 1608h | 1608h | LTE_CA_B4_B12_B30-Core | PCG-32 | AT&T | marc.grant@att.com | Rel-12 | RP-62 | Issam | CA | LTE_CA_B4_B12_B30-Core | RP-141084 |
| 2042 | 460.70.2 | Perf. part: LTE Advanced 3 Band Carrier Aggregation (3DL/1UL) for Band 4, Band 12 and Band 30 | 201d? | 2013-12-09 A | 2014-09-12 A | 100% | 2013-12-09 | 2014-09-12 | 201d? | finish no earlier than 2014-09-12 | R4 | 1608h | 1608h | LTE_CA_B4_B12_B30-Perf | PCG-32 | AT&T | marc.grant@att.com | Rel-12 | RP-62 | Issam | CA | LTE_CA_B4_B12_B30-Perf | RP-141084 |
| 2043 | 460.71 | **LTE Advanced intra-band contiguous Carrier Aggregation in Band 42** | 136d? | 2013-12-09 A | 2014-06-13 A | 100% | 2013-12-09 | 2014-06-13 | 136d? |  | R4 | 3264h | 3264h | LTE_CA_C_B42 | PCG-32 | CATT | Yuexia Song (songyuexia@catt.cn) | Rel-12 | RP-62 | Issam | CA | LTE_CA_C_B42 |  |
| 2044 | 460.71.1 | Core part: LTE Advanced intra-band contiguous Carrier Aggregation in Band 42 | 136d? | 2013-12-09 A | 2014-06-13 A | 100% | 2013-12-09 | 2014-06-13 | 136d? | finish no earlier than 2014-06-13 | R4 | 1088h | 1088h | LTE_CA_C_B42-Core | PCG-32 | CATT | Yuexia Song (songyuexia@catt.cn) | Rel-12 | RP-62 | Issam | CA | LTE_CA_C_B42-Core | RP-140569 |
| 2045 | 460.71.2 | Perf. part: LTE Advanced intra-band contiguous Carrier Aggregation in Band 42 | 136d? | 2013-12-09 A | 2014-06-13 A | 100% | 2013-12-09 | 2014-06-13 | 136d? | finish no earlier than 2014-06-13 | R4 | 1088h | 1088h | LTE_CA_C_B42-Perf | PCG-32 | CATT | Yuexia Song (songyuexia@catt.cn) | Rel-12 | RP-62 | Issam | CA | LTE_CA_C_B42-Perf | RP-140569 |
| 2046 | 460.72 | **LTE Advanced intra-band contiguous Carrier Aggregation in Band 7 - Additional bandwidth combinations** | 136d? | 2013-12-09 A | 2014-06-13 A | 100% | 2013-12-09 | 2014-06-13 | 136d? |  | R4 | 3264h | 3264h | LTE_CA_C_B7_BW | PCG-32 | Orange | Olfa BEN HADDADA | Rel-12 | RP-62 | Issam | CA | LTE_CA_C_B7_BW |  |
| 2047 | 460.72.1 | Core part: LTE Advanced intra-band contiguous Carrier Aggregation in Band 7 - Additional bandwidth combinations | 136d? | 2013-12-09 A | 2014-06-13 A | 100% | 2013-12-09 | 2014-06-13 | 136d? | finish no earlier than 2014-06-13 | R4 | 1088h | 1088h | LTE_CA_C_B7_BW-Core | PCG-32 | Orange | Olfa BEN HADDADA | Rel-12 | RP-62 | Issam | CA | LTE_CA_C_B7_BW-Core | RP-140569 |
| 2048 | 460.72.2 | Perf. part: LTE Advanced intra-band contiguous Carrier Aggregation in Band 7 - Additional bandwidth combinations | 136d? | 2013-12-09 A | 2014-06-13 A | 100% | 2013-12-09 | 2014-06-13 | 136d? | finish no earlier than 2014-06-13 | R4 | 1088h | 1088h | LTE_CA_C_B7_BW-Perf | PCG-32 | Orange | Olfa BEN HADDADA | Rel-12 | RP-62 | Issam | CA | LTE_CA_C_B7_BW-Perf | RP-140569 |
| 2049 | 460.73 | **LTE Advanced intra-band non-contiguous Carrier Aggregation in Band 41 for 3 DL** | 334d? | 2013-12-09 A | 2015-03-15 A | 100% | 2013-12-09 | 2014-09-12 | 200d? |  | R4 | 6920h | 6920h | LTE_CA_NC_B41_3DL | PCG-32 | Sprint, Alcatel-Lucent | man-hung.ng@alcatel-lucent.com | Rel-12 | RP-62 | Issam | CA | LTE_CA_NC_B41_3DL |  |
| 2050 | 460.73.1 | Core part: LTE Advanced intra-band non-contiguous Carrier Aggregation in Band 41 for 3 DL | 200d? | 2013-12-09 A | 2014-09-11 A | 100% | 2013-12-09 | 2014-09-12 | 200d? | finish no earlier than 2014-09-12 | R4 | 1600h | 1600h | LTE_CA_NC_B41_3DL-Core | PCG-32 | Sprint, Alcatel-Lucent | man-hung.ng@alcatel-lucent.com | Rel-12 | RP-62 | Issam | CA | LTE_CA_NC_B41_3DL-Core | RP-141084 |
| 2051 | 460.73.2 | Perf. part: LTE Advanced intra-band non-contiguous Carrier Aggregation in Band 41 for 3 DL | 331d? | 2013-12-09 A | 2015-03-15 A | 100% | 2013-12-09 | 2014-09-12 | 200d? | finish no earlier than 2015-03-15 | R4 | 2648h | 2648h | LTE_CA_NC_B41_3DL-Perf | PCG-32 | Sprint, Alcatel-Lucent | man-hung.ng@alcatel-lucent.com | Rel-12 | RP-62 | Issam | CA | LTE_CA_NC_B41_3DL-Perf | RP-150013 |
| 2052 | 460.74 | **LTE Advanced intra-band non-contiguous Carrier Aggregation in Band 42** | 136d? | 2013-12-09 A | 2014-06-13 A | 100% | 2013-12-09 | 2014-06-13 | 136d? |  | R4 | 3264h | 3264h | LTE_CA_NC_B42 | PCG-32 | Huawei | Liu Liehai (liuliehai@huawei.com) | Rel-12 | RP-62 | Issam | CA | LTE_CA_NC_B42 |  |
| 2053 | 460.74.1 | Core part: LTE Advanced intra-band non-contiguous Carrier Aggregation in Band 42 | 136d? | 2013-12-09 A | 2014-06-13 A | 100% | 2013-12-09 | 2014-06-13 | 136d? | finish no earlier than 2014-06-13 | R4 | 1088h | 1088h | LTE_CA_NC_B42-Core | PCG-32 | Huawei | Liu Liehai (liuliehai@huawei.com) | Rel-12 | RP-62 | Issam | CA | LTE_CA_NC_B42-Core | RP-140569 |
| 2054 | 460.74.2 | Perf. part: LTE Advanced intra-band non-contiguous Carrier Aggregation in Band 42 | 136d? | 2013-12-09 A | 2014-06-13 A | 100% | 2013-12-09 | 2014-06-13 | 136d? | finish no earlier than 2014-06-13 | R4 | 1088h | 1088h | LTE_CA_NC_B42-Perf | PCG-32 | Huawei | Liu Liehai (liuliehai@huawei.com) | Rel-12 | RP-62 | Issam | CA | LTE_CA_NC_B42-Perf | RP-140569 |
| 2055 | 460.75 | **LTE Advanced 3 Band Carrier Aggregation (3DL/1UL) for Band 1, Band 3 and Band 5** | 203d? | 2013-12-06 A | 2014-09-12 A | 100% | 2013-12-06 | 2014-09-12 | 202d? |  | R4 | 4856h | 4856h | LTE_CA_B1_B3_B5 | PCG-32 | SK Telecom | haesung.park@sk.com | Rel-12 | RP-62 | Issam | CA | LTE_CA_B1_B3_B5 |  |
| 2056 | 460.75.1 | Core part: LTE Advanced 3 Band Carrier Aggregation(3DL/1UL) for Band 1, Band 3 and Band 5 | 202d? | 2013-12-06 A | 2014-09-12 A | 100% | 2013-12-06 | 2014-09-12 | 202d? | finish no earlier than 2014-09-12 | R4 | 1616h | 1616h | LTE_CA_B1_B3_B5-Core | PCG-32 | SK Telecom | haesung.park@sk.com | Rel-12 | RP-62 | Issam | CA | LTE_CA_B1_B3_B5-Core | RP-141084 |
| 2057 | 460.75.2 | Perf. part: LTE Advanced 3 Band Carrier Aggregation(3DL/1UL) for Band 1, Band 3 and Band 5 | 202d? | 2013-12-06 A | 2014-09-12 A | 100% | 2013-12-06 | 2014-09-12 | 202d? | finish no earlier than 2014-09-12 | R4 | 1616h | 1616h | LTE_CA_B1_B3_B5-Perf | PCG-32 | SK Telecom | haesung.park@sk.com | Rel-12 | RP-62 | Issam | CA | LTE_CA_B1_B3_B5-Perf | RP-141084 |

Notes:
- 2034: Inter-band CA 3DL / Impacted TSs and TRs: LTE
- 2035: RP#65 completed / Impacted TSs and TRs: 36.101, 36.104, 36.133, new generic TR 36.853 (3 Band CA with 1UL)
- 2036: RP#65 completed / Impacted TSs and TRs: 36.141, 36.307
- 2037: Inter-band CA 3DL / Impacted TSs and TRs: LTE
- 2038: RP#65 completed / Impacted TSs and TRs: 36.101, 36.104, 36.133, 36.141, 36.307, new generic TR 36.853 (3 Band CA with 1UL)
- 2039: RP#65 completed / Impacted TSs and TRs: 36.101, 36.104, 36.133, 36.141, 36.307
- 2040: Inter-band CA 3DL / Impacted TSs and TRs: LTE
- 2041: RP#65 completed. Updated WID RP-131653=>RP-141214 / Impacted TSs and TRs: 36.101, 36.104, 36.133, 36.141, 36.307, new generic TR 36.853 (3 Band CA with 1UL)
- 2042: RP#65 completed / Impacted TSs and TRs: 36.101, 36.104, 36.133, 36.141, 36.307
- 2043: Intra-band contig. CA 2DL/2UL / Impacted TSs and TRs: LTE
- 2044: RP#64 completed. TR 36.833-1-42v100 for 1-step Approval. Updated WID RP-132029=>RP-140728 / Impacted TSs and TRs: 36.101, 36.104, 36.133, new TR 36.833-1-42
- 2045: RP#64 completed. TR 36.833-1-42v100 for 1-step Approval. Updated WID RP-132029=>RP-140728 / Impacted TSs and TRs: 36.141, 36.307
- 2046: Intra-band contig. CA 2DL/2UL / Impacted TSs and TRs: LTE
- 2047: RP#64 completed / Impacted TSs and TRs: 36.101, 36.307
- 2048: RP#64 completed / Impacted TSs and TRs: 36.307
- 2049: Intra-band non-contig. CA 3DL / Impacted TSs and TRs: LTE
- 2050: RP#65 completed / Impacted TSs and TRs: 36.101, 36.104, 36.133, 36.307, new TR 36.833-6-xy
- 2051: CD:Thu 12/03/15->Sun 15/03/15; Compl:60%->70%; Stat Rep: RP-141084->RP-141732 1st Apr 15: Compl:70%->100% 1st Apr 15: Stat Rep: RP-141732->RP-150013 / Impacted TSs and TRs: 36.141
- 2052: Intra-band non-contig. CA 2DL / Impacted TSs and TRs: LTE
- 2053: RP#64 completed. Updated WID RP-140404=>RP-140671. TR 36.833-2-42v100 for 1-step Approval / Impacted TSs and TRs: 36.101, 36.104, 36.133, new TR 36.833-2-42
- 2054: RP#64 completed / Impacted TSs and TRs: 36.141, 36.307
- 2055: Inter-band CA 3DL / Impacted TSs and TRs: LTE
- 2056: RP#65 completed. Updated WID RP-132121=>RP-141454 / Impacted TSs and TRs: 36.101, 36.104, 36.133, new generic TR 36.853 (3 Band CA with 1UL)
- 2057: RP#65 completed. Updated WID RP-132121=>RP-141454 / Impacted TSs and TRs: 36.141, 36.307

| ID | WBS | Task | Duration | Start | Finish | Complete | Baseline start | Baseline finish | Baseline duration | Constraint | Resources | Work | Actual work | Acronym | PCG approved | WI rapporteur name | WI rapporteur e-mail | Release | TSG approved | MCC resp | Special Focus Doc | Acronym_3GU_Export | Status Report |
| --- | --- | --- | --- | --- | --- | --- | --- | --- | --- | --- | --- | --- | --- | --- | --- | --- | --- | --- | --- | --- | --- | --- | --- |
| 2058 | 460.76 | **LTE Advanced 3 Band Carrier Aggregation (3DL/1UL) for Band 1, Band 3 and Band 20** | 202d? | 2013-12-09 A | 2014-09-12 A | 100% | 2013-12-09 | 2014-09-12 | 201d? |  | R4 | 4832h | 4832h | LTE_CA_B1_B3_B20 | PCG-32 | Vodafone | luis.anaya@vodafone.com | Rel-12 | RP-62 | Issam | CA | LTE_CA_B1_B3_B20 |  |
| 2059 | 460.76.1 | Core part: LTE Advanced 3 Band Carrier Aggregation (3DL/1UL) for Band 1, Band 3 and Band 20 | 201d? | 2013-12-09 A | 2014-09-12 A | 100% | 2013-12-09 | 2014-09-12 | 201d? | finish no earlier than 2014-09-12 | R4 | 1608h | 1608h | LTE_CA_B1_B3_B20-Core | PCG-32 | Vodafone | luis.anaya@vodafone.com | Rel-12 | RP-62 | Issam | CA | LTE_CA_B1_B3_B20-Core | RP-141084 |
| 2060 | 460.76.2 | Perf. part: LTE Advanced 3 Band Carrier Aggregation (3DL/1UL) for Band 1, Band 3 and Band 20 | 201d? | 2013-12-10 A | 2014-09-12 A | 100% | 2013-12-09 | 2014-09-12 | 201d? | finish no earlier than 2014-09-12 | R4 | 1608h | 1608h | LTE_CA_B1_B3_B20-Perf | PCG-32 | Vodafone | luis.anaya@vodafone.com | Rel-12 | RP-62 | Issam | CA | LTE_CA_B1_B3_B20-Perf | RP-141084 |
| 2061 | 460.77 | **LTE Advanced 3 Band Carrier Aggregation (3DL/1UL) for Band 1, Band 7 and Band 20** | 202d? | 2013-12-09 A | 2014-09-12 A | 100% | 2013-12-09 | 2014-09-12 | 201d? |  | R4 | 4832h | 4832h | LTE_CA_B1_B7_B20 | PCG-32 | Vodafone | luis.anaya@vodafone.com | Rel-12 | RP-62 | Issam | CA | LTE_CA_B1_B7_B20 |  |
| 2062 | 460.77.1 | Core part: LTE Advanced 3 Band Carrier Aggregation (3DL/1UL) for Band 1, Band 7 and Band 20 | 201d? | 2013-12-09 A | 2014-09-12 A | 100% | 2013-12-09 | 2014-09-12 | 201d? | finish no earlier than 2014-09-12 | R4 | 1608h | 1608h | LTE_CA_B1_B7_B20-Core | PCG-32 | Vodafone | luis.anaya@vodafone.com | Rel-12 | RP-62 | Issam | CA | LTE_CA_B1_B7_B20-Core | RP-141084 |
| 2063 | 460.77.2 | Perf. part: LTE Advanced 3 Band Carrier Aggregation (3DL/1UL) for Band 1, Band 7 and Band 20 | 201d? | 2013-12-10 A | 2014-09-12 A | 100% | 2013-12-09 | 2014-09-12 | 201d? | finish no earlier than 2014-09-12 | R4 | 1608h | 1608h | LTE_CA_B1_B7_B20-Perf | PCG-32 | Vodafone | luis.anaya@vodafone.com | Rel-12 | RP-62 | Issam | CA | LTE_CA_B1_B7_B20-Perf | RP-141084 |
| 2064 | 460.78 | **LTE Advanced 3 Band Carrier Aggregation (3DL/1UL) for Band 7, Band 8 and Band 20** | 270d? | 2013-12-09 A | 2014-12-15 A | 100% | 2013-12-09 | 2014-09-12 | 201d? |  | R4 | 6432h | 6432h | LTE_CA_B7_B8_B20 | PCG-32 | Vodafone | luis.anaya@vodafone.com | Rel-12 | RP-62 | Issam | CA | LTE_CA_B7_B8_B20 |  |
| 2065 | 460.78.1 | Core part: LTE Advanced 3 Band Carrier Aggregation (3DL/1UL) for Band 7, Band 8 and Band 20 | 267d? | 2013-12-09 A | 2014-12-15 A | 100% | 2013-12-09 | 2014-09-12 | 201d? | finish no earlier than 2014-12-15 | R4 | 2136h | 2136h | LTE_CA_B7_B8_B20-Core | PCG-32 | Vodafone | luis.anaya@vodafone.com | Rel-12 | RP-62 | Issam | CA | LTE_CA_B7_B8_B20-Core | RP-141732 |
| 2066 | 460.78.2 | Perf. part: LTE Advanced 3 Band Carrier Aggregation (3DL/1UL) for Band 7, Band 8 and Band 20 | 267d? | 2013-12-12 A | 2014-12-15 A | 100% | 2013-12-09 | 2014-09-12 | 201d? | finish no earlier than 2014-12-15 | R4 | 2136h | 2136h | LTE_CA_B7_B8_B20-Perf | PCG-32 | Vodafone | luis.anaya@vodafone.com | Rel-12 | RP-62 | Issam | CA | LTE_CA_B7_B8_B20-Perf | RP-141732 |
| 2067 | 460.79 | **Additional bandwidth combinations for LTE Advanced inter-band Carrier Aggregation of Band 2 and Band 29 and of Band 4 and Band 29** | 4d? | 2014-03-03 A | 2014-03-06 A | 100% | 2014-03-03 | 2014-03-06 | 4d? |  | R4 | 64h | 64h | LTE_DL_FDD700_B29_Bwset | PCG-32 | AT&T | marc.grant@att.com | Rel-12 | RP-63 | Issam | CA | LTE_DL_FDD700_B29_Bwset |  |
| 2068 | 460.79.1 | Core part: Additional bandwidth combinations for LTE Advanced inter-band Carrier Aggregation of Band 2 and Band 29 and of Band 4 and Band 29 | 4d? | 2014-03-03 A | 2014-03-06 A | 100% | 2014-03-03 | 2014-03-06 | 4d? | finish no earlier than 2014-03-06 | R4 | 32h | 32h | LTE_DL_FDD700_B29_BWset-Core | PCG-32 | AT&T | marc.grant@att.com | Rel-12 | RP-63 | Issam | CA | LTE_DL_FDD700_B29_BWset-Core | RP-140428 |
| 2069 | 460.80 | **Additional bandwidth combination set for LTE Advanced inter-band Carrier Aggregation of Band 3 and Band 20** | 72d? | 2014-03-06 A | 2014-06-13 A | 100% | 2014-03-06 | 2014-06-13 | 72d? |  | R4 | 1152h | 1152h | LTE_CA_B3_B20_BWset | PCG-32 | NSN | iwajlo.angelow@nsn.com | Rel-12 | RP-63 | Issam | CA | LTE_CA_B3_B20_BWset |  |
| 2070 | 460.80.1 | Core part: Additional bandwidth combination set for LTE Advanced inter-band Carrier Aggregation of Band 3 and Band 20 | 72d? | 2014-03-06 A | 2014-06-13 A | 100% | 2014-03-06 | 2014-06-13 | 72d? | finish no earlier than 2014-06-13 | R4 | 576h | 576h | LTE_CA_B3_B20_BWset-Core | PCG-32 | NSN | iwajlo.angelow@nsn.com | Rel-12 | RP-63 | Issam | CA | LTE_CA_B3_B20_BWset-Core | RP-140569 |
| 2071 | 460.81 | **Additional bandwidth combination set for LTE Advanced inter-band Carrier Aggregation of Band 7 and Band 20** | 72d? | 2014-03-06 A | 2014-06-13 A | 100% | 2014-03-06 | 2014-06-13 | 72d? |  | R4 | 1152h | 1152h | LTE_CA_B7_B20_BWset | PCG-32 | NSN | iwajlo.angelow@nsn.com | Rel-12 | RP-63 | Issam | CA | LTE_CA_B7_B20_BWset |  |
| 2072 | 460.81.1 | Core part: Additional bandwidth combination set for LTE Advanced inter-band Carrier Aggregation of Band 7 and Band 20 | 72d? | 2014-03-06 A | 2014-06-13 A | 100% | 2014-03-06 | 2014-06-13 | 72d? | finish no earlier than 2014-06-13 | R4 | 576h | 576h | LTE_CA_B7_B20_BWset-Core | PCG-32 | NSN | iwajlo.angelow@nsn.com | Rel-12 | RP-63 | Issam | CA | LTE_CA_B7_B20_BWset-Core | RP-140569 |
| 2073 | 460.82 | **Additional bandwidth combinations for LTE Advanced inter-band Carrier Aggregation to support 3DL fallback** | 72d? | 2014-03-06 A | 2014-06-13 A | 100% | 2014-03-06 | 2014-06-13 | 72d? |  | R4 | 1152h | 1152h | LTE_CA_3DL_FB_BW | PCG-32 | Qualcomm | Fong Gene (gfong@qti.qualcomm.com) | Rel-12 | RP-63 | Issam | CA | LTE_CA_3DL_FB_BW |  |
| 2074 | 460.82.1 | Core part: Additional bandwidth combinations for LTE Advanced inter-band Carrier Aggregation to support 3DL fallback | 72d? | 2014-03-06 A | 2014-06-13 A | 100% | 2014-03-06 | 2014-06-13 | 72d? | finish no earlier than 2014-06-13 | R4 | 576h | 576h | LTE_CA_3DL_FB_BW-Core | PCG-32 | Qualcomm | Fong Gene (gfong@qti.qualcomm.com) | Rel-12 | RP-63 | Issam | CA | LTE_CA_3DL_FB_BW-Core | RP-140569 |
| 2075 | 460.83 | **LTE Advanced 3 Band Carrier Aggregation (3DL/1UL) of Band 3, Band 7 and Band 7** | 138d? | 2014-03-06 A | 2014-09-12 A | 100% | 2014-03-06 | 2014-09-12 | 137d? |  | R4 | 3296h | 3296h | LTE_CA_B3_B7_B7 | PCG-32 | Nokia Networks | iwajlo.angelow@nsn.com | Rel-12 | RP-63 | Issam | CA | LTE_CA_B3_B7_B7 |  |
| 2076 | 460.83.1 | Core part: LTE Advanced 3 Band Carrier Aggregation (3DL/1UL) of Band 3, Band 7 and Band 7 | 137d? | 2014-03-06 A | 2014-09-12 A | 100% | 2014-03-06 | 2014-09-12 | 137d? | finish no earlier than 2014-09-12 | R4 | 1096h | 1096h | LTE_CA_B3_B7_B7-Core | PCG-32 | Nokia Networks | iwajlo.angelow@nsn.com | Rel-12 | RP-63 | Issam | CA | LTE_CA_B3_B7_B7-Core | RP-141084 |
| 2077 | 460.83.2 | Perf. part: LTE Advanced 3 Band Carrier Aggregation (3DL/1UL) of Band 3, Band 7 and Band 7 | 137d? | 2014-03-06 A | 2014-09-12 A | 100% | 2014-03-06 | 2014-09-12 | 137d? | finish no earlier than 2014-09-12 | R4 | 1096h | 1096h | LTE_CA_B3_B7_B7-Perf | PCG-32 | Nokia Networks | iwajlo.angelow@nsn.com | Rel-12 | RP-63 | Issam | CA | LTE_CA_B3_B7_B7-Perf | RP-141084 |
| 2078 | 460.84 | **LTE Advanced 3 Band Carrier Aggregation (3DL/1UL) of Band 1, Band 19 and Band 21** | 138d? | 2014-03-06 A | 2014-09-12 A | 100% | 2014-03-06 | 2014-09-12 | 137d? |  | R4 | 3296h | 3296h | LTE_CA_B1_B19_B21 | PCG-32 | NTT DOCOMO | teruaki.toeda.zf@nttdocomo.com | Rel-12 | RP-63 | Issam | CA | LTE_CA_B1_B19_B21 |  |
| 2079 | 460.84.1 | Core part: LTE Advanced 3 Band Carrier Aggregation (3DL/1UL) of Band 1, Band 19 and Band 21 | 137d? | 2014-03-06 A | 2014-09-12 A | 100% | 2014-03-06 | 2014-09-12 | 137d? | finish no earlier than 2014-09-12 | R4 | 1096h | 1096h | LTE_CA_B1_B19_B21-Core | PCG-32 | NTT DOCOMO | teruaki.toeda.zf@nttdocomo.com | Rel-12 | RP-63 | Issam | CA | LTE_CA_B1_B19_B21-Core | RP-141084 |
| 2080 | 460.84.2 | Perf. part: LTE Advanced 3 Band Carrier Aggregation (3DL/1UL) of Band 1, Band 19 and Band 21 | 137d? | 2014-03-06 A | 2014-09-12 A | 100% | 2014-03-06 | 2014-09-12 | 137d? | finish no earlier than 2014-09-12 | R4 | 1096h | 1096h | LTE_CA_B1_B19_B21-Perf | PCG-32 | NTT DOCOMO | teruaki.toeda.zf@nttdocomo.com | Rel-12 | RP-63 | Issam | CA | LTE_CA_B1_B19_B21-Perf | RP-141084 |
| 2081 | 460.85 | **LTE Advanced 3 Band Carrier Aggregation (3DL/1UL) of Band 3, Band 3 and Band 7** | 138d? | 2014-03-06 A | 2014-09-12 A | 100% | 2014-03-06 | 2014-09-12 | 137d? |  | R4 | 3296h | 3296h | LTE_CA_B3_B3_B7 | PCG-32 | TeliaSonera | Ralf.Schuh@TeliaSonera.com | Rel-12 | RP-63 | Issam | CA | LTE_CA_B3_B3_B7 |  |
| 2082 | 460.85.1 | Core part: LTE-Advanced 3 Band Carrier Aggregation (3DL/1UL) of Band 3, Band 3 and Band 7 | 137d? | 2014-03-06 A | 2014-09-12 A | 100% | 2014-03-06 | 2014-09-12 | 137d? | finish no earlier than 2014-09-12 | R4 | 1096h | 1096h | LTE_CA_B3_B3_B7-Core | PCG-32 | TeliaSonera | Ralf.Schuh@TeliaSonera.com | Rel-12 | RP-63 | Issam | CA | LTE_CA_B3_B3_B7-Core | RP-141084 |
| 2083 | 460.85.2 | Perf. part: LTE-Advanced 3 Band Carrier Aggregation (3DL/1UL) of Band 3, Band 3 and Band 7 | 137d? | 2014-03-06 A | 2014-09-12 A | 100% | 2014-03-06 | 2014-09-12 | 137d? | finish no earlier than 2014-09-12 | R4 | 1096h | 1096h | LTE_CA_B3_B3_B7-Perf | PCG-32 | TeliaSonera | Ralf.Schuh@TeliaSonera.com | Rel-12 | RP-63 | Issam | CA | LTE_CA_B3_B3_B7-Perf | RP-141084 |

Notes:
- 2058: Inter-band CA 3DL / Impacted TSs and TRs: LTE
- 2059: RP#65 completed. Updated WID RP-141017=>RP-141222 / Impacted TSs and TRs: 36.101, 36.104, 36.133, new generic TR 36.851 (2 Band CA with 1UL), TR 36.853 (3 Band CA with 1UL)
- 2060: RP#65 completed / Impacted TSs and TRs: 36.101, 36.133, 36.141, 36.307
- 2061: Inter-band CA 3DL / Impacted TSs and TRs: LTE
- 2062: RP#65 completed. Updated WID RP-140243=>RP-141223 / Impacted TSs and TRs: 36.101, 36.104, 36.133, new generic TR 36.853 (3 Band CA with 1UL), TR 36.851 (2 Band CA with 1UL)
- 2063: RP#65 completed / Impacted TSs and TRs: 36.101, 36.133, 36.141, 36.307
- 2064: Inter-band CA 3DL / Impacted TSs and TRs: LTE
- 2065: CD:Thu 11/12/14->Mon 15/12/14; Compl:85%->100%; Stat Rep: RP-141084->RP-141732 / Impacted TSs and TRs: 36.101, 36.104, 36.133, new generic TR 36.853 (3 Band CA with 1UL), TR 36.851 (2 Band CA with 1UL)
- 2066: CD:Thu 11/12/14->Mon 15/12/14; Compl:0%->100%; Stat Rep: RP-141084->RP-141732 / Impacted TSs and TRs: 36.101, 36.133, 36.141, 36.307
- 2067: Inter-band 2DL/1UL / Impacted TSs and TRs: LTE
- 2068: RP#63 approved WI (no Perf. Part) & completed. Rel-10 and Rel-11 versions of 36.307 affected / Impacted TSs and TRs: 36.101, 36.307
- 2069: Inter-band CA 2DL / Impacted TSs and TRs: LTE
- 2070: RP#64 completed / Impacted TSs and TRs: 36.101, TR 36.851
- 2071: Inter-band CA 2DL / Impacted TSs and TRs: LTE
- 2072: RP#64 completed / Impacted TSs and TRs: 36.101, TR 36.851
- 2073: Inter-band CA 2DL / Impacted TSs and TRs: LTE
- 2074: RP#64 completed, Additional BW combinations added for 6 Wis: 3 open Rel-12 Wis (B1_B5_B7, B2_B29_B30, B4_B29_B30) and 3 completed Rel-11 Wis (B3_B5, B4_B5, B4_B12) / Impacted TSs and TRs: 36.101, 36.307
- 2075: Inter-band CA 3DL. Mar15: acronym reverted to LTE_CA_B3_B7_B7_ / Impacted TSs and TRs: LTE
- 2076: RP#65 completed. Updated WID RP-140095=>RP-141196. Mar15: acronym reverted to LTE_CA_B3_B7_B7-Core_ / Impacted TSs and TRs: 36.101, 36.104, 36.133, new generic TR 36.853 (3 Band CA with 1UL)
- 2077: RP#65 completed. Updated WID RP-140095=>RP-141196. Mar15: acronym reverted from LTE_CA_B3_B7_B7-Perf_ / Impacted TSs and TRs: 36.141, 36.307
- 2078: Inter-band CA 3DL / Impacted TSs and TRs: LTE
- 2079: RP#65 completed. Updated WID RP-140106=>RP-141193 / Impacted TSs and TRs: 36.101, 36.104, 36.133, new generic TR 36.853 (3 Band CA with 1UL)
- 2080: RP#65 completed. Updated WID RP-140106=>RP-141193 / Impacted TSs and TRs: 36.141, 36.307
- 2081: Inter-band CA 3DL / Impacted TSs and TRs: LTE
- 2082: RP#65 completed. Updated RP-140390=>RP-141126 / Impacted TSs and TRs: 36.101, 36.104, 36.133, new generic TR 36.853 (3 Band CA with 1UL)
- 2083: RP#65 completed. Updated RP-140390=>RP-141126 / Impacted TSs and TRs: 36.141, 36.307

| ID | WBS | Task | Duration | Start | Finish | Complete | Remaining | Baseline start | Baseline finish | Baseline duration | Total slack | Constraint | Resources | Work | Actual work | Acronym | PCG approved | WI rapporteur name | WI rapporteur e-mail | Release | TSG approved | MCC resp | Special Focus Doc | Acronym_3GU_Export | Status Report | PCG stopped | TSG stopped |
| --- | --- | --- | --- | --- | --- | --- | --- | --- | --- | --- | --- | --- | --- | --- | --- | --- | --- | --- | --- | --- | --- | --- | --- | --- | --- | --- | --- |
| 2084 | 460.86 | **LTE Advanced intra-band contiguous Carrier Aggregation in Band 40 for 3DL** | 72d? | 2014-03-06 A | 2014-06-13 A | 100% |  | 2014-03-06 | 2014-06-13 | 72d? |  |  | R4 | 1728h | 1728h | LTE_CA_C_B40_3DL | PCG-32 | China Mobile | Pan Qun (panqun@chinamobile.com) | Rel-12 | RP-63 | Issam | CA | LTE_CA_C_B40_3DL |  |  |  |
| 2085 | 460.86.1 | Core part: LTE Advanced intra-band contiguous Carrier Aggregation in Band 40 for 3DL | 72d? | 2014-03-06 A | 2014-06-13 A | 100% |  | 2014-03-06 | 2014-06-13 | 72d? |  | finish no earlier than 2014-06-13 | R4 | 576h | 576h | LTE_CA_C_B40_3DL-Core | PCG-32 | China Mobile | Pan Qun (panqun@chinamobile.com) | Rel-12 | RP-63 | Issam | CA | LTE_CA_C_B40_3DL-Core | RP-140569 |  |  |
| 2086 | 460.86.2 | Perf. part: LTE Advanced intra-band contiguous Carrier Aggregation in Band 40 for 3DL | 72d? | 2014-03-06 A | 2014-06-13 A | 100% |  | 2014-03-06 | 2014-06-13 | 72d? |  | finish no earlier than 2014-06-13 | R4 | 576h | 576h | LTE_CA_C_B40_3DL-Perf | PCG-32 | China Mobile | Pan Qun (panqun@chinamobile.com) | Rel-12 | RP-63 | Issam | CA | LTE_CA_C_B40_3DL-Perf | RP-140569 |  |  |
| 2087 | 460.87 | **Additional bandwidth combination set for LTE Advanced inter-band Carrier Aggregation of Band 4 and Band 12** | 137d? | 2014-03-07 A | 2014-09-12 A | 100% |  | 2014-03-06 | 2014-12-05 | 197d? |  |  | R4 | 3288h | 3288h | LTE_CA_B4_B12_BWset | PCG-32 | T-Mobile USA | nelson.ueng@t-mobile.com | Rel-12 | RP-63 | Issam | CA | LTE_CA_B4_B12_BWset |  |  |  |
| 2088 | 460.87.1 | Core part: Additional bandwidth combination set for LTE Advanced inter-band Carrier Aggregation of Band 4 and Band 12 | 137d? | 2014-03-07 A | 2014-09-12 A | 100% |  | 2014-03-06 | 2014-12-05 | 197d? |  | finish no earlier than 2014-09-12 | R4 | 1096h | 1096h | LTE_CA_B4_B12_BWset-Core | PCG-32 | T-Mobile USA | nelson.ueng@t-mobile.com | Rel-12 | RP-63 | Issam | CA | LTE_CA_B4_B12_BWset-Core | RP-141084 |  |  |
| 2089 | 460.87.2 | Deleted - Perf. part: Additional bandwidth combination set for LTE Advanced inter-band Carrier Aggregation of Band 4 and Band 12 | 137d? | 2014-03-07 A | 2014-09-12 A | 100% |  | 2014-03-06 | 2014-12-05 | 197d? |  | finish no earlier than 2014-09-12 | R4 | 1096h | 1096h | LTE_CA_B4_B12_BWset-Perf | PCG-32 | T-Mobile USA | nelson.ueng@t-mobile.com | Rel-12 | RP-63 | Issam | CA | LTE_CA_B4_B12_BWset-Perf | RP-141084 | PCG-33 | RP-65 |
| 2090 | 460.88 | **LTE Advanced inter-band Carrier Aggregation of Band 41 and Band 42** | 138d? | 2014-03-06 A | 2014-09-12 A | 100% |  | 2014-03-06 | 2014-09-12 | 137d? |  |  | R4 | 2776h | 2776h | LTE_CA_B41_B42 | PCG-32 | Huawei | leo.liuye@huawei.com | Rel-12 | RP-63 | Issam | CA | LTE_CA_B41_B42 |  |  |  |
| 2091 | 460.88.1 | Core part: LTE Advanced inter-band Carrier Aggregation of Band 41 and Band 42 | 72d? | 2014-03-06 A | 2014-09-12 A | 100% |  | 2014-03-06 | 2014-09-12 | 72d? |  | finish no earlier than 2014-09-12 | R4 | 576h | 576h | LTE_CA_B41_B42-Core | PCG-32 | Huawei | leo.liuye@huawei.com | Rel-12 | RP-63 | Issam | CA | LTE_CA_B41_B42-Core | RP-141084 |  |  |
| 2092 | 460.88.2 | Perf. Part: LTE Advanced inter-band Carrier Aggregation of Band 41 and Band 42 | 137d? | 2014-03-07 A | 2014-09-12 A | 100% |  | 2014-03-06 | 2014-09-12 | 137d? |  | finish no earlier than 2014-09-12 | R4 | 1096h | 1096h | LTE_CA_B41_B42-Perf | PCG-32 | Huawei | leo.liuye@huawei.com | Rel-12 | RP-63 | Issam | CA | LTE_CA_B41_B42-Perf | RP-141084 |  |  |
| 2093 | 460.89 | **LTE Advanced 3 Band Carrier Aggregation (3DL/1UL) of Band 4, Band 4, and Band 12** | 138d? | 2014-03-06 A | 2014-09-12 A | 100% |  | 2014-03-06 | 2014-12-05 | 197d? |  |  | R4 | 3296h | 3296h | LTE_CA_B4_B4_B12 | PCG-32 | T-Mobile USA | nelson.ueng@t-mobile.com | Rel-12 | RP-63 | Issam | CA | LTE_CA_B4_B4_B12 |  |  |  |
| 2094 | 460.89.1 | Core part: LTE Advanced 3 Band Carrier Aggregation (3DL/1UL) of Band 4, Band 4, and Band 12 | 137d? | 2014-03-06 A | 2014-09-12 A | 100% |  | 2014-03-06 | 2014-12-05 | 197d? |  | finish no earlier than 2014-09-12 | R4 | 1096h | 1096h | LTE_CA_B4_B4_B12-Core | PCG-32 | T-Mobile USA | nelson.ueng@t-mobile.com | Rel-12 | RP-63 | Issam | CA | LTE_CA_B4_B4_B12-Core | RP-141084 |  |  |
| 2095 | 460.89.2 | Perf. part: LTE Advanced 3 Band Carrier Aggregation (3DL/1UL) of Band 4, Band 4, and Band 12 | 137d? | 2014-03-07 A | 2014-09-12 A | 100% |  | 2014-03-06 | 2014-12-05 | 197d? |  | finish no earlier than 2014-09-12 | R4 | 1096h | 1096h | LTE_CA_B4_B4_B12-Perf | PCG-32 | T-Mobile USA | nelson.ueng@t-mobile.com | Rel-12 | RP-63 | Issam | CA | LTE_CA_B4_B4_B12-Perf | RP-141084 |  |  |
| 2096 | 460.90 | **LTE Advanced 3 Band Carrier Aggregation (3DL/1UL) of Band 2, Band 4, and Band 4** | 138d? | 2014-03-06 A | 2014-09-12 A | 100% |  | 2014-03-06 | 2014-12-05 | 197d? |  |  | R4 | 3296h | 3296h | LTE_CA_B2_B4_B4 | PCG-32 | T-Mobile USA | nelson.ueng@T-Mobile.com | Rel-12 | RP-63 | Issam | CA | LTE_CA_B2_B4_B4 |  |  |  |
| 2097 | 460.90.1 | Core part: LTE Advanced 3 Band Carrier Aggregation (3DL/1UL) of Band 2, Band 4, and Band 4 | 137d? | 2014-03-06 A | 2014-09-12 A | 100% |  | 2014-03-06 | 2014-12-05 | 197d? |  | finish no earlier than 2014-09-12 | R4 | 1096h | 1096h | LTE_CA_B2_B4_B4-Core | PCG-32 | T-Mobile USA | nelson.ueng@T-Mobile.com | Rel-12 | RP-63 | Issam | CA | LTE_CA_B2_B4_B4-Core | RP-141084 |  |  |
| 2098 | 460.90.2 | Perf. part: LTE Advanced 3 Band Carrier Aggregation (3DL/1UL) of Band 2, Band 4, and Band 4 | 137d? | 2014-03-07 A | 2014-09-12 A | 100% |  | 2014-03-06 | 2014-12-05 | 197d? |  | finish no earlier than 2014-09-12 | R4 | 1096h | 1096h | LTE_CA_B2_B4_B4-Perf | PCG-32 | T-Mobile USA | nelson.ueng@T-Mobile.com | Rel-12 | RP-63 | Issam | CA | LTE_CA_B2_B4_B4-Perf | RP-141084 |  |  |
| 2099 | 460.91 | **Additional bandwidth combinations for LTE Advanced intra-band non-contiguous Carrier Aggregation in Band 25** | 138d? | 2014-03-06 A | 2014-09-12 A | 100% |  | 2014-03-06 | 2014-09-12 | 137d? |  |  | R4 | 3296h | 3296h | LTE_CA_NC_B25_BWset | PCG-32 | Huawei | Liu Liehai (liuliehai@huawei.com) | Rel-12 | RP-63 | Issam | CA | LTE_CA_NC_B25_BWset |  |  |  |
| 2100 | 460.91.1 | Core part: Additional bandwidth combinations for LTE Advanced intra-band non-contiguous Carrier Aggregation in Band 25 | 137d? | 2014-03-06 A | 2014-09-12 A | 100% |  | 2014-03-06 | 2014-09-12 | 137d? |  | finish no earlier than 2014-09-12 | R4 | 1096h | 1096h | LTE_CA_NC_B25_BWset-Core | PCG-32 | Huawei | Liu Liehai (liuliehai@huawei.com) | Rel-12 | RP-63 | Issam | CA | LTE_CA_NC_B25_BWset-Core | RP-141084 |  |  |
| 2101 | 460.91.2 | Perf. part: Additional bandwidth combinations for LTE Advanced intra-band non-contiguous Carrier Aggregation in Band 25 | 137d? | 2014-03-07 A | 2014-09-12 A | 100% |  | 2014-03-06 | 2014-09-12 | 137d? |  | finish no earlier than 2014-09-12 | R4 | 1096h | 1096h | LTE_CA_NC_B25_BWset-Perf | PCG-32 | Huawei | Liu Liehai (liuliehai@huawei.com) | Rel-12 | RP-63 | Issam | CA | LTE_CA_NC_B25_BWset-Perf | RP-141084 |  |  |
| 2102 | 460.92 | **Additional bandwidth combination set for LTE Advanced inter-band Carrier Aggregation of Band 2 and Band 4** | 66d? | 2014-06-15 A | 2014-09-15 A | 100% |  | 2014-06-13 | 2014-09-12 | 66d? |  |  | R4 | 1056h | 1056h | LTE_CA_B2_B4_Bwset2 | PCG-33 | T-Mobile USA | nelson.ueng@T-Mobile.com | Rel-12 | RP-64 |  | CA | LTE_CA_B2_B4_BWset |  |  |  |
| 2103 | 460.92.1 | Core part: Additional bandwidth combination set 2 for LTE Advanced inter-band Carrier Aggregation of Band 2 and Band 4 | 66d? | 2014-06-15 A | 2014-09-15 A | 100% |  | 2014-06-13 | 2014-09-12 | 66d? |  | finish no earlier than 2014-09-15 | R4 | 528h | 528h | LTE_CA_B2_B4_BWset2-Core | PCG-33 | T-Mobile USA | nelson.ueng@T-Mobile.com | Rel-12 | RP-64 |  | CA | LTE_CA_B2_B4_BWset-Core | RP-141084 |  |  |
| 2104 | 460.93 | **Additional bandwidth combination set for LTE Advanced inter-band Carrier Aggregation of Band 2 and Band 5** | 132d? | 2014-06-18 A | 2014-12-15 | 50% | 66d? | 2014-06-13 | 2014-09-12 | 66d? | 871d |  | R4 | 3168h | 1584h | LTE_CA_B2_B5_BWset | PCG-33 | AT&T | marc.grant@att.com | Rel-12 | RP-64 |  | CA | LTE_CA_B2_B5_BWset |  |  |  |
| 2105 | 460.93.1 | Core part: Additional bandwidth combination set for LTE Advanced inter-band Carrier Aggregation of Band 2 and Band 5 | 132d? | 2014-06-18 A | 2014-12-15 A | 100% |  | 2014-06-13 | 2014-09-12 | 66d? |  | finish no earlier than 2014-12-15 | R4 | 1056h | 1056h | LTE_CA_B2_B5_Bwset-Core | PCG-33 | AT&T | marc.grant@att.com | Rel-12 | RP-64 |  | CA | LTE_CA_B2_B5_Bwset-Core | RP-141732 |  |  |
| 2106 | 460.93.2 | Perf. Part: Additional bandwidth combination set for LTE Advanced inter-band Carrier Aggregation of Band 2 and Band 5 | 132d? | 2014-06-18 | 2014-12-15 |  |  | 2014-06-13 | 2014-09-12 | 66d? | 871d | finish no earlier than 2014-12-15 | R4 | 1056h |  | LTE_CA_B2_B5_BWset-Perf | PCG-33 | AT&T | marc.grant@att.com | Rel-12 | RP-64 |  | CA | LTE_CA_B2_B5_BWset-Perf | RP-141732 |  |  |
| 2107 | 460.94 | **E-UTRA UE demodulation/Channel State Information (CSI) performance requirements for multiple Carrier Aggregation configurations** | 198d? | 2014-06-16 A | 2015-03-15 A | 100% |  | 2014-06-13 | 2015-03-13 | 196d? |  |  | R4 | 3152h | 3152h | LTE_CA_Mult | PCG-33 | China Mobile | Zhang Xiaoran (zhangxiaoran@chinamobile.com) | Rel-12 | RP-64 |  | CA | LTE_CA_Mult |  |  |  |
| 2108 | 460.94.1 | Perf. Part: E-UTRA UE demodulation/Channel State Information (CSI) performance requirements for multiple Carrier Aggregation configurations | 196d? | 2014-06-16 A | 2015-03-15 A | 100% |  | 2014-06-13 | 2015-03-13 | 196d? |  | finish no earlier than 2015-03-15 | R4 | 1568h | 1568h | LTE_CA_Mult-Perf | PCG-33 | China Mobile | Zhang Xiaoran (zhangxiaoran@chinamobile.com) | Rel-12 | RP-64 |  | CA | LTE_CA_Mult-Perf | RP-150188 |  |  |

Notes:
- 2084: Intra-band contig. CA 3DL / Impacted TSs and TRs: LTE
- 2085: RP#64 completed. Updated WID RP-140453=>RP-140948 / Impacted TSs and TRs: 36.101, 36.104, 36.133, New TR 36.833-5-40
- 2086: RP#64 completed. Updated WID RP-140453=>RP-140948 / Impacted TSs and TRs: 36.141, 36.307
- 2087: Inter-band CA 2DL / Impacted TSs and TRs: LTE
- 2088: RP#65 completed. Updated WID RP-140987=>RP-141235 (removed Perf. Part) / Impacted TSs and TRs: 36.101, generic TR 36.850
- 2089: RP#65 stopped. Updated WID RP-140987=>RP-141235 (removed Perf. Part) / Impacted TSs and TRs: 36.307
- 2090: Inter-band CA 2DL / Impacted TSs and TRs: LTE
- 2091: RP#65 completed / Impacted TSs and TRs: 36.101, 36.104, TR 36.851
- 2092: RP#65 completed / Impacted TSs and TRs: 36.141
- 2093: Inter-band CA 3DL / Impacted TSs and TRs: LTE
- 2094: RP#65 completed. Updated WID RP-140116=>RP-141709 / Impacted TSs and TRs: 36.101, 36.104, 36.133, 36.141, 36.307, generic TR 36.853 (3 Band CA with 1UL)
- 2095: RP#65 completed / Impacted TSs and TRs: 36.101, 36.104, 36.133, 36.141, 36.307
- 2096: Inter-band CA 3DL / Impacted TSs and TRs: LTE
- 2097: RP#65 completed. Updated WID RP-140117=>RP-141236 / Impacted TSs and TRs: 36.101, 36.104, 36.133, 36.141, 36.307, generic TR 36.853 (3 Band CA with 1UL)
- 2098: RP#65 completed / Impacted TSs and TRs: 36.101, 36.104, 36.133, 36.141, 36.307
- 2099: Intra-band non-contig. CA 2DL / Impacted TSs and TRs: LTE
- 2100: RP#65 completed / Impacted TSs and TRs: 36.101, 36.307, TR 36.833-2-25
- 2101: RP#65 completed / Impacted TSs and TRs: 36.307
- 2102: Inter-band CA 2DL. Mar 15: acronym changed from LTE_CA_B2_B4_Bwset_ / Impacted TSs and TRs: LTE
- 2103: Dec 14: Prev CD:Fri 12/09/14; Prev %:100%, title changed. Mar 15: Acronym changed to LTE_CA_B2_B4_BWset2-Core_ / Impacted TSs and TRs: 36.101, 36.851
- 2104: 2DL/1UL / Impacted TSs and TRs: LTE
- 2105: ; WID: RP-142043->RP-141803; Stat Rep: RP-141084->RP-141732 / Impacted TSs and TRs: 36.101, 36.851
- 2106: CD:Thu 11/12/14->Mon 15/12/14; Compl:0%->0%; Stat Rep: RP-141084->RP-141732 / Impacted TSs and TRs: 36.307
- 2107: LTE / Impacted TSs and TRs: LTE
- 2108: CD:Thu 12/03/15->Sun 15/03/15; Compl:10%->90%; Stat Rep: RP-141303->RP-141839 1st Apr 15: Compl:90%->100% 1st Apr 15: Stat Rep: RP-141839->RP-150188 / Impacted TSs and TRs: 36.101

| ID | WBS | Task | Duration | Start | Finish | Complete | Baseline start | Baseline finish | Baseline duration | Constraint | Resources | Work | Actual work | Acronym | PCG approved | WI rapporteur name | WI rapporteur e-mail | Release | TSG approved | Special Focus Doc | Acronym_3GU_Export | Status Report | MCC resp |
| --- | --- | --- | --- | --- | --- | --- | --- | --- | --- | --- | --- | --- | --- | --- | --- | --- | --- | --- | --- | --- | --- | --- | --- |
| 2109 | 460.95 | **LTE Advanced 3 Band Carrier Aggregation (3DL/1UL) of Band 1, Band 3 and Band 19** | 66d? | 2014-06-16 A | 2014-09-12 A | 100% | 2014-06-13 | 2014-09-12 | 66d? |  | R4 | 1584h | 1584h | LTE_CA_B1_B3_B19 | PCG-33 | NTT DOCOMO | teruaki.toeda.zf@nttdocomo.com | Rel-12 | RP-64 | CA | LTE_CA_B1_B3_B19 |  |  |
| 2110 | 460.95.1 | Core part: LTE Advanced 3 Band Carrier Aggregation (3DL/1UL) of Band 1, Band 3 and Band 19 | 66d? | 2014-06-16 A | 2014-09-12 A | 100% | 2014-06-13 | 2014-09-12 | 66d? | finish no earlier than 2014-09-12 | R4 | 528h | 528h | LTE_CA_B1_B3_B19-Core | PCG-33 | NTT DOCOMO | teruaki.toeda.zf@nttdocomo.com | Rel-12 | RP-64 | CA | LTE_CA_B1_B3_B19-Core | RP-141084 |  |
| 2111 | 460.95.2 | Perf. Part: LTE Advanced 3 Band Carrier Aggregation (3DL/1UL) of Band 1, Band 3 and Band 19 | 66d? | 2014-06-16 A | 2014-09-12 A | 100% | 2014-06-13 | 2014-09-12 | 66d? | finish no earlier than 2014-09-12 | R4 | 528h | 528h | LTE_CA_B1_B3_B19-Perf | PCG-33 | NTT DOCOMO | teruaki.toeda.zf@nttdocomo.com | Rel-12 | RP-64 | CA | LTE_CA_B1_B3_B19-Perf | RP-141084 |  |
| 2112 | 460.96 | **LTE Advanced 3 Band Carrier Aggregation (3DL/1UL) of Band 19, Band 42 and Band 42** | 66d? | 2014-06-16 A | 2014-09-12 A | 100% | 2014-06-13 | 2014-09-12 | 66d? |  | R4 | 1584h | 1584h | LTE_CA_B19_B42_B42 | PCG-33 | NTT DOCOMO | teruaki.toeda.zf@nttdocomo.com | Rel-12 | RP-64 | CA | LTE_CA_B19_B42_B42 |  |  |
| 2113 | 460.96.1 | Core part: LTE Advanced 3 Band Carrier Aggregation (3DL/1UL) of Band 19, Band 42 and Band 42 | 66d? | 2014-06-16 A | 2014-09-12 A | 100% | 2014-06-13 | 2014-09-12 | 66d? | finish no earlier than 2014-09-12 | R4 | 528h | 528h | LTE_CA_B19_B42_B42-Core | PCG-33 | NTT DOCOMO | teruaki.toeda.zf@nttdocomo.com | Rel-12 | RP-64 | CA | LTE_CA_B19_B42_B42-Core | RP-141084 |  |
| 2114 | 460.96.2 | Perf. Part: LTE Advanced 3 Band Carrier Aggregation (3DL/1UL) of Band 19, Band 42 and Band 42 | 66d? | 2014-06-16 A | 2014-09-12 A | 100% | 2014-06-13 | 2014-09-12 | 66d? | finish no earlier than 2014-09-12 | R4 | 528h | 528h | LTE_CA_B19_B42_B42-Perf | PCG-33 | NTT DOCOMO | teruaki.toeda.zf@nttdocomo.com | Rel-12 | RP-64 | CA | LTE_CA_B19_B42_B42-Perf | RP-141084 |  |
| 2115 | 460.97 | **LTE Advanced 3 Band Carrier Aggregation (3DL/1UL) of Band 3, Band 42 and Band 42** | 198d? | 2014-06-16 A | 2015-03-15 A | 100% | 2014-06-13 | 2014-09-12 | 66d? |  | R4 | 4720h | 4720h | LTE_CA_B3_B42_B42 | PCG-33 | NTT DOCOMO | ANDO Kei (kei.andou.ye@nttdocomo.com) | Rel-12 | RP-64 | CA | LTE_CA_B3_B42_B42 |  |  |
| 2116 | 460.97.1 | Core part: LTE Advanced 3 Band Carrier Aggregation (3DL/1UL) of Band 3, Band 42 and Band 42 | 196d? | 2014-06-16 A | 2015-03-15 A | 100% | 2014-06-13 | 2014-09-12 | 66d? | finish no earlier than 2015-03-15 | R4 | 1568h | 1568h | LTE_CA_B3_B42_B42-Core | PCG-33 | NTT DOCOMO | ANDO Kei (kei.andou.ye@nttdocomo.com) | Rel-12 | RP-64 | CA | LTE_CA_B3_B42_B42-Core | RP-150013 |  |
| 2117 | 460.97.2 | Perf. Part: LTE Advanced 3 Band Carrier Aggregation (3DL/1UL) of Band 3, Band 42 and Band 42 | 196d? | 2014-06-16 A | 2015-03-15 A | 100% | 2014-06-13 | 2014-09-12 | 66d? | finish no earlier than 2016-03-15 | R4 | 1568h | 1568h | LTE_CA_B3_B42_B42-Perf | PCG-33 | NTT DOCOMO | ANDO Kei (kei.andou.ye@nttdocomo.com) | Rel-12 | RP-64 | CA | LTE_CA_B3_B42_B42-Perf | RP-150013 |  |
| 2118 | 460.98 | **LTE Advanced 3 Band Carrier Aggregation (3DL/1UL) of Band 1, Band 42 and Band 42** | 66d? | 2014-06-16 A | 2014-09-12 A | 100% | 2014-06-13 | 2014-09-12 | 66d? |  | R4 | 1584h | 1584h | LTE_CA_B1_B42_B42 | PCG-33 | NTT DOCOMO | ANDO Kei (kei.andou.ye@nttdocomo.com) | Rel-12 | RP-64 | CA | LTE_CA_B1_B42_B42 |  |  |
| 2119 | 460.98.1 | Core part: LTE Advanced 3 Band Carrier Aggregation (3DL/1UL) of Band 1, Band 42 and Band 42 | 66d? | 2014-06-16 A | 2014-09-12 A | 100% | 2014-06-13 | 2014-09-12 | 66d? | finish no earlier than 2014-09-12 | R4 | 528h | 528h | LTE_CA_B1_B42_B42-Core | PCG-33 | NTT DOCOMO | ANDO Kei (kei.andou.ye@nttdocomo.com) | Rel-12 | RP-64 | CA | LTE_CA_B1_B42_B42-Core | RP-141084 |  |
| 2120 | 460.98.2 | Perf. Part: LTE Advanced 3 Band Carrier Aggregation (3DL/1UL) of Band 1, Band 42 and Band 42 | 66d? | 2014-06-16 A | 2014-09-12 A | 100% | 2014-06-13 | 2014-09-12 | 66d? | finish no earlier than 2014-09-12 | R4 | 528h | 528h | LTE_CA_B1_B42_B42-Perf | PCG-33 | NTT DOCOMO | ANDO Kei (kei.andou.ye@nttdocomo.com) | Rel-12 | RP-64 | CA | LTE_CA_B1_B42_B42-Perf | RP-141084 |  |
| 2121 | 460.99 | **Additional bandwidth combination set for LTE Advanced intra-band contiguous Carrier Aggregation in Band 40 for 3DL** | 66d? | 2014-06-16 A | 2014-09-12 A | 100% | 2014-06-13 | 2014-09-12 | 66d? |  | R4 | 1096h | 1096h | LTE_CA_C_B40_3DL_BW | PCG-33 | TeliaSonera | Ralf.Schuh@TeliaSonera.com | Rel-12 | RP-64 | CA | LTE_CA_C_B40_3DL_BW |  |  |
| 2122 | 460.99.1 | Core part: Additional bandwidth combination set for LTE Advanced intra-band contiguous Carrier Aggregation in Band 40 for 3DL | 66d? | 2014-06-16 A | 2014-09-12 A | 100% | 2014-06-13 | 2014-09-12 | 66d? | finish no earlier than 2014-09-12 | R4 | 528h | 528h | LTE_CA_C_B40_3DL_BW-Core | PCG-33 | TeliaSonera | Ralf.Schuh@TeliaSonera.com | Rel-12 | RP-64 | CA | LTE_CA_C_B40_3DL_BW-Core | RP-141084 |  |
| 2123 | 460.99.2 | Perf. part: Additional bandwidth combination set for LTE Advanced intra-band contiguous Carrier Aggregation in Band 40 for 3DL | 5d? | 2014-09-08 A | 2014-09-12 A | 100% |  |  |  | finish no earlier than 2014-09-12 | R4 | 40h | 40h | LTE_CA_C_B40_3DL_BW-Perf | PCG-33 | TeliaSonera | Ralf.Schuh@TeliaSonera.com | Rel-12 | RP-65 |  | LTE_CA_C_B40_3DL_BW-Perf | RP-141084 |  |
| 2124 | 460.100 | **LTE Advanced inter-band Carrier Aggregation of Band 18 and Band 28** | 3d? | 2014-09-10 A | 2014-09-12 A | 100% | 2014-03-06 | 2015-03-13 | 267d? |  | R4 | 72h | 72h | LTE_CA_B18_B28 | PCG-33 | KDDI | Masaaki Obara (ms-obara@kddi.com) | Rel-12 | RP-65 | CA | LTE_CA_B18_B28 |  | Issam |
| 2125 | 460.100.1 | Core part: LTE Advanced inter-band Carrier Aggregation of Band 18 and Band 28 | 3d? | 2014-09-10 A | 2014-09-12 A | 100% | 2014-03-06 | 2015-03-13 | 267d? | finish no earlier than 2014-09-12 | R4 | 24h | 24h | LTE_CA_B18_B28-Core | PCG-33 | KDDI | Masaaki Obara (ms-obara@kddi.com) | Rel-12 | RP-65 | CA | LTE_CA_B18_B28-Core |  | Issam |
| 2126 | 460.100.2 | Perf. Part: LTE Advanced inter-band Carrier Aggregation of Band 18 and Band 28 | 3d? | 2014-09-10 A | 2014-09-12 A | 100% | 2014-03-06 | 2015-03-13 | 267d? | finish no earlier than 2014-09-12 | R4 | 24h | 24h | LTE_CA_B18_B28-Perf | PCG-33 | KDDI | Masaaki Obara (ms-obara@kddi.com) | Rel-12 | RP-65 | CA | LTE_CA_B18_B28-Perf |  | Issam |
| 2127 | 460.101 | **LTE Advanced inter-band Carrier Aggregation of Band 5 and Band 13** | 206d? | 2014-03-06 A | 2014-12-15 A | 100% | 2014-03-06 | 2014-12-05 | 197d? |  | R4 | 4896h | 4896h | LTE_CA_B5_B13 | PCG-32 | Intel | xinrong.wang@intel.com | Rel-12 | RP-63 | CA | LTE_CA_B5_B13 |  | Issam |
| 2128 | 460.101.1 | Core part: LTE Advanced inter-band Carrier Aggregation of Band 5 and Band 13 | 203d? | 2014-03-06 A | 2014-12-15 A | 100% | 2014-03-06 | 2014-12-05 | 197d? | finish no earlier than 2014-12-15 | R4 | 1624h | 1624h | LTE_CA_B5_B13-Core | PCG-32 | Intel | xinrong.wang@intel.com | Rel-12 | RP-63 | CA | LTE_CA_B5_B13-Core | RP-141732 | Issam |
| 2129 | 460.101.2 | Perf. part: LTE Advanced inter-band Carrier Aggregation of Band 5 and Band 13 | 203d? | 2014-03-06 A | 2014-12-15 A | 100% | 2014-03-06 | 2014-12-05 | 197d? | finish no earlier than 2014-12-15 | R4 | 1624h | 1624h | LTE_CA_B5_B13-Perf | PCG-32 | Intel | xinrong.wang@intel.com | Rel-12 | RP-63 | CA | LTE_CA_B5_B13-Perf | RP-141732 | Issam |
| 2130 | 460.102 | **LTE Advanced 3 Band Carrier Aggregation (3DL/1UL) of Band 2, Band 2 and Band 5** | 206d? | 2014-03-06 A | 2014-12-15 A | 100% | 2014-03-06 | 2014-12-05 | 197d? |  | R4 | 4912h | 4912h | LTE_CA_B2_B2_B5 | PCG-32 | Intel | peiling.zhang@intel.com | Rel-12 | RP-63 | CA | LTE_CA_B2_B2_B5 |  | Issam |
| 2131 | 460.102.1 | Core part: LTE Advanced 3 Band Carrier Aggregation (3DL/1UL) of Band 2, Band 2 and Band 5 | 205d? | 2014-03-06 A | 2014-12-15 A | 100% | 2014-03-06 | 2014-12-05 | 197d? | finish no earlier than 2014-12-15 | R4 | 1640h | 1640h | LTE_CA_B2_B2_B5-Core | PCG-32 | Intel | peiling.zhang@intel.com | Rel-12 | RP-63 | CA | LTE_CA_B2_B2_B5-Core | RP-141732 | Issam |
| 2132 | 460.102.2 | Perf. part: LTE Advanced 3 Band Carrier Aggregation (3DL/1UL) of Band 2, Band 2 and Band 5 | 203d? | 2014-03-06 A | 2014-12-15 A | 100% | 2014-03-06 | 2014-12-05 | 197d? | finish no earlier than 2014-12-15 | R4 | 1624h | 1624h | LTE_CA_B2_B2_B5-Perf | PCG-32 | Intel | peiling.zhang@intel.com | Rel-12 | RP-63 | CA | LTE_CA_B2_B2_B5-Perf | RP-141732 | Issam |

Notes:
- 2109: Inter-band CA 3DL / Impacted TSs and TRs: LTE
- 2110: RP#65 completed / Impacted TSs and TRs: 36.101, 36.104, 36.133, generic TR 36.853 (3 Band CA with 1UL)
- 2111: RP#65 completed / Impacted TSs and TRs: 36.141, 36.307
- 2112: Inter-band CA 3DL / Impacted TSs and TRs: LTE
- 2113: RP#65 completed / Impacted TSs and TRs: 36.101, 36.104, 36.133, generic TR 36.853 (3 Band CA with 1UL)
- 2114: RP#65 completed / Impacted TSs and TRs: 36.141, 36.307
- 2115: 3DL/1UL / Impacted TSs and TRs: LTE
- 2116: CD:Thu 11/12/14->Sun 15/03/15; Compl:50%->70%; Stat Rep: RP-141084->RP-141732 1st Apr 15: Compl:70%->100% 1st Apr 15: Stat Rep: RP-141732->RP-150013 / Impacted TSs and TRs: 36.101, 36.104, 36.133, generic TR 36.853 (3 Band CA with 1UL)
- 2117: CD:Thu 11/12/14->Tue 15/03/16; Compl:50%->70%; Stat Rep: RP-141084->RP-141732 1st Apr 15: Compl:70%->100% 1st Apr 15: CD:Tue 15/03/16->Sun 15/03/15 1st Apr 15: Stat Rep: RP-141732->RP-150013 / Impacted TSs and TRs: 36.141, 36.307
- 2118: Inter-band CA 3DL / Impacted TSs and TRs: LTE
- 2119: RP#65 completed / Impacted TSs and TRs: 36.101, 36.104, 36.133, generic TR 36.853 (3 Band CA with 1UL)
- 2120: RP#65 completed / Impacted TSs and TRs: 36.141, 36.307
- 2121: Inter-band CA 3DL / Impacted TSs and TRs: LTE
- 2122: RP#65 completed. Updated WID RP-140950=>RP-141127 / Impacted TSs and TRs: 36.101
- 2123: RP#65 updated WID RP-140950=>RP-141127 (added Perf. Part). Completed. / Impacted TSs and TRs: 36.307
- 2124: Inter-band CA 2DL / Impacted TSs and TRs: LTE
- 2125: RP#65 WID approved & completed. Triggered by revised Rel-13 WID RP-140451=>RP-141610 (take out B18_B28 for Rel-12 from the Rel-13 B1_B18_B28) / Impacted TSs and TRs: 36.101, 36.104, 36.133
- 2126: - / Impacted TSs and TRs: 36.141, 36.307
- 2127: Inter-band CA 2DL / Impacted TSs and TRs: LTE
- 2128: CD:Thu 12/03/15->Mon 15/12/14; Compl:50%->100%; Stat Rep: RP-141084->RP-141732; Release: Rel-13->Rel-12 / Impacted TSs and TRs: 36.101, 36.104, 36.133, generic TR 36.851 (2 Band CA with 1UL)
- 2129: CD:Thu 12/03/15->Mon 15/12/14; Compl:10%->100%; Stat Rep: RP-141084->RP-141732; Release: Rel-13->Rel-12 / Impacted TSs and TRs: 36.101, 36.133, 36.141, 36.307
- 2130: Inter-band CA 3DL / Impacted TSs and TRs: LTE
- 2131: CD:Thu 12/03/15->Mon 15/12/14; Compl:90%->100%; Stat Rep: RP-141084->RP-141732; Release: Rel-13->Rel-12 / Impacted TSs and TRs: 36.101, 36.104, 36.133, generic TR 36.853 (3 Band CA with 1UL)
- 2132: CD:Thu 12/03/15->Mon 15/12/14; Compl:10%->100%; Stat Rep: RP-141084->RP-141732; Release: Rel-13->Rel-12 / Impacted TSs and TRs: 36.101, 36.133, 36.141, 36.307

| ID | WBS | Task | Duration | Start | Finish | Complete | Baseline start | Baseline finish | Baseline duration | Constraint | Resources | Work | Actual work | Acronym | PCG approved | WI rapporteur name | WI rapporteur e-mail | Release | TSG approved | MCC resp | Special Focus Doc | Acronym_3GU_Export | Status Report |
| --- | --- | --- | --- | --- | --- | --- | --- | --- | --- | --- | --- | --- | --- | --- | --- | --- | --- | --- | --- | --- | --- | --- | --- |
| 2133 | 460.103 | **LTE Advanced 3 Band Carrier Aggregation (3DL/1UL) of Band 4, Band 4 and Band 5** | 206d? | 2014-03-06 A | 2014-12-15 A | 100% | 2014-03-06 | 2014-12-05 | 197d? |  | R4 | 4912h | 4912h | LTE_CA_B4_B4_B5 | PCG-32 | Intel | peiling.zhang@intel.com | Rel-12 | RP-63 | Issam | CA | LTE_CA_B4_B4_B5 |  |
| 2134 | 460.103.1 | Core part: LTE Advanced 3 Band Carrier Aggregation (3DL/1UL) of Band 4, Band 4 and Band 5 | 205d? | 2014-03-06 A | 2014-12-15 A | 100% | 2014-03-06 | 2014-12-05 | 197d? | finish no earlier than 2014-12-15 | R4 | 1640h | 1640h | LTE_CA_B4_B4_B5-Core | PCG-32 | Intel | peiling.zhang@intel.com | Rel-12 | RP-63 | Issam | CA | LTE_CA_B4_B4_B5-Core | RP-141732 |
| 2135 | 460.103.2 | Perf. part: LTE Advanced 3 Band Carrier Aggregation (3DL/1UL) of Band 4, Band 4 and Band 5 | 203d? | 2014-03-06 A | 2014-12-15 A | 100% | 2014-03-06 | 2014-12-05 | 197d? | finish no earlier than 2014-12-15 | R4 | 1624h | 1624h | LTE_CA_B4_B4_B5-Perf | PCG-32 | Intel | peiling.zhang@intel.com | Rel-12 | RP-63 | Issam | CA | LTE_CA_B4_B4_B5-Perf | RP-141732 |
| 2136 | 460.104 | **LTE Advanced 3 Band Carrier Aggregation (3DL/1UL) of Band 2, Band 5 and Band 13** | 206d? | 2014-03-06 A | 2014-12-15 A | 100% | 2014-03-06 | 2014-12-05 | 197d? |  | R4 | 4896h | 4896h | LTE_CA_B2_B5_B13 | PCG-32 | Intel | xinrong.wang@intel.com | Rel-12 | RP-63 | Issam | CA | LTE_CA_B2_B5_B13 |  |
| 2137 | 460.104.1 | Core part: LTE Advanced 3 Band Carrier Aggregation (3DL/1UL) of Band 2, Band 5 and Band 13 | 203d? | 2014-03-06 A | 2014-12-15 A | 100% | 2014-03-06 | 2014-12-05 | 197d? | finish no earlier than 2014-12-15 | R4 | 1624h | 1624h | LTE_CA_B2_B5_B13-Core | PCG-32 | Intel | xinrong.wang@intel.com | Rel-12 | RP-63 | Issam | CA | LTE_CA_B2_B5_B13-Core | RP-141732 |
| 2138 | 460.104.2 | Perf. part: LTE Advanced 3 Band Carrier Aggregation (3DL/1UL) of Band 2, Band 5 and Band 13 | 203d? | 2014-03-06 A | 2014-12-15 A | 100% | 2014-03-06 | 2014-12-05 | 197d? | finish no earlier than 2014-12-15 | R4 | 1624h | 1624h | LTE_CA_B2_B5_B13-Perf | PCG-32 | Intel | xinrong.wang@intel.com | Rel-12 | RP-63 | Issam | CA | LTE_CA_B2_B5_B13-Perf | RP-141732 |
| 2139 | 460.105 | **LTE Advanced 3 Band Carrier Aggregation (3DL/1UL) of Band 4, Band 5 and Band 13** | 206d? | 2014-03-06 A | 2014-12-15 A | 100% | 2014-03-06 | 2014-12-05 | 197d? |  | R4 | 4896h | 4896h | LTE_CA_B4_B5_B13 | PCG-32 | Intel | xinrong.wang@intel.com | Rel-12 | RP-63 | Issam | CA | LTE_CA_B4_B5_B13 |  |
| 2140 | 460.105.1 | Core part: LTE Advanced 3 Band Carrier Aggregation (3DL/1UL) of Band 4, Band 5 and Band 13 | 203d? | 2014-03-06 A | 2014-12-15 A | 100% | 2014-03-06 | 2014-12-05 | 197d? | finish no earlier than 2014-12-15 | R4 | 1624h | 1624h | LTE_CA_B4_B5_B13-Core | PCG-32 | Intel | xinrong.wang@intel.com | Rel-12 | RP-63 | Issam | CA | LTE_CA_B4_B5_B13-Core | RP-141732 |
| 2141 | 460.105.2 | Perf. part: LTE Advanced 3 Band Carrier Aggregation (3DL/1UL) of Band 4, Band 5 and Band 13 | 203d? | 2014-03-06 A | 2014-12-15 A | 100% | 2014-03-06 | 2014-12-05 | 197d? | finish no earlier than 2014-12-15 | R4 | 1624h | 1624h | LTE_CA_B4_B5_B13-Perf | PCG-32 | Intel | xinrong.wang@intel.com | Rel-12 | RP-63 | Issam | CA | LTE_CA_B4_B5_B13-Perf | RP-141732 |
| 2142 | 460.106 | **LTE Advanced 3 Band Carrier Aggregation (3DL/1UL) of Band 1, Band 3 and Band 26** | 206d? | 2014-03-06 A | 2014-12-15 A | 100% | 2014-03-06 | 2014-12-05 | 197d? |  | R4 | 4896h | 4896h | LTE_CA_B1_B3_B26 | PCG-32 | China Telecom | Zhao Dong (zhaodong@ctbri.com.cn) | Rel-12 | RP-63 | Issam | CA | LTE_CA_B1_B3_B26 |  |
| 2143 | 460.106.1 | Core part: LTE Advanced 3 Band Carrier Aggregation (3DL/1UL) of Band 1, Band 3 and Band 26 | 203d? | 2014-03-06 A | 2014-12-15 A | 100% | 2014-03-06 | 2014-12-05 | 197d? | finish no earlier than 2014-12-15 | R4 | 1624h | 1624h | LTE_CA_B1_B3_B26-Core | PCG-32 | China Telecom | Zhao Dong (zhaodong@ctbri.com.cn) | Rel-12 | RP-63 | Issam | CA | LTE_CA_B1_B3_B26-Core | RP-141732 |
| 2144 | 460.106.2 | Perf. part: LTE Advanced 3 Band Carrier Aggregation (3DL/1UL) of Band 1, Band 3 and Band 26 | 203d? | 2014-03-06 A | 2014-12-15 A | 100% | 2014-03-06 | 2014-12-05 | 197d? | finish no earlier than 2014-12-15 | R4 | 1624h | 1624h | LTE_CA_B1_B3_B26-Perf | PCG-32 | China Telecom | Zhao Dong (zhaodong@ctbri.com.cn) | Rel-12 | RP-63 | Issam | CA | LTE_CA_B1_B3_B26-Perf | RP-141732 |
| 2145 | 460.107 | **LTE Advanced 3 Band Carrier Aggregation (3DL/1UL) of Band 1, Band 18 and Band 28** | 206d? | 2014-03-06 A | 2014-12-15 A | 100% | 2014-03-06 | 2015-03-13 | 267d? |  | R4 | 4896h | 4896h | LTE_CA_B1_B18_B28 | PCG-32 | KDDI | Masaaki Obara (ms-obara@kddi.com) | Rel-12 | RP-63 | Issam | CA | LTE_CA_B1_B18_B28 |  |
| 2146 | 460.107.1 | Core part: LTE Advanced 3 Band Carrier Aggregation (3DL/1UL) of Band 1, Band 18 and Band 28 | 203d? | 2014-03-06 A | 2014-12-15 A | 100% | 2014-03-06 | 2015-03-13 | 267d? | finish no earlier than 2014-12-15 | R4 | 1624h | 1624h | LTE_CA_B1_B18_B28-Core | PCG-32 | KDDI | Masaaki Obara (ms-obara@kddi.com) | Rel-12 | RP-63 | Issam | CA | LTE_CA_B1_B18_B28-Core | RP-141732 |
| 2147 | 460.107.2 | Perf. part: LTE Advanced 3 Band Carrier Aggregation (3DL/1UL) of Band 1, Band 18 and Band 28 | 203d? | 2014-03-11 A | 2014-12-15 A | 100% | 2014-03-06 | 2015-03-13 | 267d? | finish no earlier than 2014-12-15 | R4 | 1624h | 1624h | LTE_CA_B1_B18_B28-Perf | PCG-32 | KDDI | Masaaki Obara (ms-obara@kddi.com) | Rel-12 | RP-63 | Issam | CA | LTE_CA_B1_B18_B28-Perf | RP-141732 |
| 2148 | 460.108 | **LTE Advanced 3 Band Carrier Aggregation (3DL/1UL) of Band 4, Band 7 and Band 12** | 132d? | 2014-06-18 A | 2014-12-15 A | 100% | 2014-06-13 | 2015-03-13 | 196d? |  | R4 | 3168h | 3168h | LTE_CA_B4_B7_B12 | PCG-33 | Rogers Wireless | pavlo.nebesny@rci.rogers.com | Rel-12 | RP-64 |  | CA | LTE_CA_B4_B7_B12 |  |
| 2149 | 460.108.1 | Core part: LTE Advanced 3 Band Carrier Aggregation (3DL/1UL) of Band 4, Band 7 and Band 12 | 132d? | 2014-06-18 A | 2014-12-15 A | 100% | 2014-06-13 | 2015-03-13 | 196d? | finish no earlier than 2014-12-15 | R4 | 1056h | 1056h | LTE_CA_B4_B7_B12-Core | PCG-33 | Rogers Wireless | pavlo.nebesny@rci.rogers.com | Rel-12 | RP-64 |  | CA | LTE_CA_B4_B7_B12-Core | RP-141732 |
| 2150 | 460.108.2 | Perf. Part: LTE Advanced 3 Band Carrier Aggregation (3DL/1UL) of Band 4, Band 7 and Band 12 | 132d? | 2014-06-18 A | 2014-12-15 A | 100% | 2014-06-13 | 2015-03-13 | 196d? | finish no earlier than 2014-12-15 | R4 | 1056h | 1056h | LTE_CA_B4_B7_B12-Perf | PCG-33 | Rogers Wireless | pavlo.nebesny@rci.rogers.com | Rel-12 | RP-64 |  | CA | LTE_CA_B4_B7_B12-Perf | RP-141732 |
| 2151 | 460.109 | **LTE Advanced 3 Band Carrier Aggregation (3DL/1UL) of Band 4, Band 4 and Band 7** | 132d? | 2014-06-18 A | 2014-12-15 A | 100% | 2014-06-13 | 2015-03-13 | 196d? |  | R4 | 3168h | 3168h | LTE_CA_B4_B4_B7 | PCG-33 | Rogers Wireless | pavlo.nebesny@rci.rogers.com | Rel-12 | RP-64 |  | CA | LTE_CA_B4_B4_B7 |  |
| 2152 | 460.109.1 | Core part: LTE Advanced 3 Band Carrier Aggregation (3DL/1UL) of Band 4, Band 4 and Band 7 | 132d? | 2014-06-18 A | 2014-12-15 A | 100% | 2014-06-13 | 2015-03-13 | 196d? | finish no earlier than 2014-12-15 | R4 | 1056h | 1056h | LTE_CA_B4_B4_B7-Core | PCG-33 | Rogers Wireless | pavlo.nebesny@rci.rogers.com | Rel-12 | RP-64 |  | CA | LTE_CA_B4_B4_B7-Core | RP-141732 |
| 2153 | 460.109.2 | Perf. Part: LTE Advanced 3 Band Carrier Aggregation (3DL/1UL) of Band 4, Band 4 and Band 7 | 132d? | 2014-06-18 A | 2014-12-15 A | 100% | 2014-06-13 | 2015-03-13 | 196d? | finish no earlier than 2014-12-15 | R4 | 1056h | 1056h | LTE_CA_B4_B4_B7-Perf | PCG-33 | Rogers Wireless | pavlo.nebesny@rci.rogers.com | Rel-12 | RP-64 |  | CA | LTE_CA_B4_B4_B7-Perf | RP-141732 |
| 2154 | 460.110 | **LTE Advanced 3 Band Carrier Aggregation (3DL/1UL) of Band 39, Band 41 and Band 41** | 134d? | 2014-06-16 A | 2014-12-15 A | 100% | 2014-06-13 | 2014-12-05 | 126d? |  | R4 | 3184h | 3184h | LTE_CA_B39_B41_B41 | PCG-33 | China Mobile | PAN Qun (panqun@chinamobile.com) | Rel-12 | RP-64 |  | CA | LTE_CA_B39_B41_B41 |  |
| 2155 | 460.110.1 | Core part: LTE Advanced 3 Band Carrier Aggregation (3DL/1UL) of Band 39, Band 41 and Band 41 | 132d? | 2014-06-16 A | 2014-12-15 A | 100% | 2014-06-13 | 2014-12-05 | 126d? | finish no earlier than 2014-12-15 | R4 | 1056h | 1056h | LTE_CA_B39_B41_B41-Core | PCG-33 | China Mobile | PAN Qun (panqun@chinamobile.com) | Rel-12 | RP-64 |  | CA | LTE_CA_B39_B41_B41-Core | RP-141732 |
| 2156 | 460.110.2 | Perf. Part: LTE Advanced 3 Band Carrier Aggregation (3DL/1UL) of Band 39, Band 41 and Band 41 | 132d? | 2014-06-18 A | 2014-12-15 A | 100% | 2014-06-13 | 2014-12-05 | 126d? | finish no earlier than 2014-12-15 | R4 | 1056h | 1056h | LTE_CA_B39_B41_B41-Perf | PCG-33 | China Mobile | PAN Qun (panqun@chinamobile.com) | Rel-12 | RP-64 |  | CA | LTE_CA_B39_B41_B41-Perf | RP-141732 |

Notes:
- 2133: Inter-band CA 3DL / Impacted TSs and TRs: LTE
- 2134: CD:Thu 12/03/15->Mon 15/12/14; Compl:90%->100%; Stat Rep: RP-141084->RP-141732; Release: Rel-13->Rel-12 / Impacted TSs and TRs: 36.101, 36.104, 36.133, generic TR 36.853 (3 Band CA with 1UL)
- 2135: CD:Thu 12/03/15->Mon 15/12/14; Compl:10%->100%; Stat Rep: RP-141084->RP-141732; Release: Rel-13->Rel-12 / Impacted TSs and TRs: 36.101, 36.133, 36.141, 36.307
- 2136: Inter-band CA 3DL / Impacted TSs and TRs: LTE
- 2137: CD:Thu 12/03/15->Mon 15/12/14; Compl:50%->100%; Stat Rep: RP-141084->RP-141732; Release: Rel-13->Rel-12 / Impacted TSs and TRs: 36.101, 36.104, 36.133, generic TR 36.853 (3 Band CA with 1UL)
- 2138: CD:Thu 12/03/15->Mon 15/12/14; Compl:10%->100%; Stat Rep: RP-141084->RP-141732; Release: Rel-13->Rel-12 / Impacted TSs and TRs: 36.101, 36.133, 36.141, 36.307
- 2139: Inter-band CA 3DL / Impacted TSs and TRs: LTE
- 2140: CD:Thu 12/03/15->Mon 15/12/14; Compl:50%->100%; Stat Rep: RP-141084->RP-141732; Release: Rel-13->Rel-12 / Impacted TSs and TRs: 36.101, 36.104, 36.133, generic TR 36.853 (3 Band CA with 1UL)
- 2141: CD:Thu 12/03/15->Mon 15/12/14; Compl:10%->100%; Stat Rep: RP-141084->RP-141732; Release: Rel-13->Rel-12 / Impacted TSs and TRs: 36.101, 36.133, 36.141, 36.307
- 2142: Inter-band CA 3DL / Impacted TSs and TRs: LTE
- 2143: CD:Thu 11/12/14->Mon 15/12/14; Compl:90%->100%; Stat Rep: RP-141084->RP-141732; Release: Rel-13->Rel-12 / Impacted TSs and TRs: 36.101, 36.104, 36.133, generic TR 36.853 (3 Band CA with 1UL)
- 2144: CD:Thu 11/12/14->Mon 15/12/14; Compl:90%->100%; Stat Rep: RP-141084->RP-141732; Release: Rel-13->Rel-12 / Impacted TSs and TRs: 36.141, 36.307
- 2145: Inter-band CA 3DL / Impacted TSs and TRs: LTE
- 2146: ; WID: RP-142043->RP-141788; Stat Rep: RP-141084->RP-141732; Release: Rel-13->Rel-12 / Impacted TSs and TRs: 36.101, 36.104, 36.133, generic TR 36.853 (3 Band CA with 1UL)
- 2147: ; WID: RP-142043->RP-141788; Stat Rep: RP-141084->RP-141732; Release: Rel-13->Rel-12 / Impacted TSs and TRs: 36.141, 36.307
- 2148: Inter-band CA 3DL/1UL / Impacted TSs and TRs: LTE
- 2149: CD:Thu 12/03/15->Mon 15/12/14; Compl:0%->100%; Stat Rep: RP-141084->RP-141732; Release: Rel-13->Rel-12 / Impacted TSs and TRs: 36.101, 36.104, 36.133, 36.307, generic TR 36.851 (2 Band CA with 1UL), generic TR 36.853 (3 Band CA with 1UL)
- 2150: CD:Thu 12/03/15->Mon 15/12/14; Compl:0%->100%; Stat Rep: RP-141084->RP-141732; Release: Rel-13->Rel-12 / Impacted TSs and TRs: 36.133, 36.141
- 2151: Inter-band CA 3DL/1UL / Impacted TSs and TRs: LTE
- 2152: CD:Thu 12/03/15->Mon 15/12/14; Compl:0%->100%; Stat Rep: RP-141084->RP-141732; Release: Rel-13->Rel-12 / Impacted TSs and TRs: 36.101, 36.104, 36.133, 36.307, generic TR 36.853 (3 Band CA with 1UL)
- 2153: CD:Thu 12/03/15->Mon 15/12/14; Compl:0%->100%; Stat Rep: RP-141084->RP-141732; Release: Rel-13->Rel-12 / Impacted TSs and TRs: 36.133, 36.141
- 2154: Inter-band CA 3DL/1UL / Impacted TSs and TRs: LTE
- 2155: ; WID: RP-140708->RP-142301; Stat Rep: RP-141084->RP-141732; Release: Rel-13->Rel-12 / Impacted TSs and TRs: 36.101, 36.104, 36.133, generic TR 36.853 (3 Band CA with 1UL)
- 2156: ; WID: RP-140708->RP-142301; Stat Rep: RP-141084->RP-141732; Release: Rel-13->Rel-12 / Impacted TSs and TRs: 36.141, 36.307

| ID | WBS | Task | Duration | Start | Finish | Complete | Remaining | Baseline start | Baseline finish | Baseline duration | Total slack | Constraint | Resources | Work | Actual work | Acronym | PCG approved | WI rapporteur name | WI rapporteur e-mail | Release | TSG approved | Special Focus Doc | Acronym_3GU_Export | Status Report | MCC resp | PCG stopped | TSG stopped |
| --- | --- | --- | --- | --- | --- | --- | --- | --- | --- | --- | --- | --- | --- | --- | --- | --- | --- | --- | --- | --- | --- | --- | --- | --- | --- | --- | --- |
| 2157 | 460.111 | **LTE Advanced 3 Band Carrier Aggregation (3DL/1UL) of Band 1, Band 41 and Band 41** | 132d? | 2014-06-18 A | 2014-12-15 | 50% | 66d? | 2014-06-13 | 2015-03-13 | 196d? | 871d |  | R4 | 3168h | 1584h | LTE_CA_B1_B41_B41 | PCG-33 | KDDI | Masaaki Obara (ms-obara@kddi.com) | Rel-12 | RP-64 | CA | LTE_CA_B1_B41_B41 |  |  |  |  |
| 2158 | 460.111.1 | Core part: LTE Advanced 3 Band Carrier Aggregation (3DL/1UL) of Band 1, Band 41 and Band 41 | 132d? | 2014-06-18 A | 2014-12-15 A | 100% |  | 2014-06-13 | 2015-03-13 | 196d? |  | finish no earlier than 2014-12-15 | R4 | 1056h | 1056h | LTE_CA_B1_B41_B41-Core | PCG-33 | KDDI | Masaaki Obara (ms-obara@kddi.com) | Rel-12 | RP-64 | CA | LTE_CA_B1_B41_B41-Core | RP-141732 |  |  |  |
| 2159 | 460.111.2 | Perf. Part: LTE Advanced 3 Band Carrier Aggregation (3DL/1UL) of Band 1, Band 41 and Band 41 | 132d? | 2014-06-18 | 2014-12-15 |  |  | 2014-06-13 | 2015-03-13 | 196d? | 871d | finish no earlier than 2014-12-15 | R4 | 1056h |  | LTE_CA_B1_B41_B41-Perf | PCG-33 | KDDI | Masaaki Obara (ms-obara@kddi.com) | Rel-12 | RP-64 | CA | LTE_CA_B1_B41_B41-Perf | RP-141732 |  |  |  |
| 2160 | 460.112 | **LTE Advanced 3 Band Carrier Aggregation (3DL/1UL) of Band 26, Band 41 and Band 41** | 132d? | 2014-06-18 A | 2014-12-15 | 50% | 66d? | 2014-06-13 | 2015-03-13 | 196d? | 871d |  | R4 | 3168h | 1584h | LTE_CA_B26_B41_B41 | PCG-33 | KDDI | Masaaki Obara (ms-obara@kddi.com) | Rel-12 | RP-64 | CA | LTE_CA_B26_B41_B41 |  |  |  |  |
| 2161 | 460.112.1 | Core part: LTE Advanced 3 Band Carrier Aggregation (3DL/1UL) of Band 26, Band 41 and Band 41 | 132d? | 2014-06-18 A | 2014-12-15 A | 100% |  | 2014-06-13 | 2015-03-13 | 196d? |  | finish no earlier than 2014-12-15 | R4 | 1056h | 1056h | LTE_CA_B26_B41_B41-Core | PCG-33 | KDDI | Masaaki Obara (ms-obara@kddi.com) | Rel-12 | RP-64 | CA | LTE_CA_B26_B41_B41-Core | RP-141732 |  |  |  |
| 2162 | 460.112.2 | Perf. Part: LTE Advanced 3 Band Carrier Aggregation (3DL/1UL) of Band 26, Band 41 and Band 41 | 132d? | 2014-06-18 | 2014-12-15 |  |  | 2014-06-13 | 2015-03-13 | 196d? | 871d | finish no earlier than 2014-12-15 | R4 | 1056h |  | LTE_CA_B26_B41_B41-Perf | PCG-33 | KDDI | Masaaki Obara (ms-obara@kddi.com) | Rel-12 | RP-64 | CA | LTE_CA_B26_B41_B41-Perf | RP-141732 |  |  |  |
| 2163 | 460.113 | **LTE Advanced 3 Band Carrier Aggregation (3DL/1UL) of Band 25, Band 41 and Band 41** | 68d? | 2014-09-15 A | 2014-12-15 A | 100% |  | 2014-06-13 | 2015-03-13 | 196d? |  |  | R4 | 1632h | 1632h | LTE_CA_B25_B41_B41 | PCG-33 | Alcatel-Lucent | Ng, Man Hung (man-hung.ng@alcatel-lucent.com) | Rel-12 | RP-65 | CA | LTE_CA_B25_B41_B41 |  |  |  |  |
| 2164 | 460.113.1 | Core part: LTE Advanced 3 Band Carrier Aggregation (3DL/1UL) of Band 25, Band 41 and Band 41 | 68d? | 2014-09-15 A | 2014-12-15 A | 100% |  | 2014-06-13 | 2015-03-13 | 196d? |  | finish no earlier than 2014-12-15 | R4 | 544h | 544h | LTE_CA_B25_B41_B41-Core | PCG-33 | Alcatel-Lucent | Ng, Man Hung (man-hung.ng@alcatel-lucent.com) | Rel-12 | RP-65 | CA | LTE_CA_B25_B41_B41-Core | RP-141732 |  |  |  |
| 2165 | 460.113.2 | Perf. Part: LTE Advanced 3 Band Carrier Aggregation (3DL/1UL) of Band 25, Band 41 and Band 41 | 68d? | 2014-09-15 A | 2014-12-15 A | 100% |  | 2014-06-13 | 2015-03-13 | 196d? |  | finish no earlier than 2014-12-15 | R4 | 544h | 544h | LTE_CA_B25_B41_B41-Perf | PCG-33 | Alcatel-Lucent | Ng, Man Hung (man-hung.ng@alcatel-lucent.com) | Rel-12 | RP-65 | CA | LTE_CA_B25_B41_B41-Perf | RP-141732 |  |  |  |
| 2166 | 460.114 | **LTE Advanced 3 Band Carrier Aggregation (3DL/1UL) of Band 39, Band 39 and Band 41** | 68d? | 2014-09-15 A | 2014-12-15 A | 100% |  | 2014-06-13 | 2015-03-13 | 196d? |  |  | R4 | 1632h | 1632h | LTE_CA_B39_B39_B41 | PCG-33 | China Mobile | PAN, Qun (panqun@chinamobile.com) | Rel-12 | RP-65 | CA | LTE_CA_B39_B39_B41 |  |  |  |  |
| 2167 | 460.114.1 | Core part: LTE Advanced 3 Band Carrier Aggregation (3DL/1UL) of Band 39, Band 39 and Band 41 | 68d? | 2014-09-15 A | 2014-12-15 A | 100% |  | 2014-06-13 | 2015-03-13 | 196d? |  | finish no earlier than 2014-12-15 | R4 | 544h | 544h | LTE_CA_B39_B39_B41-Core | PCG-33 | China Mobile | PAN, Qun (panqun@chinamobile.com) | Rel-12 | RP-65 | CA | LTE_CA_B39_B39_B41-Core | RP-141732 |  |  |  |
| 2168 | 460.114.2 | Perf. Part: LTE Advanced 3 Band Carrier Aggregation (3DL/1UL) of Band 39, Band 39 and Band 41 | 68d? | 2014-09-15 A | 2014-12-15 A | 100% |  | 2014-06-13 | 2015-03-13 | 196d? |  | finish no earlier than 2014-12-15 | R4 | 544h | 544h | LTE_CA_B39_B39_B41-Perf | PCG-33 | China Mobile | PAN, Qun (panqun@chinamobile.com) | Rel-12 | RP-65 | CA | LTE_CA_B39_B39_B41-Perf | RP-141732 |  |  |  |
| 2169 | 460.115 | **LTE Advanced 3 Band Carrier Aggregation (3DL/1UL) of Band 2, Band 2 and Band 29** | 68d? | 2014-09-15 A | 2014-12-15 A | 100% |  | 2014-06-13 | 2015-03-13 | 196d? |  |  | R4 | 1632h | 1632h | LTE_CA_B2_B2_B29 | PCG-33 | AT&T | marc.grant@att.com | Rel-12 | RP-65 | CA | LTE_CA_B2_B2_B29 |  |  |  |  |
| 2170 | 460.115.1 | Core part: LTE Advanced 3 Band Carrier Aggregation (3DL/1UL) of Band 2, Band 2 and Band 29 | 68d? | 2014-09-15 A | 2014-12-15 A | 100% |  | 2014-06-13 | 2015-03-13 | 196d? |  | finish no earlier than 2014-12-15 | R4 | 544h | 544h | LTE_CA_B2_B2_B29-Core | PCG-33 | AT&T | marc.grant@att.com | Rel-12 | RP-65 | CA | LTE_CA_B2_B2_B29-Core | RP-141732 |  |  |  |
| 2171 | 460.115.2 | Perf. Part: LTE Advanced 3 Band Carrier Aggregation (3DL/1UL) of Band 2, Band 2 and Band 29 | 68d? | 2014-09-15 A | 2014-12-15 A | 100% |  | 2014-06-13 | 2015-03-13 | 196d? |  | finish no earlier than 2014-12-15 | R4 | 544h | 544h | LTE_CA_B2_B2_B29-Perf | PCG-33 | AT&T | marc.grant@att.com | Rel-12 | RP-65 | CA | LTE_CA_B2_B2_B29-Perf | RP-141732 |  |  |  |
| 2172 | 460.116 | **LTE Advanced 3 Band Carrier Aggregation (3DL/1UL) of Band 2, Band 4 and Band 29** | 68d? | 2014-09-15 A | 2014-12-15 A | 100% |  | 2014-06-13 | 2015-03-13 | 196d? |  |  | R4 | 1632h | 1632h | LTE_CA_B2_B4_B29 | PCG-33 | Huawei | SHAN Huiping (shanhuiping@huawei.com) | Rel-12 | RP-65 | CA | LTE_CA_B2_B4_B29 |  |  |  |  |
| 2173 | 460.116.1 | Core part: LTE Advanced 3 Band Carrier Aggregation (3DL/1UL) of Band 2, Band 4 and Band 29 | 68d? | 2014-09-15 A | 2014-12-15 A | 100% |  | 2014-06-13 | 2015-03-13 | 196d? |  | finish no earlier than 2014-12-15 | R4 | 544h | 544h | LTE_CA_B2_B4_B29-Core | PCG-33 | Huawei | SHAN Huiping (shanhuiping@huawei.com) | Rel-12 | RP-65 | CA | LTE_CA_B2_B4_B29-Core | RP-141732 |  |  |  |
| 2174 | 460.116.2 | Perf. Part: LTE Advanced 3 Band Carrier Aggregation (3DL/1UL) of Band 2, Band 4 and Band 29 | 68d? | 2014-09-15 A | 2014-12-15 A | 100% |  | 2014-06-13 | 2015-03-13 | 196d? |  | finish no earlier than 2014-12-15 | R4 | 544h | 544h | LTE_CA_B2_B4_B29-Perf | PCG-33 | Huawei | SHAN Huiping (shanhuiping@huawei.com) | Rel-12 | RP-65 | CA | LTE_CA_B2_B4_B29-Perf | RP-141732 |  |  |  |
| 2175 | 461 | UE Conformance Test Aspects – Further Rel-12 configurations for LTE Advanced Carrier Aggregation | 393d? | 2013-09-15 A | 2015-03-15 A | 100% |  | 2013-09-09 | 2014-12-05 | 327d? |  | finish no earlier than 2015-03-15 | R5 | 3144h | 3144h | LTE_CA_Rel12-UEConTest | PCG-31 | Microsoft | jussi.kuusisto@microsoft.com | Rel-12 | RP-61 | CA | LTE_CA_Rel12-UEConTest | RP-150076 | Ingbert |  |  |
| 2176 | 462 | UE Conformance Test Aspects – Further Rel-12 configurations for LTE Advanced Carrier Aggregation with 3DL | 394d? | 2014-09-15 A | 2016-03-15 A | 100% |  |  |  |  |  | finish no earlier than 2016-03-15 | R5 | 3152h | 3152h | LTE_CA_Rel12_3DL-UEConTest | PCG-33 | Microsoft | jussi.kuusisto@microsoft.com | Rel-12 | RP-65 | CA | LTE_CA_Rel12_3DL-UEConTest | RP-151464 |  |  |  |
| 2177 | 463 | **Deleted - Carrier based HetNet ICIC for LTE** | 595d? | 2011-03-18 A | 2013-06-14 A | 100% |  | 2011-03-18 | 2013-06-14 | 595d? |  |  | R3; R1; R2 | 28560h | 28560h | LTE_CA_HetNet_ICIC | PCG-26 | Nokia Siemens Networks | krzysztof.kordybach@nsn.com | Rel-12 | RP-51 |  | LTE_CA_HetNet_ICIC |  | Juha | PCG-31 | RP-60 |
| 2178 | 463.1 | Deleted - Core part: Carrier based HetNet ICIC for LTE | 595d? | 2011-03-18 A | 2013-06-14 A | 100% |  | 2011-03-18 | 2013-06-14 | 595d? |  | finish no earlier than 2013-06-14 | R3; R1; R2 | 14280h | 14280h | LTE_CA_HetNet_ICIC-Core | PCG-26 | Nokia Siemens Networks | krzysztof.kordybach@nsn.com | Rel-12 | RP-51 |  | LTE_CA_HetNet_ICIC-Core | RP-130500 | Juha | PCG-31 | RP-60 |
| 2179 | 464 | **LTE in the US Wireless Communications Service (WCS) Band 30** | 600d? | 2012-09-12 A | 2014-12-15 A | 100% |  | 2012-09-12 | 2014-12-05 | 591d? |  |  | R4; R2; R5 | 20312h | 20312h | LTE_WCS_band | PCG-29 | AT&T | marc.grant@att.com | Rel-12 | RP-57 |  | LTE_WCS_band |  | Issam |  |  |
| 2180 | 464.1 | Core part: LTE in the US Wireless Communications Service (WCS) Band 30 | 202d? | 2012-09-12 A | 2013-06-14 A | 100% |  | 2012-09-12 | 2013-06-14 | 202d? |  | finish no earlier than 2013-06-14 | R4; R2 | 3232h | 3232h | LTE_WCS_band-Core | PCG-29 | AT&T | marc.grant@att.com | Rel-12 | RP-57 |  | LTE_WCS_band-Core | RP-130569 | Issam |  |  |
| 2181 | 464.2 | Perf. Part: LTE in the US Wireless Communications Service (WCS) Band 30 | 201d? | 2012-09-13 A | 2013-06-14 A | 100% |  | 2012-09-13 | 2013-06-14 | 201d? |  | finish no earlier than 2013-06-14 | R4 | 1608h | 1608h | LTE_WCS_band-Perf | PCG-29 | AT&T | marc.grant@att.com | Rel-12 | RP-57 |  | LTE_WCS_band-Perf | RP-130570 | Issam |  |  |
| 2182 | 464.3 | Test Part: LTE in the US Wireless Communications Service (WCS) Band 30 | 134d? | 2014-06-15 A | 2014-12-15 A | 100% |  | 2014-06-13 | 2014-12-05 | 126d? |  | finish no earlier than 2014-12-15 | R5 | 1072h | 1072h | LTE_WCS_band-UEConTest | PCG-33 | Ericsson | fredrik.sundstrom@ericsson.com | Rel-12 | RP-64 |  | LTE_WCS_band-UEConTest | RP-141773 |  |  |  |

Notes:
- 2157: Inter-band CA 3DL/1UL / Impacted TSs and TRs: LTE
- 2158: ; WID: RP-142043->RP-142297; Stat Rep: RP-141084->RP-141732; Release: Rel-13->Rel-12 / Impacted TSs and TRs: 36.101, 36.104, 36.133, generic TR 36.853 (3 Band CA with 1UL)
- 2159: Compl:100%->0%; WID: RP-142043->RP-142297; Stat Rep: RP-141084->RP-141732; Release: Rel-13->Rel-12 / Impacted TSs and TRs: 36.141, 36.307
- 2160: Inter-band CA 3DL/1UL / Impacted TSs and TRs: LTE
- 2161: ; WID: RP-142043->RP-142298; Stat Rep: RP-141084->RP-141732; Release: Rel-13->Rel-12 / Impacted TSs and TRs: 36.101, 36.104, 36.133, generic TR 36.853 (3 Band CA with 1UL)
- 2162: Compl:100%->0%; WID: RP-142043->RP-142298; Stat Rep: RP-141084->RP-141732; Release: Rel-13->Rel-12 / Impacted TSs and TRs: 36.141, 36.307
- 2163: Inter-band CA 3DL/1UL / Impacted TSs and TRs: LTE
- 2164: ; WID: RP-142043->RP-142018; Stat Rep: -->RP-141732; Release: Rel-13->Rel-12 / Impacted TSs and TRs: 36.101, 36.104, 36.307, New TR 36.833-x-yz
- 2165: ; WID: RP-142043->RP-142018; Stat Rep: -->RP-141732; Release: Rel-13->Rel-12 / Impacted TSs and TRs: 36.141
- 2166: Inter-band CA 3DL/1UL / Impacted TSs and TRs: LTE
- 2167: ; WID: RP-141288->RP-142302; Stat Rep: -->RP-141732; Release: Rel-13->Rel-12 / Impacted TSs and TRs: 36.101, 36.104, 36.133, New TR 36.8xx
- 2168: ; WID: RP-141288->RP-142302; Stat Rep: -->RP-141732; Release: Rel-13->Rel-12 / Impacted TSs and TRs: 36.141, 36.307
- 2169: Inter-band CA 3DL/1UL / Impacted TSs and TRs: LTE
- 2170: CD:Thu 11/12/14->Mon 15/12/14; Compl:0%->100%; Stat Rep: -->RP-141732; Release: Rel-13->Rel-12 / Impacted TSs and TRs: 36.101, 36.104, 36.133, New TR 36.8xx
- 2171: CD:Thu 11/12/14->Mon 15/12/14; Compl:0%->100%; Stat Rep: -->RP-141732; Release: Rel-13->Rel-12 / Impacted TSs and TRs: 36.141, 36.307
- 2172: Inter-band CA 3DL/1UL / Impacted TSs and TRs: LTE
- 2173: CD:Fri 11/12/15->Mon 15/12/14; Compl:0%->100%; Stat Rep: -->RP-141732; Release: Rel-13->Rel-12 / Impacted TSs and TRs: 36.101, 36.104, 36.133, New TR 36.8xx
- 2174: CD:Thu 11/12/14->Mon 15/12/14; Compl:0%->100%; Stat Rep: -->RP-141732; Release: Rel-13->Rel-12 / Impacted TSs and TRs: 36.141, 36.307
- 2175: ; Stat Rep: RP-141444->RP-141774 1st Apr 15: Compl:75%->100% 1st Apr 15: WID: RP-140621->RP-150077 1st Apr 15: Stat Rep: RP-141774->RP-150076 / Impacted TSs and TRs: 36.508, 36.521-1, 36.521-2, 36.521-3, 36.523-1, 36.523-2, 36.523-3, 37.571-1, 37.571-3, 37.571-5
- 2176: ; Stat Rep: -->RP-141775 1st Apr 15: Compl:6%->12% 1st Apr 15: CD:Tue 15/09/15->Tue 15/12/15 1st Apr 15: WID: RP-142231->RP-150079 1st Apr 15: Stat Rep: RP-141775->RP-150078 03/07/15: Compl:12%->35% 03/07/15: WID: RP-150079->RP-150594 03/07/15: Stat Re...; ; ; ; ; ; ; ; ; ; ; ; ; ; ; ; ; ; ; ; ; ; ; ; ; ; ; ; ; ; ; ; ; ; ; ; ; ; ; ; ; ; ; ; ; ; ; ; ; ; ; ; ; ; ; ; ; ; ; ; ; ; ; ; ; ; ; ; ; 22/3/16: Compl:90%->100% / Impacted TSs and TRs: 36.508, 36.521-1, 36.521-2, 36.521-3, 36.523-1, 36.523-2, 36.523-3, 37.571-1, 37.571-3, 37.571-5
- 2177: RP#60 stopped. RP#58 on hold til June 2013 / Impacted TSs and TRs: LTE
- 2178: RP#60 stopped at 40% completion. RP#58 on hold til June 2013 / Impacted TSs and TRs: 36.300, 36.413, 36.420, 36.423
- 2179: RP#58 RP-121701 work can start based on FCC Order (FCC-12-130) http://hraunfoss.fcc.gov/edocs_public/attachmatch/FCC-12-130A1.pdf / Impacted TSs and TRs: LTE
- 2180: RP#60 completed. Updated WID RP-121419=>RP-130843 / Impacted TSs and TRs: 36.101, 36.104, 36.113, 36.124, 36.133, 36.307, 36.331, new TR 36.846
- 2181: RP#60 completed. Updated WID RP-121419=>RP-130843 / Impacted TSs and TRs: 36.101, 36.133, 36.141
- 2182: ; Stat Rep: RP-141166->RP-141773 / Impacted TSs and TRs: 36.508, 36.521-1, 36.521-2, 36.521-3, 36.523-2, 36.523-3, 37.571-1

| ID | WBS | Task | Duration | Start | Finish | Complete | Remaining | Baseline start | Baseline finish | Baseline duration | Total slack | Constraint | Resources | Work | Actual work | Acronym | PCG approved | WI rapporteur name | WI rapporteur e-mail | Release | TSG approved | MCC resp | Acronym_3GU_Export | Status Report | PCG stopped | TSG stopped | Special Focus Doc |
| --- | --- | --- | --- | --- | --- | --- | --- | --- | --- | --- | --- | --- | --- | --- | --- | --- | --- | --- | --- | --- | --- | --- | --- | --- | --- | --- | --- |
| 2183 | 465 | **Introduction of LTE 450 MHz band in Brazil** | 331d? | 2012-09-11 A | 2013-12-06 A | 100% |  | 2012-09-11 | 2013-12-06 | 331d? |  |  | R4; R5 | 10000h | 10000h | LTE450_Brazil | PCG-29 | Huawei | Liehai Liu (liuliehai@huawei.com) | Rel-12 | RP-57 | Issam | LTE450_Brazil |  |  |  |  |
| 2184 | 465.1 | Core part: Introduction of LTE 450 MHz band in Brazil | 201d? | 2012-09-11 A | 2013-06-14 A | 100% |  | 2012-09-11 | 2013-06-14 | 201d? |  | finish no earlier than 2013-06-14 | R4 | 1608h | 1608h | LTE450_Brazil-Core | PCG-29 | Huawei | Liehai Liu (liuliehai@huawei.com) | Rel-12 | RP-57 | Issam | LTE450_Brazil-Core | RP-130567 |  |  |  |
| 2185 | 465.2 | Perf. part: Introduction of LTE 450 MHz band in Brazil | 261d? | 2012-09-13 A | 2013-09-06 A | 100% |  | 2012-09-13 | 2013-09-06 | 261d? |  | finish no earlier than 2013-09-06 | R4 | 2088h | 2088h | LTE450_Brazil-Perf | PCG-29 | Huawei | Liehai Liu (liuliehai@huawei.com) | Rel-12 | RP-57 | Issam | LTE450_Brazil-Perf | RP-131070 |  |  |  |
| 2186 | 465.3 | Test part: Introduction of LTE 450 MHz band in Brazil | 126d? | 2013-06-18 A | 2013-12-06 A | 100% |  | 2013-06-18 | 2013-12-06 | 126d? |  | finish no earlier than 2013-12-06 | R5 | 1008h | 1008h | LTE450_Brazil-UEConTest | PCG-31 | Huawei | Xiang Li (tricia.li@huawei.com) | Rel-12 | RP-60 | Ingbert | LTE450_Brazil-UEConTest | RP-131457 |  |  |  |
| 2187 | 466 | **Further Downlink MIMO Enhancement for LTE Advanced** | 927d? | 2012-09-11 A | 2016-03-15 | 99% | 0d? | 2012-09-11 | 2014-09-12 | 532d? | 0d |  | R1; R4 | 25384.8h | 20159.7h | LTE_eDL_MIMO_enh | PCG-29 | Alcatel-Lucent | Min Zhang (min.hs.zhang@alcatel-lucent.com) | Rel-12 | RP-57 | Patrick | LTE_eDL_MIMO_enh |  |  |  |  |
| 2188 | 466.1 | Core part: Further Downlink MIMO Enhancement for LTE Advanced | 464d? | 2012-09-11 A | 2014-06-13 A | 100% |  | 2012-09-11 | 2014-06-13 | 464d? |  | finish no earlier than 2014-06-13 | R1 | 3696.76h | 3696.76h | LTE_eDL_MIMO_enh-Core | PCG-29 | Alcatel-Lucent | Min Zhang (min.hs.zhang@alcatel-lucent.com) | Rel-12 | RP-57 | Patrick | LTE_eDL_MIMO_enh-Core | RP-140652 |  |  |  |
| 2189 | 466.2 | Perf. part: Further Downlink MIMO Enhancement for LTE Advanced | 595d? | 2012-09-15 A | 2014-12-15 A | 100% |  | 2012-09-18 | 2014-09-12 | 526d? |  | finish no earlier than 2014-12-15 | R4 | 4760h | 4760h | LTE_eDL_MIMO_enh-Perf | PCG-29 | Alcatel-Lucent | ren.da@alcatel-lucent.com | Rel-12 | RP-57 | Issam | LTE_eDL_MIMO_enh-Perf | RP-142042 |  |  |  |
| 2190 | 466.3 | UE Conformance Test Aspects - Further DL MIMO Enhancement for LTE-Advanced | 262d? | 2015-03-16 A | 2016-03-15 A | 100% |  |  |  |  |  | finish no earlier than 2016-03-15 | R5 | 2096h | 2096h | LTE_eDL_MIMO_enh-UEConTest | PCG-34 | ZTE |  | Rel-12 | RP-67 |  |  | RP-151189 |  |  |  |
| 2191 | 467 | **Deleted - New Carrier Type for LTE** | 265d? | 2012-09-11 A | 2013-09-06 A | 100% |  | 2012-09-11 | 2013-09-06 | 265d? |  |  | R1; R2; R4 | 14808h | 14808h | LTE_NCT | PCG-29 | Ericsson | daniel.n.larsson@ericsson.com | Rel-12 | RP-57 | Patrick | LTE_NCT |  | PCG-31 | RP-61 |  |
| 2192 | 467.1 | Deleted - Core part: New Carrier Type for LTE | 265d? | 2012-09-11 A | 2013-09-06 A | 100% |  | 2012-09-11 | 2013-09-06 | 265d? |  | finish no earlier than 2013-09-06 | R1; R2; R4 | 6360h | 6360h | LTE_NCT-Core | PCG-29 | Ericsson | daniel.n.larsson@ericsson.com | Rel-12 | RP-57 | Patrick | LTE_NCT-Core | RP-130984 | PCG-31 | RP-61 |  |
| 2193 | 467.2 | Deleted - Perf. part: New Carrier Type for LTE | 261d? | 2012-09-17 A | 2013-09-06 A | 100% |  | 2012-09-17 | 2013-09-06 | 261d? |  | finish no earlier than 2013-09-06 | R4 | 2088h | 2088h | LTE_NCT-Perf | PCG-29 | Ericsson | daniel.n.larsson@ericsson.com | Rel-12 | RP-57 | Issam | LTE_NCT-Perf | RP-130985 | PCG-31 | RP-61 |  |
| 2194 | 468 | **Further Enhancements to LTE TDD for DL-UL Interference Management and Traffic Adaptation** | 1124d? | 2012-12-07 A | 2017-03-15 | 86% | 154.64d? | 2012-12-07 | 2014-12-05 | 527d? | 283d |  | R1; R2; R3; R4 | 45698.6h | 12479.7h | LTE_TDD_eIMTA | PCG-30 | CATT | Zukang Shen (shenzukang@catt.cn) | Rel-12 | RP-58 | Patrick | LTE_TDD_eIMTA |  |  |  | Small cell |
| 2195 | 468.1 | Core part: Further Enhancements to LTE TDD for DL-UL Interference Management and Traffic Adaptation | 24.58d? | 2012-12-07 A | 2014-06-13 A | 100% |  | 2012-12-07 | 2014-06-13 | 24.58d? |  | finish no earlier than 2014-06-13 | R1; R2; R3; R4 | 786.56h | 786.56h | LTE_TDD_eIMTA-Core | PCG-30 | CATT | Zukang Shen (shenzukang@catt.cn) | Rel-12 | RP-58 | Patrick | LTE_TDD_eIMTA-Core | RP-140724 |  |  | Small cell |
| 2196 | 468.2 | Perf. part: Further Enhancements to LTE TDD for DL-UL Interference Management and Traffic Adaptation | 725d? | 2012-12-15 A | 2015-09-15 A | 100% |  | 2012-12-07 | 2014-12-05 | 527d? |  | finish no earlier than 2015-09-15 | R4 | 5800h | 5800h | LTE_TDD_eIMTA-Perf | PCG-30 | CATT | Zukang Shen (shenzukang@catt.cn) | Rel-12 | RP-58 | Patrick | LTE_TDD_eIMTA-Perf | RP-151447 |  |  | Small cell |
| 2197 | 468.3 | UE Conformance Test Aspects - Further Enhancements to LTE TDD for DL-UL Interference Management and Traffic Adaptation | 393d? | 2015-09-15 A | 2017-03-15 | 60% | 157.2d? |  |  |  | 283d | finish no earlier than 2017-03-15 | R5 | 3144h | 1886.4h | LTE_TDD_eIMTA-UEConTest | PCG-35 | CATT |  | Rel-12 | RP-69 |  |  |  |  |  |  |
| 2198 | 469 | **HetNet Mobility enhancements for LTE** | 641.65d? | 2012-04-13 A | 2014-09-12 A | 100% |  | 2012-04-13 | 2014-09-12 | 640.65d? |  |  | R2; R4 | 11624h | 11624h | HetNet_eMOB_LTE | PCG-30 | Alcatel-Lucent | sudeep.palat@alcatel-lucent.com | Rel-12 | RP-58 | Yong-Jun | HetNet_eMOB_LTE |  |  |  |  |
| 2199 | 469.1 | Core part: HetNet Mobility enhancements for LTE | 263.5d? | 2012-04-13 A | 2014-09-12 A | 100% |  | 2012-04-13 | 2014-09-12 | 263.5d? |  | finish no earlier than 2014-09-12 | R2; R4 | 4216h | 4216h | HetNet_eMOB_LTE-Core | PCG-30 | Alcatel-Lucent | sudeep.palat@alcatel-lucent.com | Rel-12 | RP-58 | Yong-Jun | HetNet_eMOB_LTE-Core | RP-141413 |  |  |  |
| 2200 | 470 | **Further enhancements for HeNB mobility-X2-GW** | 401d? | 2012-12-10 A | 2014-06-13 A | 100% |  | 2012-12-10 | 2014-06-13 | 401d? |  |  | R3 | 6408h | 6408h | EHNB_enh2_X2GW | PCG-30 | Alcatel-Lucent | Philippe.Godin@alcatel-lucent.com | Rel-12 | RP-58 | Juha | EHNB_enh2_X2GW |  |  |  | HNB |
| 2201 | 470.1 | Core part: Further enhancements for HeNB mobility-X2-GW | 400d? | 2012-12-10 A | 2014-06-13 A | 100% |  | 2012-12-10 | 2014-06-13 | 400d? |  | finish no earlier than 2014-06-13 | R3 | 3200h | 3200h | EHNB_enh2_X2GW-Core | PCG-30 | Alcatel-Lucent | Philippe.Godin@alcatel-lucent.com | Rel-12 | RP-58 | Juha | EHNB_enh2_X2GW-Core | RP-140592 |  |  | HNB |
| 2202 | 471 | **8 Rx Antennas for LTE UL** | 265d? | 2012-12-10 A | 2013-12-06 A | 100% |  | 2012-12-10 | 2013-12-06 | 265d? |  |  | R4 | 4208h | 4208h | LTE_UL_8Rx | PCG-30 | China Telecom | Shan Yang (yangshan@ctbri.com.cn) | Rel-12 | RP-58 | Issam | LTE_UL_8Rx |  |  |  |  |
| 2203 | 471.1 | Perf. part: 8 Rx Antennas for LTE UL | 261d? | 2012-12-10 A | 2013-12-06 A | 100% |  | 2012-12-10 | 2013-12-06 | 261d? |  | finish no earlier than 2013-12-06 | R4 | 2088h | 2088h | LTE_UL_8Rx-Perf | PCG-30 | China Telecom | Shan Yang (yangshan@ctbri.com.cn) | Rel-12 | RP-58 | Issam | LTE_UL_8Rx-Perf | RP-131523 |  |  |  |
| 2204 | 472 | **Low cost & enhanced coverage MTC UE for LTE** | 922d? | 2013-06-15 A | 2016-12-15 | 99% | 7.32d? | 2013-06-20 | 2015-03-13 | 456d? | 347d |  | R1; R2; R4 | 34104h | 12521.6h | LC_MTC_LTE | PCG-31 | Vodafone | eric.bouton@vodafone.com | Rel-12 | RP-60 | Patrick | LC_MTC_LTE |  |  |  | MTC, M2M |
| 2205 | 472.1 | Core part: Low cost & enhanced coverage MTC UE for LTE | 174.67d? | 2013-06-15 A | 2014-12-15 A | 100% |  | 2013-10-15 | 2014-09-12 | 108.67d? |  | finish no earlier than 2014-12-15 | R1; R2; R4 | 4192h | 4192h | LC_MTC_LTE-Core | PCG-31 | Vodafone | eric.bouton@vodafone.com | Rel-12 | RP-60 | Patrick | LC_MTC_LTE-Core | RP-142024 |  |  | MTC, M2M |
| 2206 | 472.2 | Perf. part: Low cost & enhanced coverage MTC UE for LTE | 522d? | 2013-06-15 A | 2015-06-15 A | 100% |  | 2013-06-20 | 2015-03-13 | 456d? |  | finish no earlier than 2015-06-15 | R4 | 4176h | 4176h | LC_MTC_LTE-Perf | PCG-31 | Vodafone | eric.bouton@vodafone.com | Rel-12 | RP-60 | Issam | LC_MTC_LTE-Perf | RP-150915 |  |  | MTC, M2M |
| 2207 | 472.3 | UE Conformance Test Aspects - Low cost & enhanced coverage MTC UE for LTE | 460d? | 2015-03-16 A | 2016-12-15 | 98% | 9.2d? |  |  |  | 347d | finish no earlier than 2016-12-15 | R5 | 3680h | 3606.4h | LC_MTC_LTE-UEConTest | PCG-34 | Ericsson |  | Rel-12 | RP-67 |  |  | RP-151165 |  |  |  |

Notes:
- 2183: - / Impacted TSs and TRs: LTE
- 2184: RP#60 completed. TR 36.840 v100 for 1-step Approval / Impacted TSs and TRs: 36.101, 36.104, 36.113, 36.124, 36.133, 37.104, 37.113, 36.307, new TR 36.840
- 2185: RP#61 completed / Impacted TSs and TRs: 36.133, 36.141, 37.141
- 2186: RP#62 completed / Impacted TSs and TRs: 36.508, 36.521-1, 36.521-2, 36.521-3
- 2187: Stage 3 / Impacted TSs and TRs: LTE
- 2188: RP#64 completed / Impacted TSs and TRs: 36.211, 36.212, 36.213, 36.331
- 2189: ; CD:Fri 12/06/15->Mon 15/06/15; WID: RP-141966->RP-142235; Stat Rep: RP-141378->RP-142042 / Impacted TSs and TRs: 36.101
- 2190: 03/07/15: Compl:0%->10% 03/07/15: Stat Rep: ->RP-150606 29/09/15: Compl:10%->70% 29/09/15: Stat Rep: RP-150606->RP-1511891/1/16: Compl:70%->75%...
- 2191: RP#61 stopped. Continue discussion on use cases and requirements for a NCT in LTE beyond Rel-12. Action: Ericsson to provide at RP#62 a summary of work done so far / Impacted TSs and TRs: LTE
- 2192: RP#61 stopped at 20% completion / Impacted TSs and TRs: 36.101, 36.104, 36.133, 36.211, 36.212, 36.213, 36.321, 36.331
- 2193: RP#61 stopped at 0% completion / Impacted TSs and TRs: 36.101, 36.104, 36.133, 36.141
- 2194: Stage 3. Triggered by Rel-11 TR 36.828 Study on Further Enhancements to LTE TDD for DL-UL Interference Management and Traffic Adaptation (FS_LTE_TDD_eIMTA) UID_510039 / Impacted TSs and TRs: LTE
- 2195: RP#64 completed / Impacted TSs and TRs: 36.101, 36.104, 36.133, 36.211, 36.212, 36.213, 36.214, 36.300, 36.321, 36.331, 36.413, 36.423
- 2196: ; CD:Thu 18/06/15->Mon 15/06/15; WID: RP-141966->RP-142235; Stat Rep: RP-141342->RP-141948 1st Apr 15: Compl:30%->55% 1st Apr 15: Stat Rep: RP-141948->RP-150154 03/07/15: Compl:55%->95% 03/07/15: CD:Mon 15/06/15->Tue 15/09/15 03/07/15: Stat Rep: RP-150... 29/09/15: Compl:95%->100% 29/09/15: Stat Rep: RP-150651->RP-151447 / Impacted TSs and TRs: 36.101, 36.104, 36.133, 36.141
- 2197: tested: REL-12 WI LTE_TDD_eIMTA-Core;1/1/16: Compl:0%->5%; 22/3/16: Compl:5%->15%;...; ;...
- 2198: Stage 3. Triggered by Rel-11 TR 36.839 Study on HetNet mobility enhancements for LTE (FS_HetNet_eMOB_LTE) / Impacted TSs and TRs: LTE
- 2199: SP#65 completed / Impacted TSs and TRs: 36.133, 36.304, 36.331
- 2200: Rel-10 H(e)NB Mobility Enhancements adds signalling via horizontal RAN interfaces (Iurh, X2) to support H(e)NB to H(e)NB mobility. Rel-11 TR37.803 triggered WI UID_560014 partly completed in Rel-11; remaining work including solution definition is Rel-12 / Impacted TSs and TRs: LTE
- 2201: RP#64 completed / Impacted TSs and TRs: 36.300, 36.413, 36.423
- 2202: WI has perf. part only (as change from 4Rx to 8Rx has no Core spec impact) / Impacted TSs and TRs: LTE
- 2203: RP#62 completed / Impacted TSs and TRs: 36.104, 36.141
- 2204: Triggered by Rel-11 TR 36.888 (FS_LC_MTC_UE) / Impacted TSs and TRs: LTE
- 2205: ; CD:Thu 18/06/15->Mon 15/06/15; WID: RP-130848->RP-140522; Stat Rep: RP-141221->RP-142024 / Impacted TSs and TRs: 36.101, 36.104, 36.133, 36.201, 36.211, 36.212, 36.213, 36.300, 36.302, 36.306, 36.321, 36.331
- 2206: ; CD:Thu 18/06/15->Mon 15/06/15; WID: RP-130848->RP-140522; Stat Rep: RP-141221->RP-142024 1st Apr 15: Compl:65%->90% 1st Apr 15: CD:Sun 15/03/15->Mon 15/06/15 1st Apr 15: Stat Rep: RP-142024->RP-150149 03/07/15: Compl:90%->100% 03/07/15: WID: RP-140522->RP-150940 03/07/15: Stat Rep: RP-150149->RP-150915 / Impacted TSs and TRs: 36.101, 36.104, 36.133
- 2207: 03/07/15: Compl:0%->13% 03/07/15: WID: RP-150135->RP-150838 03/07/15: Stat Rep: ->RP-150833 29/09/15: Compl:13%->25% 29/09/15: Stat Rep: RP-150833->RP-151165 ; 1/1/16: Compl:25%->70% ; 1/1/16: CD:Tue 15/12/15->Tue 15/03/16;...;...;...

| ID | WBS | Task | Duration | Start | Finish | Complete | Remaining | Baseline start | Baseline finish | Baseline duration | Total slack | Constraint | Resources | Work | Actual work | Acronym | PCG approved | WI rapporteur name | Release | TSG approved | MCC resp | Acronym_3GU_Export | Status Report | Special Focus Doc |
| --- | --- | --- | --- | --- | --- | --- | --- | --- | --- | --- | --- | --- | --- | --- | --- | --- | --- | --- | --- | --- | --- | --- | --- | --- |
| 2208 | 473 | **LTE TDD-FDD joint operation including Carrier Aggregation** | 444.03d? | 2013-04-12 A | 2014-12-15 A | 100% |  | 2013-04-12 | 2014-12-05 | 435.03d? |  |  | R1; R2; R4 | 14776h | 14776h | LTE_CA_TDD_FDD | PCG-31 | Nokia | Rel-12 | RP-60 | Patrick | LTE_CA_TDD_FDD |  |  |
| 2209 | 473.1 | Core part: LTE TDD-FDD joint operation including Carrier Aggregation | 87.33d? | 2013-04-12 A | 2014-06-13 A | 100% |  | 2013-04-12 | 2014-06-13 | 87.33d? |  | finish no earlier than 2014-06-13 | R1; R2; R4 | 2096h | 2096h | LTE_CA_TDD_FDD-Core | PCG-31 | Nokia, China Mobile (for TR) | Rel-12 | RP-60 | Patrick | LTE_CA_TDD_FDD-Core | RP-140982 |  |
| 2210 | 473.2 | Perf. part: LTE TDD-FDD joint operation including Carrier Aggregation | 397d? | 2013-06-15 A | 2014-12-15 A | 100% |  | 2013-06-20 | 2014-12-05 | 386d? |  | finish no earlier than 2014-12-15 | R4 | 3176h | 3176h | LTE_CA_TDD_FDD-Perf | PCG-31 | Nokia | Rel-12 | RP-60 | Issam | LTE_CA_TDD_FDD-Perf | RP-141972 |  |
| 2211 | 474 | **LTE Coverage Enhancements** | 604.17d? | 2013-03-01 A | 2015-06-15 | 100% | 0d? | 2013-03-01 | 2014-12-05 | 465.17d? | 0d |  | R1; R2; R4; R5 | 26709.4h | 21348.1h | Cov_Enh_LTE | PCG-31 | China Telecom | Rel-12 | RP-60 | Patrick | Cov_Enh_LTE |  |  |
| 2212 | 474.1 | Core part: LTE Coverage Enhancements | 87d? | 2013-03-01 A | 2014-06-13 A | 100% |  | 2013-03-01 | 2014-06-13 | 87d? |  | finish no earlier than 2014-06-13 | R1; R2; R4 | 2088h | 2088h | Cov_Enh_LTE-Core | PCG-31 | China Telecom | Rel-12 | RP-60 | Patrick | Cov_Enh_LTE-Core | RP-140683 |  |
| 2213 | 474.2 | Perf. part: LTE Coverage Enhancements | 397d? | 2013-06-15 A | 2014-12-15 A | 100% |  | 2013-06-20 | 2014-12-05 | 386d? |  | finish no earlier than 2014-12-15 | R4 | 3176h | 3176h | Cov_Enh_LTE-Perf | PCG-31 | China Telecom | Rel-12 | RP-60 | Issam | Cov_Enh_LTE-Perf | RP-141833 |  |
| 2214 | 474.3 | Test part: LTE Coverage Enhancements | 198d? | 2014-09-15 A | 2015-06-15 A | 100% |  |  |  |  |  | finish no earlier than 2015-09-15 | R5 | 1584h | 1584h | Cov_Enh_LTE-UEConTest | PCG-33 | China Telecom | Rel-12 | RP-65 |  | Cov_Enh_LTE-UEConTest | RP-150631 |  |
| 2215 | 475 | **Further MBMS operations support for E-UTRAN** | 330d? | 2013-09-15 A | 2014-12-15 A | 100% |  | 2013-12-09 | 2014-09-12 | 201d? |  |  | R2; R1; R3; R4 | 21280h | 21280h | MBMS_LTE_OS | PCG-31 | Verizon | Rel-12 | RP-61 | Yong-Jun | MBMS_LTE_OS |  |  |
| 2216 | 475.1 | Core part: Further MBMS operations support for E-UTRAN | 329d? | 2013-09-15 A | 2014-12-15 A | 100% |  | 2014-04-04 | 2014-09-12 | 115.25d? |  | finish no earlier than 2014-12-15 | R2; R1; R3; R4 | 10528h | 10528h | MBMS_LTE_OS-Core | PCG-31 | Verizon | Rel-12 | RP-61 | Yong-Jun | MBMS_LTE_OS-Core | RP-141821 |  |
| 2217 | 475.2 | Perf. part: Further MBMS operations support for E-UTRAN | 264d? | 2013-12-15 A | 2014-12-15 A | 100% |  | 2013-12-09 | 2014-09-12 | 201d? |  | finish no earlier than 2014-12-15 | R4 | 2112h | 2112h | MBMS_LTE_OS-Perf | PCG-32 | Verizon | Rel-12 | RP-62 | Issam | MBMS_LTE_OS-Perf | RP-141821 |  |
| 2218 | 476 | **Dual connectivity for LTE** | 789d? | 2013-12-15 A | 2016-12-15 | 92% | 62.43d? | 2013-12-09 | 2014-12-05 | 261d? | 347d |  | R2; R1; R3; R4; S2; C4 | 47888h | 28170h | LTE_SC_enh_dualC | PCG-32 | NTT DOCOMO | Rel-12 | RP-62 | Yong-Jun | LTE_SC_enh_dualC |  | Small cell |
| 2219 | 476.1 | Core part: Dual connectivity for LTE | 264d? | 2013-12-15 A | 2014-12-15 A | 100% |  | 2014-04-29 | 2014-09-12 | 99d? |  | finish no earlier than 2014-12-15 | R2; R1; R3; R4 | 8448h | 8448h | LTE_SC_enh_dualC-Core | PCG-32 | NTT DOCOMO, NEC | Rel-12 | RP-62 | Yong-Jun | LTE_SC_enh_dualC-Core | RP-141796 | Small cell |
| 2220 | 476.2 | Perf. part: Dual Connectivity for LTE | 395d? | 2013-12-15 A | 2015-06-15 A | 100% |  | 2013-12-09 | 2014-12-05 | 261d? |  | finish no earlier than 2015-06-15 | R4 | 3160h | 3160h | LTE_SC_enh_dualC-Perf | PCG-32 | NTT DOCOMO | Rel-12 | RP-62 | Issam | LTE_SC_enh_dualC-Perf | RP-150791 | Small cell |
| 2221 | 476.3 | SA2 part of Dual connectivity for LTE | 131d? | 2014-03-19 A | 2014-09-17 A | 100% |  | 2014-03-19 | 2014-09-17 | 131d? |  | finish no earlier than 2014-09-17 | S2 | 1048h | 1048h | LTE_SC_enh_dualC-S2 | PCG-32 |  | Rel-12 | RP-63 |  |  |  | Small cell |
| 2222 | 476.4 | CT aspects of Dual connectivity for LTE | 63d? | 2014-09-12 A | 2014-12-09 A | 100% |  |  |  |  |  | finish no earlier than 2014-12-09 | C4 | 504h | 504h | LTE_SC_enh_dualC-CT | PCG-33 | Huawei | Rel-12 | CP-65 |  | LTE_SC_enh_dualC-CT | CP-140487 | Small cell |
| 2223 | 476.5 | UE Conformance Test Aspects - Dual connectivity for LTE | 395d? | 2015-06-15 A | 2016-12-15 | 75% | 98.75d? |  |  |  | 347d | finish no earlier than 2016-12-15 | R5 | 3160h | 2370h | LTE_SC_enh_dualC-UEConTest | PCG-35 | Ericsson | Rel-12 | TSG-68 |  |  | RP-151167 |  |
| 2224 | 477 | **E-UTRA Small cell enhancements - Physical layer aspects** | 789d? | 2013-12-15 A | 2016-12-15 | 96% | 32.8d? | 2013-07-19 | 2014-12-05 | 364.75d? | 347d |  | R1; R2; R4 | 28204.7h | 18432.7h | LTE_SC_enh_L1 | PCG-32 | Huawei | Rel-12 | RP-62 | Patrick | LTE_SC_enh_L1 |  | Small cell |
| 2225 | 477.1 | Core part: E-UTRA Small cell enhancements - Physical layer aspects | 161.25d? | 2013-12-15 A | 2014-12-15 A | 100% |  | 2013-07-19 | 2014-09-12 | 202d? |  | finish no earlier than 2014-12-15 | R1; R2; R4 | 3870h | 3870h | LTE_SC_enh_L1-Core | PCG-32 | Huawei | Rel-12 | RP-62 | Patrick | LTE_SC_enh_L1-Core | RP-141899 | Small cell |
| 2226 | 477.2 | Perf. part: E-UTRA Small cell enhancements - Physical layer aspects | 394d? | 2013-12-15 A | 2015-06-15 A | 100% |  | 2013-12-09 | 2014-12-05 | 261d? |  | finish no earlier than 2015-06-15 | R4 | 3152h | 3152h | LTE_SC_enh_L1-Perf | PCG-32 | Huawei | Rel-12 | RP-62 | Issam | LTE_SC_enh_L1-Perf | RP-150690 | Small cell |
| 2227 | 477.3 | UE Conformance Test Aspects - E-UTRA Small cell enhancements - Physical layer aspects | 395d? | 2015-06-15 A | 2016-12-15 | 90% | 39.5d? |  |  |  | 347d | finish no earlier than 2016-12-15 | R5 | 3160h | 2844h | LTE_SC_enh_L1-UEConTest | PCG-35 | Huawei | Rel-12 | TSG-68 |  |  | RP-151247 |  |
| 2228 | 478 | **Inter-eNB Coordinated Multi-Point (CoMP) for LTE** | 264d? | 2013-12-15 A | 2014-12-15 A | 100% |  | 2014-03-14 | 2014-09-12 | 130.65d? |  |  | R3; R1 | 4738.38h | 4738.38h | COMP_LTE_IeNB | PCG-32 | Samsung | Rel-12 | RP-62 | Juha | COMP_LTE_IeNB |  |  |
| 2229 | 478.1 | Core part: Inter-eNB Coordinated Multi-Point (CoMP) for LTE | 165.5d? | 2013-12-15 A | 2014-12-15 A | 100% |  | 2014-03-14 | 2014-09-12 | 100.5d? |  | finish no earlier than 2014-12-15 | R3; R1 | 2648h | 2648h | COMP_LTE_IeNB-Core | PCG-32 | Samsung | Rel-12 | RP-62 | Juha | COMP_LTE_IeNB-Core | RP-141804 |  |
| 2230 | 479 | **Smart Congestion Mitigation in E-UTRAN** | 403d? | 2014-03-05 A | 2015-09-15 A | 100% |  | 2014-03-05 | 2014-09-12 | 138d? |  |  | R2; S1; C1 | 12376h | 12376h | SCM_LTE | PCG-32 | LG Electronics | Rel-12 | RP-63 | Yong-Jun | SCM_LTE |  |  |
| 2231 | 479.1 | Core part: Smart Congestion Mitigation in E-UTRAN | 137d? | 2014-03-06 A | 2014-09-12 A | 100% |  | 2014-03-06 | 2014-09-12 | 137d? |  | finish no earlier than 2014-09-12 | R2 | 1096h | 1096h | SCM_LTE-Core | PCG-32 | LG Electronics | Rel-12 | RP-63 | Yong-Jun | SCM_LTE-Core | RP-141292 |  |
| 2232 | 479.2 | Stage 1 Prioritization of Multimedia Telephony (MMTel) and Mobile Originating-SMS for Access Class Barring (ACB) | 3d? | 2014-03-05 A | 2014-03-07 A | 100% |  | 2014-03-05 | 2014-03-07 | 3d? |  | finish no earlier than 2013-12-11 | S1 | 24h | 24h |  | PCG-33 |  | Rel-12 | CP-64 |  |  |  |  |
| 2233 | 479.3 | CT aspects of Smart Congestion Mitigation in E-UTRAN (Stage 3) | 66d? | 2014-06-13 A | 2014-09-11 A | 100% |  | 2014-06-13 | 2014-09-12 | 66d? |  | start no earlier than 2014-06-13 | C1 | 528h | 528h | SCM_LTE-CT | PCG-33 | LG Electronics | Rel-12 | CP-64 |  | SCM_LTE-CT |  |  |
| 2234 | 479.4 | UE Conformance Test Aspects - Smart Congestion Mitigation in E-UTRAN | 132d? | 2015-03-16 A | 2015-09-15 A | 100% |  |  |  |  |  | finish no earlier than 2015-09-15 | R5 | 1056h | 1056h | SCM_LTE-UEConTest | PCG-34 | NTT DOCOMO | Rel-12 | RP-67 |  |  | RP-151445 |  |

Notes:
- 2208: - / Impacted TSs and TRs: LTE / WI rapporteur e-mail: lars.e.lindh@nokia.com
- 2209: RP#64 completed / Impacted TSs and TRs: 36.101, 36.104, 36.133, 36.201, 36.211, 36.212, 36.213, 36.300, 36.302, 36.306, 36.331, new TR 36.847 / WI rapporteur e-mail: lars.e.lindh@nokia.com, Xiaodong Shen (shenxiaodong@chinamobile.com)
- 2210: ; CD:Thu 18/06/15->Mon 15/06/15; WID: RP-130848->RP-140522; Stat Rep: RP-141374->RP-141972 / Impacted TSs and TRs: 36.101, 36.104, 36.133 / WI rapporteur e-mail: lars.e.lindh@nokia.com
- 2211: Triggered by Rel-11 TR 36.824 (FS_Cov_Enh_LTE) / Impacted TSs and TRs: LTE / WI rapporteur e-mail: Xiaoming She (shexm@ctbri.com.cn)
- 2212: RP#64 completed / Impacted TSs and TRs: 36.101, 36.104, 36.133, 36.211, 36.212, 36.213, 36.300, 36.321, 36.331 / WI rapporteur e-mail: Xiaoming She (shexm@ctbri.com.cn)
- 2213: ; CD:Thu 18/06/15->Mon 15/06/15; WID: RP-141966->RP-142235; Stat Rep: RP-141149->RP-141833 / Impacted TSs and TRs: 36.101, 36.104, 36.133, 36.141 / WI rapporteur e-mail: Xiaoming She (shexm@ctbri.com.cn)
- 2214: ; Stat Rep: -->RP-141834 03/07/15: Compl:5%->100% 03/07/15: CD:Tue 15/09/15->Mon 15/06/15 03/07/15: Stat Rep: RP-141834->RP-150631 / Impacted TSs and TRs: 36.508, 36.523-1, 36.523-2, 36.523-3 / WI rapporteur e-mail: YANG Shan (yangshan@ctbri.com.cn)
- 2215: Solutions for Minimization of Drive Tests (MDT), in order to reduce the need for manual drive testing for MBMS. / Impacted TSs and TRs: LTE / WI rapporteur e-mail: yeesin.chan@verizonwireless.com
- 2216: ; CD:Thu 18/06/15->Mon 15/06/15; WID: RP-130848->RP-140522; Stat Rep: RP-141431->RP-141821 / Impacted TSs and TRs: 36.133, 36.214, 36.300, 36.304, 36.306, 36.331, 36.413, 36.423, 37.320 / WI rapporteur e-mail: yeesin.chan@verizonwireless.com
- 2217: ; CD:Wed 17/12/14->Mon 15/12/14; WID: RP-130848->RP-140522; Stat Rep: RP-141431->RP-141821 / Impacted TSs and TRs: 36.133 / WI rapporteur e-mail: yeesin.chan@verizonwireless.com
- 2218: Triggered by TR 36.842 Study on Small Cell Enhancements for E-UTRA and E-UTRAN Higher-layer aspects (UID_580044) / Impacted TSs and TRs: LTE / WI rapporteur e-mail: tooru.uchino.fv@nttdocomo.com
- 2219: ; CD:Wed 18/03/15->Sun 15/03/15; WID: RP-130848->RP-140522; Stat Rep: RP-141264->RP-141796 / Impacted TSs and TRs: 36.101, 36.104, 36.133, 36.211, 36.212, 36.213, 36.300, 36.302, 36.306, 36.321, 36.322, 36.323, 36.331, 36.410, 36.413, 36.420, 36.423, new RAN3 TS 36.425 / WI rapporteur e-mail: RAN1/2/4 tooru.uchino.fv@nttdocomo.com, RAN3 Chenghock Ng (ngcheng@da.jp.nec.com)
- 2220: ; Stat Rep: RP-141264->RP-141796 1st Apr 15: Compl:15%->45% 1st Apr 15: Stat Rep: RP-141796->RP-150160 03/07/15: Compl:45%->100% 03/07/15: Stat Rep: RP-150160->RP-150791 / Impacted TSs and TRs: 36.101, 36.104, 36.133 / WI rapporteur e-mail: kunihiko.teshima.hg@nttdocomo.com
- 2221: SP#64 Three CRs agreed in SP-140262 (23.251CR0099, 23.401CR2658&CR2707). Dec.14:99->100% / Impacted TSs and TRs: 23.251, 23.401
- 2222: Stage 2/3. CP#65 exception in CP-140487. LM70->100 / Impacted TSs and TRs: 23.007, 23.008, 29.274, 29.281 / WI rapporteur e-mail: Xiaoyan SHI (sean.shixiaoyan@huawei.com)
- 2223: tested Core part: LTE_SC_enh_dualC-Core 29/09/15: Compl:0%->3% 29/09/15: Stat Rep: -->RP-1511671/1/16: Compl:3%->15%1/1/16: CD:Tue 15/03/16->Wed 15/06/16;...;...;...
- 2224: Triggered by TR 36.872 Study on Small Cell Enhancements for E-UTRA and E-UTRAN Physical-layer aspects (UID_580041) / Impacted TSs and TRs: LTE / WI rapporteur e-mail: Elean FAN (fanxiaoan@huawei.com)
- 2225: ; CD:Tue 12/05/15->Mon 15/12/14; WID: RP-130848->RP-140522; Stat Rep: RP-141632->RP-141899 / Impacted TSs and TRs: 36.101, 36.104, 36.133, 36.211, 36.212, 36.213, 36.214, 36.300, 36.306, 36.321, 36.331, 36.413, 36.423, 36.443 / WI rapporteur e-mail: Elean FAN (fanxiaoan@huawei.com)
- 2226: ; CD:Wed 18/03/15->Sun 15/03/15; WID: RP-130848->RP-140522; Stat Rep: RP-141632->RP-141899 1st Apr 15: Compl:40%->80% 1st Apr 15: CD:Sun 15/03/15->Mon 15/06/15 1st Apr 15: Stat Rep: RP-141899->RP-150173 03/07/15: Compl:80%->100% 03/07/15: Stat Rep: RP-150173->RP-150690 / Impacted TSs and TRs: 36.101, 36.104, 36.133, 36.141 / WI rapporteur e-mail: Elean FAN (fanxiaoan@huawei.com)
- 2227: tested Core part: LTE_SC_enh_L1-Core 29/09/15: Compl:0%->10% 29/09/15: CD:Wed 15/06/16->Thu 15/12/16 29/09/15: Stat Rep: -->RP-151247; 1/1/16: Compl:10%->40%;...;...; ;...
- 2228: Stage 3. Rel-11 did not address support of a network interface for CoMP involving multiple eNBs with non-ideal backhaul (affected operators might not take advantage of performance benefit from inter-eNB CoMP operation). / Impacted TSs and TRs: LTE / WI rapporteur e-mail: Sung Hwan Won (sunghwan.won@samsung.com)
- 2229: CD:Thu 11/12/14->Mon 15/12/14; Compl:85%->100%; Stat Rep: RP-140597->RP-141804 / Impacted TSs and TRs: 36.300, 36.423 / WI rapporteur e-mail: Sung Hwan Won (sunghwan.won@samsung.com)
- 2230: follow-up of TR 36.848 FS_SCM_LTE / Impacted TSs and TRs: LTE / WI rapporteur e-mail: youngdae.lee@lge.com
- 2231: RP#65 completed / Impacted TSs and TRs: 36.331 / WI rapporteur e-mail: youngdae.lee@lge.com
- 2232: SP#63 SP-140065 CR under TEI12 / Impacted TSs and TRs: 22.011
- 2233: CP#65 completed / Impacted TSs and TRs: 24.173, 24.301, 24.341, 27.007 / WI rapporteur e-mail: Kim, Jaehyun (jaehyun7.kim@lge.com)
- 2234: 03/07/15: Compl:0%->60% 03/07/15: WID: RP-150202->RP-150797 03/07/15: Stat Rep: ->RP-150794 29/09/15: Compl:60%->100% 29/09/15: Stat Rep: RP-150794->RP-151445

| ID | WBS | Task | Duration | Start | Finish | Complete | Remaining | Baseline start | Baseline finish | Baseline duration | Total slack | Constraint | Resources | Work | Actual work | Acronym | PCG approved | WI rapporteur name | WI rapporteur e-mail | Release | TSG approved | MCC resp | Acronym_3GU_Export | Status Report | Special Focus Doc |
| --- | --- | --- | --- | --- | --- | --- | --- | --- | --- | --- | --- | --- | --- | --- | --- | --- | --- | --- | --- | --- | --- | --- | --- | --- | --- |
| 2235 | 480 | **Positioning Enhancements for RF Pattern Matching in E-UTRA** | 36d? | 2014-04-25 A | 2014-06-13 A | 100% |  | 2014-04-25 | 2014-06-13 | 36d? |  |  | R3; R2 | 1152h | 1152h | LCS_LTE_RFPMT | PCG-32 | Polaris Wireless | Gordon Scot (sgordon@polariswireless.com) | Rel-12 | RP-63 | Juha | LCS_LTE_RFPMT |  |  |
| 2236 | 480.1 | Core part: Positioning Enhancements for RF Pattern Matching in E-UTRA | 36d? | 2014-04-25 A | 2014-06-13 A | 100% |  | 2014-04-25 | 2014-06-13 | 36d? |  | finish no earlier than 2014-06-13 | R3; R2 | 576h | 576h | LCS_LTE_RFPMT-Core | PCG-32 | Polaris Wireless | Gordon Scot (sgordon@polariswireless.com) | Rel-12 | RP-63 | Juha | LCS_LTE_RFPMT-Core | RP-140591 |  |
| 2237 | 481 | **Network-Assisted Interference Cancellation and Suppression for LTE** | 791d? | 2014-03-11 A | 2017-03-15 | 91% | 68.64d? | 2014-03-06 | 2015-06-12 | 332d? | 283d |  | R1; R2; R4; R3 | 25043.9h | 10877.2h | LTE_NAICS | PCG-32 | MediaTek | Craig.Burnet@mediatek.com | Rel-12 | RP-63 | Patrick | LTE_NAICS |  |  |
| 2238 | 481.1 | Core part: Network-Assisted Interference Cancellation and Suppression for LTE | 113.67d? | 2014-07-11 A | 2014-12-15 A | 100% |  | 2014-07-11 | 2014-09-12 | 45.67d? |  | finish no earlier than 2014-12-15 | R1; R2; R4; R3 | 2803.87h | 2803.87h | LTE_NAICS-Core | PCG-32 | MediaTek | Craig.Burnet@mediatek.com | Rel-12 | RP-63 | Patrick | LTE_NAICS-Core | RP-141866 |  |
| 2239 | 481.2 | Perf. part: Network-Assisted Interference Cancellation and Suppression for LTE | 399d? | 2014-03-11 A | 2015-09-15 A | 100% |  | 2014-03-06 | 2015-06-12 | 332d? |  | finish no earlier than 2015-09-15 | R4 | 3192h | 3192h | LTE_NAICS-Perf | PCG-32 | MediaTek | Craig.Burnet@mediatek.com | Rel-12 | RP-63 | Issam | LTE_NAICS-Perf | RP-151296 |  |
| 2240 | 481.3 | UE Conformance Test Aspects: Network-Assisted Interference Cancellation and Suppression for LTE | 393d? | 2015-09-15 A | 2017-03-15 | 80% | 78.6d? |  |  |  | 283d | finish no earlier than 2017-03-15 | R5 | 3144h | 2515.2h | LTE_NAICS-UEConTest | PCG-35 | Mediatek |  | Rel-12 | RP-69 |  |  |  |  |
| 2241 | 482 | **Performance requirements of interference cancellation and suppression receiver for SU-MIMO** | 467d? | 2014-03-06 A | 2015-12-15 A | 100% |  | 2014-03-06 | 2015-03-13 | 267d? |  |  | R4 | 7448h | 7448h | LTE_SUMIMO_RX | PCG-32 | Huawei | Qian Cheng (Q.Cheng@Huawei.com) | Rel-12 | RP-63 | Issam | LTE_SUMIMO_RX |  |  |
| 2242 | 482.1 | Perf. part: Performance requirements of interference cancellation and suppression receiver for SU-MIMO | 267d? | 2014-03-06 A | 2015-03-15 A | 100% |  | 2014-03-06 | 2015-03-13 | 267d? |  | finish no earlier than 2015-03-15 | R4 | 2136h | 2136h | LTE_SUMIMO_RX-Perf | PCG-32 | Huawei | Qian Cheng (Q.Cheng@Huawei.com) | Rel-12 | RP-63 | Issam | LTE_SUMIMO_RX-Perf | RP-150229 |  |
| 2243 | 482.2 | UE Conformance Test Aspects - Performance Requirements of Interference Cancellation and Suppression Receiver for SU-MIMO for E-UTRA | 197d? | 2015-03-16 A | 2015-12-15 A | 100% |  |  |  |  |  | finish no earlier than 2016-03-15 | R5 | 1576h | 1576h | LTE_SUMIMO_RX-UEConTest | PCG-34 | Huawei |  | Rel-12 | RP-67 |  |  | RP-151245 |  |
| 2244 | 483 | **HSPA signalling enhancements for more efficient resource usage for LCR** | 274d? | 2012-12-11 A | 2013-12-20 A | 100% |  | 2012-12-10 | 2013-12-06 | 265d? |  |  | R1; R2; R3; R4 | 16832h | 16832h | LCR_TDD_HSPA_sign_enh | PCG-30 | CATT | Yanping Xing (xingyanping@catt.cn) | Rel-12 | RP-58 | Patrick | LCR_TDD_HSPA_sign_enh |  |  |
| 2245 | 483.1 | Core part: HSPA signalling enhancements for more efficient resource usage for LCR TDD | 270d? | 2012-12-15 A | 2013-12-20 A | 100% |  | 2012-12-10 | 2013-12-06 | 265d? |  | finish no earlier than 2013-12-15 | R1; R2; R3 | 6480h | 6480h | LCR_TDD_HSPA_sign_enh-Core | PCG-30 | CATT | Yanping Xing (xingyanping@catt.cn) | Rel-12 | RP-58 | Patrick | LCR_TDD_HSPA_sign_enh-Core | RP-131499 |  |
| 2246 | 483.2 | Perf. part: HSPA signalling enhancements for more efficient resource usage for LCR TDD | 198d? | 2012-12-11 A | 2013-09-06 A | 100% |  | 2012-12-11 | 2013-09-06 | 198d? |  | finish no earlier than 2013-09-06 | R4 | 1584h | 1584h | LCR_TDD_HSPA_sign_enh-Perf | PCG-30 | CATT | Yanping Xing (xingyanping@catt.cn) | Rel-12 | RP-58 | Issam | LCR_TDD_HSPA_sign_enh-Perf | RP-130968 |  |
| 2247 | 484 | **HNB Positioning for UTRA** | 127d? | 2013-06-18 A | 2013-12-06 A | 100% |  | 2013-06-18 | 2013-12-06 | 127d? |  |  | R3 | 2032h | 2032h | UTRA_HNB_Pos | PCG-31 | Alcatel-Lucent | Martin.Warner@alcatel-lucent.com | Rel-12 | RP-60 | Juha | UTRA_HNB_Pos |  | HNB |
| 2248 | 484.1 | Core part: HNB Positioning for UTRA | 127d? | 2013-06-18 A | 2013-12-06 A | 100% |  | 2013-06-18 | 2013-12-06 | 127d? |  | finish no earlier than 2013-12-06 | R3 | 1016h | 1016h | UTRA_HNB_Pos-Core | PCG-31 | Alcatel-Lucent | Martin.Warner@alcatel-lucent.com | Rel-12 | RP-60 | Juha | UTRA_HNB_Pos-Core | RP-131974 | HNB |
| 2249 | 485 | **Dedicated Channel (DCH) enhancements for UMTS** | 722d? | 2013-09-15 A | 2016-06-15 | 99% | 0d? | 2013-09-10 | 2014-12-05 | 326d? | 0d |  | R1; R2; R3; R4 | 32048h | 19504h | UTRA_DCHenh | PCG-31 | Qualcomm | arjunb@qti.qualcomm.com | Rel-12 | RP-61 | Patrick | UTRA_DCHenh |  |  |
| 2250 | 485.1 | Core part: Dedicated Channel (DCH) enhancements for UMTS | 115.25d? | 2013-11-18 A | 2014-09-12 A | 100% |  | 2013-11-18 | 2014-09-12 | 115.25d? |  | finish no earlier than 2014-09-12 | R1; R2; R3; R4 | 3688h | 3688h | UTRA_DCHenh-Core | PCG-31 | Qualcomm | arjunb@qti.qualcomm.com | Rel-12 | RP-61 | Patrick | UTRA_DCHenh-Core | RP-141137 |  |
| 2251 | 485.2 | Perf. part: Dedicated Channel (DCH) enhancements for UMTS | 329d? | 2013-09-15 A | 2014-12-15 A | 100% |  | 2013-09-10 | 2014-12-05 | 326d? |  | finish no earlier than 2014-12-15 | R4 | 2632h | 2632h | UTRA_DCHenh-Perf | PCG-31 | Qualcomm | arjunb@qti.qualcomm.com | Rel-12 | RP-61 | Issam | UTRA_DCHenh-Perf | RP-141970 |  |
| 2252 | 485.3 | UE Conformance Test Aspects - DCH Enhancements for UMTS | 328d? | 2015-03-16 A | 2016-06-15 A | 100% |  |  |  |  |  | finish no earlier than 2016-06-15 | R5 | 2624h | 2624h | UTRA_DCHenh-UEConTest | PCG-34 | Qualcomm | NA | Rel-12 | RP-67 |  |  | RP-151279 |  |
| 2253 | 486 | **UMTS Mobility enhancements for heterogeneous networks** | 237.85d? | 2013-07-23 A | 2014-06-13 A | 100% |  | 2013-07-23 | 2014-06-13 | 237.85d? |  |  | R2; R3; R4 | 8040h | 8040h | UTRA_HetNet_mob | PCG-31 | Huawei | Xudong Yang (yangxudong@huawei.com) | Rel-12 | RP-61 | Yong-Jun | UTRA_HetNet_mob |  |  |
| 2254 | 486.1 | Core part: UMTS Mobility enhancements for heterogeneous networks | 67d? | 2013-07-23 A | 2014-06-13 A | 100% |  | 2013-07-23 | 2014-06-13 | 67d? |  | finish no earlier than 2014-06-13 | R2; R3; R4 | 1608h | 1608h | UTRA_HetNet_mob-Core | PCG-31 | Huawei | Xudong Yang (yangxudong@huawei.com) | Rel-12 | RP-61 | Yong-Jun | UTRA_HetNet_mob-Core | RP-140636 |  |
| 2255 | 486.2 | Perf. part: UMTS Mobility enhancements for heterogeneous networks | 201d? | 2013-09-09 A | 2014-06-13 A | 100% |  | 2013-09-09 | 2014-06-13 | 201d? |  | finish no earlier than 2014-06-13 | R4 | 1608h | 1608h | UTRA_HetNet_mob-Perf | PCG-31 | Huawei | Xudong Yang (yangxudong@huawei.com) | Rel-12 | RP-61 | Issam | UTRA_HetNet_mob-Perf | RP-140636 |  |
| 2256 | 487 | **UMTS Heterogeneous Networks enhancements** | 271d? | 2013-12-06 A | 2014-12-15 A | 100% |  | 2013-12-06 | 2014-12-05 | 262d? |  |  | R1; R2; R3; R4 | 12408h | 12408h | UTRA_HetNet_enh | PCG-32 | Huawei | carmela.cozzo@huawei.com | Rel-12 | RP-62 | Patrick | UTRA_HetNet_enh |  |  |
| 2257 | 487.1 | Core part: Heterogeneous Networks enhancements | 202d? | 2013-12-06 A | 2014-09-12 A | 100% |  | 2013-12-06 | 2014-09-12 | 202d? |  | finish no earlier than 2014-09-15 | R1 | 1616h | 1616h | UTRA_HetNet_enh-Core | PCG-32 | Huawei | carmela.cozzo@huawei.com | Rel-12 | RP-62 | Patrick | UTRA_HetNet_enh-Core | RP-141702 |  |
| 2258 | 487.2 | Perf. part: Heterogeneous Networks enhancements | 265d? | 2013-12-15 A | 2014-12-15 A | 100% |  | 2013-12-09 | 2014-12-05 | 261d? |  | finish no earlier than 2014-12-15 | R4 | 2120h | 2120h | UTRA_HetNet_enh-Perf | PCG-32 | Huawei | carmela.cozzo@huawei.com | Rel-12 | RP-62 | Issam | UTRA_HetNet_enh-Perf | RP-141898 |  |

Notes:
- 2235: follow-up of TR 36.809 FS_LCS_LTE_RFPMT / Impacted TSs and TRs: LTE
- 2236: RP#64 completed / Impacted TSs and TRs: 36.305, 36.455
- 2237: follow-up of TR 36.866 FS_LTE_NAICS / Impacted TSs and TRs: LTE
- 2238: CD:Mon 08/12/14->Mon 15/12/14; Compl:95%->100%; Stat Rep: RP-141621->RP-141866 / Impacted TSs and TRs: 36.211, 36.213, 36.300, 36.331, 36.423
- 2239: CD:Fri 12/06/15->Mon 15/06/15; Compl:0%->25%; Stat Rep: RP-141621->RP-141866 1st Apr 15: Compl:25%->50% 1st Apr 15: Stat Rep: RP-141866->RP-150179 03/07/15: Compl:50%->85% 03/07/15: CD:Mon 15/06/15->Tue 15/09/15 03/07/15: Stat Rep: RP-150179->RP-150862 29/09/15: Compl:85%->100% 29/09/15: WID: RP-141634->RP-151297 29/09/15: Stat Rep: RP-150862->RP-151296 / Impacted TSs and TRs: 36.101
- 2240: tested: LTE_NAICS was a REL-12 RAN1 WI; 1/1/16: Compl:0%->35%; 1/1/16: WID: RP-151298->RP-151945; ...;...; ;...
- 2241: no Core part / Impacted TSs and TRs: LTE
- 2242: CD:Fri 13/03/15->Sun 15/03/15; Compl:50%->80%; Stat Rep: RP-141255->RP-141906 1st Apr 15: Compl:80%->100% 1st Apr 15: Stat Rep: RP-141906->RP-150229 / Impacted TSs and TRs: 36.101
- 2243: 03/07/15: Compl:0%->5% 03/07/15: Stat Rep: ->RP-150692 29/09/15: Compl:5%->55% 29/09/15: WID: RP-150245->RP-151463 29/09/15: Stat Rep: RP-150692->RP-1512451/1/16: Compl:55%->100%1/1/16: CD:Tue 15/03/16->Tue 15/1...
- 2244: Stage 2/3. Triggered by Rel-11 TR 25.874 Study on HSPA feedback and signalling efficiency enhancements for LCR TDD (FS_LCRTDD_HSPAenh) UID_540026 / Impacted TSs and TRs: UTRA
- 2245: Prev CD:Fri 06/12/13; Prev %:100% / Impacted TSs and TRs: 25.222, 25.224, 25.331, 25.423, 25.433
- 2246: RP#61 completed / Impacted TSs and TRs: 25.102
- 2247: RP#62 completed / Impacted TSs and TRs: UTRA
- 2248: RP#62 closed at 85% completion. Not completed work on HNB positioning / No consensus (may be TEI12, if contribution and support). Updated WID RP-130868=>RP-132037 (HNB positiong was not addressed in this WI, however it was NOT remoded from the WID) / Impacted TSs and TRs: 25.305, 25.467, new TS 25.470
- 2249: Triggered by Rel-12 TR 25.702 Study on Dedicated Channel (DCH) enhancements for UMTS (FS_UTRA_DCHenh) UID_580040. Stage 2/3 / Impacted TSs and TRs: UTRA
- 2250: RP#65 completed / Impacted TSs and TRs: 25.101, 25.104, 25.133, 25.211, 25.212, 25.213, 25.214, 25.215, 25.306, 25.308, 25.321, 25.331, 25.423, 25.433
- 2251: ; Stat Rep: RP-141137->RP-141970 / Impacted TSs and TRs: 25.101, 25.104, 25.133
- 2252: 03/07/15: Compl:0%->15% 03/07/15: Stat Rep: ->RP-150764 29/09/15: Compl:15%->50% 29/09/15: CD:Tue 15/12/15->Wed 15/06/16 29/09/15: Stat Rep: RP-150764->RP-1512791/1/16: Compl:50%->65%...;...
- 2253: Triggered by Rel-12 TR 25.800 Study on UMTS heterogeneous networks (FS_UTRA_hetnet) UID_570024. Stage 2/3 / Impacted TSs and TRs: UTRA
- 2254: RP#64 completed. TS 25.300v100 for 1-step Approval / Impacted TSs and TRs: 25.101, 25.104, 25.133, 25.141, 25.304, 25.306, 25.331, 25.433, new TS 25.300
- 2255: RP#64 completed / Impacted TSs and TRs: 25.101, 25.104, 25.133, 25.141
- 2256: Triggered by the 2nd part of TR 25.800 (FS_UTRA_HetNet); the 1st part is addressed by UTRA_HetNet_mob UID_610026 / Impacted TSs and TRs: UTRA
- 2257: RP#65 completed. Updated WID RP-140463=>RP-141701 / Impacted TSs and TRs: 25.101, 25.211, 25.212, 25.213, 25.214, 25.300, 25.302, 25.306, 25.308, 25.319, 25.331, 25.423, 25.433
- 2258: ; Stat Rep: RP-141702->RP-141898 / Impacted TSs and TRs: 25.101, 25.104, 25.133, 25.141

| ID | WBS | Task | Duration | Start | Finish | Complete | Remaining | Baseline start | Baseline finish | Baseline duration | Total slack | Constraint | Resources | Work | Actual work | Acronym | PCG approved | WI rapporteur name | WI rapporteur e-mail | Release | TSG approved | MCC resp | Acronym_3GU_Export | Status Report | Special Focus Doc | PCG stopped | TSG stopped |
| --- | --- | --- | --- | --- | --- | --- | --- | --- | --- | --- | --- | --- | --- | --- | --- | --- | --- | --- | --- | --- | --- | --- | --- | --- | --- | --- | --- |
| 2259 | 488 | **Enhanced Broadcast of System Information** | 271d? | 2013-12-06 A | 2014-12-15 A | 100% |  | 2013-12-06 | 2014-12-05 | 262d? |  |  | R2; R1; R3; R4 | 16385.6h | 16385.6h | UTRA_SIBenh | PCG-32 | Ericsson | martin.van.der.zee@ericsson.com | Rel-12 | RP-62 | Yong-Jun | UTRA_SIBenh |  |  |  |  |
| 2260 | 488.1 | Core part: Enhanced Broadcast of System Information | 174.8d? | 2013-12-06 A | 2014-09-12 A | 100% |  | 2013-12-06 | 2014-09-12 | 174.8d? |  | finish no earlier than 2014-09-12 | R2; R1; R3; R4 | 5593.6h | 5593.6h | UTRA_SIBenh-Core | PCG-32 | Ericsson | martin.van.der.zee@ericsson.com | Rel-12 | RP-62 | Yong-Jun | UTRA_SIBenh-Core | RP-141230 |  |  |  |
| 2261 | 488.2 | Perf. part: Enhanced Broadcast of System Information | 265d? | 2013-12-15 A | 2014-12-15 A | 100% |  | 2013-12-09 | 2014-12-05 | 261d? |  | finish no earlier than 2014-12-15 | R4 | 2120h | 2120h | UTRA_SIBenh-Perf | PCG-32 | Ericsson | martin.van.der.zee@ericsson.com | Rel-12 | RP-62 | Issam | UTRA_SIBenh-Perf | RP-142080 |  |  |  |
| 2262 | 489 | **Further Enhanced Uplink (EUL) enhancements** | 329d? | 2013-12-15 A | 2015-03-15 A | 100% |  | 2013-12-09 | 2014-12-05 | 261d? |  |  | R2 | 13704h | 13704h | EDCH_enh | PCG-32 | Ericsson | mark.curran@ericsson.com | Rel-12 | RP-62 | Yong-Jun | EDCH_enh |  |  |  |  |
| 2263 | 489.1 | Core part: Further Enhanced Uplink (EUL) enhancements | 264d? | 2013-12-15 A | 2014-12-15 A | 100% |  | 2014-04-29 | 2014-09-12 | 99d? |  | finish no earlier than 2014-12-15 | R2; R1; R3; R4 | 8448h | 8448h | EDCH_enh-Core | PCG-32 | Ericsson | mark.curran@ericsson.com | Rel-12 | RP-62 | Yong-Jun | EDCH_enh-Core | RP-141860 |  |  |  |
| 2264 | 489.2 | Perf. part: Further Enhanced Uplink (EUL) enhancements | 328d? | 2013-12-15 A | 2015-03-15 A | 100% |  | 2013-12-09 | 2014-12-05 | 261d? |  | finish no earlier than 2015-03-15 | R4 | 2624h | 2624h | EDCH_enh-Perf | PCG-32 | Ericsson | mark.curran@ericsson.com | Rel-12 | RP-62 | Issam | EDCH_enh-Perf | RP-150062 |  |  |  |
| 2265 | 490 | (Small) Technical Enhancements and Improvements for Rel-12 | 197.5d? | 2012-12-25 A | 2014-09-16 A | 100% |  | 2012-12-25 | 2014-09-17 | 197.5d? |  | finish no earlier than 2014-09-17 | SP; CP; RP; GP | 6320h | 6320h | TEI12 | PCG-29 |  |  | Rel-12 | RP-56 |  | TEI12 |  |  |  |  |
| 2266 | 491 | (IETF) (Small) Technical Enhancements and Improvements for Rel-12 (draft-ietf-insipid-session-id) | 131d? | 2014-06-13 A | 2014-12-09 | 50% | 65.5d? |  |  |  | 875d | start no earlier than 2014-06-13 | C1-IETF | 1048h | 524h | TEI12_IETF | PCG-34 | Alcatel-Lucent |  | Rel-12 | CT-66 |  |  |  |  |  |  |
| 2267 | 492 | Test - (Small) Technical Enhancements and Improvements for Rel-12 | 295.5d? | 2014-10-24 A | 2015-12-11 A | 100% |  | 2014-10-24 | 2015-12-11 | 295.5d? |  | finish no earlier than 2015-12-11 | R5; G3new | 4728h | 4728h | TEI12_Test | PCG-31 |  |  | Rel-12 | RP-61 | Ingbert | TEI12_Test |  |  |  |  |
| 2268 | 493 | Release 12 Studies | 296.5d? | 2013-08-05 A | 2014-09-17 | 80% | 59.3d? | 2013-08-05 | 2014-09-17 | 296.5d? | 936d | finish no earlier than 2014-09-17 | SP; CP; GP; RP | 9488h | 7590.4h |  |  |  |  | Rel-12 |  |  |  |  |  |  |  |
| 2269 | 494 | Study on Alternatives to E.164 for Machine-Type Communications | 513d? | 2010-03-25 A | 2012-03-07 A | 100% |  | 2010-03-25 | 2012-03-07 | 513d? |  | finish no earlier than 2012-03-07 | S1 | 4080h | 4080h | FS_AMTC | PCG-24 | T-Mobile USA | gary.jones@T-Mobile.com | Rel-12 | SP-47 | Alain | FS_AMTC |  | MTC, M2M |  |  |
| 2270 | 495 | Study on enhancements for Machine-Type Communications (MTC) | 720d? | 2010-06-10 A | 2013-03-06 A | 100% |  | 2010-06-10 | 2013-03-06 | 720d? |  | finish no earlier than 2013-03-06 | S1 | 5751.26h | 5751.26h | FS_MTCe | PCG-25 | Huawei | laurence.meriau@huawei.com | Rel-12 | SP-48 | Alain | FS_MTCe |  | MTC, M2M |  |  |
| 2271 | 496 | Study on Integration of Single Sign-On (SSO) frameworks with 3GPP networks | 383d? | 2010-09-23 A | 2012-03-07 A | 100% |  | 2010-09-23 | 2012-03-07 | 383d? |  | finish no earlier than 2011-09-08 | S1 | 3041.15h | 3041.15h | FS_SSO_Int | PCG-25 | InterDigital | christopher.wallace@interdigital.com | Rel-12 | SP-49 | Alain | FS_SSO_Int |  |  |  |  |
| 2272 | 497 | Study on Continuity of Data Sessions to Local Networks | 262.85d? | 2010-12-16 A | 2011-12-14 A | 100% |  | 2010-12-16 | 2011-12-14 | 262.85d? |  | finish no earlier than 2011-12-14 | S1 | 2084.27h | 2084.27h | FS_CSN | PCG-26 | NEC | joerg.swetina@neclab.eu | Rel-12 | SP-50 | Alain | FS_CSN |  |  |  |  |
| 2273 | 498 | Study on non-MTC Mobile Data Applications Impacts | 262.77d? | 2010-12-16 A | 2011-12-14 A | 100% |  | 2010-12-16 | 2011-12-14 | 262.77d? |  | finish no earlier than 2011-12-14 | S1 | 2083.59h | 2083.59h | FS_MODAI | PCG-26 | Huawei, China Mobile | Amar Deol (adeol@huawei.com), Gang Li | Rel-12 | SP-50 | Alain | FS_MODAI |  |  |  |  |
| 2274 | 499 | Study on Proximity-based Services | 384d? | 2011-09-22 A | 2013-03-05 A | 100% |  | 2011-09-22 | 2013-03-05 | 384d? |  | finish no earlier than 2012-12-12 | S1 | 3045.82h | 3045.82h | FS_ProSe | PCG-27 | Qualcomm | Rich Hovey (rhovey@qualcomm.com) | Rel-12 | SP-53 | Alain | FS_ProSe |  | Public Safety (A-A) |  |  |
| 2275 | 500 | Study on User Plane Congestion management | 198d? | 2011-12-14 A | 2012-09-12 A | 100% |  | 2011-12-14 | 2012-09-12 | 198d? |  | finish no earlier than 2012-09-12 | S1 | 1568h | 1568h | FS_UPCON | PCG-28 | KDDI | John Visser (jvisser@rogers.com) | Rel-12 | SP-54 | Alain | FS_UPCON |  |  |  |  |
| 2276 | 501 | Study on RAN Sharing Enhancements | 401d? | 2011-12-14 A | 2013-06-19 A | 100% |  | 2011-12-14 | 2013-06-19 | 401d? |  | finish no earlier than 2013-06-19 | S1 | 3192h | 3192h | FS_RSE | PCG-28 | NEC | joerg.swetina@neclab.eu | Rel-12 | SP-54 | Alain | FS_RSE |  |  |  |  |
| 2277 | 502 | Deleted - Study on UICC/USIM enhancements | 588d? | 2009-12-10 A | 2012-03-07 A | 100% |  | 2009-12-10 | 2012-03-07 | 588d? |  | finish no earlier than 2012-03-07 | S1 | 4704h | 4704h | FS_U2e | PCG-24 | Giesecke & Devrient | ilario.macchi@gi-de.com | Rel-12 | SP-46 | Alain | FS_U2e |  |  | PCG-28 | SP-55 |
| 2278 | 503 | **Study on IMS based Peer-to-Peer Content Distribution Services (Stage 2)** | 587d? | 2010-09-23 A | 2012-12-12 A | 100% |  | 2010-09-23 | 2012-12-12 | 587d? |  |  | S2; S1; S3 | 19472h | 19472h | FS_IMS_P2P_CDS | PCG-25 | China Mobile | Yu Qing (yuqing@chinamobile.com) | Rel-12 | SP-49 | Maurice | FS_IMS_P2P_CDS |  |  |  |  |
| 2279 | 503.1 | SA1 part of Study on IMS based Peer-to-Peer Content Distribution Services (Stage 2) | 262d? | 2010-09-23 A | 2011-09-21 A | 100% |  | 2010-09-23 | 2011-09-21 | 262d? |  | finish no earlier than 2011-09-21 | S1 | 2080h | 2080h | FS_IMS_P2P_CDS | PCG-25 | China Mobile | Yu Qing (yuqing@chinamobile.com) | Rel-12 | SP-49 | Maurice |  |  |  |  |  |
| 2280 | 503.2 | SA2 part of Study on IMS based Peer-to-Peer Content Distribution Services (Stage 2) | 347d? | 2010-09-23 A | 2012-06-20 A | 100% |  | 2010-09-23 | 2012-06-20 | 347d? |  | finish no earlier than 2012-06-08 | S2 | 2776h | 2776h | FS_IMS_P2P_CDS | PCG-25 | China Mobile | Yu Qing (yuqing@chinamobile.com) | Rel-12 | SP-49 | Maurice |  |  |  |  |  |
| 2281 | 503.3 | SA3 part of Study on IMS based Peer-to-Peer Content Distribution Services (Stage 2) | 68d? | 2012-09-12 A | 2012-12-12 A | 100% |  | 2012-09-12 | 2012-12-12 | 68d? |  | finish no earlier than 2012-12-12 | S3 | 528h | 528h | FS_IMS_P2P_CDS | PCG-29 | China Mobile | Zhu Judy(zhuhongru@chinamobile.com) | Rel-12 | SP-57 | Mirko |  |  |  |  |  |
| 2282 | 504 | **Study on Core Network Overload solutions** | 852d? | 2010-09-23 A | 2013-12-11 A | 100% |  | 2010-09-23 | 2013-12-11 | 852d? |  |  | S2 | 18240.6h | 18240.6h | FS_CNO | PCG-25 | Huawei | Mirko.Schramm@huawei.com | Rel-12 | SP-49 | Maurice | FS_CNO |  |  |  |  |
| 2283 | 504.1 | Study on Core Network Overload solutions (Phase 1) | 587d? | 2010-09-23 A | 2012-12-12 A | 100% |  | 2010-09-23 | 2012-12-12 | 587d? |  | finish no earlier than 2012-12-12 | S2 | 4684.11h | 4684.11h | FS_CNO | PCG-25 | Huawei | Mirko.Schramm@huawei.com | Rel-12 | SP-49 | Maurice |  |  |  |  |  |
| 2284 | 504.2 | Study on Core Network Overload solutions (Phase 2) | 844d? | 2010-09-23 A | 2013-12-11 A | 100% |  | 2010-09-23 | 2013-12-11 | 844d? |  | finish no earlier than 2013-12-11 | S2 | 6744h | 6744h | FS_CNO | PCG-25 | Huawei | Mirko.Schramm@huawei.com | Rel-12 | SP-49 | Maurice |  |  |  |  |  |
| 2285 | 505 | Study on System Enhancements for Energy Efficiency | 399d? | 2010-12-16 A | 2012-06-20 A | 100% |  | 2010-12-16 | 2012-06-20 | 399d? |  | finish no earlier than 2012-06-20 | S2 | 3192h | 3192h | FS_SEEE | PCG-26 | Huawei | frank.mademann@huawei.com | Rel-12 | SP-50 | Maurice | FS_SEEE |  |  |  |  |
| 2286 | 506 | Study on S2a Mobility based On GTP and WLAN access to EPC | 657d? | 2011-03-23 A | 2013-09-11 A | 100% |  | 2011-03-23 | 2013-09-11 | 657d? |  | finish no earlier than 2013-09-11 | S2 | 5165.94h | 5165.94h | FS_SaMOG | PCG-26 | ZTE | Tricci So (tso@zteusa.com) | Rel-12 | SP-51 | Maurice | FS_SaMOG |  | WLAN |  |  |
| 2287 | 507 | Study on Optimized Offloading to WLAN in 3GPP-RAT Mobility | 326d? | 2012-06-18 A | 2013-09-11 A | 100% |  | 2012-06-18 | 2013-09-11 | 326d? |  | finish no earlier than 2013-09-11 | S2 | 2592h | 2592h | FS_WORM | PCG-29 | BlackBerry | Steve Barrett (sbarrett@blackberry.com) | Rel-12 | SP-56 | Maurice | FS_WORM |  | WLAN |  |  |
| 2288 | 508 | Study on Application Based Charging | 190d? | 2012-06-18 A | 2013-03-06 A | 100% |  | 2012-06-18 | 2013-03-06 | 190d? |  | finish no earlier than 2013-03-06 | S2 | 1520h | 1520h | FS_ABC | PCG-29 | Allot | Alla Goldner (agoldner@allot.com) | Rel-12 | SP-56 | Maurice | FS_ABC |  |  |  |  |

Notes:
- 2259: Triggered by Rel-12 UTRA TR 25.704 Study on Enhanced Broadcast of System Information (FS_UTRA_SIBenh) / Impacted TSs and TRs: UTRA
- 2260: RP#65 completed / Impacted TSs and TRs: 25.211, 25.212 , 25.213, 25.214, 25.301, 25.302, 25.304, 25.306, 25.321, 25.331, 25.433
- 2261: ; Stat Rep: RP-141230->RP-142080 / Impacted TSs and TRs: 25.101, 25.104, 25.133, 25.141
- 2262: Triggered by Rel-12 UTRA TR 25.700 Study on Further Enhanced Uplink (EUL) enhancements (FS_EDCH_enh) / Impacted TSs and TRs: UTRA
- 2263: ; Stat Rep: RP-141684->RP-141860 / Impacted TSs and TRs: 25.211, 25.212, 25.214, 25.304, 25.306, 25.308, 25.319, 25.321, 25.331, 25.423, 25.425, 25.433, 25.435
- 2264: ; CD:Wed 18/03/15->Sun 15/03/15; Stat Rep: RP-141684->RP-141860 1st Apr 15: Compl:75%->100% 1st Apr 15: Stat Rep: RP-141860->RP-150062 / Impacted TSs and TRs: 25.101, 25.104, 25.133, 25.141
- 2265: -
- 2266: Mar15: In WGLC / Impacted TSs and TRs: draft-ietf-insipid-session-id
- 2267: -
- 2268: -
- 2269: SP#55 completed. Determine an alternative to E.164 for identifying individual devices and route messages between those devices / Impacted TSs and TRs: 22.988
- 2270: SP#59 completed. TR 22.888 v100 for Information & Approval. Study addition of new MTC-related use cases and functionality and improvements to existing requirements in TS 22.368 / Impacted TSs and TRs: 22.888
- 2271: SP#55 completed. Linked to SA3 Study on Single Sign On (SSO) Application Security for IMS - based on SIP Digest (UID_480048), SA3 TR 33.924 Extended Identity Management (GBA-IdM) and SA3 TR 33.980 (LibSec) / Impacted TSs and TRs: 22.895
- 2272: SP#54 completed. Linked to SA1 Rel-11 Feature UID_490030 SIPTO Service Continuity of IP Data Session (SIPTO_SC) / Impacted TSs and TRs: 22.896
- 2273: SP#54 completed. Linked to UID_490036 SA2 Rel-11 TR 23.843 Study on Core Network Overload solutions (FS_CNO) / Impacted TSs and TRs: 22.801
- 2274: SP#59 completed / Impacted TSs and TRs: 22.803
- 2275: SP#57 completed. Linked to SAPP (Service Awareness and Privacy Policies), FS_UMONC (Study on Usage Monitoring Control Enhancement), QoS_SSL (QoS Control Based on Subscriber Spending Limits) / Impacted TSs and TRs: 22.805
- 2276: SP#60 completed. Extend Rel-6 Network Sharing UID_31018 (basic scenarios of network/RAN sharing) to cover more complex scenarios that arise due to recent needs for more dynamic co-operation among operators / Impacted TSs and TRs: 22.852
- 2277: SP#55 work stopped. Triggered by GSMA Smart SIM and 3GNBK projects, and to evolve from traditional USAT to multimedia USIM toolkit support, particularly to Smart Card Web Server / Impacted TSs and TRs: 22.817
- 2278: Triggered by TR 22.906 SA1 Study on IMS based Peer-to-Peer Content Distribution Services UID_450047 / Impacted TSs and TRs: 23.844
- 2279: SP#53 completed / Impacted TSs and TRs: 23.844
- 2280: SP#56 completed. TR 23.844v100 for Information and Approval / Impacted TSs and TRs: 23.844
- 2281: SP#58 completed. TR 33.844 v100 for Information and Approval / Impacted TSs and TRs: 33.844
- 2282: SP#62 completed. Linked to CT4 TR 23.857 Study on EPC Nodes Restoration (UID_490014) / Impacted TSs and TRs: 23.843
- 2283: Phase 1: complete study of overload control related to MAP /Diameter signalling, other 3GPP Core Network signalling optimization / Impacted TSs and TRs: 23.843
- 2284: SP#62 completed / Impacted TSs and TRs: 23.843
- 2285: SP#56 completed / Impacted TSs and TRs: 23.866
- 2286: SP#61 completed. Covers generic non-3GPP access (e.g. WLAN, WIMAX, CDMA/HRPD). Spin-off Feature SaMOG_WLAN. Linked to Rel-8 Support for non-3GPP accesses, Rel-10 SMOG, Rel-11 BBAI / Impacted TSs and TRs: 23.852
- 2287: SP#61 completed. Linked to UID_350027 SAE for support for non-3GPP accesses (SAES-SA-FP_n3GPP), UID_410043 MAPIM, UID_450041 IFOM, UID_530046 SaMOG / Impacted TSs and TRs: 23.890
- 2288: SP#59 completed. Linked to Rel-11 Feature UID_500032 Service Awareness and Privacy Policies (SAPP) / Impacted TSs and TRs: 23.800

| ID | WBS | Task | Duration | Start | Finish | Complete | Baseline start | Baseline finish | Baseline duration | Constraint | Resources | Work | Actual work | Acronym | PCG approved | Impacted TSs and TRs | WI rapporteur name | WI rapporteur e-mail | Release | TSG approved | MCC resp | Acronym_3GU_Export | PCG stopped | TSG stopped | Special Focus Doc | Status Report |
| --- | --- | --- | --- | --- | --- | --- | --- | --- | --- | --- | --- | --- | --- | --- | --- | --- | --- | --- | --- | --- | --- | --- | --- | --- | --- | --- |
| 2289 | 509 | **Study on Multi Access PDN connectivity and IP flow Mobility** | 1141.96d? | 2008-08-08 A | 2012-12-12 A | 100% | 2008-08-08 | 2012-12-12 | 1141.96d? |  | S2; S1 | 27327.4h | 27327.4h | FS_MAPIM | PCG-21 | 23.861 | Qualcomm | Gerardo Giaretta (gerardog@qualcomm.com) | Rel-12 | SP-41 | Maurice | FS_MAPIM |  |  |  |  |
| 2290 | 509.1 | SA1 part of Study on Multi Access PDN connectivity and IP flow Mobility | 22d? | 2008-08-08 A | 2011-09-21 A | 100% | 2008-08-08 | 2011-09-21 | 22d? | finish no earlier than 2011-09-21 | S1 | 160h | 160h | FS_MAPIM | PCG-21 | 23.861 | Qualcomm | Gerardo Giaretta (gerardog@qualcomm.com) | Rel-12 | SP-41 | Maurice |  |  |  |  |  |
| 2291 | 509.2 | SA2 part of Study on Multi Access PDN connectivity and IP flow Mobility | 1113d? | 2008-09-18 A | 2012-12-12 A | 100% | 2008-09-18 | 2012-12-12 | 1113d? | finish no earlier than 2012-12-12 | S2 | 8896h | 8896h | FS_MAPIM | PCG-21 | 23.861 | Qualcomm | Gerardo Giaretta (gerardog@qualcomm.com) | Rel-12 | SP-41 | Maurice |  |  |  |  |  |
| 2292 | 510 | Deleted - Study on IP Flow Mobility support for S2a and S2b Interfaces | 190d? | 2012-06-18 A | 2013-03-06 A | 100% | 2012-06-18 | 2013-03-06 | 190d? | finish no earlier than 2013-03-06 | S2 | 1520h | 1520h | FS_NBIFOM | PCG-29 | 23.861 | ZTE | Tricci So (tso@zteusa.com) | Rel-12 | SP-56 | Maurice | FS_NBIFOM | PCG-30 | SP-59 |  |  |
| 2293 | 511 | Study on Extended IMS Media Plane Security features | 719d? | 2010-06-10 A | 2013-03-06 A | 100% | 2010-06-10 | 2013-03-06 | 719d? | finish no earlier than 2013-03-06 | S3 | 5736h | 5736h | FS_eMEDIASEC | PCG-25 | 33.829 | Vodafone | Aguibou.Barry@vodafone.com | Rel-12 | SP-48 | Mirko | FS_eMEDIASEC |  |  |  |  |
| 2294 | 512 | Deleted - Study on Firewall traversal (Stage 2) | 854d? | 2011-06-17 A | 2014-09-17 A | 100% | 2011-06-17 | 2014-09-17 | 854d? | finish no earlier than 2014-09-17 | S3 | 6832h | 6832h | FS_Fire | PCG-27 | 33.830 | Acme Packet | Prashant Kumar (PKumar@acmepacket.com) | Rel-12 | SP-53 | Mirko | FS_Fire | PCG-33 | SP-65 |  |  |
| 2295 | 513 | Study on Security on spoofed call detection and prevention (Stage 2) | 662d? | 2012-03-07 A | 2014-09-17 A | 100% | 2012-03-07 | 2014-09-17 | 662d? | finish no earlier than 2014-09-17 | S3 | 5296h | 5296h | FS_SPOOF | PCG-28 | 33.831 | China Mobile | lixiangjun@chinamobile.com | Rel-12 | SP-55 | Mirko | FS_SPOOF |  |  |  |  |
| 2296 | 514 | Study on Security Assurance Methodology for 3GPP Network Elements | 466d? | 2012-09-13 A | 2014-06-18 A | 100% | 2012-09-13 | 2014-06-18 | 466d? | finish no earlier than 2014-03-07 | S3 | 3696h | 3696h | FS_SECAM | PCG-29 | 33.805 | Orange | loic.habermacher@orange.com | Rel-12 | SP-57 | Mirko | FS_SECAM |  |  |  |  |
| 2297 | 515 | Study on Improved Support for Dynamic Adaptive Streaming over HTTP in 3GPP | 729d? | 2011-12-14 A | 2014-09-16 A | 100% | 2011-12-14 | 2014-09-17 | 729d? | finish no earlier than 2014-09-17 | S4 | 5824h | 5824h | FS_IS_DASH | PCG-28 | 26.938 | Qualcomm | c_tstock@qualcomm.com | Rel-12 | SP-54 | Paolo | FS_IS_DASH |  |  |  |  |
| 2298 | 516 | Study on HTML5 for a new presentation layer in 3GPP services | 266d? | 2013-09-12 A | 2014-09-16 A | 100% | 2013-09-12 | 2014-09-17 | 266d? | finish no earlier than 2014-09-17 | S4 | 2128h | 2128h | FS_HTML5 | PCG-31 | 26.907 | Samsung | Imed Bouazizi (i.bouazizi@sta.samsung.com) | Rel-12 | SP-61 | Paolo | FS_HTML5 |  |  |  |  |
| 2299 | 517 | Study on version handling | 716d? | 2010-03-25 A | 2012-12-12 A | 100% | 2010-03-25 | 2012-12-12 | 716d? | finish no earlier than 2012-12-12 | S5 | 5704h | 5704h | FS_OAM_VH | PCG-24 | 32.830 | Ericsson | thomas.tovinger@ericsson.com | Rel-12 | SP-47 | Mirko | FS_OAM_VH |  |  |  |  |
| 2300 | 518 | Study on management of Heterogeneous Networks | 852d? | 2011-03-23 A | 2014-06-18 A | 100% | 2011-03-23 | 2014-06-18 | 852d? | finish no earlier than 2014-06-18 | S5 | 6816h | 6816h | FS_OAM_HetNet | PCG-26 | 32.835 | Ericsson | ulf.hubinette@ericsson.com | Rel-12 | SP-51 | Mirko | FS_OAM_HetNet |  |  |  |  |
| 2301 | 519 | Study on OAM aspects of Network Sharing | 464d? | 2011-12-07 A | 2013-09-11 A | 100% | 2011-12-07 | 2013-09-11 | 464d? | finish no earlier than 2013-09-11 | S5 | 3696h | 3696h | FS_OAM_SHARE | PCG-28 | 32.851 | Alcatel-Lucent, Huawei | Padma.Sudarsan@alcatel-lucent.com, zoulan@huawei.com | Rel-12 | SP-54 | Mirko | FS_OAM_SHARE |  |  |  |  |
| 2302 | 520 | Study on Enhanced Network Management (NM) centralized Coverage and Capacity Optimization | 590d? | 2011-09-21 A | 2014-09-17 A | 100% | 2011-09-21 | 2014-09-17 | 590d? | finish no earlier than 2014-09-17 | S5 | 4712h | 4712h | FS_SON_NM_CCO | PCG-29 | 32.836 | Ericsson | robert.petersen@ericsson.com | Rel-12 | SP-56 | Mirko | FS_SON_NM_CCO |  |  | SON |  |
| 2303 | 521 | Study on WLAN management | 788d? | 2011-09-21 A | 2014-09-17 A | 100% | 2012-06-20 | 2014-09-17 | 590d? | finish no earlier than 2014-09-17 | S5 | 6304h | 6304h | FS_WLAN_OAM | PCG-29 | 28.680, 28.681, 28.682, 28.683, 28.403 | Intel | joey.chou@intel.com | Rel-12 | SP-56 | Mirko | FS_WLAN_OAM |  |  | WLAN |  |
| 2304 | 522 | Study on Alarm Management | 201d? | 2012-12-07 A | 2013-09-11 A | 100% | 2012-12-07 | 2013-09-11 | 201d? | finish no earlier than 2013-09-11 | S5 | 1592h | 1592h | FS_OAM_AM | PCG-30 | 32.859 | TeliaSonera | tommy.berggren@teliasonera.com | Rel-12 | SP-58 | Mirko | FS_OAM_AM |  |  |  |  |
| 2305 | 523 | Study on Indication of Network to Network Interface (NNI) Routeing scenarios in SIP requests | 400d? | 2012-12-10 A | 2014-06-13 A | 100% | 2012-12-10 | 2014-06-13 | 400d? | finish no earlier than 2014-03-06 | C3 | 3190.27h | 3190.27h | FS_NNI_RS | PCG-30 | 24.802 | Ericsson | Jan.Holm@ericsson.com | Rel-12 | CP-58 | Adrian | FS_NNI_RS |  |  |  |  |
| 2306 | 524 | Study on Diameter Overload Control Mechanisms | 464d? | 2012-01-05 A | 2014-09-11 A | 100% | 2012-01-05 | 2014-09-12 | 464d? | finish no earlier than 2014-09-12 | C4 | 3712h | 3712h | FS_DOCME | PCG-30 | 29.809 | Orange | lionel.morand@orange.com | Rel-12 | CP-58 | Kimmo | FS_DOCME |  |  |  |  |
| 2307 | 525 | Study on XML based access of AF to the PCRF | 203d? | 2013-03-01 A | 2013-12-04 A | 100% | 2013-03-01 | 2014-06-13 | 341d? | finish no earlier than 2014-06-13 | C3 | 1608h | 1608h | FS_XML_AF_PCRF | PCG-30 | 29.817 | Alcatel-Lucent | horst.brinkman@alcatel-lucent.com | Rel-12 | CP-59 | Adrian | FS_XML_AF_PCRF |  |  |  |  |
| 2308 | 526 | Study on Technical aspects on Roaming End-to-end scenarios with VoLTE IMS and other networks | 328d? | 2013-09-09 A | 2014-12-09 A | 100% | 2013-09-09 | 2014-09-12 | 266d? | finish no earlier than 2014-12-09 | C3 | 2624h | 2624h | FS_REVOLTE_IMS | PCG-31 | 29.949 | Deutsche Telekom | Roland Jesske (r.jesske@telekom.de) | Rel-12 | CP-61 | Adrian | FS_REVOLTE_IMS |  |  |  |  |
| 2309 | 527 | Study on Development of conformance requirements for the IP Multimedia Services Identity Module (ISIM) application support in ME | 263d? | 2013-12-09 A | 2014-12-09 A | 100% | 2013-12-09 | 2014-09-12 | 201d? | finish no earlier than 2014-12-09 | C6 | 2104h | 2104h | FS_ISIM_CR | PCG-32 | 31.829 | Gemalto | ly-thanh.phan@gemalto.com | Rel-12 | CP-62 | Xavier | FS_ISIM_CR |  |  |  |  |
| 2310 | 528 | Study on Shared Data Update for Multiple Subscribers | 263d? | 2013-12-06 A | 2014-12-09 A | 100% | 2013-12-06 | 2014-09-12 | 201d? | finish no earlier than 2014-12-09 | C4 | 2104h | 2104h | FS_SHARED_SubData_UPD | PCG-32 | 29.854 | Huawei | Susan Shi (susan.shishufeng@huawei.com) | Rel-12 | CP-62 | Kimmo | FS_SHARED_SubData_UPD |  |  |  |  |
| 2311 | 529 | Study on GERAN improvements for Machine-Type Communications | 661d? | 2010-05-24 A | 2012-11-23 A | 100% | 2010-05-24 | 2012-11-23 | 661d? | finish no earlier than 2012-11-23 | G1; G2 | 10576h | 10576h | FS_NIMTC_GERAN | PCG-24 | 43.868 | Ericsson | paul.schliwa-bertling@ericsson.com | Rel-12 | GP-44 | Paolo | FS_NIMTC_GERAN |  |  | MTC, M2M |  |
| 2312 | 530 | Study on Voice services over Adaptive Multi-user channels on One Slot (VAMOS) enhancements | 267.67d? | 2010-10-27 A | 2014-05-30 A | 100% | 2010-10-27 | 2014-05-30 | 267.67d? | finish no earlier than 2014-05-30 | GP; G2; G1 | 6424h | 6424h | FS_eVAMOS | PCG-27 | 43.801 | China Mobile, Huawei | Chao Luo (chluo@huawei.com), dengjuan@chinamobile.com | Rel-12 | GP-50 | Paolo | FS_eVAMOS |  |  |  |  |
| 2313 | 531 | Study on GERAN enhancements for Mobile Data Applications | 430d? | 2011-04-04 A | 2014-08-29 A | 100% | 2011-04-04 | 2014-08-29 | 430d? | finish no earlier than 2014-08-29 | G2; G1 | 6880h | 6880h | FS_GERAN_eMDA | PCG-27 | 43.802 | Huawei | ming.fang@huawei.com | Rel-12 | GP-50 | Gert | FS_GERAN_eMDA |  |  |  |  |
| 2314 | 532 | Study on Inclusion of RF Pattern Matching Technologies as a positioning method in the E-UTRAN | 722d? | 2010-12-10 A | 2013-09-06 A | 100% | 2010-12-10 | 2013-09-06 | 722d? | finish no earlier than 2013-09-06 | R4 | 5776h | 5776h | FS_LCS_LTE_RFPMT | PCG-26 | LTE 36.809 | Polaris Wireless | Scot Gordon (sgordon@polariswireless.com) | Rel-12 | RP-50 | Issam | FS_LCS_LTE_RFPMT |  |  |  | RP-131082 |
| 2315 | 533 | Study on Provision of low-cost MTC UEs based on LTE | 462d? | 2011-09-19 A | 2013-06-14 A | 100% | 2011-09-19 | 2013-06-14 | 462d? | finish no earlier than 2013-06-14 | R1; R2; R4 | 11088h | 11088h | FS_LC_MTC_LTE | PCG-27 | LTE 36.888 | Vodafone | prakash.bhat@vodafone.com | Rel-12 | RP-53 | Patrick | FS_LC_MTC_LTE |  |  | MTC, M2M | RP-130583 |
| 2316 | 534 | Deleted - Study on Mobile Relay for E-UTRA | 881.5d? | 2005-05-19 A | 2014-06-23 A | 100% | 2005-05-19 | 2014-06-23 | 881.5d? | finish no earlier than 2014-06-23 | R3; R1 | 14104h | 14104h | FS_LTE_mobRelay | PCG-27 | LTE 36.836 | CATT | Haijing Hu (huhaijing@catt.cn) | Rel-12 | RP-53 | Juha | FS_LTE_mobRelay | PCG-33 | RP-64 |  | RP-140726 |
| 2317 | 535 | Study on Scenarios and Requirements of LTE Small Cell Enhancements for E-UTRA and E-UTRAN | 66d? | 2012-09-11 A | 2012-12-07 A | 100% | 2012-09-11 | 2012-12-07 | 66d? | finish no earlier than 2012-12-07 | RP | 528h | 528h | FS_LTE_SC_enh_req | PCG-29 | LTE 36.932 | China Mobile | Hai TANG (tanghai@chinamobile.com) | Rel-12 | RP-57 | Yong-Jun | FS_LTE_SC_enh_req |  |  | Small cell | RP-121651 |
| 2318 | 536 | Study on Small Cell Enhancements for E-UTRA and E-UTRAN – Physical-layer aspects | 265d? | 2012-09-11 A | 2013-09-06 A | 100% | 2012-09-11 | 2013-09-06 | 265d? | finish no earlier than 2013-09-06 | R1; R2; R4 | 6360h | 6360h | FS_LTE_SC_enh_L1 | PCG-30 | LTE 36.872 | Huawei | Elean Fan (fanxiaoan@huawei.com) | Rel-12 | RP-58 | Patrick | FS_LTE_SC_enh_L1 |  |  | Small cell | RP-131618 |
| 2319 | 537 | Study on Small Cell Enhancements for E-UTRA and E-UTRAN – Higher-layer aspects | 265d? | 2012-12-10 A | 2013-12-06 A | 100% | 2012-12-10 | 2013-12-06 | 265d? | finish no earlier than 2013-12-06 | R2; R3 | 4240h | 4240h | FS_LTE_SC_enh_hilayer | PCG-30 | LTE 36.842 | NTT DOCOMO | Hideaki Takahashi (h-takahashi@nttdocomo.co.jp) | Rel-12 | RP-58 | Yong-Jun | FS_LTE_SC_enh_hilayer |  |  | Small cell | RP-131619 |
| 2320 | 538 | Study on LTE Device-to-Device Proximity Services - Radio Aspects | 325d? | 2012-12-17 A | 2014-03-06 A | 100% | 2012-12-17 | 2014-03-06 | 325d? | finish no earlier than 2014-03-06 | R1; R2; R3; R4 | 10400h | 10400h | FS_LTE_D2D_Prox | PCG-30 | LTE 36.843 | Qualcomm | Shailesh Patil (patil@qti.qualcomm.com) | Rel-12 | RP-58 | Patrick | FS_LTE_D2D_Prox |  |  | Public Safety (A-A) | RP-140416 |
| 2321 | 539 | Study on 3D-channel model for Elevation Beamforming and FD-MIMO studies for LTE | 463d? | 2012-12-10 A | 2014-09-12 A | 100% | 2012-12-10 | 2014-09-12 | 463d? | finish no earlier than 2014-09-12 | R1 | 3704h | 3704h | FS_LTE_3D_channel | PCG-30 | LTE 36.873 | Nokia Networks | bishwarup.mondal@nsn.com | Rel-12 | RP-58 | Patrick | FS_LTE_3D_channel |  |  |  | RP-141206 |
| 2322 | 540 | Study on Energy Saving Enhancement for E-UTRAN | 397d? | 2012-12-10 A | 2014-06-13 A | 100% | 2012-12-10 | 2014-06-13 | 397d? | finish no earlier than 2014-06-13 | R3 | 3176h | 3176h | FS_Netw_Energy_enh_LTE | PCG-30 | LTE 36.887 | China Mobile | Kimba Dit Adamou, Boubacar (jinba@chinamobile.com) | Rel-12 | RP-58 | Juha | FS_Netw_Energy_enh_LTE |  |  |  | RP-140604 |
| 2323 | 541 | Study on Expansion of LTE_FDD_1670_US to include 1670-1680MHz Band for LTE in the US | 469d? | 2013-03-01 A | 2014-12-15 A | 100% | 2013-03-01 | 2014-09-12 | 403d? | finish no earlier than 2014-12-15 | R4 | 3752h | 3752h | FS_LTE_FDD_1670_US | PCG-30 | LTE 36.844 | LightSquared | masoud.olfat@lightsquared.com | Rel-13 | RP-59 | Issam | FS_LTE_FDD_1670_US |  |  |  | RP-141815 |
| 2324 | 542 | Study on Cell-specific Reference Signals (CRS) Interference Mitigation for homogenous deployments for LTE | 201d? | 2013-03-04 A | 2013-12-06 A | 100% | 2013-03-04 | 2013-12-06 | 201d? | finish no earlier than 2013-12-06 | R4 | 1608h | 1608h | FS_LTE_CRSIC | PCG-30 | LTE 36.863 | Ericsson | shaohua.li@ericsson.com | Rel-12 | RP-59 | Issam | FS_LTE_CRSIC |  |  |  | RP-131623 |
| 2325 | 543 | Study on Network-Assisted Interference Cancellation and Suppression for LTE | 265d? | 2013-03-08 A | 2014-03-06 A | 100% | 2013-03-08 | 2014-03-06 | 265d? | finish no earlier than 2014-03-06 | R1; R4 | 4240h | 4240h | FS_LTE_NAICS | PCG-30 | LTE 36.866 | MediaTek | jeff.zhuang@mediatek.com | Rel-12 | RP-59 | Patrick | FS_LTE_NAICS |  |  |  | RP-132108 |
| 2326 | 544 | Study on Coordinated Multi-Point (CoMP) operation for LTE with Non-Ideal Backhaul | 126d? | 2013-06-18 A | 2013-12-06 A | 100% | 2013-06-18 | 2013-12-06 | 126d? | finish no earlier than 2013-12-06 | R1 | 1008h | 1008h | FS_COMP_LTE_nibackhaul | PCG-31 | LTE 36.874 | Samsung | Hyojin Lee (hyojin257.lee@samsung.com) | Rel-12 | RP-60 | Patrick | FS_COMP_LTE_nibackhaul |  |  |  | RP-131626 |
| 2327 | 545 | Study on Group Communication for LTE | 130d? | 2013-09-10 A | 2014-03-06 A | 100% | 2013-09-10 | 2014-03-06 | 130d? | finish no earlier than 2014-03-06 | R2; R3 | 2080h | 2080h | FS_LTE_GC | PCG-31 | LTE 36.868 | Alcatel-Lucent | chandrika.worrall@alcatel-lucent.com | Rel-12 | RP-61 | Yong-Jun | FS_LTE_GC |  |  | Public Safety (A-A) | RP-140182 |
| 2328 | 546 | Study on Smart Congestion Mitigation in E-UTRAN | 130d? | 2013-09-09 A | 2014-03-06 A | 100% | 2013-09-09 | 2014-03-06 | 130d? | finish no earlier than 2014-03-06 | R2 | 1040h | 1040h | FS_SCM_LTE | PCG-31 | LTE 36.848 | LG Electronics | youngdae.lee@lge.com | Rel-12 | RP-61 | Yong-Jun | FS_SCM_LTE |  |  |  | RP-140102 |
| 2329 | 547 | Study on RAN aspects of RAN Sharing Enhancements for LTE | 136d? | 2013-12-06 A | 2014-06-13 A | 100% | 2013-12-06 | 2014-06-13 | 136d? | finish no earlier than 2014-06-13 | R3 | 1088h | 1088h | FS_RSE-RAN_LTE | PCG-32 | LTE 36.856 | NEC | Siva.Vakeesar@emea.nec.com | Rel-12 | RP-62 | Juha | FS_RSE-RAN_LTE |  |  |  | RP-140746 |
| 2330 | 548 | Study on RF and EMC requirements for active Antenna Array System (AAS) Base Station | 386d? | 2011-09-19 A | 2013-03-01 A | 100% | 2011-09-19 | 2013-03-01 | 386d? | finish no earlier than 2013-03-01 | R4; R1 | 6176h | 6176h | FS_AAS_BS_LTE_UTRA | PCG-27 | UTRA, LTE 37.840 | Huawei | Ronnie.zhang@huawei.com | Rel-12 | RP-53 | Issam | FS_AAS_BS_LTE_UTRA |  |  |  | RP-130124 |
| 2331 | 549 | Study on LTE-HRPD (High Rate Packet Data in 3GPP2) inter-RAT SON | 340d? | 2012-03-02 A | 2013-06-14 A | 100% | 2012-03-02 | 2013-06-14 | 340d? | finish no earlier than 2013-06-14 | R3 | 2712h | 2712h | FS_LTE_HRPD_SON | PCG-28 | UTRA, LTE 37.813 | China Telecom | Wu Jinlian (wujl@gsta.com) | Rel-12 | RP-55 | Juha | FS_LTE_HRPD_SON |  |  | SON | RP-130585 |
| 2332 | 550 | Study on Passive InterModulation (PIM) handling for UTRA and LTE Base Stations | 403d? | 2012-03-05 A | 2013-09-06 A | 100% | 2012-03-05 | 2013-09-06 | 403d? | finish no earlier than 2013-09-06 | R4; G1 | 6448h | 6448h | FS_BS_PIM | PCG-28 | UTRA, LTE 37.808 | Ericsson | johan.skold@ericsson.com | Rel-12 | RP-55 | Issam | FS_BS_PIM |  |  |  | RP-131076 |
| 2333 | 551 | Study on WLAN/3GPP Radio Interworking | 264d? | 2012-12-10 A | 2013-12-06 A | 100% | 2012-12-10 | 2013-12-06 | 264d? | finish no earlier than 2013-12-06 | R2 | 2104h | 2104h | FS_UTRA_LTE_WLAN_interw | PCG-30 | UTRA, LTE 37.834 | Intel | sasha.sirotkin@intel.com | Rel-12 | RP-58 | Yong-Jun | FS_UTRA_LTE_WLAN_interw |  |  | WLAN | RP-131611 |
| 2334 | 552 | Study on RAN Enhancements for UMTS/HSPA and LTE Interworking | 261d? | 2012-12-10 A | 2013-12-06 A | 100% | 2012-12-10 | 2013-12-06 | 261d? | finish no earlier than 2013-12-06 | R3 | 2088h | 2088h | FS_HSPA_LTE_interworking | PCG-30 | UTRA, LTE 37.852 | China Unicom | Meng Zhang (zhangmeng68@chinaunicom.cn) | Rel-12 | RP-58 | Juha | FS_HSPA_LTE_interworking |  |  |  | RP-131612 |
| 2335 | 553 | Study on Next-Generation SON for UTRA and LTE | 397d? | 2012-12-10 A | 2014-06-13 A | 100% | 2012-12-10 | 2014-06-13 | 397d? | finish no earlier than 2014-06-13 | R3 | 3176h | 3176h | FS_UTRA_LTE_NG_SON | PCG-30 | UTRA, LTE 37.822 | NSN | krzysztof.kordybach@nsn.com | Rel-12 | RP-58 | Juha | FS_UTRA_LTE_NG_SON |  |  | SON | RP-140747 |
| 2336 | 554 | Study on 2GHz FDD for UTRA and LTE in Region 1 (1980-2010MHz and 2170-2200MHz Bands) | 462d? | 2012-12-11 A | 2014-09-12 A | 100% | 2012-12-11 | 2014-09-12 | 462d? | finish no earlier than 2014-09-12 | R4 | 3696h | 3696h | FS_UTRA_LTE_1980_2170_REG1 | PCG-30 | UTRA, LTE 37.846 | DISH Network | johny.kim@dish.com, mariam.sorond@dish.com | Rel-12 | RP-58 | Issam | FS_UTRA_LTE_1980_2170_REG1 |  |  |  | RP-141099 |
| 2337 | 555 | Study on Base Station specification structure | 136d? | 2012-12-10 A | 2013-06-14 A | 100% | 2012-12-10 | 2013-06-14 | 136d? | finish no earlier than 2013-06-14 | R4 | 1088h | 1088h | FS_BSspec_struc | PCG-30 | UTRA, LTE, MSR 37.810 | Ericsson | johan.skold@ericsson.com | Rel-12 | RP-58 | Issam | FS_BSspec_struc |  |  |  | RP-130580 |
| 2338 | 556 | Study on RAN aspects of Machine Type and other mobile data applications Communications enhancements | 137d? | 2013-03-01 A | 2013-09-06 A | 100% | 2013-03-01 | 2013-09-06 | 137d? | finish no earlier than 2013-09-06 | R2 | 1096h | 1096h | FS_MTCe_RAN | PCG-30 | UTRA, LTE 37.869 | ZTE | sergio.parolari@zteitaly.com | Rel-12 | RP-59 | Yong-Jun | FS_MTCe_RAN |  |  | MTC, M2M | RP-131081 |
| 2339 | 557 | Study on UMTS heterogeneous networks | 331d? | 2012-06-12 A | 2013-09-06 A | 100% | 2012-06-12 | 2013-09-06 | 331d? | finish no earlier than 2013-09-06 | R1; R2; R3 | 7944h | 7944h | FS_UTRA_HetNet | PCG-29 | UTRA 25.800 | Huawei | carmela.cozzo@huawei.com | Rel-12 | RP-57 | Patrick | FS_UTRA_HetNet |  |  |  | RP-131606 |
| 2340 | 558 | Study on Scalable UMTS FDD bandwidth | 265d? | 2012-12-10 A | 2013-12-06 A | 100% | 2012-12-10 | 2013-12-06 | 265d? | finish no earlier than 2013-12-06 | R1; R4 | 4240h | 4240h | FS_UTRA_SCAL | PCG-30 | UTRA TR 25.701 | China Unicom | Han Xiao (hanxiao91@chinaunicom.cn) | Rel-12 | RP-58 | Patrick | FS_UTRA_SCAL |  |  |  | RP-132035 |
| 2341 | 559 | Deleted - Study on Scalable UMTS FDD bandwidth by Filtering | 136d? | 2013-12-09 A | 2014-06-13 A | 100% | 2013-12-09 | 2014-06-13 | 136d? | finish no earlier than 2014-06-13 | R1 | 1088h | 1088h | FS_UTRA_SCAL_FILT | PCG-32 | UTRA TR 25.701 | China Unicom | Han Xiao (hanxiao91@chinaunicom.cn) | Rel-12 | RP-62 | Patrick | FS_UTRA_SCAL_FILT | PCG-33 | RP-64 |  | RP-140988 |
| 2342 | 560 | Study on Dedicated Channel (DCH) enhancements for UMTS | 197d? | 2012-12-10 A | 2013-09-06 A | 100% | 2012-12-10 | 2013-09-06 | 197d? | finish no earlier than 2013-09-06 | R1 | 1576h | 1576h | FS_UTRA_DCHenh | PCG-30 | UTRA TR 25.702 | Qualcomm | Arjun Bharadwaj (arjunb@qti.qualcomm.com) | Rel-12 | RP-58 | Patrick | FS_UTRA_DCHenh |  |  |  | RP-131073 |
| 2343 | 561 | Study on Further Enhanced Uplink (EUL) enhancements | 265d? | 2012-12-10 A | 2013-12-06 A | 100% | 2012-12-10 | 2013-12-06 | 265d? | finish no earlier than 2013-12-06 | R2; R1; R3 | 6360h | 6360h | FS_EDCH_enh | PCG-30 | UTRA TR 25.700 | Ericsson | alessandro.caverni@ericsson.com | Rel-12 | RP-58 | Yong-Jun | FS_EDCH_enh |  |  |  | RP-131608 |
| 2344 | 562 | Study on HNB Emergency Warning Area for UTRA | 191d? | 2013-06-18 A | 2014-03-06 A | 100% | 2013-06-18 | 2014-03-06 | 191d? | finish no earlier than 2014-03-06 | R3 | 1520h | 1520h | FS_HNB_warn_area | PCG-31 | UTRA TR 25.703 | Alcatel-Lucent, Ip.access | Martin.Warner@alcatel-lucent.com, Kit.kilgour@ipaccess.com | Rel-12 | RP-60 | Juha | FS_HNB_warn_area |  |  | HNB | RP-140129 |
| 2345 | 563 | Study on Enhanced Broadcast of System Information | 66d? | 2013-09-09 A | 2013-12-06 A | 100% | 2013-09-09 | 2013-12-06 | 66d? | finish no earlier than 2013-12-06 | R2; R1 | 1056h | 1056h | FS_UTRA_SIBenh | PCG-31 | UTRA TR 25.704 | Ericsson | martin.van.der.zee@ericsson.com | Rel-12 | RP-61 | Yong-Jun | FS_UTRA_SIBenh |  |  |  | RP-131610 |
| 2346 | 564 | Release 11 Features | 342.75d? | 2013-06-02 A | 2014-09-16 A | 100% | 2013-06-02 | 2014-09-17 | 342.75d? | finish no earlier than 2014-09-17 | SP; CP; GP; RP | 10968h | 10968h |  |  |  |  |  | Rel-11 |  | All |  |  |  |  |  |

Notes:
- 2289: Spin-off Features MAPCON, IFOM. SP#58 completed FS_MAPIM part of 23.861 (continued under FS_NBIFOM)
- 2290: SP#53 completed
- 2291: SP#43 TR 23.861v100 for Information. SP#56 Rel-9 TR 23.861v130 renamed & progressed under new Study FS_NBIFOM. SP#58 completed the FS_MAPIM part of TR 23.861 (TR continued under FS_NBIFOM).
- 2292: SP#59 stopped (at 40% completion). SP#56 revives dormant Study FS_MAPIM. TR 23.861 title changed from (Multi Access PDN connectivity and IP flow mobility) to (Network based IP flow mobility)
- 2293: SP#59 completed. Continuation of Rel-9 Feature UID_430036 IMS Media Plane Security (MEDIASEC). Study solutions and extensions to features and functionality described in TR 33.828 and TS 33.328
- 2294: SP#65 stopped. Linked to Rel-12 Service and Media Reachability for Users over Restrictive Firewalls (SMURFs) UID_530043
- 2295: SP#65 completed. TR 33.831v100 for 1-step Approval. Linked to Rel-11 SPUCI TR 33.838
- 2296: SP#64 completed. Spin-off Rel-13 Feature SCAS. Study methodologies for specifying product security assurance and hardening requirements on 3GPP network elements (with associated test cases when feasible)
- 2297: SP#65 completed. TR 26.938v200 for Approval. SP#60 TR 26.938v100 for Information. Linked to Feature UID_470034 HTTP-based Streaming and Download Services
- 2298: SP#65 completed. TR 26.907v200 for Approval. SP#64 TR 26.907v100 for Information.
- 2299: SP#58 completed
- 2300: SP#64 completed
- 2301: SP#61 completed. Linked to Network Sharing UID_31018, SA1 22.951 (Service aspects and requirements for network sharing), SA2 23.251 (Network Sharing; Architecture)
- 2302: SP#65 completed. TR 32.836v200 for Approval. SP#63 split of Rel-12 SP-130045 WID (Enhanced NM Centralized Coverage and Capacity Optimization) into a Rel-12 Study (SP-140028) and a Rel-13 Normative WID (SP-140060)
- 2303: SP#65 revised WID SP-130042=>SP-140536 (split into Rel-12 Study & Rel-13 normative WI). Changed Title from "TR on WLAN impacts to Type-2 management interface to the 3GPP Network Manager". TR 32.841v200 for Approval. Completed; 14/09/15: WID:SP-140536->SP-150408
- 2304: SP#61 completed
- 2305: CP#64 completed
- 2306: CP#65 completed. TR 29.809 v200 for Approval. Triggered by SA2 Rel-12 TR 23.843 Study on Core Network Overload solutions (FS_CNO) UID_490036. Coordinate with CT3, SA5
- 2307: CP#64 completed. Investigate introducing an XML-based protocol (e.g. SOAP, Restful HTTP, etc.) between AF and PCRF for non-IMS applications
- 2308: CP#65 completion 09/14=>12/14. CP#64 TR 29.949v100 for Information.Dec.14:95->100
- 2309: CP#65 completion 09/14=>12/14. Gathering of all ISIM-related conformance requirements and the assessment of CT6 coverage; June2015: Compl:30%->100
- 2310: CP#65 TR 29.854v200 for Approval. Completion 09/14=>12/14. Dec.14: 80->85%. Mar.15: 100%
- 2311: GP#56 completed. GP#44 approved WID
- 2312: GP#62 completed. TR 43.801v100 for 1-step Approval. GP#50 approved WID. Triggered by Rel-8 TR 45.914 Study Multi-User-Reusing One Timeslot (MUROS) UID_50590 and Rel-9 VAMOS UID_420002
- 2313: GP#63 completed. TR~43.802v200 for Approval. GP#50 approved WID (mobile coucou). Triggered by RAN#51 (Mar 2011) WID in RP-110454 (LTE RAN Enhancements for Diverse Data Applications) UID_510031
- 2314: RP#61 completed. Linked to Rel-10 WI on Inclusion of RF Pattern Matching Technologies as a positioning method in the UTRAN (LCS_UMTS_RFPMT) UID_460005
- 2315: RP#60 completed
- 2316: RP#64 stopped at 80% completion
- 2317: RP#58 completed. TR 36.932 v100 for Information and Approval
- 2318: RP#62 completed. RP#61 TR 36.872v100 for 1-step approval. Triggered by Rel-12 TR 36.932 Study on Scenarios and Requirements of LTE Small Cell Enhancements for E-UTRA and E-UTRAN UID_570023
- 2319: RP#62 completed. Triggered by Rel-12 TR 36.932 Study on Scenarios and Requirements of LTE Small Cell Enhancements for E-UTRA and E-UTRAN UID_570023
- 2320: RP#63 completed. TR 36.843 for 1-step approval (90% complete). Started normative work. Linked to Rel-12 TR 22.803 Study on Proximity-based Services (FS_ProSe) and Feature ProSe
- 2321: RP#65 completed. Updated WID RP-130811=>RP-141237. TR 36.873v210 for Approval. Enhance performance with 3D-beamforming or with FD-MIMO. Study new channel modelling in both vertical and horizontal dimensions awa user locations in the network
- 2322: RP#64 completed. Identify potential solutions for energy saving in E-UTRAN non-overlapping scenario. Evaluate possible enhancements in overlapping scenario, so that a subset can be used for further investigation/standardization
- 2323: CD:Thu 11/12/14->Mon 15/12/14; Compl:80%->100%; Stat Rep: RP-141453->RP-141815
- 2324: RP#62 completed. Updated WID RP-130393=>RP-131840
- 2325: RP#63 completed. TR 36.866 (90% complete) for Approval. Started normative work
- 2326: RP#62 completed. Extension of Rel-11 CoMP Operation for LTE Downlink UID_530332)
- 2327: RP#63 completed. Evaluate ability of LTE to meet public safety requirements agreed in SA for GC (GC is a key functionality of Land Mobile Radio/Private Mobile Radio and public safety systems)
- 2328: RP#63 completed
- 2329: RP#64 completed. TR 36.856v100 for 1-step approval. Triggered by SA1 Re-12 TR 22.852 Study on RAN Sharing Enhancements (FS_RSE) and Rel-13 Feature RSE (TS 22.101 Stage 1)
- 2330: RP#59 completed
- 2331: RP#60 completed
- 2332: RP#61 completed (Conclusion: no spin-off WI). Linked to Rel-10 WI on Multi-standard radio Base Station RF requirements for non-contiguous spectrum deployments (MSR_NC) UID_480025
- 2333: RP#62 completed. Evaluate LTE-WLAN/UTRA-WLAN i/w procedures while improving (non-)seamless mobility. Deployed WLAN often under-utilized; User experience suboptimal when UE connects to overloaded WLAN.
- 2334: RP#62 completed. TR 37.852v100 for Information & Approval
- 2335: RP#64 completed. The study of SON features for small cell functionality covered by the Rel-12 small cell enhancement SIs (e.g. dual connectivity) is not in the scope of this study item
- 2336: RP#65 completed. Within EU these bands can be used for terrestrial mobile as a complement to mobile satellite services. Study adding an FDD band into UTRA/E-UTRA in applicable countries of Region 1
- 2337: RP#60 completed (1-step approval). Study new BS spec structure to avoid duplicate work for new RF features (in case of identical features among different RATs); avoid future discussions on how to implement new featurES in CP-150single-RAT/multi-RAT specs
- 2338: RP#61 completed
- 2339: RP#62 completed
- 2340: RP#62 completed. TR 25.701v200 for Approval
- 2341: RP#64 stopped at 85% completion. Follow-up of Rel-12 Study on scalable UMTS FDD bandwidth (FS_UTRA_SCAL). The result is captured in the same TR 25.701
- 2342: RP#61 completed
- 2343: RP#62 completed. TR 25.700v100 for Approval. Identify potential solutions to increase the uplink capacity, coverage and end-user performance (e.g. latency, achievable rates, etc.)
- 2344: RP#63 completed. TR 25.703 v100 for 1-step approval
- 2345: RP#62 completed. TR 25.704v100 for Information & Approval. Study need to add capacity to present SI Broadcast mechanism unchanged since R99
- 2346: -

| ID | WBS | Task | Duration | Start | Finish | Complete | Baseline start | Baseline finish | Baseline duration | Constraint | Resources | Work | Actual work | Acronym | PCG approved | WI rapporteur name | WI rapporteur e-mail | Release | TSG approved | MCC resp | Acronym_3GU_Export | Special Focus Doc | PCG stopped | TSG stopped |
| --- | --- | --- | --- | --- | --- | --- | --- | --- | --- | --- | --- | --- | --- | --- | --- | --- | --- | --- | --- | --- | --- | --- | --- | --- |
| 2347 | 565 | **Advanced IP Interconnection of Services** | 650d? | 2010-03-25 A | 2012-09-12 A | 100% | 2010-03-25 | 2012-09-12 | 650d? |  | S1; S2; C1; C3 | 34381.9h | 34381.9h | IPXS | PCG-24 | Telefónica | chris.friel@O2.com | Rel-11 | SP-47 | Alain | IPXS |  |  |  |
| 2348 | 565.1 | Stage 1 for Advanced IP Interconnection of Services | 392d | 2010-03-25 A | 2011-09-21 A | 100% | 2010-03-25 | 2011-09-21 | 392d | finish no earlier than 2011-09-21 | S1 | 3120h | 3120h | IPXS | PCG-24 | Telefónica | chris.friel@O2.com | Rel-11 | SP-47 | Alain |  |  |  |  |
| 2349 | 565.2 | Stage 2 for Advanced IP Interconnection of Services | 263d? | 2010-12-16 A | 2011-12-14 A | 100% | 2010-12-16 | 2011-12-14 | 263d? | finish no earlier than 2012-03-21 | S2 | 2085.91h | 2085.91h | IPXS | PCG-26 | Ericsson | fredrik.lindholm@ericsson.com | Rel-11 | SP-50 | Maurice |  |  |  |  |
| 2350 | 565.3 | **Stage 3 for Advanced IP Interconnection of Services** | 265d? | 2011-09-13 A | 2012-09-12 A | 100% | 2011-09-13 | 2012-09-12 | 265d? |  | C1; C3 | 8376h | 8376h | IPXS | PCG-27 | Ericsson | christer.holmberg@ericsson.com | Rel-11 | CP-53 | Frederic |  |  |  |  |
| 2351 | 565.3.1 | CT1 part of Stage 3 for Advanced IP Interconnection of Services | 262d? | 2011-09-16 A | 2012-09-12 A | 100% | 2011-09-16 | 2012-09-12 | 262d? | finish no earlier than 2012-12-07 | C1 | 2048h | 2048h | IPXS | PCG-27 | Ericsson | christer.holmberg@ericsson.com | Rel-11 | CP-53 | Frederic |  |  |  |  |
| 2352 | 565.3.2 | CT3 part of Stage 3 for Advanced IP Interconnection of Services | 262d? | 2011-09-13 A | 2012-09-07 A | 100% | 2011-09-13 | 2012-09-07 | 262d? | finish no earlier than 2012-09-07 | C3 | 2088h | 2088h | IPXS | PCG-27 | Ericsson | christer.holmberg@ericsson.com | Rel-11 | CP-53 | Adrian |  |  |  |  |
| 2353 | 566 | **System Improvements to Machine-Type Communications** | 1119d? | 2009-12-10 A | 2014-03-06 A | 100% | 2009-12-10 | 2014-03-06 | 1119d? |  | S1; S2; S5; C1; C3; C4; C6; R2; R3; R5 | 198763h | 198763h | SIMTC | PCG-25 | KPN | toon.norp@tno.nl | Rel-11 | SP-48 | Alain | SIMTC | MTC, M2M |  |  |
| 2354 | 566.1 | Stage 1 for SIMTC | 337d? | 2010-06-10 A | 2011-09-21 A | 100% | 2010-06-10 | 2011-09-21 | 337d? |  | S1 | 2683.46h | 2683.46h | SIMTC | PCG-25 | KPN | toon.norp@tno.nl | Rel-11 | SP-48 | Alain |  | MTC, M2M |  |  |
| 2355 | 566.2 | TR on Stage 2 for SIMTC | 593d? | 2010-06-10 A | 2012-09-12 A | 100% | 2010-06-10 | 2012-09-12 | 593d? | finish no earlier than 2012-09-12 | S2 | 4736h | 4736h | SIMTC | PCG-25 | Intel | puneet.jain@intel.com | Rel-11 | SP-48 | Maurice |  | MTC, M2M |  |  |
| 2356 | 566.3 | **BB1: Stage 2 Reachability Aspects of SIMTC** | 274d? | 2011-06-09 A | 2012-06-20 A | 100% | 2011-06-09 | 2012-06-20 | 274d? |  | S2 | 10773.1h | 10773.1h | SIMTC-Reach | PCG-27 | Intel | puneet.jain@intel.com | Rel-11 | SP-52 | Maurice | SIMTC-Reach | MTC, M2M |  |  |
| 2357 | 566.3.1 | Deleted - MTC Feature Control (described in TS 22.368, clause 7.1.1 and 23.888, clause 5.7) | 137d? | 2011-06-10 A | 2011-12-14 A | 100% | 2011-06-10 | 2011-12-14 | 137d? | finish no earlier than 2011-11-09 | S2 | 1088h | 1088h | SIMTC-Reach | PCG-27 | Intel | puneet.jain@intel.com | Rel-11 | SP-52 | Maurice |  | MTC, M2M | PCG-28 | SP-54 |
| 2358 | 566.3.2 | On-line device trigger | 273d? | 2011-06-09 A | 2012-06-20 A | 100% | 2011-06-09 | 2012-06-20 | 273d? | finish no earlier than 2012-06-20 | S2 | 2170.29h | 2170.29h | SIMTC-Reach | PCG-27 | Intel | puneet.jain@intel.com | Rel-11 | SP-52 | Maurice |  | MTC, M2M |  |  |
| 2359 | 566.3.3 | MTC Addressing | 138d? | 2011-06-09 A | 2011-12-14 A | 100% | 2011-06-09 | 2011-12-14 | 138d? | finish no earlier than 2012-03-21 | S2 | 1097.24h | 1097.24h | SIMTC-Reach | PCG-27 | Intel | puneet.jain@intel.com | Rel-11 | SP-52 | Maurice |  | MTC, M2M |  |  |
| 2360 | 566.3.4 | Identifiers – especially removal of MSISDN dependencies in the architecture | 273d? | 2011-06-09 A | 2012-06-20 A | 100% | 2011-06-09 | 2012-06-20 | 273d? | finish no earlier than 2012-06-20 | S2 | 2169.53h | 2169.53h | SIMTC-Reach | PCG-27 | Intel | puneet.jain@intel.com | Rel-11 | SP-52 | Maurice |  | MTC, M2M |  |  |
| 2361 | 566.3.5 | MSISDN-less / PS-Only | 196d? | 2011-06-13 A | 2012-03-07 A | 100% | 2011-06-13 | 2012-03-07 | 196d? | finish no earlier than 2012-03-07 | S2 | 1568h | 1568h | SIMTC-Reach | PCG-27 | Intel | puneet.jain@intel.com | Rel-11 | SP-52 | Maurice |  | MTC, M2M |  |  |
| 2362 | 566.3.6 | MTC related interfaces and functional entities to support above features (MTCsp, etc.) | 61d? | 2011-12-14 A | 2012-03-07 A | 100% | 2011-12-14 | 2012-03-07 | 61d? | finish no earlier than 2012-03-07 | S2 | 488h | 488h | SIMTC-Reach | PCG-28 | Intel | puneet.jain@intel.com | Rel-11 | SP-54 | Maurice |  | MTC, M2M |  |  |
| 2363 | 566.4 | **BB1: Stage 3 (CS+PS) Reachability Aspects of SIMTC** | 325d? | 2011-09-19 A | 2012-12-07 A | 100% | 2011-09-19 | 2012-12-07 | 325d? |  | C1; C3; C4; C6 | 19112h | 19112h | SIMTC-ReachCSPS | PCG-27 | Ericsson | mikael.wass@ericsson.com | Rel-11 | CP-53 | Frederic |  | MTC, M2M |  |  |
| 2364 | 566.4.1 | CT1 part of Stage 3 BB1: Reachability Aspects of SIMTC | 257d? | 2011-09-19 A | 2012-09-07 A | 100% | 2011-09-19 | 2012-09-07 | 257d? | finish no earlier than 2012-09-07 | C1 | 2048h | 2048h | SIMTC-ReachCSPS | PCG-27 | Ericsson | mikael.wass@ericsson.com | Rel-11 | CP-53 | Frederic |  | MTC, M2M |  |  |
| 2365 | 566.4.2 | CT3 part of Stage 3 BB1: Reachability Aspects of SIMTC | 257d? | 2011-09-19 A | 2012-09-07 A | 100% | 2011-09-19 | 2012-09-07 | 257d? | finish no earlier than 2012-09-07 | C3 | 2048h | 2048h | SIMTC-ReachCSPS | PCG-27 | Ericsson | mikael.wass@ericsson.com | Rel-11 | CP-53 | Adrian |  | MTC, M2M |  |  |
| 2366 | 566.4.3 | CT4 part of Stage 3 BB1: Reachability Aspects of SIMTC | 324d? | 2011-09-19 A | 2012-12-07 A | 100% | 2011-09-19 | 2012-12-07 | 324d? | finish no earlier than 2012-12-07 | C4 | 2568h | 2568h | SIMTC-ReachCSPS | PCG-27 | Ericsson | mikael.wass@ericsson.com | Rel-11 | CP-53 | Kimmo |  | MTC, M2M |  |  |
| 2367 | 566.4.4 | CT6 part of Stage 3 BB1: Reachability Aspects of SIMTC | 257d? | 2011-09-19 A | 2012-09-07 A | 100% | 2011-09-19 | 2012-09-07 | 257d? | finish no earlier than 2012-09-07 | C6 | 2048h | 2048h | SIMTC-ReachCSPS | PCG-27 | ST Ericsson | Andrzej Winiarski | Rel-11 | CP-53 | Xavier |  | MTC, M2M |  |  |
| 2368 | 566.5 | **Stage 2/3 for CS aspects for SIMTC** | 259d? | 2011-09-16 A | 2012-09-07 A | 100% | 2011-09-16 | 2012-09-07 | 259d? |  | C4; C1; C6 | 16544h | 16544h | SIMTC-CS | PCG-27 | Ericsson | mikael.wass@ericsson.com | Rel-11 | CP-53 | Kimmo | SIMTC-CS | MTC, M2M |  |  |
| 2369 | 566.5.1 | Deleted - Stage 2 CS aspects for SIMTC | 258d? | 2011-09-16 A | 2012-09-06 A | 100% | 2011-09-16 | 2012-09-06 | 258d? | finish no earlier than 2012-09-07 | C4 | 2056h | 2056h | SIMTC-CS | PCG-27 | Ericsson | mikael.wass@ericsson.com | Rel-11 | CP-53 | Kimmo |  | MTC, M2M | PCG-29 | CP-57 |
| 2370 | 566.5.2 | **Stage 3 CS aspects for SIMTC** | 259d? | 2011-09-16 A | 2012-09-07 A | 100% | 2011-09-16 | 2012-09-07 | 259d? |  | C1; C6 | 8272h | 8272h | SIMTC-CS | PCG-27 | Ericsson | mikael.wass@ericsson.com | Rel-11 | CP-53 | Frederic |  | MTC, M2M |  |  |
| 2371 | 566.5.2.1 | CT1 part of Stage 3 CS aspects for SIMTC | 259d? | 2011-09-16 A | 2012-09-07 A | 100% | 2011-09-16 | 2012-09-07 | 259d? | start no earlier than 2011-09-16 | C1 | 2064h | 2064h | SIMTC-CS | PCG-27 | Ericsson | mikael.wass@ericsson.com | Rel-11 | CP-53 | Frederic |  | MTC, M2M |  |  |
| 2372 | 566.5.2.2 | Deleted - CT6 part of Stage 3 CS aspects for SIMTC | 259d? | 2011-09-16 A | 2012-09-07 A | 100% | 2011-09-16 | 2012-09-07 | 259d? | start no earlier than 2011-09-16 | C6 | 2064h | 2064h | SIMTC-CS | PCG-27 | Ericsson | mikael.wass@ericsson.com | Rel-11 | CP-53 | Xavier |  | MTC, M2M | PCG-29 | CP-57 |

Notes:
- 2347: CP#58 completed. Triggered by Rel-10 TR 22.893 UID_380083 Study on advanced requirements for IP interconnect (FS_IPXS)
- 2348: SP#53 completed / Impacted TSs and TRs: 22.101, 22.228
- 2349: SP#54 completed / Impacted TSs and TRs: 23.228
- 2350: CP#58 completed / Impacted TSs and TRs: Stage 3
- 2351: CP#58 completed / Impacted TSs and TRs: 24.229
- 2352: CP#57 completed / Impacted TSs and TRs: 29.165
- 2353: SP#58 completed. Updated WID SP-110877=>SP-120848. Enhancements to Rel-10 Feature UID_410031 (NIMTC) based on Rel-11 Study on enhancements to MTC
- 2354: SP#53 completed. SP#57 added MTC definitions in 21.905 / Impacted TSs and TRs: 22.368, 21.905 (MTC definitions)
- 2355: SP#57 completed. TR 23.888v200 for Approval. Was Rel-10 UID_450028 (TR on Stage 2 for NIMTC) / Impacted TSs and TRs: New TR 23.888
- 2356: SP#56 completed. SP#58 updated WID SP-110877=>S3-121111 (SA3 normative work on Security aspects of SIMTC incorporated in SA2 TS 23.682) / Impacted TSs and TRs: 23.221, New 23.368
- 2357: SP#54 work stopped
- 2358: SP#56 completed / Impacted TSs and TRs: New 23.682
- 2359: SP#54 completed / Impacted TSs and TRs: 23.221, New 23.682
- 2360: SP#56 completed / Impacted TSs and TRs: New 23.682
- 2361: SP#55 completed / Impacted TSs and TRs: 23.060, 23.272, New 23.682
- 2362: SP#55 completed / Impacted TSs and TRs: New 23.682
- 2363: 22/01: acronym modified / Impacted TSs and TRs: Stage 3
- 2364: 22/01: acronym modified / Impacted TSs and TRs: 23.040, 24.008, 24.301, 24.341, 24.368
- 2365: 22/01: acronym modified / Impacted TSs and TRs: 29.061, New TS 29.368
- 2366: 22/01: acronym modified / Impacted TSs and TRs: 23.003, 23.008, 29.002, 29.060, 29.230, New TS (29.336, 29.337)
- 2367: 22/01: acronym modified / Impacted TSs and TRs: 31.102
- 2368: CP#57 completed. Updated WID CP-120418=>CP-120617 / Impacted TSs and TRs: Stage 2/3
- 2369: CP#57 stopped / Impacted TSs and TRs: 23.012
- 2370: CP#57 completed / Impacted TSs and TRs: Stage 3
- 2371: CP#57 completed / Impacted TSs and TRs: 24.008, 24.301
- 2372: CP#57 stopped / Impacted TSs and TRs: 31.102

| ID | WBS | Task | Duration | Start | Finish | Complete | Baseline start | Baseline finish | Baseline duration | Constraint | Resources | Work | Actual work | Acronym | PCG approved | WI rapporteur name | WI rapporteur e-mail | Release | TSG approved | MCC resp | Special Focus Doc | Acronym_3GU_Export | Status Report | PCG stopped | TSG stopped |
| --- | --- | --- | --- | --- | --- | --- | --- | --- | --- | --- | --- | --- | --- | --- | --- | --- | --- | --- | --- | --- | --- | --- | --- | --- | --- |
| 2373 | 566.6 | **Stage 2/3 for SMS in MME architecture option and related PS-only service subscription** | 129d? | 2012-06-15 A | 2012-12-07 A | 100% | 2012-06-15 | 2012-12-07 | 129d? |  | C1; C4 | 3560h | 3560h | SIMTC-PS_Only | PCG-29 | Ericsson | mikael.wass@ericsson.com | Rel-11 | CP-56 | Frederic | MTC, M2M | SIMTC-PS_Only |  |  |  |
| 2374 | 566.6.1 | CT1 part of Stage 2/3 for SMS in MME architecture option and related PS-only service subscription | 62d? | 2012-06-15 A | 2012-09-07 A | 100% | 2012-06-15 | 2012-09-07 | 62d? | finish no earlier than 2012-09-07 | C1 | 488h | 488h | SIMTC-PS_Only | PCG-29 | Ericsson | mikael.wass@ericsson.com | Rel-11 | CP-56 | Frederic | MTC, M2M |  |  |  |  |
| 2375 | 566.6.2 | CT4 part of Stage 2/3 for SMS in MME architecture option and related PS-only service subscription | 129d? | 2012-06-15 A | 2012-12-07 A | 100% | 2012-06-15 | 2012-12-07 | 129d? | finish no earlier than 2012-12-07 | C4 | 1008h | 1008h | SIMTC-PS_Only | PCG-29 | Ericsson | mikael.wass@ericsson.com | Rel-11 | CP-56 | Kimmo | MTC, M2M |  |  |  |  |
| 2376 | 566.7 | **RAN overload control for Machine-Type Communications** | 259d? | 2011-09-16 A | 2012-09-07 A | 100% | 2011-09-16 | 2012-09-07 | 259d? |  | R2; R3; C1; C6 | 20178.3h | 20178.3h | SIMTC-RAN_OC | PCG-27 | Huawei | Jeff Gao (gaoyongqiang@huawei.com) | Rel-11 | RP-53 | Yong-Jun | MTC, M2M | SIMTC-RAN_OC |  |  |  |
| 2377 | 566.7.1 | Core part: RAN overload control for Machine-Type Communications | 258d? | 2011-09-19 A | 2012-09-07 A | 100% | 2011-09-19 | 2012-09-07 | 258d? | finish no earlier than 2012-09-07 | R2; R3 | 4128h | 4128h | SIMTC-RAN_OC-Core | PCG-27 | Huawei | Jeff Gao (gaoyongqiang@huawei.com) | Rel-11 | RP-53 | Yong-Jun | MTC, M2M | SIMTC-RAN_OC-Core |  |  |  |
| 2378 | 566.7.2 | **Stage 3 (CS+PS) Extended Access Barring for UTRAN and E-UTRAN** | 259d? | 2011-09-16 A | 2012-09-07 A | 100% | 2011-09-16 | 2012-09-07 | 259d? |  | C1; C6 | 7762.29h | 7762.29h | SIMTC-RAN_OC | PCG-27 | Ericsson | mikael.wass@ericsson.com | Rel-11 | CP-53 | Frederic | MTC, M2M |  |  |  |  |
| 2379 | 566.7.2.1 | CT1 part of Stage 3 Extended Access Barring for UTRAN and E-UTRAN | 198d? | 2011-09-16 A | 2012-06-15 A | 100% | 2011-09-16 | 2012-06-15 | 198d? | finish no earlier than 2012-09-14 | C1 | 1570.29h | 1570.29h | SIMTC-RAN_OC | PCG-27 | Ericsson | mikael.wass@ericsson.com | Rel-11 | CP-53 | Frederic | MTC, M2M |  |  |  |  |
| 2380 | 566.7.2.2 | CT6 part of Stage 3 Extended Access Barring for UTRAN and E-UTRAN | 257d? | 2011-09-20 A | 2012-09-07 A | 100% | 2011-09-20 | 2012-09-07 | 257d? | finish no earlier than 2012-09-07 | C6 | 2048h | 2048h | SIMTC-RAN_OC | PCG-27 | ST Ericsson | Andrzej Winiarski | Rel-11 | CP-53 | Xavier | MTC, M2M |  |  |  |  |
| 2381 | 566.8 | Test part: System Improvements for Machine-Type Communications | 130d? | 2013-09-09 A | 2014-03-06 A | 100% | 2013-09-09 | 2014-03-06 | 130d? | finish no earlier than 2014-03-06 | R5 | 1040h | 1040h | SIMTC-UEConTest | PCG-31 | Ericsson | calle.hagenfeldt@ericsson.com | Rel-11 | RP-61 | Ingbert | MTC, M2M | SIMTC-UEConTest | RP-140075 |  |  |
| 2382 | 566.9 | BB5: Charging of SIMTC (Stage 2/3) | 269d? | 2011-12-07 A | 2012-12-12 A | 100% | 2011-12-07 | 2012-12-12 | 269d? | finish no earlier than 2012-12-12 | S5 | 2144h | 2144h | SIMTC-CH | PCG-28 | Ericsson | patrik.teppo@ericsson.com | Rel-11 | SP-54 | Mirko | MTC, M2M | SIMTC-CH |  |  |  |
| 2383 | 566.10 | **Deleted - BB2: Stage 2 Signalling Optimizations of SIMTC** | 137d? | 2011-06-10 A | 2011-12-14 A | 100% | 2011-06-10 | 2011-12-14 | 137d? |  | S2 | 5240h | 5240h | SIMTC-Sig | PCG-27 | Intel | puneet.jain@intel.com | Rel-11 | SP-52 | Maurice | MTC, M2M | SIMTC-Sig |  | PCG-28 | SP-55 |
| 2384 | 566.10.1 | Deleted - Effectively maintain connectivity for a large number of MTC Devices (TS 22.368, 7.1.1) | 137d? | 2011-06-10 A | 2011-12-14 A | 100% | 2011-06-10 | 2011-12-14 | 137d? | finish no earlier than 2011-12-07 | S2 | 1088h | 1088h | SIMTC-Sig | PCG-27 | Intel | puneet.jain@intel.com | Rel-11 | SP-52 | Maurice | MTC, M2M |  |  | PCG-28 | SP-55 |
| 2385 | 566.10.2 | Deleted - Small Data Transmissions (TS 22.368, 7.2.5) | 137d? | 2011-06-10 A | 2011-12-14 A | 100% | 2011-06-10 | 2011-12-14 | 137d? | finish no earlier than 2011-12-07 | S2 | 1088h | 1088h | SIMTC-Sig | PCG-27 | Intel | puneet.jain@intel.com | Rel-11 | SP-52 | Maurice | MTC, M2M |  |  | PCG-28 | SP-55 |
| 2386 | 566.10.3 | **Deleted - Stage 3 (CS+PS) Signalling Optimizations of SIMTC** | 62d? | 2011-09-16 A | 2011-12-09 A | 100% | 2011-09-16 | 2011-12-09 | 62d? |  | C1; C6 | 1968h | 1968h | SIMTC-Sig | PCG-27 | Ericsson | mikael.wass@ericsson.com | Rel-11 | CP-53 | Frederic | MTC, M2M |  |  | PCG-28 | CP-55 |
| 2387 | 566.10.3.1 | Deleted - CT1 part of Stage 3 Signalling Optimizations of SIMTC | 62d? | 2011-09-16 A | 2011-12-09 A | 100% | 2011-09-16 | 2011-12-09 | 62d? | finish no earlier than 2011-12-02 | C1 | 488h | 488h | SIMTC-Sig | PCG-27 | Ericsson | mikael.wass@ericsson.com | Rel-11 | CP-53 | Frederic | MTC, M2M |  |  | PCG-28 | CP-55 |
| 2388 | 566.10.3.2 | Deleted - CT6 part of Stage 3 Signalling Optimizations of SIMTC | 62d? | 2011-09-16 A | 2011-12-09 A | 100% | 2011-09-16 | 2011-12-09 | 62d? | finish no earlier than 2011-12-02 | C6 | 488h | 488h | SIMTC-Sig | PCG-27 | ST Ericsson | Andrzej Winiarski | Rel-11 | CP-53 | Xavier | MTC, M2M |  |  | PCG-28 | CP-55 |
| 2389 | 566.11 | **Deleted - BB3: Stage 2 CN-based requirements and Power Considerations of SIMTC** | 139d? | 2011-06-08 A | 2011-12-14 A | 100% | 2011-06-08 | 2011-12-14 | 139d? |  | S2 | 6360h | 6360h | SIMTC-CN_Pow | PCG-27 | Intel | puneet.jain@intel.com | Rel-11 | SP-52 | Maurice | MTC, M2M | SIMTC-CN_Pow |  | PCG-28 | SP-55 |
| 2390 | 566.11.1 | Deleted - Charging Requirements (TS 22.368, 7.1.5) | 137d? | 2011-06-10 A | 2011-12-14 A | 100% | 2011-06-10 | 2011-12-14 | 137d? | finish no earlier than 2012-03-21 | S2 | 1088h | 1088h | SIMTC-CN_Pow | PCG-27 | Intel | puneet.jain@intel.com | Rel-11 | SP-52 | Maurice | MTC, M2M |  |  | PCG-28 | SP-55 |
| 2391 | 566.11.2 | Deleted - Lower Power Consumption (TS 22.368, 7.1.1) | 137d? | 2011-06-10 A | 2011-12-14 A | 100% | 2011-06-10 | 2011-12-14 | 137d? | finish no earlier than 2011-12-07 | S2 | 1088h | 1088h | SIMTC-CN_Pow | PCG-27 | Intel | puneet.jain@intel.com | Rel-11 | SP-52 | Maurice | MTC, M2M |  |  | PCG-28 | SP-55 |
| 2392 | 566.11.3 | Deleted - MTC Monitoring (TS 22.368, 7.2.8) | 139d? | 2011-06-08 A | 2011-12-14 A | 100% | 2011-06-08 | 2011-12-14 | 139d? | finish no earlier than 2011-12-07 | S2 | 1104h | 1104h | SIMTC-CN_Pow | PCG-27 | Intel | puneet.jain@intel.com | Rel-11 | SP-52 | Maurice | MTC, M2M |  |  | PCG-28 | SP-55 |
| 2393 | 566.11.4 | **Deleted - Stage 3 (CS+PS) CN-based requirements and Power Considerations of SIMTC** | 62d? | 2011-09-16 A | 2011-12-09 A | 100% | 2011-09-16 | 2011-12-09 | 62d? |  | C1; C6 | 1968h | 1968h | SIMTC-CN_Pow | PCG-27 | Ericsson | mikael.wass@ericsson.com | Rel-11 | CP-53 | Frederic | MTC, M2M |  |  | PCG-28 | CP-55 |
| 2394 | 566.11.4.1 | Deleted - CT1 part of Stage 3 CN-based requirements and Power Considerations of SIMTC | 62d? | 2011-09-16 A | 2011-12-09 A | 100% | 2011-09-16 | 2011-12-09 | 62d? | finish no earlier than 2011-12-02 | C1 | 488h | 488h | SIMTC-CN_Pow | PCG-27 | Ericsson | mikael.wass@ericsson.com | Rel-11 | CP-53 | Frederic | MTC, M2M |  |  | PCG-28 | CP-55 |
| 2395 | 566.11.4.2 | Deleted - CT6 part of Stage 3 CN-based requirements and Power Considerations of SIMTC | 62d? | 2011-09-16 A | 2011-12-09 A | 100% | 2011-09-16 | 2011-12-09 | 62d? | finish no earlier than 2011-12-02 | C6 | 488h | 488h | SIMTC-CN_Pow | PCG-27 | ST Ericsson | Andrzej Winiarski | Rel-11 | CP-53 | Xavier | MTC, M2M |  |  | PCG-28 | CP-55 |
| 2396 | 566.12 | Deleted - TR on Security aspects of Machine-Type Communications | 662d? | 2009-12-10 A | 2012-06-20 A | 100% | 2009-12-10 | 2012-06-20 | 662d? | finish no earlier than 2012-06-20 | S3 | 5288h | 5288h |  | PCG-25 | Samsung | Rajavelsamy R (rajvel@samsung.com) | Rel-11 | SP-49 | Mirko | MTC, M2M |  |  | PCG-29 | SP-56 |

Notes:
- 2373: CP#58 completed / Impacted TSs and TRs: Stage 2/3
- 2374: CP#57 completed / Impacted TSs and TRs: 23.040, 24.008, 24.011, 24.301, 29.018, 29.118
- 2375: CP#58 completed. TS 29.338 v200 for Approval / Impacted TSs and TRs: 23.003, 23.008, 23.012, 29.002, 29.272, 29.305, New TS 29.338
- 2376: Stage 2,3. TSG#57 completed / Impacted TSs and TRs: UTRA, LTE
- 2377: RP#57 completed / Impacted TSs and TRs: 25.304, 25.331, 25.413, 36.304, 36.331, 36.413
- 2378: CP#57 completed. Updated WID CP-120418=>CP-120617 / Impacted TSs and TRs: Stage 3
- 2379: CP#56 completed / Impacted TSs and TRs: 23.122, 24.008, 24.301
- 2380: CP#57 completed / Impacted TSs and TRs: 31.102
- 2381: RP#63 completed. Updated WID RP-131341=>RP-140077 (added affected TS 36.508). Testing for core part: SIMTC-Reach, SIMTC-CS, SIMTC-PS_Only, SIMTC-RAN_OC / Impacted TSs and TRs: 34.123-1, 34.123-2, 34.123-3, 36.508, 36.523-1, 36.523-2, 36.523-3
- 2382: SP#58 completed / Impacted TSs and TRs: 32.240, 32.251, 32.298, 32.299
- 2383: SP#54 work stopped. SP#58 updated WID SP-110877=>SP-120848 / Impacted TSs and TRs: TBD
- 2384: SP#54 work stopped / Impacted TSs and TRs: TBD
- 2385: SP#54 work stopped / Impacted TSs and TRs: TBD
- 2386: CP#54 work stopped / Impacted TSs and TRs: Stage 3
- 2387: - / Impacted TSs and TRs: 23.122, 24.008, 24.301, 24.368
- 2388: - / Impacted TSs and TRs: 31.102
- 2389: SP#54 work stopped / Impacted TSs and TRs: TBD
- 2390: SP#54 work stopped / Impacted TSs and TRs: TBD
- 2391: SP#54 work stopped / Impacted TSs and TRs: TBD
- 2392: SP#54 work stopped / Impacted TSs and TRs: TBD
- 2393: CP#54 work stopped / Impacted TSs and TRs: Stage 3
- 2394: - / Impacted TSs and TRs: 23.122, 24.008, 24.301, 24.368
- 2395: - / Impacted TSs and TRs: 31.101, 31.102
- 2396: Was Rel-10 UID_460023 (Security for NIMTC). SP#56 stopped (activity transferred to Rel-12 Feature MTCe under UID_560722). / Impacted TSs and TRs: New TR 33.868

| ID | WBS | Task | Type | Duration | Start | Finish | Complete | Baseline start | Baseline finish | Baseline duration | Constraint | Resources | Work | Actual work | Acronym | PCG approved | Impacted TSs and TRs | WI rapporteur name | Release | TSG approved | MCC resp | PCG stopped | TSG stopped | Special Focus Doc | Acronym_3GU_Export |
| --- | --- | --- | --- | --- | --- | --- | --- | --- | --- | --- | --- | --- | --- | --- | --- | --- | --- | --- | --- | --- | --- | --- | --- | --- | --- |
| 2397 | 566.13 | **Deleted - BB4: Secure Connection and Privacy of SIMTC** |  | 336d? | 2011-06-08 A | 2012-09-12 A | 100% | 2011-06-08 | 2012-09-12 | 336d? |  | S3 | 7424h | 7424h | SIMTC-Sec | PCG-27 | TBD | Samsung | Rel-11 | SP-52 | Mirko | PCG-29 | CP-57 | MTC, M2M | SIMTC-Sec |
| 2398 | 566.13.1 | Deleted - Secure Connection MTC Feature (TS 22.368, 7.2.10) |  | 333d? | 2011-06-08 A | 2012-09-12 A | 100% | 2011-06-08 | 2012-09-12 | 333d? | finish no earlier than 2012-09-12 | S3 | 2656h | 2656h | SIMTC-Sec | PCG-27 | TBD | Samsung | Rel-11 | SP-52 | Mirko | PCG-29 | CP-57 | MTC, M2M |  |
| 2399 | 566.13.2 | Deleted - MTC Location Privacy |  | 261d? | 2011-09-19 A | 2012-09-12 A | 100% | 2011-09-19 | 2012-09-12 | 261d? | finish no earlier than 2012-09-12 | S3 | 2080h | 2080h | SIMTC-Priv | PCG-27 | TBD | Samsung | Rel-11 | SP-53 | Mirko | PCG-29 | CP-57 | MTC, M2M | SIMTC-Priv |
| 2400 | 566.14 | Deleted - Stage 2 on SA2 part for System Improvements to Machine-Type Communications |  | 260d? | 2010-06-10 A | 2011-06-08 A | 100% | 2010-06-10 | 2011-06-08 | 260d? | finish no earlier than 2011-06-08 | S2 | 2080h | 2080h | SIMTC | PCG-25 | TBD | Intel | Rel-11 | SP-48 | Maurice | PCG-27 | SP-52 | MTC, M2M |  |
| 2401 | 566.15 | Deleted - Stage 2 on Security part for System Improvements to Machine-Type Communications |  | 260d? | 2010-06-10 A | 2011-06-08 A | 100% | 2010-06-10 | 2011-06-08 | 260d? | finish no earlier than 2011-06-08 | S3 | 2080h | 2080h | SIMTC | PCG-25 | TBD | Samsung | Rel-11 | SP-48 | Mirko | PCG-27 | SP-52 | MTC, M2M |  |
| 2402 | 567 | **Unstructured Supplementary Service Data (USSD) simulation service in IMS** |  | 659d? | 2010-06-10 A | 2012-12-07 A | 100% | 2010-06-10 | 2012-12-07 | 659d? |  | S1; C1; C3 | 28112.1h | 28112.1h | USSI | PCG-25 |  | Deutsche Telekom | Rel-11 | SP-48 | Alain |  |  |  | USSI |
| 2403 | 567.1 | Stage 1 for USSD simulation service in IMS | milestone | 0d? | 2010-06-10 A | 2010-06-10 A | 100% | 2010-06-10 | 2010-06-10 | 0d? | finish no earlier than 2010-06-10 | S1 |  |  | USSI | PCG-25 | 22.173 | Deutsche Telekom | Rel-11 | SP-48 | Alain |  |  |  |  |
| 2404 | 567.2 | **Stage 3 for USSD simulation service in IMS** |  | 403d? | 2011-06-03 A | 2012-12-07 A | 100% | 2011-06-03 | 2012-12-07 | 403d? |  | C1; C3 | 12296.1h | 12296.1h | USSI | PCG-27 |  | Deutsche Telekom | Rel-11 | CP-52 | Frederic |  |  |  |  |
| 2405 | 567.2.1 | CT1 part of Stage 3 for USSD simulation service in IMS |  | 402d? | 2011-06-03 A | 2012-12-07 A | 100% | 2011-06-03 | 2012-12-07 | 402d? | finish no earlier than 2012-12-07 | C1 | 3184.06h | 3184.06h | USSI | PCG-27 | 24.173, 24.229, new TS 24.390 | Deutsche Telekom | Rel-11 | CP-52 | Frederic |  |  |  |  |
| 2406 | 567.2.2 | CT3 part of Stage 3 for USSD simulation service in IMS |  | 334d? | 2011-06-07 A | 2012-09-07 A | 100% | 2011-06-07 | 2012-09-07 | 334d? | finish no earlier than 2012-09-07 | C3 | 2664h | 2664h | USSI | PCG-27 | 29.165 | Deutsche Telekom | Rel-11 | CP-52 | Adrian |  |  |  |  |
| 2407 | 568 | **QoS Control Based on Subscriber Spending Limits** |  | 459d? | 2010-09-23 A | 2012-06-20 A | 100% | 2010-09-23 | 2012-06-20 | 459d? |  | S1; S2; S5; C3 | 23152h | 23152h | QoS_SSL | PCG-25 |  | Vodafone | Rel-11 | SP-49 | Alain |  |  |  | QoS_SSL |
| 2408 | 568.1 | Stage 1 for QoS Control Based on Subscriber Spending Limits |  | 262d? | 2010-09-23 A | 2011-09-21 A | 100% | 2010-09-23 | 2011-09-21 | 262d? | finish no earlier than 2011-09-21 | S1 | 2080h | 2080h | QoS_SSL | PCG-25 | 22.115 | Vodafone | Rel-11 | SP-49 | Alain |  |  |  |  |
| 2409 | 568.2 | Stage 2 for QoS Control Based on Subscriber Spending Limits |  | 133d? | 2011-03-23 A | 2011-09-21 A | 100% | 2011-03-23 | 2011-09-21 | 133d? | finish no earlier than 2011-12-14 | S2 | 1048h | 1048h | QoS_SSL | PCG-26 | 23.203 | Huawei | Rel-11 | SP-51 | Maurice |  |  |  |  |
| 2410 | 568.3 | Charging for QoS Control Based on Subscriber Spending Limits (Stage 2) |  | 397d? | 2010-12-16 A | 2012-06-20 A | 100% | 2010-12-16 | 2012-06-20 | 397d? | finish no earlier than 2012-06-20 | S5 | 3168h | 3168h | QoS_SSL | PCG-26 | 32.240, 32.296 | Nokia Siemens Networks, Huawei | Rel-11 | SP-50 | Mirko |  |  |  |  |
| 2411 | 568.4 | CT3 aspects of QoS Control Based on Subscriber Spending Limits (Stage 3) |  | 273d? | 2011-06-03 A | 2012-06-15 A | 100% | 2011-06-03 | 2012-06-15 | 273d? | finish no earlier than 2012-06-15 | C3 | 2168h | 2168h | QoS_SSL-CT3 | PCG-27 | 29.212, 29.213, 29.214, 29.215, new TS 29.219 | Huawei | Rel-11 | CP-52 | Adrian |  |  |  | QoS_SSL-CT3 |
| 2412 | 569 | **Optimized Service Charging and Allocation of Resources in IMS whilst Roaming** |  | 383d? | 2010-09-23 A | 2012-03-07 A | 100% | 2010-09-23 | 2012-03-07 | 383d? |  | S1; S2 | 14288h | 14288h | OSCAR | PCG-25 |  | Vodafone | Rel-11 | SP-49 | Alain |  |  |  | OSCAR |
| 2413 | 569.1 | TR on Stage 2 aspects of Optimized Service Charging and Allocation of Resources in IMS whilst Roaming |  | 383d? | 2010-09-23 A | 2012-03-07 A | 100% | 2010-09-23 | 2012-03-07 | 383d? | finish no earlier than 2011-12-07 | S2 | 3040h | 3040h | OSCAR | PCG-25 | new TR 23.849 | Vodafone | Rel-11 | SP-49 | Maurice |  |  |  |  |
| 2414 | 569.2 | Stage 1 for Optimized Service Charging and Allocation of Resources in IMS whilst Roaming |  | 262d? | 2010-09-23 A | 2011-09-21 A | 100% | 2010-09-23 | 2011-09-21 | 262d? | finish no earlier than 2011-09-21 | S1 | 2080h | 2080h | OSCAR | PCG-25 | 22.115, 22.173, 22.228 | Vodafone | Rel-11 | SP-49 | Alain |  |  |  |  |
| 2415 | 569.3 | Deleted - Stage 2 for Optimized Service Charging and Allocation of Resources in IMS whilst Roaming |  | 380d? | 2010-09-28 A | 2012-03-07 A | 100% | 2010-09-28 | 2012-03-07 | 380d? | finish no earlier than 2012-03-07 | S2 | 3040h | 3040h | OSCAR | PCG-25 | None | Vodafone | Rel-11 | SP-49 | Maurice | PCG-28 | SP-55 |  |  |
| 2416 | 570 | **Inclusion of Media Resource Broker (Stage 2/3)** |  | 463d? | 2011-09-16 A | 2013-06-14 A | 100% | 2011-09-16 | 2013-06-14 | 463d? |  | C1; C3; IETF | 30500h | 30500h | MRB | PCG-27 | Stage 2/3 | AT&T | Rel-11 | CP-53 | Frederic |  |  |  | MRB |
| 2417 | 570.1 | Stage 2 for Inclusion of Media Resource Broker |  | 259d? | 2011-09-16 A | 2012-09-07 A | 100% | 2011-09-16 | 2012-09-07 | 259d? | finish no earlier than 2012-09-07 | C1 | 2049.98h | 2049.98h | MRB | PCG-27 | 23.218 | AT&T | Rel-11 | CP-53 | Frederic |  |  |  |  |
| 2418 | 570.2 | **Stage 3 for Inclusion of Media Resource Broker** |  | 463d? | 2011-09-16 A | 2013-06-14 A | 100% | 2011-09-16 | 2013-06-14 | 463d? |  | C1; C3; IETF | 17338h | 17338h | MRB | PCG-27 |  | AT&T | Rel-11 | CP-53 | Frederic |  |  |  |  |
| 2419 | 570.2.1 | CT1 part of Stage 3 for Inclusion of Media Resource Broker |  | 258d? | 2011-09-16 A | 2012-09-07 A | 100% | 2011-09-16 | 2012-09-07 | 258d? | finish no earlier than 2012-09-07 | C1 | 2049.98h | 2049.98h | MRB | PCG-27 | 24.229, 29.165 | AT&T | Rel-11 | CP-53 | Frederic |  |  |  |  |
| 2420 | 570.2.2 | (IETF) Inclusion of Media Resource Broker [RFC 6917 (was draft-ietf-mediactrl-mrb)] |  | 462d? | 2011-09-16 A | 2013-06-14 A | 100% | 2011-09-16 | 2013-06-14 | 462d? | finish no earlier than 2013-06-14 | C1-IETF | 3688h | 3688h | MRB | PCG-27 | RFC 6917 (was draft-ietf-mediactrl-mrb) | Keith Drage | Rel-11 | CP-53 | Frederic |  |  |  |  |
| 2421 | 570.2.3 | CT3 part of Stage 3 for Inclusion of Media Resource Broker |  | 62d? | 2012-06-15 A | 2012-09-07 A | 100% | 2012-06-15 | 2012-09-07 | 62d? | finish no earlier than 2012-09-07 | C3 | 488h | 488h | MRB | PCG-29 | 29.165 | AT&T | Rel-11 | CP-56 | Adrian |  |  |  |  |

Notes:
- 2397: SP#57 stopped (activity transferred to Rel-12 Feature MTCe under UID_560522) / WI rapporteur e-mail: Rajavelsamy R (rajvel@samsung.com)
- 2398: SP#57 stopped (activity transferred to Rel-12 Feature MTCe / WI rapporteur e-mail: Rajavelsamy R (rajvel@samsung.com)
- 2399: SP#57 stopped (activity transferred to Rel-12 Feature MTCe / WI rapporteur e-mail: Rajavelsamy R (rajvel@samsung.com)
- 2400: SP#52 stopped / WI rapporteur e-mail: puneet.jain@intel.com
- 2401: SP#52 stopped / WI rapporteur e-mail: Rajavelsamy R (rajvel@samsung.com)
- 2402: CP#58 completed / WI rapporteur e-mail: kurt.bischinger@t-mobile.at
- 2403: SP#48 completed. Specify a CS domain USSD like service over IMS (see GSM Mobile User Initiated USSD) / WI rapporteur e-mail: kurt.bischinger@t-mobile.at
- 2404: SP#58 completed. No stage 2 impact, as reuse existing IMS architecture in TS 23.228 / WI rapporteur e-mail: reinhard.lauster@t-mobile.at
- 2405: CP#58 completed / WI rapporteur e-mail: reinhard.lauster@t-mobile.at, TS 24.390 Rapp: lili.yang@huawei.com
- 2406: CP#57 completed / WI rapporteur e-mail: reinhard.lauster@t-mobile.at
- 2407: TSG#56 completed / WI rapporteur e-mail: mona.mustapha@vodafone.com
- 2408: SP#53 completed. Use cases & service requirements to allow: 1) modification of QoS based on subscribers spending limits 2) enforcing of spending limits for roaming subscribers without having dedicated support in the visited network / WI rapporteur e-mail: mona.mustapha@vodafone.com
- 2409: SP#53 completed / WI rapporteur e-mail: Xu Xia (xiatony@huawei.com)
- 2410: SP#56 completed / WI rapporteur e-mail: Gerald.Goermer@nsn.com, shan.mingjun@huawei.com
- 2411: CP#56 completed / WI rapporteur e-mail: QiaoWeihua@huawei.com
- 2412: SP#55 completed (Stage 2/3 specified under CT1 Rel-11 Feature MRB (Inclusion of Media Resource Broker) UID_530021. Triggered by S1-102236/GSMA RILTE 10_007r1 (IREG LS_038 to 3GPP on Optimal Media Routing drawbacks) / WI rapporteur e-mail: mona.mustapha@vodafone.com
- 2413: SP#55 completed / WI rapporteur e-mail: Susana.Sabater@vodafone.com
- 2414: SP#53 completed / WI rapporteur e-mail: mona.mustapha@vodafone.com
- 2415: SP#55 no normative work in SA2. Stage 2/3 to be done in under CT1 Rel-11 Feature MRB (Inclusion of Media Resource Broker) UID_530021 / WI rapporteur e-mail: Susana.Sabater@vodafone.com
- 2416: Stage 1 and TR on Stage 2 in Rel-11 Feature OSCAR UID_490032 / WI rapporteur e-mail: Martin Dolly (md3135@att.com)
- 2417: CP#57 completed / WI rapporteur e-mail: Martin Dolly (md3135@att.com)
- 2418: CP#60 completed / WI rapporteur e-mail: Martin Dolly (md3135@att.com)
- 2419: CP#57 completed / WI rapporteur e-mail: Martin Dolly (md3135@att.com)
- 2420: CP#60 completed
- 2421: CP#57 completed / WI rapporteur e-mail: Martin Dolly (md3135@att.com)

| ID | WBS | Task | Duration | Start | Finish | Complete | Baseline start | Baseline finish | Baseline duration | Constraint | Resources | Work | Actual work | Acronym | PCG approved | WI rapporteur name | WI rapporteur e-mail | Release | TSG approved | MCC resp | Acronym_3GU_Export | Special Focus Doc | PCG stopped | TSG stopped |
| --- | --- | --- | --- | --- | --- | --- | --- | --- | --- | --- | --- | --- | --- | --- | --- | --- | --- | --- | --- | --- | --- | --- | --- | --- |
| 2422 | 571 | **Non Voice Emergency Services** | 323d? | 2010-12-16 A | 2012-03-07 A | 100% | 2010-12-16 | 2012-03-07 | 323d? |  | S1; S2 | 7736h | 7736h | NOVES | PCG-26 | Qualcomm | dwilliams@qualcomm.com | Rel-11 | SP-50 | Alain | NOVES |  |  |  |
| 2423 | 571.1 | Stage 1 for Non Voice Emergency Services | 202d? | 2010-12-16 A | 2011-09-21 A | 100% | 2010-12-16 | 2011-09-21 | 202d? | finish no earlier than 2011-09-21 | S1 | 1600h | 1600h | NOVES | PCG-26 | Qualcomm | dwilliams@qualcomm.com | Rel-11 | SP-50 | Alain |  |  |  |  |
| 2424 | 571.2 | Stage 2 for Non Voice Emergency Services (Support of IMS Emergency Sessions with Other Media on UTRAN and E-UTRAN) | 121d? | 2011-09-22 A | 2012-03-07 A | 100% | 2011-09-22 | 2012-03-07 | 121d? | finish no earlier than 2012-03-07 | S2 | 968h | 968h | NOVES-IMSESOM | PCG-27 | Alcatel-Lucent | Deb.Barclay@alcatel-lucent.com | Rel-11 | SP-53 | Maurice | NOVES-IMSESOM |  |  |  |
| 2425 | 572 | **Support for 3GPP Voice Interworking with Enterprise IP-PBX** | 516d? | 2011-03-23 A | 2013-03-01 A | 100% | 2011-03-23 | 2013-03-01 | 516d? |  | S1; C1 | 12376h | 12376h | VINE | PCG-26 | Tatara Systems | Phillip Brown (pbrown@tatarasystems.com) | Rel-11 | SP-51 | Alain | VINE |  |  |  |
| 2426 | 572.1 | Stage 1 for Support for 3GPP Voice Interworking with Enterprise IP-PBX | 133d? | 2011-03-23 A | 2011-09-21 A | 100% | 2011-03-23 | 2011-09-21 | 133d? | finish no earlier than 2011-09-21 | S1 | 1048h | 1048h | VINE | PCG-26 | Tatara Systems | Phillip Brown (pbrown@tatarasystems.com) | Rel-11 | SP-51 | Alain |  |  |  |  |
| 2427 | 572.2 | Stage 2/3 for Support for 3GPP Voice Interworking with Enterprise IP-PBX | 385d? | 2011-09-20 A | 2013-03-01 A | 100% | 2011-09-20 | 2013-03-01 | 385d? | finish no earlier than 2013-03-01 | C1 | 3072h | 3072h | VINE-CT1 | PCG-27 | Alcatel-Lucent | keith.drage@alcatel-lucent.com | Rel-11 | CP-53 | Frederic | VINE-CT1 |  |  |  |
| 2428 | 573 | **Anonymous Call Rejection in the CS domain** | 132d? | 2011-06-07 A | 2011-12-02 A | 100% | 2011-06-07 | 2011-12-02 | 132d? |  | S1; C4; C3 | 4616h | 4616h | ACR_CS | PCG-27 | Alcatel-Lucent | Betsy.Covell@alcatel-lucent.com | Rel-11 | SP-52 | Alain | ACR_CS |  |  |  |
| 2429 | 573.1 | Stage 1 for Anonymous Call Rejection in the CS domain | 2d? | 2011-06-07 A | 2011-06-08 A | 100% | 2011-06-07 | 2011-06-08 | 2d? | finish no earlier than 2011-06-07 | S1 | 16h | 16h | ACR_CS | PCG-27 | Alcatel-Lucent | Betsy.Covell@alcatel-lucent.com | Rel-11 | SP-52 | Alain |  |  |  |  |
| 2430 | 573.2 | **Core Network aspects of Anonymous Call Rejection in the CS domain** | 59d? | 2011-09-14 A | 2011-12-02 A | 100% | 2011-09-14 | 2011-12-02 | 59d? |  | C4; C3 | 1432h | 1432h | ACR_CS-CN | PCG-27 | Alcatel-Lucent | bruno.landais@alcatel-lucent.com | Rel-11 | CP-53 | Kimmo | ACR_CS-CN |  |  |  |
| 2431 | 573.2.1 | CT4 part of Core Network aspects of Anonymous Call Rejection in the CS domain (Stage 2/3) | 59d? | 2011-09-14 A | 2011-12-02 A | 100% | 2011-09-14 | 2011-12-02 | 59d? | finish no earlier than 2011-12-02 | C4 | 464h | 464h | ACR_CS-CN | PCG-27 | Alcatel-Lucent | bruno.landais@alcatel-lucent.com | Rel-11 | CP-53 | Kimmo |  |  |  |  |
| 2432 | 573.2.2 | CT3 part of Core Network aspects of Anonymous Call Rejection in the CS domain (Stage 3) | 3d? | 2011-09-14 A | 2011-09-16 A | 100% | 2011-09-14 | 2011-09-16 | 3d? | start no earlier than 2011-09-14 | C3 | 24h | 24h | ACR_CS-CN | PCG-27 | Alcatel-Lucent | bruno.landais@alcatel-lucent.com | Rel-11 | CP-53 | Adrian |  |  |  |  |
| 2433 | 574 | **Support for BroadBand Forum Accesses Interworking** | 792d? | 2009-12-10 A | 2012-12-12 A | 100% | 2009-12-10 | 2012-12-12 | 792d? |  | S2; S1; C1; C3; C4; IETF | 97983.8h | 97983.8h | BBAI | PCG-24 | Ericsson | peter.bleckert@ericsson.com | Rel-11 | SP-46 | Alain | BBAI | HNB, WLAN |  |  |
| 2434 | 574.1 | Stage 1 BB I: BBF interworking with home routed traffic for WLAN and H(e)NB | 76d? | 2009-12-10 A | 2010-03-25 A | 100% | 2009-12-10 | 2010-03-25 | 76d? | start no earlier than 2009-12-10 | S1 | 608h | 608h | BBAI | PCG-24 | Ericsson | Olle.Eriksson@ericsson.com | Rel-11 | SP-46 | Alain |  | HNB, WLAN |  |  |
| 2435 | 574.2 | TR on Stage 2 for BBAI | 588d? | 2010-03-26 A | 2012-06-20 A | 100% | 2010-03-26 | 2012-06-20 | 588d? | finish no earlier than 2012-06-19 | S2 | 4704h | 4704h | BBAI | PCG-24 | Ericsson | marco.spini@huawei.com | Rel-11 | SP-47 | Maurice |  | HNB, WLAN |  |  |
| 2436 | 574.3 | Stage 2 BB I: BBF interworking with home routed traffic for WLAN and H(e)NB | 588d? | 2010-03-26 A | 2012-06-20 A | 100% | 2010-03-26 | 2012-06-20 | 588d? | finish no earlier than 2012-06-20 | S2 | 4688.06h | 4688.06h | BBAI | PCG-24 | Ericsson | stefan.rommer@ericsson.com | Rel-11 | SP-47 | Maurice |  | HNB, WLAN |  |  |
| 2437 | 574.4 | (IETF) Stage 2 BB I: BBF interworking with home routed traffic for WLAN and H(e)NB | 266d? | 2011-12-12 A | 2012-12-12 A | 100% | 2011-12-12 | 2012-12-12 | 266d? | finish no earlier than 2012-11-24 | S2-IETF | 2119.59h | 2119.59h | BBAI | PCG-28 | Lionel Morand | Lionel Morand | Rel-11 | SP-54 | Maurice |  | HNB, WLAN |  |  |
| 2438 | 574.5 | **Stage 3 BB I - Core Network impacts: BBF interworking with home routed traffic for WLAN and H(e)NB** | 326d? | 2011-09-16 A | 2012-12-07 A | 100% | 2011-09-16 | 2012-12-07 | 326d? |  | C1; C3; C4 | 17288.2h | 17288.2h | BBAI_BBI-CT | PCG-27 | Ericsson | Zu.Qiang@Ericsson.com | Rel-11 | CP-53 | Frederic | BBAI_BBI-CT | HNB, WLAN |  |  |
| 2439 | 574.5.1 | TR on Stage 3 BB I for BBAI; UE to network protocols | 198d? | 2011-09-16 A | 2012-06-15 A | 100% | 2011-09-16 | 2012-06-15 | 198d? | finish no earlier than 2012-06-15 | C1 | 1568.15h | 1568.15h | BBAI_BBI-CT | PCG-27 | Ericsson | Zu.Qiang@Ericsson.com | Rel-11 | CP-53 | Frederic |  | HNB, WLAN |  |  |
| 2440 | 574.5.2 | TR on Stage 3 BB I for BBAI; Home (e)Node B – Security Gateway Interface | 77d? | 2012-03-02 A | 2012-06-15 A | 100% | 2012-03-02 | 2012-06-15 | 77d? | finish no earlier than 2012-06-01 | C4 | 608h | 608h | BBAI_BBI-CT | PCG-28 | Ericsson | Zu.Qiang@Ericsson.com | Rel-11 | CP-55 | Kimmo |  | HNB, WLAN |  |  |
| 2441 | 574.5.3 | Deleted - (IETF) on Stage 3 BB I for BBAI; Home (e)Node B – Security Gateway Interface | 77d? | 2012-03-02 A | 2012-06-15 A | 100% | 2012-03-02 | 2012-06-15 | 77d? | finish no earlier than 2012-06-15 | C4-IETF | 616h | 616h | BBAI_BBI-CT | PCG-28 | Lionel Morand |  | Rel-11 | CP-55 | Kimmo |  | HNB, WLAN | PCG-29 | CP-56 |
| 2442 | 574.5.4 | CT1 part of Stage 3 BB I: BBF interworking with home routed traffic for WLAN and H(e)NB | 258d? | 2011-09-16 A | 2012-09-07 A | 100% | 2011-09-16 | 2012-09-07 | 258d? | finish no earlier than 2012-09-07 | C1 | 2048h | 2048h | BBAI_BBI-CT | PCG-27 | Ericsson | Zu.Qiang@Ericsson.com | Rel-11 | CP-53 | Frederic |  | HNB, WLAN |  |  |
| 2443 | 574.5.5 | CT3 part of Stage 3 BB I: BBF interworking with home routed traffic for WLAN and H(e)NB | 259d? | 2011-09-16 A | 2012-09-07 A | 100% | 2011-09-16 | 2012-09-07 | 259d? | finish no earlier than 2012-09-07 | C3 | 2048h | 2048h | BBAI_BBI-CT | PCG-27 | Ericsson | Zu.Qiang@Ericsson.com | Rel-11 | CP-53 | Adrian |  | HNB, WLAN |  |  |
| 2444 | 574.5.6 | CT4 part of Stage 3 BB I: BBF interworking with home routed traffic for WLAN and H(e)NB | 326d? | 2011-09-16 A | 2012-12-07 A | 100% | 2011-09-16 | 2012-12-07 | 326d? | finish no earlier than 2012-12-07 | C4 | 2576h | 2576h | BBAI_BBI-CT | PCG-27 | Ericsson | Zu.Qiang@Ericsson.com | Rel-11 | CP-53 | Kimmo |  | HNB, WLAN |  |  |
| 2445 | 574.6 | Stage 1 BB II: BBF interworking with offload in access network for WLAN and for H(e)NB | 262d? | 2010-09-23 A | 2011-09-21 A | 100% | 2010-09-23 | 2011-09-21 | 262d? | finish no earlier than 2011-09-21 | S1 | 2080h | 2080h | BBAI_BBII-CTofldS1 | PCG-25 | Ericsson | Olle.Eriksson@ericsson.com | Rel-11 | SP-49 | Alain |  | HNB, WLAN |  |  |
| 2446 | 574.7 | Stage 2 BB II: BBF interworking with offload in access network for WLAN and for H(e)NB | 455d? | 2010-09-28 A | 2012-06-20 A | 100% | 2010-09-28 | 2012-06-20 | 455d? | finish no earlier than 2012-06-20 | S2 | 3640h | 3640h | BBAI_BBII-CTofldS2 | PCG-24 | Ericsson | stefan.rommer@ericsson.com | Rel-11 | SP-47 | Maurice |  | HNB, WLAN |  |  |

Notes:
- 2422: SP#55 Stage 2 completed. Triggered by SA1 Rel-11 TR 22.871 Study on Non Voice Emergency Services (FS_NOVES)
- 2423: SP#53 completed / Impacted TSs and TRs: 22.101
- 2424: SP#55 completed / Impacted TSs and TRs: 23.060, 23.167, 23.203, 23.401
- 2425: SP#53 Stage 1 completed. CP#59 completed. Triggered by Rel-11 TR 22.809 Study on Support for 3GPP Voice Interworking with Enterprise IP-PBX (FS_VINE) UID_480033
- 2426: SP#53 completed / Impacted TSs and TRs: 22.228
- 2427: CP#59 completed / Impacted TSs and TRs: 23.218, 24.229
- 2428: CP#54 completed
- 2429: SP#52 completed under TEI11. Approved WID and CRs in SP-110376 (22.082 CR#0005, 22.085 CR#0004, 22.081 CR#0007, 22.088 CR#0003, 22.004 CR#0013) / Impacted TSs and TRs: 22.004, 22.081, 22.082, 22.085, 22.088
- 2430: CP#54 completed / Impacted TSs and TRs: Stage 2/3
- 2431: CP#54 completed / Impacted TSs and TRs: 23.018, 23.081, 23.082, 23.085, 23.088, 23.205, 23.231, 24.088, 29.002, 29.011
- 2432: CP#53 completed / Impacted TSs and TRs: 29.163, 29.292
- 2433: SP#57 updated WID SP-120419=>SP-120539 (removed BB3 objectives not implemented in Stage 2). SP#56 completed. Triggered by BBF WT 203, WT-134 (interworking btw 3GPP EPS and BBF's fixed broadband accesses)
- 2434: SP#57 updated WID SP-120419=>SP-120539 (removed BB3 objectives not implemented in Stage 2). SP#47 completed. Provide service requirements for supporting interworking between 3GPP EPS and the fixed broadband accesses defined by BBF / Impacted TSs and TRs: 22.278 CR#0058
- 2435: TR 23.839 not Approved in Rel-11; progressed in Rel-12 under P4C-TI (UID_560824) / Impacted TSs and TRs: new TR 23.839
- 2436: SP#56 completed / Impacted TSs and TRs: 23.203, new 23.139
- 2437: Solved by IANA-registration. No RFC needed
- 2438: CP#58 completed / Impacted TSs and TRs: Stage 3
- 2439: CP#56 completed. Identify additional FMC specific procedurES in CP-150addition to those in 24.302 (on access authentication & authorization and tunnel management; IP mobility mode selection; security aspects) / Impacted TSs and TRs: new TR 24.820
- 2440: CP#56 completed / Impacted TSs and TRs: new TR 29.839
- 2441: Draft removed from 3GPP documentation / Impacted TSs and TRs: draft-so-ipsecme-ikev2-cpext
- 2442: CP#57 completed / Impacted TSs and TRs: 24.229, new TS 24.139
- 2443: CP#57 completed / Impacted TSs and TRs: 29.212, 29.213, 29.215
- 2444: CP#58 completed / Impacted TSs and TRs: 23.008, 29.273, 29.274, new TS 29.139
- 2445: SP#53 completed. 22/01: acronym modified / Impacted TSs and TRs: 22.278
- 2446: SP#56 completed. 22/01: acronym modified / Impacted TSs and TRs: 23.203, 23.401, 23.402, 23.139

| ID | WBS | Task | Duration | Start | Finish | Complete | Baseline start | Baseline finish | Baseline duration | Constraint | Resources | Work | Actual work | Acronym | PCG approved | Impacted TSs and TRs | WI rapporteur name | WI rapporteur e-mail | Release | TSG approved | MCC resp | Special Focus Doc | Acronym_3GU_Export | PCG stopped | TSG stopped |
| --- | --- | --- | --- | --- | --- | --- | --- | --- | --- | --- | --- | --- | --- | --- | --- | --- | --- | --- | --- | --- | --- | --- | --- | --- | --- |
| 2447 | 574.8 | **Stage 3 BB II - Core Network impacts: BBF interworking with offload in access network for WLAN and for H(e)NB** | 259d? | 2011-09-16 A | 2012-09-07 A | 100% | 2011-09-16 | 2012-09-07 | 259d? |  | C3; C1; C4 | 12888h | 12888h | BBAI_BBII-CT | PCG-27 | Stage 3 | Ericsson | Susana.Fernandez@ericsson.com | Rel-11 | CP-53 | Adrian | HNB, WLAN | BBAI_BBII-CT |  |  |
| 2448 | 574.8.1 | TR on Stage 3 BB II for 3GPP System to Fixed Broadband Access Network Interworking; UE to network protocols | 198d? | 2011-09-16 A | 2012-06-15 A | 100% | 2011-09-16 | 2012-06-15 | 198d? | finish no earlier than 2012-06-15 | C1 | 1576h | 1576h | BBAI_BBII-CT | PCG-27 | 24.820 | Ericsson | Susana.Fernandez@ericsson.com | Rel-11 | CP-53 | Frederic | HNB, WLAN |  |  |  |
| 2449 | 574.8.2 | CT1 part of Stage 3 BB II: BBF interworking with offload in access network for WLAN and for H(e)NB | 259d? | 2011-09-16 A | 2012-09-07 A | 100% | 2011-09-16 | 2012-09-07 | 259d? | finish no earlier than 2012-09-07 | C1 | 2064h | 2064h | BBAI_BBII-CT | PCG-27 | new TS 24.320 | Ericsson | Susana.Fernandez@ericsson.com | Rel-11 | CP-53 | Frederic | HNB, WLAN |  |  |  |
| 2450 | 574.8.3 | CT3 part of Stage 3 BB II: BBF interworking with offload in access network for WLAN and for H(e)NB | 259d? | 2011-09-16 A | 2012-09-07 A | 100% | 2011-09-16 | 2012-09-07 | 259d? | start no earlier than 2011-09-16 | C3 | 2056h | 2056h | BBAI_BBII-CT | PCG-27 | 29.212, 29.213, 29.215 | Ericsson | Susana.Fernandez@ericsson.com | Rel-11 | CP-53 | Adrian | HNB, WLAN |  |  |  |
| 2451 | 574.8.4 | CT4 part of Stage 3 BB II: BBF interworking with offload in access network for WLAN and for H(e)NB | 122d? | 2011-09-16 A | 2012-03-02 A | 100% | 2011-09-16 | 2012-03-02 | 122d? | start no earlier than 2011-09-16 | C4 | 976h | 976h | BBAI_BBII-CT | PCG-27 | 23.008, 29.273 | Ericsson | Susana.Fernandez@ericsson.com | Rel-11 | CP-53 | Kimmo | HNB, WLAN |  |  |  |
| 2452 | 574.9 | Deleted - Stage 1 BB III: BBF convergence and network based mobility | 262d? | 2010-09-23 A | 2011-09-21 A | 100% | 2010-09-23 | 2011-09-21 | 262d? | finish no earlier than 2011-09-21 | S1 | 2080h | 2080h |  | PCG-25 | 22.278 | Huawei | Amar Deol (adeol@huawei.com) | Rel-11 | SP-49 | Alain | HNB, WLAN |  | PCG-29 | SP-57 |
| 2453 | 574.10 | Deleted - Stage 2 BB III: BBF convergence and network based mobility | 380d? | 2010-09-28 A | 2012-03-07 A | 100% | 2010-09-28 | 2012-03-07 | 380d? | finish no earlier than 2012-03-07 | S2 | 3040h | 3040h |  | PCG-24 | 23.203, 23.401, 23.402, 23.139 | Huawei | marco.spini@huawei.com | Rel-11 | SP-47 | Maurice | HNB, WLAN |  | PCG-28 | SP-55 |
| 2454 | 574.11 | **Deleted - Stage 3 BB III - Core Network impacts: BBF convergence and network based mobility** | 122d? | 2011-09-16 A | 2012-03-02 A | 100% | 2011-09-16 | 2012-03-02 | 122d? |  | C3; C1; C4 | 6832h | 6832h |  | PCG-27 | Stage 3 | Huawei | qiaoweihua@huawei.com | Rel-11 | CP-53 | Adrian | HNB, WLAN | BBAI_BBIII-CT | PCG-28 | CP-55 |
| 2455 | 574.11.1 | Deleted - TR on Stage 3 BB III for 3GPP System to Fixed Broadband Access Network Interworking; UE to network protocols | 122d? | 2011-09-16 A | 2012-03-02 A | 100% | 2011-09-16 | 2012-03-02 | 122d? | start no earlier than 2011-09-16 | C1 | 976h | 976h |  | PCG-27 | new TR 24.820 | Huawei | qiaoweihua@huawei.com | Rel-11 | CP-53 | Frederic | HNB, WLAN |  | PCG-28 | CP-55 |
| 2456 | 574.11.2 | Deleted - CT1 part of Stage 3 BB III: BBF convergence and network based mobility | 122d? | 2011-09-16 A | 2012-03-02 A | 100% | 2011-09-16 | 2012-03-02 | 122d? | start no earlier than 2011-09-16 | C1 | 976h | 976h |  | PCG-27 | TBD | Huawei | qiaoweihua@huawei.com | Rel-11 | CP-53 | Frederic | HNB, WLAN |  | PCG-28 | CP-55 |
| 2457 | 574.11.3 | Deleted - CT3 part of Stage 3 BB III: BBF convergence and network based mobility | 122d? | 2011-09-16 A | 2012-03-02 A | 100% | 2011-09-16 | 2012-03-02 | 122d? | start no earlier than 2011-09-16 | C3 | 976h | 976h |  | PCG-27 | 29.212, 29.213, 29.215 | Huawei | qiaoweihua@huawei.com | Rel-11 | CP-53 | Adrian | HNB, WLAN |  | PCG-28 | CP-55 |
| 2458 | 574.11.4 | Deleted - CT4 part of Stage 3 BB III: BBF convergence and network based mobility | 122d? | 2011-09-16 A | 2012-03-02 A | 100% | 2011-09-16 | 2012-03-02 | 122d? | start no earlier than 2011-09-16 | C4 | 976h | 976h |  | PCG-27 | 23.008, 29.273 | Huawei | qiaoweihua@huawei.com | Rel-11 | CP-53 | Kimmo | HNB, WLAN |  | PCG-28 | CP-55 |
| 2459 | 575 | **Single Radio Voice Call Continuity (SRVCC) aspect of enhancements for Multimedia Priority Service** | 398d? | 2010-06-10 A | 2011-12-14 A | 100% | 2010-06-10 | 2011-12-14 | 398d? |  | S2 | 8432h | 8432h | eMPS_SRVCC | PCG-25 | Stage 2 | NTT DoCoMo | Atsushi Minokuchi (minokuchi@nttdocomo.co.jp) | Rel-11 | SP-48 | Maurice | Public Safety (I-A) | eMPS_SRVCC |  |  |
| 2460 | 575.1 | TR on SRVCC for eMPS | 260d? | 2010-06-10 A | 2011-06-08 A | 100% | 2010-06-10 | 2011-06-08 | 260d? | finish no earlier than 2011-06-08 | S2 | 2080h | 2080h | eMPS_SRVCC | PCG-25 | new TR 23.854 | NTT DoCoMo | Atsushi Minokuchi (minokuchi@nttdocomo.co.jp) | Rel-11 | SP-48 | Maurice | Public Safety (I-A) |  |  |  |
| 2461 | 575.2 | Stage 2 on SRVCC for eMPS | 398d? | 2010-06-10 A | 2011-12-14 A | 100% | 2010-06-10 | 2011-12-14 | 398d? | finish no earlier than 2011-12-14 | S2 | 3168h | 3168h | eMPS_SRVCC | PCG-25 | 23.216, 23.237 | NTT DoCoMo | Atsushi Minokuchi (minokuchi@nttdocomo.co.jp) | Rel-11 | SP-48 | Maurice | Public Safety (I-A) |  |  |  |
| 2462 | 576 | **Single Radio Video Call Continuity for 3G-CS** | 440d? | 2010-10-15 A | 2012-06-15 A | 100% | 2010-10-15 | 2012-06-15 | 440d? |  | S2; C1; C3; C4 | 26572.4h | 26572.4h | vSRVCC | PCG-26 |  | Samsung | xiaowan.ke@samsung.com | Rel-11 | SP-50 | Maurice |  | vSRVCC |  |  |
| 2463 | 576.1 | Stage 2 for Single Radio Video Call Continuity for 3G-CS | 199.85d? | 2010-10-15 A | 2011-09-21 A | 100% | 2010-10-15 | 2011-09-21 | 199.85d? | finish no earlier than 2011-12-07 | S2 | 1580.41h | 1580.41h | vSRVCC | PCG-26 | 23.203, 23.216, 23.237 | Samsung | xiaowan.ke@samsung.com | Rel-11 | SP-50 | Maurice |  |  |  |  |
| 2464 | 576.2 | **CN aspects of Single Radio Video Call Continuity for 3G-CS** | 275d? | 2011-06-03 A | 2012-06-15 A | 100% | 2011-06-03 | 2012-06-15 | 275d? |  | C1; C3; C4 | 10912h | 10912h | vSRVCC-CT | PCG-27 |  | NEC | gottfried.punz@neclab.eu | Rel-11 | CP-52 | Frederic |  | vSRVCC-CT |  |  |
| 2465 | 576.2.1 | CT1 aspects of Single Radio Video Call Continuity for 3G-CS | 275d? | 2011-06-03 A | 2012-06-15 A | 100% | 2011-06-03 | 2012-06-15 | 275d? | finish no earlier than 2012-06-15 | C1 | 2184h | 2184h | vSRVCC-CT | PCG-27 | 24.008, 24.237, 24.301 | NEC | gottfried.punz@neclab.eu | Rel-11 | CP-52 | Frederic |  |  |  |  |
| 2466 | 576.2.2 | CT3 aspects of Single Radio Video Call Continuity for 3G-CS | 134d? | 2011-06-03 A | 2011-12-02 A | 100% | 2011-06-03 | 2011-12-02 | 134d? | finish no earlier than 2011-12-02 | C3 | 1064h | 1064h | vSRVCC-CT | PCG-27 | 29.211, 29.212, 29.213, 29.215 | NEC | gottfried.punz@neclab.eu | Rel-11 | CP-52 | Adrian |  |  |  |  |
| 2467 | 576.2.3 | CT4 aspects of Single Radio Video Call Continuity for 3G-CS | 134d? | 2011-06-03 A | 2011-12-02 A | 100% | 2011-06-03 | 2011-12-02 | 134d? | finish no earlier than 2011-12-02 | C4 | 1064h | 1064h | vSRVCC-CT | PCG-27 | 29.280 | NEC | gottfried.punz@neclab.eu | Rel-11 | CP-52 | Kimmo |  |  |  |  |
| 2468 | 577 | **Network-provided Location information for IMS (NETLOC)** | 720d? | 2010-06-10 A | 2013-03-01 A | 100% | 2010-06-10 | 2013-03-01 | 720d? |  | S2; S1; S5; C3; C4; C1 | 57274.7h | 57274.7h | NWK-PL2IMS | PCG-25 |  | T-Mobile | michele.zarri@t-mobile.co.uk | Rel-11 | SP-48 | Maurice |  | NWK-PL2IMS |  |  |
| 2469 | 577.1 | Stage 1 for Network-provided Location information for IMS | 203d? | 2010-12-15 A | 2011-09-21 A | 100% | 2010-12-15 | 2011-09-21 | 203d? | finish no earlier than 2011-09-21 | S1 | 1608h | 1608h | NWK-PL2IMS | PCG-26 | 22.115 | n/a | n/a | Rel-11 | SP-50 | Alain |  |  |  |  |
| 2470 | 577.2 | TR on Stage 2 for Network-provided Location information for IMS | 395d? | 2010-06-10 A | 2011-12-14 A | 100% | 2010-06-10 | 2011-12-14 | 395d? | finish no earlier than 2011-12-06 | S2 | 3160h | 3160h | NWK-PL2IMS | PCG-25 | new TR 23.842 | T-Mobile | michele.zarri@t-mobile.co.uk | Rel-11 | SP-48 | Maurice |  |  |  |  |
| 2471 | 577.3 | Stage 2 for Network-provided Location information for IMS | 455d? | 2010-06-15 A | 2012-03-07 A | 100% | 2010-06-15 | 2012-03-07 | 455d? | finish no earlier than 2012-03-07 | S2 | 3640h | 3640h | NWK-PL2IMS | PCG-25 | 23.060, 23.203, 23.228, 23.401 | T-Mobile | michele.zarri@t-mobile.co.uk | Rel-11 | SP-48 | Maurice |  |  |  |  |
| 2472 | 577.4 | Charging for Network-provided Location information for IMS | 515d? | 2010-09-23 A | 2012-09-12 A | 100% | 2010-09-23 | 2012-09-12 | 515d? | finish no earlier than 2012-09-12 | S5 | 4120h | 4120h | NWK-PL2IMS_CH | PCG-25 | Stage 2 (32.240, 32.260), Stage 3 (32.298, 32.299) | Nokia Siemens Networks | Gerald.Goermer@nsn.com | Rel-11 | SP-49 | Mirko |  | NWK-PL2IMS_CH |  |  |

Notes:
- 2447: CP#57 completed
- 2448: CP#56 completed
- 2449: CP#57 completed
- 2450: CP#57 completed
- 2451: CP#55 completed
- 2452: SP#57 stopped. Updated WID SP-120419=>SP-120539 (removed BB3 objectives not implemented in Stage 2). SP#53 completed
- 2453: SP#57 updated WID SP-120419=>SP-120539 (removed BB3 objectives not implemented in Stage 2). SP#55 stopped
- 2454: CP#55 stopped
- 2455: CP#55 stopped
- 2456: CP#55 stopped
- 2457: CP#55 stopped
- 2458: CP#55 stopped
- 2459: SP#54 completed. Analyze and if needed specify mechanisms for the priority handling of SRVCC with regard to LTE/EPC
- 2460: SP#52 completed
- 2461: SP#54 completed
- 2462: CP#56 completed. Provide Single Radio VIDEO Call Continuity from E-UTRAN to UTRAN-CS based on the agreed architecture alternative in TR 23.886
- 2463: SP#53 completed. Triggered by Feasibility Study on video call handover capability in TR 23.886 UID_470048 Study on Single Radio Video Call Continuity for 3G-CS (FS_vSRVCC)
- 2464: Stage 3. CP#56 completed
- 2465: CP#56 completed
- 2466: CP#54 completed
- 2467: CP#54 completed
- 2468: Covers the case where UE is served by a 3GPP RAN. Architecture making Cell/PLMN ID (UE is camped on) available to IMS nodes when the operator needs to record this information either to fulfil legal obligations or for charging.
- 2469: SP#53 completed
- 2470: SP#54 completed
- 2471: SP#55 completed
- 2472: SP#57 completed

| ID | WBS | Task | Type | Duration | Start | Finish | Complete | Baseline start | Baseline finish | Baseline duration | Constraint | Resources | Work | Actual work | Acronym | PCG approved | WI rapporteur name | WI rapporteur e-mail | Release | TSG approved | MCC resp | Acronym_3GU_Export | Special Focus Doc | PCG stopped | TSG stopped |
| --- | --- | --- | --- | --- | --- | --- | --- | --- | --- | --- | --- | --- | --- | --- | --- | --- | --- | --- | --- | --- | --- | --- | --- | --- | --- |
| 2473 | 577.5 | **CT aspects of Network-provided Location information for IMS (Stage 3)** |  | 266d? | 2012-03-02 A | 2013-03-01 A | 100% | 2012-03-02 | 2013-03-01 | 266d? |  | C3; C4; C1 | 10186.7h | 10186.7h | NWK-PL2IMS-CT | PCG-28 | Huawei | Qiao Weihua (qiaoweihua@huawei.com) | Rel-11 | CP-55 | Adrian | NWK-PL2IMS_CT |  |  |  |
| 2474 | 577.5.1 | CT3 part of CT aspects of Network-provided Location information for IMS |  | 138d? | 2012-03-02 A | 2012-09-07 A | 100% | 2012-03-02 | 2012-09-07 | 138d? | finish no earlier than 2012-09-07 | C3 | 1088h | 1088h | NWK-PL2IMS-CT | PCG-28 | Huawei | Qiao Weihua (qiaoweihua@huawei.com) | Rel-11 | CP-55 | Adrian |  |  |  |  |
| 2475 | 577.5.2 | CT4 part of CT aspects of Network-provided Location information for IMS |  | 77d? | 2012-03-02 A | 2012-06-15 A | 100% | 2012-03-02 | 2012-06-15 | 77d? | finish no earlier than 2012-06-01 | C4 | 608h | 608h | NWK-PL2IMS-CT | PCG-28 | Huawei | Qiao Weihua (qiaoweihua@huawei.com) | Rel-11 | CP-55 | Kimmo |  |  |  |  |
| 2476 | 577.5.3 | CT1 part of CT aspects of Network-provided Location information for IMS |  | 266d? | 2012-03-02 A | 2013-03-01 A | 100% | 2012-03-02 | 2013-03-01 | 266d? | finish no earlier than 2013-06-14 | C1 | 2106.67h | 2106.67h | NWK-PL2IMS-CT | PCG-28 | Huawei | Qiao Weihua (qiaoweihua@huawei.com) | Rel-11 | CP-55 | Frederic |  |  |  |  |
| 2477 | 578 | **Service Awareness and Privacy Policies** |  | 301.15d? | 2010-10-12 A | 2011-12-02 A | 100% | 2010-10-12 | 2011-12-02 | 301.15d? |  | S2; S1; C3 | 10667.6h | 10667.6h | SAPP | PCG-26 | Allot | Alla Goldner (agoldner@allot.com) | Rel-11 | SP-50 | Maurice | SAPP |  |  |  |
| 2478 | 578.1 | Stage 1 for Service Awareness and Privacy Policies |  | 46.15d? | 2010-10-12 A | 2010-12-15 A | 100% | 2010-10-12 | 2010-12-15 | 46.15d? | finish no earlier than 2010-12-15 | S1 | 369.2h | 369.2h | SAPP | PCG-26 | Allot | Alla Goldner (agoldner@allot.com) | Rel-11 | SP-50 | Maurice |  |  |  |  |
| 2479 | 578.2 | Stage 2 for Service Awareness and Privacy Policies |  | 199.85d? | 2010-10-15 A | 2011-09-21 A | 100% | 2010-10-15 | 2011-09-21 | 199.85d? | finish no earlier than 2011-09-21 | S2 | 1582.8h | 1582.8h | SAPP | PCG-26 | Allot | Alla Goldner (agoldner@allot.com) | Rel-11 | SP-50 | Maurice |  |  |  |  |
| 2480 | 578.3 | CT3 part of Service Awareness and Privacy Policies |  | 187d? | 2011-03-18 A | 2011-12-02 A | 100% | 2011-03-18 | 2011-12-02 | 187d? | finish no earlier than 2011-12-02 | C3 | 1488h | 1488h | SAPP-CT3 | PCG-26 | Allot | Alla Goldner (agoldner@allot.com) | Rel-11 | CP-51 | Adrian | SAPP-CT3 |  |  |  |
| 2481 | 579 | **VPLMN Autonomous CSG Roaming** |  | 307d? | 2010-10-15 A | 2011-12-14 A | 100% | 2010-10-15 | 2011-12-14 | 307d? |  | S2; C4 | 6974.61h | 6974.61h | VCSG | PCG-26 | Qualcomm | AC Mahendran (ac@qualcomm.com) | Rel-11 | SP-50 | Maurice | VCSG |  |  |  |
| 2482 | 579.1 | Stage 2 for VPLMN Autonomous CSG Roaming |  | 260.85d? | 2010-10-15 A | 2011-12-14 A | 100% | 2010-10-15 | 2011-12-14 | 260.85d? | finish no earlier than 2011-12-07 | S2 | 2062.61h | 2062.61h | VCSG | PCG-26 | Qualcomm | AC Mahendran (ac@qualcomm.com) | Rel-11 | SP-50 | Maurice |  |  |  |  |
| 2483 | 579.2 | CT aspects of VPLMN Autonomous CSG Roaming | milestone | 0d? | 2011-12-07 A | 2011-12-07 A | 100% | 2011-12-07 | 2011-12-07 | 0d? | finish no earlier than 2012-09-07 | C4 |  |  | VCSG-St3 | PCG-27 | ZTE | Fei Lu (lu.fei1@zte.com.cn) | Rel-11 | CP-53 | Kimmo | VCSG-St3 |  |  |  |
| 2484 | 580 | **Data Identification in Access Network Discovery and Selection Function (ANDSF)** |  | 455d? | 2011-03-23 A | 2012-12-07 A | 100% | 2011-03-23 | 2012-12-07 | 455d? |  | S2; C1 | 12488h | 12488h | DIDA | PCG-26 | Qualcomm | Gerardo Giaretta (gerardo@qualcomm.com) | Rel-11 | SP-51 | Maurice | DIDA |  |  |  |
| 2485 | 580.1 | TR on Stage 2 for Data Identification in ANDSF |  | 193d? | 2011-03-23 A | 2011-12-14 A | 100% | 2011-03-23 | 2011-12-14 | 193d? | finish no earlier than 2011-12-07 | S2 | 1544h | 1544h | DIDA | PCG-26 | Qualcomm | Gerardo Giaretta (gerardo@qualcomm.com) | Rel-11 | SP-51 | Maurice |  |  |  |  |
| 2486 | 580.2 | Stage 2 for Data Identification in ANDSF |  | 253d? | 2011-03-24 A | 2012-03-07 A | 100% | 2011-03-24 | 2012-03-07 | 253d? | finish no earlier than 2012-03-07 | S2 | 2024h | 2024h | DIDA | PCG-26 | Qualcomm | Gerardo Giaretta (gerardo@qualcomm.com) | Rel-11 | SP-51 | Maurice |  |  |  |  |
| 2487 | 580.3 | CT aspects of Data Identification in Access Network Discovery and Selection Function (ANDSF) Stage 3 |  | 205d? | 2012-03-02 A | 2012-12-07 A | 100% | 2012-03-02 | 2012-12-07 | 205d? | finish no earlier than 2012-12-07 | C1 | 1640h | 1640h | DIDA-CT | PCG-28 | Qualcomm | Patrick Stupar (pstupar@qualcomm.com) | Rel-11 | CP-55 | Frederic | DIDA-CT |  |  |  |
| 2488 | 581 | **LOcation-Based Selection of gaTEways foR WLAN** |  | 327d? | 2011-03-23 A | 2012-06-15 A | 100% | 2011-03-23 | 2012-06-15 | 327d? |  | S2; C4 | 10170.5h | 10170.5h | LOBSTER | PCG-26 | ZTE | zhu.chunhui@zte.com.cn | Rel-11 | SP-51 | Maurice | LOBSTER | WLAN |  |  |
| 2489 | 581.1 | Stage 2 for LOcation-Based Selection of gaTEways foR WLAN |  | 194d? | 2011-03-23 A | 2011-12-14 A | 100% | 2011-03-23 | 2011-12-14 | 194d? | finish no earlier than 2011-12-07 | S2 | 1546.52h | 1546.52h | LOBSTER | PCG-26 | ZTE | zhu.chunhui@zte.com.cn | Rel-11 | SP-51 | Maurice |  | WLAN |  |  |
| 2490 | 581.2 | **CT aspects of LOcation-Based Selection of gaTEways foR WLAN** |  | 142d? | 2011-12-02 A | 2012-06-15 A | 100% | 2011-12-02 | 2012-06-15 | 142d? |  | C4 | 3392h | 3392h | LOBSTER-CT | PCG-28 | ZTE | zhou.xingyue@zte.com.cn | Rel-11 | CP-54 | Kimmo | LOBSTER-CT | WLAN |  |  |
| 2491 | 581.2.1 | CT4 part of CT aspects of LOcation-Based Selection of gaTEways foR WLAN |  | 142d? | 2011-12-02 A | 2012-06-15 A | 100% | 2011-12-02 | 2012-06-15 | 142d? | finish no earlier than 2012-06-15 | C4 | 1128h | 1128h | LOBSTER-CT | PCG-28 | ZTE | zhou.xingyue@zte.com.cn | Rel-11 | CP-54 | Kimmo |  | WLAN |  |  |
| 2492 | 581.2.2 | Deleted - CT1 part of CT aspects of LOcation-Based Selection of gaTEways foR WLAN |  | 142d? | 2011-12-02 A | 2012-06-15 A | 100% | 2011-12-02 | 2012-06-15 | 142d? | finish no earlier than 2012-06-15 | C1 | 1128h | 1128h | LOBSTER-CT | PCG-28 | ZTE | zhou.xingyue@zte.com.cn | Rel-11 | CP-54 | Frederic |  | WLAN | PCG-29 | CP-56 |
| 2493 | 582 | **Single Radio Voice Call Continuity from UTRAN/GERAN to E-UTRAN/HSPA** |  | 929d? | 2011-09-12 A | 2015-03-15 A | 100% | 2011-09-12 | 2014-12-05 | 856d? |  | S2; C1; C3; C4; G2; R2; R3; R5 | 83776.8h | 83776.8h | rSRVCC | PCG-27 | Orange | antoine.mouquet@orange-ftgroup.com | Rel-11 | SP-53 | Maurice | rSRVCC |  |  |  |
| 2494 | 582.1 | Stage 2 for Single Radio Voice Call Continuity from UTRAN/GERAN to E-UTRAN/HSPA |  | 197d? | 2011-09-22 A | 2012-06-20 A | 100% | 2011-09-22 | 2012-06-20 | 197d? | finish no earlier than 2012-06-20 | S2 | 1568h | 1568h | rSRVCC | PCG-27 | Orange | antoine.mouquet@orange-ftgroup.com | Rel-11 | SP-53 | Maurice |  |  |  |  |
| 2495 | 582.2 | **CT aspects for Single Radio Voice Call Continuity from UTRAN/GERAN to E-UTRAN/HSPA (Stage 3)** |  | 259d? | 2011-09-16 A | 2012-09-07 A | 100% | 2011-09-16 | 2012-09-07 | 259d? |  | C1; C3; C4 | 12360h | 12360h | rSRVCC-CT | PCG-27 | Ericsson | ivo.sedlacek@ericsson.com | Rel-11 | CP-53 | Frederic | rSRVCC-CT |  |  |  |
| 2496 | 582.2.1 | CT1 part for Single Radio Voice Call Continuity from UTRAN/GERAN to E-UTRAN/HSPA |  | 258d? | 2011-09-16 A | 2012-09-07 A | 100% | 2011-09-16 | 2012-09-07 | 258d? | finish no earlier than 2012-09-07 | C1 | 2048h | 2048h | rSRVCC-CT | PCG-27 | Ericsson | ivo.sedlacek@ericsson.com | Rel-11 | CP-53 | Frederic |  |  |  |  |
| 2497 | 582.2.2 | CT3 part for Single Radio Voice Call Continuity from UTRAN/GERAN to E-UTRAN/HSPA |  | 257d? | 2011-09-19 A | 2012-09-07 A | 100% | 2011-09-19 | 2012-09-07 | 257d? | finish no earlier than 2012-09-07 | C3 | 2048h | 2048h | rSRVCC-CT | PCG-27 | Ericsson | ivo.sedlacek@ericsson.com | Rel-11 | CP-53 | Adrian |  |  |  |  |
| 2498 | 582.2.3 | CT4 part for Single Radio Voice Call Continuity from UTRAN/GERAN to E-UTRAN/HSPA |  | 257d? | 2011-09-19 A | 2012-09-07 A | 100% | 2011-09-19 | 2012-09-07 | 257d? | finish no earlier than 2012-09-07 | C4 | 2048h | 2048h | rSRVCC-CT | PCG-27 | Ericsson | ivo.sedlacek@ericsson.com | Rel-11 | CP-53 | Kimmo |  |  |  |  |
| 2499 | 582.3 | GERAN aspects of Single Radio Voice Call Continuity from UTRAN/GERAN to E-UTRAN/HSPA (Stage 3) |  | 476.1d? | 2011-09-12 A | 2013-06-28 A | 100% | 2011-09-12 | 2013-06-28 | 476.1d? | finish no earlier than 2013-11-22 | G2 | 2048h | 2048h | rSRVCC-GERAN | PCG-27 | ZTE | li.jing4@zte.com.cn | Rel-11 | GP-51 | Gert | rSRVCC-GERAN |  |  |  |

Notes:
- 2473: Stage 3. 3/3: Acronym changed from "NWK-PL2IMS_CT"
- 2474: CP#57 completed. 3/3: Acronym changed from "NWK-PL2IMS_CT" / Impacted TSs and TRs: 29.212, 29.214, 29.215
- 2475: CP#57 completed. 3/3: Acronym changed from "NWK-PL2IMS_CT" / Impacted TSs and TRs: 23.008, 29.002, 29.060, 29.230, 29.272, 29.274, 29.305, 29.328, 29.329
- 2476: CP#57 completed. 3/3: Acronym changed from "NWK-PL2IMS_CT" / Impacted TSs and TRs: 24.229, 24.292
- 2477: CP#54 completed. Triggered by the SA1,SA2 Rel-10 TR 23.813 Study on Policy solutions and enhancements (FS_PP) UID_440047
- 2478: For deep packet inspection (i.e. Traffic Detection Functionality) SA1 indicated that no new requirements are needed (see Objective of FS_PP SA1,SA2 Rel-10 Study on Policy solutions and enhancements UID_440047 TR 23.813)
- 2479: SP#53 completed / Impacted TSs and TRs: 23.203
- 2480: CP#54 completed. Stage 3 to support Application Detection and Control Functionality. Update Gx / introduce Sd reference points and procedures. Update S9 reference point in roaming scenarios / Impacted TSs and TRs: 29.212, 29.213, 29.214, 29.215
- 2481: CP#56 completed. Linked to Rel-10 UID_450053 Enhanced Home NodeB / eNodeB (EHNB). Implements Rel-9 requirements for CSG support in SA1 TS 22.220
- 2482: SP#54 completed / Impacted TSs and TRs: 23.002, 23.060, 23.401
- 2483: CP#57 completed / Impacted TSs and TRs: 23.003, 23.007, 23.008, 23.012, 29.002, 29.230, 29.272
- 2484: SP#58 completed. Linked to Rel-10 IFOM (IP Flow Mobility and seamless WLAN offload) UID_450041. Defines IP flow mobility, seamless and non seamless WLAN offload and respective ANDSF extensions / Impacted TSs and TRs: Stage 2/3
- 2485: SP#54 completed / Impacted TSs and TRs: New TR 23.855
- 2486: SP#55 completed / Impacted TSs and TRs: 23.402
- 2487: CP#58 completed / Impacted TSs and TRs: 24.302, 24.312
- 2488: CP#56 completed. Related to UID_350027 SAE for support for non-3GPP accesses (SAES-SA-FP_n3GPP). Enhancements to ePDG and PDN GW selection functions for S2b and S2c based on UE location
- 2489: SP#54 completed / Impacted TSs and TRs: 23.402
- 2490: Stage 3. CP#56 completed / Impacted TSs and TRs: Stage 3
- 2491: CP#56 completed / Impacted TSs and TRs: 29.273
- 2492: CP#56 stopped / Impacted TSs and TRs: 24.302
- 2493: Stage 1 in Rel-8 TS 22.278 clause 7.1.4.2. Triggered by Rel-11 TR 23.885 Study on Single Radio Voice Call Continuity from UTRAN/GERAN to E-UTRAN/HSPA (FS_rSRVCC) UID_460030
- 2494: SP#56 completed / Impacted TSs and TRs: 23.216, 23.237
- 2495: CP#57 completed / Impacted TSs and TRs: Stage 3
- 2496: CP#57 completed / Impacted TSs and TRs: 23.009, 24.008, 24.229, 24.237, 24.292, 24.301
- 2497: CP#57 completed / Impacted TSs and TRs: 29.165, 29.292
- 2498: CP#57 completed / Impacted TSs and TRs: 23.003, 23.008, 29.002, 29.230, 29.272, 29.280, 29.303, 29.305, 29.328
- 2499: GP#60 completed. GP#51 approved WID / Impacted TSs and TRs: 44.018, 48.008

| ID | WBS | Task | Duration | Start | Finish | Complete | Baseline start | Baseline finish | Baseline duration | Constraint | Resources | Work | Actual work | Acronym | PCG approved | Impacted TSs and TRs | WI rapporteur name | Release | TSG approved | MCC resp | Acronym_3GU_Export | Status Report | Special Focus Doc | PCG stopped | TSG stopped |
| --- | --- | --- | --- | --- | --- | --- | --- | --- | --- | --- | --- | --- | --- | --- | --- | --- | --- | --- | --- | --- | --- | --- | --- | --- | --- |
| 2500 | 582.4 | **UTRAN aspects of Single Radio Voice Call Continuity from UTRAN/GERAN to E-UTRAN/HSPA** | 325d? | 2011-09-19 A | 2012-12-07 A | 100% | 2011-09-19 | 2012-12-07 | 325d? |  | R3; R2 | 10400h | 10400h | rSRVCC-RAN_UTRA | PCG-27 | UTRA | Huawei | Rel-11 | RP-53 | Juha | rSRVCC-RAN_UTRA |  |  |  |  |
| 2501 | 582.4.1 | Core part: UTRAN aspects of Single Radio Voice Call Continuity from UTRAN/GERAN to E-UTRAN/HSPA | 325d? | 2011-09-19 A | 2012-12-07 A | 100% | 2011-09-19 | 2012-12-07 | 325d? | finish no earlier than 2012-12-07 | R3; R2 | 5200h | 5200h | rSRVCC-RAN_UTRA-Core | PCG-27 | 25.331, 25.401, 25.413 | Huawei | Rel-11 | RP-53 | Juha | rSRVCC-RAN_UTRA-Core | RP-121553 |  |  |  |
| 2502 | 582.5 | Test part: Single Radio Voice Call Continuity from UTRAN/GERAN to E-UTRAN/HSPA | 196d? | 2014-06-15 A | 2015-03-15 A | 100% | 2014-06-13 | 2014-12-05 | 126d? | finish no earlier than 2015-03-15 | R5 | 1568h | 1568h | rSRVCC-UEConTest | PCG-33 | 36.508, 36.523-1, 36.523-2, 36.523-3 | Ericsson | Rel-11 | RP-64 |  | rSRVCC-UEConTest | RP-150133 |  |  |  |
| 2503 | 583 | **S2a Mobility based On GTP and WLAN access to EPC** | 651d? | 2011-09-22 A | 2014-03-05 A | 100% | 2011-09-22 | 2014-03-05 | 651d? |  | S2; C4; C1; C3; IETF | 54000h | 54000h | SaMOG_WLAN | PCG-27 | Stage 2/3 | ZTE | Rel-11 | SP-53 | Maurice | SaMOG_WLAN |  | WLAN |  |  |
| 2504 | 583.1 | Stage 2 for S2a Mobility based On GTP and WLAN access to EPC | 121d? | 2011-09-22 A | 2012-03-07 A | 100% | 2011-09-22 | 2012-03-07 | 121d? | finish no earlier than 2012-03-07 | S2 | 968h | 968h | SaMOG_WLAN | PCG-27 | 23.002, 23.203, 23.402 | ZTE | Rel-11 | SP-53 | Maurice |  |  | WLAN |  |  |
| 2505 | 583.2 | **CN aspects of Mobility based On GTP & PMIPv6 for WLAN access to EPC** | 599d? | 2011-12-02 A | 2014-03-05 A | 100% | 2011-12-02 | 2014-03-05 | 599d? |  | C4; C1; C3; IETF | 26992h | 26992h | SaMOG_WLAN-CN | PCG-28 | Stage 3 | Alcatel-Lucent | Rel-11 | CP-54 | Kimmo | SaMOG_WLAN-CN |  | WLAN |  |  |
| 2506 | 583.2.1 | CT4 part of CN aspects of Mobility based On GTP & PMIPv6 for WLAN access to EPC | 203d? | 2011-12-02 A | 2012-09-07 A | 100% | 2011-12-02 | 2012-09-07 | 203d? | finish no earlier than 2012-09-07 | C4 | 1608h | 1608h | SaMOG_WLAN-CN | PCG-28 | 23.003, 23.007, 23.008, 29.273, 29.274, 29.281, 29.303 | Alcatel-Lucent | Rel-11 | CP-54 | Kimmo |  |  | WLAN |  |  |
| 2507 | 583.2.2 | Deleted - (IETF) CT4 part of CN aspects of Mobility based On GTP & PMIPv6 for WLAN access to EPC | 498d? | 2012-04-23 A | 2014-03-05 A | 100% | 2012-04-23 | 2014-03-05 | 498d? | finish no earlier than 2014-03-05 | C4-IETF | 3960h | 3960h | SaMOG_WLAN-CN | PCG-29 | draft-ietf-radext-ieee802ext | Lionel Morand | Rel-11 | CP-56 | Kimmo |  |  | WLAN | PCG-32 | CP-53 |
| 2508 | 583.2.3 | Deleted - CT1 part of CN aspects of Mobility based On GTP & PMIPv6 for WLAN access to EPC | 142d? | 2011-12-02 A | 2012-06-15 A | 100% | 2011-12-02 | 2012-06-15 | 142d? | finish no earlier than 2012-06-15 | C1 | 1128h | 1128h | SaMOG_WLAN-CN | PCG-28 | 24.302 | Alcatel-Lucent | Rel-11 | CP-54 | Frederic |  |  | WLAN | PCG-29 | CP-56 |
| 2509 | 583.2.4 | CT3 part of CN aspects of Mobility based On GTP & PMIPv6 for WLAN access to EPC | 142d? | 2011-12-02 A | 2012-06-15 A | 100% | 2011-12-02 | 2012-06-15 | 142d? | finish no earlier than 2012-09-07 | C3 | 1128h | 1128h | SaMOG_WLAN-CN | PCG-28 | 29.212, 29.213, 29.215 | Alcatel-Lucent | Rel-11 | CP-54 | Adrian |  |  | WLAN |  |  |
| 2510 | 584 | **Roaming Architecture for Voice over IMS with Local Breakout** | 273d? | 2011-11-28 A | 2012-12-07 A | 100% | 2011-11-28 | 2012-12-07 | 273d? |  | S2; S5; C1; C3 | 16904h | 16904h | RAVEL | PCG-28 | Stage 2/3 | Deutsche Telekom | Rel-11 | SP-54 | Maurice | RAVEL |  |  |  |  |
| 2511 | 584.1 | Stage 2 for Roaming Architecture for Voice over IMS with Local Breakout | 12d? | 2011-11-28 A | 2011-12-14 A | 100% | 2011-11-28 | 2011-12-14 | 12d? | finish no earlier than 2012-03-07 | S2 | 96h | 96h | RAVEL | PCG-28 | 23.002, 23.228 | Deutsche Telekom | Rel-11 | SP-54 | Maurice |  |  |  |  |  |
| 2512 | 584.2 | Charging for Roaming Architecture for Voice over IMS with Local Breakout | 196d? | 2011-12-14 A | 2012-09-12 A | 100% | 2011-12-14 | 2012-09-12 | 196d? | finish no earlier than 2012-09-12 | S5 | 1568h | 1568h | RAVEL-CH | PCG-28 | 32.240, 32.260, 32.298, 32.299 | Nokia Siemens Networks | Rel-11 | SP-54 | Mirko | RAVEL-CH |  |  |  |  |
| 2513 | 584.3 | **CT aspects of Roaming Architecture for Voice over IMS with Local Breakout (Stage 3)** | 205d? | 2012-03-02 A | 2012-12-07 A | 100% | 2012-03-02 | 2012-12-07 | 205d? |  | C1; C3 | 6504h | 6504h | RAVEL-CT | PCG-28 | Stage 3 | Deutsche Telekom | Rel-11 | CP-55 | Frederic | RAVEL-CT |  |  |  |  |
| 2514 | 584.3.1 | CT1 part of CT aspects of Roaming Architecture for Voice over IMS with Local Breakout | 204d? | 2012-03-02 A | 2012-12-07 A | 100% | 2012-03-02 | 2012-12-07 | 204d? | finish no earlier than 2012-12-07 | C1 | 1608h | 1608h | RAVEL-CT | PCG-28 | 24.229, 24.292, 24.237 | Deutsche Telekom | Rel-11 | CP-55 | Frederic |  |  |  |  |  |
| 2515 | 584.3.2 | CT3 part of CT aspects of Roaming Architecture for Voice over IMS with Local Breakout | 204d? | 2012-03-02 A | 2012-12-07 A | 100% | 2012-03-02 | 2012-12-07 | 204d? | finish no earlier than 2012-12-07 | C3 | 1616h | 1616h | RAVEL-CT | PCG-28 | 29.165, 29.162, 29.079 | Deutsche Telekom | Rel-11 | CP-55 | Adrian |  |  |  |  |  |
| 2516 | 585 | **IMS Overload Control** | 659d? | 2012-06-18 A | 2014-12-09 A | 100% | 2012-06-18 | 2014-12-05 | 654d? |  | S2; C1; C3; IETF | 52408h | 52408h | IOC | PCG-29 | Stage 2/3 | Orange, China Mobile | Rel-11 | SP-56 | Maurice | IOC |  |  |  |  |
| 2517 | 585.1 | Stage 2 for IMS Overload Control | 64d? | 2012-06-18 A | 2012-09-12 A | 100% | 2012-06-18 | 2012-09-12 | 64d? | finish no earlier than 2012-09-12 | S2 | 504h | 504h | IOC | PCG-29 | 23.228 | Orange, China Mobile | Rel-11 | SP-56 | Maurice |  |  |  |  |  |
| 2518 | 585.2 | **Stage 3 for IMS Overload Control** | 601d? | 2012-09-05 A | 2014-12-09 A | 100% | 2012-09-05 | 2014-12-05 | 596d? |  | C1; C3; IETF | 30816h | 30816h | IOC | PCG-29 |  | Alcatel-Lucent | Rel-11 | CP-57 | Frederic |  |  |  |  |  |
| 2519 | 585.2.1 | CT1 part of Stage 3 for IMS Overload Control | 70d? | 2012-09-05 A | 2012-12-07 A | 100% | 2012-09-05 | 2012-12-07 | 70d? | finish no earlier than 2012-12-07 | C1 | 544h | 544h | IOC | PCG-29 | 24.229 | Alcatel-Lucent | Rel-11 | CP-57 | Frederic |  |  |  |  |  |
| 2520 | 585.2.2 | CT3 part of Stage 3 for IMS Overload Control | 70d? | 2012-09-05 A | 2012-12-07 A | 100% | 2012-09-05 | 2012-12-07 | 70d? | finish no earlier than 2012-12-07 | C3 | 552h | 552h | IOC | PCG-29 | 29.165 | Alcatel-Lucent | Rel-11 | CP-57 | Adrian |  |  |  |  |  |
| 2521 | 585.2.3 | (IETF) CT part of Stage 3 for IMS Overload Control (soc-overload-control) | 361d? | 2013-07-29 A | 2014-12-09 A | 100% | 2013-07-29 | 2014-12-05 | 359d? | finish no earlier than 2014-12-09 | C1-IETF; C3-IETF | 5776h | 5776h | IOC | PCG-29 | RFC 7339 | Keith Drage | Rel-11 | CP-57 | Frederic |  |  |  |  |  |
| 2522 | 585.2.4 | (IETF) CT part of Stage 3 for IMS Overload Control (soc-overload-rate-control) | 361d? | 2013-07-29 A | 2014-12-09 A | 100% | 2013-07-29 | 2014-12-05 | 359d? | finish no earlier than 2014-12-09 | C1-IETF; C3-IETF | 5776h | 5776h | IOC | PCG-29 | RFC 7415 | Keith Drage | Rel-11 | CP-57 | Frederic |  |  |  |  |  |
| 2523 | 585.2.5 | (IETF) CT part of Stage 3 for IMS Overload Control (RFC 7200) | 234d? | 2013-07-29 A | 2014-06-13 A | 100% | 2013-07-29 | 2014-06-13 | 234d? | finish no earlier than 2014-06-13 | C1-IETF; C3-IETF | 3744h | 3744h | IOC | PCG-29 | RFC 7200 (was draft-ietf-soc-load-control-event-package) | Keith Drage | Rel-11 | CP-57 | Frederic |  |  |  |  |  |
| 2524 | 586 | Rel-11 Security small Enhancements | 336d? | 2011-06-08 A | 2012-09-12 A | 100% | 2011-06-08 | 2012-09-12 | 336d? | finish no earlier than 2012-09-12 | S3 | 2680h | 2680h | SEC11 | PCG-27 |  |  | Rel-11 | SP-52 | Mirko | SEC11 |  |  |  |  |
| 2525 | 587 | Lawful Interception in the 3GPP Rel-11 | 272d? | 2011-06-10 A | 2012-06-20 A | 100% | 2011-06-10 | 2012-06-20 | 272d? | finish no earlier than 2012-06-20 | S3 | 2176h | 2176h | LI11 | PCG-27 | 33.106, 33.107, 33.108 | PIDS, Alcatel-Lucent | Rel-11 | SP-52 | Mirko | LI11 |  |  |  |  |

Notes:
- 2500: RP#58 completed / WI rapporteur e-mail: liwei.qiu@huawei.com
- 2501: RP#58 completed / WI rapporteur e-mail: liwei.qiu@huawei.com
- 2502: ; Stat Rep: RP-141167->RP-141771 1st Apr 15: Compl:40%->100% 1st Apr 15: Stat Rep: RP-141771->RP-150133 / WI rapporteur e-mail: calle.hagenfeldt@ericsson.com
- 2503: Triggered by Rel-11 TR 23.852 FS_SaMOG UID_510061, Rel-8 UID_350027 SAE for support for non-3GPP accesses (defines PMIP-S2a) / WI rapporteur e-mail: Chunhui Zhu (zhu.chunhui@zte.com.cn)
- 2504: SP#55 completed / WI rapporteur e-mail: zhu.chunhui@zte.com.cn
- 2505: - / WI rapporteur e-mail: bruno.landais@alcatel-lucent.com
- 2506: CP#57 completed / WI rapporteur e-mail: bruno.landais@alcatel-lucent.com
- 2507: CP#63 Draft removed from 3GPP documentation
- 2508: CP#56 stopped (no CT1 impact) / WI rapporteur e-mail: bruno.landais@alcatel-lucent.com
- 2509: CP#56 completed / WI rapporteur e-mail: bruno.landais@alcatel-lucent.com
- 2510: CP#58 completed. Triggered by Rel-11 TR 23.850 Study on Roaming Architecture for Voice over IMS with Local Breakout (FS_RAVEL). GSMA CPWP LS_in S5-102806 asked 3GPP SA5 to check if CS voice charging principles also apply to voice over IMS / WI rapporteur e-mail: michele.zarri@telekom.com
- 2511: SP#54 completed / WI rapporteur e-mail: michele.zarri@telekom.com
- 2512: Stage 2/3. SP#57 completed / WI rapporteur e-mail: Gerald.Goermer@nsn.com
- 2513: CP#58 completed / WI rapporteur e-mail: reinhard.lauster@)t-mobile.at
- 2514: CP#58 completed / WI rapporteur e-mail: reinhard.lauster@)t-mobile.at
- 2515: CP#58 completed / WI rapporteur e-mail: reinhard.lauster@)t-mobile.at
- 2516: SP#57 Stage 2 completed. Moved Rel-12=>Rel-11 as CT finished Stage 3. Linked to UID_410041 Study on IMS Evolution (TR 23.812). Solutions from IETF SOC WG and existing 3GPP procedures to be re-used if possible & backward compatibility ensured / WI rapporteur e-mail: Antoine MOUQUET, YU Qing
- 2517: SP#57 completed. Moved Rel-12=>Rel-11 as CT finished Stage 3. / WI rapporteur e-mail: antoine.mouquet@orange-ftgroup.com, YU Qing
- 2518: - / WI rapporteur e-mail: Keith Drage
- 2519: CP#58 completed / WI rapporteur e-mail: Keith Drage
- 2520: CP#58 completed / WI rapporteur e-mail: Keith Drage
- 2521: in RFC Ed-queue. Dec.14: 75->100. Mar15: impacted spec updated (was draft-ietf-soc-overload-control). Jun 15: RFC 7339 (was draft-ietf-soc-overload-control) / WI rapporteur e-mail: Keith Drage
- 2522: Submitted to IESG for publication. Dec14: 50->90%. Mar15: 100%. Impacted RFC updated (was draft-ietf-soc-overload-rate-control). Jun 15: RFC 7415 (was draft-ietf-soc-overload-rate-control) / WI rapporteur e-mail: Keith Drage
- 2523: CP#64 completed / WI rapporteur e-mail: Keith Drage
- 2524: SEC11 is an umbrella Feature for Security related TEI11 type of changes that are not part of any other dedicated feature
- 2525: Stage 1/2/3. SP#56 completed / WI rapporteur e-mail: Koen Jaspers (k.b.jaspers@minjus.nl), terry.jacobson@alcatel-lucent.com

| ID | WBS | Task | Duration | Start | Finish | Complete | Baseline start | Baseline finish | Baseline duration | Constraint | Resources | Work | Actual work | Acronym | PCG approved | WI rapporteur name | Release | TSG approved | MCC resp | Acronym_3GU_Export | Status Report | Special Focus Doc |
| --- | --- | --- | --- | --- | --- | --- | --- | --- | --- | --- | --- | --- | --- | --- | --- | --- | --- | --- | --- | --- | --- | --- |
| 2526 | 588 | **ZUC EEA3 and EIA3 (new Encryption & Integrity EPS security Algorithms)** | 857d? | 2009-06-04 A | 2012-09-07 A | 100% | 2009-06-04 | 2012-09-07 | 857d? |  | S3; R5 | 19488h | 19488h | EEA3_EIA3 | PCG-23 | CATR | Rel-11 | SP-44 | Mirko | EEA3_EIA3 |  |  |
| 2527 | 588.1 | ZUC EEA3 and EIA3 | 663d? | 2009-06-04 A | 2011-12-14 A | 100% | 2009-06-04 | 2011-12-14 | 663d? | finish no earlier than 2011-09-21 | S3 | 5288h | 5288h | EEA3_EIA3 | PCG-23 | CATR | Rel-11 | SP-44 | Mirko |  |  |  |
| 2528 | 588.2 | Conformance Test Aspects – ZUC (EEA3 and EIA3 Encryption & Integrity EPS security Algorithms) | 61d? | 2012-06-18 A | 2012-09-07 A | 100% | 2012-06-18 | 2012-09-07 | 61d? | finish no earlier than 2013-03-01 | R5 | 488h | 488h | EEA3_EIA3_UEConTest | PCG-29 | CATR | Rel-11 | RP-56 | Ingbert | EEA3_EIA3_UEConTest | RP-120968 |  |
| 2529 | 589 | Specification of Protection against Unsolicited Communication for IMS (produced TR-only) | 456d? | 2010-06-10 A | 2012-03-07 A | 100% | 2010-06-10 | 2012-03-07 | 456d? | finish no earlier than 2012-03-07 | S3 | 3640h | 3640h | SPUCI | PCG-25 | NEC | Rel-11 | SP-48 | Mirko | SPUCI |  |  |
| 2530 | 590 | H(e)NB security features for UE mobility scenarios (Stage 2) | 252d? | 2011-03-23 A | 2012-03-07 A | 100% | 2011-03-23 | 2012-03-07 | 252d? | finish no earlier than 2012-03-07 | S3 | 2008h | 2008h | HNB_mob_Sec | PCG-26 | Huawei | Rel-11 | SP-51 | Mirko | HNB_mob_Sec |  | HNB |
| 2531 | 591 | **Generic Bootstrapping Architecture (GBA) extensions for re-use of SIP Digest credentials** | 203d? | 2011-12-02 A | 2012-09-07 A | 100% | 2011-12-02 | 2012-09-07 | 203d? |  | S3; C4; C1 | 11824h | 11824h | GBA-ext | PCG-28 | Nokia | Rel-11 | SP-54 | Mirko | GBA-ext |  |  |
| 2532 | 591.1 | Stage 2 for GBA extensions for re-use of SIP Digest credentials | 61d? | 2011-12-14 A | 2012-03-07 A | 100% | 2011-12-14 | 2012-03-07 | 61d? | finish no earlier than 2012-02-28 | S3 | 488h | 488h | GBA-ext | PCG-28 | Nokia | Rel-11 | SP-54 | Mirko |  |  |  |
| 2533 | 591.2 | **Stage 3 for GBA extensions for re-use of SIP Digest credentials** | 203d? | 2011-12-02 A | 2012-09-07 A | 100% | 2011-12-02 | 2012-09-07 | 203d? |  | C4; C1 | 6464h | 6464h | GBA-ext-St3 | PCG-28 | Alcatel-Lucent | Rel-11 | CP-54 | Kimmo | GBA-ext-St3 |  |  |
| 2534 | 591.2.1 | CT4 part of Stage 3 for GBA extensions for re-use of SIP Digest credentials | 203d? | 2011-12-02 A | 2012-09-07 A | 100% | 2011-12-02 | 2012-09-07 | 203d? | finish no earlier than 2012-09-07 | C4 | 1608h | 1608h | GBA-ext-St3 | PCG-28 | Alcatel-Lucent | Rel-11 | CP-54 | Kimmo |  |  |  |
| 2535 | 591.2.2 | CT1 part of Stage 3 for GBA extensions for re-use of SIP Digest credentials | 202d? | 2011-12-05 A | 2012-09-07 A | 100% | 2011-12-05 | 2012-09-07 | 202d? | finish no earlier than 2012-09-07 | C1 | 1608h | 1608h | GBA-ext-St3 | PCG-28 | Alcatel-Lucent | Rel-11 | CP-54 | Frederic |  |  |  |
| 2536 | 592 | Extensions of Acoustic Test Specifications in TS 26.131 and TS 26.132 | 332d? | 2011-06-08 A | 2012-09-12 A | 100% | 2011-06-08 | 2012-09-12 | 332d? | finish no earlier than 2012-09-12 | S4 | 2648h | 2648h | Ext_ATS | PCG-27 | Orange, Qualcomm | Rel-11 | SP-52 | Paolo | Ext_ATS |  |  |
| 2537 | 593 | **Enhancements to Multimedia: PSS, MMS, and MBMS Enhancements and Performance Improvements** | 397d? | 2011-09-07 A | 2013-03-06 A | 100% | 2011-09-07 | 2013-03-06 | 397d? |  | S4 | 10928.6h | 10928.6h | EMM | PCG-27 | Qualcomm | Rel-11 | SP-53 | Paolo | EMM |  |  |
| 2538 | 593.1 | Enhancement to FEC for MBMS | 386d? | 2011-09-21 A | 2013-03-06 A | 100% | 2011-09-21 | 2013-03-06 | 386d? | finish no earlier than 2013-03-06 | S4 | 3048h | 3048h | EMM-EFEC | PCG-27 | Qualcomm | Rel-11 | SP-53 | Paolo | EMM-EFEC |  |  |
| 2539 | 593.2 | Download Delivery Enhancements for MBMS | 325d? | 2011-09-21 A | 2012-12-12 A | 100% | 2011-09-21 | 2012-12-12 | 325d? | finish no earlier than 2012-12-12 | S4 | 2576.59h | 2576.59h | EMM-DDE | PCG-27 | Qualcomm | Rel-11 | SP-53 | Paolo | EMM-DDE |  |  |
| 2540 | 593.3 | IMS-based PSS and MBMS Streaming Synchronization Enhancements | 268d? | 2011-09-07 A | 2012-09-12 A | 100% | 2011-09-07 | 2012-09-12 | 268d? | finish no earlier than 2012-09-12 | S4 | 2128h | 2128h | EMM-IPME | PCG-27 | InterDigital Communications | Rel-11 | SP-53 | Paolo | EMM-IPME |  |  |
| 2541 | 594 | Mobile 3D Video Coding | 71d? | 2012-06-07 A | 2012-09-12 A | 100% | 2012-06-07 | 2012-09-12 | 71d? | finish no earlier than 2012-09-12 | S4 | 560h | 560h | M3DV | PCG-29 | Orange | Rel-11 | SP-56 | Paolo | M3DV |  |  |
| 2542 | 595 | **Rel-11 Operations, Administration, Maintenance and Provisioning (OAM&P)** | 519d? | 2011-03-23 A | 2013-03-07 A | 100% | 2011-03-23 | 2013-03-06 | 519d? |  | S5 | 39394.5h | 39394.5h | OAM11 | PCG-26 |  | Rel-11 | SP-51 | Mirko | OAM11 |  |  |
| 2543 | 595.1 | **Rel-11 Network Infrastructure Management** | 519d? | 2011-03-23 A | 2013-03-07 A | 100% | 2011-03-23 | 2013-03-06 | 519d? |  | S5 | 8256h | 8256h | OAM11-NIM | PCG-26 |  | Rel-11 | SP-51 | Mirko | OAM11-NIM |  |  |
| 2544 | 595.1.1 | IRP framework enhancements to support Management of Converged Networks | 515d? | 2011-03-23 A | 2013-03-07 A | 100% | 2011-03-23 | 2013-03-06 | 515d? | finish no earlier than 2013-03-06 | S5 | 4104h | 4104h | OAM-FMC-IRP | PCG-26 | Nokia Siemens Networks, Ericsson | Rel-11 | SP-51 | Mirko | OAM-FMC-IRP |  |  |
| 2545 | 595.2 | **Rel-11 Performance Management** | 458d? | 2011-03-23 A | 2012-12-12 A | 100% | 2011-03-23 | 2012-12-12 | 458d? |  | S5 | 14530.5h | 14530.5h | OAM11-PM | PCG-26 |  | Rel-11 | SP-51 | Mirko | OAM11-PM |  |  |
| 2546 | 595.2.1 | IMS Performance Management enhancements | 252d? | 2011-03-23 A | 2012-03-07 A | 100% | 2011-03-23 | 2012-03-07 | 252d? | finish no earlier than 2012-09-12 | S5 | 2010.52h | 2010.52h | OAM-ePM-IMS | PCG-26 | ZTE | Rel-11 | SP-51 | Mirko | OAM-ePM-IMS |  |  |
| 2547 | 595.2.2 | Enhanced Management of UE based network performance measurements | 455d? | 2011-03-23 A | 2012-12-12 A | 100% | 2011-03-23 | 2012-12-12 | 455d? | finish no earlier than 2012-12-12 | S5 | 3624h | 3624h | OAM-ePM-UE | PCG-26 | Huawei, Ericsson, Nokia Siemens Networks | Rel-11 | SP-51 | Mirko | OAM-ePM-UE |  |  |
| 2548 | 595.2.3 | CN performance measurements enhancement | 334d? | 2011-06-08 A | 2012-09-12 A | 100% | 2011-06-08 | 2012-09-12 | 334d? | finish no earlier than 2012-09-12 | S5 | 2648h | 2648h | OAM-ePM-CN | PCG-27 | China Mobile | Rel-11 | SP-52 | Mirko | OAM-ePM-CN |  |  |
| 2549 | 595.2.4 | Management of Carrier Aggregation for LTE | 325d? | 2011-09-21 A | 2012-12-12 A | 100% | 2011-09-21 | 2012-12-12 | 325d? | finish no earlier than 2012-12-12 | S5 | 2584h | 2584h | OAM-CA | PCG-27 | Nokia Siemens Networks, Ericsson | Rel-11 | SP-53 | Mirko | OAM-CA |  | CA |

Notes:
- 2526: RP#57 completed testing / WI rapporteur e-mail: Yuan Qi (yuanqi@catr.cn)
- 2527: SP#53 completed new EPS algorithms e.g. for China / Impacted TSs and TRs: 33.401, New (35.221, 35.222, 35.223, 35.924) / WI rapporteur e-mail: Yuan Qi (yuanqi@catr.cn)
- 2528: RP#57 completed. Testing for SA3 TSs 33.401, new (35.221, 35.222, 35.223) / Impacted TSs and TRs: 36.523-1, 36.523-2, 36.523-3 / WI rapporteur e-mail: Ms Jun Chen (chenjun@catr.cn)
- 2529: SP#55 completed (No normative work). TR 33.838v200 for Approval & abandoned new TS 33.237. Continuation of Rel-9 UID_410027/410029. Builds on TR 33.937 Study of Mechanisms for PUCI / Impacted TSs and TRs: New TR 33.838, abandoned New TS 33.237 / WI rapporteur e-mail: Anand R. Prasad (anand@bq.jp.nec.com)
- 2530: SP#55 completed. Add HeNB Security extensions to Extended H(e)NB Features (EHNBF) UID_450053 / Impacted TSs and TRs: 33.320 / WI rapporteur e-mail: Marcus Wong (mwong@huawei.com)
- 2531: Stage 2/3. CP#57 completed / WI rapporteur e-mail: Silke.Holtmanns@nokia.com
- 2532: SP#55 completed / Impacted TSs and TRs: 33.220 / WI rapporteur e-mail: Silke.Holtmanns@nokia.com
- 2533: CP#57 completed / Impacted TSs and TRs: Stage 3 / WI rapporteur e-mail: jean-jacques.trottin@alcatel-lucent.com
- 2534: CP#57 completed / Impacted TSs and TRs: 29.109 / WI rapporteur e-mail: jean-jacques.trottin@alcatel-lucent.com
- 2535: CP#57 completed / Impacted TSs and TRs: 24.109 / WI rapporteur e-mail: jean-jacques.trottin@alcatel-lucent.com
- 2536: SP#57 completed / Impacted TSs and TRs: 26.131, 26.132 / WI rapporteur e-mail: stephane.ragot@orange-ftgroup.com, Andre Schevciw (aschevci@qualcomm.com)
- 2537: Stage 3. SP#59 completed / Impacted TSs and TRs: 26.140, 26.234, 26.247, New TR 26.951=>26.851 / WI rapporteur e-mail: Nikolai Leung (nleung@qualcomm.com)
- 2538: SP#59 completed / Impacted TSs and TRs: 26.346, new TR 26.947 / WI rapporteur e-mail: Thomas Stockhammer (c_tstock@qualcomm.com)
- 2539: SP#58 completed / Impacted TSs and TRs: 26.346, new TR 26.951=>26.851 / WI rapporteur e-mail: Nikolai Leung (nleung@qualcomm.com)
- 2540: SP#58 completed / Impacted TSs and TRs: 26.237, new TR 26.951=>26.851 / WI rapporteur e-mail: hang.liu@interdigital.com
- 2541: SP#57 completed. Triggered by UID_520036 Rel-11 Study on Mobile 3D Video Coding (FS_M3DVC) TR 26.905. / Impacted TSs and TRs: 26.140, 26.234, 26.244, 26.245, 26.247, 26.346, 26.430, 26.905 / WI rapporteur e-mail: gilles.teniou@orange.com
- 2542: OAM11 is an umbrella Feature also for OAM&P related TEI11 type of changes that are not part of any other dedicated feature/WI
- 2543: -
- 2544: SP#59 completed. Triggered by SA5 Studies TR 32.833, 32.828, 32.831 / Impacted TSs and TRs: 32.101/103/150, new (28.620/621/622/623/624/625/626/627/628/629/631/632/633/651/652/653/654/655/656/657/658/659/661/662/663/671/672/673/674/675/676/701/702/703/704/705/706/707/708/709/731/732/733/734/735/736/751/752/753, 32.107/156/157/853/854 / WI rapporteur e-mail: thomas.tovinger@ericsson.com, olaf.pollakowski@nsn.com
- 2545: -
- 2546: SP#55 completed / Impacted TSs and TRs: 32.409 / WI rapporteur e-mail: guo.wenjie1@zte.com.cn
- 2547: SP#58 completed / Impacted TSs and TRs: 32.421, 32.422, 32.423, 32.441, 32.442, 32.446 / WI rapporteur e-mail: Zou Lan (zlan@huawei.com), ulf.hubinette@ericsson.com, gyula.bodog@nsn.com
- 2548: SP#57 completed / Impacted TSs and TRs: 32.406, 32.407, 32.426 / WI rapporteur e-mail: Liang Shuangchun (liangshuangchun@cmdi.chinamobile.com), Li Jian (lijian@chinamobile.com)
- 2549: SP#58 completed. Updated WID SP-110636=>SP-120776. Stage 2 in Rel-10 RAN Feature UID_460007 Carrier Aggregation for LTE (LTE_CA) / Impacted TSs and TRs: 32.425 / WI rapporteur e-mail: yizhi.yao@nsn.com, per.elmdahl@ericsson.com

| ID | WBS | Task | Type | Duration | Start | Finish | Complete | Baseline start | Baseline finish | Baseline duration | Constraint | Resources | Work | Actual work | Acronym | PCG approved | Release | TSG approved | MCC resp | Special Focus Doc | Acronym_3GU_Export | WI rapporteur name | WI rapporteur e-mail |
| --- | --- | --- | --- | --- | --- | --- | --- | --- | --- | --- | --- | --- | --- | --- | --- | --- | --- | --- | --- | --- | --- | --- | --- |
| 2550 | 595.3 | **Rel-11 Self-Organizing Networks (SON) - OAM aspects** |  | 519d? | 2011-03-23 A | 2013-03-06 A | 100% | 2011-03-23 | 2013-03-06 | 519d? |  | S5 | 12456h | 12456h | OAM11-SON | PCG-26 | Rel-11 | SP-51 | Mirko | SON | OAM11-SON |  |  |
| 2551 | 595.3.1 | UTRAN Self-Organizing Networks (SON) management |  | 388d? | 2011-03-23 A | 2012-09-12 A | 100% | 2011-03-23 | 2012-09-12 | 388d? | finish no earlier than 2012-09-12 | S5 | 3088h | 3088h | OAM-SON-UTRAN | PCG-26 | Rel-11 | SP-51 | Mirko | SON | OAM-SON-UTRAN | Huawei | kai.zhangkai@huawei.com |
| 2552 | 595.3.2 | LTE Self-Organizing Networks (SON) coordination management |  | 387d? | 2011-09-21 A | 2013-03-06 A | 100% | 2011-09-21 | 2013-03-06 | 387d? | finish no earlier than 2013-03-06 | S5 | 3072h | 3072h | OAM-SON-LTE_COORD | PCG-27 | Rel-11 | SP-53 | Mirko | SON | OAM-SON-LTE_COORD | Huawei, Nokia Siemens Networks | kai.zhangkai@huawei.com, clemens.suerbaum@nsn.com |
| 2553 | 595.3.3 | Inter-RAT Energy Saving Management |  | 269d? | 2011-12-07 A | 2012-12-12 A | 100% | 2011-12-07 | 2012-12-12 | 269d? | finish no earlier than 2012-12-12 | S5 | 2144h | 2144h | OAM-IRAT-ESM | PCG-28 | Rel-11 | SP-54 | Mirko | SON | OAM-IRAT-ESM | Nokia Siemens Networks, Huawei | clemens.suerbaum@nsn.com, xiahaitao@huawei.com |
| 2554 | 596 | **Rel-11 Charging Management small Enhancements** |  | 717d? | 2010-03-25 A | 2012-12-12 A | 100% | 2010-03-25 | 2012-12-12 | 717d? |  | S5 | 11528h | 11528h | CH11 | PCG-26 | Rel-11 | SP-51 | Mirko |  | CH11 |  |  |
| 2555 | 596.1 | Add solutions for Rc - reference point within the Online Charging System (OCS) |  | 392d? | 2010-03-25 A | 2011-09-21 A | 100% | 2010-03-25 | 2011-09-21 | 392d? | finish no earlier than 2011-08-26 | S5 | 3120h | 3120h | CH-Rc | PCG-24 | Rel-11 | SP-47 | Mirko |  | CH-Rc | Huawei | shan.mingjun@huawei.com |
| 2556 | 596.2 | Charging for Policy Enhancements for Sponsored Connectivity and Coherent Access to Policy related Data Bases |  | 135d? | 2011-03-21 A | 2011-09-21 A | 100% | 2011-03-21 | 2011-09-21 | 135d? | finish no earlier than 2011-09-21 | S5 | 1064h | 1064h | PEST-CH | PCG-26 | Rel-11 | SP-51 | Mirko |  | PEST-CH | Ericsson | patrik.teppo@@ericsson.com |
| 2557 | 596.3 | Unification of Charging session from SIP AS and SRVCC functions in IMS |  | 203d? | 2012-03-07 A | 2012-12-12 A | 100% | 2012-03-07 | 2012-12-12 | 203d? | finish no earlier than 2012-12-12 | S5 | 1608h | 1608h | UCHIMS_AS-SRVCC | PCG-28 | Rel-11 | SP-55 | Mirko |  | UCHIMS_AS-SRVCC | Alcatel-Lucent | maryse.gardella@alcatel-lucent.com |
| 2558 | 597 | **Transit Inter Operator Identifier for IMS Interconnection Charging in multi operator environment** |  | 432d? | 2010-10-27 A | 2012-06-15 A | 100% | 2010-10-27 | 2012-06-15 | 432d? |  | S5; S1; C1 | 15921.1h | 15921.1h | IOI_IMS_CH | PCG-26 | Rel-11 | SP-51 | Mirko |  | IOI_IMS_CH | Deutsche Telekom | matthias.seibel@telekom.de |
| 2559 | 597.1 | Stage 1 for Transit Inter Operator Identifier for IMS Interconnection Charging in multi operator environment |  | 237d? | 2010-10-27 A | 2011-09-21 A | 100% | 2010-10-27 | 2011-09-21 | 237d? |  | S1 | 1896h | 1896h | IOI_IMS_CH | PCG-26 | Rel-11 | SP-51 | Dionisio |  |  | Deutsche Telekom | matthias.seibel@telekom.de |
| 2560 | 597.2 | Stage 2/3 SA5 part of Transit Inter Operator Identifier for IMS Interconnection Charging in multi operator environment |  | 187d? | 2010-10-27 A | 2011-12-07 A | 100% | 2010-10-27 | 2011-12-07 | 187d? | finish no earlier than 2012-03-21 | S5 | 1488h | 1488h | IOI_IMS_CH | PCG-26 | Rel-11 | SP-51 | Mirko |  |  | Deutsche Telekom | matthias.seibel@telekom.de |
| 2561 | 597.3 | Stage 3 for Transit Inter Operator Identifier for IMS Interconnection Charging in multi operator environment |  | 273d? | 2011-06-07 A | 2012-06-15 A | 100% | 2011-06-07 | 2012-06-15 | 273d? | finish no earlier than 2012-06-01 | C1 | 2169.09h | 2169.09h | IOI_IMS_CH | PCG-27 | Rel-11 | CP-52 | Frederic |  |  | Deutsche Telekom | martin.huelsemann@telekom.de] |
| 2562 | 598 | **User Data Convergence - Data Model** |  | 647d? | 2010-03-25 A | 2012-09-07 A | 100% | 2010-03-25 | 2012-09-07 | 647d? |  | C4; S1 | 22984h | 22984h | UDC_DM | PCG-25 | Rel-11 | CP-48 | Kimmo |  | UDC_DM | Telecom Italia | mauro.ficaccio@telecomitalia.it |
| 2563 | 598.1 | Stage 1 for UDC Data Model |  | 392d? | 2010-03-25 A | 2011-09-21 A | 100% | 2010-03-25 | 2011-09-21 | 392d? | finish no earlier than 2010-06-10 | S1 | 3136h | 3136h | UDC_DM | PCG-25 | Rel-11 | CP-48 | Alain |  |  | Telecom Italia | mauro.ficaccio@telecomitalia.it |
| 2564 | 598.2 | TR on User Data Convergence (UDC) Data Model |  | 593d? | 2010-06-04 A | 2012-09-07 A | 100% | 2010-06-04 | 2012-09-07 | 593d? | finish no earlier than 2012-09-07 | C4 | 4736h | 4736h | UDC_DM | PCG-25 | Rel-11 | CP-48 | Kimmo |  |  | Telecom Italia | mauro.ficaccio@telecomitalia.it |
| 2565 | 598.3 | User Data Convergence (UDC) Data Model |  | 596d? | 2010-06-04 A | 2012-09-07 A | 100% | 2010-06-04 | 2012-09-07 | 596d? | finish no earlier than 2012-09-07 | C4 | 4760h | 4760h | UDC_DM | PCG-25 | Rel-11 | CP-48 | Kimmo |  |  | Telecom Italia | mauro.ficaccio@telecomitalia.it |
| 2566 | 599 | Definition of the UICC Application for Hosting Party Module |  | 327d? | 2011-03-18 A | 2012-06-15 A | 100% | 2011-03-18 | 2012-06-15 | 327d? | finish no earlier than 2012-06-15 | C6 | 2608h | 2608h | HPM_UICC | PCG-26 | Rel-11 | CP-51 | Xavier |  | HPM_UICC | Gemalto | Denis.Lheriteau@gemalto.com |
| 2567 | 600 | Usability improvement of Inter-IMS Network to Network Interface (II-NNI) specification for inter-connection by means of Option Item list |  | 273d? | 2011-06-07 A | 2012-06-15 A | 100% | 2011-06-07 | 2012-06-15 | 273d? | finish no earlier than 2012-06-01 | C3 | 2169.56h | 2169.56h | NNI_OI | PCG-27 | Rel-11 | CP-52 | Adrian |  | NNI_OI | NTT | arai.kenjiro@lab.ntt.co.jp |
| 2568 | 601 | **enhanced Nodes Restoration for EPC (Stage 2/3)** |  | 668d? | 2011-06-03 A | 2013-12-06 A | 100% | 2011-06-03 | 2013-12-06 | 668d? |  | C4; C1; C3; IETF | 27728h | 27728h | eNR_EPC | PCG-27 | Rel-11 | CP-52 | Kimmo |  | eNR_EPC | ZTE | lu.fei1@zte.com.cn |
| 2569 | 601.1 | CT4 part of enhanced Nodes Restoration for EPC |  | 402d? | 2011-06-03 A | 2012-12-07 A | 100% | 2011-06-03 | 2012-12-07 | 402d? | finish no earlier than 2012-12-07 | C4 | 3192h | 3192h | eNR_EPC | PCG-27 | Rel-11 | CP-52 | Kimmo |  |  | ZTE | lu.fei1@zte.com.cn |
| 2570 | 601.2 | (IETF) CT4 part of enhanced Nodes Restoration for EPC (RFC 7077) |  | 266d? | 2012-12-07 A | 2013-12-06 A | 100% | 2012-12-07 | 2013-12-06 | 266d? | finish no earlier than 2013-12-06 | C4-IETF | 2104h | 2104h | eNR_EPC | PCG-30 | Rel-11 | CP-58 | Kimmo |  |  | Lionel Morand | Lionel Morand |
| 2571 | 601.3 | CT1 part of enhanced Nodes Restoration for EPC |  | 66d? | 2011-12-02 A | 2012-03-02 A | 100% | 2011-12-02 | 2012-03-02 | 66d? | finish no earlier than 2012-06-15 | C1 | 528h | 528h | eNR_EPC | PCG-28 | Rel-11 | CP-54 | Frederic |  |  | ZTE | lu.fei1@zte.com.cn |
| 2572 | 601.4 | CT3 part of enhanced Nodes Restoration for EPC |  | 67d? | 2012-09-10 A | 2012-12-07 A | 100% | 2012-09-10 | 2012-12-07 | 67d? | finish no earlier than 2012-12-07 | C3 | 528h | 528h | eNR_EPC | PCG-29 | Rel-11 | CP-57 | Adrian |  |  | ZTE | lu.fei1@zte.com.cn |
| 2573 | 602 | **Reference Location Information (Stage 3)** |  | 78d? | 2011-06-03 A | 2011-09-16 A | 100% | 2011-06-03 | 2011-09-16 | 78d? |  | C4; C1 | 1860.74h | 1860.74h | RLI | PCG-27 | Rel-11 | CP-52 | Kimmo |  | RLI | Huawei | susan.shishufeng@Huawei.com |
| 2574 | 602.1 | CT4 part of Reference Location Information (Stage 3) | milestone | 0d? | 2011-06-03 A | 2011-06-03 A | 100% | 2011-06-03 | 2011-06-03 | 0d? | finish no earlier than 2011-06-03 | C4 |  |  | RLI | PCG-27 | Rel-11 | CP-52 | Kimmo |  |  | Huawei | susan.shishufeng@Huawei.com |
| 2575 | 602.2 | CT1 part of Reference Location Information (Stage 3) |  | 78d? | 2011-06-03 A | 2011-09-16 A | 100% | 2011-06-03 | 2011-09-16 | 78d? | finish no earlier than 2011-08-30 | C1 | 612.74h | 612.74h | RLI | PCG-27 | Rel-11 | CP-52 | Frederic |  |  | Huawei | susan.shishufeng@Huawei.com |

Notes:
- 2550: -
- 2551: SP#57 completed. Updated WID SP-110518=>SP-120552 / Impacted TSs and TRs: UTRA 32.405, 32.500, 32.511, 32.521, 32.522, 32.526, 32.642, 32.646
- 2552: SP#59 completed / Impacted TSs and TRs: LTE 32.425, 32.500, 32.521, 32.522, 32.526, 32.762, 32.766
- 2553: SP#58 completed. Triggered by Rel-11 TR 32.834 (Study on OAM aspects of inter-RAT Energy Saving) UID_510045. Needs coordination with RAN WGs / Impacted TSs and TRs: 32.405, 32.551, 32.522, 32.526, 32.642, 32.646, 32.762, 32.766
- 2554: CH11 is an umbrella Feature also for OAM&P related TEI11 type of changes that are not part of any other dedicated feature/WI / Impacted TSs and TRs: TR 30.821
- 2555: SP#53 completed. Stage 3 (Stage 1 in 22.115). Triggered by Rel-10 TR 32.825 SA5 Study on Rc Reference Point Functionalities and Message Flows (UID_410044) / Impacted TSs and TRs: 32.296, 32.299
- 2556: SP#53 completed. Stage 3 / Impacted TSs and TRs: 32.251, 32.298, 32.299
- 2557: Stage 2/3. SP#58 completed / Impacted TSs and TRs: 32.260, 32.275, 32.298, 32.299
- 2558: Stage 2/3. CP#56 completed. Stage 1 in SA1 22.115
- 2559: SP#53 completed under IPXS / Impacted TSs and TRs: 22.115
- 2560: SP#54 completed / Impacted TSs and TRs: 32.240, 32.260, 32.298, 32.299
- 2561: CP#56 completed / Impacted TSs and TRs: 24.229
- 2562: CP#57 completed. SP#48 Stage 1 completed as Rel-10
- 2563: SP#53 completed under Rel-10 UDC / Impacted TSs and TRs: 22.101
- 2564: CP#57 completed / Impacted TSs and TRs: new TR 29.935
- 2565: CP#57 completed / Impacted TSs and TRs: 29.335
- 2566: CP#56 completed / Impacted TSs and TRs: 31.102, New TS 31.104
- 2567: CP#56 completed. Stage 3 (No architectural change, specify the list of selectable items related to control plane signalling directly for the same architecture) / Impacted TSs and TRs: 29.165
- 2568: Triggered by DRAFT TR 23.857 Study on EPC Nodes Restoration UID_490014
- 2569: CP#58 completed / Impacted TSs and TRs: 23.007, 23.008, 23.018, 29.274, 29.275
- 2570: CP#62 completed / Impacted TSs and TRs: RFC 7077 (was draft-ietf-netext-update-notifications)
- 2571: CP#55 completed / Impacted TSs and TRs: 29.118
- 2572: CP#58 completed / Impacted TSs and TRs: 29.212
- 2573: CP#53 completed. Stage 2 clause C.1.1 of SA2 TS 23.167 CR#0182 (WI code: TEI11)
- 2574: CP#52 completed / Impacted TSs and TRs: 23.008, 29.228, 29.328, 29.329
- 2575: CP#53 completed / Impacted TSs and TRs: 24.229

| ID | WBS | Task | Duration | Start | Finish | Complete | Baseline start | Baseline finish | Baseline duration | Constraint | Resources | Work | Actual work | Acronym | PCG approved | WI rapporteur name | WI rapporteur e-mail | Release | TSG approved | MCC resp | Acronym_3GU_Export | PCG stopped | TSG stopped | Special Focus Doc |
| --- | --- | --- | --- | --- | --- | --- | --- | --- | --- | --- | --- | --- | --- | --- | --- | --- | --- | --- | --- | --- | --- | --- | --- | --- |
| 2576 | 603 | **IMS Stage 3 IETF Protocol Alignment - phase 5** | 868d? | 2011-06-07 A | 2014-09-12 A | 100% | 2011-06-07 | 2014-12-05 | 927d? |  | C1; C3; IETF | 34260h | 34260h | IMSProtoc5 | PCG-27 | Alcatel-Lucent | keith.drage@alcatel-lucent.com | Rel-11 | CP-52 | Frederic | IMSProtoc5 |  |  |  |
| 2577 | 603.1 | CT1 part of IMS Stage 3 IETF Protocol Alignment - phase 5 | 333d? | 2011-06-07 A | 2012-09-07 A | 100% | 2011-06-07 | 2012-09-07 | 333d? | finish no earlier than 2012-09-07 | C1 | 2648h | 2648h | IMSProtoc5 | PCG-27 | Alcatel-Lucent | keith.drage@alcatel-lucent.com | Rel-11 | CP-52 | Frederic |  |  |  |  |
| 2578 | 603.2 | (IETF) CT1 part of IMS Stage 3 IETF Protocol Alignment - phase 5 (RFC 7315) | 356.5d? | 2013-03-01 A | 2014-09-12 A | 100% | 2013-03-01 | 2014-12-05 | 416.5d? | finish no earlier than 2014-09-12 | C1-IETF | 2812h | 2812h | IMSProtoc5 | PCG-30 | Roland Jesske | Roland Jesske | Rel-11 | CP-59 | Frederic |  |  |  |  |
| 2579 | 603.3 | (IETF) CT1 part of IMS Stage 3 IETF Protocol Alignment - phase 5 (RFC 7135) | 203d? | 2013-09-06 A | 2014-06-13 A | 100% | 2013-09-06 | 2014-06-13 | 203d? | finish no earlier than 2014-06-13 | C1-IETF | 1608h | 1608h | IMSProtoc5 | PCG-31 | Roland Jesske | Roland Jesske | Rel-11 | CP-61 |  |  |  |  |  |
| 2580 | 603.4 | CT3 part of IMS Stage 3 IETF Protocol Alignment - phase 5 | 333d? | 2011-06-07 A | 2012-09-07 A | 100% | 2011-06-07 | 2012-09-07 | 333d? | finish no earlier than 2012-09-07 | C3 | 2648h | 2648h | IMSProtoc5 | PCG-27 | Alcatel-Lucent | keith.drage@alcatel-lucent.com | Rel-11 | CP-52 | Adrian |  |  |  |  |
| 2581 | 603.5 | Deleted - (IETF) CT3 part of IMS Stage 3 IETF Protocol Alignment - phase 5 (avasarala-dispatch-comm-div-notification) | 466d? | 2012-12-07 A | 2014-09-12 A | 100% | 2012-12-07 | 2014-12-05 | 526d? | finish no earlier than 2014-09-12 | C3-IETF | 3712h | 3712h | IMSProtoc5 | PCG-30 | Andrew Allen | Andrew Allen | Rel-11 | CP-58 | Adrian |  | PCG-33 | CP-65 |  |
| 2582 | 604 | **Service Identification for RRC Improvements in GERAN (Stage 2/3)** | 258d? | 2011-09-19 A | 2012-09-07 A | 100% | 2011-09-19 | 2012-09-07 | 258d? |  | S2; C4; C3; G2 | 16216h | 16216h | SIRIG | PCG-27 | China Mobile | zhanghao@chinamobile.com | Rel-11 | GP-51 | Maurice | SIRIG |  |  |  |
| 2583 | 604.1 | Stage 2 for Service Identification for RRC Improvements in GERAN | 61d? | 2012-06-18 A | 2012-09-07 A | 100% | 2012-06-18 | 2012-09-07 | 61d? | finish no earlier than 2012-09-07 | S2 | 480h | 480h | SIRIG | PCG-29 |  |  | Rel-11 | SP-56 | Maurice |  |  |  |  |
| 2584 | 604.2 | **CN aspects of Service Identification for RRC Improvements in GERAN** | 203d? | 2011-12-02 A | 2012-09-07 A | 100% | 2011-12-02 | 2012-09-07 | 203d? |  | C4; C3 | 5464h | 5464h | SIRIG | PCG-28 | China Mobile | zhanghao@chinamobile.com | Rel-11 | CP-54 | Kimmo |  |  |  |  |
| 2585 | 604.2.1 | CT4 part of CN aspects of Service Identification for RRC Improvements in GERAN | 203d? | 2011-12-02 A | 2012-09-07 A | 100% | 2011-12-02 | 2012-09-07 | 203d? | finish no earlier than 2012-09-07 | C4 | 1608h | 1608h | SIRIG | PCG-28 | China Mobile | zhanghao@chinamobile.com | Rel-11 | CP-54 | Kimmo |  |  |  |  |
| 2586 | 604.2.2 | Deleted - CT3 part of CN aspects of Service Identification for RRC Improvements in GERAN | 77d? | 2012-03-02 A | 2012-06-15 A | 100% | 2012-03-02 | 2012-06-15 | 77d? | finish no earlier than 2012-06-01 | C3 | 608h | 608h | SIRIG | PCG-28 | China Mobile | zhanghao@chinamobile.com | Rel-11 | CP-55 | Adrian |  | PCG-29 | CP-56 |  |
| 2587 | 604.3 | GERAN2 part of Service Identification for RRC Improvements in GERAN | 252d? | 2011-09-19 A | 2012-08-31 A | 100% | 2011-09-19 | 2012-08-31 | 252d? | finish no earlier than 2012-08-31 | G2 | 2016h | 2016h | SIRIG | PCG-27 | China Mobile, Huawei | Juan Deng, Yang Zhao | Rel-11 | GP-51 | Gert |  |  |  |  |
| 2588 | 605 | **SAE Protocol Development - Phase 2** | 259d? | 2011-09-16 A | 2012-09-07 A | 100% | 2011-09-16 | 2012-09-07 | 259d? |  | C1 | 6168h | 6168h | SAES2 | PCG-27 | Nokia Siemens Networks | robert.zaus@nsn.com | Rel-11 | CP-53 | Frederic | SAES2 |  |  |  |
| 2589 | 605.1 | SAE Protocol Development (Stage 3) - Phase 2 | 259d? | 2011-09-16 A | 2012-09-07 A | 100% | 2011-09-16 | 2012-09-07 | 259d? | finish no earlier than 2012-09-07 | C1 | 2048h | 2048h | SAES2 | PCG-27 | Nokia Siemens Networks | robert.zaus@nsn.com | Rel-11 | CP-53 | Frederic |  |  |  |  |
| 2590 | 605.2 | CS Fallback in EPS - Phase 2 | 259d? | 2011-09-16 A | 2012-09-07 A | 100% | 2011-09-16 | 2012-09-07 | 259d? | finish no earlier than 2012-09-07 | C1 | 2048h | 2048h | SAES2-CSFB | PCG-27 | Nokia Siemens Networks | robert.zaus@nsn.com | Rel-11 | CP-53 | Frederic | SAES2-CSFB |  |  |  |
| 2591 | 606 | **GCSMSC and GCR Redundancy for VGCS/VBS (Stage 2/3)** | 258d? | 2011-09-19 A | 2012-09-07 A | 100% | 2011-09-19 | 2012-09-07 | 258d? |  | C1 | 5680h | 5680h | RT_VGCS_Red | PCG-27 | Nokia Siemens Networks | robert.zaus@nsn.com | Rel-11 | CP-53 | Frederic | RT_VGCS_Red |  |  |  |
| 2592 | 606.1 | CT1 part of GCSMSC and GCR Redundancy for VGCS/VBS | 258d? | 2011-09-19 A | 2012-09-07 A | 100% | 2011-09-19 | 2012-09-07 | 258d? | finish no earlier than 2012-09-07 | C1 | 2048h | 2048h | RT_VGCS_Red | PCG-27 | Nokia Siemens Networks | robert.zaus@nsn.com | Rel-11 | CP-53 | Frederic |  |  |  |  |
| 2593 | 606.2 | Deleted - CT4 part of GCSMSC and GCR Redundancy for VGCS/VBS | 197d? | 2011-09-19 A | 2012-06-15 A | 100% | 2011-09-19 | 2012-06-15 | 197d? | finish no earlier than 2012-06-15 | C4 | 1568h | 1568h | RT_VGCS_Red | PCG-27 | Nokia Siemens Networks | robert.zaus@nsn.com | Rel-11 | CP-53 | Kimmo |  | PCG-29 | CP-56 |  |
| 2594 | 607 | Support of RFC 6140 in IMS | 203d? | 2011-12-02 A | 2012-09-07 A | 100% | 2011-12-02 | 2012-09-07 | 203d? | finish no earlier than 2012-09-07 | C1 | 1608h | 1608h | GINI | PCG-28 | Deutsche Telekom | martin.huelsemann@telekom.de | Rel-11 | CP-54 | Frederic | GINI |  |  |  |
| 2595 | 608 | **Enhancements for Multimedia Priority Service (MPS) – Gateway Control Priority** | 203d? | 2011-12-02 A | 2012-09-07 A | 100% | 2011-12-02 | 2012-09-07 | 203d? |  | C4; C3 | 6464h | 6464h | eMPS_Gateway | PCG-28 | Telcordia | Viqar Shaikh | Rel-11 | CP-54 | Kimmo | eMPS_Gateway |  |  | Public Safety (I-A) |
| 2596 | 608.1 | CT4 part of Enhancements for Multimedia Priority Service (MPS) – Gateway Control Priority | 202d? | 2011-12-02 A | 2012-09-07 A | 100% | 2011-12-02 | 2012-09-07 | 202d? | finish no earlier than 2012-09-07 | C4 | 1608h | 1608h | eMPS_Gateway | PCG-28 | Telcordia | Viqar Shaikh | Rel-11 | CP-54 | Kimmo |  |  |  | Public Safety (I-A) |
| 2597 | 608.2 | CT3 part of Enhancements for Multimedia Priority Service (MPS) – Gateway Control Priority | 202d? | 2011-12-02 A | 2012-09-07 A | 100% | 2011-12-02 | 2012-09-07 | 202d? | finish no earlier than 2012-09-07 | C3 | 1608h | 1608h | eMPS_Gateway | PCG-28 | Telcordia | Viqar Shaikh | Rel-11 | CP-54 | Adrian |  |  |  | Public Safety (I-A) |
| 2598 | 609 | Inter-IMS Network to Network Interface (II-NNI) enhancements: SIP timers applicability (Stage 3) | 138d? | 2012-03-02 A | 2012-09-07 A | 100% | 2012-03-02 | 2012-09-07 | 138d? | start no earlier than 2012-03-02 | C3 | 1088h | 1088h | NNI_timers | PCG-28 | Telecom Italia | antonio.ascolese@telecomitalia.it | Rel-11 | CP-55 | Adrian | NNI_timers |  |  |  |
| 2599 | 610 | AT commands for Universal Resource Identifier (URI) support | 188d? | 2012-06-15 A | 2013-03-01 A | 100% | 2012-06-15 | 2013-03-01 | 188d? | finish no earlier than 2013-03-01 | C1 | 1496h | 1496h | ATURI | PCG-29 | Intel | frank.kowalewski@intel.com | Rel-11 | CP-56 | Frederic | ATURI |  |  |  |
| 2600 | 611 | PS Additional Number (Stage 3) | 62d? | 2012-06-15 A | 2012-09-07 A | 100% | 2012-06-15 | 2012-09-07 | 62d? | finish no earlier than 2012-09-07 | C4 | 488h | 488h | PSAN | PCG-29 | Deutsche Telekom | Yvette.koza@t-mobile.at | Rel-11 | CP-56 | Kimmo | PSAN |  |  |  |
| 2601 | 612 | Generic IMS User Group Over Sh | 62d? | 2012-06-15 A | 2012-09-07 A | 100% | 2012-06-15 | 2012-09-07 | 62d? | finish no earlier than 2012-09-07 | C4 | 488h | 488h | GenUG_Sh | PCG-29 | Alcatel-Lucent | jean-jacques.trottin@alcatel-lucent.com | Rel-11 | CP-56 | Kimmo | GenUG_Sh |  |  |  |

Notes:
- 2576: CP#57 completed
- 2577: CP#57 completed / Impacted TSs and TRs: 23.218, 24.229, 24.930
- 2578: CP#65 completed / Impacted TSs and TRs: RFC 7315 (was draft-drage-sipping-rfc3455bis), draft-mohali-dispatch-originating-cdiv-parameter
- 2579: CP#64 completed / Impacted TSs and TRs: RFC 7135 (was draft-polk-local-emergency-rph-namespace)
- 2580: CP#57 completed / Impacted TSs and TRs: 29.163, 29.165
- 2581: CP#64 Draft removed from 3GPP documentation / Impacted TSs and TRs: draft-avasarala-dispatch-comm-div-notification
- 2582: TSG#57, GP#55 completed. CT defined a generic solution (not only for GERAN) / Impacted TSs and TRs: GERAN
- 2583: SP#57 completed / Impacted TSs and TRs: 23.060, 23.251
- 2584: CP#57 completed
- 2585: CP#57 completed / Impacted TSs and TRs: 29.281
- 2586: CP#56 stopped (SA2 decided NO CT3 impact) / Impacted TSs and TRs: 29.212
- 2587: GP#55 completed. GP#51 approved WID / Impacted TSs and TRs: 48.018
- 2588: CP#57 completed. Stage 3 continuation of Rel-8 Feature SAES (3GPP System Architecture Evolution Specification - Evolved Packet System) UID_320005
- 2589: CP#57 completed / Impacted TSs and TRs: 23.122, 24.008, 24.167, 24.229, 24.301, 24.302, 24.303, 24.304, 24.305, 24.312, 29.018, 29.118
- 2590: CP#57 completed / Impacted TSs and TRs: 23.122, 24.008, 24.167, 24.229, 24.301, 24.302, 24.303, 24.304, 24.305, 24.312, 29.018, 29.118
- 2591: CP#57 completed. Stage 2/3 adding a CN internal functionality, not affecting Voice Group Call Service (VGCS)/VBS as perceived by service subscriber. Hence, no Stage 1 impact for VGCS/VBS (42.068, 42.069) / Impacted TSs and TRs: Stage 2/3
- 2592: CP#57 completed / Impacted TSs and TRs: 43.068, 43.069
- 2593: CP#56 stopped (no CT4 impact) / Impacted TSs and TRs: 29.002
- 2594: CP#57 completed. Stage 3. Support procedures and protocol extensions in RFC6140 "Registration for Multiple Phone Numbers in SIP" to IMS for complex UEs. Ensure co-existence with NGCN IP-PBX registration procedures already defined in IMS. / Impacted TSs and TRs: 24.229
- 2595: CP#57 completed. Stage 3. Stage 1 for MPS in 22.153. Details of any MGW actions for priority needs to be further studied within the scope of this WI. / Impacted TSs and TRs: Stage 3
- 2596: CP#57 completed / Impacted TSs and TRs: 23.333, 23.334, 29.232, 29.238, 29.332, 29.333, 29.334
- 2597: CP#57 completed / Impacted TSs and TRs: 29.162, 29.163, 29.292
- 2598: CP#57 completed / Impacted TSs and TRs: 29.165
- 2599: CP#59 completed. Define new AT cmd for URI addresses for IMS services (eg VoLTE). 27.007(AT cmd to control MT functions and GSM/UMTS/LTE network services from TE), 27.005(AT commands for SMS). Currently address types for AT cmd based on dialling# / Impacted TSs and TRs: 27.005, 27.007
- 2600: CP#57 completed. Stage 1 in Rel-11 SA1 TS 22.101 clause 17.7.3 (No Stage 2 needed since no architecture impact) / Impacted TSs and TRs: 23.003, 23.008, 29.002, 29.272, 29.230
- 2601: CP#57 completed / Impacted TSs and TRs: 29.364

| ID | WBS | Task | Duration | Start | Finish | Complete | Baseline start | Baseline finish | Baseline duration | Constraint | Resources | Work | Actual work | Acronym | PCG approved | WI rapporteur name | WI rapporteur e-mail | Release | TSG approved | MCC resp | Acronym_3GU_Export | PCG stopped | TSG stopped | Status Report |
| --- | --- | --- | --- | --- | --- | --- | --- | --- | --- | --- | --- | --- | --- | --- | --- | --- | --- | --- | --- | --- | --- | --- | --- | --- |
| 2602 | 613 | **IMS Operator Determined Call Barring** | 205d? | 2012-09-07 A | 2013-06-14 A | 100% | 2012-09-07 | 2013-06-14 | 205d? |  | C1; C4 | 5411.54h | 5411.54h | IODB | PCG-29 | Orange | Youssef.Chadli@Orange.com | Rel-11 | CP-57 | Frederic | IODB |  |  |  |
| 2603 | 613.1 | CT1 part of IMS Operator Determined Call Barring | 203d? | 2012-09-10 A | 2013-06-14 A | 100% | 2012-09-10 | 2013-06-14 | 203d? | finish no earlier than 2013-06-14 | C1 | 1616h | 1616h | IODB | PCG-29 | Orange | Youssef.Chadli@Orange.com | Rel-11 | CP-57 | Frederic |  |  |  |  |
| 2604 | 613.2 | CT4 part of IMS Operator Determined Call Barring | 69d? | 2012-09-07 A | 2013-03-12 A | 100% | 2012-09-07 | 2013-03-12 | 69d? | finish no earlier than 2012-12-07 | C4 | 515.54h | 515.54h | IODB | PCG-29 | Orange | Youssef.Chadli@Orange.com | Rel-11 | CP-57 | Kimmo |  |  |  |  |
| 2605 | 614 | **Enhanced T.38 FAX support (Stage 3)** | 69d? | 2012-09-06 A | 2012-12-07 A | 100% | 2012-09-06 | 2012-12-07 | 69d? |  | C3; C1; C4 | 2728h | 2728h | MMTel_T.38_FAX | PCG-29 | NEC | Naoaki Suzuki (n-suzuki@en.jp.nec.com) | Rel-11 | CP-57 | Adrian | MMTel_T.38_FAX |  |  |  |
| 2606 | 614.1 | CT3 part of Enhanced T.38 FAX support | 68d? | 2012-09-07 A | 2012-12-07 A | 100% | 2012-09-07 | 2012-12-07 | 68d? | finish no earlier than 2012-12-07 | C3 | 528h | 528h | MMTel_T.38_FAX | PCG-29 | NEC | Naoaki Suzuki (n-suzuki@en.jp.nec.com) | Rel-11 | CP-57 | Adrian |  |  |  |  |
| 2607 | 614.2 | CT1 part of Enhanced T.38 FAX support | 67d? | 2012-09-07 A | 2012-12-07 A | 100% | 2012-09-07 | 2012-12-07 | 67d? | finish no earlier than 2012-12-07 | C1 | 528h | 528h | MMTel_T.38_FAX | PCG-29 | NEC | Naoaki Suzuki (n-suzuki@en.jp.nec.com) | Rel-11 | CP-57 | Frederic |  |  |  |  |
| 2608 | 614.3 | CT4 part of Enhanced T.38 FAX support | 2d? | 2012-09-06 A | 2012-09-07 A | 100% | 2012-09-06 | 2012-09-07 | 2d? | finish no earlier than 2012-12-07 | C4 | 16h | 16h | MMTel_T.38_FAX | PCG-29 | NEC | Naoaki Suzuki (n-suzuki@en.jp.nec.com) | Rel-11 | CP-57 | Kimmo |  |  |  |  |
| 2609 | 615 | **Deleted - Enhancement of the Protocols for SMS over SGs (Stage 3)** | 142d? | 2011-12-02 A | 2012-06-15 A | 100% | 2011-12-02 | 2012-06-15 | 142d? |  | C4; C1 | 5664h | 5664h | PROTOC_SMS_SGs | PCG-28 | Alcatel-Lucent | jean-jacques.trottin@alcatel-lucent.com | Rel-11 | CP-54 | Kimmo | PROTOC_SMS_SGs | PCG-29 | CP-56 |  |
| 2610 | 615.1 | Deleted - TR Study on enhancement of protocols for SMS service over SGs | 142d? | 2011-12-02 A | 2012-06-15 A | 100% | 2011-12-02 | 2012-06-15 | 142d? | finish no earlier than 2012-06-15 | C4 | 1128h | 1128h | PROTOC_SMS_SGs | PCG-28 | Alcatel-Lucent | jean-jacques.trottin@alcatel-lucent.com | Rel-11 | CP-54 | Kimmo |  | PCG-29 | CP-56 |  |
| 2611 | 615.2 | Deleted - CT4 part of Enhancement of the Protocols for SMS over SGs | 142d? | 2011-12-02 A | 2012-06-15 A | 100% | 2011-12-02 | 2012-06-15 | 142d? | finish no earlier than 2012-06-15 | C4 | 1128h | 1128h | PROTOC_SMS_SGs | PCG-28 | Alcatel-Lucent | jean-jacques.trottin@alcatel-lucent.com | Rel-11 | CP-54 | Kimmo |  | PCG-29 | CP-56 |  |
| 2612 | 615.3 | Deleted - CT1 part of Enhancement of the Protocols for SMS over SGs | 142d? | 2011-12-02 A | 2012-06-15 A | 100% | 2011-12-02 | 2012-06-15 | 142d? | finish no earlier than 2012-06-15 | C1 | 1136h | 1136h | PROTOC_SMS_SGs | PCG-28 | Alcatel-Lucent | jean-jacques.trottin@alcatel-lucent.com | Rel-11 | CP-54 | Frederic |  | PCG-29 | CP-56 |  |
| 2613 | 616 | **Full Support of Multi-Operator Core Network by GERAN** | 584d? | 2011-03-04 A | 2013-05-17 A | 100% | 2011-03-04 | 2013-05-17 | 584d? |  | G2; S2; C1 | 31293.3h | 31293.3h | Full_MOCN-GERAN | PCG-26 | Alcatel-Lucent | michel.robert@alcatel-lucent.com | Rel-11 | GP-49 | Paolo | Full_MOCN-GERAN |  |  |  |
| 2614 | 616.1 | GERAN part of Full Support of Multi-Operator Core Network by GERAN | 584d? | 2011-03-04 A | 2013-05-17 A | 100% | 2011-03-04 | 2013-05-17 | 584d? | finish no earlier than 2013-06-07 | G2 | 4656.4h | 4656.4h | Full_MOCN-GERAN | PCG-26 | Alcatel-Lucent | michel.robert@alcatel-lucent.com | Rel-11 | GP-49 | Gert |  |  |  |  |
| 2615 | 616.2 | Stage 2 for Full Support of Multi-Operator Core Network by GERAN | 160.8d? | 2011-06-08 A | 2012-03-07 A | 100% | 2011-06-08 | 2012-03-07 | 160.8d? | finish no earlier than 2012-03-07 | S2 | 1278.4h | 1278.4h | Full_MOCN-GERAN | PCG-26 | Alcatel-Lucent | nicolas.drevon@alcatel-lucent.com | Rel-11 | GP-49 | Maurice |  |  |  |  |
| 2616 | 616.3 | **CN Stage 3 for Full Support of Multi-Operator Core Network by GERAN** | 403d? | 2011-06-03 A | 2012-12-07 A | 100% | 2011-06-03 | 2012-12-07 | 403d? |  | C1; C4 | 9838.51h | 9838.51h | Full_MOCN-GERAN | PCG-26 | Alcatel-Lucent | jennifer.liu@alcatel-lucent.com | Rel-11 | GP-49 | Frederic |  |  |  |  |
| 2617 | 616.3.1 | CT1 part of CN Stage 3 for Full Support of Multi-Operator Core Network by GERAN | 362.8d? | 2011-06-03 A | 2012-12-07 A | 100% | 2011-06-03 | 2012-12-07 | 362.8d? | finish no earlier than 2012-12-07 | C1 | 2886.51h | 2886.51h | Full_MOCN-GERAN | PCG-26 | Alcatel-Lucent | jennifer.liu@alcatel-lucent.com | Rel-11 | GP-49 | Frederic |  |  |  |  |
| 2618 | 616.3.2 | CT4 part of CN Stage 3 for Full Support of Multi-Operator Core Network by GERAN | 64d? | 2012-06-13 A | 2012-09-07 A | 100% | 2012-06-13 | 2012-09-07 | 64d? | finish no earlier than 2012-09-07 | C4 | 504h | 504h | Full_MOCN-GERAN | PCG-29 | Alcatel-Lucent | michel.robert@alcatel-lucent.com | Rel-11 | GP-54 | Kimmo |  |  |  |  |
| 2619 | 616.4 | Stage 2 for Gateway Core Network Sharing for GERAN | 192d? | 2012-06-18 A | 2013-03-06 A | 100% | 2012-06-18 | 2013-03-06 | 192d? | finish no earlier than 2013-03-06 | S2 | 1504h | 1504h | Full_MOCN-GERAN-GWCN | PCG-29 | Vodafone | chris.pudney@vodafone.com | Rel-11 | SP-56 | Maurice | Full_MOCN-GERAN-GWCN |  |  |  |
| 2620 | 617 | **Medium range/local area requirements for multicarrier BTS** | 264d? | 2011-11-25 A | 2012-11-23 A | 100% | 2011-11-25 | 2012-11-23 | 264d? |  | G1 | 6296h | 6296h | MRLA | PCG-28 | Ericsson | Eric Nordström | Rel-11 | GP-52 | Paolo | MRLA |  |  |  |
| 2621 | 617.1 | Core part: Medium range/local area requirements for multicarrier BTS | 263d? | 2011-11-25 A | 2012-11-23 A | 100% | 2011-11-25 | 2012-11-23 | 263d? | finish no earlier than 2012-11-23 | G1 | 2096h | 2096h | MRLA-Core | PCG-28 | Ericsson | Eric Nordström | Rel-11 | GP-52 | Paolo | MRLA-Core |  |  |  |
| 2622 | 617.2 | Perf. part: Medium range/local area requirements for multicarrier BTS | 262d? | 2011-11-28 A | 2012-11-23 A | 100% | 2011-11-28 | 2012-11-23 | 262d? | finish no earlier than 2012-11-23 | G1 | 2088h | 2088h | MRLA-Perf | PCG-28 | Ericsson | Eric Nordström | Rel-11 | GP-52 | Paolo | MRLA-Perf |  |  |  |
| 2623 | 618 | Domain Specific Access Control in GERAN | 131d? | 2012-03-05 A | 2012-08-31 A | 100% | 2012-03-05 | 2012-08-31 | 131d? | finish no earlier than 2012-08-31 | G2 | 1048h | 1048h | GDSAC | PCG-28 | Vodafone | chris.pudney@vodafone.com | Rel-11 | GP-53 | Gert | GDSAC |  |  |  |
| 2624 | 619 | **Extending 850 MHz Upper Band (814 – 849 MHz)** | 589d? | 2010-12-10 A | 2013-03-01 A | 100% | 2010-12-10 | 2013-03-01 | 589d? |  | R4; R2; R3; R5 | 33352h | 33352h | e850_UB | PCG-26 | Sprint | John.J.Humbert@Sprint.com | Rel-11 | RP-50 | Issam | e850_UB |  |  |  |
| 2625 | 619.1 | Core part: Extending 850 MHz Upper Band (814 – 849 MHz) | 324d? | 2010-12-10 A | 2012-03-02 A | 100% | 2010-12-10 | 2012-03-02 | 324d? | finish no earlier than 2012-03-02 | R4; R2; R3 | 7776h | 7776h | e850_UB-Core | PCG-26 | Sprint | John.J.Humbert@Sprint.com | Rel-11 | RP-50 | Issam | e850_UB-Core |  |  | RP-120075 |
| 2626 | 619.2 | Perf. part: Extending 850 MHz Upper Band (814 – 849 MHz) | 324d? | 2010-12-10 A | 2012-03-02 A | 100% | 2010-12-10 | 2012-03-02 | 324d? | finish no earlier than 2012-03-02 | R4 | 2592h | 2592h | e850_UB-Perf | PCG-26 | Sprint | John.J.Humbert@Sprint.com | Rel-11 | RP-50 | Issam | e850_UB-Perf |  |  | RP-120076 |
| 2627 | 619.3 | Test part: Extending 850 MHz Upper Band (814 – 849 MHz) | 517d? | 2011-03-18 A | 2013-03-01 A | 100% | 2011-03-18 | 2013-03-01 | 517d? | finish no earlier than 2013-03-01 | R5 | 4136h | 4136h | e850_UB-UEConTest | PCG-26 | Sprint | John.J.Humbert@Sprint.com | Rel-11 | RP-51 | Ingbert | e850_UB-UEConTest |  |  | RP-130043 |

Notes:
- 2602: LS_in C4-121615 GSMA IREG RILTE concluded that TS 22.041 clause 5.4 Stage 1 requirements are not covered by stage 3 specifications
- 2603: CP#60 completed. Handling of premium rate numbers remained OPEN in Rel-11 (shifted to Rel-12). CP-130384 LS_out sent to SA1 / GSMA informing this TSG CT decision. / Impacted TSs and TRs: New TS 24.315
- 2604: CP#58 completed / Impacted TSs and TRs: 23.008 , 23.015 , 29.328 , 29.329 , 29.364
- 2605: CP#58 completed. Linked to Rel-8 Feature: IMS Multimedia Telephony Service (IMS-MMTel) UID_7038. SA1 added FAX stage 1 requirement only in Rel-10 under TEI10 to TS 22.173 (CR#0064)
- 2606: CP#58 completed / Impacted TSs and TRs: 29.163
- 2607: CP#58 completed / Impacted TSs and TRs: 24.229
- 2608: CP#57 completed / Impacted TSs and TRs: 29.332
- 2609: CP#56 stopped. Reason: Protocols for SMS over SGs is replaced by the SIMTC SMS in MME solution (as solution not only for MTC user but for general subscribers) / Impacted TSs and TRs: Stage 3
- 2610: CP#56 stopped (abandonned new TR 29.818) / Impacted TSs and TRs: new TR 29.818
- 2611: CP#56 stopped (abandonned new TS 29.218 Diameter based protocols for SMS service over SGs) / Impacted TSs and TRs: 29.305, new TS 29.218
- 2612: CP#56 stopped / Impacted TSs and TRs: 23.040, 24.011, 43.068
- 2613: GP#58 completed. GP#49 approved WID. Standardization of management of MOCN supporting MSs/UES in CP-150GERAN. Continuation of Rel-10 MOCN-GERAN UID_490001 / Impacted TSs and TRs: GERAN
- 2614: GP#58 completed. GP#49 approved WID / Impacted TSs and TRs: 44.018, 44.060, 45.002, 45.008, 48.008, 48.018
- 2615: SP#55 completed / Impacted TSs and TRs: 23.251, 23.272
- 2616: CP#58 completed
- 2617: CP#58 completed / Impacted TSs and TRs: 24.008
- 2618: CP#57 completed / Impacted TSs and TRs: 23.003
- 2619: SP#59 completed. (23.251CR0062R2 as TEI11. TS 23.251 specifies both MOCN and GWCN for E-UTRAN and UTRAN, but GWCN is not yet supported on GERAN. Extend Full_MOCN-GERAN to also cover GWCN GERAN / Impacted TSs and TRs: 23.251
- 2620: GP#56 completed. GP#52 approved WID / Impacted TSs and TRs: GERAN
- 2621: Stage 3. GP#56 completed. GP#52 approved WID / Impacted TSs and TRs: 45.005
- 2622: Test spec. GP#56 completed. GP#52 approved WID / Impacted TSs and TRs: 51.021
- 2623: GP#55 completed. GP#53 approved WID. Work is dependent upon Full_MOCN-GERAN (UID_510001) / Impacted TSs and TRs: GERAN 44.018
- 2624: Stage 3. Triggered by R4 Rel-10 LTE TR 37.806 Study on Extending 850 MHz (UID_440016) / Impacted TSs and TRs: UTRA, LTE
- 2625: RP#55 completed / Impacted TSs and TRs: 25.101, 25.104, 25.113, 25.133, 25.141, 25.461, 25.466, 36.101, 36.104, 36.113, 36.124, 36.133, 36.141, 36.307, 36.331, 37.104, 37.113, 37.141
- 2626: RP#55 completed / Impacted TSs and TRs: 25.101, 25.104, 25.113, 25.133, 25.141, 25.461, 25.466, 36.101, 36.104, 36.124, 36.133, 36.141, 36.307, 36.331, 37.104, 37.113, 37.141
- 2627: RP#59 completed / Impacted TSs and TRs: 34.108, 34.121-1, 34.121-2, 34.123-1, 34.123-2, 34.123-3, 36.508, 36.521-1, 36.521-2, 36.521-3, 36.523-1, 36.523-2, 36.523-3

| ID | WBS | Task | Duration | Start | Finish | Complete | Baseline start | Baseline finish | Baseline duration | Constraint | Resources | Work | Actual work | Acronym | PCG approved | WI rapporteur name | WI rapporteur e-mail | Release | TSG approved | MCC resp | Special Focus Doc | Acronym_3GU_Export | Status Report |
| --- | --- | --- | --- | --- | --- | --- | --- | --- | --- | --- | --- | --- | --- | --- | --- | --- | --- | --- | --- | --- | --- | --- | --- |
| 2628 | 620 | **Further Self Optimizing Networks (SON) enhancements** | 325d? | 2011-09-19 A | 2012-12-07 A | 100% | 2011-09-19 | 2012-12-07 | 325d? |  | R3; R2 | 10400h | 10400h | SONenh2_LTE_UTRA | PCG-27 | Nokia Siemens Networks | krzysztof.kordybach@nsn.com | Rel-11 | RP-53 | Juha | SON | SONenh2_LTE_UTRA |  |
| 2629 | 620.1 | Core part: Further Self Optimizing Networks (SON) enhancements | 325d? | 2011-09-19 A | 2012-12-07 A | 100% | 2011-09-19 | 2012-12-07 | 325d? | finish no earlier than 2012-12-07 | R3; R2 | 5200h | 5200h | SONenh2_LTE_UTRA-Core | PCG-27 | Nokia Siemens Networks | krzysztof.kordybach@nsn.com | Rel-11 | RP-53 | Juha | SON | SONenh2_LTE_UTRA-Core | RP-121557 |
| 2630 | 621 | **Enhancement of Minimization of Drive Tests for E-UTRAN and UTRAN** | 590d? | 2011-09-19 A | 2013-12-06 A | 100% | 2011-09-19 | 2013-12-06 | 590d? |  | R2; R1; R3; R4; R5 | 35608h | 35608h | eMDT_UMTSLTE | PCG-27 | MediaTek | Johan Johansson | Rel-11 | RP-53 | Yong-Jun |  | eMDT_UMTSLTE |  |
| 2631 | 621.1 | Core part: Enhancement of Minimization of Drive Tests for E-UTRAN and UTRAN | 325d? | 2011-09-19 A | 2012-12-07 A | 100% | 2011-09-19 | 2012-12-07 | 325d? | finish no earlier than 2012-12-07 | R2; R1; R3; R4 | 10400h | 10400h | eMDT_UMTSLTE-Core | PCG-27 | MediaTek | Johan Johansson | Rel-11 | RP-53 | Yong-Jun |  | eMDT_UMTSLTE-Core | RP-121556 |
| 2632 | 621.2 | Test part: Enhancement of Minimization of Drive Tests for E-UTRAN and UTRAN | 202d? | 2013-03-04 A | 2013-12-06 A | 100% | 2013-03-04 | 2013-12-06 | 202d? | finish no earlier than 2013-12-06 | R5 | 1608h | 1608h | eMDT_UMTSLTE-UEConTest | PCG-30 | NTT DoCoMo | masahiro.tamaoki.eu@nttdocomo.com | Rel-11 | RP-59 | Ingbert |  | eMDT_UMTSLTE-UEConTest | RP-131447 |
| 2633 | 622 | **Network Energy Saving for E-UTRAN** | 258d? | 2011-09-19 A | 2012-09-07 A | 100% | 2011-09-19 | 2012-09-07 | 258d? |  | R3; GP | 6224h | 6224h | Netw_Energy_LTE | PCG-27 | China Mobile | yangning@chinamobile.com | Rel-11 | RP-53 | Juha |  | Netw_Energy_LTE |  |
| 2634 | 622.1 | Core part: Network Energy Saving for E-UTRAN | 257d? | 2011-09-19 A | 2012-09-07 A | 100% | 2011-09-19 | 2012-09-07 | 257d? | finish no earlier than 2012-09-07 | R3 | 2056h | 2056h | Netw_Energy_LTE-Core | PCG-27 | China Mobile | yangning@chinamobile.com | Rel-11 | RP-53 | Juha |  | Netw_Energy_LTE-Core | RP-121016 |
| 2635 | 622.2 | GERAN part: Network Energy Saving for E-UTRAN | 5d? | 2012-08-27 A | 2012-08-31 A | 100% | 2012-08-27 | 2012-08-31 | 5d? | finish no earlier than 2012-08-31 | GP | 40h | 40h |  | PCG-29 | Alcatel-Lucent | marguerite.woch@alcatel-lucent.com | Rel-11 | GP-55 | Paolo |  |  |  |
| 2636 | 623 | **E-UTRA medium range and MSR medium range/local area BS class requirements** | 325d? | 2011-09-19 A | 2012-12-07 A | 100% | 2011-09-19 | 2012-12-07 | 325d? |  | R4; G1 | 12432h | 12432h | medBS_class_LTE_MSR | PCG-27 | Ericsson | johan.skold@ericsson.com | Rel-11 | RP-53 | Issam |  | medBS_class_LTE_MSR |  |
| 2637 | 623.1 | Core part: E-UTRA medium range and MSR medium range/local area BS class requirements | 323d? | 2011-09-19 A | 2012-12-07 A | 100% | 2011-09-19 | 2012-12-07 | 323d? | finish no earlier than 2012-12-07 | R4 | 2576h | 2576h | medBS_class_LTE_MSR-Core | PCG-27 | Ericsson | johan.skold@ericsson.com | Rel-11 | RP-53 | Issam |  | medBS_class_LTE_MSR-Core | RP-121558 |
| 2638 | 623.2 | Perf. part: E-UTRA medium range and MSR medium range/local area BS class requirements | 321d? | 2011-09-23 A | 2012-12-07 A | 100% | 2011-09-23 | 2012-12-07 | 321d? | finish no earlier than 2012-12-07 | R4 | 2568h | 2568h | medBS_class_LTE_MSR-Perf | PCG-27 | Ericsson | johan.skold@ericsson.com | Rel-11 | RP-53 | Issam |  | medBS_class_LTE_MSR-Perf | RP-121559 |
| 2639 | 623.3 | GERAN part: E-UTRA medium range and MSR medium range/local area BS class requirements | 261d? | 2011-11-28 A | 2012-11-23 A | 100% | 2011-11-28 | 2012-11-23 | 261d? | finish no earlier than 2012-11-23 | G1 | 2088h | 2088h | medBS_class_LTE_MSR-GERAN | PCG-28 | Ericsson | Eric Nordström | Rel-11 | GP-52 | Paolo |  | medBS_class_LTE_MSR-GERAN |  |
| 2640 | 624 | **RF Requirements for Multi-Band and Multi-Standard Radio (MB-MSR) Base Station** | 553.1d? | 2012-02-06 A | 2014-03-06 A | 100% | 2012-02-06 | 2014-03-06 | 553.1d? |  | R4; G1 | 20915.2h | 20915.2h | MB_MSR_RF | PCG-28 | Huawei | Liu Ye (leo.liuye@huawei.com) | Rel-11 | RP-55 | Issam |  | MB_MSR_RF |  |
| 2641 | 624.1 | Core part: RF Requirements for Multi-Band and Multi-Standard Radio (MB-MSR) Base Station | 223.1d? | 2012-02-06 A | 2012-12-07 A | 100% | 2012-02-06 | 2012-12-07 | 223.1d? | finish no earlier than 2012-12-07 | R4; G1 | 3569.6h | 3569.6h | MB_MSR_RF-Core | PCG-28 | Huawei | Liu Ye (leo.liuye@huawei.com) | Rel-11 | RP-55 | Issam |  | MB_MSR_RF-Core | RP-121985 |
| 2642 | 624.2 | Perf. part: RF Requirements for Multi-Band and Multi-Standard Radio (MB-MSR) Base Station | 531d? | 2012-03-08 A | 2014-03-06 A | 100% | 2012-03-08 | 2014-03-06 | 531d? | finish no earlier than 2014-03-06 | R4; G1 | 8496h | 8496h | MB_MSR_RF-Perf | PCG-28 | Huawei | Liu Ye (leo.liuye@huawei.com) | Rel-11 | RP-55 | Issam |  | MB_MSR_RF-Perf | RP-140064 |
| 2643 | 625 | **Further enhancements to H(e)NB mobility - Part 1** | 129d? | 2012-06-15 A | 2012-12-07 A | 100% | 2012-06-15 | 2012-12-07 | 129d? |  | R3; R2 | 4128h | 4128h | EHNB_enh1 | PCG-29 | Alcatel-Lucent | Martin.Warner@alcatel-lucent.com | Rel-11 | RP-56 | Juha | HNB | EHNB_enh1 |  |
| 2644 | 625.1 | Core part: Further enhancements to H(e)NB mobility - Part 1 | 129d? | 2012-06-15 A | 2012-12-07 A | 100% | 2012-06-15 | 2012-12-07 | 129d? | finish no earlier than 2012-12-07 | R3; R2 | 2064h | 2064h | EHNB_enh1-Core | PCG-29 | Alcatel-Lucent | Martin.Warner@alcatel-lucent.com | Rel-11 | RP-56 | Juha | HNB | EHNB_enh1-Core | RP-121563 |
| 2645 | 626 | **Further enhancements to H(e)NB mobility - Part 2** | 127d? | 2012-06-19 A | 2012-12-07 A | 100% | 2012-06-19 | 2012-12-07 | 127d? |  | R3; R2 | 4064h | 4064h | EHNB_enh2 | PCG-29 | Alcatel-Lucent | Martin.Warner@alcatel-lucent.com | Rel-11 | RP-56 | Juha | HNB | EHNB_enh2 |  |
| 2646 | 626.1 | Core part: Further enhancements to H(e)NB mobility - Part 2 | 127d? | 2012-06-19 A | 2012-12-07 A | 100% | 2012-06-19 | 2012-12-07 | 127d? | finish no earlier than 2012-12-07 | R3; R2 | 2032h | 2032h | EHNB_enh2-Core | PCG-29 | Alcatel-Lucent | Martin.Warner@alcatel-lucent.com | Rel-11 | RP-56 | Juha | HNB | EHNB_enh2-Core | RP-121564 |
| 2647 | 627 | **Network-Based Positioning Support for LTE** | 1391d? | 2009-03-05 A | 2014-06-13 A | 100% | 2009-03-05 | 2014-06-13 | 1391d? |  | R2; R1; R3; R4 | 91464h | 91464h | LCS_LTE-NBPS | PCG-22 | TruePosition | terri.brooks@trueposition.com | Rel-11 | RP-43 | Yong-Jun |  | LCS_LTE-NBPS |  |
| 2648 | 627.1 | Core part: Network-Based Positioning Support for LTE | 1125d? | 2009-03-05 A | 2013-06-12 A | 100% | 2009-03-05 | 2013-06-12 | 1125d? | finish no earlier than 2013-06-12 | R2; R1; R3; R4 | 36000h | 36000h | LCS_LTE-NBPS-Core | PCG-22 | TruePosition | terri.brooks@trueposition.com | Rel-11 | RP-43 | Yong-Jun |  | LCS_LTE-NBPS-Core | RP-130483 |
| 2649 | 627.2 | Perf. part: Network-Based Positioning Support for LTE | 1377d? | 2009-03-24 A | 2014-06-13 A | 100% | 2009-03-24 | 2014-06-13 | 1377d? | finish no earlier than 2014-06-13 | R4 | 11016h | 11016h | LCS_LTE-NBPS-Perf | PCG-22 | TruePosition | terri.brooks@trueposition.com | Rel-11 | RP-43 | Yong-Jun |  | LCS_LTE-NBPS-Perf | RP-140626 |
| 2650 | 628 | **Service continuity improvements for MBMS for LTE** | 993d? | 2010-06-04 A | 2014-03-06 A | 100% | 2010-06-04 | 2014-03-06 | 993d? |  | R2; R3; R5 | 35496h | 35496h | MBMS_LTE_SC | PCG-25 | Huawei | David.Lecompte@huawei.com | Rel-11 | RP-48 | Yong-Jun |  | MBMS_LTE_SC |  |
| 2651 | 628.1 | Core part: Service continuity improvements for MBMS for LTE | 596d? | 2010-06-04 A | 2012-09-07 A | 100% | 2010-06-04 | 2012-09-07 | 596d? | finish no earlier than 2012-09-07 | R2; R3 | 9536h | 9536h | MBMS_LTE_SC-Core | PCG-25 | Huawei | David.Lecompte@huawei.com | Rel-11 | RP-48 | Yong-Jun |  | MBMS_LTE_SC-Core | RP-121001 |
| 2652 | 628.2 | Test part: Service continuity improvements for MBMS for LTE | 266d? | 2013-03-04 A | 2014-03-06 A | 100% | 2013-03-04 | 2014-03-06 | 266d? | finish no earlier than 2014-03-06 | R5 | 2128h | 2128h | MBMS_LTE_SC-UEConTest | PCG-30 | Ericsson | leif.mattisson@ericsson.com | Rel-11 | RP-59 | Ingbert |  | MBMS_LTE_SC-UEConTest | RP-140074 |

Notes:
- 2628: Stage 1/2/3 / Impacted TSs and TRs: UTRA, LTE
- 2629: RP#58 completed / Impacted TSs and TRs: 25.331, 25.401, 25.410, 25.413, 25.423, 25.433, 36.300, 36.331, 36.413, 36.423
- 2630: Stage 2/3 / Impacted TSs and TRs: UTRA, LTE
- 2631: RP#58 completed / Impacted TSs and TRs: 25.133, 25.123, 25.304, 25.331, 25.413, 25.423, 36.133, 36.304, 36.306, 36.331, 36.413, 36.423, 37.320, 36.300
- 2632: RP#62 completed / Impacted TSs and TRs: 34.108, 34.109, 34.123-1, 34.123-2, 34.123-3, 36.508, 36.509, 36.523-1, 36.523-2, 36.523-3
- 2633: Stage 2/3 / Impacted TSs and TRs: LTE, GERAN
- 2634: RP#57 completed. Inter-RAT aspect can affect UTRA and GERAN as well / Impacted TSs and TRs: 25.413, 36.300, 36.413, 36.423
- 2635: GP#55 approved WID and completed. Stage 3. ChangES in CP-150RIM protocol and in SON Transfer RIM application to provide support for Energy Savings Indication feature / Impacted TSs and TRs: 48.018 [Serving GPRS Support Node (SGSN); BSS GPRS protocol (BSSGP)]
- 2636: Stage 3. GERAN BS RF requirements specs need aligned with RAN4 ongoing Rel-11 Feature UID_530037 E-UTRA medium range and MSR medium range/local area BS class requirements (medBS_class_LTE_MSR) / Impacted TSs and TRs: UTRA, LTE, GERAN
- 2637: RP#58 completed. TR 37.809 v200 for Approval / Impacted TSs and TRs: 25.104, 36.104, 37.104, new TR 37.809
- 2638: RP#58 completed / Impacted TSs and TRs: 25.141, 36.141, 37.141
- 2639: GP#56 completed. GP#52 approved WID / Impacted TSs and TRs: 45.005, 51.021
- 2640: - / Impacted TSs and TRs: UTRA, LTE, GERAN
- 2641: RP#58 completed / Impacted TSs and TRs: 25.104, 25.105, 36.104, 37.104, new TR 37.812
- 2642: RP#63 completed / Impacted TSs and TRs: 25.141, 25.142, 36.141, 37.141
- 2643: Stage 2/3. Triggered by FS_EHNB_enh (UTRA, LTE TR 37.803 under AI 12.3.2). Compare also Rel-10 WI HNB_HENB_mob_enh RP-110183 / Impacted TSs and TRs: UTRA, LTE
- 2644: RP#58 completed / Impacted TSs and TRs: 25.413, 25.467, 25.469, 36.300, 36.413, 36.423
- 2645: Stage 2/3. Legacy UE Handling (X2-GW, 20% complete, moved to Rel-12 UID_580030). Triggered by FS_EHNB_enh (UTRA, LTE TR 37.803 under AI 12.3.2) / Impacted TSs and TRs: UTRA, LTE
- 2646: RP#58 completed Legacy UE Handling (X2-GW, 20% complete, moved to Rel-12 UID_580030). Updated WID RP-121147=>RP-121712 / Impacted TSs and TRs: 25.413, 25.467, 25.469, 25.471
- 2647: - / Impacted TSs and TRs: LTE
- 2648: RP#60 completed / Impacted TSs and TRs: 36.214, 36.300, 36.305, 36.401, 36.413, 36.455, new TS (36.111, 36.456, 36.457, 36.458, 36.459)
- 2649: RP#64 completed. TS 36.112v100 for 1-step Approval / Impacted TSs and TRs: 36.111, new TS 36.112
- 2650: - / Impacted TSs and TRs: LTE
- 2651: RP#57 completed / Impacted TSs and TRs: 25.446, 36.300, 36.304, 36.321, 36.322, 36.323, 36.331, 36.440, 36.441, 36.442, 36.443, 36.444, 36.445
- 2652: RP#63 completed / Impacted TSs and TRs: 36.508, 36.523-1, 36.523-2, 36.523-3

| ID | WBS | Task | Duration | Start | Finish | Complete | Baseline start | Baseline finish | Baseline duration | Constraint | Resources | Work | Actual work | Acronym | PCG approved | WI rapporteur name | WI rapporteur e-mail | Release | TSG approved | MCC resp | Acronym_3GU_Export | Status Report | Special Focus Doc |
| --- | --- | --- | --- | --- | --- | --- | --- | --- | --- | --- | --- | --- | --- | --- | --- | --- | --- | --- | --- | --- | --- | --- | --- |
| 2653 | 629 | **Further Enhanced Non CA-based ICIC for LTE** | 991d? | 2011-03-22 A | 2014-12-15 A | 100% | 2011-03-22 | 2014-09-12 | 922d? |  | R1; R2; R3; R4; R5 | 63112h | 63112h | eICIC_enh_LTE | PCG-26 | China Mobile | ShenXiaodong@chinamobile.com | Rel-11 | RP-51 | Patrick | eICIC_enh_LTE |  |  |
| 2654 | 629.1 | Core part: Further Enhanced Non CA-based ICIC for LTE | 456d? | 2011-03-22 A | 2012-12-07 A | 100% | 2011-03-22 | 2012-12-07 | 456d? | finish no earlier than 2012-12-07 | R1; R2; R3; R4 | 14592h | 14592h | eICIC_enh_LTE-Core | PCG-26 | China Mobile | ShenXiaodong@chinamobile.com | Rel-11 | RP-51 | Patrick | eICIC_enh_LTE-Core | RP-121986 |  |
| 2655 | 629.2 | Perf. part: Further Enhanced Non CA-based ICIC for LTE | 715d? | 2011-03-23 A | 2013-12-06 A | 100% | 2011-03-23 | 2013-12-06 | 715d? | finish no earlier than 2013-12-06 | R4 | 5720h | 5720h | eICIC_enh_LTE-Perf | PCG-26 | China Mobile | ShenXiaodong@chinamobile.com | Rel-11 | RP-51 | Issam | eICIC_enh_LTE-Perf | RP-131463 |  |
| 2656 | 629.3 | Test part: Further Enhanced Non CA-based ICIC for LTE | 395d? | 2013-06-15 A | 2014-12-15 A | 100% | 2013-06-18 | 2014-09-12 | 326d? | finish no earlier than 2014-12-15 | R5 | 3160h | 3160h | eICIC_enh_LTE-UEConTest | PCG-31 | ZTE | Carolyn Taylor (carolyn.tayl@zte.com.cn) | Rel-11 | RP-60 | Ingbert | eICIC_enh_LTE-UEConTest | RP-141847 |  |
| 2657 | 630 | **New Band LTE Downlink FDD 716-728 MHz (Band 29, Carrier Aggregation of Band 2 and Band 29 and of Band 4 and Band 29)** | 456d? | 2011-03-22 A | 2012-12-07 A | 100% | 2011-03-22 | 2012-12-07 | 456d? |  | R4 | 10880h | 10880h | LTE_DL_FDD700 | PCG-26 | AT&T | marc.grant@att.com | Rel-11 | RP-51 | Issam | LTE_DL_FDD700 |  | CA |
| 2658 | 630.1 | Core part: New Band LTE Downlink FDD 716-728 MHz (Band 29), Carrier Aggregation of Band 2 and Band 29 and of Band 4 and Band 29 | 453d? | 2011-03-22 A | 2012-12-07 A | 100% | 2011-03-22 | 2012-12-07 | 453d? | finish no earlier than 2012-12-07 | R4 | 3624h | 3624h | LTE_DL_FDD700-Core | PCG-26 | AT&T | marc.grant@att.com | Rel-11 | RP-51 | Issam | LTE_DL_FDD700-Core | RP-121604 |  |
| 2659 | 630.2 | Perf. part: New Band LTE Downlink FDD 716-728 MHz (Band 29), Carrier Aggregation of Band 2 and Band 29 and of Band 4 and Band 29 | 451d? | 2011-03-29 A | 2012-12-07 A | 100% | 2011-03-29 | 2012-12-07 | 451d? | finish no earlier than 2012-12-07 | R4 | 3608h | 3608h | LTE_DL_FDD700-Perf | PCG-26 | AT&T | marc.grant@att.com | Rel-11 | RP-51 | Issam | LTE_DL_FDD700-Perf | RP-121605 |  |
| 2660 | 631 | **LTE RAN Enhancements for Diverse Data Applications** | 657d? | 2011-03-18 A | 2013-09-06 A | 100% | 2011-03-18 | 2013-09-06 | 657d? |  | R2; R5 | 15248h | 15248h | LTE_eDDA | PCG-26 | BlackBerry | Gordon Young (gyoung@rim.com) | Rel-11 | RP-51 | Yong-Jun | LTE_eDDA |  |  |
| 2661 | 631.1 | Core part: LTE RAN Enhancements for Diverse Data Applications | 456d? | 2011-03-18 A | 2012-12-07 A | 100% | 2011-03-18 | 2012-12-07 | 456d? | finish no earlier than 2012-12-07 | R2 | 3648h | 3648h | LTE_eDDA-Core | PCG-26 | BlackBerry | Gordon Young (gyoung@rim.com) | Rel-11 | RP-51 | Yong-Jun | LTE_eDDA-Core | RP-121571 |  |
| 2662 | 631.2 | Test part: LTE RAN Enhancements for Diverse Data Applications | 136d? | 2013-03-04 A | 2013-09-06 A | 100% | 2013-03-04 | 2013-09-06 | 136d? | finish no earlier than 2013-09-06 | R5 | 1088h | 1088h | LTE_eDDA-UEConTest | PCG-30 | BlackBerry | Enikő Sokondár (esokondar@rim.com) | Rel-11 | RP-59 | Ingbert | LTE_eDDA-UEConTest | RP-130946 |  |
| 2663 | 632 | **LTE E850 - Lower Band for Region 2 (non-US), Band 27** | 516d? | 2011-03-23 A | 2013-03-01 A | 100% | 2011-03-23 | 2013-03-01 | 516d? |  | R1; R2; R4; R5 | 28496h | 28496h | LTE_e850_LB | PCG-26 | NII Holdings | bill.shvodian@nii.com | Rel-11 | RP-51 | Patrick | LTE_e850_LB |  |  |
| 2664 | 632.1 | Core part: LTE E850 - Lower Band for Region 2 (non-US), Band 27 | 328d? | 2011-06-15 A | 2012-09-07 A | 100% | 2011-06-15 | 2012-09-07 | 328d? | finish no earlier than 2012-09-07 | R1; R2; R4 | 7872h | 7872h | LTE_e850_LB-Core | PCG-26 | NII Holdings | bill.shvodian@nii.com | Rel-11 | RP-51 | Patrick | LTE_e850_LB-Core | RP-120570 |  |
| 2665 | 632.2 | Perf. part: LTE E850 - Lower Band for Region 2 (non-US), Band 27 | 326d? | 2011-03-23 A | 2012-06-15 A | 100% | 2011-03-23 | 2012-06-15 | 326d? | finish no earlier than 2012-12-07 | R4 | 2608h | 2608h | LTE_e850_LB-Perf | PCG-26 | NII Holdings | bill.shvodian@nii.com | Rel-11 | RP-51 | Issam | LTE_e850_LB-Perf | RP-120571 |  |
| 2666 | 632.3 | Test part: LTE E850 - Lower Band for Region 2 (non-US), Band 27 | 189d? | 2012-06-18 A | 2013-03-01 A | 100% | 2012-06-18 | 2013-03-01 | 189d? | finish no earlier than 2013-03-01 | R5 | 1504h | 1504h | LTE_e850_LB-UEConTest | PCG-29 | NII Holdings | bill.shvodian@nii.com | Rel-11 | RP-56 | Ingbert | LTE_e850_LB-UEConTest | RP-130045 |  |
| 2667 | 633 | **LTE for 700 MHz Digital Dividend** | 538d? | 2011-06-07 A | 2013-06-14 A | 100% | 2011-06-07 | 2013-06-14 | 538d? |  | R4; R2; R3; R5 | 28032h | 28032h | LTE_APAC700 | PCG-27 | Ericsson | olav.queseth@ericsson.com | Rel-11 | RP-52 | Issam | LTE_APAC700 |  |  |
| 2668 | 633.1 | Core part: LTE for 700 MHz Digital Dividend | 273d? | 2011-06-07 A | 2012-06-15 A | 100% | 2011-06-07 | 2012-06-15 | 273d? | finish no earlier than 2012-06-15 | R4; R2; R3 | 6552h | 6552h | LTE_APAC700-Core | PCG-27 | Ericsson | olav.queseth@ericsson.com | Rel-11 | RP-52 | Issam | LTE_APAC700-Core | RP-120572 |  |
| 2669 | 633.2 | Perf. part: LTE for 700 MHz Digital Dividend | 271d? | 2011-06-09 A | 2012-06-15 A | 100% | 2011-06-09 | 2012-06-15 | 271d? | finish no earlier than 2012-06-15 | R4 | 2168h | 2168h | LTE_APAC700-Perf | PCG-27 | Ericsson | olav.queseth@ericsson.com | Rel-11 | RP-52 | Issam | LTE_APAC700-Perf | RP-120573 |  |
| 2670 | 633.3 | Test part: LTE for 700 MHz Digital Dividend | 262d? | 2012-06-18 A | 2013-06-14 A | 100% | 2012-06-18 | 2013-06-14 | 262d? | finish no earlier than 2013-06-14 | R5 | 2096h | 2096h | LTE_APAC700-UEConTest | PCG-29 | Ericsson | fredrik.sundstrom@ericsson.com | Rel-11 | RP-56 | Ingbert | LTE_APAC700-UEConTest | RP-130467 |  |
| 2671 | 634 | **Relays for LTE (part 2)** | 930d? | 2009-12-04 A | 2013-06-14 A | 100% | 2009-12-04 | 2013-06-14 | 930d? |  | R4 | 17496.4h | 17496.4h | LTE_Relay2 | PCG-24 | Ericsson | christian.hoymann@ericsson.com | Rel-11 | RP-46 | Patrick | LTE_Relay2 |  |  |
| 2672 | 634.1 | Core part: Relays for LTE (part 2) | 333d? | 2011-06-07 A | 2012-09-07 A | 100% | 2011-06-07 | 2012-09-07 | 333d? | finish no earlier than 2012-09-07 | R4 | 2656.39h | 2656.39h | LTE_Relay2-Core | PCG-27 | Ericsson | christian.hoymann@ericsson.com | Rel-11 | RP-52 | Issam | LTE_Relay2-Core | RP-121008 |  |
| 2673 | 634.2 | Perf. part: Relays for LTE (part 2) | 925d? | 2009-12-04 A | 2013-06-14 A | 100% | 2009-12-04 | 2013-06-14 | 925d? | finish no earlier than 2013-06-14 | R4 | 7400h | 7400h | LTE_Relay2-Perf | PCG-24 | Ericsson | christian.hoymann@ericsson.com | Rel-11 | RP-46 | Issam | LTE_Relay2-Perf | RP-130487 |  |
| 2674 | 635 | **Signalling and Procedure for Interference Avoidance for in-device coexistence** | 325d? | 2011-09-19 A | 2012-12-07 A | 100% | 2011-09-19 | 2012-12-07 | 325d? |  | R2; R4 | 12976h | 12976h | SPIA_IDC_LTE | PCG-27 | China Mobile | Zhenping HU | Rel-11 | RP-53 | Yong-Jun | SPIA_IDC_LTE |  |  |
| 2675 | 635.1 | Core part: Signalling and Procedure for Interference Avoidance for in-device coexistence | 325d? | 2011-09-19 A | 2012-12-07 A | 100% | 2011-09-19 | 2012-12-07 | 325d? | finish no earlier than 2012-12-07 | R2; R4 | 5200h | 5200h | SPIA_IDC_LTE-Core | PCG-27 | China Mobile | Zhenping HU | Rel-11 | RP-53 | Yong-Jun | SPIA_IDC_LTE-Core | RP-121573 |  |
| 2676 | 635.2 | Perf. part: Signalling and Procedure for Interference Avoidance for in-device coexistence | 322d? | 2011-09-20 A | 2012-12-07 A | 100% | 2011-09-20 | 2012-12-07 | 322d? | finish no earlier than 2012-12-07 | R4 | 2576h | 2576h | SPIA_IDC_LTE-Perf | PCG-27 | China Mobile | Zhenping HU | Rel-11 | RP-53 | Issam | SPIA_IDC_LTE-Perf | RP-121574 |  |

Notes:
- 2653: - / Impacted TSs and TRs: LTE
- 2654: RP#58 completed / Impacted TSs and TRs: 36.101, 36.133, 36.201, 36.211, 36.212, 36.213, 36.214, 36.300, 36.304, 36.321, 36.331, 36.413, 36.423
- 2655: RP#62 completed / Impacted TSs and TRs: 36.101, 36.104, 36.133, 36.141
- 2656: ; Stat Rep: RP-141131->RP-141847 / Impacted TSs and TRs: 36.508, 36.521-1, 36.521-2, 36.521-3, 36.523-1, 36.523-2, 36.523-3
- 2657: Stage 3 / Impacted TSs and TRs: LTE
- 2658: RP#58 completed / Impacted TSs and TRs: 36.101, 36.104, 36.141, 36.307
- 2659: RP#58 completed / Impacted TSs and TRs: 36.101, 36.104, 36.133, 36.141, 36.307
- 2660: Stage 2/3 / Impacted TSs and TRs: LTE
- 2661: RP#58 completed / Impacted TSs and TRs: 36.300, 36.321, 36.331, new TR 36.822
- 2662: RP#61 completed / Impacted TSs and TRs: 36.523-1, 36.523-2, 36.523-3
- 2663: Stage 3 / Impacted TSs and TRs: LTE
- 2664: RP#56 completed / Impacted TSs and TRs: 25.101, 25.104, 25.461, 25.466, 36.101, 36.104, 36.113, 36.124, 36.307, 37.104, 37.113
- 2665: RP#56 completed / Impacted TSs and TRs: 25.123, 25.133, 25.141, 36.133, 36.141, 37.141
- 2666: RP#59 completed / Impacted TSs and TRs: 36.508, 36.521-1, 36.521-2, 36.521-3, 36.523-2, 36.523-3, 37.571-1
- 2667: Stage 3. Asian Pacific American Caucus (APAC) Asia-Pacific Telecommunity (APT) Wireless Forum / Impacted TSs and TRs: LTE
- 2668: RP#56 completed. TR 36.820 v100 for Information and Approval / Impacted TSs and TRs: 25.461, 25.466, 36.101, 36.104, 36.113, 36.124, 36.133, 36.307, 37.104, 37.113, new TR 36.820
- 2669: RP#56 completed / Impacted TSs and TRs: 36.133, 36.141, 37.141
- 2670: RP#60 completed / Impacted TSs and TRs: 36.508, 36.521-1, 36.521-2, 36.521-3, 36.523-2, 36.523-3, 37.571-1
- 2671: Continuation of Rel-10 (open RAN4 Core & Perf parts) / Impacted TSs and TRs: LTE
- 2672: RP#57 completed. TS 36.116, TR 36.826 v100 for Information & Approval. RP#52 Core part not completed in Rel-10 / Impacted TSs and TRs: 36.133, new RAN4 (36.116, 36.826)
- 2673: RP#60 completed. New TS 36.117 v100 for 1-step Approval. RP#52 transferred completely from Rel-10 UID_460213 / Impacted TSs and TRs: 36.133, new TS 36.117 (E-UTRA Relay conformance testing)
- 2674: Stage 2/3 / Impacted TSs and TRs: LTE
- 2675: RP#58 completed / Impacted TSs and TRs: 36.133, 36.300, 36.306, 36.321, 36.331
- 2676: RP#58 completed / Impacted TSs and TRs: 36.133

| ID | WBS | Task | Duration | Start | Finish | Complete | Remaining | Baseline start | Baseline finish | Baseline duration | Total slack | Constraint | Resources | Work | Actual work | Acronym | PCG approved | WI rapporteur name | Release | TSG approved | MCC resp | Acronym_3GU_Export | Status Report | Special Focus Doc |
| --- | --- | --- | --- | --- | --- | --- | --- | --- | --- | --- | --- | --- | --- | --- | --- | --- | --- | --- | --- | --- | --- | --- | --- | --- |
| 2677 | 636 | **Coordinated Multi-Point Operation for LTE** | 860d? | 2011-09-19 A | 2014-12-15 A | 100% |  | 2011-09-19 | 2014-09-12 | 791d? |  |  | R1; R2; R3; R4; R5 | 66128h | 66128h | COMP_LTE | PCG-27 | Huawei, Samsung | Rel-11 | RP-53 | Patrick | COMP_LTE |  |  |
| 2678 | 636.1 | Core part: Coordinated Multi-Point Operation for LTE – Uplink | 325d? | 2011-09-19 A | 2012-12-07 A | 100% |  | 2011-09-19 | 2012-12-07 | 325d? |  | finish no earlier than 2012-12-07 | R1; R2; R3; R4 | 10400h | 10400h | COMP_LTE_UL-Core | PCG-27 | Huawei | Rel-11 | RP-53 | Patrick | COMP_LTE_UL-Core | RP-121575 |  |
| 2679 | 636.2 | Perf. part: Coordinated Multi-Point Operation for LTE – Uplink | 321d? | 2011-09-23 A | 2012-12-07 A | 100% |  | 2011-09-23 | 2012-12-07 | 321d? |  | finish no earlier than 2012-12-07 | R4 | 2568h | 2568h | COMP_LTE_UL-Perf | PCG-27 | Huawei | Rel-11 | RP-53 | Issam | COMP_LTE_UL-Perf | RP-121576 |  |
| 2680 | 636.3 | Core part: Coordinated Multi-Point Operation for LTE – Downlink | 325d? | 2011-09-19 A | 2012-12-07 A | 100% |  | 2011-09-19 | 2012-12-07 | 325d? |  | finish no earlier than 2012-12-07 | R1; R2; R3; R4 | 10400h | 10400h | COMP_LTE_DL-Core | PCG-27 | Samsung | Rel-11 | RP-53 | Patrick | COMP_LTE_DL-Core | RP-121577 |  |
| 2681 | 636.4 | Perf. part: Coordinated Multi-Point Operation for LTE – Downlink | 582d? | 2011-09-23 A | 2013-12-06 A | 100% |  | 2011-09-23 | 2013-12-06 | 582d? |  | finish no earlier than 2013-12-06 | R4 | 4656h | 4656h | COMP_LTE_DL-Perf | PCG-27 | Samsung | Rel-11 | RP-53 | Issam | COMP_LTE_DL-Perf | RP-131465 |  |
| 2682 | 636.5 | Test part: Coordinated Multi-Point Operation for LTE | 463d? | 2013-03-15 A | 2014-12-15 A | 100% |  | 2013-03-04 | 2014-09-12 | 404d? |  | finish no earlier than 2014-12-15 | R5 | 3704h | 3704h | COMP_LTE-UEConTest | PCG-30 | Samsung | Rel-11 | RP-59 | Ingbert | COMP_LTE-UEConTest | RP-141782 |  |
| 2683 | 637 | **Enhanced downlink control channel(s) for LTE Advanced** | 732d? | 2011-12-09 A | 2014-09-12 A | 100% |  | 2011-12-09 | 2014-09-12 | 731d? |  |  | R1; R2; R4; R5 | 38272h | 38272h | LTE_enh_dl_ctrl | PCG-28 | Alcatel-Lucent | Rel-11 | RP-54 | Patrick | LTE_enh_dl_ctrl |  |  |
| 2684 | 637.1 | Core part: Enhanced downlink control channel(s) for LTE Advanced | 265d? | 2011-12-09 A | 2012-12-07 A | 100% |  | 2011-12-09 | 2012-12-07 | 265d? |  | finish no earlier than 2012-12-07 | R1; R2; R4 | 6360h | 6360h | LTE_enh_dl_ctrl-Core | PCG-28 | Alcatel-Lucent | Rel-11 | RP-54 | Patrick | LTE_enh_dl_ctrl-Core | RP-121579 |  |
| 2685 | 637.2 | Perf. part: Enhanced downlink control channel(s) for LTE Advanced | 659d? | 2011-12-16 A | 2014-06-13 A | 100% |  | 2011-12-16 | 2014-06-13 | 659d? |  | finish no earlier than 2014-06-13 | R4 | 5272h | 5272h | LTE_enh_dl_ctrl-Perf | PCG-28 | Alcatel-Lucent | Rel-11 | RP-54 | Issam | LTE_enh_dl_ctrl-Perf | RP-140651 |  |
| 2686 | 637.3 | Test part: Enhanced downlink control channel(s) for LTE Advanced | 402d? | 2013-03-04 A | 2014-09-12 A | 100% |  | 2013-03-04 | 2014-09-12 | 402d? |  | finish no earlier than 2014-09-12 | R5 | 3216h | 3216h | LTE_enh_dl_ctrl-UEConTest | PCG-30 | Huawei | Rel-11 | RP-59 | Ingbert | LTE_enh_dl_ctrl-UEConTest | RP-141256 |  |
| 2687 | 638 | **Public Safety Broadband High Power UE for Band 14 for Region 2** | 403d? | 2012-03-05 A | 2013-09-06 A | 100% |  | 2012-03-05 | 2013-09-06 | 403d? |  |  | R4; R5 | 9144h | 9144h | LTE_B14_PSBB_HPUE | PCG-28 | Motorola Solutions | Rel-11 | RP-55 | Issam | LTE_B14_PSBB_HPUE |  | Public Safety (A-A) |
| 2688 | 638.1 | Core part: Public Safety Broadband High Power UE for Band 14 for Region 2 | 201d? | 2012-03-05 A | 2012-12-07 A | 100% |  | 2012-03-05 | 2012-12-07 | 201d? |  | finish no earlier than 2012-12-07 | R4 | 1608h | 1608h | LTE_B14_PSBB_HPUE-Core | PCG-28 | Motorola Solutions | Rel-11 | RP-55 | Issam | LTE_B14_PSBB_HPUE-Core | RP-121581 | Public Safety (A-A) |
| 2689 | 638.2 | Test part: Public Safety Broadband High Power UE for Band 14 for Region 2 | 138d? | 2013-03-04 A | 2013-09-06 A | 100% |  | 2013-03-04 | 2013-09-06 | 138d? |  | finish no earlier than 2013-09-06 | R5 | 1088h | 1088h | LTE_B14_PSBB_HPUE-UEConTest | PCG-30 | Motorola Solutions | Rel-11 | RP-59 | Ingbert | LTE_B14_PSBB_HPUE-UEConTest | RP-130949 | Public Safety (A-A) |
| 2690 | 639 | **Improved Minimum Performance Requirements for E-UTRA: Interference Rejection** | 671d? | 2012-03-05 A | 2014-09-12 A | 100% |  | 2012-03-05 | 2014-09-12 | 670d? |  |  | R4; R5 | 14952h | 14952h | LTE_Interf_Rej | PCG-28 | Renesas Mobile | Rel-11 | RP-55 | Issam | LTE_Interf_Rej |  |  |
| 2691 | 639.1 | Perf. part: Improved Minimum Performance Requirements for E-UTRA: Interference Rejection | 201d? | 2012-03-05 A | 2012-12-07 A | 100% |  | 2012-03-05 | 2012-12-07 | 201d? |  | finish no earlier than 2012-12-07 | R4 | 1608h | 1608h | LTE_Interf_Rej-Perf | PCG-28 | Renesas Mobile | Rel-11 | RP-55 | Issam | LTE_Interf_Rej-Perf | RP-121582 |  |
| 2692 | 639.2 | Test part: Improved Minimum Performance Requirements for E-UTRA: Interference Rejection | 327d? | 2013-06-18 A | 2014-09-12 A | 100% |  | 2013-06-18 | 2014-09-12 | 327d? |  | finish no earlier than 2014-09-12 | R5 | 2608h | 2608h | LTE_Interf_Rej-UEConTest | PCG-31 | Broadcom | Rel-11 | RP-60 | Ingbert | LTE_Interf_Rej-UEConTest | RP-141602 |  |
| 2693 | 640 | **Additional special subframe configuration for LTE TDD** | 341d? | 2012-03-05 A | 2013-06-14 A | 100% |  | 2012-03-05 | 2013-06-14 | 341d? |  |  | R4; R2; R3; R5 | 14808h | 14808h | LTE_TDD_add_subframe | PCG-28 | China Mobile | Rel-11 | RP-55 | Issam | LTE_TDD_add_subframe |  |  |
| 2694 | 640.1 | Core part: Additional special subframe configuration for LTE TDD | 137d? | 2012-03-05 A | 2012-09-07 A | 100% |  | 2012-03-05 | 2012-09-07 | 137d? |  | finish no earlier than 2012-09-07 | R4; R2; R3 | 3288h | 3288h | LTE_TDD_add_subframe-Core | PCG-28 | China Mobile | Rel-11 | RP-55 | Issam | LTE_TDD_add_subframe-Core | RP-121019 |  |
| 2695 | 640.2 | Test part: Additional special subframe configuration for LTE TDD | 76d? | 2013-03-04 A | 2013-06-14 A | 100% |  | 2013-03-04 | 2013-06-14 | 76d? |  | finish no earlier than 2013-09-13 | R5 | 608h | 608h | LTE_TDD_add_subframe-UEConTest | PCG-30 | Huawei | Rel-11 | RP-59 | Ingbert | LTE_TDD_add_subframe-UEConTest | RP-130475 |  |
| 2696 | 641 | **Rel-11 LTE Carrier Aggregation** | 1062d? | 2010-12-10 A | 2014-12-15 | 99% | 8.37d? | 2010-12-10 | 2014-12-05 | 1054d? | 872d |  | R1; R2; R3; R4; R5 | 315760h | 263184h | LTE_CA_Rel-11 | PCG-30 |  | Rel-11 | RP-58 | Patrick | LTE_CA_Rel-11 |  | CA |
| 2697 | 641.1 | **LTE Carrier Aggregation Enhancements** | 995d? | 2011-03-15 A | 2014-12-15 | 93% | 65.41d? | 2011-03-22 | 2014-12-05 | 982d? | 872d |  | R1; R2; R3; R4; R5 | 70824h | 47768h | LTE_CA_enh | PCG-26 | Nokia | Rel-11 | RP-51 | Patrick | LTE_CA_enh |  | CA |
| 2698 | 641.1.1 | Core part: LTE Carrier Aggregation Enhancements | 646.25d? | 2011-03-22 A | 2013-08-27 | 80% | 129.25d? | 2011-03-22 | 2013-03-01 | 517d? | 1215.75d | finish no earlier than 2013-03-01 | R1; R2; R4; R3 | 20680h | 16544h | LTE_CA_enh-Core | PCG-26 | Nokia | Rel-11 | RP-51 | Patrick | LTE_CA_enh-Core | RP-130059 | CA |
| 2699 | 641.1.2 | Perf. part: LTE Carrier Aggregation Enhancements | 994d? | 2011-03-15 A | 2014-12-15 A | 100% |  | 2011-03-29 | 2014-12-05 | 977d? |  | finish no earlier than 2014-12-15 | R4 | 7936h | 7936h | LTE_CA_enh-Perf | PCG-26 | Nokia | Rel-11 | RP-51 | Issam | LTE_CA_enh-Perf | RP-141969 | CA |
| 2700 | 641.1.3 | Test part: LTE Carrier Aggregation Enhancements | 326d? | 2013-06-18 A | 2014-09-12 A | 100% |  | 2013-06-18 | 2014-09-12 | 326d? |  | finish no earlier than 2014-09-12 | R5 | 2608h | 2608h | LTE_CA_enh-UEConTest | PCG-31 | Microsoft | Rel-11 | RP-60 | Ingbert | LTE_CA_enh-UEConTest | RP-141443 | CA |
| 2701 | 641.2 | UE Conformance Test Aspects – LTE Advanced Carrier Aggregation of Intra-band contiguous and Inter-band configurations | 329d? | 2012-09-11 A | 2013-12-06 A | 100% |  | 2012-09-11 | 2013-12-06 | 329d? |  | finish no earlier than 2013-12-06 | R5 | 2624h | 2624h | LTE_CA_intraC_inter_UEConTest | PCG-29 | Nokia | Rel-11 | RP-57 | Ingbert | LTE_CA_intraC_inter_UEConTest | RP-131446 | CA |

Notes:
- 2677: Stage 3. Triggered by Rel-11 TR 36.819 Study on Coordinated Multi-Point Operation for LTE (FS_CoMP_LTE) / Impacted TSs and TRs: LTE / WI rapporteur e-mail: Juho Lee (juho95.lee@samsung.com), david.mazzarese@huawei.com
- 2678: RP#58 completed / Impacted TSs and TRs: 36.101, 36.104, 36.133, 36.201, 36.211, 36.212, 36.213, 36.214, 36.300, 36.306, 36.321, 36.331, 36.423 / WI rapporteur e-mail: david.mazzarese@huawei.com
- 2679: RP#58 completed / Impacted TSs and TRs: 36.101, 36.104, 36.133, 36.141 / WI rapporteur e-mail: Xinwei Zhi (zhixinwei@huawei.com)
- 2680: RP#58 completed / Impacted TSs and TRs: 36.101, 36.104, 36.133, 36.201, 36.211, 36.212, 36.213, 36.214, 36.300, 36.306, 36.321, 36.331, 36.423 / WI rapporteur e-mail: Juho Lee (juho95.lee@samsung.com)
- 2681: RP#62 completed / Impacted TSs and TRs: 36.101, 36.104, 36.133, 36.141, 36.307 / WI rapporteur e-mail: xutao.zhou@samsung.com
- 2682: Impacted TSs and TRs: 36.508, 36.521-1, 36.521-2, 36.523-1, 36.523-2, 36.523-3 / WI rapporteur e-mail: Stoyan.Baev@partner.samsung.com
- 2683: Stage 3. RP#58 Core completed. Triggered by UID_510037 Rel-11 TR 36.871 Study on further Downlink MIMO enhancements for LTE-Advanced (FS_LTE_eDL_MIMO_enh) / Impacted TSs and TRs: LTE / WI rapporteur e-mail: sigen.ye@alcatel-lucent.com
- 2684: RP#58 completed / Impacted TSs and TRs: 36.101, 36.211, 36.212, 36.213, 36.331 / WI rapporteur e-mail: sigen.ye@alcatel-lucent.com
- 2685: RP#64 completed / Impacted TSs and TRs: 36.101, 36.104, 36.133, 36.141 / WI rapporteur e-mail: teck.hu@alcatel-lucent.com
- 2686: RP#65 completed / Impacted TSs and TRs: 36.508, 36.521-1, 36.521-2, 36.523-1, 36.523-2, 36.523-3 / WI rapporteur e-mail: Xu Kai (xk.xukai@huawei.com)
- 2687: Stage 3 / Impacted TSs and TRs: LTE / WI rapporteur e-mail: xiaowei.jin@motorolasolutions.com
- 2688: RP#58 completed. TR 36.837 v100 for Information and Approval / Impacted TSs and TRs: 36.101, new TR 36.837 / WI rapporteur e-mail: xiaowei.jin@motorolasolutions.com
- 2689: RP#61 completed / Impacted TSs and TRs: 36.521-1, 36.521-2 / WI rapporteur e-mail: xiaowei.jin@motorolasolutions.com
- 2690: RP#58 completed. Triggered by FS_enh_perf_UE_LTE. Adds Perf. requirements for demodulation of the already specified PDSCH with the transmission modes defined in Rel-8 to Rel-10 / Impacted TSs and TRs: LTE / WI rapporteur e-mail: Timo Roman
- 2691: RP#58 completed / Impacted TSs and TRs: 36.101 / WI rapporteur e-mail: Timo Roman
- 2692: RP#65 completed. TR 36.904 for 1-step Approval. Testing for 36.101 / Impacted TSs and TRs: 36.508, 36.521-1, 36.521-2, New TR 36.904 / WI rapporteur e-mail: jarkko.hellsten@kolumbus.fi
- 2693: Stage 3. Exists already for 1UL a WI LTE_CA_B3_B5 / Impacted TSs and TRs: LTE / WI rapporteur e-mail: Xiaodong Shen
- 2694: RP#57 completed / Impacted TSs and TRs: 36.211, 36.213, 36.331, 36.423 / WI rapporteur e-mail: Xiaodong Shen
- 2695: RP#60 completed / Impacted TSs and TRs: 36.508, 36.523-1, 36.523-2, 36.523-3 / WI rapporteur e-mail: Li Xiang (tricia.li@huawei.com)
- 2696: LTE_CA_Rel-11 / Impacted TSs and TRs: LTE
- 2697: Stage 3 / Impacted TSs and TRs: LTE / WI rapporteur e-mail: lars.e.lindh@nokia.com
- 2698: RP#59 completed. New TR 36.823 v100 for Information and Approval / Impacted TSs and TRs: 36.101, 36.104, 36.133, 36.201, 36.211, 36.212, 36.213, 36.300, 36.302, 36.306, 36.321, 36.331, 36.413, 36.423, new TR 36.823 / WI rapporteur e-mail: lars.e.lindh@nokia.com
- 2699: ; Stat Rep: RP-141377->RP-141969 / Impacted TSs and TRs: 36.101, 36.104, 36.133, 36.141 / WI rapporteur e-mail: lars.e.lindh@nokia.com
- 2700: SP#65 completed / Impacted TSs and TRs: 36.508, 36.521-1, 36.521-2, 36.521-3, 36.523-1, 36.523-2, 36.523-3 / WI rapporteur e-mail: jussi.kuusisto@microsoft.com
- 2701: RP#62 completed / Impacted TSs and TRs: 36.508, 36.521-1, 36.521-2, 36.521-3, 36.523-1, 36.523-2, 36.523-3, 37.571-1 / WI rapporteur e-mail: jussi.kuusisto@nokia.com

| ID | WBS | Task | Duration | Start | Finish | Complete | Baseline start | Baseline finish | Baseline duration | Constraint | Resources | Work | Actual work | PCG approved | Release | TSG approved | MCC resp | Special Focus Doc | Acronym | WI rapporteur name | WI rapporteur e-mail | Acronym_3GU_Export | Status Report |
| --- | --- | --- | --- | --- | --- | --- | --- | --- | --- | --- | --- | --- | --- | --- | --- | --- | --- | --- | --- | --- | --- | --- | --- |
| 2702 | 641.3 | **Rel-11 inter-band Carrier Aggregation** | 528d? | 2010-12-10 A | 2012-12-07 A | 100% | 2010-12-10 | 2012-12-07 | 528d? |  | R4 | 180968h | 180968h | PCG-30 | Rel-11 | RP-58 | Issam | CA |  |  |  |  |  |
| 2703 | 641.3.1 | **LTE Advanced Carrier Aggregation of Band 3 and Band 7** | 528d? | 2010-12-10 A | 2012-12-07 A | 100% | 2010-12-10 | 2012-12-07 | 528d? |  | R4 | 12040h | 12040h | PCG-25 | Rel-11 | RP-48 | Issam | CA | LTE_CA_B3_B7 | TeliaSonera | Ralf.Schuh@TeliaSonera.com | LTE_CA_B3_B7 |  |
| 2704 | 641.3.1.1 | Core part: LTE Advanced Carrier Aggregation of Band 3 and Band 7 | 456d? | 2010-12-10 A | 2012-09-07 A | 100% | 2010-12-10 | 2012-09-07 | 456d? | finish no earlier than 2012-09-07 | R4 | 3648h | 3648h | PCG-25 | Rel-11 | RP-48 | Issam | CA | LTE_CA_B3_B7-Core | TeliaSonera | Ralf.Schuh@TeliaSonera.com | LTE_CA_B3_B7-Core | RP-121022 |
| 2705 | 641.3.1.2 | Perf. part: LTE Advanced Carrier Aggregation of Band 3 and Band 7 | 523d? | 2010-12-17 A | 2012-12-07 A | 100% | 2010-12-17 | 2012-12-07 | 523d? | finish no earlier than 2012-12-07 | R4 | 4168h | 4168h | PCG-25 | Rel-11 | RP-48 | Issam | CA | LTE_CA_B3_B7-Perf | TeliaSonera | Ralf.Schuh@TeliaSonera.com | LTE_CA_B3_B7-Perf | RP-121023 |
| 2706 | 641.3.2 | **LTE Advanced Carrier Aggregation of Band 4 and Band 17** | 528d? | 2010-12-10 A | 2012-12-07 A | 100% | 2010-12-10 | 2012-12-07 | 528d? |  | R4 | 12064h | 12064h | PCG-26 | Rel-11 | RP-50 | Issam | CA | LTE_CA_B4_B17 | AT&T | marc.grant@att.com | LTE_CA_B4_B17 |  |
| 2707 | 641.3.2.1 | Core part: LTE Advanced Carrier Aggregation of Band 4 and Band 17 | 459d? | 2010-12-10 A | 2012-09-07 A | 100% | 2010-12-10 | 2012-09-07 | 459d? | finish no earlier than 2012-09-07 | R4 | 3672h | 3672h | PCG-26 | Rel-11 | RP-50 | Issam | CA | LTE_CA_B4_B17-Core | AT&T | marc.grant@att.com | LTE_CA_B4_B17-Core | RP-121024 |
| 2708 | 641.3.2.2 | Perf. part: LTE Advanced Carrier Aggregation of Band 4 and Band 17 | 521d? | 2010-12-17 A | 2012-12-07 A | 100% | 2010-12-17 | 2012-12-07 | 521d? | finish no earlier than 2012-12-07 | R4 | 4168h | 4168h | PCG-26 | Rel-11 | RP-50 | Issam | CA | LTE_CA_B4_B17-Perf | AT&T | marc.grant@att.com | LTE_CA_B4_B17-Perf | RP-121595 |
| 2709 | 641.3.3 | **LTE Advanced Carrier Aggregation of Band 4 and Band 13** | 528d? | 2010-12-10 A | 2012-12-07 A | 100% | 2010-12-10 | 2012-12-07 | 528d? |  | R4 | 12040h | 12040h | PCG-26 | Rel-11 | RP-50 | Issam | CA | LTE_CA_B4_B13 | Ericsson | christian.bergljung@ericsson.com | LTE_CA_B4_B13 |  |
| 2710 | 641.3.3.1 | Core part: LTE Advanced Carrier Aggregation of Band 4 and Band 13 | 456d? | 2010-12-10 A | 2012-09-07 A | 100% | 2010-12-10 | 2012-09-07 | 456d? | finish no earlier than 2012-09-07 | R4 | 3648h | 3648h | PCG-26 | Rel-11 | RP-50 | Issam | CA | LTE_CA_B4_B13-Core | Ericsson | christian.bergljung@ericsson.com | LTE_CA_B4_B13-Core | RP-121026 |
| 2711 | 641.3.3.2 | Perf. part: LTE Advanced Carrier Aggregation of Band 4 and Band 13 | 521d? | 2010-12-21 A | 2012-12-07 A | 100% | 2010-12-21 | 2012-12-07 | 521d? | finish no earlier than 2012-12-07 | R4 | 4168h | 4168h | PCG-26 | Rel-11 | RP-50 | Issam | CA | LTE_CA_B4_B13-Perf | Ericsson | christian.bergljung@ericsson.com | LTE_CA_B4_B13-Perf | RP-121594 |
| 2712 | 641.3.4 | **LTE Advanced Carrier Aggregation of Band 4 and Band 12** | 456d? | 2011-03-22 A | 2012-12-07 A | 100% | 2011-03-22 | 2012-12-07 | 456d? |  | R4; R2 | 18200h | 18200h | PCG-26 | Rel-11 | RP-51 | Issam | CA | LTE_CA_B4_B12 | Leap Wireless | Bill Chandler (bchandler@cricketcommunications.com) | LTE_CA_B4_B12 |  |
| 2713 | 641.3.4.1 | Core part: LTE Advanced Carrier Aggregation of Band 4 and Band 12 | 456d? | 2011-03-22 A | 2012-12-07 A | 100% | 2011-03-22 | 2012-12-07 | 456d? | finish no earlier than 2012-12-07 | R4; R2 | 7296h | 7296h | PCG-26 | Rel-11 | RP-51 | Issam | CA | LTE_CA_B4_B12-Core | Leap Wireless | Bill Chandler (bchandler@cricketcommunications.com) | LTE_CA_B4_B12-Core | RP-121592 |
| 2714 | 641.3.4.2 | Perf. part: LTE Advanced Carrier Aggregation of Band 4 and Band 12 | 451d? | 2011-03-29 A | 2012-12-07 A | 100% | 2011-03-29 | 2012-12-07 | 451d? | finish no earlier than 2012-12-07 | R4 | 3608h | 3608h | PCG-26 | Rel-11 | RP-51 | Issam | CA | LTE_CA_B4_B12-Perf | Leap Wireless | Bill Chandler (bchandler@cricketcommunications.com) | LTE_CA_B4_B12-Perf | RP-121593 |
| 2715 | 641.3.5 | **LTE Advanced Carrier Aggregation of Band 5 and Band 12** | 456d? | 2011-03-22 A | 2012-12-07 A | 100% | 2011-03-22 | 2012-12-07 | 456d? |  | R4; R2 | 18200h | 18200h | PCG-26 | Rel-11 | RP-51 | Issam | CA | LTE_CA_B5_B12 | US Cellular | sebastian.thalanany@uscellular.com | LTE_CA_B5_B12 |  |
| 2716 | 641.3.5.1 | Core part: LTE Advanced Carrier Aggregation of Band 5 and Band 12 | 456d? | 2011-03-22 A | 2012-12-07 A | 100% | 2011-03-22 | 2012-12-07 | 456d? | finish no earlier than 2012-12-07 | R4; R2 | 7296h | 7296h | PCG-26 | Rel-11 | RP-51 | Issam | CA | LTE_CA_B5_B12-Core | US Cellular | sebastian.thalanany@uscellular.com | LTE_CA_B5_B12-Core | RP-121596 |
| 2717 | 641.3.5.2 | Perf. part: LTE Advanced Carrier Aggregation of Band 5 and Band 12 | 451d? | 2011-03-25 A | 2012-12-07 A | 100% | 2011-03-25 | 2012-12-07 | 451d? | finish no earlier than 2012-12-07 | R4 | 3608h | 3608h | PCG-26 | Rel-11 | RP-51 | Issam | CA | LTE_CA_B5_B12-Perf | US Cellular | sebastian.thalanany@uscellular.com | LTE_CA_B5_B12-Perf | RP-121597 |
| 2718 | 641.3.6 | **LTE Advanced Carrier Aggregation of Band 7 and Band 20** | 389d? | 2011-03-22 A | 2012-09-07 A | 100% | 2011-03-22 | 2012-09-07 | 389d? |  | R4 | 9288h | 9288h | PCG-26 | Rel-11 | RP-51 | Issam | CA | LTE_CA_B7_B20 | Huawei | Steven Chen | LTE_CA_B7_B20 |  |
| 2719 | 641.3.6.1 | Core part: LTE Advanced Carrier Aggregation of Band 7 and Band 20 | 386d? | 2011-03-22 A | 2012-09-07 A | 100% | 2011-03-22 | 2012-09-07 | 386d? | finish no earlier than 2012-09-07 | R4 | 3088h | 3088h | PCG-26 | Rel-11 | RP-51 | Issam | CA | LTE_CA_B7_B20-Core | Huawei | Steven Chen | LTE_CA_B7_B20-Core | RP-121032 |
| 2720 | 641.3.6.2 | Perf. part: LTE Advanced Carrier Aggregation of Band 7 and Band 20 | 386d? | 2011-03-25 A | 2012-09-07 A | 100% | 2011-03-25 | 2012-09-07 | 386d? | finish no earlier than 2012-09-07 | R4 | 3088h | 3088h | PCG-26 | Rel-11 | RP-51 | Issam | CA | LTE_CA_B7_B20-Perf | Huawei | Steven Chen | LTE_CA_B7_B20-Perf | RP-121033 |
| 2721 | 641.3.7 | **LTE Advanced Carrier Aggregation of Band 2 and Band 17** | 455d? | 2011-03-23 A | 2012-12-07 A | 100% | 2011-03-23 | 2012-12-07 | 455d? |  | R4 | 10336h | 10336h | PCG-26 | Rel-11 | RP-51 | Issam | CA | LTE_CA_B2_B17 | AT&T | marc.grant@att.com | LTE_CA_B2_B17 |  |
| 2722 | 641.3.7.1 | Core part: LTE Advanced Carrier Aggregation of Band 2 and Band 17 | 386d? | 2011-03-23 A | 2012-09-07 A | 100% | 2011-03-23 | 2012-09-07 | 386d? | finish no earlier than 2012-09-07 | R4 | 3088h | 3088h | PCG-26 | Rel-11 | RP-51 | Issam | CA | LTE_CA_B2_B17-Core | AT&T | marc.grant@att.com | LTE_CA_B2_B17-Core | RP-121034 |
| 2723 | 641.3.7.2 | Perf. part: LTE Advanced Carrier Aggregation of Band 2 and Band 17 | 451d? | 2011-03-25 A | 2012-12-07 A | 100% | 2011-03-25 | 2012-12-07 | 451d? | finish no earlier than 2012-12-07 | R4 | 3608h | 3608h | PCG-26 | Rel-11 | RP-51 | Issam | CA | LTE_CA_B2_B17-Perf | AT&T | marc.grant@att.com | LTE_CA_B2_B17-Perf | RP-121585 |
| 2724 | 641.3.8 | **LTE Advanced Carrier Aggregation of Band 4 and Band 5** | 455d? | 2011-03-23 A | 2012-12-07 A | 100% | 2011-03-23 | 2012-12-07 | 455d? |  | R4 | 10856h | 10856h | PCG-26 | Rel-11 | RP-51 | Issam | CA | LTE_CA_B4_B5 | AT&T | marc.grant@att.com | LTE_CA_B4_B5 |  |
| 2725 | 641.3.8.1 | Core part: LTE Advanced Carrier Aggregation of Band 4 and Band 5 | 451d? | 2011-03-23 A | 2012-12-07 A | 100% | 2011-03-23 | 2012-12-07 | 451d? | finish no earlier than 2012-12-07 | R4 | 3608h | 3608h | PCG-26 | Rel-11 | RP-51 | Issam | CA | LTE_CA_B4_B5-Core | AT&T | marc.grant@att.com | LTE_CA_B4_B5-Core | RP-121757 |
| 2726 | 641.3.8.2 | Perf. part: LTE Advanced Carrier Aggregation of Band 4 and Band 5 | 451d? | 2011-03-25 A | 2012-12-07 A | 100% | 2011-03-25 | 2012-12-07 | 451d? | finish no earlier than 2012-12-07 | R4 | 3608h | 3608h | PCG-26 | Rel-11 | RP-51 | Issam | CA | LTE_CA_B4_B5-Perf | AT&T | marc.grant@att.com | LTE_CA_B4_B5-Perf | RP-121589 |

Notes:
- 2702: LTE_CA_Rel-11 / Impacted TSs and TRs: LTE
- 2703: RP#57 completed. In Europe Band 3,7,20 are interesting for LTE and LTE-Advanced deployment. Different CA combinations for these bands are of high priority for Region 1 / Impacted TSs and TRs: LTE
- 2704: RP#57 completed. RP#59 new generic TR 36.850v100 for Information and Approval / Impacted TSs and TRs: 36.101, 36.104, 36.307, new generic TR 36.850
- 2705: RP#57 completed / Impacted TSs and TRs: 36.133, 36.141
- 2706: Stage 3. RP#57 Core completed. RP#58 Perf completed / Impacted TSs and TRs: LTE
- 2707: RP#57 completed. RP#59 new generic TR 36.850v100 for Information and Approval / Impacted TSs and TRs: 36.101, 36.104, 36.133, 36.141, 36.307, new generic TR 36.850
- 2708: RP#58 completed / Impacted TSs and TRs: 36.101, 36.104, 36.133, 36.307
- 2709: Stage 3. RP#57 Core completed. RP#58 Perf completed / Impacted TSs and TRs: LTE
- 2710: RP#57 completed / Impacted TSs and TRs: 36.101, 36.104, 36.133, 36.307, new generic TR 36.850
- 2711: RP#58 completed / Impacted TSs and TRs: 36.101, 36.133, 36.141
- 2712: Stage 3. RP#58 completed / Impacted TSs and TRs: LTE
- 2713: RP#58 completed. RP#59 new generic TR 36.850v100 for Information and Approval / Impacted TSs and TRs: 36.101, 36.104, 36.307, new generic TR 36.850
- 2714: RP#58 completed / Impacted TSs and TRs: 36.133, 36.141
- 2715: Stage 3. RP#58 completed / Impacted TSs and TRs: LTE
- 2716: RP#58 completed. RP#59 new generic TR 36.850v100 for Information and Approval / Impacted TSs and TRs: 36.101, 36.104, 36.133, 36.141, 36.307, new generic TR 36.850
- 2717: RP#58 completed / Impacted TSs and TRs: 36.101, 36.104, 36.133, 36.307
- 2718: Stage 3. RP#57 completed / Impacted TSs and TRs: LTE
- 2719: RP#57 completed. RP#59 new generic TR 36.850v100 for Information and Approval / Impacted TSs and TRs: 36.101, 36.104, 36.307, new generic TR 36.850
- 2720: RP#57 completed / Impacted TSs and TRs: 36.133, 36.141
- 2721: Stage 3. RP#57 Core completed. RP#58 Perf completed / Impacted TSs and TRs: LTE
- 2722: RP#57 completed. RP#59 new generic TR 36.850v100 for Information and Approval / Impacted TSs and TRs: 36.101, 36.104, 36.133, 36.141, 36.307, new generic TR 36.850
- 2723: RP#58 completed / Impacted TSs and TRs: 36.101, 36.104, 36.133, 36.307
- 2724: Stage 3. RP#58 completed / Impacted TSs and TRs: LTE
- 2725: RP#58 completed. RP#59 new generic TR 36.850v100 for Information and Approval / Impacted TSs and TRs: 36.101, 36.104, 36.133, 36.141, 36.307, new generic TR 36.850
- 2726: RP#58 completed / Impacted TSs and TRs: 36.101, 36.104, 36.133, 36.307

| ID | WBS | Task | Duration | Start | Finish | Complete | Baseline start | Baseline finish | Baseline duration | Constraint | Resources | Work | Actual work | Acronym | PCG approved | WI rapporteur name | WI rapporteur e-mail | Release | TSG approved | MCC resp | Special Focus Doc | Acronym_3GU_Export | Status Report |
| --- | --- | --- | --- | --- | --- | --- | --- | --- | --- | --- | --- | --- | --- | --- | --- | --- | --- | --- | --- | --- | --- | --- | --- |
| 2727 | 641.3.9 | **LTE Advanced Carrier Aggregation of Band 5 and Band 17** | 455d? | 2011-03-23 A | 2012-12-07 A | 100% | 2011-03-23 | 2012-12-07 | 455d? |  | R4 | 10856h | 10856h | LTE_CA_B5_B17 | PCG-26 | AT&T | marc.grant@att.com | Rel-11 | RP-51 | Issam | CA | LTE_CA_B5_B17 |  |
| 2728 | 641.3.9.1 | Core part: LTE Advanced Carrier Aggregation of Band 5 and Band 17 | 451d? | 2011-03-23 A | 2012-12-07 A | 100% | 2011-03-23 | 2012-12-07 | 451d? | finish no earlier than 2012-12-07 | R4 | 3608h | 3608h | LTE_CA_B5_B17-Core | PCG-26 | AT&T | marc.grant@att.com | Rel-11 | RP-51 | Issam | CA | LTE_CA_B5_B17-Core | RP-121598 |
| 2729 | 641.3.9.2 | Perf. part: LTE Advanced Carrier Aggregation of Band 5 and Band 17 | 451d? | 2011-03-25 A | 2012-12-07 A | 100% | 2011-03-25 | 2012-12-07 | 451d? | finish no earlier than 2012-12-07 | R4 | 3608h | 3608h | LTE_CA_B5_B17-Perf | PCG-26 | AT&T | marc.grant@att.com | Rel-11 | RP-51 | Issam | CA | LTE_CA_B5_B17-Perf | RP-121599 |
| 2730 | 641.3.10 | **LTE Advanced Carrier Aggregation of Band 3 and Band 20** | 258d? | 2011-09-19 A | 2012-09-07 A | 100% | 2011-09-19 | 2012-09-07 | 258d? |  | R4 | 6168h | 6168h | LTE_CA_B3_B20 | PCG-27 | Vodafone | tim.frost@vodafone.com | Rel-11 | RP-53 | Issam | CA | LTE_CA_B3_B20 |  |
| 2731 | 641.3.10.1 | Core part: LTE Advanced Carrier Aggregation of Band 3 and Band 20 | 256d? | 2011-09-19 A | 2012-09-07 A | 100% | 2011-09-19 | 2012-09-07 | 256d? | finish no earlier than 2012-09-07 | R4 | 2048h | 2048h | LTE_CA_B3_B20-Core | PCG-27 | Vodafone | tim.frost@vodafone.com | Rel-11 | RP-53 | Issam | CA | LTE_CA_B3_B20-Core | RP-121046 |
| 2732 | 641.3.10.2 | Perf. part: LTE Advanced Carrier Aggregation of Band 3 and Band 20 | 257d? | 2011-09-20 A | 2012-09-07 A | 100% | 2011-09-20 | 2012-09-07 | 257d? | finish no earlier than 2012-09-07 | R4 | 2056h | 2056h | LTE_CA_B3_B20-Perf | PCG-27 | Vodafone | tim.frost@vodafone.com | Rel-11 | RP-53 | Issam | CA | LTE_CA_B3_B20-Perf | RP-121047 |
| 2733 | 641.3.11 | **LTE Advanced Carrier Aggregation of Band 8 and Band 20** | 325d? | 2011-09-19 A | 2012-12-07 A | 100% | 2011-09-19 | 2012-12-07 | 325d? |  | R4 | 7752h | 7752h | LTE_CA_B8_B20 | PCG-27 | Vodafone | Luis.Anaya@vodafone.com | Rel-11 | RP-53 | Issam | CA | LTE_CA_B8_B20 |  |
| 2734 | 641.3.11.1 | Core part: LTE Advanced Carrier Aggregation of Band 8 and Band 20 | 323d? | 2011-09-19 A | 2012-12-07 A | 100% | 2011-09-19 | 2012-12-07 | 323d? | finish no earlier than 2012-12-07 | R4 | 2584h | 2584h | LTE_CA_B8_B20-Core | PCG-27 | Vodafone | Luis.Anaya@vodafone.com | Rel-11 | RP-53 | Issam | CA | LTE_CA_B8_B20-Core | RP-121600 |
| 2735 | 641.3.11.2 | Perf. part: LTE Advanced Carrier Aggregation of Band 8 and Band 20 | 321d? | 2011-09-23 A | 2012-12-07 A | 100% | 2011-09-23 | 2012-12-07 | 321d? | finish no earlier than 2012-12-07 | R4 | 2568h | 2568h | LTE_CA_B8_B20-Perf | PCG-27 | Vodafone | Luis.Anaya@vodafone.com | Rel-11 | RP-53 | Issam | CA | LTE_CA_B8_B20-Perf | RP-121601 |
| 2736 | 641.3.12 | **LTE Advanced Carrier Aggregation of Band 3 and Band 5** | 258d? | 2011-09-19 A | 2012-09-07 A | 100% | 2011-09-19 | 2012-09-07 | 258d? |  | R4 | 6160h | 6160h | LTE_CA_B3_B5 | PCG-27 | SK Telecom | Haesung Park | Rel-11 | RP-53 | Issam | CA | LTE_CA_B3_B5 |  |
| 2737 | 641.3.12.1 | Core part: LTE Advanced Carrier Aggregation of Band 3 and Band 5 | 256d? | 2011-09-19 A | 2012-09-07 A | 100% | 2011-09-19 | 2012-09-07 | 256d? | finish no earlier than 2012-09-07 | R4 | 2048h | 2048h | LTE_CA_B3_B5-Core | PCG-27 | SK Telecom | Haesung Park | Rel-11 | RP-53 | Issam | CA | LTE_CA_B3_B5-Core | RP-121042 |
| 2738 | 641.3.12.2 | Perf. part: LTE Advanced Carrier Aggregation of Band 3 and Band 5 | 256d? | 2011-09-21 A | 2012-09-07 A | 100% | 2011-09-21 | 2012-09-07 | 256d? | finish no earlier than 2012-09-07 | R4 | 2048h | 2048h | LTE_CA_B3_B5-Perf | PCG-27 | SK Telecom | Haesung Park | Rel-11 | RP-53 | Issam | CA | LTE_CA_B3_B5-Perf | RP-121043 |
| 2739 | 641.3.13 | **LTE Advanced Carrier Aggregation of Band 4 and Band 7** | 325d? | 2011-09-19 A | 2012-12-07 A | 100% | 2011-09-19 | 2012-12-07 | 325d? |  | R4 | 7744h | 7744h | LTE_CA_B4_B7 | PCG-27 | Rogers Wireless | takwing.wan@rci.rogers.com | Rel-11 | RP-53 | Issam | CA | LTE_CA_B4_B7 |  |
| 2740 | 641.3.13.1 | Core part: LTE Advanced Carrier Aggregation of Band 4 and Band 7 | 322d? | 2011-09-19 A | 2012-12-07 A | 100% | 2011-09-19 | 2012-12-07 | 322d? | finish no earlier than 2012-12-07 | R4 | 2576h | 2576h | LTE_CA_B4_B7-Core | PCG-27 | Rogers Wireless | takwing.wan@rci.rogers.com | Rel-11 | RP-53 | Issam | CA | LTE_CA_B4_B7-Core | RP-121590 |
| 2741 | 641.3.13.2 | Perf. part: LTE Advanced Carrier Aggregation of Band 4 and Band 7 | 321d? | 2011-09-23 A | 2012-12-07 A | 100% | 2011-09-23 | 2012-12-07 | 321d? | finish no earlier than 2012-12-07 | R4 | 2568h | 2568h | LTE_CA_B4_B7-Perf | PCG-27 | Rogers Wireless | takwing.wan@rci.rogers.com | Rel-11 | RP-53 | Issam | CA | LTE_CA_B4_B7-Perf | RP-121591 |
| 2742 | 641.3.14 | **LTE Advanced Carrier Aggregation of Band 11 and Band 18** | 265d? | 2011-12-09 A | 2012-12-07 A | 100% | 2011-12-09 | 2012-12-07 | 265d? |  | R4; R2 | 10568h | 10568h | LTE_CA_B11_B18 | PCG-28 | KDDI | Masaaki Obara (ms-obara@kddi.com) | Rel-11 | RP-54 | Issam | CA | LTE_CA_B11_B18 |  |
| 2743 | 641.3.14.1 | Core part: LTE Advanced Carrier Aggregation of Band 11 and Band 18 | 265d? | 2011-12-09 A | 2012-12-07 A | 100% | 2011-12-09 | 2012-12-07 | 265d? | finish no earlier than 2012-12-07 | R4; R2 | 4240h | 4240h | LTE_CA_B11_B18-Core | PCG-28 | KDDI | Masaaki Obara (ms-obara@kddi.com) | Rel-11 | RP-54 | Issam | CA | LTE_CA_B11_B18-Core | RP-121602 |
| 2744 | 641.3.14.2 | Perf. part: LTE Advanced Carrier Aggregation of Band 11 and Band 18 | 261d? | 2011-12-15 A | 2012-12-07 A | 100% | 2011-12-15 | 2012-12-07 | 261d? | finish no earlier than 2012-12-07 | R4 | 2088h | 2088h | LTE_CA_B11_B18-Perf | PCG-28 | KDDI | Masaaki Obara (ms-obara@kddi.com) | Rel-11 | RP-54 | Issam | CA | LTE_CA_B11_B18-Perf | RP-121603 |
| 2745 | 641.3.15 | **LTE Advanced Carrier Aggregation of Band 1 and Band 18** | 198d? | 2011-12-09 A | 2012-09-07 A | 100% | 2011-12-09 | 2012-09-07 | 198d? |  | R4; R2 | 7904h | 7904h | LTE_CA_B1_B18 | PCG-28 | KDDI | Masaaki Obara (ms-obara@kddi.com) | Rel-11 | RP-54 | Issam | CA | LTE_CA_B1_B18 |  |
| 2746 | 641.3.15.1 | Core part: LTE Advanced Carrier Aggregation of Band 1 and Band 18 | 198d? | 2011-12-09 A | 2012-09-07 A | 100% | 2011-12-09 | 2012-09-07 | 198d? | finish no earlier than 2012-09-07 | R4; R2 | 3168h | 3168h | LTE_CA_B1_B18-Core | PCG-28 | KDDI | Masaaki Obara (ms-obara@kddi.com) | Rel-11 | RP-54 | Issam | CA | LTE_CA_B1_B18-Core | RP-121052 |
| 2747 | 641.3.15.2 | Perf. part: LTE Advanced Carrier Aggregation of Band 1 and Band 18 | 196d? | 2011-12-13 A | 2012-09-07 A | 100% | 2011-12-13 | 2012-09-07 | 196d? | finish no earlier than 2012-12-07 | R4 | 1568h | 1568h | LTE_CA_B1_B18-Perf | PCG-28 | KDDI | Masaaki Obara (ms-obara@kddi.com) | Rel-11 | RP-54 | Issam | CA | LTE_CA_B1_B18-Perf | RP-121053 |
| 2748 | 641.3.16 | **LTE Advanced Carrier Aggregation of Band 1 and Band 19** | 197d? | 2011-12-12 A | 2012-09-07 A | 100% | 2011-12-12 | 2012-09-07 | 197d? |  | R4; R2 | 6432h | 6432h | LTE_CA_B1_B19 | PCG-28 | NTT DoCoMo | Hiromasa Umeda (umedah@nttdocomo.co.jp) | Rel-11 | RP-54 | Issam | CA | LTE_CA_B1_B19 |  |
| 2749 | 641.3.16.1 | Core part: LTE Advanced Carrier Aggregation of Band 1 and Band 19 | 137d? | 2012-03-05 A | 2012-09-07 A | 100% | 2012-03-05 | 2012-09-07 | 137d? | finish no earlier than 2012-09-07 | R4; R2 | 2192h | 2192h | LTE_CA_B1_B19-Core | PCG-28 | NTT DoCoMo | Hiromasa Umeda (umedah@nttdocomo.co.jp) | Rel-11 | RP-54 | Issam | CA | LTE_CA_B1_B19-Core | RP-120552 |
| 2750 | 641.3.16.2 | Perf. part: LTE Advanced Carrier Aggregation of Band 1 and Band 19 | 136d? | 2011-12-12 A | 2012-06-15 A | 100% | 2011-12-12 | 2012-06-15 | 136d? | finish no earlier than 2012-12-07 | R4 | 1088h | 1088h | LTE_CA_B1_B19-Perf | PCG-28 | NTT DoCoMo | Hiromasa Umeda (umedah@nttdocomo.co.jp) | Rel-11 | RP-54 | Issam | CA | LTE_CA_B1_B19-Perf | RP-120553 |

Notes:
- 2727: Stage 3. RP#58 completed / Impacted TSs and TRs: LTE
- 2728: RP#58 completed. RP#59 new generic TR 36.850v100 for Information and Approval / Impacted TSs and TRs: 36.101, 36.104, 36.133, 36.141, 36.307, new generic TR 36.850
- 2729: RP#58 completed / Impacted TSs and TRs: 36.101, 36.104, 36.133, 36.141, 36.307
- 2730: Stage 3. RP#57 completed / Impacted TSs and TRs: LTE
- 2731: RP#57 completed. RP#59 new generic TR 36.850v100 for Information and Approval / Impacted TSs and TRs: 36.101, 36.104, 36.133, 36.307, new generic TR 36.850
- 2732: RP#57 completed / Impacted TSs and TRs: 36.101, 36.104, 36.133, 36.141, 36.307
- 2733: Stage 3. RP#58 completed / Impacted TSs and TRs: LTE
- 2734: RP#58 completed. RP#59 new generic TR 36.850v100 for Information and Approval / Impacted TSs and TRs: 36.101, 36.104, 36.307, new generic TR 36.850
- 2735: RP#58 completed / Impacted TSs and TRs: 36.101, 36.104, 36.133, 36.141
- 2736: Stage 3. RP#57 completed / Impacted TSs and TRs: LTE
- 2737: RP#57 completed. RP#59 new generic TR 36.850v100 for Information and Approval / Impacted TSs and TRs: 36.101, 36.104, 36.133, 36.307, new generic TR 36.850
- 2738: RP#57 completed / Impacted TSs and TRs: 36.133, 36.141
- 2739: Stage 3. RP#58 completed / Impacted TSs and TRs: LTE
- 2740: RP#58 completed. RP#59 new generic TR 36.850v100 for Information and Approval / Impacted TSs and TRs: 36.101, 36.104, 36.133, 36.141, 36.307, 37.104, new generic TR 36.850
- 2741: RP#58 completed / Impacted TSs and TRs: 36.101, 36.104, 36.133, 36.141, 36.307
- 2742: Stage 3. RP#58 completed / Impacted TSs and TRs: LTE
- 2743: RP#58 completed. RP#59 new generic TR 36.850v100 for Information and Approval / Impacted TSs and TRs: 36.101, 36.104, 36.307, new generic TR 36.850
- 2744: RP#58 completed / Impacted TSs and TRs: 36.133
- 2745: Stage 3. RP#57 completed / Impacted TSs and TRs: LTE
- 2746: RP#57 completed. RP#59 new generic TR 36.850v100 for Information and Approval / Impacted TSs and TRs: 36.101, 36.104, 36.307, new generic TR 36.850
- 2747: RP#57 completed / Impacted TSs and TRs: 36.133, 36.141
- 2748: Stage 3. RP#56 completed. Updated WID RP-111765=>RP-120866 / Impacted TSs and TRs: LTE
- 2749: RP#56 completed. RP#59 new generic TR 36.850v100 for Information and Approval / Impacted TSs and TRs: 36.101, 36.104, 36.133, 36.307, new generic TR 36.850
- 2750: RP#56 completed / Impacted TSs and TRs: 36.133, 36.141

| ID | WBS | Task | Duration | Start | Finish | Complete | Remaining | Baseline start | Baseline finish | Baseline duration | Total slack | Constraint | Resources | Work | Actual work | Acronym | PCG approved | WI rapporteur name | Release | TSG approved | MCC resp | Special Focus Doc | Acronym_3GU_Export | Status Report |
| --- | --- | --- | --- | --- | --- | --- | --- | --- | --- | --- | --- | --- | --- | --- | --- | --- | --- | --- | --- | --- | --- | --- | --- | --- |
| 2751 | 641.3.17 | **LTE Advanced Carrier Aggregation of Band 1 and Band 21** | 265d? | 2011-12-09 A | 2012-12-07 A | 100% |  | 2011-12-09 | 2012-12-07 | 265d? |  |  | R4; R2 | 9496h | 9496h | LTE_CA_B1_B21 | PCG-28 | NTT DoCoMo | Rel-11 | RP-54 | Issam | CA | LTE_CA_B1_B21 |  |
| 2752 | 641.3.17.1 | Core part: LTE Advanced Carrier Aggregation of Band 1 and Band 21 | 198d? | 2011-12-09 A | 2012-09-07 A | 100% |  | 2011-12-09 | 2012-09-07 | 198d? |  | finish no earlier than 2012-09-07 | R4; R2 | 3168h | 3168h | LTE_CA_B1_B21-Core | PCG-28 | NTT DoCoMo | Rel-11 | RP-54 | Issam | CA | LTE_CA_B1_B21-Core | RP-121054 |
| 2753 | 641.3.17.2 | Perf. part: LTE Advanced Carrier Aggregation of Band 1 and Band 21 | 263d? | 2011-12-13 A | 2012-12-07 A | 100% |  | 2011-12-13 | 2012-12-07 | 263d? |  | finish no earlier than 2012-12-07 | R4 | 2088h | 2088h | LTE_CA_B1_B21-Perf | PCG-28 | NTT DoCoMo | Rel-11 | RP-54 | Issam | CA | LTE_CA_B1_B21-Perf | RP-121055 |
| 2754 | 641.3.18 | **LTE Advanced Carrier Aggregation of Band 3 and Band 8** | 204d? | 2012-03-05 A | 2012-12-07 A | 100% |  | 2012-03-05 | 2012-12-07 | 204d? |  |  | R4 | 4864h | 4864h | LTE_CA_B3_B8 | PCG-28 | KT | Rel-11 | RP-55 | Issam | CA | LTE_CA_B3_B8 |  |
| 2755 | 641.3.18.1 | Core part: LTE Advanced Carrier Aggregation of Band 3 and Band 8 | 201d? | 2012-03-05 A | 2012-12-07 A | 100% |  | 2012-03-05 | 2012-12-07 | 201d? |  | finish no earlier than 2012-12-07 | R4 | 1608h | 1608h | LTE_CA_B3_B8-Core | PCG-28 | KT | Rel-11 | RP-55 | Issam | CA | LTE_CA_B3_B8-Core | RP-121586 |
| 2756 | 641.3.18.2 | Perf. part: LTE Advanced Carrier Aggregation of Band 3 and Band 8 | 203d? | 2012-03-06 A | 2012-12-07 A | 100% |  | 2012-03-06 | 2012-12-07 | 203d? |  | finish no earlier than 2012-12-07 | R4 | 1624h | 1624h | LTE_CA_B3_B8-Perf | PCG-28 | KT | Rel-11 | RP-55 | Issam | CA | LTE_CA_B3_B8-Perf | RP-121587 |
| 2757 | 641.4 | **Rel-11 intra-band Carrier Aggregation** | 334d? | 2011-06-07 A | 2012-09-07 A | 100% |  | 2011-06-07 | 2012-09-07 | 334d? |  |  | RP | 18864h | 18864h |  | PCG-30 |  | Rel-11 | RP-58 |  | CA |  |  |
| 2758 | 641.4.1 | **LTE Advanced Carrier Aggregation in Band 38** | 334d? | 2011-06-07 A | 2012-09-07 A | 100% |  | 2011-06-07 | 2012-09-07 | 334d? |  |  | R4 | 7976h | 7976h | LTE_CA_B38 | PCG-27 | Huawei | Rel-11 | RP-52 | Issam | CA | LTE_CA_B38 |  |
| 2759 | 641.4.1.1 | Core part: LTE Advanced Carrier Aggregation in Band 38 | 331d? | 2011-06-07 A | 2012-09-07 A | 100% |  | 2011-06-07 | 2012-09-07 | 331d? |  | finish no earlier than 2012-09-07 | R4 | 2648h | 2648h | LTE_CA_B38-Core | PCG-27 | Huawei | Rel-11 | RP-52 | Issam | CA | LTE_CA_B38-Core | RP-121060 |
| 2760 | 641.4.1.2 | Perf. part: LTE Advanced Carrier Aggregation in Band 38 | 333d? | 2011-06-08 A | 2012-09-07 A | 100% |  | 2011-06-08 | 2012-09-07 | 333d? |  | finish no earlier than 2012-09-07 | R4 | 2656h | 2656h | LTE_CA_B38-Perf | PCG-27 | Huawei | Rel-11 | RP-52 | Issam | CA | LTE_CA_B38-Perf | RP-121061 |
| 2761 | 641.4.2 | **LTE Advanced Carrier Aggregation in Band 41** | 197d? | 2011-06-07 A | 2012-03-02 A | 100% |  | 2011-06-07 | 2012-03-02 | 197d? |  |  | R4 | 4720h | 4720h | LTE_CA_B41 | PCG-27 | Clearwire | Rel-11 | RP-52 | Issam | CA | LTE_CA_B41 |  |
| 2762 | 641.4.2.1 | Core part: LTE Advanced Carrier Aggregation in Band 41 | 196d? | 2011-06-07 A | 2012-03-02 A | 100% |  | 2011-06-07 | 2012-03-02 | 196d? |  | finish no earlier than 2012-02-23 | R4 | 1568h | 1568h | LTE_CA_B41-Core | PCG-27 | Clearwire | Rel-11 | RP-52 | Issam | CA | LTE_CA_B41-Core | RP-120126 |
| 2763 | 641.4.2.2 | Perf. part: LTE Advanced Carrier Aggregation in Band 41 | 197d? | 2011-06-07 A | 2012-03-02 A | 100% |  | 2011-06-07 | 2012-03-02 | 197d? |  | finish no earlier than 2012-03-02 | R4 | 1576h | 1576h | LTE_CA_B41-Perf | PCG-27 | Clearwire | Rel-11 | RP-52 | Issam | CA | LTE_CA_B41-Perf | RP-120127 |
| 2764 | 641.4.3 | **LTE Advanced Carrier Aggregation in Band 7** | 258d? | 2011-09-19 A | 2012-09-07 A | 100% |  | 2011-09-19 | 2012-09-07 | 258d? |  |  | R4 | 6168h | 6168h | LTE_CA_B7 | PCG-27 | China Unicom | Rel-11 | RP-53 | Issam | CA | LTE_CA_B7 |  |
| 2765 | 641.4.3.1 | Core part: LTE Advanced Carrier Aggregation in Band 7 | 256d? | 2011-09-19 A | 2012-09-07 A | 100% |  | 2011-09-19 | 2012-09-07 | 256d? |  | finish no earlier than 2012-09-07 | R4 | 2048h | 2048h | LTE_CA_B7-Core | PCG-27 | China Unicom | Rel-11 | RP-53 | Issam | CA | LTE_CA_B7-Core | RP-121062 |
| 2766 | 641.4.3.2 | Perf. part: LTE Advanced Carrier Aggregation in Band 7 | 257d? | 2011-09-20 A | 2012-09-07 A | 100% |  | 2011-09-20 | 2012-09-07 | 257d? |  | finish no earlier than 2012-09-07 | R4 | 2056h | 2056h | LTE_CA_B7-Perf | PCG-27 | China Unicom | Rel-11 | RP-53 | Issam | CA | LTE_CA_B7-Perf | RP-121063 |
| 2767 | 642 | **UE Over The Air (Antenna) conformance testing methodology - Laptop mounted equipment Free Space test** | 1842d? | 2009-09-18 A | 2016-09-15 | 99% | 0d? | 2009-09-18 | 2014-12-05 | 1374d? | 0d |  | R4; R5 | 45192h | 25064h | UEAnt_FSTest | PCG-23 | CATR | Rel-11 | RP-45 | Issam |  | UEAnt_FSTest |  |
| 2768 | 642.1 | Core part: UE Over The Air (Antenna) conformance testing methodology - Laptop mounted equipment Free Space test | 583d? | 2009-09-18 A | 2011-12-09 A | 100% |  | 2009-09-18 | 2011-12-09 | 583d? |  | finish no earlier than 2011-12-09 | R4 | 4664h | 4664h | UEAnt_FSTest-Core | PCG-23 | CATR | Rel-11 | RP-45 | Issam |  | UEAnt_FSTest-Core | RP-111456 |
| 2769 | 642.2 | Test part: UE Over The Air (Antenna) conformance testing methodology - Laptop mounted equipment Free Space test | 1388d? | 2011-06-15 A | 2016-09-15 A | 100% |  | 2011-06-07 | 2014-12-05 | 926d? |  | finish no earlier than 2016-09-15 | R5 | 11056h | 11056h | UEAnt_FSTest-UEConTest | PCG-27 | ZTE | Rel-11 | RP-52 | Ingbert |  | UEAnt_FSTest-UEConTest | RP-151187 |
| 2770 | 643 | **Eight carrier HSDPA** | 589d? | 2010-09-15 A | 2012-12-07 A | 100% |  | 2010-09-15 | 2012-12-07 | 589d? |  |  | R1; R2; R3; R4 | 37768h | 37768h | 8C_HSDPA | PCG-26 | Ericsson | Rel-11 | RP-50 | Patrick |  | 8C_HSDPA |  |
| 2771 | 643.1 | Core part: Eight carrier HSDPA | 461d? | 2010-09-15 A | 2012-06-15 A | 100% |  | 2010-09-15 | 2012-06-15 | 461d? |  | finish no earlier than 2012-06-15 | R1; R2; R3; R4 | 14752h | 14752h | 8C_HSDPA-Core | PCG-26 | Ericsson | Rel-11 | RP-50 | Patrick |  | 8C_HSDPA-Core | RP-120971 |
| 2772 | 643.2 | Perf. part: Eight carrier HSDPA | 523d? | 2010-12-15 A | 2012-12-07 A | 100% |  | 2010-12-15 | 2012-12-07 | 523d? |  | finish no earlier than 2012-12-07 | R4 | 4168h | 4168h | 8C_HSDPA-Perf | PCG-26 | Ericsson | Rel-11 | RP-50 | Issam |  | 8C_HSDPA-Perf | RP-120972 |
| 2773 | 644 | **UE demodulation performance requirements under multiple-cell scenario for 1.28Mcps TDD** | 324d? | 2010-12-10 A | 2012-03-02 A | 100% |  | 2010-12-10 | 2012-03-02 | 324d? |  |  | R4; R5 | 7760h | 7760h | LCR_TDD_UE_demod_mc | PCG-26 | China Mobile | Rel-11 | RP-50 | Issam |  | LCR_TDD_UE_demod_mc |  |
| 2774 | 644.1 | Perf. part: UE demodulation performance requirements under multiple-cell scenario for 1.28Mcps TDD | 201d? | 2010-12-10 A | 2011-09-16 A | 100% |  | 2010-12-10 | 2011-09-16 | 201d? |  | finish no earlier than 2011-09-16 | R4 | 1608h | 1608h | LCR_TDD_UE_demod_mc-Perf | PCG-26 | China Mobile | Rel-11 | RP-50 | Issam |  | LCR_TDD_UE_demod_mc-Perf | RP-110996 |
| 2775 | 644.2 | Test part: UE demodulation performance requirements under multiple-cell scenario for 1.28Mcps TDD | 121d? | 2011-09-19 A | 2012-03-02 A | 100% |  | 2011-09-19 | 2012-03-02 | 121d? |  | finish no earlier than 2012-02-23 | R5 | 968h | 968h | LCR_TDD_UE_demod_mc-UEConTest | PCG-27 | China Mobile | Rel-11 | RP-53 | Ingbert |  | LCR_TDD_UE_demod_mc-UEConTest | RP-120052 |

Notes:
- 2751: Stage 3. RP#57 completed. Updated WID RP-111764=>RP-121173 / Impacted TSs and TRs: LTE / WI rapporteur e-mail: Hiromasa Umeda (umedah@nttdocomo.co.jp)
- 2752: RP#57 completed. RP#59 new generic TR 36.850v100 for Information and Approval / Impacted TSs and TRs: 36.101, 36.104, 36.133, 36.307, new generic TR 36.850 / WI rapporteur e-mail: Hiromasa Umeda (umedah@nttdocomo.co.jp)
- 2753: RP#57 completed / Impacted TSs and TRs: 36.133, 36.141 / WI rapporteur e-mail: Hiromasa Umeda (umedah@nttdocomo.co.jp)
- 2754: Stage 3. RP#58 completed / Impacted TSs and TRs: LTE / WI rapporteur e-mail: Chungwoo HWANG (cwhwang@kt.com)
- 2755: RP#58 completed. RP#59 new generic TR 36.850v100 for Information and Approval / Impacted TSs and TRs: 36.101, 36.104, 36.133, 36.307, new generic TR 36.850 / WI rapporteur e-mail: Chungwoo HWANG (cwhwang@kt.com)
- 2756: RP#58 completed / Impacted TSs and TRs: 36.133, 36.141 / WI rapporteur e-mail: Chungwoo HWANG (cwhwang@kt.com)
- 2757: LTE_CA_Rel-11 / Impacted TSs and TRs: LTE
- 2758: Stage 3. RP#57 completed. WI only covers intra-band contiguous and not non-contiguous aspects / Impacted TSs and TRs: LTE / WI rapporteur e-mail: ronnie.zhang@huawei.com
- 2759: RP#57 completed. TR 36.830 v100 for Information & Approval / Impacted TSs and TRs: 36.101, 36.104, 36.133, 36.141, 36.307, 37.104, 37.141, new TR 36.833-1-38 [instead of 36.830] / WI rapporteur e-mail: ronnie.zhang@huawei.com
- 2760: RP#57 completed / Impacted TSs and TRs: 36.101, 36.104, 36.133, 36.141, 36.307, 37.104, 37.141 / WI rapporteur e-mail: ronnie.zhang@huawei.com
- 2761: RP#55 completed. WI only covers intra-band contiguous and not non-contiguous aspects. / Impacted TSs and TRs: LTE / WI rapporteur e-mail: michael.hart@clearwire.com
- 2762: RP#55 completed. Updated WID RP-110673=>RP-120249. TR 36.827 v100 for Information + Approval / Impacted TSs and TRs: 36.101, 36.104, 36.133, 36.141, 36.307, 37.104, new TR 36.833-1-41 [instead of 36.827] / WI rapporteur e-mail: michael.hart@clearwire.com
- 2763: RP#55 completed / Impacted TSs and TRs: 36.101, 36.104, 36.133, 36.141, 36.307 / WI rapporteur e-mail: michael.hart@clearwire.com
- 2764: Stage 3. RP#57 completed. Updated WID RP-111356=>RP-121193. WI only covers intra-band contiguous and not non-contiguous aspects / Impacted TSs and TRs: LTE / WI rapporteur e-mail: Zhangchao Ma (mazc@chinaunicom.cn), Zhonghao Zhang (zhangzh306@chinaunicom.cn)
- 2765: RP#57 completed. TR 36.831 v100 for Information & Approval / Impacted TSs and TRs: 36.101, 36.104, 36.133, 36.141, 36.307, 37.104, 37.141, new TR 36.833-1-07 [instead of 36.831] / WI rapporteur e-mail: Zhangchao Ma (mazc@chinaunicom.cn), Zhonghao Zhang (zhangzh306@chinaunicom.cn)
- 2766: RP#57 completed / Impacted TSs and TRs: 36.101, 36.104, 36.133, 36.141, 36.307, 37.104, 37.141 / WI rapporteur e-mail: Zhangchao Ma (mazc@chinaunicom.cn), Zhonghao Zhang (zhangzh306@chinaunicom.cn)
- 2767: - / Impacted TSs and TRs: UTRA / WI rapporteur e-mail: Guo Lin (guolin@emcite.com)
- 2768: RP#54 completed / Impacted TSs and TRs: 25.144, 25.914, 34.114 / WI rapporteur e-mail: Guo Lin (guolin@emcite.com)
- 2769: 1st Apr 15: CD:Mon 15/06/15->Wed 15/06/16 1st Apr 15: Stat Rep: RP-141846->RP-150068 03/07/15: Stat Rep: RP-150068->RP-150603 29/09/15: Stat Rep: RP-150603->RP-151187;...;... / Impacted TSs and TRs: 34.114 / WI rapporteur e-mail: carolyn.tayl@zte.com.cn
- 2770: Stage 3 / Impacted TSs and TRs: UTRA / WI rapporteur e-mail: johan.hultell@ericsson.com
- 2771: RP#57 completed / Impacted TSs and TRs: 25.101, 25.104, 25.133, 25.211, 25.212, 25.213, 25.214, 25.215, 25.308, 25.331, 25.423, 25.433, 26.306 / WI rapporteur e-mail: johan.hultell@ericsson.com
- 2772: RP#57 completed / Impacted TSs and TRs: 25.101, 25.104, 25.133, 25.141 / WI rapporteur e-mail: johan.hultell@ericsson.com
- 2773: Stage 3 / Impacted TSs and TRs: UTRA / WI rapporteur e-mail: Li Nan (linan@chinamobile.com)
- 2774: RP#53 completed. TR 25.873v100 for Approval / Impacted TSs and TRs: 25.102, new TR 25.873 / WI rapporteur e-mail: Li Nan (linan@chinamobile.com)
- 2775: RP#55 completed / Impacted TSs and TRs: 34.108, 34.122 / WI rapporteur e-mail: Ma Shuai (mashuai@chinamobile.com)

| ID | WBS | Task | Duration | Start | Finish | Complete | Baseline start | Baseline finish | Baseline duration | Constraint | Resources | Work | Actual work | Acronym | PCG approved | WI rapporteur name | WI rapporteur e-mail | Release | TSG approved | MCC resp | Acronym_3GU_Export | Status Report |
| --- | --- | --- | --- | --- | --- | --- | --- | --- | --- | --- | --- | --- | --- | --- | --- | --- | --- | --- | --- | --- | --- | --- |
| 2776 | 645 | **Uplink Transmit Diversity for HSPA** | 929d? | 2010-12-10 A | 2014-06-13 A | 100% | 2010-12-10 | 2014-06-13 | 929d? |  | R1; R4; R2; R3; R5 | 83568.3h | 83568.3h | HSPA_UL_TxDiv | PCG-26 | Huawei | zongjie.wang@huawei.com | Rel-11 | RP-50 | Patrick | HSPA_UL_TxDiv |  |
| 2777 | 645.1 | Core part: Uplink Transmit Diversity for HSPA - Closed Loop | 528d? | 2010-12-10 A | 2012-12-07 A | 100% | 2010-12-10 | 2012-12-07 | 528d? | finish no earlier than 2012-12-07 | R1; R4; R2; R3 | 16896h | 16896h | HSPA_UL_TxDiv-CL-Core | PCG-26 | Huawei | zongjie.wang@huawei.com | Rel-11 | RP-50 | Patrick | HSPA_UL_TxDiv-CL-Core | RP-121542 |
| 2778 | 645.2 | Perf. part: Uplink Transmit Diversity for HSPA - Closed Loop | 721d? | 2010-12-14 A | 2013-09-06 A | 100% | 2010-12-14 | 2013-09-06 | 721d? | finish no earlier than 2013-09-06 | R4 | 5760.31h | 5760.31h | HSPA_UL_TxDiv-CL-Perf | PCG-26 | Huawei | zongjie.wang@huawei.com | Rel-11 | RP-50 | Issam | HSPA_UL_TxDiv-CL-Perf | RP-130477 |
| 2779 | 645.3 | Core part: Uplink Transmit Diversity for HSPA - Open Loop | 528d? | 2010-12-10 A | 2012-12-07 A | 100% | 2010-12-10 | 2012-12-07 | 528d? | finish no earlier than 2012-12-07 | R4; R1; R2; R3 | 16896h | 16896h | HSPA_UL_TxDiv-OL-Core | PCG-26 | Huawei | zongjie.wang@huawei.com | Rel-11 | RP-50 | Patrick | HSPA_UL_TxDiv-OL-Core | RP-121544 |
| 2780 | 645.4 | Perf. part: Uplink Transmit Diversity for HSPA - Open Loop | 521d? | 2010-12-14 A | 2012-12-07 A | 100% | 2010-12-14 | 2012-12-07 | 521d? | finish no earlier than 2012-12-07 | R4 | 4168h | 4168h | HSPA_UL_TxDiv-OL-Perf | PCG-26 | Huawei | zongjie.wang@huawei.com | Rel-11 | RP-50 | Issam | HSPA_UL_TxDiv-OL-Perf | RP-121545 |
| 2781 | 645.5 | Test part: Uplink Transmit Diversity for HSPA | 336d? | 2013-03-04 A | 2014-06-13 A | 100% | 2013-03-04 | 2014-06-13 | 336d? | finish no earlier than 2014-06-13 | R5 | 2688h | 2688h | HSPA_UL_TxDiv-UEConTest | PCG-30 | Qualcomm | Shubhang Vora (svora@qti.qualcomm.com) | Rel-11 | RP-59 | Ingbert | HSPA_UL_TxDiv-UEConTest | RP-140767 |
| 2782 | 646 | **Introduction of New Configuration for 4C-HSDPA** | 328d? | 2011-03-22 A | 2012-06-15 A | 100% | 2011-03-22 | 2012-06-15 | 328d? |  | R4; R2 | 10928h | 10928h | 4C_HSDPA_Config | PCG-26 | Telus Communications | jorge.delrio@telus.com | Rel-11 | RP-51 | Issam | 4C_HSDPA_Config |  |
| 2783 | 646.1 | Core part: Introduction of New Configuration for 4C-HSDPA | 192d? | 2011-03-22 A | 2011-12-09 A | 100% | 2011-03-22 | 2011-12-09 | 192d? | finish no earlier than 2011-12-09 | R4; R2 | 3072h | 3072h | 4C_HSDPA_Config-Core | PCG-26 | Telus Communications | jorge.delrio@telus.com | Rel-11 | RP-51 | Issam | 4C_HSDPA_Config-Core | RP-111463 |
| 2784 | 646.2 | Perf. part: Introduction of New Configuration for 4C-HSDPA | 326d? | 2011-03-24 A | 2012-06-15 A | 100% | 2011-03-24 | 2012-06-15 | 326d? | finish no earlier than 2012-06-15 | R4 | 2608h | 2608h | 4C_HSDPA_Config-Perf | PCG-26 | Telus Communications | jorge.delrio@telus.com | Rel-11 | RP-51 | Issam | 4C_HSDPA_Config-Perf | RP-120475 |
| 2785 | 647 | **Non-contiguous 4C-HSDPA operation** | 516d? | 2011-03-23 A | 2013-03-01 A | 100% | 2011-03-23 | 2013-03-01 | 516d? |  | R4; R2; R3 | 24360h | 24360h | NC_4C_HSDPA | PCG-26 | Ericsson | muhammad.kazmi@ericsson.com | Rel-11 | RP-51 | Issam | NC_4C_HSDPA |  |
| 2786 | 647.1 | Core part: Non-contiguous 4C-HSDPA operation | 328d? | 2011-06-15 A | 2012-09-07 A | 100% | 2011-06-15 | 2012-09-07 | 328d? | finish no earlier than 2012-09-07 | R4; R2; R3 | 7872h | 7872h | NC_4C_HSDPA-Core | PCG-26 | Ericsson | muhammad.kazmi@ericsson.com | Rel-11 | RP-51 | Issam | NC_4C_HSDPA-Core | RP-120842 |
| 2787 | 647.2 | Perf. part: Non-contiguous 4C-HSDPA operation | 513d? | 2011-03-23 A | 2013-03-01 A | 100% | 2011-03-23 | 2013-03-01 | 513d? | finish no earlier than 2013-03-01 | R4 | 4104h | 4104h | NC_4C_HSDPA-Perf | PCG-26 | Ericsson | muhammad.kazmi@ericsson.com | Rel-11 | RP-51 | Issam | NC_4C_HSDPA-Perf | RP-130049 |
| 2788 | 648 | **Further Enhancements to CELL_FACH** | 1057d? | 2011-03-18 A | 2015-03-15 A | 100% | 2011-03-18 | 2014-09-12 | 924d? |  | R1; R2; R3; R4; R5 | 66320h | 66320h | Cell_FACH_enh | PCG-26 | Qualcomm | Ravi Agarwal | Rel-11 | RP-51 | Patrick | Cell_FACH_enh |  |
| 2789 | 648.1 | Core part: Further Enhancements to CELL_FACH | 458d? | 2011-03-18 A | 2012-12-07 A | 100% | 2011-03-18 | 2012-12-07 | 458d? | finish no earlier than 2012-12-07 | R2; R1; R3; R4 | 14656h | 14656h | Cell_FACH_enh-Core | PCG-26 | Qualcomm | Ravi Agarwal | Rel-11 | RP-51 | Yong-Jun | Cell_FACH_enh-Core | RP-121547 |
| 2790 | 648.2 | Perf. part: Further Enhancements to CELL_FACH | 717d? | 2011-03-24 A | 2013-12-06 A | 100% | 2011-03-24 | 2013-12-06 | 717d? | finish no earlier than 2013-12-06 | R4 | 5728h | 5728h | Cell_FACH_enh-Perf | PCG-26 | Qualcomm | Heechoon Lee (heechoon@qti.qualcomm.com) | Rel-11 | RP-51 | Issam | Cell_FACH_enh-Perf | RP-131459 |
| 2791 | 648.3 | Test part: Further Enhancements to CELL_FACH | 457d? | 2013-06-15 A | 2015-03-15 A | 100% | 2013-06-18 | 2014-09-12 | 327d? | finish no earlier than 2015-03-15 | R5 | 3656h | 3656h | Cell_FACH_enh-UEConTest | PCG-31 | Ericsson | leif.mattisson@ericsson.com | Rel-11 | RP-60 | Ingbert | Cell_FACH_enh-UEConTest | RP-150132 |
| 2792 | 649 | **HSDPA Multiflow Data Transmission** | 924d? | 2011-09-19 A | 2015-03-15 A | 100% | 2011-09-19 | 2014-12-05 | 851d? |  | R2; R1; R3; R4; R5 | 54136h | 54136h | HSDPA_MFTX | PCG-27 | Nokia Siemens Networks | Alexander Sayenko | Rel-11 | RP-53 | Yong-Jun | HSDPA_MFTX |  |
| 2793 | 649.1 | Core part: HSDPA Multiflow Data Transmission | 325d? | 2011-09-19 A | 2012-12-07 A | 100% | 2011-09-19 | 2012-12-07 | 325d? | finish no earlier than 2012-12-07 | R2; R1; R3; R4 | 10400h | 10400h | HSDPA_MFTX-Core | PCG-27 | Nokia Siemens Networks | Alexander Sayenko | Rel-11 | RP-53 | Yong-Jun | HSDPA_MFTX-Core | RP-121551 |
| 2794 | 649.2 | Perf. part: HSDPA Multiflow Data Transmission | 519d? | 2011-09-20 A | 2013-09-06 A | 100% | 2011-09-20 | 2013-09-06 | 519d? | finish no earlier than 2013-09-06 | R4 | 4152h | 4152h | HSDPA_MFTX-Perf | PCG-27 | Nokia Siemens Networks | kamil.bechta@nsn.com | Rel-11 | RP-53 | Issam | HSDPA_MFTX-Perf | RP-130959 |
| 2795 | 649.3 | Test part: HSDPA Multiflow Data Transmission | 328d? | 2013-12-15 A | 2015-03-15 A | 100% | 2013-12-06 | 2014-12-05 | 262d? | finish no earlier than 2015-03-15 | R5 | 2624h | 2624h | HSDPA_MFTX-UEConTest | PCG-32 | Qualcomm | Shubhang Vora (svora@qti.qualcomm.com) | Rel-11 | RP-62 | Ingbert | HSDPA_MFTX-UEConTest | RP-150126 |
| 2796 | 650 | **Four Branch MIMO transmission for HSDPA** | 590d? | 2011-09-19 A | 2013-12-06 A | 100% | 2011-09-19 | 2013-12-06 | 590d? |  | R1; R2; R3; R4 | 33968h | 33968h | 4Tx_HSDPA | PCG-27 | Ericsson | johan.hultell@ericsson.com | Rel-11 | RP-53 | Patrick | 4Tx_HSDPA |  |
| 2797 | 650.1 | Core part: Four Branch MIMO transmission for HSDPA | 325d? | 2011-09-19 A | 2012-12-07 A | 100% | 2011-09-19 | 2012-12-07 | 325d? | finish no earlier than 2012-12-07 | R1; R2; R3; R4 | 10400h | 10400h | 4Tx_HSDPA-Core | PCG-27 | Ericsson | johan.hultell@ericsson.com | Rel-11 | RP-53 | Patrick | 4Tx_HSDPA-Core | RP-121549 |
| 2798 | 650.2 | Perf. part: Four Branch MIMO transmission for HSDPA | 586d? | 2011-09-21 A | 2013-12-06 A | 100% | 2011-09-21 | 2013-12-06 | 586d? | finish no earlier than 2013-12-06 | R4 | 4688h | 4688h | 4Tx_HSDPA-Perf | PCG-27 | Ericsson | johan.hultell@ericsson.com | Rel-11 | RP-53 | Issam | 4Tx_HSDPA-Perf | RP-131460 |
| 2799 | 651 | **MIMO with 64QAM for HSUPA** | 464d? | 2011-12-09 A | 2013-09-06 A | 100% | 2011-12-09 | 2013-09-06 | 464d? |  | R1; R2; R3; R4 | 26984h | 26984h | MIMO_64QAM_HSUPA | PCG-28 | Nokia Siemens Networks | Karri Ranta-aho | Rel-11 | RP-54 | Patrick | MIMO_64QAM_HSUPA |  |
| 2800 | 651.1 | Core part: MIMO with 64QAM for HSUPA | 265d? | 2011-12-09 A | 2012-12-07 A | 100% | 2011-12-09 | 2012-12-07 | 265d? | finish no earlier than 2012-12-07 | R1; R2; R3; R4 | 8480h | 8480h | MIMO_64QAM_HSUPA-Core | PCG-28 | Nokia Siemens Networks | Karri Ranta-aho | Rel-11 | RP-54 | Patrick | MIMO_64QAM_HSUPA-Core | RP-121554 |
| 2801 | 651.2 | Perf. part: MIMO with 64QAM for HSUPA | 457d? | 2011-12-13 A | 2013-09-06 A | 100% | 2011-12-13 | 2013-09-06 | 457d? | finish no earlier than 2013-09-06 | R4 | 3656h | 3656h | MIMO_64QAM_HSUPA-Perf | PCG-28 | Nokia Siemens Networks | kamil.bechta@nsn.com | Rel-11 | RP-54 | Issam | MIMO_64QAM_HSUPA-Perf | RP-130960 |

Notes:
- 2776: Stage 2/3 / Impacted TSs and TRs: UTRA
- 2777: RP#58 completed / Impacted TSs and TRs: 25.101, 25.104, 25.133, 25.211, 25.212, 25.213, 25.214, 25.215, 25.306, 25.319, 25.321, 25.331, 25.423, 25.433
- 2778: RP#61 completed / Impacted TSs and TRs: 25.101, 25.104, 25.133, 25.141
- 2779: RP#58 completed / Impacted TSs and TRs: 25.101, 25.133, 25.306, 25.319, 25.321, 25.331, 25.423, 25.433
- 2780: RP#58 completed / Impacted TSs and TRs: 25.101, 25.133
- 2781: RP#64 completed / Impacted TSs and TRs: 34.121-1, 34.121-2, 34.123-1, 34.123-2, 34.123-3
- 2782: - / Impacted TSs and TRs: UTRA
- 2783: RP#54 completed. RP#62 existing TS 25.317 replaced by new TS 25.327 / Impacted TSs and TRs: 25.101, 25.104, 25.141, 25.317 replaced by new TS 25.327
- 2784: RP#56 completed. RP#62 existing TS 25.317 replaced by new TS 25.327 / Impacted TSs and TRs: 25.101, 25.104, 25.141, 25.317 replaced by new TS 25.327
- 2785: - / Impacted TSs and TRs: UTRA
- 2786: RP#56 completed / Impacted TSs and TRs: 25.101, 25.104, 25.133, 25.331, 25.423, 25.433
- 2787: RP#59 completed / Impacted TSs and TRs: 25.101, 25.104, 25.133, 25.141
- 2788: - / Impacted TSs and TRs: UTRA
- 2789: RP#58 completed / Impacted TSs and TRs: 25.101, 25.104, 25.133, 25.211, 25.212, 25.213, 25.214, 25.306, 25.308, 25.319, 25.321, 25.331, 25.423, 25.433
- 2790: RP#62 completed / Impacted TSs and TRs: 25.101, 25.104, 25.133, 25.141
- 2791: ; Stat Rep: RP-141164->RP-141770 1st Apr 15: Compl:92%->100% 1st Apr 15: Stat Rep: RP-141770->RP-150132 / Impacted TSs and TRs: 34.108, 34.121-1, 34.121-2, 34.123-1, 34.123-2, 34.123-3, 36.508, 36.523-1, 36.523-2, 36.523-3
- 2792: Stage 2,3 / Impacted TSs and TRs: UTRA
- 2793: RP#58 completed / Impacted TSs and TRs: 25.101, 25.104, 25.133, 25.211, 25.212, 25.214, 25.306, 25.308, 25.321, 25.331, 25.423, 25.433
- 2794: RP#61 completed / Impacted TSs and TRs: 25.101, 25.104, 25.133, 25.141
- 2795: ; Stat Rep: RP-141136->RP-141961 1st Apr 15: Compl:90%->100% 1st Apr 15: Stat Rep: RP-141961->RP-150126 / Impacted TSs and TRs: 34.108, 34.121-1, 34.121-2, 34.123-1, 34.123-2, 34.123-3
- 2796: Stage 3 / Impacted TSs and TRs: UTRA
- 2797: RP#58 completed / Impacted TSs and TRs: 25.101, 25.104, 25.133, 25.211, 25.212, 25.213, 25.214, 25.215, 25.308, 25.331, 25.423, 25.433, 26.306
- 2798: RP#62 completed / Impacted TSs and TRs: 25.101, 25.104, 25.133, 25.141
- 2799: Specified UE and BS performance requirements for uplink MIMO together with QPSK and 16QAM modulations for E-DCH/HSUPA. 64QAM is for future releases / Impacted TSs and TRs: UTRA
- 2800: RP#58 completed / Impacted TSs and TRs: 25.101, 25.104, 25.133, 25.211, 25.212, 25.213, 25.214, 25.215, 25.308, 25.321, 25.331, 25.423, 25.433, 26.306
- 2801: RP#61 completed / Impacted TSs and TRs: 25.101, 25.104, 25.133, 25.141

| ID | WBS | Task | Type | Duration | Start | Finish | Complete | Baseline start | Baseline finish | Baseline duration | Constraint | Resources | Work | Actual work | Acronym | PCG approved | Impacted TSs and TRs | WI rapporteur name | Release | TSG approved | MCC resp | Acronym_3GU_Export | Status Report | Special Focus Doc | PCG stopped | TSG stopped |
| --- | --- | --- | --- | --- | --- | --- | --- | --- | --- | --- | --- | --- | --- | --- | --- | --- | --- | --- | --- | --- | --- | --- | --- | --- | --- | --- |
| 2802 | 652 | **HSDPA Dual-Band Multi-Carrier combinations** |  | 198d? | 2011-12-09 A | 2012-09-07 A | 100% | 2011-12-09 | 2012-09-07 | 198d? |  | R4; R2 | 7920h | 7920h | HSDPA_DB_MC | PCG-28 | UTRA | Ericsson | Rel-11 | RP-54 | Issam | HSDPA_DB_MC |  |  |  |  |
| 2803 | 652.1 | Core part: HSDPA Dual-Band Multi-Carrier combinations |  | 198d? | 2011-12-09 A | 2012-09-07 A | 100% | 2011-12-09 | 2012-09-07 | 198d? | finish no earlier than 2012-09-07 | R4; R2 | 3168h | 3168h | HSDPA_DB_MC-Core | PCG-28 | 25.101, 25.104, 25.141, 25.317 replaced by new TS 25.327 | Ericsson | Rel-11 | RP-54 | Issam | HSDPA_DB_MC-Core | RP-120987 |  |  |  |
| 2804 | 652.2 | Perf. part: HSDPA Dual-Band Multi-Carrier combinations |  | 198d? | 2011-12-09 A | 2012-09-07 A | 100% | 2011-12-09 | 2012-09-07 | 198d? | finish no earlier than 2012-09-07 | R4 | 1584h | 1584h | HSDPA_DB_MC-Perf | PCG-28 | 25.101, 25.104, 25.141 | Ericsson | Rel-11 | RP-54 | Issam | HSDPA_DB_MC-Perf | RP-120988 |  |  |  |
| 2805 | 653 | Split TTCN Test Models for IMS testing in TS 34.229-3 |  | 201d? | 2013-12-09 A | 2014-09-12 A | 100% | 2013-12-09 | 2014-09-12 | 201d? | finish no earlier than 2014-09-12 | R5 | 1608h | 1608h | IMS-CCR_Test2 | PCG-32 | 34.229-3, New TS 34.229-4 | Spirent | Rel-11 | RP-62 | Ingbert | IMS-CCR_Test2 | RP-141155 |  |  |  |
| 2806 | 654 | (Small) Technical Enhancements and Improvements for Rel-11 |  | 595d? | 2010-06-18 A | 2012-09-20 A | 100% | 2010-06-18 | 2012-09-20 | 595d? | finish no earlier than 2012-09-20 | SP; CP; RP; GP | 19040h | 19040h | TEI11 | PCG-25 |  |  | Rel-11 | SP-48 | All | TEI11 |  |  |  |  |
| 2807 | 655 | Test - (Small) Technical Enhancements and Improvements for Rel-11 |  | 397d? | 2012-06-15 A | 2013-12-11 A | 100% | 2012-06-15 | 2013-12-11 | 397d? | finish no earlier than 2013-12-11 | R5; G3new | 6352h | 6352h | TEI11_Test | PCG-29 |  |  | Rel-11 | RP-56 | Ingbert | TEI11_Test |  |  |  |  |
| 2808 | 656 | (IETF) (Small) Technical Enhancements and Improvements for Rel-11 (RFC 7077) |  | 333d? | 2012-09-07 A | 2013-12-06 A | 100% | 2012-09-07 | 2013-12-06 | 333d? | finish no earlier than 2013-11-28 | C4-IETF | 2632.95h | 2632.95h | TEI11_IETF | PCG-29 | RFC 7077 (was draft-ietf-netext-update-notifications) | Lionel Morand | Rel-11 | CP-57 | Kimmo | TEI11_IETF |  |  |  |  |
| 2809 | 657 | Release 11 Studies | milestone | 0d? | 2009-12-10 A | 2009-12-10 A | 100% | 2009-12-10 | 2012-09-14 | 727d? | finish no earlier than 2012-12-07 | SP; CP; GP; RP |  |  |  |  |  |  | Rel-11 |  | All |  |  |  |  |  |
| 2810 | 658 | Study on IMS based Peer-to-Peer Content Distribution Services |  | 195d? | 2009-09-11 A | 2010-06-10 A | 100% | 2009-05-12 | 2010-06-10 | 284d? | finish no earlier than 2010-06-10 | S1; S2 | 3120h | 3120h | FS_IMS_P2P | PCG-23 | 22.906 | China Mobile | Rel-11 | SP-45 | Alain | FS_IMS_P2P |  |  |  |  |
| 2811 | 659 | Study on Non Voice Emergency Services |  | 467d? | 2009-12-10 A | 2011-09-21 A | 100% | 2009-12-10 | 2011-09-21 | 467d? | finish no earlier than 2011-09-21 | S1 | 3720h | 3720h | FS_NOVES | PCG-24 | 22.871 | Qualcomm | Rel-11 | SP-46 | Alain | FS_NOVES |  |  |  |  |
| 2812 | 660 | Study on Support for 3GPP Voice Interworking with Enterprise IP-PBX |  | 130d? | 2010-09-23 A | 2011-03-23 A | 100% | 2010-09-23 | 2011-03-23 | 130d? | finish no earlier than 2011-02-21 | S1; S2 | 2080h | 2080h | FS_VINE | PCG-25 | 22.809 | Tatara Systems | Rel-11 | SP-48 | Alain | FS_VINE |  |  |  |  |
| 2813 | 661 | Study on IMS Network-Independent Public User Identities |  | 185d? | 2010-09-23 A | 2011-06-08 A | 100% | 2010-09-23 | 2011-06-08 | 185d? | finish no earlier than 2011-06-08 | S1 | 1480h | 1480h | FS_INIPUI | PCG-25 | 22.894 | Vodafone | Rel-11 | SP-49 | Alain | FS_INIPUI |  |  |  |  |
| 2814 | 662 | Study on IMS Evolution |  | 849d? | 2008-09-18 A | 2011-12-14 A | 100% | 2008-09-18 | 2011-12-14 | 849d? | finish no earlier than 2011-12-07 | S2 | 6784h | 6784h | FS_eIMS | PCG-21 | 23.812 | China Mobile | Rel-11 | SP-41 | Maurice | FS_eIMS |  |  |  |  |
| 2815 | 663 | Study on Policy solutions and enhancements |  | 521d? | 2009-06-12 A | 2011-06-10 A | 100% | 2000-01-03 | 2002-01-03 | 525d? | finish no earlier than 2011-06-10 | S2; S1 | 8336h | 8336h | FS_PP | PCG-23 | 23.813 | AT&T | Rel-11 | SP-44 | Maurice | FS_PP |  |  |  |  |
| 2816 | 664 | Study on IPv6 Migration |  | 525d? | 2009-06-04 A | 2011-06-08 A | 100% | 2009-06-04 | 2011-06-08 | 525d? | finish no earlier than 2011-06-08 | S2 | 4200h | 4200h | FS_IP6M | PCG-23 | 23.975 | China Mobile | Rel-11 | SP-44 | Maurice | FS_IP6M |  |  |  |  |
| 2817 | 665 | Study on Single Radio Voice Call Continuity from UTRAN/GERAN to E-UTRAN/HSPA |  | 528d? | 2009-12-10 A | 2011-12-14 A | 100% | 2009-12-10 | 2011-12-14 | 528d? | finish no earlier than 2011-09-21 | S2 | 4208h | 4208h | FS_rSRVCC | PCG-24 | 23.885 | Orange | Rel-11 | SP-46 | Maurice | FS_rSRVCC |  |  |  |  |
| 2818 | 666 | Study on Roaming Architecture for Voice over IMS with Local Breakout |  | 194d? | 2011-03-23 A | 2011-12-14 A | 100% | 2011-03-23 | 2011-12-14 | 194d? | finish no earlier than 2011-12-07 | S2 | 1535.79h | 1535.79h | FS_RAVEL | PCG-26 | 23.850 | Deutsche Telekom | Rel-11 | SP-51 | Maurice | FS_RAVEL |  |  |  |  |
| 2819 | 667 | Study on UTRAN key management enhancements |  | 1102d? | 2007-12-20 A | 2012-03-07 A | 100% | 2007-12-20 | 2012-03-07 | 1102d? | finish no earlier than 2012-02-20 | S3 | 8808.12h | 8808.12h | FS_UKM | PCG-21 | 33.859 | Ericsson | Rel-11 | SP-38 | Mirko | FS_UKM |  |  |  |  |
| 2820 | 668 | Study on Single Sign On (SSO) Application Security for IMS - based on SIP Digest |  | 532d? | 2010-06-10 A | 2012-06-20 A | 100% | 2010-06-10 | 2012-06-20 | 532d? | finish no earlier than 2012-06-20 | S3 | 4247.09h | 4247.09h | FS_SSO_APS | PCG-25 | 33.914 converted to 33.804 | Nokia | Rel-11 | SP-48 | Mirko | FS_SSO_APS |  |  |  |  |
| 2821 | 669 | Study on Mobile 3D Video Coding |  | 273d? | 2011-06-08 A | 2012-06-20 A | 100% | 2011-06-08 | 2012-06-20 | 273d? | finish no earlier than 2012-06-20 | S4 | 2168h | 2168h | FS_M3DVC | PCG-27 | 26.905 | Orange | Rel-11 | SP-52 | Paolo | FS_M3DVC |  |  |  |  |
| 2822 | 670 | Study on Management of Converged Networks |  | 591d? | 2010-06-10 A | 2012-09-12 A | 100% | 2010-06-10 | 2012-09-12 | 591d? | finish no earlier than 2012-09-12 | S5 | 4720h | 4720h | FS_ManCon | PCG-25 | 32.833 | Nokia Siemens Networks | Rel-11 | SP-48 | Mirko | FS_ManCon |  |  |  |  |
| 2823 | 671 | Study on User Data Convergence (UDC) information model handling and provisioning: Example Use Cases |  | 321d? | 2010-09-23 A | 2011-12-14 A | 100% | 2010-09-23 | 2011-12-14 | 321d? | finish no earlier than 2011-12-14 | S5 | 2560h | 2560h | FS_UDC_AppUseCase | PCG-25 | 32.901 | Alcatel-Lucent | Rel-11 | SP-49 | Mirko | FS_UDC_AppUseCase |  |  |  |  |
| 2824 | 672 | Study on OAM aspects of inter-RAT Energy Saving |  | 194d? | 2011-03-23 A | 2011-12-14 A | 100% | 2011-03-23 | 2011-12-14 | 194d? | start no earlier than 2011-03-23 | S5 | 1528h | 1528h | FS_OAM_ES_iRAT | PCG-26 | 32.834 | Nokia Siemens Networks | Rel-11 | SP-51 | Mirko | FS_OAM_ES_iRAT |  | SON |  |  |
| 2825 | 673 | Study on impacts on UE-Core Network signalling from Energy Saving |  | 261d? | 2010-06-04 A | 2011-06-03 A | 100% | 2010-06-04 | 2011-06-03 | 261d? | finish no earlier than 2011-06-03 | C1 | 2088h | 2088h | FS_UE-CN_ES | PCG-25 | 24.826 | NEC | Rel-11 | CP-48 | Frederic | FS_UE-CN_ES |  |  |  |  |
| 2826 | 674 | Study on EPC Nodes Restoration |  | 588d? | 2010-09-17 A | 2012-12-07 A | 100% | 2010-09-17 | 2012-12-07 | 588d? | finish no earlier than 2012-12-07 | C4 | 4664h | 4664h | FS_EPC_NR | PCG-25 | 23.857 | ZTE | Rel-11 | CP-49 | Kimmo | FS_EPC_NR |  |  |  |  |
| 2827 | 675 | Study on Signal Precoding enhancements for EGPRS2 DL |  | 394d? | 2010-09-03 A | 2012-03-02 A | 100% | 2010-09-03 | 2012-03-02 | 394d? | finish no earlier than 2012-03-02 | G1; G2 | 6304h | 6304h | FS_SPEED | PCG-25 | GERAN 45.860 | Ericsson | Rel-11 | GP-46 | Paolo | FS_SPEED |  |  |  |  |
| 2828 | 676 | Study on Coordinated Multi-Point operation for LTE |  | 203d? | 2010-12-10 A | 2011-09-16 A | 100% | 2010-12-10 | 2011-09-16 | 203d? | finish no earlier than 2011-09-16 | R1; R2; R3 | 4872h | 4872h | FS_CoMP_LTE | PCG-24 | LTE 36.819 | Samsung | Rel-11 | RP-47 | Patrick | FS_CoMP_LTE | RP-111343 |  |  |  |
| 2829 | 677 | Study on Signalling and procedure for interference avoidance for in-device coexistence |  | 338d? | 2010-06-04 A | 2011-09-16 A | 100% | 2010-06-04 | 2011-09-16 | 338d? | finish no earlier than 2011-09-16 | R2; R4 | 5408h | 5408h | FS_SPIA_IDC | PCG-25 | LTE 36.816 | China Mobile | Rel-11 | RP-48 | Yong-Jun | FS_SPIA_IDC | RP-111057 |  |  |  |
| 2830 | 678 | Study on HetNet mobility enhancements for LTE |  | 391d? | 2011-03-18 A | 2012-09-07 A | 100% | 2011-03-18 | 2012-09-07 | 391d? | finish no earlier than 2012-09-07 | R2; R1; R3; R4 | 12512h | 12512h | FS_HetNet_eMOB_LTE | PCG-26 | LTE 36.839 | Alcatel-Lucent | Rel-11 | RP-51 | Yong-Jun | FS_HetNet_eMOB_LTE | RP-121085 |  |  |  |
| 2831 | 679 | Study on further Downlink MIMO enhancements for LTE-Advanced |  | 193d? | 2011-03-18 A | 2011-12-09 A | 100% | 2011-03-18 | 2011-12-09 | 193d? | finish no earlier than 2011-12-09 | R1 | 1544h | 1544h | FS_LTE_eDL_MIMO_enh | PCG-26 | LTE 36.871 | Alcatel-Lucent | Rel-11 | RP-51 | Patrick | FS_LTE_eDL_MIMO_enh | RP-111550 |  |  |  |
| 2832 | 680 | Study on Further Enhancements to LTE TDD for DL-UL Interference Management and Traffic Adaptation |  | 328d? | 2011-03-22 A | 2012-06-15 A | 100% | 2011-03-22 | 2012-06-15 | 328d? | finish no earlier than 2012-06-15 | R1; R4 | 5248h | 5248h | FS_LTE_TDD_eIMTA | PCG-26 | LTE 36.828 | CATT | Rel-11 | RP-51 | Patrick | FS_LTE_TDD_eIMTA | RP-120587 | Small cell |  |  |
| 2833 | 681 | Study on LTE Coverage Enhancements |  | 197d? | 2011-09-19 A | 2012-06-15 A | 100% | 2011-09-19 | 2012-06-15 | 197d? | finish no earlier than 2012-06-15 | R1; R2 | 3152h | 3152h | FS_Cov_Enh_LTE | PCG-27 | LTE 36.824 | China Telecom | Rel-11 | RP-53 | Patrick | FS_Cov_Enh_LTE | RP-120589 |  |  |  |
| 2834 | 682 | Study on Enhanced performance requirement for LTE UE |  | 121d? | 2011-09-19 A | 2012-03-02 A | 100% | 2011-09-19 | 2012-03-02 | 121d? | finish no earlier than 2012-03-02 | R4; R1 | 1936h | 1936h | FS_enh_perf_UE_LTE | PCG-27 | LTE 36.829 | NTT DoCoMo | Rel-11 | RP-53 | Issam | FS_enh_perf_UE_LTE | RP-120167 |  |  |  |
| 2835 | 683 | Study on Measurements of radio performances for LTE terminals - Total Radiated Power (TRP) and Total Radiated Sensitivity (TRS) test methodology |  | 136d? | 2012-03-05 A | 2012-09-07 A | 100% | 2012-03-05 | 2012-09-07 | 136d? | finish no earlier than 2012-09-07 | R4 | 1088h | 1088h | FS_LTE_OTA | PCG-28 | LTE 25.914, New TR 37.902 | CATR | Rel-11 | RP-55 | Issam | FS_LTE_OTA | RP-121083 |  |  |  |
| 2836 | 684 | Study on Measurement of Radiated Performance for MIMO and multi-antenna reception for HSPA and LTE terminals |  | 712.8d? | 2009-03-06 A | 2012-03-02 A | 100% | 2009-03-06 | 2012-03-02 | 712.8d? | finish no earlier than 2012-03-02 | R4 | 5702.4h | 5702.4h | FS_HSPA_LTE_measRP_MIMO_multi-antenna | PCG-22 | UTRA, LTE 37.976 | Vodafone | Rel-11 | RP-43 | Issam | FS_HSPA_LTE_measRP_MIMO_multi-antenna | RP-120154 |  |  |  |
| 2837 | 685 | Study on Extending 850 MHz |  | 860d? | 2009-05-30 A | 2012-09-07 A | 100% | 2009-05-30 | 2012-09-07 | 860d? | finish no earlier than 2012-09-07 | R4 | 6880h | 6880h | FS_e850 | PCG-23 | UTRA, LTE 37.806 | Ericsson | Rel-11 | RP-44 | Issam | FS_e850 | RP-121080 |  |  |  |
| 2838 | 686 | Study on RAN improvements for Machine-Type Communications |  | 523d? | 2009-09-18 A | 2011-09-16 A | 100% | 2009-09-18 | 2011-09-16 | 523d? | finish no earlier than 2011-09-16 | R2; R1; R3; R4 | 16736h | 16736h | FS_NIMTC_RAN | PCG-23 | UTRA, LTE 37.868 | Huawei | Rel-11 | RP-45 | Yong-Jun | FS_NIMTC_RAN | RP-111052 | MTC, M2M |  |  |
| 2839 | 687 | Study on UE Application Layer Data Throughput Performance |  | 264d? | 2010-09-16 A | 2011-09-16 A | 100% | 2010-09-16 | 2011-09-16 | 264d? | finish no earlier than 2011-09-16 | R5; R4 | 4224h | 4224h | FS_UE_App_Data_Perf | PCG-26 | UTRA, LTE 37.901 | Spirent | Rel-11 | RP-50 | Ingbert | FS_UE_App_Data_Perf | RP-111543 |  |  |  |
| 2840 | 688 | Study on further enhancements for HNB and HeNB |  | 330d? | 2011-03-18 A | 2012-06-15 A | 100% | 2011-03-18 | 2012-06-15 | 330d? | finish no earlier than 2012-06-15 | R3; R2 | 5280h | 5280h | FS_EHNB_enh | PCG-26 | UTRA, LTE 37.803 | Alcatel-Lucent | Rel-11 | RP-51 | Juha | FS_EHNB_enh | RP-120579 | HNB |  |  |
| 2841 | 689 | Study on Interference analysis between 800~900 MHz bands |  | 326d? | 2011-03-23 A | 2012-06-15 A | 100% | 2011-03-23 | 2012-06-15 | 326d? | finish no earlier than 2012-06-15 | R4 | 2608h | 2608h | FS_B800_B900_Interf_LTE | PCG-26 | UTRA, LTE impacts TR 37.804 | LG Uplus | Rel-11 | RP-51 | Issam | FS_B800_B900_Interf_LTE | RP-120586 |  |  |  |
| 2842 | 690 | Study on UMTS/LTE in 900 MHz band (Japan, Korea) |  | 272d? | 2011-06-07 A | 2012-06-15 A | 100% | 2011-06-07 | 2012-06-15 | 272d? | finish no earlier than 2012-06-15 | R4 | 2176h | 2176h | FS_UTRA_LTE_900MHz | PCG-27 | UTRA, LTE 37.804 | NTT DoCoMo | Rel-11 | SP-52 | Issam | FS_UTRA_LTE_900MHz | RP-120580 |  |  |  |
| 2843 | 691 | Study on Uplink MIMO |  | 203d? | 2010-12-10 A | 2011-09-16 A | 100% | 2010-12-10 | 2011-09-16 | 203d? | finish no earlier than 2011-09-16 | R1 | 1624h | 1624h | FS_UTRA_UL_MIMO | PCG-26 | UTRA 25.871 | Qualcomm | Rel-11 | RP-50 | Patrick | FS_UTRA_UL_MIMO | RP-111048 |  |  |  |
| 2844 | 692 | Study on HSDPA Multipoint Transmission |  | 203d? | 2010-12-10 A | 2011-09-16 A | 100% | 2010-12-10 | 2011-09-16 | 203d? | finish no earlier than 2011-09-16 | R1; R2; R3 | 4872h | 4872h | FS_HSDPA_MP_TX | PCG-26 | UTRA 25.872 | Nokia Siemens Networks | Rel-11 | RP-50 | Patrick | FS_HSDPA_MP_TX | RP-111049 |  |  |  |
| 2845 | 693 | Study on UE Over The Air (OTA) test method with Head and Hand Phantoms |  | 258d? | 2011-09-19 A | 2012-09-07 A | 100% | 2011-09-19 | 2012-09-07 | 258d? | finish no earlier than 2012-09-07 | R4; R5 | 4128h | 4128h | FS_OTA_phantoms_UTRA | PCG-27 | UTRA 25.914 | Nokia | Rel-11 | RP-53 | Issam | FS_OTA_phantoms_UTRA | RP-121078 |  |  |  |
| 2846 | 694 | Study on HSPA feedback and signalling efficiency enhancements for LCR TDD |  | 199d? | 2011-12-07 A | 2012-09-07 A | 100% | 2011-12-07 | 2012-09-07 | 199d? | finish no earlier than 2012-09-07 | R1 | 1584h | 1584h | FS_LCRTDD_HSPAenh | PCG-28 | UTRA 25.874 | TD Tech | Rel-11 | RP-54 | Patrick | FS_LCRTDD_HSPAenh | RP-121079 |  |  |  |
| 2847 | 695 | Deleted - Study on Enhanced Uplink Transmission for LTE |  | 328d? | 2011-03-22 A | 2012-06-15 A | 100% | 2011-03-22 | 2012-06-15 | 328d? | finish no earlier than 2012-06-15 | R1 | 2624h | 2624h | FS_eUL_TX_LTE | PCG-26 | LTE 36.8xy | Huawei | Rel-11 | RP-51 | Patrick | FS_eUL_TX_LTE | RP-120585 |  | PCG-29 | RP-56 |
| 2848 | 696 | Release 10 Features |  | 728d? | 2008-12-11 A | 2011-09-21 A | 100% | 2008-12-11 | 2011-09-21 | 728d? | finish no earlier than 2011-09-21 | CP; GP; RP; SP | 23296h | 23296h |  |  |  |  | Rel-10 |  |  |  |  |  |  |  |

Notes:
- 2802: Stage 3 / WI rapporteur e-mail: muhammad.kazmi@ericsson.com
- 2803: RP#57 completed. RP#62 existing TS 25.317 replaced by new TS 25.327 / WI rapporteur e-mail: muhammad.kazmi@ericsson.com
- 2804: RP#57 completed / WI rapporteur e-mail: muhammad.kazmi@ericsson.com
- 2805: SP#65 completed. TS 34.229-4 for Approval. Split out of old TS 34.229-3 a new TS 34.229-4 / WI rapporteur e-mail: richard.catmur@spirent.com
- 2806: SP#50 EU-Alert is introduced under Public Warning System in parallel with the already existing ETWS and CMAS. SA1 22.268 CR#9r1 adds EU-ALERT specific requirements & CT1 23.041 CRs#
- 2807: -
- 2808: CP#62 completed / WI rapporteur e-mail: Lionel Morand
- 2809: -
- 2810: SP#48 completed. 3/3/15: start date corrected (was 05/09) / WI rapporteur e-mail: Li Gang (ligangyf@chinamobile.com)
- 2811: SP#53 completed. Spin-off Feature UID_500030 Non Voice Emergency Services (NOVES) / WI rapporteur e-mail: dwilliams@qualcomm.com
- 2812: SP#51 completed. Support Interworking between 3GPP networks and Enterprise environments to provide enterprise voice services via 3GPP mobile devices / WI rapporteur e-mail: Phillip Brown (pbrown@tatarasystems.com)
- 2813: SP#52 completed / WI rapporteur e-mail: mona.mustapha@vodafone.com
- 2814: SP#54 completed / WI rapporteur e-mail: Li Gang (ligangyf@chinamobile.com), Yu Qing (yuqing@chinamobile.com)
- 2815: SP#52 completed. 3/3/15: start and finish dates corrected (was start on Jan-00, ends on Jan-02) / WI rapporteur e-mail: farooq.bari@att.com
- 2816: SP#52 completed / WI rapporteur e-mail: Li Lianyuan (lilianyuan@chinamobile.com), Liu Hong (liuhongyfw@chinamobile.com)
- 2817: SP#54 completed. Study on "reverse direction" from UTRAN/GERAN to E-UTRAN/HSPA (Rel-8 SRVCC was in the other direction E-UTRAN/HSPA to GERAN/UTRAN) / WI rapporteur e-mail: delphin.barankanira@orange-ftgroup.com
- 2818: SP#54 completed. Linked to Rel-11 OSCAR (Optimized Service Charging and Allocation of ResourcES in CP-150IMS whilst Roaming) UID_490032. Related to LBO/home routing decision / WI rapporteur e-mail: michele.zarri@telekom.com
- 2819: SP#55 completed / WI rapporteur e-mail: karl.norrman@ericsson.com
- 2820: SP#56 completed. SP#55 TR 33.914v200 approved (converted 33.804). Study reuse of non-UICC credentials (in particular SIP Digest) to provide security for access to applications. Provide reference material for IMS based non-UICC based SSO to applications / WI rapporteur e-mail: Silke.Holtmanns@nokia.com
- 2821: SP#56 completed. Extends Rel-10 work on 3D video formats UID_480044 Improved Video Coding Support for PSS and MBMS / WI rapporteur e-mail: gilles.teniou@orange-ftgroup.com
- 2822: SP#57 completed. TR 32.833v200 for Approval / WI rapporteur e-mail: Jörg Schmidt (J.Schmidt@nsn.com)
- 2823: SP#54 completed / WI rapporteur e-mail: Nick Mazzarella (njmazzarella@alcatel-lucent.com)
- 2824: SP#54 completed. Triggered by Rel-10 UID_430044 TR 32.826 Study on Energy Savings Management (FS_OAM_ESM) and UID_470037 OAM aspects of Energy Saving in Radio Networks (OAM-ES) / WI rapporteur e-mail: clemens.suerbaum@nsn.com
- 2825: CP#52 completed. Linked to SA5 UID_430044 (FS_OAM-ESM) & UID_470037 (OAM-ES), RAN3 UID_470015 (FS_Energy_LTE), RAN1 UID_460016 (FS_Energy_UMTS) / WI rapporteur e-mail: gottfried.punz@nw.neclab.eu
- 2826: CP#58 completed. Continue work in Rel-11 especially to cover handling of Idle mode Signalling Reduction (ISR). Linked to SA2 UID_490036 Study on Core Network Overload solutions / WI rapporteur e-mail: lu.fei1@zte.com.cn
- 2827: GP#53 completed (03/12). GP#46 approved WID. / WI rapporteur e-mail: marten.sundberg@ericsson.com
- 2828: RP#53 completed / WI rapporteur e-mail: bruno.clerckx@samsung.com
- 2829: RP#53 completed. Studied coexistence scenario of LTE and Industrial, Scientific and Medical (ISM) Radio within the same device working in adjacent frequencies / WI rapporteur e-mail: Zhenping Hu (huzhenping@chinamobile.com)
- 2830: RP#57 completed. TR 36.839 v100 for Information & Approval / WI rapporteur e-mail: sudeep.palat@alcatel-lucent.com
- 2831: RP#54 completed / WI rapporteur e-mail: federico.boccardi@alcatel-lucent.com
- 2832: RP#56 completed. TR 36.828 for Information and Approval / WI rapporteur e-mail: Zukang Shen (shenzukang@catt.cn)
- 2833: RP#56 completed. TR 36.824 v200 for Approval / WI rapporteur e-mail: Peng Chen (chenpeng@ctbri.com.cn)
- 2834: RP#55 completed. TR 36.829 v100 for Information + Approval / WI rapporteur e-mail: Yuta Sagae
- 2835: RP#57 completed / WI rapporteur e-mail: Xudong An (anxudong@emcite.com)
- 2836: RP#55 completed. TR 37.976 v200 for Approval / WI rapporteur e-mail: Tim.frost@vodafone.com
- 2837: RP#57 completed. TR 37.806 v200 for Approval / WI rapporteur e-mail: christian.bergljung@ericsson.com
- 2838: RP#53 completed. TR 37.868v100 for Approval (No WID change: RAN overload only). Triggered by TR 22.868 Study on Facilitating Machine to Machine Communication in GSM and UMTS (M2M) UID_7027 and Rel-10 NIMTC UID_410030 / WI rapporteur e-mail: Jeff Gao (gaoyq@huawei.com)
- 2839: RP#54 completed / WI rapporteur e-mail: ron.borsato@spirent.com
- 2840: RP#56 completed. TR 37.803 v200 for Approval / WI rapporteur e-mail: Martin.Warner@alcatel-lucent.com
- 2841: RP#56 completed. Impacts TR 37.804 Study on UMTS/LTE in 900 MHz band (Japan, Korea) UID_520018 / WI rapporteur e-mail: Koo Yeon Sang (yskoo@lguplus.co.kr)
- 2842: RP#56 completed. Updated WID RP-111751=>RP-120617. TR 37.804 v100 for Information and Approval. Linked to Study on Interference analysis between 800~900 MHz bands UID_510038 / WI rapporteur e-mail: Masahiro Fujii (fujiima@nttdocomo.co.jp)
- 2843: RP#53 completed (1-step Approval) / WI rapporteur e-mail: Sharad Sambhwani
- 2844: RP#53 completed / WI rapporteur e-mail: karri.ranta-aho@nsn.com
- 2845: RP#57 completed / WI rapporteur e-mail: petri.j.vasenkari@nokia.com
- 2846: RP#57 completed. TR 25.874 v100 for Information & Approval / WI rapporteur e-mail: limei.wei@td-tech.com
- 2847: RP#56 stopped. RP-120856 discussion: most content moved to Rel-11 Coordinated Multi-Point Operation for LTE Uplink (COMP_LTE_UL) and RAN1 has no time to look at it / WI rapporteur e-mail: Yongxing Zhou
- 2848: -

| ID | WBS | Task | Duration | Start | Finish | Complete | Baseline start | Baseline finish | Baseline duration | Constraint | Resources | Work | Actual work | Acronym | PCG approved | WI rapporteur name | WI rapporteur e-mail | Release | TSG approved | MCC resp | Special Focus Doc | Acronym_3GU_Export | PCG stopped | TSG stopped | Status Report |
| --- | --- | --- | --- | --- | --- | --- | --- | --- | --- | --- | --- | --- | --- | --- | --- | --- | --- | --- | --- | --- | --- | --- | --- | --- | --- |
| 2849 | 697 | **Enhancements for Multimedia Priority Service** | 1311d? | 2006-03-13 A | 2011-03-18 A | 100% | 2006-03-13 | 2011-03-18 | 1311d? |  | S1; S2; C4; C3; C1 | 72120h | 72120h | eMPS | PCG-21 | Telcordia | jgarraha@telcordia.com | Rel-10 | SP-39 | Alain | Public Safety (I-A) | eMPS |  |  |  |
| 2850 | 697.1 | Stage 1 on enhancements for Multimedia Priority Service | 584d? | 2006-03-13 A | 2008-06-05 A | 100% | 2006-03-13 | 2008-06-05 | 584d? | start no earlier than 2006-03-12 | S1 | 4672h | 4672h | ePRIOR-St1 | PCG-21 | Telcordia | jgarraha@telcordia.com | Rel-10 | SP-39 | Alain | Public Safety (I-A) | ePRIOR |  |  |  |
| 2851 | 697.2 | **Stage 2 on enhancements for Multimedia Priority Service** | 206d? | 2009-12-10 A | 2010-09-23 A | 100% | 2009-12-10 | 2010-09-23 | 206d? |  | S2 | 6592h | 6592h | ePRIOR-St2 | PCG-24 | Telcordia, NTT DoCoMo | Vijay Varma, Katsutoshi Nishida | Rel-10 | SP-46 | Maurice | Public Safety (I-A) |  |  |  |  |
| 2852 | 697.2.1 | Stage 2 on eMPS for CSFB | 206d? | 2009-12-10 A | 2010-09-23 A | 100% | 2009-12-10 | 2010-09-23 | 206d? | finish no earlier than 2010-09-24 | S2 | 1648h | 1648h | ePRIOR-St2 | PCG-24 | Telcordia, NTT DoCoMo | Vijay Varma, Katsutoshi Nishida | Rel-10 | SP-46 | Maurice | Public Safety (I-A) |  |  |  |  |
| 2853 | 697.2.2 | Stage 2 on eMPS for EPS Bearer Service | 206d? | 2009-12-10 A | 2010-09-23 A | 100% | 2009-12-10 | 2010-09-23 | 206d? | finish no earlier than 2010-12-09 | S2 | 1648h | 1648h | ePRIOR-St2 | PCG-24 | Telcordia, NTT DoCoMo | Vijay Varma, Katsutoshi Nishida | Rel-10 | SP-46 | Maurice | Public Safety (I-A) |  |  |  |  |
| 2854 | 697.2.3 | Stage 2 on eMPS for IMS Aspects | 206d? | 2009-12-10 A | 2010-09-23 A | 100% | 2009-12-10 | 2010-09-23 | 206d? | finish no earlier than 2010-12-09 | S2 | 1648h | 1648h | ePRIOR-St2 | PCG-24 | Telcordia, NTT DoCoMo | Vijay Varma, Katsutoshi Nishida | Rel-10 | SP-46 | Maurice | Public Safety (I-A) |  |  |  |  |
| 2855 | 697.3 | Deleted - TR 23.854 on Stage 2 on enhancements for Multimedia Priority Service | 266d? | 2009-12-10 A | 2010-12-16 A | 100% | 2009-12-10 | 2010-12-16 | 266d? | finish no earlier than 2011-03-17 | S2 | 2128h | 2128h |  | PCG-24 | Telcordia, NTT DoCoMo | Vijay Varma, Katsutoshi Nishida | Rel-10 | SP-46 | Maurice | Public Safety (I-A) |  | PCG-27 | SP-50 |  |
| 2856 | 697.4 | **Stage 3 on enhancements for Multimedia Priority Service** | 131d? | 2010-09-17 A | 2011-03-18 A | 100% | 2010-09-17 | 2011-03-18 | 131d? |  | C4; C3; C1 | 6288h | 6288h | eMPS-CN | PCG-25 | Ericsson | Philip.hodges@ericsson.com | Rel-10 | CP-49 | Kimmo | Public Safety (I-A) | eMPS-CN |  |  |  |
| 2857 | 697.4.1 | CT4 part on Stage 3 on enhancements for Multimedia Priority Service | 131d? | 2010-09-17 A | 2011-03-18 A | 100% | 2010-09-17 | 2011-03-18 | 131d? | start no earlier than 2010-09-17 | C4 | 1048h | 1048h | eMPS-CN | PCG-25 | Ericsson | Philip.hodges@ericsson.com | Rel-10 | CP-49 | Kimmo | Public Safety (I-A) |  |  |  |  |
| 2858 | 697.4.2 | CT3 part on Stage 3 on enhancements for Multimedia Priority Service | 131d? | 2010-09-17 A | 2011-03-18 A | 100% | 2010-09-17 | 2011-03-18 | 131d? | start no earlier than 2010-09-17 | C3 | 1048h | 1048h | eMPS-CN | PCG-25 | Ericsson | Philip.hodges@ericsson.com | Rel-10 | CP-49 | Adrian | Public Safety (I-A) |  |  |  |  |
| 2859 | 697.4.3 | CT1 part on Stage 3 on enhancements for Multimedia Priority Service | 131d? | 2010-09-17 A | 2011-03-18 A | 100% | 2010-09-17 | 2011-03-18 | 131d? | start no earlier than 2010-09-17 | C1 | 1048h | 1048h | eMPS-CN | PCG-25 | Ericsson | Philip.hodges@ericsson.com | Rel-10 | CP-49 | Frederic | Public Safety (I-A) |  |  |  |  |
| 2860 | 698 | **Network Improvements for Machine-Type Communications** | 1365d? | 2008-09-18 A | 2013-11-22 A | 100% | 2008-09-18 | 2013-11-22 | 1365d? |  | S1; S2; S5; C1; C4; C6; G2; R2; R3; R5; G3new | 149017h | 149017h | NIMTC | PCG-21 | KPN | toon.norp@tno.nl | Rel-10 | SP-41 | Alain | MTC, M2M | NIMTC |  |  |  |
| 2861 | 698.1 | Stage 1 for Network Improvements for Machine-Type Communications | 397d? | 2008-09-18 A | 2010-03-25 A | 100% | 2008-09-18 | 2010-03-25 | 397d? | finish no earlier than 2009-12-10 | S1 | 3176h | 3176h | NIMTC | PCG-21 | KPN | toon.norp@tno.nl | Rel-10 | SP-41 | Alain | MTC, M2M |  |  |  |  |
| 2862 | 698.2 | Deleted - TR on Stage 2 for Network Improvements for Machine-Type Communications | 321d? | 2009-09-24 A | 2010-12-16 A | 100% | 2009-09-24 | 2010-12-16 | 321d? | finish no earlier than 2010-11-30 | S2 | 2568h | 2568h | NIMTC | PCG-23 | Samsung | erik.guttman@partner.samsung.com | Rel-10 | SP-45 | Maurice | MTC, M2M |  | PCG-26 | SP-50 |  |
| 2863 | 698.3 | Stage 2 for Network Improvements for Machine-Type Communications | 19d? | 2010-08-30 A | 2010-09-23 A | 100% | 2010-08-30 | 2010-09-23 | 19d? | finish no earlier than 2010-09-17 | S2 | 152h | 152h | NIMTC | PCG-23 | Samsung | erik.guttman@partner.samsung.com | Rel-10 | SP-45 | Maurice | MTC, M2M |  |  |  |  |
| 2864 | 698.4 | Deleted - Security for Network Improvements for Machine-Type Communications | 193.15d? | 2009-12-10 A | 2010-09-23 A | 100% | 2009-12-10 | 2010-09-23 | 193.15d? | finish no earlier than 2010-09-23 | S3 | 1545.2h | 1545.2h | NIMTC | PCG-24 | Samsung | Rajavelsamy R (rajvel@samsung.com) | Rel-10 | SP-46 | Mirko | MTC, M2M |  | PCG-25 | SP-49 |  |
| 2865 | 698.5 | Charging for Network Improvements for Machine-Type Communication | 3d? | 2011-03-21 A | 2011-03-23 A | 100% | 2011-03-21 | 2011-03-23 | 3d? | start no earlier than 2011-03-21 | S5 | 24h | 24h | NIMTC-CH | PCG-26 | Ericsson | patrik.teppo@@ericsson.com | Rel-10 | SP-51 | Mirko | MTC, M2M | NIMTC-CH |  |  |  |
| 2866 | 698.6 | **CN part of Stage 3 for Network Improvements for Machine-Type Communications** | 261d? | 2010-06-04 A | 2011-06-03 A | 100% | 2010-06-04 | 2011-06-03 | 261d? |  | C1; C4; C6 | 12976h | 12976h | NIMTC-CN | PCG-25 | Ericsson | mikael.wass@ericsson.com | Rel-10 | CP-48 | Frederic | MTC, M2M | NIMTC-CN |  |  |  |
| 2867 | 698.6.1 | CT1 part of Stage 3 for Network Improvements for Machine-Type Communications | 261d? | 2010-06-04 A | 2011-06-03 A | 100% | 2010-06-04 | 2011-06-03 | 261d? | finish no earlier than 2011-06-03 | C1 | 2088h | 2088h | NIMTC-CN | PCG-25 | Ericsson | mikael.wass@ericsson.com | Rel-10 | CP-48 | Frederic | MTC, M2M |  |  |  |  |
| 2868 | 698.6.2 | Deleted - CT3 part of Stage 3 for Network Improvements for Machine-Type Communications | 261d? | 2010-06-04 A | 2011-06-03 A | 100% | 2010-06-04 | 2011-06-03 | 261d? | finish no earlier than 2010-12-10 | C3 | 2088h | 2088h | NIMTC-CN | PCG-25 | Ericsson | mikael.wass@ericsson.com | Rel-10 | CP-48 | Adrian | MTC, M2M |  | PCG-27 | CP-52 |  |
| 2869 | 698.6.3 | CT4 part of Stage 3 for Network Improvements for Machine-Type Communications | 261d? | 2010-06-04 A | 2011-06-03 A | 100% | 2010-06-04 | 2011-06-03 | 261d? | finish no earlier than 2011-03-18 | C4 | 2088h | 2088h | NIMTC-CN | PCG-25 | Ericsson | mikael.wass@ericsson.com | Rel-10 | CP-48 | Kimmo | MTC, M2M |  |  |  |  |
| 2870 | 698.6.4 | CT6 part of Stage 3 for Network Improvements for Machine-Type Communications | 56d? | 2011-03-18 A | 2011-06-03 A | 100% | 2011-03-18 | 2011-06-03 | 56d? | finish no earlier than 2011-06-03 | C6 | 448h | 448h | NIMTC-CN | PCG-26 | Sagem-Orga | heiko.kruse@sagem-orga.com | Rel-10 | CP-51 | Xavier | MTC, M2M |  |  |  |  |
| 2871 | 698.7 | GERAN part of Network Improvements for Machine-Type Communications (Stage 3) | 261d? | 2010-09-03 A | 2011-09-02 A | 100% | 2010-09-03 | 2011-09-02 | 261d? | finish no earlier than 2011-09-02 | G2 | 2088h | 2088h | NIMTC | PCG-25 | Vodafone, Ericsson | leo.patanapongpibul@vodafone.com, john.diachina@ericsson.com | Rel-10 | GP-47 | Gert | MTC, M2M |  |  |  |  |
| 2872 | 698.8 | MS Conformance Test Aspects for GERAN - Network Improvements for Machine-Type Communications | 333d? | 2012-08-27 A | 2013-11-22 A | 100% | 2012-08-27 | 2013-11-22 | 333d? | finish no earlier than 2013-11-22 | G3new | 2656h | 2656h | NIMTC_GERAN-MSTest | PCG-29 | ST-Ericsson | hakan.e.grunditz@stericsson.com | Rel-10 | GP-55 | Ingbert | MTC, M2M | NIMTC_GERAN-MSTest |  |  |  |
| 2873 | 698.9 | RAN mechanisms to avoid CN overload due to Machine-Type Communications | 131d? | 2010-09-17 A | 2011-03-18 A | 100% | 2010-09-17 | 2011-03-18 | 131d? | finish no earlier than 2011-03-18 | R2; R3 | 2096h | 2096h | NIMTC-RAN_overload | PCG-25 | Huawei | Jeff Gao (gaoyq@huawei.com) | Rel-10 | RP-49 | Yong-Jun | MTC, M2M | NIMTC-RAN_overload |  |  | RP-110063 |
| 2874 | 698.10 | UE Conformance Test Aspects - Network Improvements for Machine-Type Communications | 202d? | 2012-09-11 A | 2013-06-14 A | 100% | 2012-09-11 | 2013-06-14 | 202d? | finish no earlier than 2013-06-14 | R5 | 1616h | 1616h | NIMTC-UEConTest | PCG-29 | Ericsson | calle.hagenfeldt@ericsson.com | Rel-10 | RP-57 | Ingbert | MTC, M2M | NIMTC-UEConTest |  |  | RP-130465 |

Notes:
- 2849: CP#51 completed. SP#49 moved Stage 1 from Rel-9 & Completed Stage 2. SP#40 Stage 1 completed. Continuation of Rel-8 Feature PRIOR (UID_340044)
- 2850: 22/01: acronym modified / Impacted TSs and TRs: 22.153, 22.278
- 2851: 22/01: acronym modified
- 2852: 22/01: acronym modified / Impacted TSs and TRs: 23.002, 23.203, 23.221, 23.228, 23.272, 23.401
- 2853: 22/01: acronym modified / Impacted TSs and TRs: 23.002, 23.203, 23.221, 23.228, 23.272, 23.401
- 2854: 22/01: acronym modified / Impacted TSs and TRs: 23.002, 23.203, 23.221, 23.228, 23.272, 23.401
- 2855: SP#49 TR 23.854 v100 for Information. SP#50 moved to Rel-11 SRVCC aspect of enhancements for Multimedia Priority Service UID_480135 (place holder for solution alternatives and agreed functions to be reflected in affected existing TS) / Impacted TSs and TRs: new TR 23.854
- 2856: CP#51 completed / Impacted TSs and TRs: Stage 3
- 2857: CP#51 completed / Impacted TSs and TRs: 23.008, 29.002, 29.228, 29.229, 29.272, 29.274, 29.277, 29.328, 29.329
- 2858: CP#51 completed / Impacted TSs and TRs: 29.212, 29.213, 29.214
- 2859: CP#51 completed / Impacted TSs and TRs: 24.008, 24.229, 24.301
- 2860: Triggered by Rel-8 UID_7027 Study on Facilitating Machine to Machine Communication in GSM and UMTS (FS_M2M) TR 22.868
- 2861: SP#47 completed / Impacted TSs and TRs: 22.011, New 22.368
- 2862: SP#50 updated WID SP-090832=>SP-100863 (TR 23.888 not submitted for approval to conclude Rel-10 NIMTC as it will continue to serve as basis for Rel-11 SIMTC work item) / Impacted TSs and TRs: New TR 23.888
- 2863: SP#49 completed / Impacted TSs and TRs: 23.060, 23.236, 23.401
- 2864: SP#49 stopped (activity transferred to Rel-11 Feature SIMTC under UID_490028 "TR on Security aspects of Machine-Type Communications". / Impacted TSs and TRs: New TR 33.868
- 2865: SP#51 completed / Impacted TSs and TRs: 32.251, 32.298, 32.299
- 2866: CP#52 completed / Impacted TSs and TRs: Stage 3
- 2867: CP#52 completed / Impacted TSs and TRs: 23.122, 24.008, 24.301, New 24.368
- 2868: CP#52 stopped (SA2 decided to move impact from CT3 to CT4). Updated WID CP-110147=>CP-110442 (no CT3 impact) / Impacted TSs and TRs: 29.212, 29.213, 29.215
- 2869: CP#52 completed / Impacted TSs and TRs: 23.003, 23.008, 29.002, 29.060, 29.230, 29.272, 29.274, 29.275, 29.282
- 2870: CP#52 completed / Impacted TSs and TRs: 31.102
- 2871: GP#51 completed. GP#47 approved WID / Impacted TSs and TRs: 44.018, 44.060
- 2872: GP#60 completed. GP#55 approved WID. Testing for CT1 part of Stage 3 for NIMTC UID_480105, GERAN part of NIMTC (Stage 3) UID_490003 / Impacted TSs and TRs: 51.010-1, 51.010-2
- 2873: RP#51 completed / Impacted TSs and TRs: UTRA, LTE 25.331, 25.413, 36.331, 36.413
- 2874: RP#60 completed. Testing for CT1 part of Stage 3 UID_480105, RAN mechanisms to avoid CN overload due to MTC UID_490024 / Impacted TSs and TRs: 34.123-1, 34.123-2, 34.123-3, 36.523-1, 36.523-2, 36.523-3

| ID | WBS | Task | Duration | Start | Finish | Complete | Baseline start | Baseline finish | Baseline duration | Constraint | Resources | Work | Actual work | Acronym | PCG approved | WI rapporteur name | Release | TSG approved | MCC resp | Acronym_3GU_Export | Special Focus Doc |
| --- | --- | --- | --- | --- | --- | --- | --- | --- | --- | --- | --- | --- | --- | --- | --- | --- | --- | --- | --- | --- | --- |
| 2875 | 699 | **Multi Access PDN Connectivity** | 527d? | 2009-03-13 A | 2011-03-18 A | 100% | 2009-03-13 | 2011-03-18 | 527d? |  | S2; C4; C1; C3 | 23680h | 23680h | MAPCON | PCG-22 | Telecom Italia | Rel-10 | SP-43 | Maurice | MAPCON |  |
| 2876 | 699.1 | Stage 2 for Multi Access PDN Connectivity | 401d? | 2009-03-13 A | 2010-09-23 A | 100% | 2009-03-13 | 2010-09-23 | 401d? |  | S2 | 3208h | 3208h | MAPCON |  | Telecom Italia | Rel-10 | TSG-43 | Maurice |  |  |
| 2877 | 699.2 | **CT aspects of Multi Access PDN Connectivity** | 90d? | 2010-11-15 A | 2011-03-18 A | 100% | 2010-11-15 | 2011-03-18 | 90d? |  | C4; C1; C3 | 3608h | 3608h | MAPCON-St3 | PCG-26 | ZTE | Rel-10 | CP-50 | Kimmo | MAPCON-St3 |  |
| 2878 | 699.2.1 | CT4 aspects of Multi Access PDN Connectivity | 20d? | 2010-11-15 A | 2010-12-10 A | 100% | 2010-11-15 | 2010-12-10 | 20d? | start no earlier than 2010-12-10 | C4 | 160h | 160h | MAPCON-St3 | PCG-26 | ZTE | Rel-10 | CP-50 | Kimmo |  |  |
| 2879 | 699.2.2 | CT1 aspects of Multi Access PDN Connectivity | 71d? | 2010-12-10 A | 2011-03-18 A | 100% | 2010-12-10 | 2011-03-18 | 71d? | start no earlier than 2010-12-10 | C1 | 568h | 568h | MAPCON-St3 | PCG-26 | ZTE | Rel-10 | CP-50 | Frederic |  |  |
| 2880 | 699.2.3 | CT3 aspects of Multi Access PDN Connectivity | 90d? | 2010-11-15 A | 2011-03-18 A | 100% | 2010-11-15 | 2011-03-18 | 90d? | finish no earlier than 2011-03-18 | C3 | 720h | 720h | MAPCON-St3 | PCG-26 | ZTE | Rel-10 | CP-50 | Adrian |  |  |
| 2881 | 700 | **IMS Service Continuity – Inter Device Transfer enhancements** | 924d? | 2009-06-04 A | 2012-12-07 A | 100% | 2009-06-04 | 2012-12-07 | 924d? |  | S1; S2; C1; IETF | 41168h | 41168h | IMS_SC_eIDT | PCG-23 | Huawei | Rel-10 | SP-44 | Alain | IMS_SC_eIDT |  |
| 2882 | 700.1 | Stage 1 - IMS Service Continuity – Inter Device Transfer enhancements | 211d? | 2009-06-04 A | 2010-03-25 A | 100% | 2009-06-04 | 2010-03-25 | 211d? | finish no earlier than 2010-03-25 | S1 | 1688h | 1688h | IMS_SC_eIDT | PCG-23 | Huawei | Rel-10 | SP-44 | Alain |  |  |
| 2883 | 700.2 | Stage 2 - IMS Inter-UE Transfer enhancements | 261d? | 2009-09-24 A | 2010-09-23 A | 100% | 2009-09-24 | 2010-09-23 | 261d? | finish no earlier than 2010-09-23 | S2 | 2088h | 2088h | IMS_SC_eIDT | PCG-23 | Huawei | Rel-10 | SP-45 | Maurice |  |  |
| 2884 | 700.3 | Stage 3 - IMS Inter-UE Transfer enhancements | 261d? | 2010-03-19 A | 2011-03-18 A | 100% | 2010-03-19 | 2011-03-18 | 261d? | start no earlier than 2010-03-19 | C1 | 2088h | 2088h | IMS_SC_eIDT | PCG-24 | Huawei | Rel-10 | CP-47 | Frederic |  |  |
| 2885 | 700.4 | (IETF) Stage 3 - IMS Inter-UE Transfer enhancements | 717d? | 2010-03-19 A | 2012-12-07 A | 100% | 2010-03-19 | 2012-12-07 | 717d? | finish no earlier than 2012-12-04 | C1-IETF | 5736h | 5736h | IMS_SC_eIDT | PCG-27 | christer.holmberg@ericsson.com | Rel-10 | CP-52 | Frederic |  |  |
| 2886 | 701 | **IP-Short-Message-Gateway enhancements for CPM-SMS Interworking** | 257d? | 2009-09-24 A | 2010-09-17 A | 100% | 2009-09-24 | 2010-09-17 | 257d? |  | S1; S2; C3 | 9904.8h | 9904.8h | CPM-SMS | PCG-23 | China Mobile | Rel-10 | SP-45 | Alain | CPM-SMS |  |
| 2887 | 701.1 | Stage 1 for CPM-SMS | 131d? | 2009-09-24 A | 2010-03-25 A | 100% | 2009-09-24 | 2010-03-25 | 131d? | finish no earlier than 2010-03-25 | S1 | 1048h | 1048h | CPM-SMS | PCG-23 | China Mobile | Rel-10 | SP-45 | Alain |  |  |
| 2888 | 701.2 | Stage 2 for CPM-SMS | 130.1d? | 2009-09-24 A | 2010-03-25 A | 100% | 2009-09-24 | 2010-03-25 | 130.1d? | finish no earlier than 2010-03-25 | S2 | 1040.8h | 1040.8h | CPM-SMS | PCG-23 | Orange | Rel-10 | SP-45 | Maurice |  |  |
| 2889 | 701.3 | Stage 3 for IP-Short-Message-Gateway enhancements for CPM-SMS Interworking | 206d? | 2009-12-04 A | 2010-09-17 A | 100% | 2009-12-04 | 2010-09-17 | 206d? | finish no earlier than 2010-09-17 | C3 | 1648h | 1648h | CPM-SMS | PCG-24 | Ericsson | Rel-10 | CP-46 | Adrian |  |  |
| 2890 | 702 | **Completion of Communications on Not Logged-in** | 387d? | 2009-09-24 A | 2011-03-18 A | 100% | 2009-09-24 | 2011-03-18 | 387d? |  | S1; C1; C3 | 11992h | 11992h | CCNL | PCG-23 | Deutsche Telekom | Rel-10 | SP-45 | Alain | CCNL |  |
| 2891 | 702.1 | Stage 1 for Completion of Communications on Not Logged-in | 1d? | 2009-09-24 A | 2009-09-24 A | 100% | 2009-09-24 | 2009-09-24 | 1d? | start no earlier than 2009-09-24 | S1 | 8h | 8h | CCNL | PCG-23 | Deutsche Telekom | Rel-10 | SP-45 | Alain |  |  |
| 2892 | 702.2 | CT1 part of Stage 3 for Completion of Communications on Not Logged-in | 261d? | 2010-03-19 A | 2011-03-18 A | 100% | 2010-03-19 | 2011-03-18 | 261d? | finish no earlier than 2011-03-18 | C1 | 2088h | 2088h | CCNL | PCG-24 | Deutsche Telekom | Rel-10 | CP-47 | Frederic |  |  |
| 2893 | 702.3 | CT3 part of Stage 3 for Completion of Communications on Not Logged-in | 76d? | 2010-06-04 A | 2010-09-17 A | 100% | 2010-06-04 | 2010-09-17 | 76d? | finish no earlier than 2010-09-17 | C3 | 608h | 608h | CCNL | PCG-25 | Deutsche Telekom | Rel-10 | CP-48 | Adrian |  |  |
| 2894 | 703 | **Local IP Access and Selected Internet IP Traffic Offload** | 390d? | 2009-09-24 A | 2011-03-23 A | 100% | 2009-09-24 | 2011-03-23 | 390d? |  | S2; S1; S3; S5; C4; C1 | 66128h | 66128h | LIPA_SIPTO | PCG-23 | Huawei, China Mobile | Rel-10 | SP-45 | Maurice | LIPA_SIPTO | HNB |
| 2895 | 703.1 | Stage 1 for Local IP Access and Selected Internet IP Traffic Offload | 131d? | 2009-09-24 A | 2010-03-25 A | 100% | 2009-09-24 | 2010-03-25 | 131d? | finish no earlier than 2010-03-25 | S1 | 1048h | 1048h | LIPA_SIPTO | PCG-23 | Huawei, China Mobile | Rel-10 | SP-45 | Alain |  | HNB |
| 2896 | 703.2 | TR on Local IP Access and Selected Internet IP Traffic Offload | 387d? | 2009-09-24 A | 2011-03-18 A | 100% | 2009-09-24 | 2011-03-18 | 387d? | finish no earlier than 2011-03-18 | S2 | 3096h | 3096h | LIPA_SIPTO | PCG-23 | Huawei, China Mobile | Rel-10 | SP-45 | Maurice |  | HNB |
| 2897 | 703.3 | Security for Local IP Access and Selected Internet IP Traffic Offload | 261d? | 2009-09-24 A | 2010-09-23 A | 100% | 2009-09-24 | 2010-09-23 | 261d? | finish no earlier than 2010-09-23 | S3 | 2088h | 2088h | LIPA_SIPTO | PCG-23 | Huawei, Qualcomm | Rel-10 | SP-45 | Mirko |  | HNB |
| 2898 | 703.4 | OAM&P for Local IP Access and Selected Internet IP Traffic Offload | 390d? | 2009-09-24 A | 2011-03-23 A | 100% | 2009-09-24 | 2011-03-23 | 390d? | finish no earlier than 2011-03-23 | S5 | 3120h | 3120h | LIPA_SIPTO | PCG-23 | Huawei, China Mobile | Rel-10 | SP-45 | Mirko |  | HNB |
| 2899 | 703.5 | Charging for Local IP Access and Selected Internet IP Traffic Offload | 335d? | 2009-12-10 A | 2011-03-23 A | 100% | 2009-12-10 | 2011-03-23 | 335d? | finish no earlier than 2011-03-23 | S5 | 2680h | 2680h | LIPA_SIPTO | PCG-24 | Huawei, China Mobile | Rel-10 | SP-46 | Mirko |  | HNB |

Notes:
- 2875: CP#51 completed. SP#49 Stage 2 completed. Triggered by TR 23.861 UID_410043 FS_MAPIM. Stage 1 in Rel-9 22.278 (6.2 - IP session control) / WI rapporteur e-mail: ivano.guardini@telecomitalia.it
- 2876: SP#49 completed. Triggered by TR 23.861 UID_410043 FS_MAPIM. Stage 1 in Rel-9 22.278 (6.2 - IP session control) / Impacted TSs and TRs: 23.237, 23.401, 23.402 / WI rapporteur e-mail: ivano.guardini@telecomitalia.it
- 2877: CP#51 completed / WI rapporteur e-mail: Xingyue (Joy) Zhou (zhou.xingyue@zte.com.cn)
- 2878: CP#50 completed / Impacted TSs and TRs: 29.273, 29.272, 29.002, 23.008 / WI rapporteur e-mail: Xingyue (Joy) Zhou (zhou.xingyue@zte.com.cn)
- 2879: CP#51 completed / Impacted TSs and TRs: 24.302, 24.312 / WI rapporteur e-mail: Xingyue (Joy) Zhou (zhou.xingyue@zte.com.cn)
- 2880: CP#51 completed / Impacted TSs and TRs: 29.215 / WI rapporteur e-mail: Xingyue (Joy) Zhou (zhou.xingyue@zte.com.cn)
- 2881: CP#51 completed. SP#47 Stage 1 completed. Rel-9 set Inter-Device Transfer requirements UID_410033 (IMS_SCC-IDT). Adds IDT scenarios and requirements / WI rapporteur e-mail: Amar Deol (adeol@huawei.com)
- 2882: SP#47 completed / Impacted TSs and TRs: 22.228 / WI rapporteur e-mail: Amar Deol (adeol@huawei.com)
- 2883: SP#49 completed / Impacted TSs and TRs: 23.237, 23.292, new 23.831 / WI rapporteur e-mail: Lee Valerius (lvalerius@huawei.com)
- 2884: CP#51 completed. WID updated CP-100334=>CP-110285 / Impacted TSs and TRs: 24.216, 24.229, 24.237, new (24.837, 24.337) / WI rapporteur e-mail: georg.mayer@huawei.com
- 2885: CP#58 completed / Impacted TSs and TRs: RFC 6809 (was draft-ietf-sipcore-proxy-feature) / WI rapporteur e-mail: christer.holmberg@ericsson.com
- 2886: CP#49 completed. SP#47 Stage 1 completed. IP-SM-GW enhancements for interworking with OMA CPM / WI rapporteur e-mail: Qing Huang (huangqing@chinamobile.com)
- 2887: SP#47 completed. External requirements (Stage 1 in OMA-RD-CPM-V1_0-20090310-C) / Impacted TSs and TRs: 22.340 / WI rapporteur e-mail: Qing Huang
- 2888: SP#47 completed / Impacted TSs and TRs: 23.204, new TR 23.824 / WI rapporteur e-mail: antoine.mouquet@orange-ftgroup.com
- 2889: CP#49 completed. Linked to Rel-8 UID_340031 Service-Level Interworking for Messaging Services (MESSIW) 23.204 / Impacted TSs and TRs: 29.311 / WI rapporteur e-mail: Jan Holm
- 2890: CP#51 completed. SP#45 Stage 1 completed / WI rapporteur e-mail: Kurt Bischinger
- 2891: SP#45 completed / Impacted TSs and TRs: 22.173 CR#0056r1 / WI rapporteur e-mail: Kurt Bischinger
- 2892: CP#51 completed / Impacted TSs and TRs: 24.173, 24.642 / WI rapporteur e-mail: martin.huelsemann@telekom.de
- 2893: CP#49 completed / Impacted TSs and TRs: 29.165 / WI rapporteur e-mail: martin.huelsemann@telekom.de
- 2894: TSG#51 completed. Updated WID SP-100696=>SP-110131. SP#49 Stage 2 & Security completed. UID_400035 Enhanced Home NodeB/eNodeB (EHNB) formerly covered Local IP Access to Internet and Local access to Home Network from the Home NodeB/eNodeB / WI rapporteur e-mail: patrice.hede@huawei.com, Tao Sun (suntao@chinamobile.com)
- 2895: SP#47 completed / Impacted TSs and TRs: 22.101, 22.220 / WI rapporteur e-mail: Amar Deol (adeolf@huawei.com), Gang Li (ligangyf@chinamobile.com)
- 2896: SP#51 completed. TR 23.829 for Approval / Impacted TSs and TRs: New TR 23.829 / WI rapporteur e-mail: patrice.hede@huawei.com, Tao Sun (suntao@chinamobile.com)
- 2897: SP#49 completed / Impacted TSs and TRs: 33.102, 33.107, 33.108, 33.320, 33.401 / WI rapporteur e-mail: Marcus Wong (mwong@huawei.com), Brian Rosenberg (bmr@qualcomm.com)
- 2898: SP#51 completed. Updated WID SP-100696=>SP-110131 / Impacted TSs and TRs: 32.581, 32.582, 32.584, 32.591, 32.592, 32.642, 32.646, 32.772, 32.782 / WI rapporteur e-mail: Zou Lan (zlan@huawei.com), Chen Gang (chengang@chinamobile.com)
- 2899: SP#51 completed. Updated WID SP-100696=>SP-110131 / Impacted TSs and TRs: 32.251 / WI rapporteur e-mail: shan.mingjun@huawei.com, Ai Chen (chenai@chinamobile.com)

| ID | WBS | Task | Duration | Start | Finish | Complete | Baseline start | Baseline finish | Baseline duration | Constraint | Resources | Work | Actual work | Acronym | PCG approved | WI rapporteur name | WI rapporteur e-mail | Release | TSG approved | MCC resp | Special Focus Doc | Acronym_3GU_Export |
| --- | --- | --- | --- | --- | --- | --- | --- | --- | --- | --- | --- | --- | --- | --- | --- | --- | --- | --- | --- | --- | --- | --- |
| 2900 | 703.6 | **Stage 2/3 for Local IP Access** | 387d? | 2009-09-24 A | 2011-03-18 A | 100% | 2009-09-24 | 2011-03-18 | 387d? |  | S2; C4; C1 | 17968h | 17968h | LIPA | PCG-23 | Huawei, China Mobile | patrice.hede@huawei.com, Tao Sun (suntao@chinamobile.com) | Rel-10 | SP-45 | Maurice | HNB | LIPA |
| 2901 | 703.6.1 | Stage 2 for Local IP Access | 261d? | 2009-09-24 A | 2010-09-23 A | 100% | 2009-09-24 | 2010-09-23 | 261d? | finish no earlier than 2010-08-10 | S2 | 2088h | 2088h | LIPA | PCG-23 | Huawei, China Mobile | patrice.hede@huawei.com, Tao Sun (suntao@chinamobile.com) | Rel-10 | SP-45 | Maurice | HNB |  |
| 2902 | 703.6.2 | **Stage 3 for Local IP Access** | 206d? | 2010-06-04 A | 2011-03-18 A | 100% | 2010-06-04 | 2011-03-18 | 206d? |  | C4; C1 | 6592h | 6592h | LIPA | PCG-25 | China Mobile | Zhang Hao (zhanghao@chinamobile.com) | Rel-10 | CP-48 | Kimmo | HNB |  |
| 2903 | 703.6.2.1 | CT4 part of Stage 3 for Local IP Access | 206d? | 2010-06-04 A | 2011-03-18 A | 100% | 2010-06-04 | 2011-03-18 | 206d? | finish no earlier than 2011-03-18 | C4 | 1648h | 1648h | LIPA | PCG-25 | China Mobile | Zhang Hao (zhanghao@chinamobile.com) | Rel-10 | CP-48 | Kimmo | HNB |  |
| 2904 | 703.6.2.2 | CT1 part of Stage 3 for Local IP Access | 206d? | 2010-06-04 A | 2011-03-18 A | 100% | 2010-06-04 | 2011-03-18 | 206d? | finish no earlier than 2011-03-18 | C1 | 1648h | 1648h | LIPA | PCG-25 | China Mobile | Zhang Hao (zhanghao@chinamobile.com) | Rel-10 | CP-48 | Frederic | HNB |  |
| 2905 | 703.7 | **Stage 2/3 for SIPTO for macro networks** | 387d? | 2009-09-24 A | 2011-03-18 A | 100% | 2009-09-24 | 2011-03-18 | 387d? |  | S2; C4; C1 | 17408h | 17408h | SIPTO | PCG-23 | Huawei, China Mobile | patrice.hede@huawei.com, Tao Sun (suntao@chinamobile.com) | Rel-10 | SP-45 | Maurice | HNB | SIPTO |
| 2906 | 703.7.1 | Stage 2 for SIPTO for macro networks | 261d? | 2009-09-24 A | 2010-09-23 A | 100% | 2009-09-24 | 2010-09-23 | 261d? | finish no earlier than 2010-09-23 | S2 | 2088h | 2088h | SIPTO | PCG-23 | Huawei, China Mobile | patrice.hede@huawei.com, Tao Sun (suntao@chinamobile.com) | Rel-10 | SP-45 | Maurice | HNB |  |
| 2907 | 703.7.2 | **Stage 3 for SIPTO for macro networks** | 206d? | 2010-06-04 A | 2011-03-18 A | 100% | 2010-06-04 | 2011-03-18 | 206d? |  | C4; C1 | 6032h | 6032h | SIPTO | PCG-25 | Huawei | Caixia Qi (qcxmay@huawei.com) | Rel-10 | CP-48 | Kimmo | HNB |  |
| 2908 | 703.7.2.1 | CT4 part of Stage 3 for SIPTO for macro networks | 206d? | 2010-06-04 A | 2011-03-18 A | 100% | 2010-06-04 | 2011-03-18 | 206d? | finish no earlier than 2011-03-18 | C4 | 1648h | 1648h | SIPTO | PCG-25 | Huawei | Caixia Qi (qcxmay@huawei.com) | Rel-10 | CP-48 | Kimmo | HNB |  |
| 2909 | 703.7.2.2 | CT1 part of Stage 3 for SIPTO for macro networks | 136d? | 2010-06-04 A | 2010-12-10 A | 100% | 2010-06-04 | 2010-12-10 | 136d? | finish no earlier than 2011-03-18 | C1 | 1088h | 1088h | SIPTO | PCG-25 | Huawei | Caixia Qi (qcxmay@huawei.com) | Rel-10 | CP-48 | Frederic | HNB |  |
| 2910 | 704 | **IP Flow Mobility and seamless WLAN offload** | 390d? | 2009-09-24 A | 2011-03-23 A | 100% | 2009-09-24 | 2011-03-23 | 390d? |  | S2; S1; S5; C1; C3 | 26808h | 26808h | IFOM | PCG-23 | Qualcomm | Gerardo Giaretta (gerardo@qualcomm.com) | Rel-10 | SP-45 | Maurice | WLAN | IFOM |
| 2911 | 704.1 | Stage 1 for IP Flow Mobility and seamless WLAN offload | 56d? | 2009-09-24 A | 2009-12-10 A | 100% | 2009-09-24 | 2009-12-10 | 56d? | finish no earlier than 2009-12-10 | S1 | 448h | 448h | IFOM | PCG-23 | Qualcomm | David Williams (dwilliam@qualcomm.com) | Rel-10 | SP-45 | Alain | WLAN |  |
| 2912 | 704.2 | Stage 2 for IP Flow Mobility and seamless WLAN offload | 261d? | 2009-09-24 A | 2010-09-23 A | 100% | 2009-09-24 | 2010-09-23 | 261d? | finish no earlier than 2010-09-23 | S2 | 2088h | 2088h | IFOM | PCG-23 | Qualcomm | Gerardo Giaretta (gerardo@qualcomm.com) | Rel-10 | SP-45 | Maurice | WLAN |  |
| 2913 | 704.3 | Charging for IP Flow Mobility and seamless WLAN offload | 260d? | 2010-03-25 A | 2011-03-23 A | 100% | 2010-03-25 | 2011-03-23 | 260d? | finish no earlier than 2011-03-23 | S5 | 2080h | 2080h | IFOM | PCG-24 | Alcatel-Lucent | maryse.gardella@alcatel-lucent.com | Rel-10 | SP-47 | Mirko | WLAN |  |
| 2914 | 704.4 | **Stage 3 for IP Flow Mobility and seamless WLAN offload** | 206d? | 2010-06-04 A | 2011-03-18 A | 100% | 2010-06-04 | 2011-03-18 | 206d? |  | C1; C3 | 6592h | 6592h | IFOM-CT | PCG-25 | Qualcomm | Patrick Stupar (pstupar@qualcomm.com) | Rel-10 | CP-48 | Frederic | WLAN | IFOM-CT |
| 2915 | 704.4.1 | CT1 part of Stage 3 for IP Flow Mobility and seamless WLAN offload | 206d? | 2010-06-04 A | 2011-03-18 A | 100% | 2010-06-04 | 2011-03-18 | 206d? | finish no earlier than 2011-03-18 | C1 | 1648h | 1648h | IFOM-CT | PCG-25 | Qualcomm | Patrick Stupar (pstupar@qualcomm.com) | Rel-10 | CP-48 | Frederic | WLAN |  |
| 2916 | 704.4.2 | CT3 part of Stage 3 for IP Flow Mobility and seamless WLAN offload | 206d? | 2010-06-04 A | 2011-03-18 A | 100% | 2010-06-04 | 2011-03-18 | 206d? | finish no earlier than 2011-03-18 | C3 | 1648h | 1648h | IFOM-CT | PCG-25 | Qualcomm | Patrick Stupar (pstupar@qualcomm.com) | Rel-10 | CP-48 | Adrian | WLAN |  |
| 2917 | 705 | **Enabling Coder Selection and Rate Adaptation for UTRAN and E-UTRAN for Load Adaptive Applications** | 827.4d? | 2009-07-15 A | 2012-09-07 A | 100% | 2009-07-15 | 2012-09-07 | 827.4d? |  | S2; S4; C4; C3; C1; IETF | 85939.2h | 85939.2h | ECSRA_LAA | PCG-23 | Qualcomm | AC Mahendran (ac@qualcomm.com) | Rel-10 | SP-45 | Maurice |  | ECSRA_LAA |
| 2918 | 705.1 | TR on Enabling Coder Selection and Rate Adaptation for UTRAN and E-UTRAN for Load Adaptive Applications | 186d? | 2010-01-07 A | 2010-09-23 A | 100% | 2010-01-07 | 2010-09-23 | 186d? | finish no earlier than 2010-09-23 | S2; S4 | 2976h | 2976h | ECSRA_LAA | PCG-23 | Qualcomm | AC Mahendran (ac@qualcomm.com) | Rel-10 | SP-45 | Maurice |  |  |
| 2919 | 705.2 | SA4 review of TR on Enabling Coder Selection and Rate Adaptation for UTRAN and E-UTRAN for Load Adaptive Applications | 320d? | 2009-09-24 A | 2010-12-15 A | 100% | 2009-09-24 | 2010-12-15 | 320d? | finish no earlier than 2010-12-15 | S4 | 2560h | 2560h | ECSRA_LAA | PCG-23 | Qualcomm | AC Mahendran (ac@qualcomm.com) | Rel-10 | SP-45 | Paolo |  |  |
| 2920 | 705.3 | Stage 2 for Enabling Coder Selection and Rate Adaptation for UTRAN and E-UTRAN for Load Adaptive Applications | 261d? | 2009-09-24 A | 2010-09-23 A | 100% | 2009-09-24 | 2010-09-23 | 261d? | finish no earlier than 2010-09-23 | S2 | 2088h | 2088h | ECSRA_LAA | PCG-23 | Qualcomm | AC Mahendran (ac@qualcomm.com) | Rel-10 | SP-45 | Maurice |  |  |
| 2921 | 705.4 | SA4 aspects of Enabling Coder Selection and Rate Adaptation for UTRAN and E-UTRAN for Load Adaptive Applications | 130d? | 2010-09-23 A | 2011-03-23 A | 100% | 2010-09-23 | 2011-03-23 | 130d? | finish no earlier than 2011-03-23 | S4 | 1040h | 1040h | ECSRA_LAA | PCG-25 | Qualcomm | AC Mahendran (ac@qualcomm.com) | Rel-10 | SP-49 | Paolo |  |  |
| 2922 | 705.5 | **CN aspects of Enabling Coder Selection and Rate Adaptation for UTRAN and E-UTRAN for Load Adaptive Applications** | 827.4d? | 2009-07-15 A | 2012-09-07 A | 100% | 2009-07-15 | 2012-09-07 | 827.4d? |  | C4; C3; C1 | 37560h | 37560h | ECSRA_LAA-CN | PCG-25 | Ericsson | philip.hodges@ericsson.com | Rel-10 | CP-49 | Kimmo |  | ECSRA_LAA-CN |
| 2923 | 705.5.1 | CT4 part of CN aspects of Enabling Coder Selection and Rate Adaptation for UTRAN and E-UTRAN for Load Adaptive Applications | 186d? | 2010-09-17 A | 2011-06-03 A | 100% | 2010-09-17 | 2011-06-03 | 186d? | start no earlier than 2010-09-17 | C4 | 1488h | 1488h | ECSRA_LAA-CN | PCG-25 | Ericsson | philip.hodges@ericsson.com | Rel-10 | CP-49 | Kimmo |  |  |
| 2924 | 705.5.2 | (IETF) CT3, CT4 part of CN aspects of Enabling Coder Selection and Rate Adaptation for UTRAN and E-UTRAN for Load Adaptive Applications | 827.4d? | 2009-07-15 A | 2012-09-07 A | 100% | 2009-07-15 | 2012-09-07 | 827.4d? | finish no earlier than 2012-09-07 | C3-IETF; C4-IETF | 13238.4h | 13238.4h | ECSRA_LAA-CN | PCG-27 | Lionel Morand |  | Rel-10 | CP-53 | Adrian |  |  |
| 2925 | 705.5.3 | CT3 part of CN aspects of Enabling Coder Selection and Rate Adaptation for UTRAN and E-UTRAN for Load Adaptive Applications | 186d? | 2010-09-17 A | 2011-06-03 A | 100% | 2010-09-17 | 2011-06-03 | 186d? | finish no earlier than 2011-06-03 | C3 | 1488h | 1488h | ECSRA_LAA-CN | PCG-25 | Ericsson | philip.hodges@ericsson.com | Rel-10 | CP-49 | Adrian |  |  |
| 2926 | 705.5.4 | CT1 part of CN aspects of Enabling Coder Selection and Rate Adaptation for UTRAN and E-UTRAN for Load Adaptive Applications | 186d? | 2010-09-17 A | 2011-06-03 A | 100% | 2010-09-17 | 2011-06-03 | 186d? | start no earlier than 2010-09-17 | C1 | 1488h | 1488h | ECSRA_LAA-CN | PCG-25 | Ericsson | philip.hodges@ericsson.com | Rel-10 | CP-49 | Frederic |  |  |

Notes:
- 2900: -
- 2901: SP#49 completed (has impacts to RAN) / Impacted TSs and TRs: 23.060, 23.401
- 2902: CP#51 completed
- 2903: CP#51 completed / Impacted TSs and TRs: 23.008, 23.015, 29.002, 29.060, 29.272, 29.274, 29.281, 29.303
- 2904: CP#51 completed / Impacted TSs and TRs: 24.008, 24.301
- 2905: -
- 2906: SP#49 completed (SIPTO GW selection for wild card APN and for GERAN. Serving-GW selection for SIPTO. Corrections and Clarifications of the SIPTO procedure) / Impacted TSs and TRs: 23.060, 23.401
- 2907: CP#51 completed. Updated WID CP-100419=>CP-110091
- 2908: CP#51 completed. Updated WID CP-100419=>CP-110091 / Impacted TSs and TRs: 23.003, 23.008, 29.002, 29.272, 29.303
- 2909: CP#50 completed / Impacted TSs and TRs: 24.008, 24.301
- 2910: SP#51 completed. Triggered by Rel-10 TR 23.861 (UID_410043 Study on Multi Access PDN connectivity and IP flow mobility - MAPIM)
- 2911: SP#46 completed / Impacted TSs and TRs: 22.278
- 2912: SP#49 completed / Impacted TSs and TRs: 23.203, 23.402, new 23.261
- 2913: SP#51 completed / Impacted TSs and TRs: 32.240, 32.251, 32.252, 32.298, 32.299
- 2914: CP#51 completed / Impacted TSs and TRs: Stage 3
- 2915: CP#51 completed / Impacted TSs and TRs: 24.008, 24.301, 24.302, 24.303, 24.312, 24.327
- 2916: CP#51 completed / Impacted TSs and TRs: 29.212, 29.213, 29.214, 29.215
- 2917: CP#52 completed. Triggered by Rel-9 UID_440013 Vocoder rate adaptation for LTE / Impacted TSs and TRs: UTRA, LTE
- 2918: SP#48 completed / Impacted TSs and TRs: new 23.860
- 2919: SP#50 completed / Impacted TSs and TRs: new 23.860
- 2920: SP#49 completed / Impacted TSs and TRs: 23.060, 23.203, 23.228, 23.401
- 2921: SP#51 completed / Impacted TSs and TRs: 26.114
- 2922: CP#52 completed / Impacted TSs and TRs: Stage 2/3
- 2923: CP#52 completed / Impacted TSs and TRs: 23.334, 29.334, 29.238, 23.333, 29.333, 29.232, 29.332
- 2924: CP#57 completed / Impacted TSs and TRs: RFC 6679 (was draft-ietf-avtcore-ecn-for-rtp)
- 2925: CP#52 completed / Impacted TSs and TRs: 29.162, 29.163, 29.213, 29.235, 29.292
- 2926: CP#52 completed / Impacted TSs and TRs: 24.229

| ID | WBS | Task | Type | Duration | Start | Finish | Complete | Baseline start | Baseline finish | Baseline duration | Constraint | Resources | Work | Actual work | Acronym | PCG approved | Impacted TSs and TRs | WI rapporteur name | WI rapporteur e-mail | Release | TSG approved | MCC resp | Special Focus Doc | Acronym_3GU_Export | PCG stopped | TSG stopped |
| --- | --- | --- | --- | --- | --- | --- | --- | --- | --- | --- | --- | --- | --- | --- | --- | --- | --- | --- | --- | --- | --- | --- | --- | --- | --- | --- |
| 2927 | 706 | **Extended H(e)NB features** |  | 467d? | 2008-12-11 A | 2010-09-23 A | 100% | 2008-12-11 | 2010-09-23 | 467d? |  | S1; S2; S3 | 15552h | 15552h | EHNBF | PCG-23 | UTRA, LTE | NEC | joerg.swetina@neclab.eu | Rel-10 | SP-45 | Alain | HNB | EHNBF |  |  |
| 2928 | 706.1 | Stage 1 of Extended H(e)NB features |  | 131d? | 2009-09-24 A | 2010-03-25 A | 100% | 2009-09-24 | 2010-03-25 | 131d? | finish no earlier than 2010-03-25 | S1 | 1048h | 1048h | EHNBF | PCG-23 | 22.220 | NEC | joerg.swetina@neclab.eu | Rel-10 | SP-45 | Alain | HNB |  |  |  |
| 2929 | 706.2 | IMS aspects of Architecture for Home NodeB |  | 336d? | 2008-12-11 A | 2010-03-25 A | 100% | 2008-12-11 | 2010-03-25 | 336d? | finish no earlier than 2010-03-25 | S2 | 2688h | 2688h | EHNB-IMS | PCG-22 | New 23.832 | Alcatel-Lucent | Nicolas Drevon | Rel-10 | SP-42 | Maurice | HNB | EHNB-IMS |  |  |
| 2930 | 706.3 | Extended H(e)NB Security features (Stage 2) |  | 76d? | 2010-06-10 A | 2010-09-23 A | 100% | 2010-06-10 | 2010-09-23 | 76d? | finish no earlier than 2010-09-23 | S3 | 608h | 608h | EHNBF-Sec | PCG-25 | 33.320 | Huawei | Marcus Wong (mwong@huawei.com) | Rel-10 | SP-48 | Mirko | HNB | EHNBF-Sec |  |  |
| 2931 | 707 | **Optimal Media Routing** |  | 314d? | 2010-03-25 A | 2011-06-08 A | 100% | 2010-03-25 | 2011-06-08 | 314d? |  | S2; S5; C3; C1 | 22696h | 22696h | OMR | PCG-24 |  | Alcatel-Lucent | andy.bennett@alcatel-lucent.com | Rel-10 | SP-46 | Maurice |  | OMR |  |  |
| 2932 | 707.1 | Stage 2 for Optimal Media Routing | milestone | 0d? | 2010-03-25 A | 2010-03-25 A | 100% | 2010-03-25 | 2010-03-25 | 0d? |  | S2 |  |  | OMR | PCG-24 | 23.228 | Alcatel-Lucent | andy.bennett@alcatel-lucent.com | Rel-10 | SP-46 | Maurice |  |  |  |  |
| 2933 | 707.2 | **Stage 3 for Optimal Media Routing** |  | 261d? | 2010-06-04 A | 2011-06-03 A | 100% | 2010-06-04 | 2011-06-03 | 261d? |  | C3; C1; C4 | 11648h | 11648h | OMR | PCG-25 |  | Alcatel-Lucent | jim.calme@alcatel-lucent.com | Rel-10 | CP-48 | Adrian |  |  |  |  |
| 2934 | 707.2.1 | CT3 part of Stage 3 for Optimal Media Routeing |  | 261d? | 2010-06-04 A | 2011-06-03 A | 100% | 2010-06-04 | 2011-06-03 | 261d? | finish no earlier than 2011-06-03 | C3 | 2088h | 2088h | OMR | PCG-25 | 29.162, 29.163, 29.165, 29.235, new TS 29.079 | Alcatel-Lucent | jim.calme@alcatel-lucent.com | Rel-10 | CP-48 | Adrian |  |  |  |  |
| 2935 | 707.2.2 | CT1 part of Stage 3 for Optimal Media Routeing |  | 206d? | 2010-06-04 A | 2011-03-18 A | 100% | 2010-06-04 | 2011-03-18 | 206d? | finish no earlier than 2011-03-18 | C1 | 1648h | 1648h | OMR | PCG-25 | 24.229 | Alcatel-Lucent | jim.calme@alcatel-lucent.com | Rel-10 | CP-48 | Frederic |  |  |  |  |
| 2936 | 707.2.3 | Deleted - CT4 part of Stage 3 for Optimal Media Routeing |  | 206d? | 2010-06-04 A | 2011-03-18 A | 100% | 2010-06-04 | 2011-03-18 | 206d? | finish no earlier than 2011-03-18 | C4 | 1648h | 1648h | OMR | PCG-25 |  | Alcatel-Lucent | jim.calme@alcatel-lucent.com | Rel-10 | CP-48 | Kimmo |  |  | PCG-26 | CP-51 |
| 2937 | 707.3 | Charging for Optimal Media Routing |  | 125d? | 2010-12-16 A | 2011-06-08 A | 100% | 2010-12-16 | 2011-06-08 | 125d? | finish no earlier than 2011-06-08 | S5 | 1000h | 1000h | OMR | PCG-26 | 32.260, 32.298, 32.299 | Alcatel-Lucent | maryse.gardella@alcatel-lucent.com | Rel-10 | SP-50 | Mirko |  |  |  |  |
| 2938 | 708 | **IMS Emergency Session Enhancements** |  | 312d? | 2010-03-25 A | 2011-06-03 A | 100% | 2010-03-25 | 2011-06-03 | 312d? |  | S1; S2; C1 | 9552h | 9552h | IESE | PCG-24 |  | Deutsche Telekom, T-Mobile | michele.zarri@t-mobile.co.uk | Rel-10 | SP-47 | Maurice | Public Safety (I-A) | IESE |  |  |
| 2939 | 708.1 | Stage 1 for IMS Emergency Session Enhancements |  | 1d? | 2010-03-25 A | 2010-03-25 A | 100% | 2010-03-25 | 2010-03-25 | 1d? | start no earlier than 2010-03-25 | S1 | 8h | 8h | IESE | PCG-24 | 22.101 CR#0343 | Deutsche Telekom, T-Mobile | Kurt Bischinger | Rel-10 | SP-47 | Alain | Public Safety (I-A) |  |  |  |
| 2940 | 708.2 | Stage 2 for IMS Emergency Session Enhancements |  | 131d? | 2010-03-25 A | 2010-09-23 A | 100% | 2010-03-25 | 2010-09-23 | 131d? | finish no earlier than 2010-09-23 | S2 | 1048h | 1048h | IESE | PCG-24 | 23.167 | Deutsche Telekom, T-Mobile | michele.zarri@t-mobile.co.uk | Rel-10 | SP-47 | Maurice | Public Safety (I-A) |  |  |  |
| 2941 | 708.3 | Stage 3 for IMS Emergency Session Enhancements |  | 126d? | 2010-12-10 A | 2011-06-03 A | 100% | 2010-12-10 | 2011-06-03 | 126d? | finish no earlier than 2011-06-03 | C1 | 1008h | 1008h | IESE | PCG-26 | 24.229 | Deutsche Telekom | reinhard.lauster@t-mobile.at | Rel-10 | CP-50 | Frederic | Public Safety (I-A) |  |  |  |
| 2942 | 709 | **S2b Mobility based on GTP** |  | 202d? | 2010-06-10 A | 2011-03-18 A | 100% | 2010-06-10 | 2011-03-18 | 202d? |  | S2; C4; C3; C1 | 12800h | 12800h | SMOG | PCG-25 |  | Alcatel-Lucent | bruno.landais@alcatel-lucent.com | Rel-10 | SP-48 | Maurice | WLAN | SMOG |  |  |
| 2943 | 709.1 | Stage 2 for S2b Mobility based on GTP |  | 76d? | 2010-06-10 A | 2010-09-23 A | 100% | 2010-06-10 | 2010-09-23 | 76d? | finish no earlier than 2010-09-23 | S2 | 608h | 608h | SMOG | PCG-25 | 23.002, 23.203, 23.402 | Alcatel-Lucent | bruno.landais@alcatel-lucent.com | Rel-10 | SP-48 | Maurice | WLAN |  |  |  |
| 2944 | 709.2 | **Stage 3 for S2b Mobility based on GTP** |  | 131d? | 2010-09-17 A | 2011-03-18 A | 100% | 2010-09-17 | 2011-03-18 | 131d? |  | C4; C3; C1 | 5728h | 5728h | SMOG-St3 | PCG-25 |  | Alcatel-Lucent | bruno.landais@alcatel-lucent.com | Rel-10 | CP-49 | Kimmo | WLAN | SMOG-St3 |  |  |
| 2945 | 709.2.1 | CT4 part of Stage 3 for S2b Mobility based on GTP |  | 131d? | 2010-09-17 A | 2011-03-18 A | 100% | 2010-09-17 | 2011-03-18 | 131d? | finish no earlier than 2011-03-18 | C4 | 1048h | 1048h | SMOG-St3 | PCG-25 | 23.003, 23.007, 23.008, 29.273, 29.274, 29.281, 29.303 | Alcatel-Lucent | bruno.landais@alcatel-lucent.com | Rel-10 | CP-49 | Kimmo | WLAN |  |  |  |
| 2946 | 709.2.2 | CT3 part of Stage 3 for S2b Mobility based on GTP |  | 131d? | 2010-09-17 A | 2011-03-18 A | 100% | 2010-09-17 | 2011-03-18 | 131d? | finish no earlier than 2011-03-18 | C3 | 1048h | 1048h | SMOG-St3 | PCG-25 | 29.212, 29.213, 29.215 | Alcatel-Lucent | bruno.landais@alcatel-lucent.com | Rel-10 | CP-49 | Adrian | WLAN |  |  |  |
| 2947 | 709.2.3 | CT1 part of Stage 3 for S2b Mobility based on GTP |  | 61d? | 2010-09-17 A | 2010-12-10 A | 100% | 2010-09-17 | 2010-12-10 | 61d? | finish no earlier than 2010-12-10 | C1 | 488h | 488h | SMOG-St3 | PCG-25 | 24.302 | Alcatel-Lucent | bruno.landais@alcatel-lucent.com | Rel-10 | CP-49 | Frederic | WLAN |  |  |  |
| 2948 | 710 | **Policy Enhancements for Sponsored Connectivity and Coherent Access to Policy related Databases** |  | 113.15d? | 2010-10-12 A | 2011-03-18 A | 100% | 2010-10-12 | 2011-03-18 | 113.15d? |  | S2; C3 | 2378.4h | 2378.4h | PEST | PCG-26 |  | Qualcomm | AC Mahendran (ac@qualcomm.com) | Rel-10 | SP-50 | Maurice |  | PEST |  |  |
| 2949 | 710.1 | Stage 2 for Policy Enhancements for Sponsored Connectivity and Coherent Access to Policy related Databases | milestone | 0d? | 2010-10-12 A | 2010-12-15 A | 100% | 2010-10-12 | 2010-12-15 | 0d? | finish no earlier than 2010-12-15 | S2 |  |  | PEST | PCG-26 | 23.002, 23.203 | Qualcomm | AC Mahendran (ac@qualcomm.com) | Rel-10 | SP-50 | Maurice |  |  |  |  |
| 2950 | 710.2 | CT3 aspects of Policy Enhancements for Sponsored Connectivity and Coherent Access to Policy related Databases |  | 71d? | 2010-12-10 A | 2011-03-18 A | 100% | 2010-12-10 | 2011-03-18 | 71d? | finish no earlier than 2011-03-18 | C3 | 568h | 568h | PEST-CT3 | PCG-26 | 29.212, 29.213, 29.214, 29.215 | ZTE | zhou.xiaoyun@zte.com.cn | Rel-10 | CP-50 | Adrian |  | PEST-CT3 |  |  |

Notes:
- 2927: SP#49 completed. Adds extensions to Rel-9 functionality in UID_400035 Enhanced Home NodeB / eNodeB (EHNB)
- 2928: SP#47 completed
- 2929: SP#47 completed. Chosen solution has no normative impacts
- 2930: SP#49 completed
- 2931: CP#52 completed. SP#47 Stage 2 completed. Triggered by TR 23.894 (UID_370050 Study on System enhancements for the use of IMS servicES in CP-150local breakout)
- 2932: SP#47 completed
- 2933: CP#51 completion 03/11=>06/11. WID updated CP-100327=>CP-110134
- 2934: CP#52 completed
- 2935: CP#51 completed. WID updated CP-100327=>CP-110134
- 2936: CP#51 stopped (CT4 specs not impacted). WID updated CP-100327=>CP-110134
- 2937: SP#52 completed. Stage 3: Linked to CT3 TS 29.079 OMR within the IMS; Stage 3 (UID_480110)
- 2938: CP#52 completed. SP#49 completed. Source of external requirements: ETSI TISPAN TS 181.019 (Business Communication Requirements)
- 2939: SP#47 completed
- 2940: SP#49 completed
- 2941: CP#52 completed
- 2942: CP#51 completed. SP#49 Stage 2 completed. Related to Rel-10 UID_470049 Study on S2b mobility based on GTP (TR23.834), UID_350027 SAE for support for non-3GPP accesses. Stage1 in Rel-8 UID_320022 Reqs for evolution of 3GPP system architecture (AIPN-SAE)
- 2943: SP#49 completed
- 2944: CP#51 Stage 3 completed
- 2945: CP#51 completed
- 2946: CP#51 completed
- 2947: CP#50 completed
- 2948: CP#51 completed. SP#50 Stage 2 completed. Triggered by the SA1,SA2 Rel-10 TR 23.813 Study on Policy solutions and enhancements (FS_PP) UID_440047. Provides Video Call seamless service continuity for 3G/LTE terminal user
- 2949: SP#51 updated WID SP-100702=>SP-110196. SP#49 work completed as SA2 CRs approved under TEI10 (SP-10557)
- 2950: CP#51 completed

| ID | WBS | Task | Duration | Start | Finish | Complete | Baseline start | Baseline finish | Baseline duration | Constraint | Resources | Work | Actual work | Acronym | PCG approved | WI rapporteur name | WI rapporteur e-mail | Release | TSG approved | MCC resp | Acronym_3GU_Export | PCG stopped | TSG stopped |
| --- | --- | --- | --- | --- | --- | --- | --- | --- | --- | --- | --- | --- | --- | --- | --- | --- | --- | --- | --- | --- | --- | --- | --- |
| 2951 | 711 | **Lawful Interception in the 3GPP Rel-10** | 315d? | 2010-03-25 A | 2011-06-08 A | 100% | 2010-03-25 | 2011-06-08 | 315d? |  | S3 | 20480h | 20480h | LI10 | PCG-24 | PIDS, BT | Koen Jaspers (k.b.jaspers@minjus.nl), alex.leadbeater@bt.com | Rel-10 | SP-47 | Mirko | LI10 |  |  |
| 2952 | 711.1 | LI for CAT (Customer Alerting Tones) | 315d? | 2010-03-25 A | 2011-06-08 A | 100% | 2010-03-25 | 2011-06-08 | 315d? | finish no earlier than 2011-03-23 | S3 | 2520h | 2520h | LI10 | PCG-24 | PIDS, BT | Koen Jaspers (k.b.jaspers@minjus.nl), alex.leadbeater@bt.com | Rel-10 | SP-47 | Mirko |  |  |  |
| 2953 | 711.2 | LI for CRS (Customized Ringing Signal) | 315d? | 2010-03-25 A | 2011-06-08 A | 100% | 2010-03-25 | 2011-06-08 | 315d? | finish no earlier than 2011-03-23 | S3 | 2520h | 2520h | LI10 | PCG-24 | PIDS, BT | Koen Jaspers (k.b.jaspers@minjus.nl), alex.leadbeater@bt.com | Rel-10 | SP-47 | Mirko |  |  |  |
| 2954 | 711.3 | LI for EPS enhancements | 315d? | 2010-03-25 A | 2011-06-08 A | 100% | 2010-03-25 | 2011-06-08 | 315d? | finish no earlier than 2011-03-23 | S3 | 2520h | 2520h | LI10 | PCG-24 | PIDS, BT | Koen Jaspers (k.b.jaspers@minjus.nl), alex.leadbeater@bt.com | Rel-10 | SP-47 | Mirko |  |  |  |
| 2955 | 711.4 | LI for VCC (Voice Call Continuity) | 260d? | 2010-03-25 A | 2011-03-23 A | 100% | 2010-03-25 | 2011-03-23 | 260d? | finish no earlier than 2011-03-23 | S3 | 2080h | 2080h | LI10 | PCG-24 | PIDS, BT | Koen Jaspers (k.b.jaspers@minjus.nl), alex.leadbeater@bt.com | Rel-10 | SP-47 | Mirko |  |  |  |
| 2956 | 711.5 | LI for MEDIASEC (IMS Media security) | 260d? | 2010-03-25 A | 2011-03-23 A | 100% | 2010-03-25 | 2011-03-23 | 260d? | finish no earlier than 2011-03-23 | S3 | 2080h | 2080h | LI10 | PCG-24 | PIDS, BT | Koen Jaspers (k.b.jaspers@minjus.nl), alex.leadbeater@bt.com | Rel-10 | SP-47 | Mirko |  |  |  |
| 2957 | 711.6 | LI for H(e)NB also with Local IP Access and Selected IP Traffic Offload (LIPA, SIPTO) | 260d? | 2010-03-25 A | 2011-03-23 A | 100% | 2010-03-25 | 2011-03-23 | 260d? | finish no earlier than 2011-03-23 | S3 | 2080h | 2080h | LI10 | PCG-24 | PIDS, BT | Koen Jaspers (k.b.jaspers@minjus.nl), alex.leadbeater@bt.com | Rel-10 | SP-47 | Mirko |  |  |  |
| 2958 | 711.7 | LI for MBMS enhancements | 260d? | 2010-03-25 A | 2011-03-23 A | 100% | 2010-03-25 | 2011-03-23 | 260d? | finish no earlier than 2011-03-23 | S3 | 2080h | 2080h | LI10 | PCG-24 | PIDS, BT | Koen Jaspers (k.b.jaspers@minjus.nl), alex.leadbeater@bt.com | Rel-10 | SP-47 | Mirko |  |  |  |
| 2959 | 711.8 | LI for LCLS (Local Call Local Switch) | 260d? | 2010-03-25 A | 2011-03-23 A | 100% | 2010-03-25 | 2011-03-23 | 260d? | finish no earlier than 2011-03-23 | S3 | 2080h | 2080h | LI10 | PCG-24 | PIDS, BT | Koen Jaspers (k.b.jaspers@minjus.nl), alex.leadbeater@bt.com | Rel-10 | SP-47 | Mirko |  |  |  |
| 2960 | 712 | Optimization of IMS based PSS and MBMS User Service | 260d? | 2010-03-25 A | 2011-03-23 A | 100% | 2010-03-25 | 2011-03-23 | 260d? | finish no earlier than 2011-03-23 | S4 | 2080h | 2080h | OPT_IMS_PSS_MBMS_US | PCG-24 | Ericsson | markus.kampmann@ericsson.com | Rel-10 | SP-47 | Paolo | OPT_IMS_PSS_MBMS_US |  |  |
| 2961 | 713 | **HTTP-based Streaming and Download Services** | 392d? | 2010-03-25 A | 2011-09-21 A | 100% | 2010-03-25 | 2011-09-21 | 392d? |  | S4; IETF | 10468.8h | 10468.8h | HTTP_SDS | PCG-24 | Qualcomm | Thomas Stockhammer (c_tstock@qualcomm.com) | Rel-10 | SP-47 | Paolo | HTTP_SDS |  |  |
| 2962 | 713.1 | HTTP-based Streaming and Download Services in 3GPP | 315d? | 2010-03-25 A | 2011-06-08 A | 100% | 2010-03-25 | 2011-06-08 | 315d? | finish no earlier than 2011-05-26 | S4 | 2520h | 2520h | HTTP_SDS | PCG-24 | Qualcomm | Thomas Stockhammer (c_tstock@qualcomm.com) | Rel-10 | SP-47 | Paolo |  |  |  |
| 2963 | 713.2 | (IETF) HTTP-based Streaming and Download Services in 3GPP | 211.6d? | 2010-03-25 A | 2011-09-21 A | 100% | 2010-03-25 | 2011-09-21 | 211.6d? | start no earlier than 2010-03-25 | S4-IETF | 1676.8h | 1676.8h | HTTP_SDS | PCG-27 |  |  | Rel-10 | CP-52 | Paolo |  |  |  |
| 2964 | 714 | PSS and MBMS enhancements | 205d? | 2010-06-10 A | 2011-03-23 A | 100% | 2010-06-10 | 2011-03-23 | 205d? | finish no earlier than 2011-03-23 | S4 | 1640h | 1640h | MBS_Enh | PCG-25 | Ericsson | Markus.Kampmann@ericsson.com | Rel-10 | SP-48 | Paolo | MBS_Enh |  |  |
| 2965 | 715 | Enhancements and Addition of Audio Tests to 26.131 and 26.132 | 260d? | 2010-06-10 A | 2011-06-08 A | 100% | 2010-06-10 | 2011-06-08 | 260d? | finish no earlier than 2011-06-08 | S4 | 2080h | 2080h | EAAT | PCG-25 | Vodafone | ramin.afchar@vodafone.com | Rel-10 | SP-48 | Paolo | EAAT |  |  |
| 2966 | 716 | Video Coding Enhancements in MTSI | 3d? | 2011-03-21 A | 2011-03-23 A | 100% | 2011-03-21 | 2011-03-23 | 3d? | start no earlier than 2011-03-21 | S4 | 24h | 24h | VCEM | PCG-26 | Ericsson | frederic.gabin@ericsson.com | Rel-10 | SP-51 | Paolo | VCEM |  |  |
| 2967 | 717 | **Rel-10 Operations, Administration, Maintenance and Provisioning (OAM&P)** | 467d? | 2009-12-10 A | 2011-09-21 A | 100% | 2009-12-10 | 2011-09-21 | 467d? |  | S5; C4 | 54144h | 54144h | OAM10 | PCG-24 |  |  | Rel-10 | SP-46 | Mirko | OAM10 |  |  |
| 2968 | 717.1 | **Rel-10 Network Infrastructure Management** | 467d? | 2009-12-10 A | 2011-09-21 A | 100% | 2009-12-10 | 2011-09-21 | 467d? |  | S5 | 14592h | 14592h | OAM10-NIM | PCG-24 |  |  | Rel-10 | SP-46 | Mirko | OAM10-NIM |  |  |
| 2969 | 717.1.1 | Common RAT Network Resource Model (NRM) | 390d? | 2009-12-10 A | 2011-06-08 A | 100% | 2009-12-10 | 2011-06-08 | 390d? | finish no earlier than 2011-06-08 | S5 | 3120h | 3120h | RAT_NRM_common | PCG-24 | Ericsson | robert.petersen@ericsson.com | Rel-10 | SP-46 | Mirko | RAT_NRM_common |  |  |
| 2970 | 717.1.2 | IRP Solution Set specification organisation improvements | 260d? | 2010-03-25 A | 2011-03-23 A | 100% | 2010-03-25 | 2011-03-23 | 260d? | finish no earlier than 2011-03-23 | S5 | 2080h | 2080h | OAM-IRP-SS | PCG-24 | Nokia Siemens Networks, Huawei | Jörg Schmidt (J.Schmidt@nsn.com), Lan Zou (zlan@huawei.com) | Rel-10 | SP-47 | Mirko | OAM-IRP-SS |  |  |
| 2971 | 717.1.3 | Deleted - Service Oriented Architecture (SOA) for IRP continuation from Rel-9 | 260d? | 2010-03-25 A | 2011-03-23 A | 100% | 2010-03-25 | 2011-03-23 | 260d? | finish no earlier than 2011-06-08 | S5 | 2080h | 2080h | OAM-SOA-IRP | PCG-24 | Nokia Siemens Networks, Ericsson | Jörg Schmidt (J.Schmidt@NSN.com), edwin.tse@ericsson.com | Rel-10 | SP-47 | Mirko | OAM-SOA-IRP | PCG-26 | SP-51 |
| 2972 | 717.1.4 | IRP Overview, Profiles & Usage Guide | 260d? | 2010-06-10 A | 2011-06-08 A | 100% | 2010-06-10 | 2011-06-08 | 260d? | finish no earlier than 2011-06-08 | S5 | 2080h | 2080h | OAM-NIM-IRP_OPU | PCG-25 | Nokia Siemens Networks | Jörg Schmidt (J.Schmidt@NSN.com) | Rel-10 | SP-48 | Mirko | OAM-NIM-IRP_OPU |  |  |
| 2973 | 717.1.5 | Alarm Correlation and Root Cause Analysis | 133d? | 2011-03-23 A | 2011-09-21 A | 100% | 2011-03-23 | 2011-09-21 | 133d? | finish no earlier than 2011-09-21 | S5 | 1048h | 1048h | OAM-AC-RCA | PCG-26 | Ericsson | brendan.hassett@ericsson.com | Rel-10 | SP-51 | Mirko | OAM-AC-RCA |  |  |
| 2974 | 717.1.6 | Inventory Management Network Resource Model enhancements | 56d? | 2011-03-23 A | 2011-06-08 A | 100% | 2011-03-23 | 2011-06-08 | 56d? | start no earlier than 2011-03-23 | S5 | 448h | 448h | OAM-IM-NMR | PCG-26 | Nokia Siemens Networks | olaf.pollakowski@nsn.com | Rel-10 | SP-51 | Mirko | OAM-IM-NMR |  |  |

Notes:
- 2951: SP#52 completed / Impacted TSs and TRs: 33.106 (LI requirements), 33.107 (LI architecture and functions), 33.108 (Handover interface for LI)
- 2952: SP#52 completed / Impacted TSs and TRs: 33.106, 33.107, 33.108
- 2953: SP#52 completed / Impacted TSs and TRs: 33.106, 33.107, 33.108
- 2954: SP#52 completed / Impacted TSs and TRs: 33.106, 33.107, 33.108
- 2955: SP#51 completed / Impacted TSs and TRs: 33.106, 33.107, 33.108
- 2956: SP#51 completed / Impacted TSs and TRs: 33.106, 33.107, 33.108
- 2957: SP#51 completed / Impacted TSs and TRs: 33.106, 33.107, 33.108
- 2958: SP#51 completed / Impacted TSs and TRs: 33.106, 33.107, 33.108
- 2959: SP#51 completed / Impacted TSs and TRs: 33.106, 33.107, 33.108
- 2960: SP#51 completed. Work to enhance UID_430046 Rel-9 IMS_PSS_MBMS_US_EXT / Impacted TSs and TRs: 26.237
- 2961: SP#52 completed. Work to enhance UID_430038 Rel-9 PSS and MBMS extensions
- 2962: SP#52 completed / Impacted TSs and TRs: 26.234, 26.244, 26.346, new TS 26.247
- 2963: SP#53/IETF#81: Draft not included in 3GPP documentation. Dec.14: IETF RFC added / Impacted TSs and TRs: RFC 6381 (was draft-gellens-mime-bucket-bis)
- 2964: SP#51 completed. Linked to Rel-9 Feature UID_430038 PSS and MBMS extensions (PMA-MBS_Ext). / Impacted TSs and TRs: 26.234, 26.346
- 2965: SP#52 completed. Reduce fragmentation in acoustic testing (3GPP SA4, ETSI STQ, GCF CAG, CTIA) & Review existing acoustic tests to determine need for new spec / Impacted TSs and TRs: 26.131, 26.132
- 2966: SP#51 completed. Linked to Rel-7 UID_7040 Multimedia Telephony Service for IMS - Media handling and interaction in MTSI (MTSI-MHI) / Impacted TSs and TRs: 26.114
- 2967: OAM10 is an umbrella Feature also for OAM&P related TEI10 type of changes that are not part of any other dedicated feature/WI / Impacted TSs and TRs: TR 30.820
- 2968: umbrella BB
- 2969: SP#52 completed. Share equipment btw several RATs (RET,TMA,repeaters) to reduce costs. With existing modelling is difficult to see that several cells are affected when an antenna tilt is changed etc / Impacted TSs and TRs: 32.616, 32.642, 32.646, 32.652, 32.656, 32.762, 32.766 new (32.791, 32.792, 32.796)
- 2970: SP#51 completed / Impacted TSs and TRs: 32.153, new (32.111-6,32.126,32.176,32.306,32.316,32.326,32.336,32.346,32.356,32.366,32.376,32.386,32.396,32.416,32.446,32.506/26/36,32.606,32.616,32.626,32.636,32.646,32.656,32.666,32.676,32.696,32.716,32.726,32.736,32.746,32.756,32.766,32.776,32.786)
- 2971: SP#51 work stopped (Reason: lack of progress). Continuation of Rel-9 UID_440065 SOA for IRP (covering SOA Architecture & SOA-supporting Solution Set) to address SOA conforming Registration & Discovery capabilities / Impacted TSs and TRs: 32.101, 32.150
- 2972: SP#52 completed. Updated WID SP-100777=>SP-110277 / Impacted TSs and TRs: new TS 32.103
- 2973: SP#53 completed. Triggered by Rel-10 TR 32.832 Study on Alarm Correlation and Alarm Root Cause Analysis UID_480045 & TR 32.829 Study on Harmonization of 3GPP Alarm IRP and TMF Interface Program Fault Management UID_460038 / Impacted TSs and TRs: 32.111-1, 32.111-2, 32.111-6
- 2974: SP#52 completed. Inventory NRM specified in Rel-6 is mainly hardware related. Rel-10 TR 32.828 recommends extending the scope of inventory NRM. Additionally, NGMN Top OPE Recs, v1.0 sets inventory enhancements as one of top 10 priority items / Impacted TSs and TRs: 32.690, 32.691, 32.692, 32.696

| ID | WBS | Task | Duration | Start | Finish | Complete | Baseline start | Baseline finish | Baseline duration | Constraint | Resources | Work | Actual work | Acronym | PCG approved | Release | TSG approved | MCC resp | Special Focus Doc | Acronym_3GU_Export | WI rapporteur name |
| --- | --- | --- | --- | --- | --- | --- | --- | --- | --- | --- | --- | --- | --- | --- | --- | --- | --- | --- | --- | --- | --- |
| 2975 | 717.2 | **Rel-10 Self-Organizing Networks (SON) - OAM aspects** | 390d? | 2009-12-10 A | 2011-06-08 A | 100% | 2009-12-10 | 2011-06-08 | 390d? |  | S5 | 11000h | 11000h | OAM10-SON | PCG-24 | Rel-10 | SP-46 | Mirko | SON | OAM10-SON |  |
| 2976 | 717.2.1 | SON Self-optimization management continuation | 390d? | 2009-12-10 A | 2011-06-08 A | 100% | 2009-12-10 | 2011-06-08 | 390d? | finish no earlier than 2011-03-23 | S5 | 3120h | 3120h | LTE-SON-OAM_SO | PCG-24 | Rel-10 | SP-46 | Mirko | SON | LTE-SON-OAM_SO | Huawei |
| 2977 | 717.2.2 | SON Self-healing management | 335d? | 2009-12-10 A | 2011-03-23 A | 100% | 2009-12-10 | 2011-03-23 | 335d? | finish no earlier than 2011-03-23 | S5 | 2680h | 2680h | LTE-SON-OAM_SH | PCG-24 | Rel-10 | SP-46 | Mirko | SON | LTE-SON-OAM_SH | ZTE |
| 2978 | 717.2.3 | OAM aspects of Energy Saving in Radio Networks | 260d? | 2010-03-25 A | 2011-03-23 A | 100% | 2010-03-25 | 2011-03-23 | 260d? | finish no earlier than 2011-03-23 | S5 | 2080h | 2080h | OAM-ES | PCG-24 | Rel-10 | SP-47 | Mirko | SON | OAM-ES | Nokia Siemens Networks |
| 2979 | 717.3 | Rel-10 Subscription Management (SuM) evolution | 260d? | 2010-03-25 A | 2011-03-23 A | 100% | 2010-03-25 | 2011-03-23 | 260d? | finish no earlier than 2011-03-23 | S5 | 2080h | 2080h | OAM10-SuM | PCG-24 | Rel-10 | SP-47 | Mirko |  | OAM10-SuM | Ericsson |
| 2980 | 717.4 | **Rel-10 Performance Management** | 315d? | 2010-03-25 A | 2011-06-08 A | 100% | 2010-03-25 | 2011-06-08 | 315d? |  | S5; C4 | 19000h | 19000h |  | PCG-24 | Rel-10 | SP-47 | Mirko |  |  |  |
| 2981 | 717.4.1 | Key Performance Indicators (KPIs) for IMS | 260d? | 2010-03-25 A | 2011-03-23 A | 100% | 2010-03-25 | 2011-03-23 | 260d? | finish no earlier than 2011-03-23 | S5 | 2080h | 2080h | OAM-PM-KPI_IMS | PCG-24 | Rel-10 | SP-47 | Mirko |  | OAM-PM-KPI_IMS | China Mobile |
| 2982 | 717.4.2 | Key Performance Indicators (KPIs) for EPC | 260d? | 2010-03-25 A | 2011-03-23 A | 100% | 2010-03-25 | 2011-03-23 | 260d? | finish no earlier than 2011-03-23 | S5 | 2080h | 2080h | OAM-PM-KPI_EPC | PCG-24 | Rel-10 | SP-47 | Mirko |  | OAM-PM-KPI_EPC | China Mobile |
| 2983 | 717.4.3 | **Management of UE based network performance measurements** | 315d? | 2010-03-25 A | 2011-06-08 A | 100% | 2010-03-25 | 2011-06-08 | 315d? |  | S5; C4 | 7720h | 7720h | OAM-PM-UE | PCG-24 | Rel-10 | SP-47 | Mirko |  | OAM-PM-UE | Huawei, Nokia Siemens Networks, Ericsson |
| 2984 | 717.4.3.1 | SA5 aspects of Management of UE based network performance measurements | 315d? | 2010-03-25 A | 2011-06-08 A | 100% | 2010-03-25 | 2011-06-08 | 315d? | finish no earlier than 2011-06-08 | S5 | 2520h | 2520h |  | PCG-24 | Rel-10 | SP-47 | Mirko |  |  | Huawei, Nokia Siemens Networks, Ericsson |
| 2985 | 717.4.3.2 | CN aspects of Management of UE based network performance measurements | 20d? | 2011-02-21 A | 2011-03-18 A | 100% | 2011-02-21 | 2011-03-18 | 20d? | start no earlier than 2011-02-21 | C4 | 160h | 160h |  | PCG-26 | Rel-10 | CP-51 | Kimmo |  |  | Nokia Siemens Networks |
| 2986 | 717.4.4 | 3G HNB and LTE HeNB Subsystem performance measurements | 260d? | 2010-03-25 A | 2011-03-23 A | 100% | 2010-03-25 | 2011-03-23 | 260d? | finish no earlier than 2011-03-23 | S5 | 2080h | 2080h | OAM-PM-HeNS | PCG-24 | Rel-10 | SP-47 | Mirko | HNB | OAM-PM-HeNS | China Mobile |
| 2987 | 718 | **Rel-10 Charging Management small Enhancements** | 470d? | 2009-06-04 A | 2011-03-23 A | 100% | 2009-06-04 | 2011-03-23 | 470d? |  | S5 | 7520h | 7520h | CH10 | PCG-24 | Rel-10 | SP-47 | Mirko | WLAN | CH10 |  |
| 2988 | 718.1 | IWLAN mobility charging | 470d? | 2009-06-04 A | 2011-03-23 A | 100% | 2009-06-04 | 2011-03-23 | 470d? | finish no earlier than 2011-03-23 | S5 | 3760h | 3760h | eIWLAN_Mob | PCG-23 | Rel-10 | SP-44 | Mirko | WLAN | eIWLAN_Mob | Orange |
| 2989 | 719 | **Advice of Charge (AoC) service support enhancements** | 312d? | 2010-03-25 A | 2011-06-03 A | 100% | 2010-03-25 | 2011-06-03 | 312d? |  | S5; C1 | 8560h | 8560h | eAoC | PCG-24 | Rel-10 | SP-47 | Mirko |  | eAoC | Deutsche Telekom |
| 2990 | 719.1 | SA5 part - AoC enhancements | 260d? | 2010-03-25 A | 2011-03-23 A | 100% | 2010-03-25 | 2011-03-23 | 260d? | finish no earlier than 2011-03-23 | S5 | 2080h | 2080h | eAoC | PCG-24 | Rel-10 | SP-47 | Mirko |  |  | Deutsche Telekom |
| 2991 | 719.2 | CT1 part - AoC enhancements (Stage 3) | 186d? | 2010-09-17 A | 2011-06-03 A | 100% | 2010-09-17 | 2011-06-03 | 186d? | finish no earlier than 2011-06-03 | C1 | 1488h | 1488h | eAoC | PCG-25 | Rel-10 | CP-49 | Frederic |  |  | Deutsche Telekom |
| 2992 | 720 | IMS Stage 3 IETF Protocol Alignment - phase 4 | 261d? | 2010-03-19 A | 2011-03-18 A | 100% | 2010-03-19 | 2011-03-18 | 261d? | finish no earlier than 2011-03-18 | C1 | 2088h | 2088h | IMSProtoc4 | PCG-24 | Rel-10 | CP-47 | Frederic |  | IMSProtoc4 | Alcatel-Lucent |
| 2993 | 721 | Enhanced User Data Convergence (UDC) Model | 206d? | 2010-06-04 A | 2011-03-18 A | 100% | 2010-06-04 | 2011-03-18 | 206d? | finish no earlier than 2011-03-18 | C4 | 1648h | 1648h | eUDC | PCG-25 | Rel-10 | CP-48 | Kimmo |  | eUDC | China Mobile |
| 2994 | 722 | **Further improvements of II-NNI Stage 3 based on operational feedback and evolution of other specifications** | 724d? | 2010-06-04 A | 2013-03-01 A | 100% | 2010-06-04 | 2013-03-01 | 724d? |  | C3 | 10625.9h | 10625.9h | II-NNI2 | PCG-25 | Rel-10 | CP-48 | Adrian |  | II-NNI2 | Orange |
| 2995 | 722.1 | Further improvements of II-NNI Stage 3 | 206d? | 2010-06-04 A | 2011-03-18 A | 100% | 2010-06-04 | 2011-03-18 | 206d? | start no earlier than 2010-06-04 | C3 | 1648h | 1648h | II-NNI2 | PCG-25 | Rel-10 | CP-48 | Adrian |  |  | Orange |
| 2996 | 722.2 | (IETF) Further improvements of II-NNI Stage 3 (RFC 6794) | 230d? | 2012-04-20 A | 2013-03-01 A | 100% | 2012-04-20 | 2013-03-01 | 230d? | finish no earlier than 2013-03-01 | C3-IETF | 1832h | 1832h | II-NNI2 | PCG-29 | Rel-10 | CP-56 | Adrian |  |  | Lionel Morand |
| 2997 | 722.3 | (IETF) Further improvements of II-NNI Stage 3 (RFC 6809) | 170d? | 2012-04-20 A | 2012-12-07 A | 100% | 2012-04-20 | 2012-12-07 | 170d? | finish no earlier than 2012-12-04 | C3-IETF | 1353.89h | 1353.89h | II-NNI2 | PCG-29 | Rel-10 | CP-56 | Adrian |  |  | christer.holmberg@ericsson.com |
| 2998 | 723 | AT Commands for IMS-configuration | 206d? | 2010-06-04 A | 2011-03-18 A | 100% | 2010-06-04 | 2011-03-18 | 206d? |  | C1 | 1648h | 1648h | AT_IMS | PCG-25 | Rel-10 | CP-48 | Frederic |  | AT_IMS | Ericsson |
| 2999 | 724 | AT Commands for USIM Application Toolkit (USAT) | 131d? | 2010-09-17 A | 2011-03-18 A | 100% | 2010-09-17 | 2011-03-18 | 131d? |  | C1 | 52.4h | 52.4h | AT_UICC | PCG-25 | Rel-10 | CP-49 | Frederic |  | AT_UICC | ST-Ericsson |
| 3000 | 725 | Communication Control for IMS by USIM (Stage 3) | 131d? | 2010-09-17 A | 2011-03-18 A | 100% | 2010-09-17 | 2011-03-18 | 131d? | start no earlier than 2010-09-17 | C6 | 1048h | 1048h | CC_IMS_USIM | PCG-25 | Rel-10 | CP-49 | Xavier |  | CC_IMS_USIM | Gemalto |
| 3001 | 726 | Dynamic view of SIP message for Inter-IMS Network to Network Interface (II-NNI) (Stage 3) | 126d? | 2010-12-10 A | 2011-06-03 A | 100% | 2010-12-10 | 2011-06-03 | 126d? | finish no earlier than 2011-06-03 | C3 | 1008h | 1008h | NNI_DV | PCG-26 | Rel-10 | CP-50 | Adrian |  | NNI_DV | NTT |
| 3002 | 727 | Introduction of Smart Card Web Server launch functionality | 71d? | 2010-12-10 A | 2011-03-18 A | 100% | 2010-12-10 | 2011-03-18 | 71d? | finish no earlier than 2011-03-18 | C6 | 568h | 568h | SCWS_L | PCG-26 | Rel-10 | CP-50 | Xavier |  | SCWS_L | Telecom Italia |
| 3003 | 728 | USAT using AT Commands | 71d? | 2010-12-10 A | 2011-03-18 A | 100% | 2010-12-10 | 2011-03-18 | 71d? | finish no earlier than 2011-03-18 | C6 | 568h | 568h | USAT_AT | PCG-26 | Rel-10 | CP-50 | Xavier |  | USAT_AT | Giesecke & Devrient |

Notes:
- 2975: umbrella BB
- 2976: SP#52 completed. Cont'd Rel-9 SON self-optimization management UID_390007 / Impacted TSs and TRs: 32.425, 32.521, 32.522, 32.526, 32.762, 32.766 / WI rapporteur e-mail: Lan Zou (zlan@huawei.com)
- 2977: SP#51 completed. WID updated SP-100776=>SP-110150. Work moved to Rel-10 after split of the Rel-9 UID_390007 SON self-optimization (removed Self-Healing handling) / Impacted TSs and TRs: 32.522, 32.526, 32.762, 32.766, new TS 32.541 / WI rapporteur e-mail: zhu.weihong@zte.com.cn
- 2978: SP#51 completed. WID updated SP-100226=>SP-110128. Triggered by Rel-10 TR 32.826 Study on Telecommunication Management; Energy Savings Management (FS_OAM_ESM) UID_430044 / Impacted TSs and TRs: 32.425, 32.522, 32.526, 32.626, 32.762, 32.766, new TS 32.551 / WI rapporteur e-mail: clemens.suerbaum@nsn.com
- 2979: SP#51 completed / Impacted TSs and TRs: 32.172, 32.175, 32.176 / WI rapporteur e-mail: leo.yang@ericsson.com
- 2980: umbrella BB
- 2981: SP#51 completed / Impacted TSs and TRs: new 32.454 / WI rapporteur e-mail: Li Jian (lijian@chinamobile.com), Liang Shuangchun (liangshuangchun@cmdi.chinamobile.com)
- 2982: SP#51 completed / Impacted TSs and TRs: new 32.455 / WI rapporteur e-mail: Li Jian (lijian@chinamobile.com), Liang Shuangchun (liangshuangchun@cmdi.chinamobile.com)
- 2983: SP#52 completed. Stage 2/3. Linked to UID_460003 Minimization of drive tests for E-UTRAN and UTRAN (MDT_UMTSLTE) / WI rapporteur e-mail: Zou Lan (zlan@huawei.com), gyula.bodog@nsn.com, ulf.hubinette@ericsson.com
- 2984: SP#52 completed / Impacted TSs and TRs: 32.421, 32.422, 32.423, 32.441, 32.442, 32.446 / WI rapporteur e-mail: Zou Lan (zlan@huawei.com), gyula.bodog@nsn.com, ulf.hubinette@ericsson.com
- 2985: CP#51 completed under the SA5 WI code / Impacted TSs and TRs: 23.008 (CR#0330), 29.002 (CR#1007), 29.230 (CR#0207), 29.272 (CR#0329) / WI rapporteur e-mail: ulrich.wiehe@nsn.com
- 2986: SP#51 completed / Impacted TSs and TRs: 32.582, 32.592, new (32.452, 32.453) / WI rapporteur e-mail: Chen Gang (chengang@chinamobile.com)
- 2987: CH10 is an umbrella Feature also for OAM&P related TEI10 type of changes that are not part of any other dedicated feature/WI / Impacted TSs and TRs: TR 30.820
- 2988: SP#51 completed. RAT differentiation for charging. Completes Rel-8 Feature IWLAN_Mob UID_370049 Mobility between 3GPP-WLAN Interworking and 3GPP Systems. Cooperation with CT1,CT3 on affected protocols / Impacted TSs and TRs: 32.240, 32.252, 32.298, 32.299 / WI rapporteur e-mail: Jean-Luc Garcia (jl.garcia@orange-ftgroup.com)
- 2989: CP#52 completed. SP#51 completed SA5. Continuation of Rel-8 BB UID_80042: Advice of Charge (AoC) support in IMS Charging (IMSTSS). Stage 2/3 work / WI rapporteur e-mail: matthias.seibel@telekom.de
- 2990: SP#51 completed. SA1 Stage 1 in 22.115 / Impacted TSs and TRs: 32.275, 32.280, 32.298, 32.299 / WI rapporteur e-mail: matthias.seibel@telekom.de
- 2991: CP#52 completed. SA1 Stage 1 in 22.115, 22.173, 22.024. Add mobile-specific CAI format and volume charging elements. Extensions to existing AoC XML / Impacted TSs and TRs: 24.647 / WI rapporteur e-mail: reinhard.lauster@t-mobile.at
- 2992: CP#51 completed. Ensure protocol alignment between 3GPP Stage 3 IMS work and IETF. Review capabilities provided in SIP by IETF and document whether these capabilities are supported in the IM CN Subsystem or not / Impacted TSs and TRs: 23.218, 24.229, 24.930 / WI rapporteur e-mail: keith.drage@alcatel-lucent.com
- 2993: CP#51 completed. Specify CRUD (Create/Read/Update/Delete) operations based on SOAP protocol, which may be used by the applications having no high real-time requirement to the data access operations / Impacted TSs and TRs: 29.335 / WI rapporteur e-mail: Lan Sizhong (lansizhong@chinamobile.com)
- 2994: Improvements of Rel-9 Feature UID_440027 Operational description of the Inter-IMS Network to Network Interface (II-NNI) / WI rapporteur e-mail: beata.dobrowolska@orange-ftgroup.com
- 2995: CP#51 completed / Impacted TSs and TRs: 29.165 / WI rapporteur e-mail: beata.dobrowolska@orange-ftgroup.com
- 2996: CP#59 completed AUTH 48 RFC-to-be-6794 / Impacted TSs and TRs: RFC 6794 (was draft-ietf-sip-session-policy-framework) / WI rapporteur e-mail: Lionel Morand
- 2997: CP#58 completed / Impacted TSs and TRs: RFC 6809 (was draft-ietf-sipcore-proxy-feature) / WI rapporteur e-mail: Christer Holmberg
- 2998: CP#51 completed. Specify 1) IMS-related AT-commands to configure MT and 2) IMS-related unsolicited response codes from MT to present to end-user / Impacted TSs and TRs: 27.007 / WI rapporteur e-mail: atle.monrad@ericsson.com
- 2999: CP#51 completed / Impacted TSs and TRs: 27.007 / WI rapporteur e-mail: magnus.mk.karlsson@stericsson.com
- 3000: CP#51 completed. Stage 1 in TS 22.038 USAT service description. Linked to CT6's UID_1273 Rel-5 BB Provisioning of IP-based multimedia services (24.229, 31.103) and UID_390021 Rel-8 BB CT6 aspects of SAE (31.102, 31.111) / Impacted TSs and TRs: 31.102, 31.103, 31.111 / WI rapporteur e-mail: Denis.Lheriteau@gemalto.com
- 3001: CP#52 completed. Linked to CT3 Rel-10 Feature UID_480014 Further improvements of II-NNI Stage 3 based on operational feedback and evolution of other specifications (II-NNI2) / Impacted TSs and TRs: 29.165 / WI rapporteur e-mail: arai.kenjiro@lab.ntt.co.jp
- 3002: CP#51 completed. Define a solution which allows enabling to launch Smart Card Web Server servicES in CP-150an easy and simple manner / Impacted TSs and TRs: 31.102 / WI rapporteur e-mail: davide.pratone@telecomitalia.it
- 3003: CP#51 completed. Stage 3 based on SA1 22.038CR#37r1 (Make USAT proactive capability reqs applicable to ME as a whole without regard to any particular configuration; e.g. a modem connected to an external display) / Impacted TSs and TRs: Stage 3 31.102, 31.111 / WI rapporteur e-mail: enric.fort@gi-de.com

| ID | WBS | Task | Type | Duration | Start | Finish | Complete | Baseline start | Baseline finish | Baseline duration | Constraint | Resources | Work | Actual work | Acronym | PCG approved | WI rapporteur name | WI rapporteur e-mail | Release | TSG approved | MCC resp | Acronym_3GU_Export | Status Report | Special Focus Doc | PCG stopped | TSG stopped |
| --- | --- | --- | --- | --- | --- | --- | --- | --- | --- | --- | --- | --- | --- | --- | --- | --- | --- | --- | --- | --- | --- | --- | --- | --- | --- | --- |
| 3004 | 729 | **Single Radio Voice Call Continuity (SRVCC) enhancements (Stage 3)** |  | 528d? | 2010-12-10 A | 2012-12-07 A | 100% | 2010-12-10 | 2012-12-07 | 528d? |  | C1; C4; IETF | 17295.4h | 17295.4h | eSRVCC | PCG-26 | China Mobile | Jiang Y (jiangyi@chinamobile.com) | Rel-10 | CP-50 | Frederic | eSRVCC |  |  |  |  |
| 3005 | 729.1 | CT1 part of Stage 3 for SRVCC enhancements |  | 71d? | 2010-12-10 A | 2011-03-18 A | 100% | 2010-12-10 | 2011-03-18 | 71d? | finish no earlier than 2011-03-18 | C1 | 568h | 568h | eSRVCC | PCG-26 | China Mobile | Jiang Y (jiangyi@chinamobile.com) | Rel-10 | CP-50 | Frederic |  |  |  |  |  |
| 3006 | 729.2 | CT4 part of Stage 3 for SRVCC enhancements |  | 71d? | 2010-12-10 A | 2011-03-18 A | 100% | 2010-12-10 | 2011-03-18 | 71d? | finish no earlier than 2011-03-18 | C4 | 568h | 568h | eSRVCC | PCG-26 | China Mobile | Jiang Y (jiangyi@chinamobile.com) | Rel-10 | CP-50 | Kimmo |  |  |  |  |  |
| 3007 | 729.3 | (IETF) CT1 part of Stage 3 for SRVCC enhancements (RFC 6809) |  | 436.8d? | 2010-12-10 A | 2012-12-07 A | 100% | 2010-12-10 | 2012-12-07 | 436.8d? | finish no earlier than 2013-03-01 | C1-IETF | 3487.38h | 3487.38h | eSRVCC | PCG-27 | christer.holmberg@ericsson.com | christer.holmberg@ericsson.com | Rel-10 | CP-52 | Frederic |  |  |  |  |  |
| 3008 | 730 | **Single Radio Voice Call Continuity (SRVCC) in alerting phase (Stage 3)** |  | 589d? | 2010-12-10 A | 2013-03-01 A | 100% | 2010-12-10 | 2013-03-01 | 589d? |  | C1; R5 | 11440h | 11440h | aSRVCC | PCG-26 | ZTE | li.shitao@zte.com.cn | Rel-10 | CP-50 | Frederic | aSRVCC |  |  |  |  |
| 3009 | 730.1 | CT aspects of Single Radio Voice Call Continuity (SRVCC) in alerting phase (Stage 3) |  | 126d? | 2010-12-10 A | 2011-06-03 A | 100% | 2010-12-10 | 2011-06-03 | 126d? | finish no earlier than 2011-06-03 | C1 | 1008h | 1008h | aSRVCC | PCG-26 | ZTE | li.shitao@zte.com.cn | Rel-10 | CP-50 | Frederic |  |  |  |  |  |
| 3010 | 730.2 | Conformance test aspects SRVCC in alerting phase |  | 126d? | 2012-09-11 A | 2013-03-01 A | 100% | 2012-09-11 | 2013-03-01 | 126d? | finish no earlier than 2013-03-01 | R5 | 1008h | 1008h | aSRVCC-UEConTest | PCG-29 | NTT DoCoMo | Takao.Shimizu.rp@nttdocomo.com | Rel-10 | RP-57 | Ingbert | aSRVCC-UEConTest | RP-130042 |  |  |  |
| 3011 | 731 | **PCRF failure and restoration** |  | 71d? | 2010-12-10 A | 2011-03-18 A | 100% | 2010-12-10 | 2011-03-18 | 71d? |  | C4; C3 | 2130h | 2130h | PCRF_FR | PCG-26 | NEC | Toshiyuki Tamura (tamurato@aj.jp.nec.com) | Rel-10 | CP-50 | Kimmo | PCRF_FR |  |  |  |  |
| 3012 | 731.1 | CT4 part of PCRF failure and restoration |  | 71d? | 2010-12-10 A | 2011-03-18 A | 100% | 2010-12-10 | 2011-03-18 | 71d? | finish no earlier than 2011-03-18 | C4 | 568h | 568h | PCRF_FR | PCG-26 | NEC | Toshiyuki Tamura (tamurato@aj.jp.nec.com) | Rel-10 | CP-50 | Kimmo |  |  |  |  |  |
| 3013 | 731.2 | CT3 part of PCRF failure and restoration |  | 53.25d? | 2010-12-10 A | 2011-03-18 A | 100% | 2010-12-10 | 2011-03-18 | 53.25d? | start no earlier than 2010-12-10 | C3 | 426h | 426h | PCRF_FR | PCG-26 | NEC | Toshiyuki Tamura (tamurato@aj.jp.nec.com) | Rel-10 | CP-50 | Adrian |  |  |  |  |  |
| 3014 | 732 | Formalization of WLAN Files | milestone | 0d? | 2011-02-23 A | 2011-03-18 A | 100% | 2011-02-23 | 2011-03-18 | 0d? | start no earlier than 2011-03-16 | C1 |  |  | FoWF | PCG-26 | Deutsche Telekom | dieter.jacobsohn@telekom.de | Rel-10 | CP-51 | Frederic | FoWF |  | WLAN |  |  |
| 3015 | 733 | CS and IMS Interworking for CAT service - Early Session model |  | 58d? | 2011-03-16 A | 2011-06-03 A | 100% | 2011-03-16 | 2011-06-03 | 58d? |  | C3 | 464h | 464h | CIIC_ES | PCG-26 | ZTE | li.shitao@zte.com.cn | Rel-10 | CP-51 | Adrian | CIIC_ES |  |  |  |  |
| 3016 | 734 | EPC Node Restoration without Idle mode Signalling Reduction (ISR) activated |  | 3d? | 2011-03-16 A | 2011-03-18 A | 100% | 2011-03-16 | 2011-03-18 | 3d? | finish no earlier than 2011-03-18 | C4 | 24h | 24h | EPC_NR | PCG-26 | Alcatel-Lucent | bruno.landais@alcatel-lucent.com | Rel-10 | CP-51 | Kimmo | EPC_NR |  |  |  |  |
| 3017 | 735 | EPC Node Restoration with Idle mode Signalling Reduction (ISR) activated |  | 58d? | 2011-03-16 A | 2011-06-03 A | 100% | 2011-03-16 | 2011-06-03 | 58d? | finish no earlier than 2011-03-18 | C4 | 464h | 464h | EPC_NR_ISR | PCG-26 | NEC | Toshiyuki Tamura (tamurato@aj.jp.nec.com) | Rel-10 | CP-51 | Kimmo | EPC_NR_ISR |  |  |  |  |
| 3018 | 736 | Mobile Terminating Roaming Forwarding with pre-paging |  | 58d? | 2011-03-16 A | 2011-06-03 A | 100% | 2011-03-16 | 2011-06-03 | 58d? | finish no earlier than 2011-03-18 | C4 | 464h | 464h | MTRF | PCG-26 | Ericsson | philip.hodges@ericsson.com | Rel-10 | CP-51 | Kimmo | MTRF |  |  |  |  |
| 3019 | 737 | **UICC access to IMS Specification** |  | 58d? | 2011-03-16 A | 2011-06-03 A | 100% | 2011-03-16 | 2011-06-03 | 58d? |  | C6; C1 | 1416h | 1416h | IMS-UICC-S | PCG-26 | Gemalto | Denis.Lheriteau@gemalto.com | Rel-10 | CP-51 | Xavier | IMS-UICC-S |  |  |  |  |
| 3020 | 737.1 | CT6 part of UICC access to IMS Specification |  | 3d? | 2011-03-16 A | 2011-03-18 A | 100% | 2011-03-16 | 2011-03-18 | 3d? | start no earlier than 2011-03-16 | C6 | 24h | 24h | IMS-UICC-S | PCG-26 | Gemalto | Denis.Lheriteau@gemalto.com | Rel-10 | CP-51 | Xavier |  |  |  |  |  |
| 3021 | 737.2 | CT1 part of UICC access to IMS Specification |  | 58d? | 2011-03-16 A | 2011-06-03 A | 100% | 2011-03-16 | 2011-06-03 | 58d? | start no earlier than 2011-03-16 | C1 | 464h | 464h | IMS-UICC-S | PCG-26 | Gemalto | Denis.Lheriteau@gemalto.com | Rel-10 | CP-51 | Frederic |  |  |  |  |  |
| 3022 | 738 | Deleted - Testing for Terminal support of Rel-10 USIM, ISIM and USAT features |  | 463d? | 2012-03-05 A | 2013-12-03 A | 100% | 2012-03-05 | 2013-12-03 | 463d? | finish no earlier than 2013-06-14 | C6 | 3704h | 3704h | USIM_R10_Test | PCG-28 | Gemalto | Denis.Praca@gemalto.com | Rel-10 | CP-55 | Xavier | USIM_R10_Test |  |  | PCG-32 | CP-62 |
| 3023 | 739 | **CN aspects of Local Call Local Switch** |  | 472d? | 2009-05-29 A | 2011-03-18 A | 100% | 2009-05-29 | 2011-03-18 | 472d? |  | C4 | 13008h | 13008h | LCLS-CN | PCG-23 | Vodafone | David.Hutton@vodafone.com | Rel-10 | CP-44 | Kimmo | LCLS-CN |  |  |  |  |
| 3024 | 739.1 | TR on CN aspects of Local Call Local Switch |  | 341d? | 2009-05-29 A | 2010-09-16 A | 100% | 2009-05-29 | 2010-09-16 | 341d? | finish no earlier than 2010-09-17 | C4 | 2728h | 2728h | LCLS-CN | PCG-23 | Vodafone | David.Hutton@vodafone.com | Rel-10 | CP-44 | Kimmo |  |  |  |  |  |
| 3025 | 739.2 | Stage 2/3 for CN aspects of Local Call Local Switch |  | 131d? | 2010-09-17 A | 2011-03-18 A | 100% | 2010-09-17 | 2011-03-18 | 131d? | finish no earlier than 2011-03-18 | C4 | 1048h | 1048h | LCLS-CN | PCG-25 | Vodafone | David.Hutton@vodafone.com | Rel-10 | CP-49 | Kimmo |  |  |  |  |  |
| 3026 | 739.3 | Deleted - CT3 aspects of Local Call Local Switch |  | 341d? | 2009-05-29 A | 2010-09-16 A | 100% | 2009-05-29 | 2010-09-16 | 341d? | finish no earlier than 2010-09-17 | C3 | 2728h | 2728h | LCLS-CN | PCG-23 | Vodafone | David.Hutton@vodafone.com | Rel-10 | CP-44 | Adrian |  |  |  | PCG-25 | CP-49 |
| 3027 | 739.4 | Deleted - CT1 aspects of Local Call Local Switch |  | 341d? | 2009-05-29 A | 2010-09-16 A | 100% | 2009-05-29 | 2010-09-16 | 341d? | finish no earlier than 2010-09-17 | C1 | 2728h | 2728h | LCLS-CN | PCG-23 | Vodafone | David.Hutton@vodafone.com | Rel-10 | CP-44 | Frederic |  |  |  | PCG-25 | CP-49 |
| 3028 | 740 | Local Call Local Switch | milestone | 0d? | 2007-05-07 A | 2007-05-07 A | 100% | 2007-05-07 | 2011-05-20 | 1055.8d? |  | GP; G2 |  |  | LCLS | PCG-22 | Huawei | wang_zhixi@huawei.com | Rel-10 | GP-41 | Paolo | LCLS |  |  |  |  |

Notes:
- 3004: Triggered by SA2 TR 23.856 Study on Single Radio Voice Call Continuity enhancements (FS_eSRVCC) UID_440049
- 3005: CP#51 completed / Impacted TSs and TRs: 24.229, 24.237
- 3006: CP#51 completed / Impacted TSs and TRs: 23.003, 23.008, 29.002, 29.230, 29.272, 29.305, 29.328, 29.329
- 3007: CP#58 completed / Impacted TSs and TRs: RFC 6809 (was draft-ietf-sipcore-proxy-feature)
- 3008: Builds on Rel-8 UID_390057 (IMS-Cont) TS 23.216 Stage 2. Provide Stage 3 for SRVCC PS-CS transfer of a call in alerting phase. Stage 2 TEI10 in TS 23.237 (6.3.2.1.4c/d, 6.3.2.1.7a/b)
- 3009: CP#52 completed / Impacted TSs and TRs: 24.008, 24.237
- 3010: RP#59 completed / Impacted TSs and TRs: 36.523-1, 36.523-2, 36.523-3, 34.229-1, 34.229-2, 34.229-3
- 3011: CP#51 completed. Triggered by CT3 TR 29.816 Study on Policy and Charging Rules Function (PCRF) failure and restoration (FS_PCRF-FR) UID_450013 / Impacted TSs and TRs: Stage 2/3 work
- 3012: CP#51 completed / Impacted TSs and TRs: Stage 2 23.007, Stage 3 29.230
- 3013: CP#51 completed / Impacted TSs and TRs: Stage 3 29.212, 29.213, 29.214, 29.215
- 3014: CP#51 completed. TS 24.235 for Info+Approval. Define the ME files as specified in 24.234 in OMA Device Management structure / Impacted TSs and TRs: Stage 3: 24.234, New 24.235
- 3015: CP#52 completed. Stage 1 in Rel-8 TS 22.182 Customized Alerting Tones (CAT) service. Stage 3 TS 24.182 defines 3 impl models: Gateway, Forking, Early Session. Specify missing CAT service interworking procedures btw CS & IMS networks / Impacted TSs and TRs: Stage 3 29.163, 29.235, 29.292
- 3016: CP#51 completed. Triggered by DRAFT TR 23.857 Study on EPC Nodes Restoration (FS_EPC_NR) UID_490014 / Impacted TSs and TRs: Stage 2/3: 23.007, 29.274
- 3017: CP#52 completed. Triggered by DRAFT TR 23.857 Study on EPC Nodes Restoration (FS_EPC_NR) UID_490014 / Impacted TSs and TRs: Stage 2/3: 23.007, 29.274
- 3018: CP#52 completed. Provides Stage 2/3 alternative solution to Mobile Terminating Roaming Retry to solve roaming events during paging, in particular to support CSFB. Hence, no new Stage 1 requirements exist / Impacted TSs and TRs: Stage 2/3: 23.012, 23.018, 23.116, 29.002
- 3019: CP#52 completed. Triggered by Rel-10 TR 31.828 Study on UICC access to IMS (FS_IMS-UICC) UID_480017. Specify mechanism in UICC and ME to make use of IMS functionality implemented in ME for case a) an ISIM is present b) no ISIM is present in UICC
- 3020: CP#51 completed / Impacted TSs and TRs: 31.102, 31.103, 31.111
- 3021: CP#52 completed / Impacted TSs and TRs: 24.229
- 3022: CP#62 stopped (at 70% completion 06/13). Testing for New featurES in CP-150Rel-10 specifications for USIM, ISIM applications and USIM Application Toolkit (USAT) in TS 31.102, 31.103, 31.111 / Impacted TSs and TRs: 31.121, 31.124, New TS 31.ABC (Conformance Testing of specific features)
- 3023: CP#51 completed / Impacted TSs and TRs: GERAN Stage 2/3
- 3024: CP#49 completed / Impacted TSs and TRs: new TR 23.889
- 3025: CP#51 completed / Impacted TSs and TRs: 23.003, 23.009, 23.205, 23.231, 29.002, 29.205, 29.232, new TS 23.284
- 3026: CP#49 stopped. Result of study TR 23.889: no CT3 specification impact
- 3027: CP#49 stopped. Result of study TR 23.889: no CT1 specification impact
- 3028: GP#50 completed. GP#41 WID approved / Impacted TSs and TRs: GERAN Stage 3: 48.008, 48.103

| ID | WBS | Task | Duration | Start | Finish | Complete | Baseline start | Baseline finish | Baseline duration | Constraint | Resources | Work | Actual work | Acronym | PCG approved | WI rapporteur name | Release | TSG approved | MCC resp | Acronym_3GU_Export | Status Report | Special Focus Doc |
| --- | --- | --- | --- | --- | --- | --- | --- | --- | --- | --- | --- | --- | --- | --- | --- | --- | --- | --- | --- | --- | --- | --- |
| 3029 | 741 | **Tightened Link Level Performance Requirements for Single Antenna MS** | 659d? | 2010-09-03 A | 2013-03-01 A | 100% | 2010-09-03 | 2013-03-01 | 659d? |  | G1; G2; C1; G3new | 30856h | 30856h | TIGHTER | PCG-25 | Renesas Mobile | Rel-10 | GP-46 | Paolo | TIGHTER |  |  |
| 3030 | 741.1 | CT1 part for TIGHTER | 196d? | 2010-09-03 A | 2011-06-03 A | 100% | 2010-09-03 | 2011-06-03 | 196d? | finish no earlier than 2011-06-03 | C1 | 1568h | 1568h | TIGHTER | PCG-25 | Renesas Mobile | Rel-10 | GP-46 | Frederic |  |  |  |
| 3031 | 741.2 | TIGHTER Performance Requirements | 186d? | 2010-09-03 A | 2011-05-20 A | 100% | 2010-09-03 | 2011-05-20 | 186d? | finish no earlier than 2011-05-20 | G1; G2 | 2976h | 2976h | TIGHTER | PCG-25 | Renesas Mobile | Rel-10 | GP-46 | Paolo |  |  |  |
| 3032 | 741.3 | TIGHTER Testing | 654d? | 2010-09-08 A | 2013-03-01 A | 100% | 2010-09-08 | 2013-03-01 | 654d? | finish no earlier than 2013-03-01 | G3new | 5224h | 5224h | TIGHTER | PCG-25 | Renesas Mobile | Rel-10 | GP-46 | Ingbert |  |  |  |
| 3033 | 742 | **Support of Multi-Operator Core Network by GERAN** | 206d? | 2010-05-21 A | 2011-03-04 A | 100% | 2010-05-21 | 2011-03-04 | 206d? |  | G2; S2; C1 | 8392h | 8392h | MOCN-GERAN | PCG-25 | Alcatel-Lucent | Rel-10 | GP-47 | Gert | MOCN-GERAN |  |  |
| 3034 | 742.1 | Stage 2 for Support of Multi-Operator Core Network by GERAN | 150d? | 2010-05-21 A | 2010-12-16 A | 100% | 2010-05-21 | 2010-12-16 | 150d? | finish no earlier than 2010-12-15 | S2 | 1200h | 1200h | MOCN-GERAN | PCG-25 | Alcatel-Lucent | Rel-10 | GP-47 | Maurice |  |  |  |
| 3035 | 742.2 | CT1 part of Stage 3 for Support of Multi-Operator Core Network by GERAN | 146d? | 2010-05-21 A | 2010-12-10 A | 100% | 2010-05-21 | 2010-12-10 | 146d? | finish no earlier than 2010-12-10 | C1 | 1168h | 1168h | MOCN-GERAN | PCG-25 | Alcatel-Lucent | Rel-10 | GP-47 | Frederic |  |  |  |
| 3036 | 742.3 | GERAN2 part of Stage 3 for Support of Multi-Operator Core Network by GERAN | 135d? | 2010-08-30 A | 2011-03-04 A | 100% | 2010-08-30 | 2011-03-04 | 135d? | finish no earlier than 2011-03-04 | G2 | 1080h | 1080h | MOCN-GERAN | PCG-25 | Alcatel-Lucent | Rel-10 | GP-47 | Gert |  |  |  |
| 3037 | 743 | **Enhancements of Iur-g interface** | 196d? | 2010-09-03 A | 2011-06-03 A | 100% | 2010-09-03 | 2011-06-03 | 196d? |  | G2; R3 | 5752h | 5752h | eIurg | PCG-25 | China Mobile, ZTE | Rel-10 | GP-47 | Gert | eIurg |  |  |
| 3038 | 743.1 | GERAN part for Enhancements of Iur-g interface (Stage 2/3) | 131d? | 2010-09-03 A | 2011-03-04 A | 100% | 2010-09-03 | 2011-03-04 | 131d? | finish no earlier than 2011-03-04 | G2 | 1048h | 1048h | eIurg-GERAN | PCG-25 | China Mobile, ZTE | Rel-10 | GP-47 | Gert | eIurg-GERAN |  |  |
| 3039 | 743.2 | Core part: Enhancements of Iur-g interface (Stage 2/3) | 196d? | 2010-09-03 A | 2011-06-03 A | 100% | 2010-09-03 | 2011-06-03 | 196d? | finish no earlier than 2011-06-03 | R3 | 1568h | 1568h | eIurg-RAN | PCG-25 | ZTE | Rel-10 | RP-49 | Juha | eIurg-RAN | RP-110526 |  |
| 3040 | 744 | 1.28 Mcps TDD Repeater | 599d? | 2007-12-04 A | 2010-03-19 A | 100% | 2007-12-04 | 2010-03-19 | 599d? | finish no earlier than 2010-03-19 | R4 | 4792h | 4792h | RANimp-Repeaters1.28TDD | PCG-21 | RITT | Rel-10 | RP-38 | Issam | RANimp-Repeaters1.28TDD | RP-100039 |  |
| 3041 | 745 | 1.28 Mcps TDD Multi-carrier HSUPA | 321d? | 2009-09-18 A | 2010-12-10 A | 100% | 2009-09-18 | 2010-12-10 | 321d? | finish no earlier than 2010-12-10 | R1; R2; R3; R4 | 10272h | 10272h | TDD_MC_HSUPA | PCG-23 | CATR | Rel-10 | RP-45 | Patrick | TDD_MC_HSUPA | RP-101079 |  |
| 3042 | 746 | **1.28 Mcps TDD Home NodeB RF requirements** | 266d? | 2009-12-04 A | 2010-12-10 A | 100% | 2009-12-04 | 2010-12-10 | 266d? |  | R4 | 5304h | 5304h | HNB_LCRTDD_RF | PCG-24 | TD Tech | Rel-10 | RP-46 | Issam | HNB_LCRTDD_RF |  | HNB |
| 3043 | 746.1 | Core part: 1.28Mcps TDD Home NodeB RF requirements | 131d? | 2009-12-04 A | 2010-06-04 A | 100% | 2009-12-04 | 2010-06-04 | 131d? | finish no earlier than 2010-12-10 | R4 | 1048h | 1048h | HNB_LCRTDD_RF-Core | PCG-24 | TD Tech | Rel-10 | RP-46 | Issam | HNB_LCRTDD_RF-Core | RP-100446 | HNB |
| 3044 | 746.2 | Perf. part: 1.28Mcps TDD Home NodeB RF requirements | 266d? | 2009-12-04 A | 2010-12-10 A | 100% | 2009-12-04 | 2010-12-10 | 266d? | finish no earlier than 2010-12-10 | R4 | 2128h | 2128h | HNB_LCRTDD_RF-Perf | PCG-24 | TD Tech | Rel-10 | RP-46 | Issam | HNB_LCRTDD_RF-Perf | RP-101081 | HNB |
| 3045 | 747 | **Multi-User Multiple-Input and Multiple-Output (MU-MIMO) for 1.28Mcps TDD** | 316d? | 2010-03-19 A | 2011-06-03 A | 100% | 2010-03-19 | 2011-06-03 | 316d? |  | R1; R2; R3; R4 | 17224h | 17224h | MUMIMO_LCR_TDD | PCG-24 | CATT | Rel-10 | RP-47 | Patrick | MUMIMO_LCR_TDD |  |  |
| 3046 | 747.1 | Core part: MU-MIMO for 1.28Mcps TDD | 191d? | 2010-03-19 A | 2010-12-10 A | 100% | 2010-03-19 | 2010-12-10 | 191d? | finish no earlier than 2010-12-10 | R1; R2; R3 | 4584h | 4584h | MUMIMO_LCR_TDD-Core | PCG-24 | CATT | Rel-10 | RP-47 | Patrick | MUMIMO_LCR_TDD-Core | RP-101085 |  |
| 3047 | 747.2 | Perf. part: MU-MIMO for 1.28Mcps TDD | 316d? | 2010-03-19 A | 2011-06-03 A | 100% | 2010-03-19 | 2011-06-03 | 316d? | finish no earlier than 2011-06-03 | R4 | 2528h | 2528h | MUMIMO_LCR_TDD-Perf | PCG-24 | CATT | Rel-10 | RP-47 | Issam | MUMIMO_LCR_TDD-Perf | RP-110520 |  |
| 3048 | 748 | **AGNSS Minimum Performance for UTRAN** | 523d? | 2009-09-18 A | 2011-09-16 A | 100% | 2009-09-18 | 2011-09-16 | 523d? |  | R4; R5 | 13624h | 13624h | AGNSSPerf_UTRAN | PCG-23 | Thales | Rel-10 | RP-45 | Issam | AGNSSPerf_UTRAN |  |  |
| 3049 | 748.1 | AGNSS Minimum Performance Specification Development | 321d? | 2009-09-18 A | 2010-12-10 A | 100% | 2009-09-18 | 2010-12-10 | 321d? | finish no earlier than 2010-12-10 | R4 | 2568h | 2568h | AGNSSPerf_UTRAN | PCG-23 | Thales | Rel-10 | RP-45 | Issam | AGNSSPerf_UTRAN | RP-101078 |  |
| 3050 | 748.2 | AGNSS test case development for UMTS | 336d? | 2010-06-04 A | 2011-09-16 A | 100% | 2010-06-04 | 2011-09-16 | 336d? | finish no earlier than 2011-09-16 | R5 | 2688h | 2688h | AGNSSPerf_UTRAN | PCG-25 | Thales | Rel-10 | RP-48 | Ingbert | AGNSSPerf_UTRAN | RP-110979 |  |
| 3051 | 749 | **Inclusion of RF Pattern Matching Technologies as positioning method in the UTRAN** | 336d? | 2009-12-04 A | 2011-03-18 A | 100% | 2009-12-04 | 2011-03-18 | 336d? |  | R2; R3 | 10752h | 10752h | LCS_UMTS_RFPMT | PCG-24 | Polaris Wireless | Rel-10 | RP-46 | Yong-Jun | LCS_UMTS_RFPMT | RP-110048 |  |
| 3052 | 749.1 | Core part: Inclusion of RF Pattern Matching Technologies as positioning method in the UTRAN | 336d? | 2009-12-04 A | 2011-03-18 A | 100% | 2009-12-04 | 2011-03-18 | 336d? | finish no earlier than 2011-03-18 | R2; R3 | 5376h | 5376h | LCS_UMTS_RFPMT-Core | PCG-24 | Polaris Wireless | Rel-10 | RP-46 | Yong-Jun | LCS_UMTS_RFPMT-Core | RP-110048 |  |

Notes:
- 3029: GP#46 approved WID / Impacted TSs and TRs: GERAN / WI rapporteur e-mail: carsten.juncker@renesasmobile.com
- 3030: CP#52 completed / Impacted TSs and TRs: 24.008 / WI rapporteur e-mail: marko.niemi@renesasmobile.com
- 3031: GP#50 completed / Impacted TSs and TRs: 45.005, 45.015 / WI rapporteur e-mail: carsten.juncker@renesasmobile.com
- 3032: GP#57 completed / Impacted TSs and TRs: 51.010 / WI rapporteur e-mail: carsten.juncker@renesasmobile.com
- 3033: GP#47 approved WID. 900 MHz spectrum re-farming to other RATs lead operators to reduce GSM capacity and therefore share their GSM networks. Hence the need for the most suitable (GE)RAN sharing method / Impacted TSs and TRs: GERAN / WI rapporteur e-mail: michel.robert@alcatel-lucent.com
- 3034: SP#50 completed / Impacted TSs and TRs: 23.251 / WI rapporteur e-mail: michel.robert@alcatel-lucent.com
- 3035: CP#50 completed / Impacted TSs and TRs: 24.008 CR#1644 / WI rapporteur e-mail: michel.robert@alcatel-lucent.com
- 3036: GP#49 completed / Impacted TSs and TRs: 48.008 CR#0325, 48.018 CR#0303 / WI rapporteur e-mail: michel.robert@alcatel-lucent.com
- 3037: GP#47 approved WID / Impacted TSs and TRs: GERAN,UTRA / WI rapporteur e-mail: Ms Juan Deng (dengjuan@chinamobile.com), Xinhui Wang (wangxinhui@zte.com.cn)
- 3038: GP#49 completed. GP#48 updated WID GP-101659=>GP-101758 (restricting the scope to GERAN BSC and TD-SCDMA RNC only). GP#47 approved WID / Impacted TSs and TRs: 43.130, 48.008 / WI rapporteur e-mail: Ms Juan Deng (dengjuan@chinamobile.com), Xinhui Wang (wangxinhui@zte.com.cn)
- 3039: RP#52 completed / Impacted TSs and TRs: UTRA Stage 2 (25.401, 25.420), Stage 3 (25.423) / WI rapporteur e-mail: Liu Junqiang (liu.junqiang@zte.com.cn)
- 3040: RP#47 completed / Impacted TSs and TRs: UTRA 25.113, New 25.116, 25.153 (testing) / WI rapporteur e-mail: qinyan@chinattl.com
- 3041: RP#50 completed / Impacted TSs and TRs: UTRA 25.102, 25.105, 25.123, 25.221, 25.222, 25.223, 25.224, 25.225, 25.306, 25.319, 25.321, 25.331, 25.423, 25.427, 25.433 / WI rapporteur e-mail: Aihui Song (songaihui@mail.ritt.com.cn)
- 3042: RP#50 completed. Triggered by FS_RAN-HNBLCRTDD UID_410016 Study on 1.28 Mcps TDD Home NodeB (TR 25.866) / Impacted TSs and TRs: UTRA / WI rapporteur e-mail: Li Rong (lirong@td-tech.com)
- 3043: RP#48 completed / Impacted TSs and TRs: 25.105 / WI rapporteur e-mail: Li Rong (lirong@td-tech.com)
- 3044: RP#50 completed. TR 25.968 v100 for Approval / Impacted TSs and TRs: 25.142, new TR 25.968 / WI rapporteur e-mail: Li Rong (lirong@td-tech.com)
- 3045: RP#52 completed / Impacted TSs and TRs: UTRA / WI rapporteur e-mail: Yanping Xing (xingyanping@datangmobile.cn)
- 3046: RP#50 completed / Impacted TSs and TRs: 25.221, 25.222, 25.224, 25.306, 25.308, 25.319, 25.331, 25.423, 25.425, 25.433, 25.435 / WI rapporteur e-mail: Yanping Xing (xingyanping@datangmobile.cn)
- 3047: RP#52 completed / Impacted TSs and TRs: 25.102, 25.105, 25.142 / WI rapporteur e-mail: Sanjun Feng (fengsanjun@datangmobile.cn)
- 3048: RP#53 completed. Triggered by Rel-7 UID_20050 (GNSS in UTRAN) and Rel-8 UID_400051 (Support for Additional NSS). Linked to GERAN Rel-9 UID_38002 (AGNSS Performances and Testing Procedures) / Impacted TSs and TRs: UTRA / WI rapporteur e-mail: Michel.monnerat@thalesaleniaspace.com
- 3049: RP#50 completed / Impacted TSs and TRs: new 25.172 / WI rapporteur e-mail: Michel.monnerat@thalesaleniaspace.com
- 3050: RP#53 completed / Impacted TSs and TRs: 34.108, 34.109, 34.123-1, 34.123-2, 34.123-3, 36.37.571-5, new 34.172 / WI rapporteur e-mail: Michel.monnerat@thalesaleniaspace.com
- 3051: RP#51 completed. Triggered by Study UID_380079 Evaluation of the inclusion of Path Loss Based Technology in the UTRAN (25.907) / Impacted TSs and TRs: UTRA / WI rapporteur e-mail: Norman Shaw (nshaw@polariswireless.com)
- 3052: RP#51 completed / Impacted TSs and TRs: 25.305, 25.453 / WI rapporteur e-mail: Norman Shaw (nshaw@polariswireless.com)

| ID | WBS | Task | Duration | Start | Finish | Complete | Baseline start | Baseline finish | Baseline duration | Constraint | Resources | Work | Actual work | Acronym | PCG approved | WI rapporteur name | WI rapporteur e-mail | Release | TSG approved | MCC resp | Acronym_3GU_Export | Status Report | PCG stopped | TSG stopped | Special Focus Doc |
| --- | --- | --- | --- | --- | --- | --- | --- | --- | --- | --- | --- | --- | --- | --- | --- | --- | --- | --- | --- | --- | --- | --- | --- | --- | --- |
| 3053 | 750 | **Four carrier HSDPA** | 992d? | 2009-12-04 A | 2013-09-06 A | 100% | 2009-12-04 | 2013-09-06 | 992d? |  | R1; R2; R3; R4; R5 | 57872h | 57872h | 4C_HSDPA | PCG-24 | Qualcomm | Arjun Bharadwaj (arjunb@qualcomm.com) | Rel-10 | RP-46 | Patrick | 4C_HSDPA |  |  |  |  |
| 3054 | 750.1 | Core part: Four carrier HSDPA | 336d? | 2009-12-04 A | 2011-03-18 A | 100% | 2009-12-04 | 2011-03-18 | 336d? | finish no earlier than 2011-03-18 | R1; R2; R3; R4 | 10752h | 10752h | 4C_HSDPA-Core | PCG-24 | Qualcomm | Arjun Bharadwaj (arjunb@qualcomm.com) | Rel-10 | RP-46 | Patrick | 4C_HSDPA-Core | RP-110046 |  |  |  |
| 3055 | 750.2 | Perf. part: Four carrier HSDPA | 466d? | 2009-12-04 A | 2011-09-16 A | 100% | 2009-12-04 | 2011-09-16 | 466d? | finish no earlier than 2011-09-16 | R4 | 3728h | 3728h | 4C_HSDPA-Perf | PCG-24 | Qualcomm | Arjun Bharadwaj (arjunb@qualcomm.com) | Rel-10 | RP-46 | Issam | 4C_HSDPA-Perf | RP-110986 |  |  |  |
| 3056 | 750.3 | Test part: Four carrier HSDPA | 464d? | 2011-12-02 A | 2013-09-06 A | 100% | 2011-12-02 | 2013-09-06 | 464d? | finish no earlier than 2013-09-06 | R5 | 3712h | 3712h | 4C_HSDPA-UEConTest | PCG-28 | Qualcomm | Shubhang Vora (svora@qualcomm.com) | Rel-10 | RP-54 | Ingbert | 4C_HSDPA-UEConTest | RP-130940 |  |  |  |
| 3057 | 751 | **Performance Requirements for two-antenna 1.28Mcps TDD Type 1 and Type 2 UE receiver** | 316d? | 2010-03-19 A | 2011-06-03 A | 100% | 2010-03-19 | 2011-06-03 | 316d? |  | R4 | 5504h | 5504h | 2ant_UE_LCR_TDD | PCG-24 | TD Tech | dafei.wang@td-tech.com | Rel-10 | RP-47 | Issam | 2ant_UE_LCR_TDD |  |  |  |  |
| 3058 | 751.1 | Core part: Performance Requirements for two-antenna 1.28Mcps TDD Type 1 and Type 2 UE receiver | 56d? | 2010-03-19 A | 2010-06-04 A | 100% | 2010-03-19 | 2010-06-04 | 56d? | finish no earlier than 2010-06-04 | R4 | 448h | 448h | 2ant_UE_LCR_TDD-Core | PCG-24 | TD Tech | dafei.wang@td-tech.com | Rel-10 | RP-47 | Issam | 2ant_UE_LCR_TDD-Core | RP-100454 |  |  |  |
| 3059 | 751.2 | Perf. part: Performance Requirements for two-antenna 1.28Mcps TDD Type 1 and Type 2 UE receiver | 316d? | 2010-03-19 A | 2011-06-03 A | 100% | 2010-03-19 | 2011-06-03 | 316d? | finish no earlier than 2011-06-03 | R4 | 2528h | 2528h | 2ant_UE_LCR_TDD-Perf | PCG-24 | TD Tech | dafei.wang@td-tech.com | Rel-10 | RP-47 | Issam | 2ant_UE_LCR_TDD-Perf | RP-110521 |  |  |  |
| 3060 | 752 | **Automatic Neighbour Relation (ANR) for UTRAN** | 663d? | 2010-06-04 A | 2012-12-07 A | 100% | 2010-06-04 | 2012-12-07 | 663d? |  | R3; R2; R5 | 22672h | 22672h | ANR_UTRAN | PCG-25 | ZTE | Zhai.hengxing@zte.com.cn | Rel-10 | RP-48 | Juha | ANR_UTRAN |  |  |  |  |
| 3061 | 752.1 | Core part: Automatic Neighbour Relation (ANR) for UTRAN | 261d? | 2010-06-04 A | 2011-06-03 A | 100% | 2010-06-04 | 2011-06-03 | 261d? | finish no earlier than 2011-06-03 | R3; R2 | 4176h | 4176h | ANR_UTRAN-Core | PCG-25 | ZTE | Zhai.hengxing@zte.com.cn | Rel-10 | RP-48 | Juha | ANR_UTRAN-Core | RP-110522 |  |  |  |
| 3062 | 752.2 | Test part: Automatic Neighbour Relation (ANR) for UTRAN | 323d? | 2011-09-19 A | 2012-12-07 A | 100% | 2011-09-19 | 2012-12-07 | 323d? | finish no earlier than 2012-12-07 | R5 | 2584h | 2584h | ANR_UTRAN-UEConTest | PCG-27 | Ericsson | leif.mattisson@ericsson.com | Rel-10 | RP-53 | Ingbert | ANR_UTRAN-UEConTest | RP-121529 |  |  |  |
| 3063 | 753 | **Support of New Band Combinations for Dual-Band Dual Cell HSDPA** | 261d? | 2010-06-04 A | 2011-06-03 A | 100% | 2010-06-04 | 2011-06-03 | 261d? |  | R4; R2 | 9568h | 9568h | DB_DC_HSDPA | PCG-25 | AT&T | Vince Spatafora (vs5785@att.com) | Rel-10 | RP-48 | Issam | DB_DC_HSDPA |  |  |  |  |
| 3064 | 753.1 | Core part: Support of New Band Combinations for Dual-Band Dual Cell HSDPA | 261d? | 2010-06-04 A | 2011-06-03 A | 100% | 2010-06-04 | 2011-06-03 | 261d? | finish no earlier than 2011-06-03 | R4; R2 | 4176h | 4176h | DB_DC_HSDPA-Core | PCG-25 | AT&T | Vince Spatafora (vs5785@att.com) | Rel-10 | RP-48 | Issam | DB_DC_HSDPA-Core | RP-110523 |  |  |  |
| 3065 | 753.2 | Deleted - Perf. part: Support of New Band Combinations for Dual-Band Dual Cell HSDPA | 76d? | 2010-06-04 A | 2010-09-17 A | 100% | 2010-06-04 | 2010-09-17 | 76d? | finish no earlier than 2010-09-17 | R4; R2 | 1216h | 1216h | DB_DC_HSDPA-Perf | PCG-25 | AT&T | Vince Spatafora (vs5785@att.com) | Rel-10 | RP-48 | Issam | DB_DC_HSDPA-Perf | RP-100759 | PCG-25 | RP-49 |  |
| 3066 | 754 | **MIMO operation with non-MIMO coexistence in HSDPA** | 459d? | 2010-06-04 A | 2012-03-02 A | 100% | 2010-06-04 | 2012-03-02 | 459d? |  | R4; R5 | 12936h | 12936h | MIMO_HSDPA | PCG-25 | Qualcomm | Heechoon Lee | Rel-10 | RP-48 | Issam | MIMO_HSDPA |  |  |  |  |
| 3067 | 754.1 | Core part: MIMO operation with non-MIMO coexistence in HSDPA | 186d? | 2010-09-17 A | 2011-06-03 A | 100% | 2010-09-17 | 2011-06-03 | 186d? | finish no earlier than 2011-06-03 | R4 | 1488h | 1488h | MIMO_HSDPA-Core | PCG-25 | Qualcomm | Heechoon Lee | Rel-10 | RP-49 | Issam | MIMO_HSDPA-Core | RP-110524 |  |  |  |
| 3068 | 754.2 | Perf. part: MIMO operation with non-MIMO coexistence in HSDPA | 261d? | 2010-06-04 A | 2011-06-03 A | 100% | 2010-06-04 | 2011-06-03 | 261d? | finish no earlier than 2011-06-03 | R4 | 2088h | 2088h | MIMO_HSDPA-Perf | PCG-25 | Qualcomm | Heechoon Lee | Rel-10 | RP-48 | Issam | MIMO_HSDPA-Perf | RP-110525 |  |  |  |
| 3069 | 754.3 | Test part: MIMO operation with non-MIMO coexistence in HSDPA | 252d? | 2011-03-18 A | 2012-03-02 A | 100% | 2011-03-18 | 2012-03-02 | 252d? | finish no earlier than 2012-03-02 | R5 | 2016h | 2016h | MIMO_HSDPA-UEConTest | PCG-26 | Qualcomm | Shubhang Vora (svora@qualcomm.com) | Rel-10 | RP-51 | Ingbert | MIMO_HSDPA-UEConTest | RP-120042 |  |  |  |
| 3070 | 755 | Interfrequency detected set measurements for UMTS | 61d? | 2010-09-17 A | 2010-12-10 A | 100% | 2010-09-17 | 2010-12-10 | 61d? | finish no earlier than 2010-12-10 | R2; R4 | 976h | 976h | Interf_dset_meas_UMTS | PCG-25 | Nokia | Chris.callender@nokia.com | Rel-10 | RP-49 | Yong-Jun | Interf_dset_meas_UMTS | RP-101093 |  |  |  |
| 3071 | 756 | **Carrier Aggregation for LTE** | 793d? | 2009-12-04 A | 2012-12-07 A | 100% | 2009-12-04 | 2012-12-07 | 793d? |  | R1; R2; R3; R4; R5 | 51024h | 51024h | LTE_CA | PCG-24 | Nokia | Asbjorn.grovlen@nokia.com | Rel-10 | RP-46 | Patrick | LTE_CA |  |  |  | CA |
| 3072 | 756.1 | Core part: Carrier Aggregation for LTE | 391d? | 2009-12-04 A | 2011-06-03 A | 100% | 2009-12-04 | 2011-06-03 | 391d? | finish no earlier than 2011-06-03 | R1; R2; R3; R4 | 12512h | 12512h | LTE_CA-Core | PCG-24 | Nokia | lars.e.lindh@nokia.com | Rel-10 | RP-46 | Patrick | LTE_CA-Core | RP-110535 |  |  | CA |
| 3073 | 756.2 | Perf. part: Carrier Aggregation for LTE | 528d? | 2009-12-04 A | 2011-12-09 A | 100% | 2009-12-04 | 2011-12-09 | 528d? | finish no earlier than 2011-12-09 | R4 | 4224h | 4224h | LTE_CA-Perf | PCG-24 | Nokia | lars.e.lindh@nokia.com | Rel-10 | RP-46 | Issam | LTE_CA-Perf | RP-111452 |  |  | CA |
| 3074 | 756.3 | Test part: Carrier Aggregation for LTE | 321d? | 2011-09-19 A | 2012-12-07 A | 100% | 2011-09-19 | 2012-12-07 | 321d? | finish no earlier than 2012-12-07 | R5 | 2568h | 2568h | LTE_CA-UEConTest | PCG-27 | Nokia | jussi.kuusisto@nokia.com | Rel-10 | RP-53 | Ingbert | LTE_CA-UEConTest | RP-121528 |  |  | CA |
| 3075 | 757 | **Enhanced Downlink Multiple Antenna Transmission for LTE** | 930d? | 2009-12-04 A | 2013-06-14 A | 100% | 2009-12-04 | 2013-06-14 | 930d? |  | R1; R2; R4; R5 | 44624h | 44624h | LTE_eDL_MIMO | PCG-24 | NTT DoCoMo | Hidekazu Taoka (taoka@nttdocomo.com) | Rel-10 | RP-46 | Patrick | LTE_eDL_MIMO |  |  |  |  |
| 3076 | 757.1 | Core part: Enhanced Downlink Multiple Antenna Transmission for LTE | 336d? | 2009-12-04 A | 2011-03-18 A | 100% | 2009-12-04 | 2011-03-18 | 336d? | finish no earlier than 2011-03-18 | R1; R2; R4 | 8064h | 8064h | LTE_eDL_MIMO-Core | PCG-24 | NTT DoCoMo | Hidekazu Taoka (taoka@nttdocomo.com) | Rel-10 | RP-46 | Patrick | LTE_eDL_MIMO-Core | RP-110067 |  |  |  |
| 3077 | 757.2 | Perf. part: Enhanced Downlink Multiple Antenna Transmission for LTE | 589d? | 2009-12-04 A | 2012-03-02 A | 100% | 2009-12-04 | 2012-03-02 | 589d? | finish no earlier than 2012-03-02 | R4 | 4712h | 4712h | LTE_eDL_MIMO-Perf | PCG-24 | NTT DoCoMo | Hidekazu Taoka (taoka@nttdocomo.com) | Rel-10 | RP-46 | Issam | LTE_eDL_MIMO-Perf | RP-120053 |  |  |  |
| 3078 | 757.3 | Test part: Enhanced Downlink Multiple Antenna Transmission for LTE | 261d? | 2012-06-18 A | 2013-06-14 A | 100% | 2012-06-18 | 2013-06-14 | 261d? | finish no earlier than 2013-06-14 | R5 | 2088h | 2088h | LTE_eDL_MIMO-UEConTest | PCG-29 | ZTE | Carolyn Taylor (carolyn.tayl@zte.com.cn) | Rel-10 | RP-56 | Ingbert | LTE_eDL_MIMO-UEConTest | RP-130464 |  |  |  |

Notes:
- 3053: RP#53 completed / Impacted TSs and TRs: UTRA
- 3054: RP#51 completed. RP#52 TR 25.864 v200 for Approval / Impacted TSs and TRs: 25.101, 25.104, 25.133, 25.211, 25.212, 25.213, 25.214, 25.215, 25.308, 25.331, 25.423, 25.433, 26.306, new TR 25.864
- 3055: RP#53 completed / Impacted TSs and TRs: 25.101, 25.104, 25.133, 25.141
- 3056: RP#61 completed / Impacted TSs and TRs: 34.108, 34.121-1, 34.121-2, 34.123-1, 34.123-2, 34.123-3
- 3057: Stage 3. RP#52 completed / Impacted TSs and TRs: UTRA
- 3058: RP#48 completed / Impacted TSs and TRs: 25.102
- 3059: RP#52 completed / Impacted TSs and TRs: 25.102
- 3060: RP#52 Core completed. Automatic Neighbour Relation (ANR) function for UTRAN relieves operators from the burden of manually managing the Neighbour cell Relations (NRs) / Impacted TSs and TRs: UTRA
- 3061: RP#52 completed / Impacted TSs and TRs: 25.331, 25.413, 25.423, new TS 25.484 (Stage 2)
- 3062: RP#58 completed / Impacted TSs and TRs: 34.108, 34.123-1, 34.123-2, 34.123-3
- 3063: RP#52 completed. Rel-9 Dual-Band Dual-Cell HSDPA (UID_430015 Support for different bands for Dual-Cell HSDPA) has one combination per region in principle. This work adds additional combinations: Band I and XI (Region 3) and Band II and V (Region 2) / Impacted TSs and TRs: UTRA
- 3064: RP#52 completed. RP#62 existing TS 25.317 replaced by new TS 25.327 / Impacted TSs and TRs: 25.101, 25.104, 25.141, 25.317 replaced by new TS 25.327
- 3065: RP#49 stopped (Reason: no need for Performance work) / Impacted TSs and TRs: 25.101, 25.104, 25.141, 25.317
- 3066: RP#52 completed. RP#49 updated WID RP-100687=>RP-100993 (changed Title: MIMO Testing in HSDPA => MIMO operation with non-MIMO coexistence in HSDPA) / Impacted TSs and TRs: UTRA
- 3067: RP#52 completed / Impacted TSs and TRs: 25.104
- 3068: RP#52 completed / Impacted TSs and TRs: 25.101, 25.141
- 3069: RP#55 completed / Impacted TSs and TRs: 34.108, 34.121-1, 34.121-2, 34.123-1, 34.123-2, 34.123-3
- 3070: RP#50 completed / Impacted TSs and TRs: UTRA 25.133, 25.331
- 3071: - / Impacted TSs and TRs: LTE
- 3072: RP#52 completed. RP#56 new RAN4 TR (36.807, 36.808) v200 for Approval / Impacted TSs and TRs: 36.101, 36.104, 36.133, 36.211, 36.212, 36.213, 36.300, 36.302, 36.306, 36.321, 36.331, 36.413, 36.423, 37.104, new RAN4 TR (36.807, 36.808)
- 3073: RP#54 completed / Impacted TSs and TRs: 36.101, 36.104, 36.133, 36.141, 37.141
- 3074: RP#58 completed / Impacted TSs and TRs: 36.508, 36.521-1, 36.521-2, 36.521-3, 36.523-1, 36.523-2, 36.523-3, 37.571-1, 37.571-3, 37.571-5
- 3075: - / Impacted TSs and TRs: LTE
- 3076: RP#51 completed. RP#56 new RAN4 TR 36.807 v200 for Approval / Impacted TSs and TRs: 36.101, 36.104, 36.133, 36.201, 36.211, 36.212, 36.213, 36.300, 36.306, 36.321, 36.331, new RAN4 TR 36.807
- 3077: RP#55 completed / Impacted TSs and TRs: 36.101, 36.104, 36.133, 36.141
- 3078: RP#60 completed. Testing for 36.101, 36.133 / Impacted TSs and TRs: 36.508, 36.521-1, 36.521-2

| ID | WBS | Task | Duration | Start | Finish | Complete | Baseline start | Baseline finish | Baseline duration | Constraint | Resources | Work | Actual work | Acronym | PCG approved | WI rapporteur name | WI rapporteur e-mail | Release | TSG approved | MCC resp | Acronym_3GU_Export | Status Report | PCG stopped | TSG stopped |
| --- | --- | --- | --- | --- | --- | --- | --- | --- | --- | --- | --- | --- | --- | --- | --- | --- | --- | --- | --- | --- | --- | --- | --- | --- |
| 3079 | 758 | **Uplink Multiple Antenna Transmission for LTE** | 3445d? | 2000-01-03 A | 2013-03-01 A | 100% | 2000-01-03 | 2013-03-01 | 3445d? |  | R1; R2; R4; R5 | 125976h | 125976h | LTE_UL_MIMO | PCG-24 | Huawei | Mattias.wennstrom@huawei.com | Rel-10 | RP-46 | Patrick | LTE_UL_MIMO |  |  |  |
| 3080 | 758.1 | Core part: UL multiple antenna transmission for LTE | 391d? | 2000-01-03 A | 2001-06-29 A | 100% | 2000-01-03 | 2001-06-29 | 391d? |  | R1; R2; R4 | 9384h | 9384h | LTE_UL_MIMO-Core | PCG-24 | Huawei | Mattias.wennstrom@huawei.com | Rel-10 | RP-46 | Patrick | LTE_UL_MIMO-Core | RP-110537 |  |  |
| 3081 | 758.2 | Perf. part: UL multiple antenna transmission for LTE | 466d? | 2009-12-04 A | 2011-09-16 A | 100% | 2009-12-04 | 2011-09-16 | 466d? | finish no earlier than 2011-09-16 | R4 | 3728h | 3728h | LTE_UL_MIMO-Perf | PCG-24 | Huawei | Mattias.wennstrom@huawei.com | Rel-10 | RP-46 | Issam | LTE_UL_MIMO-Perf | RP-110992 |  |  |
| 3082 | 758.3 | Test part: UL multiple antenna transmission for LTE | 328d? | 2011-12-02 A | 2013-03-01 A | 100% | 2011-12-02 | 2013-03-01 | 328d? | finish no earlier than 2013-03-01 | R5 | 2624h | 2624h | LTE_UL_MIMO-UEConTest | PCG-28 | Huawei | Zhang Xin (suzanna.zhang@huawei.com) | Rel-10 | RP-54 | Ingbert | LTE_UL_MIMO-UEConTest | RP-130038 |  |  |
| 3083 | 759 | **Relays for LTE** | 394d? | 2009-12-04 A | 2011-06-08 A | 100% | 2009-12-04 | 2011-06-08 | 394d? |  | R1; R2; R4; S2; S3; C4; C6 | 36856h | 36856h | LTE_Relay | PCG-24 | Ericsson | christian.hoymann@ericsson.com | Rel-10 | RP-46 | Patrick | LTE_Relay |  |  |  |
| 3084 | 759.1 | Core part: Relays for LTE | 391d? | 2009-12-04 A | 2011-06-03 A | 100% | 2009-12-04 | 2011-06-03 | 391d? | finish no earlier than 2011-06-03 | R1; R2; R4 | 9384h | 9384h | LTE_Relay-Core | PCG-24 | Ericsson | christian.hoymann@ericsson.com | Rel-10 | RP-46 | Patrick | LTE_Relay-Core | RP-110540 |  |  |
| 3085 | 759.2 | Deleted - Perf. part: Relays for LTE | 391d? | 2009-12-04 A | 2011-06-03 A | 100% | 2009-12-04 | 2011-06-03 | 391d? | finish no earlier than 2011-09-16 | R4 | 3128h | 3128h | LTE_Relay-Perf | PCG-24 | Ericsson | christian.hoymann@ericsson.com | Rel-10 | RP-46 | Issam | LTE_Relay-Perf | RP-110541 | PCG-27 | RP-52 |
| 3086 | 759.3 | Stage 2 for Relays for LTE | 3d? | 2011-06-06 A | 2011-06-08 A | 100% | 2011-06-06 | 2011-06-08 | 3d? | start no earlier than 2011-06-06 | S2 | 24h | 24h | LTE_Relay | PCG-27 | Vodafone | chris.pudney@vodafone.com | Rel-10 | SP-52 | Maurice | LTE_Relay |  |  |  |
| 3087 | 759.4 | **LTE Relay Nodes Security** | 69d? | 2010-12-16 A | 2011-03-22 A | 100% | 2010-12-16 | 2011-03-22 | 69d? |  | S3; C6 | 2232h | 2232h | LTE_Relay-Sec | PCG-26 | Qualcomm | Adrian Escott (aescott@qualcomm.com) | Rel-10 | SP-50 | Mirko | LTE_Relay-Sec |  |  |  |
| 3088 | 759.4.1 | TR on LTE Relay Nodes Security | 69d? | 2010-12-16 A | 2011-03-22 A | 100% | 2010-12-16 | 2011-03-22 | 69d? | finish no earlier than 2011-03-23 | S3 | 552h | 552h | LTE_Relay-Sec | PCG-26 | Qualcomm | Adrian Escott (aescott@qualcomm.com) | Rel-10 | SP-50 | Mirko |  |  |  |  |
| 3089 | 759.4.2 | Security for LTE Relay Nodes (Stage 2) | 69d? | 2010-12-16 A | 2011-03-22 A | 100% | 2010-12-16 | 2011-03-22 | 69d? | finish no earlier than 2011-03-23 | S3 | 552h | 552h | LTE_Relay-Sec | PCG-26 | Qualcomm | Adrian Escott (aescott@qualcomm.com) | Rel-10 | SP-50 | Mirko |  |  |  |  |
| 3090 | 759.4.3 | CT6 aspects of LTE Relay Node Security | 3d? | 2011-03-16 A | 2011-03-18 A | 100% | 2011-03-16 | 2011-03-18 | 3d? | start no earlier than 2011-03-16 | C6 | 24h | 24h | LTE_Relay-Sec | PCG-26 | n/a | n/a | Rel-10 | CP-51 | Xavier |  |  |  |  |
| 3091 | 759.5 | Core Network Impacts for Relay Nodes | 3d? | 2011-03-16 A | 2011-03-18 A | 100% | 2011-03-16 | 2011-03-18 | 3d? | finish no earlier than 2011-03-18 | C4 | 24h | 24h | LTE_Relay-CN | PCG-26 | Vodafone | David.Hutton@vodafone.com | Rel-10 | CP-51 | Kimmo | LTE_Relay-CN |  |  |  |
| 3092 | 760 | **Enhanced Inter-Cell Interference Control (ICIC) for non-Carrier Aggregation (CA) based deployments of heterogeneous networks for LTE** | 1119d? | 2010-03-19 A | 2014-06-13 A | 100% | 2010-03-19 | 2014-06-13 | 1119d? |  | R1; R2; R3; R4; R5 | 64384h | 64384h | eICIC_LTE | PCG-24 | China Mobile | Xiaodong XU (xuxiaodong@chinamobile.com) | Rel-10 | RP-47 | Patrick | eICIC_LTE |  |  |  |
| 3093 | 760.1 | Core part: Enhanced Inter-Cell Interference Control (ICIC) for non-Carrier Aggregation (CA) based deployments of heterogeneous networks for LTE | 316d? | 2010-03-19 A | 2011-06-03 A | 100% | 2010-03-19 | 2011-06-03 | 316d? | finish no earlier than 2011-06-03 | R1; R2; R3; R4 | 10112h | 10112h | eICIC_LTE-Core | PCG-24 | China Mobile | Xiaodong XU (xuxiaodong@chinamobile.com) | Rel-10 | RP-47 | Patrick | eICIC_LTE-Core | RP-110543 |  |  |
| 3094 | 760.2 | Perf. part: Enhanced Inter-Cell Interference Control (ICIC) for non-Carrier Aggregation (CA) based deployments of heterogeneous networks for LTE | 589d? | 2010-03-19 A | 2012-06-15 A | 100% | 2010-03-19 | 2012-06-15 | 589d? | finish no earlier than 2012-06-15 | R4 | 4712h | 4712h | eICIC_LTE-Perf | PCG-24 | China Mobile | Xiaodong XU (xuxiaodong@chinamobile.com) | Rel-10 | RP-47 | Issam | eICIC_LTE-Perf | RP-120461 |  |  |
| 3095 | 760.3 | Test part: Enhanced Inter-Cell Interference Control (ICIC) for non-Carrier Aggregation (CA) based deployments of heterogeneous networks for LTE | 600d? | 2012-03-05 A | 2014-06-13 A | 100% | 2012-03-05 | 2014-06-13 | 600d? | finish no earlier than 2014-06-13 | R5 | 4800h | 4800h | eICIC_LTE-UEConTest | PCG-28 | Qualcomm | Anjali Mishra (ajha@qualcomm.com) | Rel-10 | RP-55 | Ingbert | eICIC_LTE-UEConTest | RP-140766 |  |  |
| 3096 | 761 | **LTE TDD in 2600MHz for US** | 191d? | 2010-03-19 A | 2010-12-10 A | 100% | 2010-03-19 | 2010-12-10 | 191d? |  | R4; R2; R3; R5 | 11344h | 11344h | LTE_TDD_2600_US | PCG-24 | Clearwire | michael.hart@clearwire.com | Rel-10 | RP-47 | Issam | LTE_TDD_2600_US |  |  |  |
| 3097 | 761.1 | Core part: LTE TDD in 2600MHz for US | 129d? | 2010-03-19 A | 2010-09-15 A | 100% | 2010-03-19 | 2010-09-17 | 131d? | finish no earlier than 2010-09-17 | R4; R2; R3 | 3096h | 3096h | LTE_TDD_2600_US-Core | PCG-24 | Clearwire | michael.hart@clearwire.com | Rel-10 | RP-47 | Issam | LTE_TDD_2600_US-Core | RP-100782 |  |  |
| 3098 | 761.2 | Perf. part: LTE TDD in 2600MHz for US | 131d? | 2010-03-19 A | 2010-09-17 A | 100% | 2010-03-19 | 2010-09-17 | 131d? | finish no earlier than 2010-09-17 | R4 | 1048h | 1048h | LTE_TDD_2600_US-Perf | PCG-24 | Clearwire | michael.hart@clearwire.com | Rel-10 | RP-47 | Issam | LTE_TDD_2600_US-Perf | RP-100783 |  |  |
| 3099 | 761.3 | UE conformance test part: LTE TDD in 2600MHz for US | 136d? | 2010-06-04 A | 2010-12-10 A | 100% | 2010-06-04 | 2010-12-10 | 136d? | finish no earlier than 2010-12-10 | R5 | 1088h | 1088h | LTE_TDD_2600_US-UEConTest | PCG-25 | Clearwire | michael.hart@clearwire.com | Rel-10 | RP-48 | Ingbert | LTE_TDD_2600_US-UEConTest | RP-101071 |  |  |
| 3100 | 762 | **Adding 2 GHz band LTE FDD (Band 23) for Ancillary Terrestrial Component (ATC) of Mobile Satellite Service (MSS) in North America** | 454d? | 2010-03-19 A | 2011-12-09 A | 100% | 2010-03-19 | 2011-12-09 | 454d? |  | R2; R4; R5 | 19568h | 19568h | S_Band_LTE_ATC_MSS | PCG-24 | DBSD | Mariam.Sorond@ico.com | Rel-10 | RP-47 | Yong-Jun | S_Band_LTE_ATC_MSS |  |  |  |
| 3101 | 762.1 | Core part: Adding 2 GHz band LTE FDD (Band 23) for ATC of MSS in North America | 316d? | 2010-03-19 A | 2011-06-03 A | 100% | 2010-03-19 | 2011-06-03 | 316d? | finish no earlier than 2011-06-03 | R4; R2 | 5056h | 5056h | S_Band_LTE_ATC_MSS-Core | PCG-24 | DBSD | Mariam.Sorond@ico.com | Rel-10 | RP-47 | Issam | S_Band_LTE_ATC_MSS-Core | RP-110545 |  |  |
| 3102 | 762.2 | Perf. part: Adding 2 GHz band LTE FDD (Band 23) for ATC of MSS in North America | 316d? | 2010-03-19 A | 2011-06-03 A | 100% | 2010-03-19 | 2011-06-03 | 316d? | finish no earlier than 2011-06-03 | R4 | 2528h | 2528h | S_Band_LTE_ATC_MSS-Perf | PCG-24 | DBSD | Mariam.Sorond@ico.com | Rel-10 | RP-47 | Issam | S_Band_LTE_ATC_MSS-Perf | RP-110546 |  |  |
| 3103 | 762.3 | Test part: Adding 2 GHz band LTE FDD (Band 23) for ATC of MSS in North America | 137d? | 2011-06-07 A | 2011-12-09 A | 100% | 2011-06-07 | 2011-12-09 | 137d? | finish no earlier than 2011-12-09 | R5 | 1088h | 1088h | S_Band_LTE_ATC_MSS-UEConTest | PCG-27 | DBSD | Mariam.Sorond@ico.com | Rel-10 | RP-52 | Ingbert | S_Band_LTE_ATC_MSS-UEConTest | RP-111444 |  |  |

Notes:
- 3079: - / Impacted TSs and TRs: LTE
- 3080: RP#52 completed. TR 36.817 v110 for Approval. RP#56 new TR 36.807 v200 for Approval / Impacted TSs and TRs: 36.101, 36.104, 36.133, 36.201, 36.211, 36.212, 36.213, 36.300, 36.306, 36.321, 36.331, new RAN4 (TR 36.807, 36.817)
- 3081: RP#53 completed / Impacted TSs and TRs: 36.101, 36.104, 36.133, 36.141, 36.817
- 3082: RP#59 completed / Impacted TSs and TRs: 36.508, 36.521-1, 36.521-2, 36.521-3, 36.523-1, 36.523-2, 36.523-3
- 3083: RP#52 completed (open RAN4 Core & Perf parts moved to new Rel-11) / Impacted TSs and TRs: LTE
- 3084: RP#52 completed. Updated WID RP-101417=>RP-101911 (contains only Core part completed in Rel-10). Open RAN4 Core & Perf parts moved to new Rel-11 / Impacted TSs and TRs: 36.201, 36.211, 36.212, 36.213, 36.300, 36.321, 36.323, 36.331, New RAN1 TS 36.216
- 3085: RP#52 stopped at 30% (no CRs so far) . Transferred completely to Rel-11 together with remaining core part / Impacted TSs and TRs: 36.133, New TS 36.117 (E-UTRA Relay conformance testing)
- 3086: SP#52 SP-110338 (S2-85/S2-112851) 23.401 Cat F CR#2128 Completion of Relay procedure overview / Impacted TSs and TRs: 23.401
- 3087: -
- 3088: SP#51 completed / Impacted TSs and TRs: 33.816
- 3089: SP#51 completed (impacting Stage 3 in CT and RAN) / Impacted TSs and TRs: 33.401 (CR#0437,0438), CT1 24.301, CT4 (29.272, 29.274), CT6 31.102, RAN2 (36.331, 36.323), RAN3 36.413
- 3090: CP#51 completed / Impacted TSs and TRs: 31.101, 31.102
- 3091: CP#51 completed / Impacted TSs and TRs: 23.003, 23.008, 29.303, 29.230, 29.272
- 3092: RP#56 completed / Impacted TSs and TRs: LTE
- 3093: RP#52 completed / Impacted TSs and TRs: 36.101, 36.133, 36.201, 36.211, 36.212, 36.213, 36.214, 36.300, 36.321, 36.331, 36.413, 36.423
- 3094: RP#56 completed / Impacted TSs and TRs: 36.101, 36.133
- 3095: RP#64 completed / Impacted TSs and TRs: 36.508, 36.521-1, 36.521-2, 36.521-3, 36.523-1, 36.523-2, 36.523-3
- 3096: RP#50 Testing completed. RP#49 Core+Perf completed / Impacted TSs and TRs: LTE
- 3097: RP#49 completed 1st Apr 15: CD:Fri 17/09/10->Wed 15/09/10 / Impacted TSs and TRs: 25.461, 25.466, 36.101, 36.104, 36.113, 36.124, 36.133, 36.141, 36.307, 36.331, 37.104, 37.113, 37.141, new TR 36.812
- 3098: RP#49 completed / Impacted TSs and TRs: 36.101, 36.104, 36.133, 36.141, 36.307, 37.104, 37.141, new TR 36.812
- 3099: RP#50 completed / Impacted TSs and TRs: 36.508, 36.521-1, 36.521-2, 36.521-3, 36.523-1, 36.523-2, 36.523-3
- 3100: RP#52 completed. Updated WID RP-101401=>RP-110775 (changed in Title "LTE" to "LTE FDD (Band 23)" / Impacted TSs and TRs: LTE
- 3101: RP#52 completed / Impacted TSs and TRs: 25.101, 25.104, 25.141, 25.461, 25.466, 36.101, 36.104, 36.113, 36.124, 36.133, 36.307, 37.104, 37.141, new TR 36.811
- 3102: RP#52 completed / Impacted TSs and TRs: 36.101, 36.104, 36.113, 36.124, 36.133, 36.141, 36.307, 36.811
- 3103: RP#54 completed / Impacted TSs and TRs: 36.508, 36.521-1, 36.521-2, 36.521-3, 36.523-1, 36.523-2, 36.523-3

| ID | WBS | Task | Duration | Start | Finish | Complete | Baseline start | Baseline finish | Baseline duration | Constraint | Resources | Work | Actual work | Acronym | PCG approved | WI rapporteur name | WI rapporteur e-mail | Release | TSG approved | MCC resp | Acronym_3GU_Export | Status Report | Special Focus Doc |
| --- | --- | --- | --- | --- | --- | --- | --- | --- | --- | --- | --- | --- | --- | --- | --- | --- | --- | --- | --- | --- | --- | --- | --- |
| 3104 | 763 | **Adding L-Band (Band 24) LTE for Ancillary Terrestrial Component (ATC) of Mobile Satellite Service (MSS) in North America** | 463d? | 2009-12-11 A | 2011-09-16 A | 100% | 2009-12-11 | 2011-09-16 | 463d? |  | R4; R2; R5 | 18864h | 18864h | L_Band_LTE_ATC_MSS | PCG-24 | LightSquared | Eric.Jacks@lightsquared.com, Maqbool.Aliani@lightsquared.com | Rel-10 | RP-47 | Issam | L_Band_LTE_ATC_MSS |  |  |
| 3105 | 763.1 | Core part: Adding L-Band (Band 24) LTE for ATC of MSS in North America | 261d? | 2009-12-11 A | 2010-12-10 A | 100% | 2009-12-11 | 2010-12-10 | 261d? | finish no earlier than 2010-12-10 | R4; R2 | 4176h | 4176h | L_Band_LTE_ATC_MSS-Core | PCG-24 | LightSquared | Eric.Jacks@lightsquared.com, Maqbool.Aliani@lightsquared.com | Rel-10 | RP-47 | Issam | L_Band_LTE_ATC_MSS-Core | RP-101117 |  |
| 3106 | 763.2 | Perf. part: Adding L-Band (Band 24) LTE for ATC of MSS in North America | 316d? | 2010-03-19 A | 2011-06-03 A | 100% | 2010-03-19 | 2011-06-03 | 316d? | finish no earlier than 2011-06-03 | R4 | 2528h | 2528h | L_Band_LTE_ATC_MSS-Perf | PCG-24 | LightSquared | Eric.Jacks@lightsquared.com, Maqbool.Aliani@lightsquared.com | Rel-10 | RP-47 | Issam | L_Band_LTE_ATC_MSS-Perf | RP-110548 |  |
| 3107 | 763.3 | Test part: Adding L-Band (Band 24) LTE for ATC of MSS in North America | 131d? | 2011-03-18 A | 2011-09-16 A | 100% | 2011-03-18 | 2011-09-16 | 131d? | finish no earlier than 2011-09-16 | R5 | 1048h | 1048h | L_Band_LTE_ATC_MSS-UEConTest | PCG-26 | LightSquared | masoud.olfat@lightsquared.com | Rel-10 | RP-51 | Ingbert | L_Band_LTE_ATC_MSS-UEConTest | RP-110980 |  |
| 3108 | 764 | **LTE Self Optimizing Networks (SON) enhancements** | 316d? | 2010-03-19 A | 2011-06-03 A | 100% | 2010-03-19 | 2011-06-03 | 316d? |  | R3; R2; R4 | 15168h | 15168h | SONenh_LTE | PCG-24 | Nokia Siemens Networks | krzysztof.kordybach@nsn.com | Rel-10 | RP-47 | Juha | SONenh_LTE |  | SON |
| 3109 | 764.1 | Core part: LTE Self Optimizing Networks (SON) enhancements | 316d? | 2010-03-19 A | 2011-06-03 A | 100% | 2010-03-19 | 2011-06-03 | 316d? | finish no earlier than 2011-06-03 | R3; R2; R4 | 7584h | 7584h | SONenh_LTE-Core | PCG-24 | Nokia Siemens Networks | krzysztof.kordybach@nsn.com | Rel-10 | RP-47 | Juha | SONenh_LTE-Core | RP-110547 | SON |
| 3110 | 765 | **Further enhancements to MBMS for LTE** | 459d? | 2010-06-04 A | 2012-03-02 A | 100% | 2010-06-04 | 2012-03-02 | 459d? |  | R2; R3; R5 | 14840h | 14840h | MBMS_LTE_enh | PCG-25 | Huawei | Ms Zhao Junhui (zhaojh@huawei.com) | Rel-10 | RP-48 | Yong-Jun | MBMS_LTE_enh |  |  |
| 3111 | 765.1 | Core part: Further enhancements to MBMS for LTE | 206d? | 2010-06-04 A | 2011-03-18 A | 100% | 2010-06-04 | 2011-03-18 | 206d? | finish no earlier than 2011-03-18 | R2; R3 | 3296h | 3296h | MBMS_LTE_enh-Core | PCG-25 | Huawei | Ms Zhao Junhui (zhaojh@huawei.com) | Rel-10 | RP-48 | Yong-Jun | MBMS_LTE_enh-Core | RP-110083 |  |
| 3112 | 765.2 | Test part: Further enhancements to MBMS for LTE | 66d? | 2011-12-02 A | 2012-03-02 A | 100% | 2011-12-02 | 2012-03-02 | 66d? | finish no earlier than 2012-03-02 | R5 | 528h | 528h | MBMS_LTE_enh-UEConTest | PCG-28 | Huawei | Zhang Xin (suzanna.zhang@huawei.com) | Rel-10 | RP-54 | Ingbert | MBMS_LTE_enh-UEConTest | RP-120049 |  |
| 3113 | 766 | **UMTS/LTE 3500 MHz** | 1456d? | 2007-11-30 A | 2013-06-14 A | 100% | 2007-11-30 | 2013-06-14 | 1456d? |  | R4; R2; R3; R5 | 87360h | 87360h | RInImp8-UMTSLTE3500 | PCG-21 | Ericsson | johan.skold@ericsson.com | Rel-10 | RP-38 | Issam | RInImp8-UMTSLTE3500 |  |  |
| 3114 | 766.1 | Core part: UMTS/LTE 3500 MHz | 994d? | 2007-11-30 A | 2011-09-16 A | 100% | 2007-11-30 | 2011-09-16 | 994d? | finish no earlier than 2011-09-16 | R4; R2; R3 | 23856h | 23856h | RInImp8-UMTSLTE3500 | PCG-21 | Ericsson | johan.skold@ericsson.com | Rel-10 | RP-38 | Issam | RInImp8-UMTSLTE3500 | RP-110987 |  |
| 3115 | 766.2 | Conformance Test Aspects – LTE 3500 | 1189d? | 2008-12-05 A | 2013-06-14 A | 100% | 2008-12-05 | 2013-06-14 | 1189d? | finish no earlier than 2013-06-14 | R5 | 9512h | 9512h | LTE-UEConTest_LTE3500 | PCG-22 | Ericsson | fredrik.sundstrom@ericsson.com | Rel-10 | RP-42 | Ingbert | LTE-UEConTest_LTE3500 | RP-130461 |  |
| 3116 | 766.3 | Conformance Test Aspects – UMTS 3500 | 925d? | 2008-12-05 A | 2012-06-15 A | 100% | 2008-12-05 | 2012-06-15 | 925d? | finish no earlier than 2012-06-15 | R5 | 7400h | 7400h | RInImp-UEConTest_UMTS3500 | PCG-22 | Ericsson | fredrik.sundstrom@ericsson.com | Rel-10 | RP-42 | Ingbert | RInImp-UEConTest_UMTS3500 | RP-120450 |  |
| 3117 | 767 | **Minimization of Drive Tests for E-UTRAN and UTRAN** | 854d? | 2009-12-04 A | 2013-03-01 A | 100% | 2009-12-04 | 2013-03-01 | 854d? |  | R2; R4; R3; R5 | 39784h | 39784h | MDT_UMTSLTE | PCG-24 | Nokia Siemens Networks | malgorzata.tomala@nsn.com | Rel-10 | RP-46 | Yong-Jun | MDT_UMTSLTE |  |  |
| 3118 | 767.1 | Core part: Minimization of Drive Tests for E-UTRAN and UTRAN | 391d? | 2009-12-04 A | 2011-06-03 A | 100% | 2009-12-04 | 2011-06-03 | 391d? | finish no earlier than 2011-06-03 | R2; R4; R3 | 9384h | 9384h | MDT_UMTSLTE-Core | PCG-24 | Nokia Siemens Networks | malgorzata.tomala@nsn.com | Rel-10 | RP-46 | Yong-Jun | MDT_UMTSLTE-Core | RP-110528 |  |
| 3119 | 767.2 | Test part: Minimization of Drive Tests for E-UTRAN | 384d? | 2011-09-19 A | 2013-03-01 A | 100% | 2011-09-19 | 2013-03-01 | 384d? | finish no earlier than 2013-03-01 | R5 | 3072h | 3072h | MDT_UMTSLTE-UEConTest | PCG-27 | Ericsson | leif.mattisson@ericsson.com | Rel-10 | RP-53 | Ingbert | MDT_UMTSLTE-UEConTest | RP-130036 |  |
| 3120 | 768 | **HNB and HeNB Mobility Enhancements** | 718d? | 2010-03-19 A | 2012-12-07 A | 100% | 2010-03-19 | 2012-12-07 | 718d? |  | R3; R2; R5 | 23016h | 23016h | HNB_HENB_mob_enh | PCG-24 | Alcatel-Lucent | Martin,Warner@alcatel-lucent.com | Rel-10 | RP-47 | Juha | HNB_HENB_mob_enh |  | HNB |
| 3121 | 768.1 | Core part: HNB and HeNB Mobility Enhancements | 261d? | 2010-03-19 A | 2011-03-18 A | 100% | 2010-03-19 | 2011-03-18 | 261d? | start no earlier than 2010-03-19 | R3; R2 | 4176h | 4176h | HNB_HENB_mob_enh-Core | PCG-24 | Alcatel-Lucent | Martin.Warner@alcatel-lucent.com | Rel-10 | RP-47 | Juha | HNB_HENB_mob_enh-Core | RP-110058 | HNB |
| 3122 | 768.2 | Test part: HeNB Mobility Enhancements | 201d? | 2012-03-05 A | 2012-12-07 A | 100% | 2012-03-05 | 2012-12-07 | 201d? | finish no earlier than 2012-12-07 | R5 | 1608h | 1608h | HNB_HENB_mob_enh-UEConTest_LTE | PCG-28 | Qualcomm | Anjali Mishra (ajha@qualcom.com) | Rel-10 | RP-55 | Ingbert | HNB_HENB_mob_enh-UEConTest_LTE | RP-121533 | HNB |
| 3123 | 769 | **Expanded 1900 MHz Band for UTRA and LTE** | 596d? | 2010-06-04 A | 2012-09-07 A | 100% | 2010-06-04 | 2012-09-07 | 596d? |  | R4; R2; R5 | 25312h | 25312h | E1900 | PCG-25 | Sprint | nick.j.baustert@sprint.com | Rel-10 | RP-48 | Issam | E1900 |  |  |
| 3124 | 769.1 | Core part: Expanded 1900 MHz Band for UTRA and LTE | 261d? | 2010-06-04 A | 2011-06-03 A | 100% | 2010-06-04 | 2011-06-03 | 261d? | finish no earlier than 2011-06-03 | R4; R2 | 4176h | 4176h | E1900-Core | PCG-25 | Sprint | nick.j.baustert@sprint.com | Rel-10 | RP-48 | Issam | E1900-Core | RP-110529 |  |
| 3125 | 769.2 | Perf. part: Expanded 1900 MHz Band for UTRA and LTE | 261d? | 2010-06-04 A | 2011-06-03 A | 100% | 2010-06-04 | 2011-06-03 | 261d? | finish no earlier than 2011-06-03 | R4; R2 | 4176h | 4176h | E1900-Perf | PCG-25 | Sprint | nick.j.baustert@sprint.com | Rel-10 | RP-48 | Issam | E1900-Perf | RP-110530 |  |
| 3126 | 769.3 | Test part: Expanded 1900 MHz Band for UTRA and LTE | 333d? | 2011-06-07 A | 2012-09-07 A | 100% | 2011-06-07 | 2012-09-07 | 333d? | finish no earlier than 2012-09-07 | R5 | 2656h | 2656h | E1900-UEConTest | PCG-27 | Sprint | nick.j.baustert@sprint.com | Rel-10 | RP-52 | Ingbert | E1900-UEConTest | RP-120957 |  |
| 3127 | 770 | **Multi-Standard Radio Base Station RF requirements for non-contiguous spectrum deployments** | 389d? | 2010-06-04 A | 2011-11-25 A | 100% | 2010-06-04 | 2011-11-25 | 389d? |  | R4; G1 | 16160h | 16160h | MSR_NC | PCG-25 | Ericsson | johan.skold@ericsson.com | Rel-10 | RP-48 | Issam | MSR_NC |  |  |
| 3128 | 770.1 | Core part: Multi-Standard Radio BS RF requirements for non-contiguous spectrum deployments | 261d? | 2010-06-04 A | 2011-06-03 A | 100% | 2010-06-04 | 2011-06-03 | 261d? | finish no earlier than 2011-06-03 | R4 | 2088h | 2088h | MSR_NC-Core | PCG-25 | Ericsson | johan.skold@ericsson.com | Rel-10 | RP-48 | Issam | MSR_NC-Core | RP-110531 |  |
| 3129 | 770.2 | Perf. part: Multi-Standard Radio BS RF requirements for non-contiguous spectrum deployments | 336d? | 2010-06-04 A | 2011-09-16 A | 100% | 2010-06-04 | 2011-09-16 | 336d? | finish no earlier than 2011-09-16 | R4 | 2688h | 2688h | MSR_NC-Perf | PCG-25 | Ericsson | johan.skold@ericsson.com | Rel-10 | RP-48 | Issam | MSR_NC-Perf | RP-110988 |  |

Notes:
- 3104: RP#53 completed / Impacted TSs and TRs: LTE
- 3105: RP#51 completed / Impacted TSs and TRs: 25.101, 25.104, 25.141, 25.461, 25.466, 34.124, 36.101, 36.104, 36.113, 36.124, 36.133, 36.307, 37.104, 37.141, new RAN4 TR 36.813
- 3106: RP#52 completed / Impacted TSs and TRs: 34.121-1, 36.101, 36.104, 36.113, 36.124, 36.133, 36.141, 36.307, 36.521-1, 36.813
- 3107: RP#53 completed / Impacted TSs and TRs: 36.508, 36.521-1, 36.521-2, 36.521-3, 36.523-2
- 3108: RP#52 completed / Impacted TSs and TRs: LTE
- 3109: RP#52 completed (Stage 1,2,3) / Impacted TSs and TRs: 36.300, 36.331, 36.413, 36.423
- 3110: RP#51 completed. SA2 decided not to support MBR>GBR in Rel-10 MBMS. For SA2, MBR=GBR in Rel-10 MBMS. Hence RAN removed enabling statistical multiplexing gains for variable bit rate services in Objectives / Impacted TSs and TRs: LTE
- 3111: RP#51 completed / Impacted TSs and TRs: 25.446, 36.300, 36.321, 36.322, 36.323, 36.331, 36.440, 36.441, 36.442, 36.443, 36.444, 36.445
- 3112: RP#55 completed / Impacted TSs and TRs: 36.508, 36.523-1, 36.523-2, 36.523-3
- 3113: - / Impacted TSs and TRs: UTRA, LTE
- 3114: RP#53 completed. TR 37.801v200 for Approval / Impacted TSs and TRs: 25.101, 25.104, 25.113, 25.133, 25.141, 25.307, 25.307, 25.331, 25.461, 25.463, 34.124, 36.101, 36.104, 36.113, 36.141, 36.331, new 37.801
- 3115: RP#60 completed / Impacted TSs and TRs: 36.508, 36.521-1, 36.521-2, 36.521-3
- 3116: RP#56 completed / Impacted TSs and TRs: 34.108, 34.121-1, 34.121-2
- 3117: Triggered by UID_430021 TR 36.805 (Study on Minimization of drive-tests in NGN) / Impacted TSs and TRs: UTRA, LTE
- 3118: RP#52 completed / Impacted TSs and TRs: 25.133, 25.215, 25.304, 25.331, 25.423, 36.133, 36.214, 36.300, 36.304, 36.331, 36.413, 36.423, new 37.320 (Stage 2)
- 3119: RP#59 completed. Testing for LTE only / Impacted TSs and TRs: LTE 34.108, 34.109, 34.123-1, 34.123-2, 34.123-3, 36.508, 36.509, 36.523-1, 36.523-2, 36.523-3
- 3120: - / Impacted TSs and TRs: UTRA, LTE
- 3121: RP#51 completed / Impacted TSs and TRs: 25.413, 25.467, 25.469, 36.300, 36.413, 36.423, new 25.471
- 3122: RP#58 completed / Impacted TSs and TRs: 34.108, 34.123-1, 34.123-2, 34.123-3, 36.508, 36.523-1, 36.523-2, 36.523-3
- 3123: Expand UTRA and E-UTRA band 2 to include frequencies between 1910 1915 MHz and 1990-1995 MHz (US FCC allocation) / Impacted TSs and TRs: UTRA, LTE
- 3124: RP#52 completed / Impacted TSs and TRs: 25.101, 25.104, 25.113, 25.133, 25.141, 25.461, 25.466, 36.101, 36.104, 36.113, 36.124, 36.133, 36.141, 36.307, 36.331, new TR 36.818
- 3125: RP#52 completed / Impacted TSs and TRs: 25.101, 25.104, 25.113, 25.133, 25.141, 25.461, 25.466, 36.101, 36.104, 36.113, 36.124, 36.133, 36.141, 36.307, 36.331, new TR 36.818
- 3126: RP#57 completed / Impacted TSs and TRs: 34.108, 34.121-1, 34.121-2, 34.123-1, 34.123-2, 34.123-3, 36.508, 36.521-1, 36.521-2, 36.521-3, 36.523-1, 36.523-2, 36.523-3
- 3127: - / Impacted TSs and TRs: UTRA, LTE, GERAN
- 3128: RP#52 completed / Impacted TSs and TRs: 25.104, 36.104, 37.104, new TR 37.802
- 3129: RP#53 completed / Impacted TSs and TRs: 25.141, 36.141, 37.141, 37.802

| ID | WBS | Task | Type | Duration | Start | Finish | Complete | Remaining | Baseline start | Baseline finish | Baseline duration | Total slack | Constraint | Resources | Work | Actual work | Acronym | PCG approved | WI rapporteur name | WI rapporteur e-mail | Release | TSG approved | MCC resp | Acronym_3GU_Export | Impacted TSs and TRs | PCG stopped | TSG stopped | Status Report | Special Focus Doc |
| --- | --- | --- | --- | --- | --- | --- | --- | --- | --- | --- | --- | --- | --- | --- | --- | --- | --- | --- | --- | --- | --- | --- | --- | --- | --- | --- | --- | --- | --- |
| 3130 | 770.3 | **GERAN part: Multi-Standard Radio BS RF requirements for non-contiguous spectrum deployments** |  | 324d? | 2010-09-03 A | 2011-11-25 A | 100% |  | 2010-09-03 | 2011-11-25 | 324d? |  |  | G1 | 5160h | 5160h | MSR_NC-GERAN | PCG-25 | Ericsson | mats.y.samuelsson@ericsson.com | Rel-10 | GP-47 | Paolo | MSR_NC-GERAN |  |  |  |  |  |
| 3131 | 770.3.1 | GERAN Core part: Multi-Standard Radio BS RF requirements for non-contiguous spectrum deployments |  | 261d? | 2010-09-03 A | 2011-09-02 A | 100% |  | 2010-09-03 | 2011-09-02 | 261d? |  | finish no earlier than 2011-09-02 | G1 | 2088h | 2088h | MSR_NC-GERAN | PCG-25 | Ericsson | mats.y.samuelsson@ericsson.com | Rel-10 | GP-47 | Paolo |  | 45.005 |  |  |  |  |
| 3132 | 770.3.2 | GERAN BS Test part: Multi-Standard Radio BS RF requirements for non-contiguous spectrum deployments |  | 62d? | 2011-09-02 A | 2011-11-25 A | 100% |  | 2011-09-02 | 2011-11-25 | 62d? |  | finish no earlier than 2011-11-25 | G1 | 496h | 496h | MSR_NC-GERAN | PCG-28 | Ericsson | mats.y.samuelsson@ericsson.com | Rel-10 | GP-52 | Paolo |  | 51.021 |  |  |  |  |
| 3133 | 771 | (Small) Technical Enhancements and Improvements for Rel-10 |  | 470d? | 2009-06-04 A | 2011-03-23 A | 100% |  | 2009-06-04 | 2011-03-23 | 470d? |  | finish no earlier than 2011-03-23 | SP; CP; RP; GP | 15040h | 15040h | TEI10 | PCG-23 |  |  | Rel-10 | SP-44 |  | TEI10 |  |  |  |  |  |
| 3134 | 772 | (IETF) (Small) Technical Enhancements and Improvements for Rel-10 (draft-atarius) |  | 1244d? | 2009-06-04 A | 2014-12-09 | 75% | 312.5d? | 2009-06-04 | 2014-12-05 | 1242d? | 875d | finish no earlier than 2014-12-09 | C1-IETF | 9952h | 7452h | TEI10_IETF | PCG-27 | Andrew Allen | Andrew Allen | Rel-10 | CP-52 | Frederic | TEI10_IETF | draft-atarius-dispatch-meid-urn |  |  |  |  |
| 3135 | 773 | (IETF) (Small) Technical Enhancements and Improvements for Rel-10 (RFC6275) |  | 562d? | 2009-06-04 A | 2011-07-29 A | 100% |  | 2009-06-04 | 2011-07-29 | 562d? |  | finish no earlier than 2011-07-29 | C1-IETF | 4496h | 4496h | TEI10_IETF1 | PCG-27 |  |  | Rel-10 | CP-53 | Frederic | TEI10_IETF1 | RFC 6275 (was draft-ietf-mext-rfc3775bis) |  |  |  |  |
| 3136 | 774 | Test - (Small) Technical Enhancements and Improvements for Rel-10 |  | 271d? | 2011-12-01 A | 2012-12-07 A | 100% |  | 2011-12-01 | 2012-12-07 | 271d? |  | finish no earlier than 2012-12-07 | R5; G3new | 4336h | 4336h | TEI10_Test | PCG-28 | n/a |  | Rel-10 | RP-54 | Ingbert | TEI10_Test |  |  |  |  |  |
| 3137 | 775 | **Deleted - Registration in Densely-populated area (RED)** |  | 665d? | 2007-03-12 A | 2009-09-24 A | 100% |  | 2007-03-12 | 2009-09-24 | 665d? |  |  | S1 | 9544h | 9544h | RED |  | NTT DoCoMo | tanakai@nttdocomo.co.jp | Rel-10 | SP-35 | Alain | RED |  | PCG-24 | SP-46 |  |  |
| 3138 | 775.1 | Deleted - Stage 1 for RED |  | 4d? | 2007-03-12 A | 2007-03-15 A | 100% |  | 2007-03-12 | 2007-03-15 | 4d? |  | start no earlier than 2007-03-12 | S1 | 32h | 32h | RED |  | NTT DoCoMo | takakurat@s1.nttdocomo.co.jp | Rel-10 | SP-35 | Alain |  | 22.101 CR#0207 | PCG-24 | SP-46 |  |  |
| 3139 | 775.2 | Deleted - Stage 2 for RED |  | 524d? | 2007-09-25 A | 2009-09-24 A | 100% |  | 2007-09-25 | 2009-09-24 | 524d? |  | finish no earlier than 2009-09-24 | S2 | 4192h | 4192h | RED |  | NTT DoCoMo | tanakai@nttdocomo.co.jp | Rel-10 | SP-37 | Maurice |  | draft TR 23.880 withdrawn, 23.002, 23.060, 23.221, 23.236 | PCG-23 | SP-45 |  |  |
| 3140 | 776 | **Deleted - Network Selection for non-3GPP Access** |  | 471d? | 2007-12-07 A | 2009-09-24 A | 100% |  | 2007-12-07 | 2009-09-24 | 471d? |  |  | S1; C6 | 15072h | 15072h | N3GtoNSP | PCG-21 | Telefónica O2 | chris.friel@O2.com | Rel-10 | SP-38 | Alain | N3GtoNSP |  | PCG-23 | SP-45 |  |  |
| 3141 | 776.1 | Deleted - Stage 1 for N3GtoNSP |  | 471d? | 2007-12-07 A | 2009-09-24 A | 100% |  | 2007-12-07 | 2009-09-24 | 471d? |  | finish no earlier than 2009-12-10 | S1 | 3768h | 3768h | N3GtoNSP | PCG-21 | Telefónica O2 | chris.friel@O2.com | Rel-10 | SP-38 | Alain |  | 22.011 | PCG-23 | SP-45 |  |  |
| 3142 | 776.2 | Deleted - CT6 issues for N3GtoNSP |  | 471d? | 2007-12-07 A | 2009-09-24 A | 100% |  | 2007-12-07 | 2009-09-24 | 471d? |  | finish no earlier than 2009-12-04 | C6 | 3768h | 3768h | N3GtoNSP | PCG-21 | Telefónica O2 | chris.friel@O2.com | Rel-10 | CP-38 | Xavier |  | 36.300 | PCG-23 | CP-45 |  |  |
| 3143 | 777 | **Deleted - GTP-based S8 chaining** |  | 337d? | 2008-12-11 A | 2010-03-25 A | 100% |  | 2008-12-11 | 2010-03-25 | 337d? |  |  | S2 | 5392h | 5392h | GTPchaining | PCG-22 | Huawei | Haining Wang (wanghaining@huawei.com) | Rel-10 | SP-42 | Maurice | GTPchaining |  | PCG-24 | SP-47 |  |  |
| 3144 | 777.1 | Deleted - Stage 2 for GTPchaining |  | 337d? | 2008-12-11 A | 2010-03-25 A | 100% |  | 2008-12-11 | 2010-03-25 | 337d? |  | finish no earlier than 2010-03-25 | S2 | 2696h | 2696h | GTPchaining | PCG-22 | Huawei | Haining Wang (wanghaining@huawei.com) | Rel-10 | SP-42 | Maurice |  | 23.402 | PCG-24 | SP-47 |  |  |
| 3145 | 778 | Deleted - UTRAN 2 ms TTI uplink range improvement |  | 272d? | 2009-03-06 A | 2010-03-19 A | 100% |  | 2009-03-06 | 2010-03-19 | 272d? |  | finish no earlier than 2010-03-19 | R1; R2; R3; R4 | 8704h | 8704h | RANimp-2mTTI_ULimp | PCG-22 | Nokia Siemens Networks | Karri Ranta-aho (karri.ranta-aho@nsn.com) | Rel-10 | RP-43 | Patrick | RANimp-2mTTI_ULimp | 25.133, 25.212, 25.214, 25.321, 25.331 | PCG-24 | RP-47 | RP-100040 |  |
| 3146 | 779 | Deleted - Enhanced Home NodeB / eNodeB continuation of Rel-9 |  | 337d? | 2008-12-11 A | 2010-03-25 A | 100% |  | 2008-12-11 | 2010-03-25 | 337d? |  |  | S2 | 2696h | 2696h | eEHNB | PCG-23 | Alcatel-Lucent | Nicolas Drevon | Rel-10 | SP-44 | Maurice | eEHNB |  | PCG-24 | SP-47 |  | HNB |
| 3147 | 780 | **Deleted - Fixed Wireless Customer-Premises Equipment (CPE) RF Requirements** |  | 391d? | 2009-12-04 A | 2011-06-03 A | 100% |  | 2009-12-04 | 2011-06-03 | 391d? |  |  | R4; R5 | 12512h | 12512h | FW_CPE_RF | PCG-24 | Verizon Wireless | zheng.zhao@verizonwireless.com | Rel-10 | RP-46 | Issam | FW_CPE_RF | LTE | PCG-27 | RP-52 |  |  |
| 3148 | 780.1 | Deleted - Core part: Fixed Wireless Customer-Premises Equipment (CPE) RF Requirements |  | 391d? | 2009-12-04 A | 2011-06-03 A | 100% |  | 2009-12-04 | 2011-06-03 | 391d? |  | finish no earlier than 2011-06-03 | R4 | 3128h | 3128h | FW_CPE_RF-Core | PCG-24 | Verizon Wireless | zheng.zhao@verizonwireless.com | Rel-10 | RP-46 | Issam | FW_CPE_RF-Core | 36.101 | PCG-27 | RP-52 | RP-110539 |  |
| 3149 | 780.2 | Deleted - Test part: Fixed Wireless Customer-Premises Equipment (CPE) RF Requirements |  | 391d? | 2009-12-04 A | 2011-06-03 A | 100% |  | 2009-12-04 | 2011-06-03 | 391d? |  | finish no earlier than 2011-06-03 | R5 | 3128h | 3128h | FW_CPE_RF-UEConTest | PCG-24 | Verizon Wireless | zheng.zhao@verizonwireless.com | Rel-10 | RP-46 | Ingbert | FW_CPE_RF-UEConTest | 36.521-1 | PCG-27 | RP-52 | RP-110504 |  |
| 3150 | 781 | **Deleted - Latency reductions for LTE** |  | 266d? | 2009-12-04 A | 2010-12-10 A | 100% |  | 2009-12-04 | 2010-12-10 | 266d? |  |  | R2; R1 | 8512h | 8512h | LTE_LATRED | PCG-24 | Ericsson | henrik.enbuske@ericsson.com | Rel-10 | RP-46 | Yong-Jun | LTE_LATRED | LTE | PCG-26 | RP-50 |  |  |
| 3151 | 781.1 | Deleted - Core part: Latency reductions for LTE |  | 266d? | 2009-12-04 A | 2010-12-10 A | 100% |  | 2009-12-04 | 2010-12-10 | 266d? |  | finish no earlier than 2010-12-10 | R2; R1 | 4256h | 4256h | LTE_LATRED-Core | PCG-24 | Ericsson | henrik.enbuske@ericsson.com | Rel-10 | RP-46 | Yong-Jun | LTE_LATRED-Core | 36.213, 36.300, 36.306, 36.321, 36.331 | PCG-26 | RP-50 | RP-101112 |  |
| 3152 | 782 | **Deleted - Enhanced Interference Management for Home NodeBs** |  | 131d? | 2010-03-19 A | 2010-09-17 A | 100% |  | 2010-03-19 | 2010-09-17 | 131d? |  |  | R3 | 2096h | 2096h | HNB_IM | PCG-24 | Qualcomm | Andrei Radulescu (aradules@qualcomm.com) | Rel-10 | RP-47 | Juha | HNB_IM | UTRA | PCG-25 | RP-49 | RP-100754 | HNB |
| 3153 | 782.1 | Deleted - Core part: Enhanced Interference Management for Home NodeBs |  | 131d? | 2010-03-19 A | 2010-09-17 A | 100% |  | 2010-03-19 | 2010-09-17 | 131d? |  | finish no earlier than 2010-09-17 | R3 | 1048h | 1048h | HNB_IM-Core | PCG-24 | Qualcomm | Andrei Radulescu (aradules@qualcomm.com) | Rel-10 | RP-47 | Juha | HNB_IM-Core | 25.413, 25.467, 25.469 | PCG-25 | RP-49 | RP-100754 | HNB |
| 3154 | 783 | Release 10 Studies | milestone | 0d? | 2009-03-12 A | 2009-03-12 A | 100% |  | 2009-03-12 | 2011-03-23 | 531d? |  | finish no earlier than 2011-03-23 | CP; GP; RP; SP |  |  |  |  |  |  | Rel-10 |  |  |  |  |  |  |  |  |

Notes:
- 3130: -
- 3131: GP#51 completed. GP#47 approved WID
- 3132: GP#52 completed
- 3133: -
- 3134: Not completed internet-draft, waiting for draft-montemurro to complete
- 3135: SP#53/IETF#81: RFC 6275 completed
- 3136: -
- 3137: SP#35 Stage 1 completed. SP#45 Stage 2 work stopped. SP#46 work stopped/abandoned
- 3138: SP#35 completed. SP#46 work stopped/abandoned
- 3139: SP#45 Stage 2 work stopped
- 3140: SP#45 work stopped/abandoned
- 3141: SP#45 work stopped/abandoned
- 3142: SP#45 work stopped/abandoned
- 3143: SP#47 work stopped (depending on ongoing related CT4 work). Stage 1 in UID_320022 Rel-8 Requirements for evolution of the 3GPP system architecture (AIPN-SAE): 22.278, 22.011, 22.246
- 3144: SP#47 work stopped
- 3145: RP#47 work stopped/abandoned (no CR approved). Cell sets the TTI (Transmission Time Interval) to 2 ms
- 3146: SP#47 deleted (SA2 work moved under SA1 UID_450053). SP#44 Umbrella Feature created to host WIs moved out of Rel-9 (SA2 UID_420034 on IMS aspects of Architecture for Home NodeB)
- 3147: RP#52 work stopped (lack of contributions). Add new power classES in CP-150E-UTRAN UL to allow CPE type applications to be operated at higher max output power
- 3148: RP#52 work stopped at 55% (lack of contributions)
- 3149: RP#52 work stopped (lack of contributions)
- 3150: RP#50 work stopped (RP-101266)
- 3151: RP#50 work stopped (RP-101266)
- 3152: RP#49 stopped (no further standardization needed). Ensure that Enhanced Interference Management methods identified in Rel-9 for HNBs do not fail in deployments with a large penetration of CSG-aware UEs
- 3153: RP#49 stopped (no further standardization needed)
- 3154: -

| ID | WBS | Task | Type | Duration | Start | Finish | Complete | Baseline start | Baseline finish | Baseline duration | Constraint | Resources | Work | Actual work | Acronym | Impacted TSs and TRs | WI rapporteur name | Release | TSG approved | MCC resp | Acronym_3GU_Export | PCG approved | Status Report | PCG stopped | TSG stopped |
| --- | --- | --- | --- | --- | --- | --- | --- | --- | --- | --- | --- | --- | --- | --- | --- | --- | --- | --- | --- | --- | --- | --- | --- | --- | --- |
| 3155 | 784 | **Study on enhanced voice service requirements for the Evolved Packet System (EPS)** |  | 670d? | 2007-09-03 A | 2010-03-25 A | 100% | 2007-09-03 | 2010-03-25 | 670d? |  | S1; S4 | 18744h | 18744h | FS_EV_EPS | 22.813 | France Telecom | Rel-10 | SP-37 | Alain | FS_EV_EPS |  |  |  |  |
| 3156 | 784.1 | Use cases definition and service and system requirements |  | 334d? | 2007-09-03 A | 2008-12-11 A | 100% | 2007-09-03 | 2008-12-11 | 334d? | finish no earlier than 2008-12-11 | S1 | 2672h | 2672h | FS_EV_EPS-S1 | 22.813 | France Telecom | Rel-10 | SP-37 | Alain | FS_EV_EPS-S1 |  |  |  |  |
| 3157 | 784.2 | Codec specific part of FS_EV_EPS |  | 669d? | 2007-09-03 A | 2010-03-25 A | 100% | 2007-09-03 | 2010-03-25 | 669d? | finish no earlier than 2010-03-25 | S4 | 5352h | 5352h | FS_EV_EPS-S4 | 22.813 | Ericsson | Rel-10 | SP-37 | Paolo | FS_EV_EPS-S4 |  |  |  |  |
| 3158 | 785 | Study on advanced requirements for IP interconnect |  | 528d? | 2007-12-04 A | 2009-12-10 A | 100% | 2007-12-04 | 2009-12-10 | 528d? | finish no earlier than 2009-12-10 | S1 | 4224h | 4224h | FS_IPXS | 22.893 | Telefónica O2 | Rel-10 | SP-38 | Alain | FS_IPXS | PCG-21 |  |  |  |
| 3159 | 786 | Study on Personal Broadcast Service |  | 397d? | 2008-09-18 A | 2010-03-25 A | 100% | 2008-09-18 | 2010-03-25 | 397d? | finish no earlier than 2010-03-25 | S1 | 3168h | 3168h | FS_PBS | 22.947 | ETRI | Rel-10 | SP-41 | Alain | FS_PBS | PCG-21 |  |  |  |
| 3160 | 787 | Study on LCS support in SAE for non-3GPP accesses |  | 397d? | 2008-09-18 A | 2010-03-25 A | 100% | 2008-09-18 | 2010-03-25 | 397d? | finish no earlier than 2010-03-25 | S1 | 3168h | 3168h | FS_LCS_n3GPP | 22.814 | SK Telecom | Rel-10 | SP-41 | Alain | FS_LCS_n3GPP | PCG-21 |  |  |  |
| 3161 | 788 | Study on Haptic Services |  | 272d? | 2009-03-12 A | 2010-03-25 A | 100% | 2009-03-12 | 2010-03-25 | 272d? | finish no earlier than 2010-03-25 | S1 | 2168h | 2168h | FS_Haptics | 22.987 | SK Telecom | Rel-10 | SP-43 | Alain | FS_Haptics | PCG-22 |  |  |  |
| 3162 | 789 | Study on System enhancements for the use of IMS services in Local BreakOut and Optimal Routing of Media |  | 575d? | 2007-10-01 A | 2009-12-10 A | 100% | 2007-10-01 | 2009-12-10 | 575d? | finish no earlier than 2009-12-10 | S2 | 4600h | 4600h | FS_IMS_LBO_ORM | 23.894 | Telecom Italia, BT | Rel-10 | SP-37 | Maurice | FS_IMS_LBO_ORM |  |  |  |  |
| 3163 | 790 | Study on Intra Domain Connection of RAN Nodes to Multiple CN Nodes |  | 533d? | 2008-03-12 A | 2010-03-25 A | 100% | 2008-03-12 | 2010-03-25 | 533d? | finish no earlier than 2010-03-25 | S2 | 4264h | 4264h | FS_IDC | 23.924 (was 23.823) | China Mobile | Rel-10 | SP-39 | Maurice | FS_IDC | PCG-21 |  |  |  |
| 3164 | 791 | Study on Single Radio Voice Call Continuity enhancements |  | 341d? | 2009-06-04 A | 2010-09-23 A | 100% | 2009-06-04 | 2010-09-23 | 341d? | finish no earlier than 2010-09-23 | S2 | 2728h | 2728h | FS_eSRVCC | 23.856 | China Mobile | Rel-10 | SP-44 | Maurice | FS_eSRVCC | PCG-23 |  |  |  |
| 3165 | 792 | Study on Single Radio Video Call Continuity for 3G-CS |  | 131d? | 2010-03-25 A | 2010-09-23 A | 100% | 2010-03-25 | 2010-09-23 | 131d? | finish no earlier than 2010-09-23 | S2 | 1048h | 1048h | FS_vSRVCC | 23.886 | Samsung | Rel-10 | SP-47 | Maurice | FS_vSRVCC | PCG-24 |  |  |  |
| 3166 | 793 | Study on S2b Mobility based on GTP |  | 56d? | 2010-03-25 A | 2010-06-10 A | 100% | 2010-03-25 | 2010-06-10 | 56d? | finish no earlier than 2010-06-07 | S2 | 448h | 448h | FS_SMOG | 23.834 | Alcatel-Lucent | Rel-10 | SP-47 | Maurice | FS_SMOG | PCG-24 |  |  |  |
| 3167 | 794 | Study on Surround Sound codec extension for PSS and MBMS |  | 530d? | 2009-03-12 A | 2011-03-23 A | 100% | 2009-03-12 | 2011-03-23 | 530d? | finish no earlier than 2011-03-23 | S4 | 4240h | 4240h | FS_SS_PSS_MBMS | 26.950 | Fraunhofer Gesellschaft | Rel-10 | SP-43 | Paolo | FS_SS_PSS_MBMS | PCG-22 |  |  |  |
| 3168 | 795 | Study on Improved Video Coding Support |  | 205d? | 2010-06-10 A | 2011-03-23 A | 100% | 2010-06-10 | 2011-03-23 | 205d? | finish no earlier than 2011-03-23 | S4 | 1640h | 1640h | FS_IVCS | 26.904 | Nokia, ETRI | Rel-10 | SP-48 | Paolo | FS_IVCS | PCG-25 |  |  |  |
| 3169 | 796 | Study on Rc Reference Point Functionalities and Message Flows |  | 397d? | 2008-09-18 A | 2010-03-25 A | 100% | 2008-09-18 | 2010-03-25 | 397d? | finish no earlier than 2010-03-23 | S5 | 3170.08h | 3170.08h | FS_OAM_Rc | 32.825 | Huawei | Rel-10 | SP-41 | Mirko | FS_OAM_Rc | PCG-21 |  |  |  |
| 3170 | 797 | Study on Telecommunication Management; Energy Savings Management |  | 271d? | 2009-03-12 A | 2010-03-25 A | 100% | 2009-03-12 | 2010-03-25 | 271d? | finish no earlier than 2010-03-25 | S5 | 2168h | 2168h | FS_OAM_ESM | 32.826 | Orange, Vodafone | Rel-10 | SP-43 | Mirko | FS_OAM_ESM | PCG-22 |  |  |  |
| 3171 | 798 | Study on Integration of Device Management Information with Itf-N |  | 211d? | 2009-06-04 A | 2010-03-25 A | 100% | 2009-06-04 | 2010-03-25 | 211d? | finish no earlier than 2010-03-25 | S5 | 1688h | 1688h | FS_IDMI_Itf-N | 32.827 | Motorola | Rel-10 | SP-44 | Mirko | FS_IDMI_Itf-N | PCG-23 |  |  |  |
| 3172 | 799 | Study on Alignment of 3GPP Generic NRM IRP and TMF Shared Information Data (SID) model |  | 335d? | 2009-12-10 A | 2011-03-23 A | 100% | 2009-12-10 | 2011-03-23 | 335d? | finish no earlier than 2011-03-23 | S5 | 2680h | 2680h | FS_3GNRM_TMFSID | 32.828 | Nokia Siemens Networks | Rel-10 | SP-46 | Mirko | FS_3GNRM_TMFSID | PCG-24 |  |  |  |
| 3173 | 800 | Study on Harmonization of 3GPP Alarm IRP and TMF Interface Program (TIP) Fault Management |  | 335d? | 2009-12-10 A | 2011-03-23 A | 100% | 2009-12-10 | 2011-03-23 | 335d? | finish no earlier than 2011-03-23 | S5 | 2680h | 2680h | FS_3G_TMF_FM | 32.829 | Nokia Siemens Networks, Alcatel-Lucent | Rel-10 | SP-46 | Mirko | FS_3G_TMF_FM | PCG-24 |  |  |  |
| 3174 | 801 | Study on Alarm Correlation and Alarm Root Cause Analysis |  | 205d? | 2010-06-10 A | 2011-03-23 A | 100% | 2010-06-10 | 2011-03-23 | 205d? | finish no earlier than 2011-03-23 | S5 | 1640h | 1640h | FS_AC_ARCA | 32.832 | Ericsson | Rel-10 | SP-48 | Mirko | FS_AC_ARCA | PCG-25 |  |  |  |
| 3175 | 802 | Study on Alignment of 3GPP PM IRP and TMF Interface Program (TIP) PM |  | 205d? | 2010-06-10 A | 2011-03-23 A | 100% | 2010-06-10 | 2011-03-23 | 205d? | finish no earlier than 2011-03-23 | S5 | 1640h | 1640h | FS_3G_TMF_PM | 32.831 | Alcatel-Lucent | Rel-10 | SP-48 | Mirko | FS_3G_TMF_PM | PCG-25 |  |  |  |
| 3176 | 803 | Study on Policy and Charging Rules Function (PCRF) failure and restoration |  | 261d? | 2009-08-18 A | 2010-09-17 A | 100% | 2009-08-18 | 2010-09-17 | 261d? | finish no earlier than 2010-09-17 | C3 | 2088h | 2088h | FS_PCRF-FR | 29.816 | NEC | Rel-10 | CP-45 | Adrian | FS_PCRF-FR | PCG-23 |  |  |  |
| 3177 | 804 | Study on User Data Convergence (UDC) evolution |  | 206d? | 2010-06-04 A | 2011-03-18 A | 100% | 2010-06-04 | 2011-03-18 | 206d? | finish no earlier than 2011-03-18 | C4 | 1648h | 1648h | FS_UDCe | 23.845 | Alcatel-Lucent | Rel-10 | CP-48 | Kimmo | FS_UDCe | PCG-25 |  |  |  |
| 3178 | 805 | Study on UICC access to IMS |  | 206d? | 2010-06-04 A | 2011-03-18 A | 100% | 2010-06-04 | 2011-03-18 | 206d? | finish no earlier than 2011-03-18 | C6 | 1648h | 1648h | FS_IMS-UICC | 31.828 | Gemalto | Rel-10 | CP-48 | Xavier | FS_IMS-UICC | PCG-25 |  |  |  |
| 3179 | 806 | Study on Uplink Tx Diversity for HSPA |  | 208.4d? | 2009-08-18 A | 2010-06-04 A | 100% | 2009-08-18 | 2010-06-04 | 208.4d? | finish no earlier than 2010-06-04 | R4 | 1667.2h | 1667.2h | FS_UL-TxDiv-HSPA | UTRA 25.863 | Qualcomm | Rel-10 | RP-45 | Issam | FS_UL-TxDiv-HSPA | PCG-23 | RP-100499 |  |  |
| 3180 | 807 | Study on Solutions for Energy Saving within UTRA Node B |  | 206d? | 2009-12-04 A | 2010-09-17 A | 100% | 2009-12-04 | 2010-09-17 | 206d? | finish no earlier than 2010-09-17 | R1; R3 | 3296h | 3296h | FS_Energy_UMTS | UTRA 25.927 | Vodafone | Rel-10 | RP-46 | Patrick | FS_Energy_UMTS | PCG-24 | RP-100796 |  |  |
| 3181 | 808 | Study on Potential solutions for energy saving for E-UTRAN |  | 348.75d? | 2010-02-02 A | 2011-06-03 A | 100% | 2010-02-02 | 2011-06-03 | 348.75d? | finish no earlier than 2011-06-03 | R3; R2 | 5580h | 5580h | FS_Energy_LTE | LTE 36.927 | China Mobile | Rel-10 | RP-47 | Juha | FS_Energy_LTE | PCG-24 | RP-110597 |  |  |
| 3182 | 809 | Study on Improvements of distributed antenna for 1.28Mcps TDD |  | 200.55d? | 2010-03-05 A | 2010-12-10 A | 100% | 2010-03-05 | 2010-12-10 | 200.55d? | finish no earlier than 2010-12-10 | R1; R2; R3 | 4813.2h | 4813.2h | FS_distr_ant_LCR_TDD | UTRA 25.865 | ZTE | Rel-10 | RP-47 | Patrick | FS_distr_ant_LCR_TDD | PCG-24 | RP-101287 |  |  |
| 3183 | 810 | Deleted - Study on Unauthenticated PS Emergency Calls |  | 471d? | 2008-06-05 A | 2010-03-25 A | 100% | 2008-06-05 | 2010-03-25 | 471d? | finish no earlier than 2010-03-25 | S1 | 3768h | 3768h | FS_UAPSEC | 22.984 | Nokia Siemens Networks | Rel-10 | SP-40 | Alain | FS_UAPSEC | PCG-21 |  | PCG-24 | SP-47 |
| 3184 | 811 | Deleted - Study on enhancements to IMS border functions for IMS Interconnection of services |  | 586d? | 2008-09-18 A | 2010-12-15 A | 100% | 2008-09-18 | 2010-12-15 | 586d? | finish no earlier than 2010-12-15 | S2 | 4688h | 4688h | FS_eIMS_IBCF | 23.848 | Starent Networks | Rel-10 | SP-41 | Maurice | FS_eIMS_IBCF | PCG-21 |  | PCG-26 | SP-50 |
| 3185 | 812 | Deleted - Study on EPC Charging enhancement |  | 211d? | 2009-06-04 A | 2010-03-25 A | 100% | 2009-06-04 | 2010-03-25 | 211d? | finish no earlier than 2010-03-25 | S5 | 1688h | 1688h | FS_EPCcharg |  | Nokia Siemens Networks | Rel-10 | SP-44 | Mirko | FS_EPCcharg | PCG-23 |  | PCG-24 | SP-47 |
| 3186 | 813 | Deleted - Study on Interworking Proxy between GTP based and PMIP based interfaces |  | 186d? | 2009-09-18 A | 2010-06-04 A | 100% | 2009-09-18 | 2010-06-04 | 186d? | finish no earlier than 2010-06-04 | C4 | 1488h | 1488h | FS_GTP-MIP-IW | 29.875 | NTT DoCoMo | Rel-10 | CP-45 | Kimmo | FS_GTP-MIP-IW | PCG-23 |  | PCG-25 | CP-48 |
| 3187 | 814 | Release 9 Features | milestone | 0d? | 2000-01-01 A | 2000-01-01 A | 100% | 2000-01-01 | 2000-01-01 | 0d? |  | CP; GP; RP; SP |  |  |  |  |  | Rel-9 |  |  |  |  |  |  |  |

Notes:
- 3155: SP#47 completed. TR 22.813-100 for Approval. Spin-off Feature UID_470030 Codec for Enhanced Voice Services / WI rapporteur e-mail: philippe.lottin@orange.com
- 3156: SP#47 completed. TR 22.813-100 for Approval / WI rapporteur e-mail: philippe.lottin@orange.com
- 3157: SP#47 completed. TR 22.813-100 for Approval / WI rapporteur e-mail: stefan.bruhn@ericson.com
- 3158: SP#46 completed. Linked to Rel-8 Feature UID_380060 IP Interconnection of Services (IPinterc). Spin-off Feature Rel-11 UID_470051 Advanced IP Interconnection of Services / WI rapporteur e-mail: chris.friel@O2.com
- 3159: SP#47 completed / WI rapporteur e-mail: Jaihyung Cho
- 3160: SP#47 completed / WI rapporteur e-mail: jinhan.song@sktelecom.com
- 3161: SP#47 completed. Covers Mobile/Fixed/Cordless/etc terminals. Haptic (human-machine tactile communication) extend service offering & richness of user experience beyond current visual & auditory senses / WI rapporteur e-mail: jinhan.song@sktelecom.com
- 3162: SP#46 completed. Spin-off Feature UID_460028 Optimal Media Routeing (OMR). Linked to Study on Multimedia Session Continuity UID_350051, Study on Centralized IMS Service Control UID_330012, IMS inter-operator service interconnection interface UID_360011 / WI rapporteur e-mail: mario.madella@telecomitalia.it, victor.kueh@bt.com
- 3163: SP#47 completed. Concluded no further normative work expected. Linked to 23.236 / WI rapporteur e-mail: LIU HONG (liuhongyfw@chinamobile.com)
- 3164: SP#49 completed (Conclusion: select the SIP anchoring based solution for normative work CR (TEI10) introducing and completing stage-2). Analyzed performance of Rel-8 SRVCC solution from E-UTRAN/HSPA to UTRAN/GERAN / WI rapporteur e-mail: Hou zhiqiang (houzhiqiang@chinamobile.com), Jiang Yi (jiangyi@chinamobile.com)
- 3165: SP#49 completed. TR 23.886v100 for Approval. Related to Rel-8 UID_350030 Single Radio Voice Call Continuity for 3GPP (SAES-SRVCC). Study how to provide Video Call seamless service continuity for 3G/LTE terminal user / WI rapporteur e-mail: Haris Zisimopoulos (haris.z@samsung.com)
- 3166: SP#48 completed. Triggered by Rel-8 UID_350027 SAE for support for non-3GPP accesses. Nature of relationship: S2b one of the interfaces defined for non-3GPP accesses support in EPS. Stage 1 in Rel-8 UID_320022 (AIPN-SAE) 22.278,22.101 / WI rapporteur e-mail: bruno.landais@alcatel-lucent.com
- 3167: SP#51 completed. Extend Rel-8 UID_34043 (Extending PSS and MBMS User Services for optimized Mobile TV) / WI rapporteur e-mail: jan.plogsties@iis.franhofer.de
- 3168: SP#51 completed. Extends Rel-9 Improved Video Support for PSS and MBMS (UID_430039) / WI rapporteur e-mail: imed.bouazizi@nokia.com, jaihyung@etri.re.kr
- 3169: SP#47 completed / WI rapporteur e-mail: shan.mingjun@huawei.com
- 3170: SP#47 completed. Study result might impact Feature UID_420011 Self Organising Networks (SON) / WI rapporteur e-mail: Jean-Michel Cornilly (Orange)
- 3171: SP#47 completed / WI rapporteur e-mail: Yizhi Yao (yzyao@motorola.com)
- 3172: SP#51 completed / WI rapporteur e-mail: olaf.pollakowski@nsn.com
- 3173: SP#51 completed / WI rapporteur e-mail: olaf.pollakowski@nsn.com, Padma.Sudarsan@alcatel-lucent.com
- 3174: SP#51 completed / WI rapporteur e-mail: edwin.tse@ericsson.com
- 3175: SP#51 completed / WI rapporteur e-mail: Padma.Sudarsan@alcatel-lucent.com
- 3176: CP#49 completed / WI rapporteur e-mail: gottfried.punz@nw.neclab.eu
- 3177: CP#51 completed. Study UDC evolution from FeaturES in CP-150Rel-9 UID_400034 and Rel-10 UID_480011 UDC Data Model / WI rapporteur e-mail: jean-jacques.trottin@alcatel-lucent.com
- 3178: CP#51 completed / WI rapporteur e-mail: Denis.Lheriteau@gemalto.com
- 3179: RP#48 completed / WI rapporteur e-mail: Heechoon Lee (heechoon@qualcomm.com)
- 3180: RP#49 completed. Based on ETSI EE TS 102 706. / WI rapporteur e-mail: Prakash.bhat@vodafone.com
- 3181: RP#52 completed / WI rapporteur e-mail: Yang Ning (yangning@chinamobile.com)
- 3182: RP#50 completed. TR 25.865 v101 for Approval / WI rapporteur e-mail: huang.he4@zte.com.cn
- 3183: SP#47 work stopped/abandoned / WI rapporteur e-mail: Juergen.Merkel@nsn.com
- 3184: SP#50 work stopped. Additional work may be addressed as part of the Rel-11 Feature UID_470051 Advanced IP Interconnection of Services (IPXS) / WI rapporteur e-mail: Rajat Ghai (rghai@starentnetworks.com)
- 3185: SP#47 work stopped. Issue covered by Rel-10 UID_460039 Charging for LIPA_SIPTO and UID_4700xy Charging for IFOM / WI rapporteur e-mail: Gerald.Goermer@nsn.com
- 3186: CP#48 work stopped/abandoned / WI rapporteur e-mail: takaaki.matsuura.sp@s1.nttdocomo.com
- 3187: -

| ID | WBS | Task | Duration | Start | Finish | Complete | Baseline start | Baseline finish | Baseline duration | Constraint | Resources | Work | Actual work | Acronym | PCG approved | WI rapporteur name | WI rapporteur e-mail | Release | TSG approved | MCC resp | Special Focus Doc | Acronym_3GU_Export | Status Report |
| --- | --- | --- | --- | --- | --- | --- | --- | --- | --- | --- | --- | --- | --- | --- | --- | --- | --- | --- | --- | --- | --- | --- | --- |
| 3188 | 815 | **Enhanced Home NodeB / eNodeB** | 921d? | 2008-06-05 A | 2011-12-09 A | 100% | 2008-06-05 | 2011-12-09 | 921d? |  | S1; S2; S3; S5; C1; C6; R2; R3; R4; R5; GP | 113136h | 113136h | EHNB | PCG-21 | T-Mobile | michael.kurz@t-mobile.at | Rel-9 | SP-40 | Alain | HNB | EHNB |  |
| 3189 | 815.1 | Stage 1 for EHNB | 261d? | 2008-06-05 A | 2009-06-04 A | 100% | 2008-06-05 | 2009-06-04 | 261d? | finish no earlier than 2009-06-04 | S1 | 2088h | 2088h | EHNB | PCG-21 | T-Mobile | michael.kurz@t-mobile.at | Rel-9 | SP-40 | Alain | HNB |  |  |
| 3190 | 815.2 | Architecture aspects of EHNB | 266d? | 2008-09-18 A | 2009-09-24 A | 100% | 2008-09-18 | 2009-09-24 | 266d? | finish no earlier than 2009-09-22 | S2 | 2128h | 2128h | EHNB | PCG-21 | T-Mobile | sebastian.speicher@telekom.de | Rel-9 | SP-41 | Maurice | HNB |  |  |
| 3191 | 815.3 | Security aspects of Enhanced Home NodeB / eNodeB | 262d? | 2008-12-11 A | 2009-12-10 A | 100% | 2008-12-11 | 2009-12-10 | 262d? | finish no earlier than 2009-12-10 | S3 | 2096h | 2096h | EHNB-Sec | PCG-22 | Huawei | Marcus Wong (mwong@huawei.com) | Rel-9 | SP-42 | Mirko | HNB | EHNB-Sec |  |
| 3192 | 815.4 | CT1 aspects - Support of Home NB and Home eNB enhancements | 321d? | 2009-09-18 A | 2010-12-10 A | 100% | 2009-09-18 | 2010-12-10 | 321d? | finish no earlier than 2010-12-10 | C1 | 2568h | 2568h | EHNB-CT1 | PCG-23 | Qualcomm | Ramachandran Subramanian (rsubrama@qualcomm.com) | Rel-9 | CP-45 | Frederic | HNB | EHNB-CT1 |  |
| 3193 | 815.5 | CT6 aspects - Support of Home NB and Home eNB enhancements | 131d? | 2009-09-18 A | 2010-03-19 A | 100% | 2009-09-18 | 2010-03-19 | 131d? | finish no earlier than 2010-03-19 | C6 | 1048h | 1048h | EHNB-CT6 | PCG-23 | Qualcomm | Ramachandran Subramanian (rsubrama@qualcomm.com) | Rel-9 | CP-45 | Xavier | HNB | EHNB-CT6 |  |
| 3194 | 815.6 | 3G HNB Gateway and LTE HeNB Gateway OAM&P | 336d? | 2008-12-11 A | 2010-03-25 A | 100% | 2008-12-11 | 2010-03-25 | 336d? | finish no earlier than 2010-03-25 | S5 | 2688h | 2688h | HNB-OAM_GW | PCG-22 | China Mobile | GangChen (chengang@chinamobile.com) | Rel-9 | SP-42 | Mirko | HNB | HNB-OAM_GW |  |
| 3195 | 815.7 | 3G HNB and LTE HeNB OAM&P Type 1 Interface | 272d? | 2009-03-12 A | 2010-03-25 A | 100% | 2009-03-12 | 2010-03-25 | 272d? | finish no earlier than 2010-03-25 | S5 | 2168h | 2168h | HNB_eHNB-OAM_Type1 | PCG-22 | Huawei | Zou Lan (zlan@huawei.com) | Rel-9 | SP-43 | Mirko | HNB | HNB_eHNB-OAM_Type1 |  |
| 3196 | 815.8 | 3G HNB and LTE HeNB OAM&P Type 2 Interface | 225d? | 2009-05-15 A | 2010-03-25 A | 100% | 2009-05-15 | 2010-03-25 | 225d? | finish no earlier than 2010-03-25 | S5 | 1800h | 1800h | HNB_eHNB-OAM_Type2 | PCG-23 | Ericsson | edwin.tse@ericsson.com | Rel-9 | SP-44 | Mirko | HNB | HNB_eHNB-OAM_Type2 |  |
| 3197 | 815.9 | LTE FDD Home eNodeB RF Requirements | 336d? | 2008-12-05 A | 2010-03-19 A | 100% | 2008-12-05 | 2010-03-19 | 336d? | finish no earlier than 2010-03-19 | R4 | 2688h | 2688h | HeNB-RF_FDD | PCG-22 | Motorola | Ying Cai (yingcai@motorola.com) | Rel-9 | RP-42 | Issam | HNB | HeNB-RF_FDD | RP-100035 |
| 3198 | 815.10 | LTE TDD Home eNodeB RF Requirements | 271d? | 2009-03-06 A | 2010-03-19 A | 100% | 2009-03-06 | 2010-03-19 | 271d? | finish no earlier than 2010-03-19 | R4 | 2168h | 2168h | HeNB-RF_TDD | PCG-22 | China Mobile | Nan Li (linan@chinamobile.com) | Rel-9 | RP-43 | Issam | HNB | HeNB-RF_TDD | RP-100036 |
| 3199 | 815.11 | Home NB and Home eNB enhancements - RAN3 aspects | 197d? | 2009-03-06 A | 2009-12-04 A | 100% | 2009-03-06 | 2009-12-04 | 197d? | finish no earlier than 2009-12-04 | R3 | 1576h | 1576h | EHNB-RAN3 | PCG-22 | Alcatel-Lucent | Martin Warner (mw15@alcatel-lucent.com) | Rel-9 | RP-43 | Juha | HNB | EHNB-RAN3 | RP-091050 |
| 3200 | 815.12 | Home NB and Home eNB enhancements - RAN2 aspects | 271d? | 2009-03-06 A | 2010-03-19 A | 100% | 2009-03-06 | 2010-03-19 | 271d? | finish no earlier than 2010-03-19 | R2 | 2168h | 2168h | EHNB-RAN2 | PCG-22 | Huawei | Yang Xudong (yangxudong@huawei.com) | Rel-9 | RP-43 | Yong-Jun | HNB | EHNB-RAN2 | RP-100037 |
| 3201 | 815.13 | Conformance Test Aspects – Home NB enhancements for FDD | 322d? | 2010-09-17 A | 2011-12-09 A | 100% | 2010-09-17 | 2011-12-09 | 322d? | finish no earlier than 2011-12-09 | R5 | 2568h | 2568h | EHNB-UTRA_FDD_UEConTest | PCG-25 | Huawei | trica_li@huawei.com | Rel-9 | RP-49 | Ingbert | HNB | EHNB-UTRA_FDD_UEConTest | RP-111679 |
| 3202 | 815.14 | Conformance Test Aspects – Home eNB enhancements | 201d? | 2010-12-10 A | 2011-09-16 A | 100% | 2010-12-10 | 2011-09-16 | 201d? | finish no earlier than 2011-09-16 | R5 | 1608h | 1608h | EHNB-LTE_UEConTest | PCG-26 | Qualcomm | Mrs Lena Chaponniere (lchaponn@qualcomm.com) | Rel-9 | RP-50 | Ingbert | HNB | EHNB-LTE_UEConTest | RP-110972 |
| 3203 | 815.15 | Home NB and Home eNB enhancements - GERAN aspects | 341d? | 2009-05-18 A | 2010-09-03 A | 100% | 2009-05-18 | 2010-09-03 | 341d? | finish no earlier than 2010-09-03 | GP | 2728h | 2728h | EHNB-GERAN | PCG-23 | Nokia Siemens Networks | leonardo.provvedi@roke.co.uk | Rel-9 | GP-42 | Paolo | HNB | EHNB-GERAN |  |
| 3204 | 816 | **Value-Added Services for Short Message Service** | 586d? | 2007-09-10 A | 2009-12-04 A | 100% | 2007-09-10 | 2009-12-04 | 586d? |  | S1; C4; C1 | 20264h | 20264h | VAS4SMS |  | China Mobile | Wu Bin (wubin@chinamobile.com) | Rel-9 | SP-37 | Alain |  | VAS4SMS |  |
| 3205 | 816.1 | Stage 1 for VAS4SMS | 133d? | 2007-09-10 A | 2008-03-12 A | 100% | 2007-09-10 | 2008-03-12 | 133d? | finish no earlier than 2008-03-21 | S1 | 1064h | 1064h | VAS4SMS |  | China Mobile | Wu Bin (wubin@chinamobile.com) | Rel-9 | SP-37 | Alain |  |  |  |
| 3206 | 816.2 | CT4 aspects of VAS4SMS Interface and Signalling Flow | 322d? | 2008-09-12 A | 2009-12-04 A | 100% | 2008-09-12 | 2009-12-04 | 322d? | finish no earlier than 2009-12-04 | C4 | 2568h | 2568h | VAS4SMS | PCG-21 | China Mobile | Wu Bin (wubin@chinamobile.com) | Rel-9 | CP-41 | Kimmo |  |  |  |
| 3207 | 816.3 | CT1 aspects of VAS4SMS Interface and Signalling Flow | 321d? | 2008-09-09 A | 2009-12-04 A | 100% | 2008-09-09 | 2009-12-04 | 321d? | finish no earlier than 2009-12-04 | C1 | 2568h | 2568h | VAS4SMS | PCG-21 | China Mobile | Wu Bin (wubin@chinamobile.com) | Rel-9 | CP-41 | Frederic |  |  |  |
| 3208 | 817 | **Definition of End-User Identity** | 334d? | 2007-09-03 A | 2008-12-11 A | 100% | 2007-09-03 | 2008-12-11 | 334d? |  | S1 | 5344h | 5344h | EUI |  | Nokia Siemens Networks | Juergen.Merkel@nsn.com | Rel-9 | SP-38 | Alain |  | EUI |  |
| 3209 | 817.1 | Stage 1 for Definition of End-User Identity | 334d? | 2007-09-03 A | 2008-12-11 A | 100% | 2007-09-03 | 2008-12-11 | 334d? | finish no earlier than 2008-12-11 | S1 | 2672h | 2672h | EUI | PCG-21 | Nokia Siemens Networks | Juergen.Merkel@nsn.com | Rel-9 | SP-38 | Alain |  |  |  |
| 3210 | 818 | **Customized Ringing Signal** | 522d? | 2007-12-06 A | 2009-12-03 A | 100% | 2007-12-06 | 2009-12-03 | 522d? |  | S1; C1 | 11296h | 11296h | CRS | PCG-21 | SK Telecom, China Mobile | Donghee Shim (SK Telecom), Jianping Zheng (China Mobile) | Rel-9 | SP-38 | Alain |  | CRS |  |
| 3211 | 818.1 | Stage 1 for Customized Ringing Signal | 266d? | 2007-12-06 A | 2008-12-11 A | 100% | 2007-12-06 | 2008-12-11 | 266d? | finish no earlier than 2008-12-11 | S1 | 2128h | 2128h | CRS | PCG-21 | SK Telecom, China Mobile | Donghee Shim (SK Telecom), Jianping Zheng (China Mobile) | Rel-9 | SP-38 | Alain |  |  |  |
| 3212 | 818.2 | Stage 3 for IMS Customized Ringing Signal (CRS) Service | 136d? | 2009-05-29 A | 2009-12-03 A | 100% | 2009-05-29 | 2009-12-03 | 136d? | finish no earlier than 2010-06-04 | C1 | 816h | 816h | CRS | PCG-23 | China Mobile | wangzhao | Rel-9 | CP-44 | Frederic |  |  |  |

Notes:
- 3188: RP#54 Testing completed / Impacted TSs and TRs: UTRA, LTE
- 3189: CP#49 the SA1-reqs are moving. CT1 will align when the work in SA1 is clear. (was SP#44 completed.) / Impacted TSs and TRs: 22.220, 22.011
- 3190: SP#45 completed / Impacted TSs and TRs: 23.401, 23.402, 23.060, New 23.830
- 3191: SP#46 completed / Impacted TSs and TRs: New 33.320
- 3192: CP#50 completed (Roaming aspects for manual CSG selection, Support of temporary users and CSG membership changes, Support of user controlled and operator controlled lists) / Impacted TSs and TRs: 23.122, 24.008, 24.285, 24.301
- 3193: CP#47 completed. Storing of CSG related data items on the USIM / Impacted TSs and TRs: 31.102
- 3194: SP#47 completed / Impacted TSs and TRs: 32.632, 32.633, 32.635, New (32.771, 32.772, 32.773, 32.775, 32.781, 32.782, 32.783, 32.785)
- 3195: SP#47 completed / Impacted TSs and TRs: 32.581, 32.582, 32.583, 32.584, New (32.591, 32.592, 32.593, 32.594)
- 3196: SP#47 completed / Impacted TSs and TRs: New (32.571, 32.572)
- 3197: RP#47 completed / Impacted TSs and TRs: 36.104, 36.141, New TR 36.921
- 3198: RP#47 completed / Impacted TSs and TRs: 36.104, 36.141, 36.300, 36.331, 36.413, New TR 36.922
- 3199: RP#46 completed (based on high priority items specified in RP-090995) / Impacted TSs and TRs: 25.413, 25.467, 25.467, 25.468, 25.469, 25.469, 36.401, 36.413, New 25.444
- 3200: RP#47 completed / Impacted TSs and TRs: 25.304, 25.331, 25.367, 36.300, 36.304, 36.331
- 3201: UTRA. RP#54 completed. Testing for UID_430026 Support of Home NB and Home eNB enhancements RAN2 aspects (25.304, 25.331, 25.367) / Impacted TSs and TRs: 34.108, 34.121-1, 34.121-2, 34.123-1, 34.123-2, 34.123-3
- 3202: RP#53 completed / Impacted TSs and TRs: 36.508, 36.523-1, 36.523-2, 36.523-3
- 3203: GP#47 completed. GP#42 WID approved / Impacted TSs and TRs: 43.055, 43.129, 44.018, 44.060, 45.008, 48.008, 48.018
- 3204: CP#46 completed
- 3205: SP#39 completed. SP#43 Feature moved to Rel-9 / Impacted TSs and TRs: new 22.142
- 3206: CP#46 completed / Impacted TSs and TRs: new 23.142
- 3207: CP#46 completed / Impacted TSs and TRs: 23.040
- 3208: SP#42 closed. Stage 1 work closed at 5% completion due to lack of input (added only the EUI definition in 21.905)
- 3209: SP#42 closed. Stage 1 work closed at 5% completion due to lack of input (added only the EUI definition in 21.905) / Impacted TSs and TRs: 21.905
- 3210: CP#48 completed
- 3211: SP#42 completed. / Impacted TSs and TRs: 22.173, new 22.183
- 3212: CP#48 completed / Impacted TSs and TRs: 24.173, new 24.183

| ID | WBS | Task | Type | Duration | Start | Finish | Complete | Baseline start | Baseline finish | Baseline duration | Constraint | Resources | Work | Actual work | Acronym | PCG approved | Impacted TSs and TRs | WI rapporteur name | Release | TSG approved | MCC resp | Special Focus Doc | Acronym_3GU_Export | Status Report |
| --- | --- | --- | --- | --- | --- | --- | --- | --- | --- | --- | --- | --- | --- | --- | --- | --- | --- | --- | --- | --- | --- | --- | --- | --- |
| 3213 | 819 | **Public Warning System** |  | 1315d? | 2007-12-06 A | 2012-12-07 A | 100% | 2007-12-06 | 2012-12-07 | 1315d? |  | S1; C1; C4; R2; R3; R5 | 73920h | 73920h | PWS | PCG-21 | LTE | T-Mobile | Rel-9 | SP-38 | Alain | Public Safety (I-A) | PWS |  |
| 3214 | 819.1 | Stage 1 for Public Warning System |  | 266d? | 2007-12-06 A | 2008-12-11 A | 100% | 2007-12-06 | 2008-12-11 | 266d? | finish no earlier than 2008-12-11 | S1 | 2128h | 2128h | PWS | PCG-21 | 22.268 | T-Mobile | Rel-9 | SP-38 | Alain | Public Safety (I-A) |  |  |
| 3215 | 819.2 | **Stage 3 for Public Warning System** |  | 137d? | 2009-05-29 A | 2009-12-04 A | 100% | 2009-05-29 | 2009-12-04 | 137d? |  | C1; C4 | 4368h | 4368h | PWS-St3 | PCG-23 |  | Qualcomm | Rel-9 | CP-44 | Frederic | Public Safety (I-A) | PWS-St3 |  |
| 3216 | 819.2.1 | CT1 aspects of Stage 3 for Public Warning System |  | 137d? | 2009-05-29 A | 2009-12-04 A | 100% | 2009-05-29 | 2009-12-04 | 137d? | finish no earlier than 2009-12-04 | C1 | 1088h | 1088h | PWS-St3 | PCG-23 | 23.041 | Qualcomm | Rel-9 | CP-44 | Frederic | Public Safety (I-A) |  |  |
| 3217 | 819.2.2 | CT4 aspects of Stage 3 for Public Warning System |  | 136d? | 2009-05-30 A | 2009-12-04 A | 100% | 2009-05-30 | 2009-12-04 | 136d? | finish no earlier than 2009-12-04 | C4 | 1088h | 1088h | PWS-St3 | PCG-23 | 29.168 | Qualcomm | Rel-9 | CP-44 | Kimmo | Public Safety (I-A) |  |  |
| 3218 | 819.3 | Public Warning System (PWS) – RAN aspects |  | 136d? | 2009-05-30 A | 2009-12-04 A | 100% | 2009-05-30 | 2009-12-04 | 136d? | finish no earlier than 2009-12-04 | R2; R3 | 2176h | 2176h | PWS-RAN | PCG-23 | LTE 36.300, 36.302, 36.331, 36.413 | AT&T | Rel-9 | RP-44 | Yong-Jun | Public Safety (I-A) | PWS-RAN | RP-091052 |
| 3219 | 819.4 | Conformance Test Aspects – Public Warning System (PWS) – RAN aspects for LTE |  | 267d? | 2011-12-02 A | 2012-12-07 A | 100% | 2011-12-02 | 2012-12-07 | 267d? | finish no earlier than 2012-12-07 | R5 | 2128h | 2128h | PWS-RAN_UEConTest | PCG-28 | 36.508, 36.523-1, 36.523-2, 36.523-3 | Qualcomm | Rel-9 | RP-54 | Ingbert | Public Safety (I-A) | PWS-RAN_UEConTest | RP-121525 |
| 3220 | 820 | **Support of Personal Area Networks and Enhancements to Personal Network Management** |  | 523d? | 2008-06-05 A | 2010-06-04 A | 100% | 2008-06-05 | 2010-06-04 | 523d? |  | S1; C1 | 12544h | 12544h | PAN_EPNM | PCG-21 |  | Vodafone | Rel-9 | SP-40 | Alain |  | PAN_EPNM |  |
| 3221 | 820.1 | Stage 1 for Support of Personal Area Networks and Enhancements to Personal Network Management | milestone | 0d? | 2008-06-05 A | 2008-06-05 A | 100% | 2008-06-05 | 2008-06-05 | 0d? | finish no earlier than 2008-06-05 | S1 |  |  | PAN_EPNM | PCG-21 | 22.259 | Vodafone | Rel-9 | SP-40 | Alain |  |  |  |
| 3222 | 820.2 | Stage 2 for Support of Personal Area Networks and Enhancements to Personal Network Management |  | 196d? | 2009-03-06 A | 2009-12-04 A | 100% | 2009-03-06 | 2009-12-04 | 196d? | finish no earlier than 2009-12-04 | C1 | 1568h | 1568h | PAN_EPNM | PCG-22 | 23.259 | Huawei | Rel-9 | CP-43 | Frederic |  |  |  |
| 3223 | 820.3 | Stage 3 for Support of Personal Area Networks and Enhancements to Personal Network Management |  | 326d? | 2009-03-09 A | 2010-06-04 A | 100% | 2009-03-09 | 2010-06-04 | 326d? | finish no earlier than 2010-06-04 | C1 | 2608h | 2608h | PAN_EPNM | PCG-22 | 24.259 | Huawei | Rel-9 | CP-43 | Frederic |  |  |  |
| 3224 | 821 | **Multi-Media Telephony Service enhancements** |  | 472d? | 2008-06-05 A | 2010-03-25 A | 100% | 2008-06-05 | 2010-03-25 | 472d? |  | S1; S5; C1 | 17840h | 17840h | eMMTel | PCG-21 |  | France Telecom | Rel-9 | SP-40 | Alain |  | eMMTel |  |
| 3225 | 821.1 | Stage 1 for eMMTel |  | 136d? | 2008-06-05 A | 2008-12-11 A | 100% | 2008-06-05 | 2008-12-11 | 136d? | start no earlier than 2008-06-05 | S1 | 1088h | 1088h | eMMTel | PCG-21 | 22.173 | France Telecom | Rel-9 | SP-40 | Alain |  |  |  |
| 3226 | 821.2 | Multimedia Telephony (MMTel) Service and Supplementary Services - Online Charging and completion for Offline Charging (all supplementary services) |  | 272d? | 2009-03-12 A | 2010-03-25 A | 100% | 2009-03-12 | 2010-03-25 | 272d? | finish no earlier than 2010-03-25 | S5 | 2168h | 2168h | eMMTel-SS-CH | PCG-22 | 32.275, 32.298, 32.299 | Alcatel-Lucent | Rel-9 | SP-43 | Mirko |  | eMMTel-SS-CH |  |
| 3227 | 821.3 | Support of Real-time Transfer of Tariff Information (RTTI) in IMS charging |  | 271d? | 2009-03-12 A | 2010-03-25 A | 100% | 2009-03-12 | 2010-03-25 | 271d? | finish no earlier than 2010-03-25 | S5 | 2168h | 2168h | IMSTSS-RTTI-CH | PCG-22 | 32.240, 32.280, 32.298, 32.299 | Orange | Rel-9 | SP-43 | Mirko |  | IMSTSS-RTTI-CH |  |
| 3228 | 821.4 | Stage 3 - Enhancements for Completion of Communications Supplementary service |  | 136d? | 2009-05-30 A | 2009-12-04 A | 100% | 2009-05-30 | 2009-12-04 | 136d? | finish no earlier than 2009-12-04 | C1 | 1088h | 1088h | eMMTel-CC | PCG-23 | 24.642 | France Telecom | Rel-9 | CP-44 | Frederic |  | eMMTel-CC |  |
| 3229 | 822 | **User Data Convergence (UDC)** |  | 527d? | 2008-06-05 A | 2010-06-10 A | 100% | 2008-06-05 | 2010-06-10 | 527d? |  | S1; S5; C4 | 25056h | 25056h | UDC | PCG-21 |  | Nokia Siemens Networks | Rel-9 | SP-40 | Alain |  | UDC |  |
| 3230 | 822.1 | Stage 1 for User Data Convergence (UDC) |  | 136d? | 2008-06-05 A | 2008-12-11 A | 100% | 2008-06-05 | 2008-12-11 | 136d? | start no earlier than 2008-06-05 | S1 | 1088h | 1088h | UDC | PCG-21 | 22.101, new 22.985 | Nokia Siemens Networks | Rel-9 | SP-40 | Alain |  |  |  |
| 3231 | 822.2 | **Stage 2/3 for User Data Convergence (UDC) Technical Realization** |  | 272d? | 2009-03-06 A | 2010-03-19 A | 100% | 2009-03-06 | 2010-03-19 | 272d? |  | C4 | 5376h | 5376h | UDC-CN | PCG-22 |  | Ericsson | Rel-9 | CP-43 | Kimmo |  | UDC-CN |  |
| 3232 | 822.2.1 | User Data Convergence (UDC) Technical Realization (Stage 2) |  | 271d? | 2009-03-06 A | 2010-03-19 A | 100% | 2009-03-06 | 2010-03-19 | 271d? | finish no earlier than 2010-03-19 | C4 | 2168h | 2168h | UDC-CN | PCG-22 | new 23.335 | Ericsson | Rel-9 | CP-43 | Kimmo |  |  |  |
| 3233 | 822.2.2 | User Data Convergence (UDC) Protocol Description |  | 130d? | 2009-09-18 A | 2010-03-19 A | 100% | 2009-09-18 | 2010-03-19 | 130d? | finish no earlier than 2010-03-19 | C4 | 1040h | 1040h | UDC-CN | PCG-23 | new 29.335 | China Mobile, Ericsson | Rel-9 | CP-45 | Kimmo |  |  |  |
| 3234 | 822.3 | **User Data Convergence (UDC) Modelling and Management** |  | 266d? | 2009-06-04 A | 2010-06-10 A | 100% | 2009-06-04 | 2010-06-10 | 266d? |  | S5 | 5944h | 5944h | UDC-MMAN | PCG-23 |  | T-Mobile, China Mobile, Ericsson | Rel-9 | SP-44 | Mirko |  | UDC-MMAN |  |
| 3235 | 822.3.1 | UDC – Framework for Model Handling and Management |  | 266d? | 2009-06-04 A | 2010-06-10 A | 100% | 2009-06-04 | 2010-06-10 | 266d? | finish no earlier than 2010-06-10 | S5 | 2128h | 2128h | UDC-MMAN-MFRM | PCG-23 | 32.172, new 32.181 | T-Mobile | Rel-9 | SP-44 | Mirko |  | UDC-MMAN-MFRM |  |
| 3236 | 822.3.2 | UDC – Common Baseline Information Model |  | 211d? | 2009-06-04 A | 2010-03-25 A | 100% | 2009-06-04 | 2010-03-25 | 211d? | finish no earlier than 2010-03-25 | S5 | 1688h | 1688h | UDC-MMAN-CBIM | PCG-23 | 32.172, new 32.182 | China Mobile, Ericsson | Rel-9 | SP-44 | Mirko |  | UDC-MMAN-CBIM |  |

Notes:
- 3213: TSG#46 completed. Larger scope than Rel-8 Feature UID_370051 (ETWS). Triggered by TR 22.968 Study UID_320025 (FS_PWS) / WI rapporteur e-mail: Mark.Younge@t-mobile.com
- 3214: SP#42 completed / WI rapporteur e-mail: Mark.Younge@t-mobile.com
- 3215: RP#46 completed / WI rapporteur e-mail: Ramachandran Subramanian (rsubrama@qualcomm.com)
- 3216: CP#46 completed / WI rapporteur e-mail: Ramachandran Subramanian (rsubrama@qualcomm.com)
- 3217: CP#46 completed / WI rapporteur e-mail: Ramachandran Subramanian (rsubrama@qualcomm.com)
- 3218: RP#46 completed / WI rapporteur e-mail: don.zelmer@att.com
- 3219: RP#58 completed / WI rapporteur e-mail: Shubhang Vora (svora@qualcomm.com)
- 3220: CP#48 completed / WI rapporteur e-mail: armin.toepfer@vodafone.com
- 3221: SP#40 completed / WI rapporteur e-mail: armin.toepfer@vodafone.com
- 3222: CP#46 completed / WI rapporteur e-mail: Lili Yang (kadyyang@huawei.com)
- 3223: CP#48 completed / WI rapporteur e-mail: Lili Yang (kadyyang@huawei.com)
- 3224: SP#47 completed / WI rapporteur e-mail: philippe.lottin@orange.com
- 3225: SP#42 completed / WI rapporteur e-mail: philippe.lottin@orange.com
- 3226: SP#47 completed / WI rapporteur e-mail: maryse.gardella@alcatel-lucent.com
- 3227: SP#47 completed. Linked to SA5 Rel-8 UID_380042 AoC support in IMS Charging (IMSTSS) / WI rapporteur e-mail: Jean-Luc Garcia (jl.garcia@orange-ftgroup.com)
- 3228: CP#46 completed / WI rapporteur e-mail: Youssef.chadli@orange-ftgroup.com
- 3229: SP#48 completed. Triggered by Rel-8 SA5 Study of Common Profile Storage Framework of User Data for network services and management (UID_320006) TR 32.808 / WI rapporteur e-mail: juergen.merkel@nsn.com
- 3230: SP#42 completed / WI rapporteur e-mail: juergen.merkel@nsn.com
- 3231: - / WI rapporteur e-mail: emiliano.merino@ericsson.com
- 3232: CP#47 completed / WI rapporteur e-mail: emiliano.merino@ericsson.com
- 3233: CP#47 completed / WI rapporteur e-mail: Lan Si Zhong (lansizhong@chinamobile.com), emiliano.merino@ericsson.com
- 3234: SP#48 completed / WI rapporteur e-mail: istvan.aba@t-mobile.at, lansizhong@chinamobile.com, miguel.a.garcia@ericsson.com
- 3235: SP#48 completed / WI rapporteur e-mail: istvan.aba@t-mobile.at
- 3236: SP#47 completed / WI rapporteur e-mail: Lan Si Zhong, Miguel Garcia

| ID | WBS | Task | Duration | Start | Finish | Complete | Baseline start | Baseline finish | Baseline duration | Constraint | Resources | Work | Actual work | Acronym | PCG approved | WI rapporteur name | WI rapporteur e-mail | Release | TSG approved | MCC resp | Acronym_3GU_Export | Status Report | Special Focus Doc |
| --- | --- | --- | --- | --- | --- | --- | --- | --- | --- | --- | --- | --- | --- | --- | --- | --- | --- | --- | --- | --- | --- | --- | --- |
| 3237 | 823 | **IMS Services Centralization and Continuity** | 393d? | 2008-09-18 A | 2010-03-19 A | 100% | 2008-09-18 | 2010-03-19 | 393d? |  | S1; S2; C1 | 30992h | 30992h | IMS_SCC | PCG-21 | NEC | joerg.swetina@neclab.eu | Rel-9 | SP-41 | Alain | IMS_SCC |  |  |
| 3238 | 823.1 | Stage 1 - Inter-Device Transfer – Requirements | 61d? | 2008-09-18 A | 2008-12-11 A | 100% | 2008-09-18 | 2008-12-11 | 61d? | finish no earlier than 2009-06-18 | S1 | 488h | 488h | IMS_SCC-IDT | PCG-21 | NEC | joerg.swetina@neclab.eu | Rel-9 | SP-41 | Alain | IMS_SCC-IDT |  |  |
| 3239 | 823.2 | **Stage 2/3 for IMS Service Continuity Enhancements: Service, Policy and Interactions** | 393d? | 2008-09-18 A | 2010-03-19 A | 100% | 2008-09-18 | 2010-03-19 | 393d? |  | S2; C1 | 9456h | 9456h | IMS_SCC-SPI | PCG-21 | Huawei | HengLiang Zhang (hl_zhang@huawei.com) | Rel-9 | SP-41 | Maurice | IMS_SCC-SPI |  |  |
| 3240 | 823.2.1 | Stage 2 for IMS Service Continuity Enhancements: Service, Policy and Interactions | 186d? | 2008-09-18 A | 2009-06-04 A | 100% | 2008-09-18 | 2009-06-04 | 186d? | finish no earlier than 2009-06-04 | S2 | 1488h | 1488h | IMS_SCC-SPI | PCG-21 | Huawei | HengLiang Zhang (hl_zhang@huawei.com) | Rel-9 | SP-41 | Maurice |  |  |  |
| 3241 | 823.2.2 | Stage 3 for IMS Service Continuity Enhancements: Service, Policy, Interactions and Inter UE Transfer | 212d? | 2009-05-29 A | 2010-03-19 A | 100% | 2009-05-29 | 2010-03-19 | 212d? | finish no earlier than 2010-03-19 | C1 | 1696h | 1696h | IMS_SCC-SPI | PCG-23 | Qualcomm | Roozbeh Atarius (ratarius@qualcomm.com) | Rel-9 | CP-44 | Frederic |  |  |  |
| 3242 | 823.3 | **Stage 2/3 for IMS Centralized Services** | 393d? | 2008-09-18 A | 2010-03-19 A | 100% | 2008-09-18 | 2010-03-19 | 393d? |  | S2; C1 | 9448h | 9448h | IMS_SCC-ICS | PCG-21 | Alcatel-Lucent | andy.bennett@alcatel-lucent.com | Rel-9 | SP-41 | Maurice | IMS_SCC-ICS |  |  |
| 3243 | 823.3.1 | Stage 2 for IMS Centralized Services | 186d? | 2008-09-18 A | 2009-06-04 A | 100% | 2008-09-18 | 2009-06-04 | 186d? | finish no earlier than 2009-06-04 | S2 | 1488h | 1488h | IMS_SCC-ICS | PCG-21 | Alcatel-Lucent | andy.bennett@alcatel-lucent.com | Rel-9 | SP-41 | Maurice |  |  |  |
| 3244 | 823.3.2 | Stage 3 for Enhancements to IMS Centralized Services | 212d? | 2009-05-29 A | 2010-03-19 A | 100% | 2009-05-29 | 2010-03-19 | 212d? | finish no earlier than 2010-03-19 | C1 | 1688h | 1688h | IMS_SCC-ICS | PCG-23 | Nokia Siemens Networks | Peter.Leis@nsn.com | Rel-9 | CP-44 | Frederic |  |  |  |
| 3245 | 823.4 | Stage 3 - IMS Centralized Services support via I1 interface | 271d? | 2009-03-06 A | 2010-03-19 A | 100% | 2009-03-06 | 2010-03-19 | 271d? | finish no earlier than 2010-03-19 | C1 | 2168h | 2168h | IMS_SCC-ICS_I1 | PCG-22 | Huawei | Lili Yang(kadyyang@huawei.com) | Rel-9 | CP-43 | Frederic | IMS_SCC-ICS_I1 |  |  |
| 3246 | 824 | **Service Specific Access Control in EPS** | 922d? | 2008-12-11 A | 2012-06-15 A | 100% | 2008-12-11 | 2012-06-15 | 922d? |  | S1; C1; R5 | 26000h | 26000h | SSAC | PCG-22 | NTT DoCoMo | Frederic Thepot (thepot@docomolab-euro.com) | Rel-9 | SP-42 | Alain | SSAC |  |  |
| 3247 | 824.1 | Stage 1 for Service Specific Access Control in EPS | 1d? | 2008-12-11 A | 2008-12-11 A | 100% | 2008-12-11 | 2008-12-11 | 1d? | start no earlier than 2008-12-11 | S1 | 8h | 8h | SSAC | PCG-22 | NTT DoCoMo | Frederic Thepot (thepot@docomolab-euro.com) | Rel-9 | SP-42 | Alain |  |  |  |
| 3248 | 824.2 | Stage 3 for Service Specific Access Control in EPS | 212d? | 2009-05-29 A | 2010-03-19 A | 100% | 2009-05-29 | 2010-03-19 | 212d? | finish no earlier than 2010-03-19 | C1 | 1696h | 1696h | SSAC | PCG-23 | NTT DoCoMo | Hideyuki Yamashita (yamashitahi@s1.nttdocomo.co.jp) | Rel-9 | CP-44 | Frederic |  |  |  |
| 3249 | 824.3 | Conformance Test Aspects - Service Specific Access Control | 272d? | 2011-06-07 A | 2012-06-15 A | 100% | 2011-06-07 | 2012-06-15 | 272d? | finish no earlier than 2012-06-15 | R5 | 2168h | 2168h | SSAC_UEConTest | PCG-27 | NTT DoCoMo | Takao.Shimizu.rp@nttdocomo.com | Rel-9 | RP-52 | Ingbert | SSAC_UEConTest | RP-120447 |  |
| 3250 | 825 | **Support for IMS Emergency Calls over GPRS and EPS** | 3785d? | 2000-01-03 A | 2014-06-13 A | 100% | 2000-01-03 | 2014-06-13 | 3785d? |  | S1; S2; S3; C1; C3; C4; R2; R3; R5; IETF | 293512h | 293512h | IMS_EMER_GPRS_EPS | PCG-21 | Alcatel-Lucent | Deborah Barclay | Rel-9 | SP-38 | Maurice | IMS_EMER_GPRS_EPS |  | Public Safety (I-A) |
| 3251 | 825.1 | Stage 1 for IMS Emergency Calls over GPRS and EPS | 239d? | 2008-01-14 A | 2008-12-11 A | 100% | 2008-01-14 | 2008-12-11 | 239d? | finish no earlier than 2008-12-11 | S1 | 1912h | 1912h | IMS_EMER_GPRS_EPS | PCG-21 | Alcatel-Lucent | Deborah Barclay | Rel-9 | SP-38 | Alain |  |  | Public Safety (I-A) |
| 3252 | 825.2 | Stage 2 for IMS Emergency Calls over GPRS and EPS | 364d? | 2008-01-14 A | 2009-06-04 A | 100% | 2008-01-14 | 2009-06-04 | 364d? | finish no earlier than 2009-06-04 | S2 | 2912h | 2912h | IMS_EMER_GPRS_EPS | PCG-21 | Alcatel-Lucent | Deborah Barclay | Rel-9 | SP-38 | Maurice |  |  | Public Safety (I-A) |
| 3253 | 825.3 | Security aspects for IMS Emergency Calls over GPRS and EPS | 391d? | 2008-12-12 A | 2010-06-10 A | 100% | 2008-12-12 | 2010-06-10 | 391d? | finish no earlier than 2010-03-25 | S3 | 3128h | 3128h | IMS_EMER_GPRS_EPS-Sec | PCG-22 | Alcatel-Lucent | Deborah Barclay | Rel-9 | SP-42 | Mirko | IMS_EMER_GPRS_EPS-Sec |  | Public Safety (I-A) |
| 3254 | 825.4 | **Stage 3 for IMS Emergency Calls over GPRS and EPS** | 801d? | 2009-05-29 A | 2012-06-15 A | 100% | 2009-05-29 | 2012-06-15 | 801d? |  | C1; C3; C4; R5 | 33331.7h | 33331.7h | IMS_EMER_GPRS_EPS | PCG-23 | Alcatel-Lucent | Frank Alfano (falfano@alcatel-lucent.com) | Rel-9 | CP-44 | Frederic |  |  | Public Safety (I-A) |
| 3255 | 825.4.1 | CT1 aspects - Stage 3 for IMS Emergency Calls over GPRS and EPS | 212d? | 2009-05-29 A | 2010-03-19 A | 100% | 2009-05-29 | 2010-03-19 | 212d? | finish no earlier than 2010-03-19 | C1 | 1696h | 1696h | IMS_EMER_GPRS_EPSC1 | PCG-23 | Alcatel-Lucent | Frank Alfano (falfano@alcatel-lucent.com) | Rel-9 | CP-44 | Frederic |  |  | Public Safety (I-A) |
| 3256 | 825.4.2 | Conformance Test Aspects - CT1 aspects for IMS Emergency Calls over GPRS and EPS | 532d? | 2010-06-04 A | 2012-06-15 A | 100% | 2010-06-04 | 2012-06-15 | 532d? | finish no earlier than 2012-06-15 | R5 | 4256h | 4256h | IMS_EMER_GPRS_EPS_UEConTest | PCG-25 | Samsung | stoyan.baev@partner.samsung.com | Rel-9 | RP-48 | Ingbert | IMS_EMER_GPRS_EPS_UEConTest | RP-120445 | Public Safety (I-A) |
| 3257 | 825.4.3 | CT3 aspects - Stage 3 for IMS Emergency Calls over GPRS and EPS | 82d? | 2009-05-29 A | 2009-09-18 A | 100% | 2009-05-29 | 2009-09-18 | 82d? | start no earlier than 2009-05-29 | C3 | 651.68h | 651.68h | IMS_EMER_GPRS_EPSC3 | PCG-23 | Alcatel-Lucent | Frank Alfano (falfano@alcatel-lucent.com) | Rel-9 | CP-44 | Adrian |  |  | Public Safety (I-A) |
| 3258 | 825.4.4 | CT4 aspects - Stage 3 for IMS Emergency Calls over GPRS and EPS | 137d? | 2009-05-29 A | 2009-12-04 A | 100% | 2009-05-29 | 2009-12-04 | 137d? | finish no earlier than 2009-12-04 | C4 | 1096h | 1096h | IMS_EMER_GPRS_EPSC4 | PCG-23 | Alcatel-Lucent | Frank Alfano (falfano@alcatel-lucent.com) | Rel-9 | CP-44 | Kimmo |  |  | Public Safety (I-A) |
| 3259 | 825.5 | Support for IMS Emergency Calls over LTE | 207d? | 2000-01-03 A | 2000-10-16 A | 100% | 2000-01-03 | 2000-10-16 | 207d? |  | R2; R3 | 3312h | 3312h | IMS_EMER_LTE | PCG-22 | Alcatel-Lucent | Sudeep Palat (spalat@alcatel-lucent.com) | Rel-9 | RP-42 | Yong-Jun | IMS_EMER_LTE | RP-090698 | Public Safety (I-A) |
| 3260 | 825.6 | Conformance Test Aspects – Support for IMS Emergency Calls over LTE | 187d? | 2010-03-25 A | 2010-12-10 A | 100% | 2010-03-25 | 2010-12-10 | 187d? | finish no earlier than 2010-12-10 | R5 | 1496h | 1496h | IMS_EMER_LTE_UEConTest | PCG-24 | Ericsson | leif.mattisson@ericsson.com | Rel-9 | RP-47 | Ingbert | IMS_EMER_LTE_UEConTest | RP-101068 | Public Safety (I-A) |

Notes:
- 3237: CP#47 completed
- 3238: SP#42 completed / Impacted TSs and TRs: 22.101, 22.228
- 3239: -
- 3240: SP#57 Removal of the MSC server assisted mid-call feature from Rel-9 by 23.237CR#0433 (CT1 proposed moving this feature to Rel-10). SP#44 completed. TR 23.838 for Approval / Impacted TSs and TRs: 23.237, 23.292, 23.216, new 23.838
- 3241: CP#47 completed / Impacted TSs and TRs: 24.216, 24.229, 24.237
- 3242: -
- 3243: SP#44 completed. TR 23.883 for Information + Approval / Impacted TSs and TRs: 23.292, new 23.883
- 3244: CP#47 completed / Impacted TSs and TRs: 24.292, 24.604, 24.607, 24.608, 24.611, 24.623
- 3245: CP#47 completed / Impacted TSs and TRs: 24.237, 24.292, new 24.294
- 3246: CP#47 completed. Triggered by TR 22.986 Study on Service Specific Access Control in EPS. As EPS is a PS-Domain only system, Domain Specific Access Control (DSAC) doesn't apply, hence SSAC allows restriction of voice and non-voice calls separately
- 3247: SP#42 completed. If UE supports E-UTRA and IMS, SSAC is a mandatory Rel-9 function (during congestion in emergency case earthquake/tsunami improves mobile communications). / Impacted TSs and TRs: 22.011 CR0136
- 3248: CP#47 completed / Impacted TSs and TRs: 24.173, 27.007
- 3249: RP#56 completed. Testing for Stage 3 for Service Specific Access Control in EPS (24.173, 27.007) UID_440040 / Impacted TSs and TRs: 34.229-1, 34.229-2, 34.229-3
- 3250: RP#56 completed testing. CP#47 completed. SP#48 completed / Impacted TSs and TRs: GERAN, LTE
- 3251: SP#42 completed / Impacted TSs and TRs: 22.101
- 3252: SP#44 completed / Impacted TSs and TRs: 23.869, 23.060, 23.167, 23.203, 23.221, 23.228, 23.271, 23.401, 23.402
- 3253: SP#48 completed / Impacted TSs and TRs: 33.401, 33.402
- 3254: RP#56 completed testing. CP#47 completed / Impacted TSs and TRs: GERAN, LTE
- 3255: CP#47 completed / Impacted TSs and TRs: 23.122, 24.008, 24.229, 24.301, 24.302
- 3256: RP#56 completed / Impacted TSs and TRs: 34.108, 34.123-1, 34.123-2, 34.123-3, 34.229-1, 34.229-2, 34.229-3, 36.508, 36.523-1, 36.523-2, 36.523-3
- 3257: CP#45 completed / Impacted TSs and TRs: 29.212, 29.213, 29.214, 29.215
- 3258: CP#46 completed / Impacted TSs and TRs: 23.003, 23.008, 29.060, 29.272, 29.273, 29.274, 29.275, 29.276
- 3259: RP#45 completed / Impacted TSs and TRs: 36.331, 36.413
- 3260: RP#50 completed / Impacted TSs and TRs: 36.508, 36.523-1, 36.523-2, 36.523-3

| ID | WBS | Task | Type | Duration | Start | Finish | Complete | Baseline start | Baseline finish | Baseline duration | Constraint | Resources | Work | Actual work | Acronym | PCG approved | WI rapporteur name | WI rapporteur e-mail | Release | TSG approved | MCC resp | Special Focus Doc | Acronym_3GU_Export | Status Report |
| --- | --- | --- | --- | --- | --- | --- | --- | --- | --- | --- | --- | --- | --- | --- | --- | --- | --- | --- | --- | --- | --- | --- | --- | --- |
| 3261 | 825.7 | **Single Radio Voice Call Continuity (SRVCC) support for IMS Emergency Calls** |  | 1511d? | 2008-09-18 A | 2014-06-13 A | 100% | 2008-09-18 | 2014-06-13 | 1511d? |  | S2; C1; C4; C3; IETF | 112300h | 112300h | IMS_EMER_GPRS_EPS-SRVCC | PCG-21 | China Mobile | Yu Qing (Yuqing@chinamobile.com) | Rel-9 | SP-41 | Maurice | Public Safety (I-A) | IMS_EMER_GPRS_EPS-SRVCC |  |
| 3262 | 825.7.1 | SRVCC support for IMS Emergency Calls |  | 322d? | 2008-09-18 A | 2009-12-10 A | 100% | 2008-09-18 | 2009-12-10 | 322d? | finish no earlier than 2009-12-10 | S2 | 2576h | 2576h | IMS_EMER_GPRS_EPS-SRVCC | PCG-21 | China Mobile | Yu Qing (Yuqing@chinamobile.com) | Rel-9 | SP-41 | Maurice | Public Safety (I-A) |  |  |
| 3263 | 825.7.2 | **CT aspects of SRVCC support for IMS Emergency Calls** |  | 1330d? | 2009-05-29 A | 2014-06-13 A | 100% | 2009-05-29 | 2014-06-13 | 1330d? |  | C1; C4; C3; IETF | 49284h | 49284h | IMS_EMER_GPRS_EPS-SRVCC | PCG-24 | China Mobile | jiangyi@chinamobile.com | Rel-9 | CP-46 | Frederic | Public Safety (I-A) |  |  |
| 3264 | 825.7.2.1 | CT1 aspects of SRVCC support for IMS Emergency Calls |  | 137d? | 2009-05-29 A | 2009-12-04 A | 100% | 2009-05-29 | 2009-12-04 | 137d? | finish no earlier than 2009-12-04 | C1 | 1096h | 1096h | IMS_EMER_GPRS_EPS-SRVCC | PCG-23 | China Mobile | jiangyi@chinamobile.com | Rel-9 | CP-44 | Frederic | Public Safety (I-A) |  |  |
| 3265 | 825.7.2.2 | CT4 aspects of SRVCC support for IMS Emergency Calls |  | 137d? | 2009-05-29 A | 2009-12-04 A | 100% | 2009-05-29 | 2009-12-04 | 137d? | finish no earlier than 2009-12-04 | C4 | 1096h | 1096h | IMS_EMER_GPRS_EPS-SRVCC | PCG-23 | China Mobile | jiangyi@chinamobile.com | Rel-9 | CP-44 | Kimmo | Public Safety (I-A) |  |  |
| 3266 | 825.7.2.3 | CT3 aspects of SRVCC support for IMS Emergency Calls |  | 1d? | 2009-12-04 A | 2009-12-04 A | 100% | 2009-12-04 | 2009-12-04 | 1d? | finish no earlier than 2009-12-04 | C3 | 8h | 8h | IMS_EMER_GPRS_EPS-SRVCC | PCG-24 | China Mobile | jiangyi@chinamobile.com | Rel-9 | CP-46 | Kimmo | Public Safety (I-A) |  |  |
| 3267 | 825.7.2.4 | (IETF) CT3 aspects of SRVCC support for IMS Emergency Calls (RFC 7254) |  | 568d? | 2012-04-20 A | 2014-06-13 A | 100% | 2012-04-20 | 2014-06-13 | 568d? | finish no earlier than 2014-06-13 | C3-IETF | 4524h | 4524h | IMS_EMER_GPRS_EPS-SRVCC | PCG-29 | Andrew Allen | Andrew Allen | Rel-9 | CP-56 | Adrian | Public Safety (I-A) |  |  |
| 3268 | 826 | **LCS for LTE and EPS** |  | 981d? | 2008-06-05 A | 2012-03-02 A | 100% | 2008-06-05 | 2012-03-02 | 981d? |  | S2; C1; C4; R2; R1; R3; R4; R5 | 83592h | 83592h | LCS_LTE_EPS | PCG-22 |  |  | Rel-9 | SP-43 | Maurice | Public Safety (I-A) | LCS_LTE_EPS |  |
| 3269 | 826.1 | **LCS Control Plane Solution for EPS** |  | 468d? | 2008-06-05 A | 2010-03-19 A | 100% | 2008-06-05 | 2010-03-19 | 468d? |  | S2; C4; C1 | 16712h | 16712h | LCS_EPS-CPS | PCG-21 | Polaris Wireless | Robert Gross (rgross@polariswireless.com) | Rel-9 | SP-40 | Maurice | Public Safety (I-A) | LCS_EPS-CPS |  |
| 3270 | 826.1.1 | Stage 2 for LCS Control Plane Solution for EPS |  | 261d? | 2008-06-05 A | 2009-06-04 A | 100% | 2008-06-05 | 2009-06-04 | 261d? | finish no earlier than 2009-06-04 | S2 | 2088h | 2088h | LCS_EPS-CPS | PCG-21 | Polaris Wireless | Robert Gross (rgross@polariswireless.com) | Rel-9 | SP-40 | Maurice | Public Safety (I-A) |  |  |
| 3271 | 826.1.2 | CT4 aspects of Control Plane LCS in the EPC |  | 212d? | 2009-05-29 A | 2010-03-19 A | 100% | 2009-05-29 | 2010-03-19 | 212d? | finish no earlier than 2010-03-19 | C4 | 1696h | 1696h | LCS_EPS-CPS | PCG-23 | Polaris Wireless | Robert Gross (rgross@polariswireless.com) | Rel-9 | CP-44 | Kimmo | Public Safety (I-A) |  |  |
| 3272 | 826.1.3 | CT1 aspects of Control Plane LCS in the EPC |  | 212d? | 2009-05-29 A | 2010-03-19 A | 100% | 2009-05-29 | 2010-03-19 | 212d? | finish no earlier than 2010-03-19 | C1 | 1696h | 1696h | LCS_EPS-CPS | PCG-23 | Polaris Wireless | Robert Gross (rgross@polariswireless.com) | Rel-9 | CP-44 | Frederic | Public Safety (I-A) |  |  |
| 3273 | 826.2 | Positioning Support for LTE | milestone | 0d? | 2008-12-05 A | 2008-12-05 A | 100% | 2008-12-05 | 2010-06-04 | 392d? | finish no earlier than 2010-06-04 | R2; R1; R3; R4 |  |  | LCS_LTE | PCG-22 | Qualcomm | Nathan Tenny (ntenny@qualcomm.com) | Rel-9 | RP-42 | Yong-Jun | Public Safety (I-A) | LCS_LTE | RP-100442 |
| 3274 | 826.3 | Conformance Test Aspects – Positioning Support for LTE |  | 512d? | 2010-03-19 A | 2012-03-02 A | 100% | 2010-03-19 | 2012-03-02 | 512d? | finish no earlier than 2012-03-02 | R5 | 4096h | 4096h | LCS_LTE_UEConTest | PCG-24 | Qualcomm | Shubhang Vora (svoral@qualcomm.com) | Rel-9 | RP-47 | Ingbert | Public Safety (I-A) | LCS_LTE_UEConTest | RP-120034 |
| 3275 | 827 | **MBMS support in EPS** |  | 921d? | 2008-06-05 A | 2011-12-09 A | 100% | 2008-06-05 | 2011-12-09 | 921d? |  | S2; S3; S5; C3; C4; R2; R3; R4; R5 | 82896h | 82896h | MBMS_EPS | PCG-21 | China Mobile | Liu Hong (liuhongyfw@chinamobile.com) | Rel-9 | SP-40 | Maurice |  | MBMS_EPS |  |
| 3276 | 827.1 | Stage 2 for MBMS support in EPS |  | 261d? | 2008-06-05 A | 2009-06-04 A | 100% | 2008-06-05 | 2009-06-04 | 261d? | finish no earlier than 2009-06-04 | S2 | 2088h | 2088h | MBMS_EPS | PCG-21 | China Mobile | Liu Hong (liuhongyfw@chinamobile.com) | Rel-9 | SP-40 | Maurice |  |  |  |
| 3277 | 827.2 | Security for MBMS support in EPS |  | 261d? | 2008-12-11 A | 2009-12-10 A | 100% | 2008-12-11 | 2009-12-10 | 261d? | finish no earlier than 2009-12-10 | S3 | 2088h | 2088h | MBMS_EPS | PCG-22 | China Mobile | Liu Hong (liuhongyfw@chinamobile.com) | Rel-9 | SP-42 | Mirko |  |  |  |
| 3278 | 827.3 | MBMS Charging in EPS |  | 201d? | 2009-03-06 A | 2009-12-10 A | 100% | 2009-03-06 | 2009-12-10 | 201d? | finish no earlier than 2009-12-10 | S5 | 1600h | 1600h | MBMS_EPS | PCG-22 | ZTE | guo.wenjie1@zte.com.cn | Rel-9 | SP-43 | Mirko |  |  |  |
| 3279 | 827.4 | CT4 aspects of MBMS support in EPS (Stage 3) |  | 137d? | 2009-05-29 A | 2009-12-04 A | 100% | 2009-05-29 | 2009-12-04 | 137d? | finish no earlier than 2009-12-04 | C4 | 1096h | 1096h | MBMS_EPS | PCG-23 | China Mobile, ZTE | wangjingyf@chinamobile.com, lu.fei1@zte.com.cn | Rel-9 | CP-44 | Kimmo |  |  |  |
| 3280 | 827.5 | CT3 aspects of MBMS support in EPS (Stage 3) |  | 137d? | 2009-05-29 A | 2009-12-04 A | 100% | 2009-05-29 | 2009-12-04 | 137d? | start no earlier than 2009-05-29 | C3 | 1096h | 1096h | MBMS_EPS | PCG-23 | ZTE, China Mobile | zhou.xiaoyun@zte.com.cn, wangjingyf@chinamobile.com | Rel-9 | CP-44 | Adrian |  |  |  |
| 3281 | 827.6 | MBMS support in LTE |  | 272d? | 2009-03-06 A | 2010-03-19 A | 100% | 2009-03-06 | 2010-03-19 | 272d? | finish no earlier than 2010-03-19 | R2; R3; R4 | 6528h | 6528h | MBMS_LTE | PCG-22 | Huawei | arnaud.meylan@huawei.com | Rel-9 | RP-43 | Yong-Jun |  | MBMS_LTE | RP-100033 |
| 3282 | 827.7 | Conformance Test Aspects – MBMS support in LTE |  | 262d? | 2010-12-10 A | 2011-12-09 A | 100% | 2010-12-10 | 2011-12-09 | 262d? | finish no earlier than 2011-12-09 | R5 | 2088h | 2088h | MBMS_LTE-UEConTest | PCG-26 | Huawei | Zhang Xin (zhangxin0208@huawei.com) | Rel-9 | RP-50 | Ingbert |  | MBMS_LTE-UEConTest | RP-111437 |
| 3283 | 828 | **Access Network Discovery and Selection Function enhancements** |  | 333d? | 2008-12-11 A | 2010-03-19 A | 100% | 2008-12-11 | 2010-03-19 | 333d? |  | S2; C1 | 7384h | 7384h | eANDSF | PCG-22 | Motorola | Apostolis Salkintzis (salki@motorola.com) | Rel-9 | SP-42 | Maurice |  | eANDSF |  |
| 3284 | 828.1 | Stage 2 for Access Network Discovery and Selection Function enhancements |  | 126d? | 2008-12-11 A | 2009-06-04 A | 100% | 2008-12-11 | 2009-06-04 | 126d? | finish no earlier than 2009-06-04 | S2 | 1008h | 1008h | eANDSF | PCG-22 | Motorola | Apostolis Salkintzis (salki@motorola.com) | Rel-9 | SP-42 | Maurice |  |  |  |
| 3285 | 828.2 | CT1 aspects of Access Network Discovery and Selection Function enhancements |  | 131d? | 2009-09-18 A | 2010-03-19 A | 100% | 2009-09-18 | 2010-03-19 | 131d? | finish no earlier than 2010-03-19 | C1 | 1048h | 1048h | eANDSF | PCG-23 | Panasonic | benjamin.limck@sg.panasonic.com | Rel-9 | CP-45 | Frederic |  |  |  |

Notes:
- 3261: CP#56 added IETF dependency
- 3262: SP#46 completed / Impacted TSs and TRs: 23.870, 23.216, 23.237
- 3263: CP#46 completed
- 3264: CP#46 completed / Impacted TSs and TRs: 24.229, 24.237
- 3265: CP#46 completed / Impacted TSs and TRs: 29.205, 29.280
- 3266: CP#46 completed / Impacted TSs and TRs: 29.163
- 3267: CP#64 completed / Impacted TSs and TRs: RFC 7254 (was draft-montemurro-gsma-imei-urn)
- 3268: - / Impacted TSs and TRs: LTE
- 3269: Triggered by abandoned Study UID_380068 (FS_LCS_EPS). Linked to Feature UID_380064 Support for IMS Emergency Calls over GPRS and EPS
- 3270: SP#44 completed / Impacted TSs and TRs: 23.891, 23.271, 23.401, 23.402
- 3271: CP#47 completed (IANA registrations outstanding). Stage 3 SLs and SLg interfaces & transport of positioning messages between E-SMLC and MME in the scope of UID_420006 (Positioning Support for LTE) / Impacted TSs and TRs: 24.080, 29.002, 29.272, 29.230, new 24.171, 29.171, 29.172, 29.173
- 3272: CP#47 completed / Impacted TSs and TRs: 24.301
- 3273: RP#48 completed. UID_400038 (LCS Control Plane Solution for EPS) depends on this WI / Impacted TSs and TRs: 34.213, 36.133, 36.211, 36.214, 36.300, 36.305, 36.331, 36.355, 36.410, 36.413, 36.455, new 36.171
- 3274: RP#55 completed. RP#56 TS 37.571-4 v200 for Approval / Impacted TSs and TRs: 36.508, 36.509, new (37.571-1, 37.571-2, 37.571-3, 37.571-4, 37.571-5)
- 3275: RP#47 completed. SP#46, CP#46 completed / Impacted TSs and TRs: LTE
- 3276: SP#44 completed / Impacted TSs and TRs: 23.246
- 3277: SP#46 completed / Impacted TSs and TRs: 33.246
- 3278: SP#46 completed / Impacted TSs and TRs: 32.273, 32.251, 32.298, 32.299
- 3279: CP#46 completed / Impacted TSs and TRs: 29.274, 29.281, 23.007, 23.008
- 3280: CP#46 completed / Impacted TSs and TRs: 29.061
- 3281: RP#47 completed / Impacted TSs and TRs: 25.446, 36.101, 36.104, 36.141, 36.300, 36.304, 36.321, 36.322, 36.323, 36.331, 36.440, 36.441, 36.442, 36.444, 36.445
- 3282: RP#54 completed / Impacted TSs and TRs: 36.508, 36.521-1, 36.521-2, 36.523-1, 36.523-2, 36.523-3
- 3283: CP#47 completed. No new Rel-9 use cases defined. Implement service requirements not covered in Rel-8 / Impacted TSs and TRs: 22.278, SA3 33.402 CR#0055
- 3284: SP#44 completed / Impacted TSs and TRs: 23.402, 23.002
- 3285: CP#47 completed / Impacted TSs and TRs: 24.302, 24.312

| ID | WBS | Task | Duration | Start | Finish | Complete | Baseline start | Baseline finish | Baseline duration | Constraint | Resources | Work | Actual work | Acronym | PCG approved | WI rapporteur name | WI rapporteur e-mail | Release | TSG approved | MCC resp | Acronym_3GU_Export | Impacted TSs and TRs | Status Report |
| --- | --- | --- | --- | --- | --- | --- | --- | --- | --- | --- | --- | --- | --- | --- | --- | --- | --- | --- | --- | --- | --- | --- | --- |
| 3286 | 829 | **Multiple PDN Connection to the Same APN for PMIP-based Interfaces** | 267d? | 2009-03-13 A | 2010-03-19 A | 100% | 2009-03-13 | 2010-03-19 | 267d? |  | S2; C4; C1 | 8392h | 8392h | MUPSAP | PCG-22 | Samsung | erik.guttman@partner.samsung.com | Rel-9 | SP-43 | Maurice | MUPSAP |  |  |
| 3287 | 829.1 | Stage 2 for Multiple PDN Connection to the Same APN for PMIP-based Interfaces | 61d? | 2009-03-13 A | 2009-06-04 A | 100% | 2009-03-13 | 2009-06-04 | 61d? | finish no earlier than 2009-06-04 | S2 | 488h | 488h | MUPSAP | PCG-22 | Samsung | erik.guttman@partner.samsung.com | Rel-9 | SP-43 | Maurice |  | 23.060, 23.203, 23.401, 23.402 |  |
| 3288 | 829.2 | CT4 aspects of Multiple PDN Connection to the Same APN for PMIP-based Interfaces | 56d? | 2009-09-18 A | 2009-12-04 A | 100% | 2009-09-18 | 2009-12-04 | 56d? | finish no earlier than 2009-12-04 | C4 | 448h | 448h | MUPSAP | PCG-23 | Samsung | Surjyakanta Mohapatra (surjya.kanta@samsung.com) | Rel-9 | CP-45 | Kimmo |  | 29.275, 23.008, 29.282 |  |
| 3289 | 829.3 | CT1 aspects of Multiple PDN Connection to the Same APN for PMIP-based Interfaces | 131d? | 2009-09-18 A | 2010-03-19 A | 100% | 2009-09-18 | 2010-03-19 | 131d? | finish no earlier than 2010-03-19 | C1 | 1048h | 1048h | MUPSAP | PCG-23 | Samsung | Surjyakanta Mohapatra (surjya.kanta@samsung.com) | Rel-9 | CP-45 | Frederic |  | 24.302 |  |
| 3290 | 830 | **System aspects of vocoder rate adaptation for LTE** | 1403.68d? | 2007-05-07 A | 2012-09-12 A | 100% | 2007-05-07 | 2012-09-12 | 1403.68d? |  | S2; S4; C1; C3; R2; IETF | 108798h | 108798h | LTEimp-Vocoder | PCG-23 | Qualcomm | AC Mahendran (ac@qualcomm.com) | Rel-9 | SP-45 | Maurice | LTEimp-Vocoder | LTE |  |
| 3291 | 830.1 | SA2 system aspects of vocoder rate adaptation for LTE | 81d? | 2009-06-04 A | 2009-09-24 A | 100% | 2009-06-04 | 2009-09-24 | 81d? | start no earlier than 2009-06-04 | S2 | 648h | 648h | LTEimp-Vocoder | PCG-23 | Qualcomm | AC Mahendran (ac@qualcomm.com) | Rel-9 | SP-45 | Maurice |  | 23.401 CR#1103r3 |  |
| 3292 | 830.2 | SA4 system aspects of vocoder rate adaptation for LTE | 136d? | 2009-06-04 A | 2009-12-10 A | 100% | 2009-06-04 | 2009-12-10 | 136d? | finish no earlier than 2009-12-07 | S4 | 1088h | 1088h | LTEimp-Vocoder | PCG-23 | Qualcomm | Nikolai Leung | Rel-9 | SP-45 | Paolo |  | 26.114 |  |
| 3293 | 830.3 | Vocoder rate adaptation for LTE | 81d? | 2009-05-30 A | 2009-09-18 A | 100% | 2009-05-30 | 2009-09-18 | 81d? | finish no earlier than 2009-09-18 | R2 | 648h | 648h | LTEimp-Vocoder | PCG-23 | Alcatel-Lucent | Sudeep Palat (spalat@alcatel-lucent.com) | Rel-9 | RP-44 | Yong-Jun |  | 36.300 CR#0114 | RP-090704 |
| 3294 | 830.4 | (IETF) SA4 system aspects of vocoder rate adaptation for LTE | 677.6d? | 2009-06-04 A | 2012-09-12 A | 100% | 2009-06-04 | 2012-09-12 | 677.6d? | finish no earlier than 2012-09-14 | S4-IETF | 5420.8h | 5420.8h | LTEimp-Vocoder | PCG-27 | Lionel Morand |  | Rel-9 | SP-52 | Paolo |  | RFC 6679 (was draft-ietf-avtcore-ecn-for-rtp) |  |
| 3295 | 830.5 | (IETF) CT aspects of vocoder rate adaptation for LTE | 1400.68d? | 2007-05-07 A | 2012-09-07 A | 100% | 2007-05-07 | 2012-09-07 | 1400.68d? | finish no earlier than 2012-09-07 | C1-IETF; C3-IETF; C4-IETF | 33616.3h | 33616.3h | LTEimp-Vocoder | PCG-27 | Lionel Morand |  | Rel-9 | CP-52 | Frederic |  | RFC 6679 (was draft-ietf-avtcore-ecn-for-rtp) |  |
| 3296 | 831 | Access Security Enhancements | 505d? | 2007-07-02 A | 2009-06-04 A | 100% | 2007-07-02 | 2009-06-04 | 505d? | finish no earlier than 2009-06-03 | S3 | 4040h | 4040h | ACCSEC2 |  | Ericsson | Bengt.Sahlin@ericsson.com | Rel-9 | SP-26 | Mirko | ACCSEC2 | 33.102, 43.020 |  |
| 3297 | 832 | **Protection against Unsolicited Communication for IMS (PUCI)** | 322d? | 2008-09-18 A | 2009-12-10 A | 100% | 2008-09-18 | 2009-12-10 | 322d? |  | S3; S1 | 8216h | 8216h | PUCI | PCG-21 | NEC | Anand R. Prasad (anand@bq.jp.nec.com) | Rel-9 | SP-41 | Alain | PUCI |  |  |
| 3298 | 832.1 | Stage 1 for PUCI | 61d? | 2008-09-18 A | 2008-12-11 A | 100% | 2008-09-18 | 2008-12-11 | 61d? | finish no earlier than 2009-06-18 | S1 | 488h | 488h | PUCI | PCG-21 | NEC | Anand R. Prasad (anand@bq.jp.nec.com) | Rel-9 | SP-41 | Alain |  | 22.228 |  |
| 3299 | 832.2 | SA3 work on PUCI | 322d? | 2008-09-18 A | 2009-12-10 A | 100% | 2008-09-18 | 2009-12-10 | 322d? | finish no earlier than 2009-12-10 | S3 | 2576h | 2576h | PUCI | PCG-21 | NEC | Anand R. Prasad (anand@bq.jp.nec.com) | Rel-9 | SP-41 | Mirko |  | New 33.937 |  |
| 3300 | 833 | **IMS Media Plane Security** | 922d? | 2009-03-13 A | 2012-09-14 A | 100% | 2009-03-13 | 2012-09-14 | 922d? |  | S3; C1; C4; C3; IETF | 67928h | 67928h | MEDIASEC | PCG-22 | Vodafone | Peter.Howard@vodafone.com | Rel-9 | SP-43 | Mirko | MEDIASEC |  |  |
| 3301 | 833.1 | SA3 aspects of IMS Media Plane Security | 271d? | 2009-03-13 A | 2010-03-25 A | 100% | 2009-03-13 | 2010-03-25 | 271d? | finish no earlier than 2010-03-25 | S3 | 2168h | 2168h | MEDIASEC | PCG-22 | Vodafone | Peter.Howard@vodafone.com | Rel-9 | SP-43 | Mirko |  | New 33.828, 33.328 |  |
| 3302 | 833.2 | (IETF) SA3, CT1, CT3 aspects of IMS Media Plane Security | 919d? | 2009-03-18 A | 2012-09-14 A | 100% | 2009-03-18 | 2012-09-14 | 919d? | finish no earlier than 2012-09-14 | S3-IETF; C1-IETF; C3-IETF | 22056h | 22056h | MEDIASEC | PCG-27 | Peter Dawes |  | Rel-9 | SP-52 | Mirko |  | draft-dawes-dispatch-mediasec-parameter |  |
| 3303 | 833.3 | **CN aspects of IMS Media Plane Security** | 186d? | 2009-09-18 A | 2010-06-04 A | 100% | 2009-09-18 | 2010-06-04 | 186d? |  | C1; C4; C3 | 6824h | 6824h | MEDIASEC_CORE | PCG-23 | Vodafone | peter.dawes@vodafone.com | Rel-9 | CP-45 | Frederic | MEDIASEC_CORE |  |  |
| 3304 | 833.3.1 | CT1 aspects of IMS Media Plane Security | 33d? | 2009-09-18 A | 2010-03-19 A | 100% | 2009-09-18 | 2010-03-19 | 33d? | finish no earlier than 2010-03-19 | C1 | 264h | 264h | MEDIASEC_CORE | PCG-23 | Vodafone | peter.dawes@vodafone.com | Rel-9 | CP-45 | Frederic |  | 23.218, 24.229 |  |
| 3305 | 833.3.2 | CT4 aspects of IMS Media Plane Security | 131d? | 2009-09-18 A | 2010-03-19 A | 100% | 2009-09-18 | 2010-03-19 | 131d? | finish no earlier than 2010-03-19 | C4 | 1048h | 1048h | MEDIASEC_CORE | PCG-23 | Vodafone | peter.dawes@vodafone.com | Rel-9 | CP-45 | Kimmo |  | 29.238, 23.334, 29.334 |  |
| 3306 | 833.3.3 | CT3 aspects of IMS Media Plane Security | 131d? | 2009-12-04 A | 2010-06-04 A | 100% | 2009-12-04 | 2010-06-04 | 131d? | finish no earlier than 2010-06-04 | C3 | 1048h | 1048h | MEDIASEC_CORE | PCG-24 | Vodafone | peter.dawes@vodafone.com | Rel-9 | CP-46 | Adrian |  | 29.162 |  |
| 3307 | 834 | **GBAPush enhancements (Generic push layer)** | 533d? | 2008-03-12 A | 2010-03-25 A | 100% | 2008-03-12 | 2010-03-25 | 533d? |  | S3 | 8528h | 8528h | eGBAPush | PCG-23 | Ericsson | Rolf Blom | Rel-9 | SP-44 | Mirko | eGBAPush | New 33.224 |  |
| 3308 | 834.1 | SA3 part of eGBAPush (Generic push layer) | 533d? | 2008-03-12 A | 2010-03-25 A | 100% | 2008-03-12 | 2010-03-25 | 533d? | finish no earlier than 2010-03-25 | S3 | 4264h | 4264h | eGBAPush | PCG-21 | Ericsson | Rolf Blom | Rel-9 | SP-39 | Mirko |  | New 33.224 |  |
| 3309 | 835 | Extended Identity Management | 136d? | 2009-06-04 A | 2009-12-10 A | 100% | 2009-06-04 | 2009-12-10 | 136d? | finish no earlier than 2009-12-10 | S3 | 1088h | 1088h | GBA-IdM | PCG-23 | Nokia | Silke.Holtmanns@nokia.com | Rel-9 | SP-44 | Mirko | GBA-IdM | New 33.924, CT4 29.109 (added service code) |  |

Notes:
- 3286: CP#47 completed. Continues Rel-8 SAES Stage 2 UID_320005. Stage 1 in 22.278 (EPS Service requirements)
- 3287: SP#44 completed
- 3288: CP#46 completed
- 3289: CP#47 completed
- 3290: Triggered by RAN2 UID_440013 Vocoder rate adaptation for LTE
- 3291: SP#45 completed (CR adding support for Explicit Congestion Notification)
- 3292: SP#46 completed
- 3293: RP#45 completed
- 3294: SP#57 completed
- 3295: CP#57 completed
- 3296: SP#44 completed. Stopped TR 33.801. CRs 33.102,43.020 on A5/2 removal done long time ago. A5/4 introduction CRs will be done under UID_440057 128 bit encryption for GSM and GPRS. SP#26 approved WID (improved GERAN security)
- 3297: SP#46 TR 33.937 completed but no specification work done in Rel-9. Related work in OMA Categorization Based Content Screening
- 3298: SP#42 completed
- 3299: SP#46 completed. No normative work done in Rel-9
- 3300: -
- 3301: SP#47 completed
- 3302: CP#57 completed, ietf-draft discontinued, documented within 3GPP
- 3303: CP#48 completed
- 3304: CP#47 completed
- 3305: CP#47 completed
- 3306: CP#48 completed
- 3307: SP#43 umbrella to host 33.224, moved from Rel-8 to Rel-9. SP#47 completed
- 3308: SP#47 completed
- 3309: SP#46 completed. Stage 1 not identified (GBA Liberty Interworking has been outlined and GBAOpenID interworking is analogous)

| ID | WBS | Task | Duration | Start | Finish | Complete | Baseline start | Baseline finish | Baseline duration | Constraint | Resources | Work | Actual work | Acronym | PCG approved | WI rapporteur name | Release | TSG approved | MCC resp | Acronym_3GU_Export | PCG stopped | TSG stopped |
| --- | --- | --- | --- | --- | --- | --- | --- | --- | --- | --- | --- | --- | --- | --- | --- | --- | --- | --- | --- | --- | --- | --- |
| 3310 | 836 | **Network Domain Security (NDS) enhancements to support backhaul security** | 924d? | 2009-06-04 A | 2012-12-07 A | 100% | 2009-06-04 | 2012-12-07 | 924d? |  | S3; IETF | 23452.8h | 23452.8h | NDS_Backhaul | PCG-23 | Vodafone | Rel-9 | SP-44 | Mirko | NDS_Backhaul |  |  |
| 3311 | 836.1 | SA3 part of Network Domain Security (NDS) enhancements to support backhaul security | 211d? | 2009-06-04 A | 2010-03-25 A | 100% | 2009-06-04 | 2010-03-25 | 211d? | finish no earlier than 2010-03-25 | S3 | 1688h | 1688h | NDS_Backhaul | PCG-23 | Vodafone | Rel-9 | SP-44 | Mirko |  |  |  |
| 3312 | 836.2 | (IETF) SA3 part of Network Domain Security (NDS) enhancements to support backhaul security | 740.6d? | 2009-06-04 A | 2012-12-07 A | 100% | 2009-06-04 | 2012-12-07 | 740.6d? | finish no earlier than 2012-12-07 | S3-IETF | 5924.8h | 5924.8h | NDS_Backhaul | PCG-27 | Bengt Sahlin | Rel-9 | SP-52 | Mirko |  |  |  |
| 3313 | 836.3 | Deleted - CT4 part of Network Domain Security (NDS) enhancements to support backhaul security | 132d? | 2009-06-04 A | 2009-12-04 A | 100% | 2009-06-04 | 2009-12-04 | 132d? | finish no earlier than 2009-12-04 | C4 | 1056h | 1056h | NDS_Backhaul | PCG-23 | Vodafone | Rel-9 | SP-44 | Kimmo |  | PCG-24 | CP-46 |
| 3314 | 837 | **128 bit encryption for GSM and GPRS** | 136d? | 2009-06-04 A | 2009-12-10 A | 100% | 2009-06-04 | 2009-12-10 | 136d? |  | S3; C1; C4; G2; G3new | 10392h | 10392h | A5/4-GEA4 | PCG-23 | Ericsson | Rel-9 | SP-44 | Mirko | A5/4-GEA4 |  |  |
| 3315 | 837.1 | SA3 part of 128 bit encryption for GSM and GPRS | 136d? | 2009-06-04 A | 2009-12-10 A | 100% | 2009-06-04 | 2009-12-10 | 136d? | finish no earlier than 2010-01-06 | S3 | 1088h | 1088h | A5/4-GEA4 | PCG-23 | Ericsson | Rel-9 | SP-44 | Mirko |  |  |  |
| 3316 | 837.2 | CT1 part of 128 bit encryption for GSM and GPRS | 77d? | 2009-06-04 A | 2009-09-18 A | 100% | 2009-06-04 | 2009-09-18 | 77d? | start no earlier than 2009-06-04 | C1 | 616h | 616h | A5/4-GEA4 | PCG-23 | Ericsson | Rel-9 | SP-44 | Frederic |  |  |  |
| 3317 | 837.3 | CT4 part of 128 bit encryption for GSM and GPRS | 136d? | 2009-06-04 A | 2009-12-10 A | 100% | 2009-06-04 | 2009-12-10 | 136d? | start no earlier than 2009-06-04 | C4 | 1088h | 1088h | A5/4-GEA4 | PCG-23 | Ericsson | Rel-9 | SP-44 | Kimmo |  |  |  |
| 3318 | 837.4 | GERAN2 part of 128 bit encryption for GSM and GPRS | 67d? | 2009-06-04 A | 2009-09-04 A | 100% | 2009-06-04 | 2009-09-04 | 67d? | finish no earlier than 2009-09-04 | G2 | 536h | 536h | A5/4-GEA4 | PCG-23 | Ericsson | Rel-9 | SP-44 | Gert |  |  |  |
| 3319 | 837.5 | GERAN3new (testing) part of 128 bit encryption for GSM and GPRS | 122d? | 2009-06-04 A | 2009-11-20 A | 100% | 2009-06-04 | 2009-11-20 | 122d? | finish no earlier than 2009-11-20 | G3new | 976h | 976h | A5/4-GEA4 | PCG-23 | Ericsson | Rel-9 | SP-44 | Ingbert |  |  |  |
| 3320 | 837.6 | Deleted - SA2 part of 128 bit encryption for GSM and GPRS | 81d? | 2009-06-04 A | 2009-09-24 A | 100% | 2009-06-04 | 2009-09-24 | 81d? | finish no earlier than 2009-09-24 | S2 | 648h | 648h | A5/4-GEA4 | PCG-23 | Ericsson | Rel-9 | SP-44 | Maurice |  | PCG-23 | SP-45 |
| 3321 | 838 | Timed Graphics | 337d? | 2008-12-11 A | 2010-03-25 A | 100% | 2008-12-11 | 2010-03-25 | 337d? | finish no earlier than 2010-03-25 | S4 | 2696h | 2696h | TG | PCG-22 | Ericsson | Rel-9 | SP-42 | Paolo | TG |  |  |
| 3322 | 839 | Managing MTSI Media Adaptation | 197d? | 2009-03-12 A | 2009-12-10 A | 100% | 2009-03-12 | 2009-12-10 | 197d? | finish no earlier than 2009-12-10 | S4 | 1568h | 1568h | M3A | PCG-22 | Samsung | Rel-9 | SP-43 | Paolo | M3A |  |  |
| 3323 | 840 | **PSS and MBMS Aspects** | 272d? | 2009-03-12 A | 2010-03-25 A | 100% | 2009-03-12 | 2010-03-25 | 272d? |  | S4 | 6512h | 6512h | PMA | PCG-23 | Ericsson, Nokia | Rel-9 | SP-44 | Paolo | PMA |  |  |
| 3324 | 840.1 | PSS and MBMS extensions | 271d? | 2009-03-12 A | 2010-03-25 A | 100% | 2009-03-12 | 2010-03-25 | 271d? | finish no earlier than 2010-03-25 | S4 | 2168h | 2168h | PMA-MBS_Ext | PCG-22 | Ericsson | Rel-9 | SP-43 | Paolo | PMA-MBS_Ext |  |  |
| 3325 | 840.2 | Improved Video Support for PSS and MBMS | 271d? | 2009-03-12 A | 2010-03-25 A | 100% | 2009-03-12 | 2010-03-25 | 271d? | finish no earlier than 2010-03-25 | S4 | 2168h | 2168h | PMA-IVS | PCG-22 | Nokia | Rel-9 | SP-43 | Paolo | PMA-IVS |  |  |
| 3326 | 841 | IMS based PSS and MBMS User Service extensions | 197d? | 2009-03-12 A | 2009-12-10 A | 100% | 2009-03-12 | 2009-12-10 | 197d? | finish no earlier than 2009-12-10 | S4 | 1576h | 1576h | IMS_PSS_MBMS_US_EXT | PCG-22 | Ericsson | Rel-9 | SP-43 | Paolo | IMS_PSS_MBMS_US_EXT |  |  |
| 3327 | 842 | Syndicated Feed Reception within 3GPP environments | 136d? | 2009-06-04 A | 2009-12-10 A | 100% | 2009-06-04 | 2009-12-10 | 136d? | start no earlier than 2009-06-04 | S4 | 1088h | 1088h | SFR | PCG-23 | Ericsson | Rel-9 | SP-44 | Paolo | SFR |  |  |
| 3328 | 843 | Distortion Measurement Test Methods and Requirements | 131d? | 2009-09-24 A | 2010-03-25 A | 100% | 2009-09-24 | 2010-03-25 | 131d? | finish no earlier than 2010-03-25 | S4 | 1048h | 1048h | DTMR | PCG-23 | Motorola | Rel-9 | SP-45 | Paolo | DTMR |  |  |
| 3329 | 844 | **Rel-9 Operations, Administration, Maintenance and Provisioning (OAM&P)** | 601d? | 2008-02-22 A | 2010-06-10 A | 100% | 2008-02-22 | 2010-06-10 | 601d? |  | S5 | 36890.4h | 36890.4h | OAM9 | PCG-22 |  | Rel-9 | SP-42 | Mirko | OAM9 |  |  |
| 3330 | 844.1 | **Rel-9 Network Infrastructure Management** | 337d? | 2008-12-11 A | 2010-03-25 A | 100% | 2008-12-11 | 2010-03-25 | 337d? |  | S5 | 8760h | 8760h | OAM9-NIM | PCG-22 |  | Rel-9 | SP-42 | Mirko | OAM9-NIM |  |  |
| 3331 | 844.1.1 | Software Management for Network Elements | 336d? | 2008-12-11 A | 2010-03-25 A | 100% | 2008-12-11 | 2010-03-25 | 336d? | finish no earlier than 2010-03-25 | S5 | 2688h | 2688h | OAM9-NE_SWM | PCG-22 | Huawei, Nokia Siemens Networks | Rel-9 | SP-42 | Mirko | OAM9-NE_SWM |  |  |
| 3332 | 844.1.2 | Service Oriented Architecture (SOA) for IRP | 211d? | 2009-06-04 A | 2010-03-25 A | 100% | 2009-06-04 | 2010-03-25 | 211d? | finish no earlier than 2010-03-25 | S5 | 1688h | 1688h |  | PCG-23 | Ericsson, Nokia Siemens Networks | Rel-9 | SP-44 | Mirko |  |  |  |
| 3333 | 844.1.3 | IRP SOAP Solution Sets continuation from Rel-8 | 211d? | 2009-06-04 A | 2010-03-25 A | 100% | 2009-06-04 | 2010-03-25 | 211d? | finish no earlier than 2010-03-25 | S5 | 1688h | 1688h |  | PCG-23 | Ericsson | Rel-9 | SP-44 | Mirko |  |  |  |

Notes:
- 3310: Continuation of Rel-8 UID_390044 SAE security architecture. Covers gaps in backhaul security in SAE (also applicable to UTRAN and GERAN backhaul) / WI rapporteur e-mail: Peter.Howard@vodafone.com
- 3311: SP#47 completed / Impacted TSs and TRs: 33.102, 33.210, 33.310, 33.401, 33.402 / WI rapporteur e-mail: Peter.Howard@vodafone.com
- 3312: CP#58 completed / Impacted TSs and TRs: RFC 6712 (was draft-ietf-pkix-cmp-transport-protocols)
- 3313: CP#46 completed. No impact on CT4 specs / WI rapporteur e-mail: Peter.Howard@vodafone.com
- 3314: Allow 128 as an alternative to 64 bit keys (Stage 2/3 + Test spec) / WI rapporteur e-mail: Karl Norrman
- 3315: SP#46 completed / Impacted TSs and TRs: 33.102,43.020, New 55.226 / WI rapporteur e-mail: Karl Norrman
- 3316: CP#45 completed / Impacted TSs and TRs: 24.008,44.064 / WI rapporteur e-mail: Karl Norrman
- 3317: CP#46 completed. Kc128 enhancements are carried as UMTS keys => no impact on CT4 29.002, 29.060 / WI rapporteur e-mail: Karl Norrman
- 3318: GP#43 WID approved + completed / Impacted TSs and TRs: 44.018,48.008,48.018,48.058 / WI rapporteur e-mail: Karl Norrman
- 3319: GP#44 completed. GP#43 WID approved / Impacted TSs and TRs: 51.010 / WI rapporteur e-mail: Karl Norrman
- 3320: SP#45 work stopped/abandoned / Impacted TSs and TRs: 23.060 / WI rapporteur e-mail: Karl Norrman
- 3321: SP#47 completed. Provide graphics in parallel to a video stream (without requiring an umbrella scene descriptor such as 3GPP DIMS in TS 26.142) / Impacted TSs and TRs: 26.114, 26.140, 26.234, 26.244, 26.245, 26.346, New 26.430 / WI rapporteur e-mail: clinton.priddle@ericsson.com
- 3322: SP#46 completed. Work extending Rel-8 UID_34041 MTSI Video - Dynamic Rate Adaptation/Signalling of Image Size. Update speech/video adaptation algorithms used by network to control MTSI client terminal in congestion or poor transmission conditions. / Impacted TSs and TRs: 26.114 / WI rapporteur e-mail: kyunghun.jung@samsung.com
- 3323: Umbrella WI / WI rapporteur e-mail: Clinton.Priddle@ericsson.com, imed.bouazizi@nokia.com
- 3324: SP#47 completed. Extends Rel-8 UID_34043 (PSS_MBMS_OMTV) & ensures compatibility with UID_34046 (IMS_PSS_MBMS_US) / Impacted TSs and TRs: 26.234, 26.346 / WI rapporteur e-mail: Clinton.Priddle@ericsson.com
- 3325: SP#47 completed / Impacted TSs and TRs: 26.234, 26.244, 26.346, new 26.903 / WI rapporteur e-mail: imed.bouazizi@nokia.com
- 3326: SP#46 completed. Work extending Rel-8 UID_34046 (IMS_PSS_MBMS_US), SA2 UID_410034 IMSSCC-SPI (IMS Service Continuity Enhancements: Service, Policy and Interactions) / Impacted TSs and TRs: 26.237 / WI rapporteur e-mail: Markus Kampmann
- 3327: SP#46 completed. TS 26.150v100 for Approval. RSS optimized for mobile use. Reuse/reference OMA's enabler DCD. / Impacted TSs and TRs: New 26.150 / WI rapporteur e-mail: Thorsten.Lohmar@ericsson.com
- 3328: SP#47 completed / Impacted TSs and TRs: 26.131, 26.132 / WI rapporteur e-mail: Stephen Kendall (wcsk01@motorola.com)
- 3329: OAM9 is an umbrella Feature also for OAM&P related TEI9 type of changes that are not part of any other dedicated feature/WI / Impacted TSs and TRs: TR 30.819
- 3330: SP#42 umbrella BB created to host OAM WIs
- 3331: SP#47 completed / Impacted TSs and TRs: 32.531, 32.532, 32.533, new 32.537 / WI rapporteur e-mail: Bidipta Das (bidipta@huawei.com), Clemens Suerbaum (clemens.suerbaum@nsn.com)
- 3332: SP#47 completed (covering SOA Architecture & SOA-supporting Solution Set). Triggered by UID_400029 Study on Service Oriented Architecture (SOA) for IRP (TR 32.824) / Impacted TSs and TRs: 32.101, 32.102, 32.150 / WI rapporteur e-mail: edwin.tse@ericsson.com, Jörg Schmidt (joerg@cox.net)
- 3333: SP#47 completed. Continuation of Rel-8 UID_400030 IRP SOAP Solution Sets / Impacted TSs and TRs: New (32.127/ 327/ 337/ 357/ 387/ 397/ 447/ 397/ 447/ 507/ 537), 32.121,32.122,32.123,32,32.321,32.322,32.323,32.325,32.331,32.332,32.333,32.335,32.351,32.352,32.353,32.381,32.382,32.383,32.385,32.391,32.392,32.393,32.395,32.441,32.442,32.443 / WI rapporteur e-mail: John Power

| ID | WBS | Task | Duration | Start | Finish | Complete | Baseline start | Baseline finish | Baseline duration | Constraint | Resources | Work | Actual work | Acronym | PCG approved | Release | TSG approved | MCC resp | Acronym_3GU_Export | Impacted TSs and TRs | WI rapporteur name | Special Focus Doc | PCG stopped | TSG stopped |
| --- | --- | --- | --- | --- | --- | --- | --- | --- | --- | --- | --- | --- | --- | --- | --- | --- | --- | --- | --- | --- | --- | --- | --- | --- |
| 3334 | 844.2 | **Rel-9 Performance Management** | 327d? | 2009-03-12 A | 2010-06-10 A | 100% | 2009-03-12 | 2010-06-10 | 327d? |  | S5 | 7890.41h | 7890.41h | OAM9-PM | PCG-22 | Rel-9 | SP-42 | Mirko | OAM9-PM |  |  |  |  |  |
| 3335 | 844.2.1 | Enhancement of UTRAN Performance Measurements | 136d? | 2009-06-04 A | 2009-12-10 A | 100% | 2009-06-04 | 2009-12-10 | 136d? | start no earlier than 2009-06-04 | S5 | 1088h | 1088h |  | PCG-23 | Rel-9 | SP-44 | Mirko |  | 32.405 | China Mobile |  |  |  |
| 3336 | 844.2.2 | Enhancement of E-UTRAN Performance Measurements | 327d? | 2009-03-12 A | 2010-06-10 A | 100% | 2009-03-12 | 2010-06-10 | 327d? | finish no earlier than 2010-06-10 | S5 | 2616h | 2616h |  | PCG-22 | Rel-9 | SP-43 | Mirko |  | 32.425 | Motorola, Huawei |  |  |  |
| 3337 | 844.2.3 | Enhancement of EPC Performance Measurements | 197d? | 2009-03-12 A | 2009-12-10 A | 100% | 2009-03-12 | 2009-12-10 | 197d? | finish no earlier than 2010-03-25 | S5 | 1570.41h | 1570.41h |  | PCG-22 | Rel-9 | SP-43 | Mirko |  | 32.426 | China Mobile |  |  |  |
| 3338 | 844.3 | **Rel-9 Self-Organizing Networks (SON) - OAM aspects** | 601d? | 2008-02-22 A | 2010-06-10 A | 100% | 2008-02-22 | 2010-06-10 | 601d? |  | S5 | 11736h | 11736h | OAM9-SON | PCG-22 | Rel-9 | SP-43 | Mirko | OAM9-SON |  |  | SON |  |  |
| 3339 | 844.3.1 | SON self-optimization management (moved from Rel-8 LTE_SON-OAM) | 600d? | 2008-02-22 A | 2010-06-10 A | 100% | 2008-02-22 | 2010-06-10 | 600d? | finish no earlier than 2010-06-10 | S5 | 4800h | 4800h |  | PCG-21 | Rel-9 | SP-39 | Mirko |  | 32.425, new (32.521, 32.522, 32.523, 32.525) | Huawei | SON |  |  |
| 3340 | 844.3.2 | Automatic Radio Network Configuration Data Preparation | 266d? | 2009-06-04 A | 2010-06-10 A | 100% | 2009-06-04 | 2010-06-10 | 266d? | finish no earlier than 2010-06-10 | S5 | 2128h | 2128h |  | PCG-23 | Rel-9 | SP-44 | Mirko |  | 32.501, 32.502, 32.503, 32.505, new 32.507 | Nokia Siemens Networks | SON |  |  |
| 3341 | 844.4 | Rel-9 Subscription Management (SuM) evolution | 266d? | 2009-06-04 A | 2010-06-10 A | 100% | 2009-06-04 | 2010-06-10 | 266d? | finish no earlier than 2010-06-10 | S5 | 2128h | 2128h | OAM9-SuM | PCG-23 | Rel-9 | SP-44 | Mirko | OAM9-SuM | 32.140, 32.141, 32.152, 32.172, 32.175 | Ericsson |  |  |  |
| 3342 | 844.5 | Deleted - Rel-9 Trace | 196d? | 2009-03-13 A | 2009-12-10 A | 100% | 2009-03-13 | 2009-12-10 | 196d? | finish no earlier than 2009-12-10 | S5 | 1568h | 1568h | OAM9-Trace | PCG-22 | Rel-9 | SP-42 | Mirko | OAM9-Trace |  |  |  | PCG-24 | SP-46 |
| 3343 | 845 | Rel-9 Charging Management small Enhancements | 211d? | 2009-06-04 A | 2010-03-25 A | 100% | 2009-06-04 | 2010-03-25 | 211d? |  | S5 | 1688h | 1688h | CH9 | PCG-23 | Rel-9 | SP-44 | Mirko | CH9 | TR 30.819 |  |  |  |  |
| 3344 | 846 | **CS-IBCF and CS-TrGW definition in 3GPP specifications** | 472d? | 2008-05-30 A | 2010-03-19 A | 100% | 2008-05-30 | 2010-03-19 | 472d? |  | C3; C4 | 14490.3h | 14490.3h | CS-IBCF | PCG-21 | Rel-9 | CP-40 | Adrian | CS-IBCF |  | Telecom Italia |  |  |  |
| 3345 | 846.1 | CT3 aspects of CS-IBCF and CS-TrGW definition in 3GPP specifications | 472d? | 2008-05-30 A | 2010-03-19 A | 100% | 2008-05-30 | 2010-03-19 | 472d? | finish no earlier than 2009-12-04 | C3 | 3770.34h | 3770.34h | CS-IBCF | PCG-21 | Rel-9 | CP-40 | Adrian |  | 29.235 | Telecom Italia |  |  |  |
| 3346 | 846.2 | CT4 aspects of CS-IBCF and CS-TrGW definition in 3GPP specifications | 396d? | 2008-05-30 A | 2009-12-04 A | 100% | 2008-05-30 | 2009-12-04 | 396d? | finish no earlier than 2009-12-04 | C4 | 3168h | 3168h | CS-IBCF | PCG-21 | Rel-9 | CP-40 | Kimmo |  | 23.231, 29.232, new 29.238 | Telecom Italia |  |  |  |
| 3347 | 847 | **IMS – Interconnection Border Control Function (IBCF) – Transition Gateway (TrGW); Ix Interface; Stage 3** | 322d? | 2008-09-12 A | 2009-12-04 A | 100% | 2008-09-12 | 2009-12-04 | 322d? |  | C4; C3 | 10086.4h | 10086.4h | IMS_IBCF | PCG-21 | Rel-9 | CP-41 | Kimmo | IMS_IBCF |  | Alcatel-Lucent |  |  |  |
| 3348 | 847.1 | CT4 part of IMS – Interconnection Border Control Function (IBCF) – Transition Gateway (TrGW); Ix Interface; Stage 3 | 321d? | 2008-09-12 A | 2009-12-04 A | 100% | 2008-09-12 | 2009-12-04 | 321d? | finish no earlier than 2009-12-04 | C4 | 2568h | 2568h | IMS_IBCF | PCG-21 | Rel-9 | CP-41 | Kimmo |  | new 29.238 | Alcatel-Lucent |  |  |  |
| 3349 | 847.2 | CT3 part of IMS – Interconnection Border Control Function (IBCF) – Transition Gateway (TrGW); Ix Interface; Stage 3 | 295.8d? | 2008-09-12 A | 2009-12-04 A | 100% | 2008-09-12 | 2009-12-04 | 295.8d? | finish no earlier than 2010-03-19 | C3 | 2366.4h | 2366.4h | IMS_IBCF | PCG-21 | Rel-9 | CP-41 | Adrian |  | 29.162, 29.235 | Alcatel-Lucent |  |  |  |
| 3350 | 848 | IMS Application Level Gateway Control Function (ALGCF) – IMS Access Media Gateway (IMA-MGW); Iq Interface; Stage 2 and Stage 3 | 321d? | 2008-09-12 A | 2009-12-04 A | 100% | 2008-09-12 | 2009-12-04 | 321d? | finish no earlier than 2009-12-04 | C4 | 2568h | 2568h | IMS_AGCF | PCG-21 | Rel-9 | CP-41 | Kimmo | IMS_AGCF | New 23.334, 29.334 | Alcatel-Lucent |  |  |  |
| 3351 | 849 | **Enhancements of IMS Customized Alerting Tone (CAT) Service** | 392d? | 2008-12-05 A | 2010-06-04 A | 100% | 2008-12-05 | 2010-06-04 | 392d? |  | C1 | 5846.4h | 5846.4h | eCAT | PCG-22 | Rel-9 | CP-42 | Frederic | eCAT |  | China Mobile |  |  |  |
| 3352 | 849.1 | Stage 3 for Enhancements of IMS Customized Alerting Tone (CAT) Service | 391d? | 2008-12-05 A | 2010-06-04 A | 100% | 2008-12-05 | 2010-06-04 | 391d? | finish no earlier than 2010-06-04 | C1 | 3128h | 3128h | eCAT-SS | PCG-22 | Rel-9 | CP-42 | Frederic | eCAT-SS | 24.182 | China Mobile |  |  |  |
| 3353 | 850 | **Completion of IMS Restoration Procedures** | 212d? | 2009-05-29 A | 2010-03-19 A | 100% | 2009-05-29 | 2010-03-19 | 212d? |  | C3; C4; C1 | 10176h | 10176h | eIMS_RP | PCG-23 | Rel-9 | CP-44 | Kimmo | eIMS_RP |  | Ericsson |  |  |  |
| 3354 | 850.1 | CT4 aspects of Completion of IMS Restoration Procedures | 212d? | 2009-05-29 A | 2010-03-19 A | 100% | 2009-05-29 | 2010-03-19 | 212d? | finish no earlier than 2010-03-19 | C4 | 1696h | 1696h | eIMS_RP | PCG-23 | Rel-9 | CP-44 | Kimmo |  | 23.380, 23.820 | Ericsson |  |  |  |
| 3355 | 850.2 | CT1 aspects of Completion of IMS Restoration Procedures | 212d? | 2009-05-29 A | 2010-03-19 A | 100% | 2009-05-29 | 2010-03-19 | 212d? | finish no earlier than 2010-03-19 | C1 | 1696h | 1696h | eIMS_RP | PCG-23 | Rel-9 | CP-44 | Kimmo |  | 24.229 | Ericsson |  |  |  |
| 3356 | 850.3 | CT3 aspects of Completion of IMS Restoration Procedures | 212d? | 2009-05-29 A | 2010-03-19 A | 100% | 2009-05-29 | 2010-03-19 | 212d? | finish no earlier than 2010-03-19 | C3 | 1696h | 1696h | eIMS_RP | PCG-24 | Rel-9 | CP-46 | Kimmo |  | 29.061, 29.212, 29.213, 29.214, 29.215 | Ericsson |  |  |  |
| 3357 | 851 | **IMS Stage 3 IETF Protocol Alignment - phase 3** | 1458d? | 2009-05-29 A | 2014-12-05 A | 100% | 2009-05-29 | 2014-12-05 | 1455d? |  | C1; IETF | 40216h | 40216h | IMSProtoc3 | PCG-23 | Rel-9 | CP-44 | Frederic | IMSProtoc3 |  | Alcatel-Lucent |  |  |  |
| 3358 | 851.1 | CT1 aspects of IMS Stage 3 - IETF Protocol Alignment - phase 3 | 212d? | 2009-05-29 A | 2010-03-19 A | 100% | 2009-05-29 | 2010-03-19 | 212d? | finish no earlier than 2010-03-19 | C1 | 1696h | 1696h | IMSProtoc3 | PCG-23 | Rel-9 | CP-44 | Frederic |  | 23.218, 24.229, 24.930 | Alcatel-Lucent |  |  |  |
| 3359 | 851.2 | (IETF) CT1 IMS Stage 3 - IETF Protocol Alignment (RFC 7329) | 1242d? | 2009-05-29 A | 2014-12-05 A | 100% | 2009-05-29 | 2014-12-05 | 1240d? | finish no earlier than 2014-12-09 | C1-IETF | 9936h | 9936h | IMSProtoc3 | PCG-27 | Rel-9 | CP-52 | Frederic |  | RFC 7329 (was draft-kaplan-insipid-session-id) | christer.holmberg@ericsson.com |  |  |  |
| 3360 | 851.3 | (IETF) CT1 IMS Stage 3 - IETF Protocol Alignment (RFC 7044) | 659d? | 2011-09-13 A | 2014-03-07 A | 100% | 2011-09-13 | 2014-03-07 | 659d? | finish no earlier than 2014-02-10 | C1-IETF | 5256h | 5256h | IMSProtoc3 | PCG-27 | Rel-9 | CP-53 | Frederic |  | RFC 7044 (was draft-ietf-sipcore-rfc4244bis) | christer.holmberg@ericsson.com |  |  |  |

Notes:
- 3334: SP#42 umbrella BB created to host OAM WIs
- 3335: SP#46 completed / WI rapporteur e-mail: liangshuangchun@cmdi.chinamobile.com, lijian@chinamobile.com, Bao Haitao
- 3336: SP#48 completed / WI rapporteur e-mail: Yizhi Yao (yzyao@motorola.com),Lan Zou (zlan@huawei.com)
- 3337: SP#46 completed / WI rapporteur e-mail: Li Jian (lijian@chinamobile.com), Liang Shuangchun (liangshuangchun@cmdi.chinamobile.com)
- 3338: SP#43 umbrella BB created to host OAM WIs
- 3339: SP#48 completed / WI rapporteur e-mail: Lan Zou (zlan@huawei.com)
- 3340: SP#48 completed / WI rapporteur e-mail: clemens.suerbaum@nsn.com
- 3341: SP#48 completed / WI rapporteur e-mail: frode.nergard@ericsson.com
- 3342: SP#46 stopped (no work in Rel-9)
- 3343: CH9 is an umbrella Feature also for OAM&P related TEI9 type of changes that are not part of any other dedicated feature/WI
- 3344: CP#47 completed. Rel-8 UID_380061 (Ipinterc) covers Stage 1 in SA1 22.101, 22.228 / WI rapporteur e-mail: mauro.ficaccio@telecomitalia.it
- 3345: CP#47 completed / WI rapporteur e-mail: mauro.ficaccio@telecomitalia.it
- 3346: CP#46 completed / WI rapporteur e-mail: mauro.ficaccio@telecomitalia.it
- 3347: CP#46 completed / WI rapporteur e-mail: bruno.landais@alcatel-lucent.fr
- 3348: CP#46 completed / WI rapporteur e-mail: bruno.landais@alcatel-lucent.fr
- 3349: CP#46 completed / WI rapporteur e-mail: bruno.landais@alcatel-lucent.fr
- 3350: CP#46 completed / WI rapporteur e-mail: bruno.landais@alcatel-lucent.fr
- 3351: CP#48 completed. Stage 1 in 22.182 / WI rapporteur e-mail: Jiang Yi
- 3352: CP#48 completed / WI rapporteur e-mail: Jiang Yi
- 3353: CP#47 completed. Continuation of Rel-8 Feature UID_400012 IMS Restoration Procedures / WI rapporteur e-mail: Emiliano Merino (emiliano.merino@ericsson.com)
- 3354: CP#47 completed / WI rapporteur e-mail: Emiliano Merino (emiliano.merino@ericsson.com)
- 3355: CP#47 completed / WI rapporteur e-mail: Emiliano Merino (emiliano.merino@ericsson.com)
- 3356: CP#47 completed / WI rapporteur e-mail: Emiliano Merino (emiliano.merino@ericsson.com)
- 3357: CP#47 completed / WI rapporteur e-mail: Keith Drage (drage@alcatel-lucent.com)
- 3358: CP#47 completed / WI rapporteur e-mail: Keith Drage (drage@alcatel-lucent.com)
- 3359: CP#65 completed / WI rapporteur e-mail: christer.holmberg@ericsson.com
- 3360: CP#63 completed / WI rapporteur e-mail: christer.holmberg@ericsson.com

| ID | WBS | Task | Type | Duration | Start | Finish | Complete | Baseline start | Baseline finish | Baseline duration | Constraint | Resources | Work | Actual work | Acronym | PCG approved | WI rapporteur name | WI rapporteur e-mail | Release | TSG approved | MCC resp | Acronym_3GU_Export | TSG stopped | Special Focus Doc | Status Report |
| --- | --- | --- | --- | --- | --- | --- | --- | --- | --- | --- | --- | --- | --- | --- | --- | --- | --- | --- | --- | --- | --- | --- | --- | --- | --- |
| 3361 | 852 | **Operational description of the Inter-IMS Network to Network Interface (II-NNI)** |  | 1460d? | 2009-05-29 A | 2014-12-09 A | 100% | 2009-05-29 | 2014-12-05 | 1455d? |  | C3; IETF | 58408h | 58408h | II-NNI | PCG-23 | Orange | sebastien.daudet@orange-ftgroup.com | Rel-9 | CP-44 | Adrian | II-NNI |  |  |  |
| 3362 | 852.1 | Operational description of the Inter-IMS Network to Network Interface |  | 267d? | 2009-05-29 A | 2010-06-04 A | 100% | 2009-05-29 | 2010-06-04 | 267d? | start no earlier than 2009-05-29 | C3 | 2136h | 2136h | II-NNI | PCG-23 | Orange |  | Rel-9 | CP-44 | Adrian |  |  |  |  |
| 3363 | 852.2 | (IETF) Operational description of the Inter-IMS Network to Network Interface (RFC 7329) |  | 633d? | 2012-04-20 A | 2014-09-12 A | 100% | 2012-04-20 | 2014-12-05 | 693d? | finish no earlier than 2014-09-12 | C3-IETF | 5040h | 5040h | II-NNI | PCG-29 | christer.holmberg@ericsson.com | christer.holmberg@ericsson.com | Rel-9 | CP-56 | Adrian |  |  |  |  |
| 3364 | 852.3 | (IETF) Operational description of the Inter-IMS Network to Network Interface (RFC 7316) |  | 634d? | 2012-04-20 A | 2014-09-12 A | 100% | 2012-04-20 | 2014-12-05 | 694d? | finish no earlier than 2014-12-09 | C3-IETF | 5064h | 5064h | II-NNI | PCG-29 | Keith Drage | Keith Drage | Rel-9 | CP-56 | Adrian |  |  |  |  |
| 3365 | 852.4 | (IETF) Operational description of the Inter-IMS Network to Network Interface |  | 696d? | 2012-04-20 A | 2014-12-09 A | 100% | 2012-04-20 | 2014-12-05 | 694d? | finish no earlier than 2014-12-09 | C3-IETF | 5560h | 5560h | II-NNI | PCG-29 | Roland Jesske | Roland Jesske | Rel-9 | CP-56 | Adrian |  |  |  |  |
| 3366 | 852.5 | (IETF) Operational description of the Inter-IMS Network to Network Interface |  | 696d? | 2012-04-20 A | 2014-12-09 A | 100% | 2012-04-20 | 2014-12-05 | 694d? | finish no earlier than 2014-12-09 | C3-IETF | 5536h | 5536h | II-NNI | PCG-29 | Roland Jesske | Roland Jesske | Rel-9 | CP-56 | Adrian |  |  |  |  |
| 3367 | 852.6 | (IETF) Operational description of the Inter-IMS Network to Network Interface |  | 697d? | 2012-04-20 A | 2014-12-09 A | 100% | 2012-04-20 | 2014-12-05 | 695d? | finish no earlier than 2014-12-09 | C3-IETF | 5560h | 5560h | II-NNI | PCG-29 | Keith Drage | Keith Drage | Rel-9 | CP-56 | Adrian |  |  |  |  |
| 3368 | 852.7 | Deleted - (IETF) Operational description of the Inter-IMS Network to Network Interface |  | 433d? | 2012-04-20 A | 2013-12-06 A | 100% | 2012-04-20 | 2014-12-05 | 694d? | finish no earlier than 2013-12-06 | C3-IETF | 3456h | 3456h | II-NNI | PCG-29 | Peter Dawes | peter.dawes@vodafone.com | Rel-9 | CP-56 | Adrian |  | SP-69 |  |  |
| 3369 | 852.8 | Deleted - (IETF) Operational description of the Inter-IMS Network to Network Interface (avasarala-dispatch-comm-div-notification) |  | 340d? | 2013-03-01 A | 2014-06-13 A | 100% | 2013-03-01 | 2014-06-13 | 340d? | finish no earlier than 2014-06-13 | C3-IETF | 2696h | 2696h | II-NNI | PCG-30 | Andrew Allen | Andrew Allen | Rel-9 | CP-59 | Adrian |  | SP-69 |  |  |
| 3370 | 853 | Definition of Ml interface for Control Plane LCS (Stage 3) |  | 131d? | 2009-09-18 A | 2010-03-19 A | 100% | 2009-09-18 | 2010-03-19 | 131d? | finish no earlier than 2010-03-19 | C1 | 1048h | 1048h | EMC2 | PCG-23 | Alcatel-Lucent | Keith Drage (drage@alcatel-lucent.com) | Rel-9 | CP-45 | Frederic | EMC2 |  | Public Safety (I-A) |  |
| 3371 | 854 | PCC enhancements |  | 56d? | 2009-09-18 A | 2009-12-04 A | 100% | 2009-09-18 | 2009-12-04 | 56d? | finish no earlier than 2009-12-04 | C3 | 448h | 448h | PCC-Enh | PCG-23 | Huawei | Wei Weihua (weiwh@huawei.com) | Rel-9 | CP-45 | Adrian | PCC-Enh |  |  |  |
| 3372 | 855 | 3GPP IMS Conferencing Management Object (MO) |  | 2d? | 2009-12-03 A | 2009-12-04 A | 100% | 2009-12-03 | 2009-12-04 | 2d? | start no earlier than 2009-12-03 | C1 | 16h | 16h | IMS_ConfMO | PCG-24 |  |  | Rel-9 | CP-46 | Frederic | IMS_ConfMO |  |  |  |
| 3373 | 856 | In Case of Emergency (ICE) Graphics |  | 3d? | 2010-03-17 A | 2010-03-19 A | 100% | 2010-03-17 | 2010-03-19 | 3d? | finish no earlier than 2010-03-19 | C6 | 24h | 24h | ICE_Graphics | PCG-24 | Sagem-Orga | heiko.kruse@sagem-orga.com | Rel-9 | CP-47 | Xavier | ICE_Graphics |  |  |  |
| 3374 | 857 | **Rel-9 Improvements of the Radio Interface** |  | 397d? | 2008-09-12 A | 2010-03-19 A | 100% | 2008-09-12 | 2010-03-19 | 397d? |  | RP; GP | 19744h | 19744h | RInImp9 | PCG-21 |  |  | Rel-9 | RP-41 | Issam | RInImp9 |  |  |  |
| 3375 | 857.1 | LCR TDD UE OTA Performance Requirements |  | 186d? | 2008-09-12 A | 2009-05-29 A | 100% | 2008-09-12 | 2009-05-29 | 186d? | finish no earlier than 2009-05-29 | R4 | 1488h | 1488h | RInImp9-RFLCROTA | PCG-21 | RITT | Wu Xiang (wuxiang@chinattl.com) | Rel-9 | RP-41 | Issam | RInImp9-RFLCROTA |  |  | RP-090389 |
| 3376 | 857.2 | **RF requirements for Multicarrier and Multi-RAT BS** |  | 347d? | 2008-11-21 A | 2010-03-19 A | 100% | 2008-11-21 | 2010-03-19 | 347d? |  | R4; G1 | 10336h | 10336h | RInImp9-RFmulti | PCG-21 | Ericsson | Johan.skold@ericsson.com | Rel-9 | RP-41 | Issam | RInImp9-RFmulti |  |  |  |
| 3377 | 857.2.1 | RAN4 part of RF requirements for Multicarrier and Multi RAT BS |  | 337d? | 2008-12-05 A | 2010-03-19 A | 100% | 2008-12-05 | 2010-03-19 | 337d? | finish no earlier than 2010-03-19 | R4 | 2696h | 2696h | RInImp9-Rfmulti | PCG-22 | Ericsson | johan.skold@ericsson.com | Rel-9 | RP-42 | Issam |  |  |  | RP-100027 |
| 3378 | 857.2.2 | GERAN part of RF requirements for Multicarrier and Multi RAT BS |  | 261d? | 2008-11-21 A | 2009-11-20 A | 100% | 2008-11-21 | 2009-11-20 | 261d? | finish no earlier than 2009-11-20 | G1 | 2088h | 2088h | RInImp9-RFmulti-GERAN | PCG-22 | Ericsson | mats.y.samuelsson@ericsson.com | Rel-9 | GP-40 | Paolo | RInImp9-RFmulti-GERAN |  |  |  |
| 3379 | 857.3 | Extended UMTS/LTE 800 MHz | milestone | 0d? | 2008-12-05 A | 2008-12-05 A | 100% | 2008-12-05 | 2009-09-18 | 207d? |  | R4; R2; R3 |  |  | RInImp9-UMTSLTE800 | PCG-22 | NTT DoCoMo | Shingo Suwa (suwas@nttdocomo.co.jp) | Rel-9 | RP-42 | Issam | RInImp9-UMTSLTE800 |  |  | RP-090687 |
| 3380 | 857.4 | UMTS/LTE 800 MHz for Europe | milestone | 0d? | 2009-03-06 A | 2009-03-06 A | 100% | 2009-03-06 | 2010-03-19 | 272d? | finish no earlier than 2010-03-19 | R4; R2; R3 |  |  | RInImp9-UMTSLTE800EU | PCG-22 | Ericsson | olav.queseth@ericsson.com | Rel-9 | RP-43 | Issam | RInImp9-UMTSLTE800EU |  |  | RP-100028 |
| 3381 | 857.5 | Performance requirement for LCR TDD with UE speeds up to 350 km/h |  | 196d? | 2009-03-06 A | 2009-12-04 A | 100% | 2009-03-06 | 2009-12-04 | 196d? | finish no earlier than 2009-12-04 | R4 | 1568h | 1568h | RInImp9-LCRTDD350 | PCG-22 | CATT | Yuexia Song (songyuexia@catt.cn) | Rel-9 | RP-43 | Issam | RInImp9-LCRTDD350 |  |  | RP-091035 |
| 3382 | 857.6 | Extended UMTS/LTE 1500 MHz | milestone | 0d? | 2009-05-30 A | 2009-05-30 A | 100% | 2009-05-30 | 2010-03-19 | 211d? | finish no earlier than 2010-03-19 | R4; R2; R3 |  |  | UMTSLTE1500 | PCG-23 | NTT DoCoMo | Shingo Suwa (suwas@nttdocomo.co.jp) | Rel-9 | RP-44 | Issam | UMTSLTE1500 |  |  | RP-100029 |
| 3383 | 858 | **Rel-9 Improvements of the Radio Interface - UE Conformance Testing** |  | 350d? | 2009-05-19 A | 2010-09-17 A | 100% | 2009-05-19 | 2010-09-17 | 350d? |  | R5 | 8184h | 8184h |  | PCG-23 |  |  | Rel-9 | RP-44 | Ingbert |  |  |  |  |
| 3384 | 858.1 | Conformance Test Aspects – UMTS/LTE in 800 MHz for Europe |  | 350d? | 2009-05-19 A | 2010-09-17 A | 100% | 2009-05-19 | 2010-09-17 | 350d? | finish no earlier than 2010-09-17 | R5 | 2800h | 2800h | RInImp-UEConTest-UMTSLTE800EU | PCG-23 | Ericsson | fredrik.sundstrom@ericsson.com | Rel-9 | RP-44 | Ingbert | RInImp-UEConTest-UMTSLTE800EU |  |  | RP-100736 |
| 3385 | 858.2 | Conformance Test Aspects – Extended UMTS/LTE 1500 MHz |  | 186d? | 2009-09-18 A | 2010-06-04 A | 100% | 2009-09-18 | 2010-06-04 | 186d? | finish no earlier than 2010-06-04 | R5 | 1488h | 1488h | UMTSLTE1500_UEConTest | PCG-23 | NTT DoCoMo | Nguyen Dung Dao (dao@nttdocomo.co.jp) | Rel-9 | RP-45 | Ingbert | UMTSLTE1500_UEConTest |  |  | RP-100487 |
| 3386 | 858.3 | TDD UE Over The Air (Antenna) conformance testing methodology |  | 81d? | 2009-05-30 A | 2009-09-18 A | 100% | 2009-05-30 | 2009-09-18 | 81d? | finish no earlier than 2009-09-18 | R5 | 648h | 648h | UEAnt_TDDTest | PCG-23 | CATR | Qu Yan (quyan@emcite.com) | Rel-9 | RP-44 | Ingbert | UEAnt_TDDTest |  |  | RP-090727 |
| 3387 | 858.4 | Conformance Test Aspects – Performance requirement for LCR TDD with UE speeds up to 350 km/h |  | 56d? | 2010-03-19 A | 2010-06-04 A | 100% | 2010-03-19 | 2010-06-04 | 56d? | finish no earlier than 2010-06-04 | R5 | 448h | 448h | RInImp9-LCRTDD350_UEConTest | PCG-24 | CATT | Xiaozhong Chen (chexiaozhong@datangmobile.cn) | Rel-9 | RP-47 | Ingbert | RInImp9-LCRTDD350_UEConTest |  |  | RP-100496 |
| 3388 | 859 | Conformance Test Aspects – SMS over IMS in E-UTRAN |  | 131d? | 2009-09-18 A | 2010-03-19 A | 100% | 2009-09-18 | 2010-03-19 | 131d? | finish no earlier than 2010-06-18 | R5 | 1048h | 1048h | SMSoverIMS_UEConTest | PCG-23 | Alcatel-Lucent | Nidal Khrais (khrais@alcatel-lucent.com) | Rel-9 | RP-45 | Ingbert | SMSoverIMS_UEConTest |  |  | RP-100072 |

Notes:
- 3361: -
- 3362: CP#48 completed / Impacted TSs and TRs: 29.165
- 3363: CP#65 complete / Impacted TSs and TRs: RFC 7329 (was draft-kaplan-insipid-session-id)
- 3364: CP#65 complete / Impacted TSs and TRs: RFC 7316 (was draft-vanelburg-dispatch-private-network-ind)
- 3365: In RFC Editors Queue. Dec.14: 75->90; 7/3/16: 90%->100 / Impacted TSs and TRs: draft-ietf-salud-alert-info-urns
- 3366: In RFC Editors Queue. Mar15: 90->100%. RFC updated (was draft-ietf-cuss-sip-uui). Jun 15: RFC 7433 (was draft-ietf-cuss-sip-uui) / Impacted TSs and TRs: RFC 7433
- 3367: In RFC Editors Queue. Dec.14: 75->90. Mar15: 90->100%. RFC updated (was draft-ietf-cuss-sip-uui-isdni). June 15: RFC 7434 (was draft-ietf-cuss-sip-uui-isdn) / Impacted TSs and TRs: RFC 7434
- 3368: CP#62 removed from Rel-8 to Rel-11. Not completed internet-draft / Impacted TSs and TRs: Rel-12 remains draft-dawes-sipping-debug
- 3369: CP#64 Draft removed from 3GPP documentation / Impacted TSs and TRs: draft-avasarala-dispatch-comm-div-notification
- 3370: CP#47 completed [Stage 3 for Rel-7 Emergency Calls (EMC1)]. Related to Rel-9 UID_400038 LCS Control Plane Solution for EPS. Stage 2 in Rel-9 UID_400038 (23.271), UID_410037 (23.167) / Impacted TSs and TRs: 24.229
- 3371: CP#46 completed / Impacted TSs and TRs: 29.212, 29.213, 29.215
- 3372: CP#46 completed. Linked to Rel-6 UID_11051 (IMS Management objects) under the Feature UID_32021 (IMS Phase 2). MO compatible with OMA DM v1.2 & upwards and defined using OMA DM Device Description Framework (OMA-ERELD _DM-V1_2) / Impacted TSs and TRs: New 24.166
- 3373: CP#47 approved WID and completed. Added capability to store ICE graphical information (picture). Linked to CT6 Rel-8 ICE Feature UID_380059 In Case of Emergency numbers storage and easy access on UICC / Impacted TSs and TRs: 31.102 CR#0433
- 3374: RP#41 umbrella Feature created to host Rel-9 WIs / Impacted TSs and TRs: GERAN, UTRA, LTE
- 3375: RP#44 completed technical work (RAN4 internal TR abandoned) / Impacted TSs and TRs: UTRA (no TR 25.8xy produced)
- 3376: RP#47 completed. RF requirements specification applicable to Multi-Standard Radio (MSR) Base Station with multiple carriers and/or multiple 3GPP Radio Access Technologies (RAT) / Impacted TSs and TRs: GERAN, UTRA, LTE
- 3377: RP#48 completed / Impacted TSs and TRs: UTRA, LTE 25.104, 25.105, 36.104, new 37.104, 37.113, 37.141, 37.900
- 3378: GP#44 Core spec completed. GP#40 WID approved / Impacted TSs and TRs: GERAN 45.005, 51.021
- 3379: RP#45 completed / Impacted TSs and TRs: UTRA, LTE 25.101, 25.104, 25.113, 25.133, 34.124, 36.101, 36.104, 36.113, 36.124, 36.133, 36.141, 25.306, 25.307, 25.331, 36.331, 25.461, 25.466, new 36.800
- 3380: RP#47 completed / Impacted TSs and TRs: UTRA, LTE 25.101, 25.104, 25.113, 25.133, 25.141, 34.124, 36.101, 36.104, 36.113, 36.124, 36.133, 36.141, new 36.810, 25.306, 25.307, 25.331, 36.331, 25.461, 25.466
- 3381: RP#46 completed / Impacted TSs and TRs: UTRA 25.102, 25.105, 25.142
- 3382: RP#47 completed. For potential deployment in Japan / Impacted TSs and TRs: UTRA, LTE 25.101, 25.104, 25.113, 25.133, 25.141, 25.306, 25.307, 25.331, 25.461, 25.466, 34.124, 36.101, 36.104, 36.113, 36.124, 36.133, 36.141, 36.331, new (36.821, 36.307)
- 3383: - / Impacted TSs and TRs: UTRA, LTE
- 3384: RP#49 completed. Testing for UID_430009 UMTS/LTE 800 MHz for Europe / Impacted TSs and TRs: UTRA, LTE 34.108, 34.121-1, 34.121-2, 36.508, 36.521-1, 36.521-2, 36.521-3
- 3385: RP#48 completed / Impacted TSs and TRs: UTRA, LTE 34.108, 34.121-1, 34.121-2, 34.123-1, 34.123-2, 36.508, 36.521-1, 36.521-2, 36.521-3, 36.523-1, 36.523-2, 36.523-3
- 3386: RP#45 completed. Finalized TDD UE test methodology based on R4 TR 25.914 (UE and MS antenna performance evaluation method) and TS 25.144 Over the Air (Antenna) minimum performance requirements for the speech mode (terminal close to head) / Impacted TSs and TRs: UTRA 34.114
- 3387: RP#48 completed. Testing for UID_430010 Performance requirement for LCR TDD with UE speeds up to 350 km/h / Impacted TSs and TRs: UTRA 34.122
- 3388: RP#47 completed / Impacted TSs and TRs: LTE 34.229-1, 34.229-2, 34.229-3

| ID | WBS | Task | Type | Duration | Start | Finish | Complete | Baseline start | Baseline finish | Baseline duration | Constraint | Resources | Work | Actual work | PCG approved | Release | TSG approved | MCC resp | Acronym | WI rapporteur name | WI rapporteur e-mail | Status Report | Acronym_3GU_Export | Special Focus Doc |
| --- | --- | --- | --- | --- | --- | --- | --- | --- | --- | --- | --- | --- | --- | --- | --- | --- | --- | --- | --- | --- | --- | --- | --- | --- |
| 3389 | 860 | **Rel-9 RAN improvements** |  | 2395d? | 2009-03-06 A | 2018-04-16 A | 100% | 2000-01-03 | 2010-03-19 | 2667d? |  | RP | 76640h | 76640h | PCG-22 | Rel-9 | RP-43 | Issam |  |  |  |  |  |  |
| 3390 | 860.1 | Dual-Cell HSUPA | milestone | 0d? | 2009-03-06 A | 2009-03-06 A | 100% | 2009-03-06 | 2010-03-19 | 272d? | finish no earlier than 2010-03-19 | R1; R2; R3; R4 |  |  | PCG-22 | Rel-9 | RP-43 | Patrick | RANimp-DC_HSUPA | Nokia Siemens Networks | Karri Ranta-aho (karri.ranta-aho@nsn.com) | RP-100030 | RANimp-DC_HSUPA |  |
| 3391 | 860.2 | Support for different bands for Dual-Cell HSDPA | milestone | 0d? | 2009-03-06 A | 2009-03-06 A | 100% | 2009-03-06 | 2009-12-04 | 197d? |  | R4; R2; R3 |  |  | PCG-22 | Rel-9 | RP-43 | Issam | RANimp-MultiBand_DC_HSDPA | Nokia Siemens Networks | Tuomo Säynäjäkangas (tuomo.saynajakangas@nsn.com) | RP-091038 | RANimp-MultiBand_DC_HSDPA |  |
| 3392 | 860.3 | Combination of DC-HSDPA with MIMO | milestone | 0d? | 2009-03-06 A | 2009-03-06 A | 100% | 2009-03-06 | 2009-12-04 | 197d? |  | R1; R2; R3; R4 |  |  | PCG-22 | Rel-9 | RP-43 | Patrick | RANimp-DC_MIMO | Ericsson | johan.bergman@ericsson.com | RP-091039 | RANimp-DC_MIMO |  |
| 3393 | 860.4 | Transmit Antenna Array (TxAA) extension for non-MIMO UEs | milestone | 0d? | 2009-03-06 A | 2009-03-06 A | 100% | 2009-03-06 | 2009-12-04 | 197d? |  | R1; R2; R3; R4 |  |  | PCG-22 | Rel-9 | RP-43 | Patrick | RANimp-TxAA_nonMIMO | Nokia | Arto Lehti (arto.lehti@nokia.com) | RP-091040 | RANimp-TxAA_nonMIMO |  |
| 3394 | 860.5 | Cell Portion for 1.28 Mcps TDD |  | 2395d? | 2009-03-06 A | 2018-04-16 A | 100% | 2000-01-03 | 2000-07-07 | 136d? | finish no earlier than 2009-03-06 | R3; R1; R4 | 57480h | 57480h | PCG-23 | Rel-9 | RP-44 | Juha | CP_LCRTDD | CATT | Ying Zhang (zhangying2@datangmobile.cn) | RP-091041 | CP_LCRTDD |  |
| 3395 | 861 | **Rel-9 RAN improvements - UE Conformance Testing** |  | 588d? | 2010-09-17 A | 2012-12-07 A | 100% | 2010-09-17 | 2012-12-07 | 588d? |  | R5 | 11848h | 11848h | PCG-25 | Rel-9 | RP-49 | Ingbert |  |  |  |  |  |  |
| 3396 | 861.1 | Conformance Test Aspects – Combination of DC-HSDPA with MIMO |  | 186d? | 2010-09-17 A | 2011-06-03 A | 100% | 2010-09-17 | 2011-06-03 | 186d? | finish no earlier than 2011-06-03 | R5 | 1488h | 1488h | PCG-25 | Rel-9 | RP-49 | Ingbert | RANimp-DC_MIMO_UEConTest | Ericsson | leif.mattisson@ericsson.com | RP-110510 | RANimp-DC_MIMO_UEConTest |  |
| 3397 | 861.2 | Conformance Test Aspects – Dual-Cell HSUPA |  | 453d? | 2011-03-18 A | 2012-12-07 A | 100% | 2011-03-18 | 2012-12-07 | 453d? | finish no earlier than 2012-12-07 | R5 | 3624h | 3624h | PCG-26 | Rel-9 | RP-51 | Ingbert | RANimp-DC_HSUPA_UEConTest | Ericsson | leif.mattisson@ericsson.com | RP-121524 | RANimp-DC_HSUPA_UEConTest |  |
| 3398 | 861.3 | Conformance Test Aspects – Support for different bands for Dual-Cell HSDPA |  | 254d? | 2011-03-18 A | 2012-03-02 A | 100% | 2011-03-18 | 2012-03-02 | 254d? | finish no earlier than 2012-03-02 | R5 | 2032h | 2032h | PCG-26 | Rel-9 | RP-51 | Ingbert | RANimp-MultiBand_DC_HSDPA_UEConTest | Ericsson | leif.mattisson@ericsson.com | RP-120036 | RANimp-MultiBand_DC_HSDPA_UEConTest |  |
| 3399 | 862 | **LTE improvements** |  | 587d? | 2009-03-06 A | 2011-06-03 A | 100% | 2009-03-06 | 2011-06-03 | 587d? |  | R1; R2; R4; R5 | 21840h | 21840h | PCG-22 | Rel-9 | RP-42 | Patrick | LTEimp |  |  |  | LTEimp |  |
| 3400 | 862.1 | LTE Pico NodeB RF Requirements |  | 196d? | 2009-03-06 A | 2009-12-04 A | 100% | 2009-03-06 | 2009-12-04 | 196d? | finish no earlier than 2010-03-05 | R4 | 1568h | 1568h | PCG-22 | Rel-9 | RP-43 | Issam | LTEimp-Pico_eNB-RF | Huawei | Liyan Yin (yinliyan@huawei.com) | RP-091045 | LTEimp-Pico_eNB-RF |  |
| 3401 | 862.2 | Enhanced Dual-Layer transmission for LTE | milestone | 0d? | 2009-03-06 A | 2009-03-06 A | 100% | 2009-03-06 | 2010-03-19 | 272d? | finish no earlier than 2010-03-18 | R1; R2; R4 |  |  | PCG-22 | Rel-9 | RP-43 | Patrick | LTEimp-eDL | China Mobile | Xu Xiaodong (xuxiaodong@chinamobile.com) | RP-100034 | LTEimp-eDL |  |
| 3402 | 862.3 | UE Conformance Test Aspects – Enhanced Dual-layer transmission for LTE TDD |  | 186d? | 2010-09-17 A | 2011-06-03 A | 100% | 2010-09-17 | 2011-06-03 | 186d? | finish no earlier than 2011-06-03 | R5 | 1488h | 1488h | PCG-25 | Rel-9 | RP-49 | Ingbert | LTEimp-eDL_UEConTest | China Mobile | Shanpeng Xiao (xiaoshanpeng@chinamobile.com) | RP-110509 | LTEimp-eDL_UEConTest |  |
| 3403 | 863 | Rel-9 Self-Organizing Networks (SON) | milestone | 0d? | 2009-03-06 A | 2009-03-06 A | 100% | 2009-03-06 | 2010-03-19 | 272d? | finish no earlier than 2010-03-19 | R3; R2 |  |  | PCG-22 | Rel-9 | SP-42 | Juha | SON | Nokia Siemens Networks | krzysztof.kordybach@nsn.com | RP-100038 | SON | SON |
| 3404 | 864 | **AGNSS Performances and Testing Procedures** |  | 787d? | 2008-05-16 A | 2011-05-20 A | 100% | 2008-05-16 | 2011-05-20 | 787d? |  | G1; G3new | 22664h | 22664h |  | Rel-9 |  | Paolo | AGNSSPTP | Thales | Michel.monnerat@thalesaleniaspace.com |  | AGNSSPTP |  |
| 3405 | 864.1 | AGNSS Minimum Performances |  | 472d? | 2008-05-16 A | 2010-03-05 A | 100% | 2008-05-16 | 2010-03-05 | 472d? | finish no earlier than 2010-03-05 | G1 | 3776h | 3776h |  | Rel-9 |  | Paolo | AGNSSPTP-Perfreq | Thales | Michel.monnerat@thalesaleniaspace.com |  | AGNSSPTP-Perfreq |  |
| 3406 | 864.2 | AGNSS Testing Procedures |  | 787d? | 2008-05-16 A | 2011-05-20 A | 100% | 2008-05-16 | 2011-05-20 | 787d? | finish no earlier than 2011-05-20 | G3new | 6296h | 6296h |  | Rel-9 |  | Ingbert | AGNSSPTP-MStest | Thales | Michel.monnerat@thalesaleniaspace.com |  | AGNSSPTP-MStest |  |
| 3407 | 865 | **Voice services over Adaptive Multi-user channels on One Slot** |  | 860d? | 2008-11-21 A | 2012-03-02 A | 100% | 2008-11-21 | 2012-03-02 | 860d? |  | GP; G1; G2; G3new | 71592h | 71592h | PCG-22 | Rel-9 | SP-42 | Paolo | VAMOS | Nokia Siemens Networks, China Mobile | juergen.hofmann@nsn.com, liuxiaoyu@chinamobile.com |  | VAMOS |  |
| 3408 | 865.1 | Stage 2 for Voice services over Adaptive Multi-user channels on One Slot |  | 392d? | 2008-11-21 A | 2010-05-21 A | 100% | 2008-11-21 | 2010-05-21 | 392d? | finish no earlier than 2010-05-21 | GP; G1; G2 | 9408h | 9408h | PCG-22 | Rel-9 | GP-40 | Paolo | VAMOS | Nokia Siemens Networks, China Mobile | juergen.hofmann@nsn.com, liuxiaoyu@chinamobile.com |  |  |  |
| 3409 | 865.2 | Stage 3 for Voice services over Adaptive Multi-user channels on One Slot |  | 596d? | 2008-11-24 A | 2011-03-04 A | 100% | 2008-11-24 | 2011-03-04 | 596d? | finish no earlier than 2011-03-04 | GP; G1; G2 | 14304h | 14304h | PCG-22 | Rel-9 | GP-40 | Paolo | VAMOS | Nokia Siemens Networks, China Mobile | juergen.hofmann@nsn.com, liuxiaoyu@chinamobile.com |  |  |  |
| 3410 | 865.3 | VAMOS Radio Performance Requirements |  | 651d? | 2008-11-24 A | 2011-05-20 A | 100% | 2008-11-24 | 2011-05-20 | 651d? | finish no earlier than 2011-05-20 | GP; G1; G2 | 15624h | 15624h | PCG-22 | Rel-9 | GP-40 | Paolo | VAMOS | Nokia Siemens Networks, China Mobile | juergen.hofmann@nsn.com, liuxiaoyu@chinamobile.com |  |  |  |
| 3411 | 865.4 | VAMOS - MS conformance testing |  | 392d? | 2010-09-03 A | 2012-03-02 A | 100% | 2010-09-03 | 2012-03-02 | 392d? | finish no earlier than 2012-03-02 | G3new | 3128h | 3128h | PCG-25 | Rel-9 | GP-47 | Ingbert | VAMOS_MStest | BlackBerry | Raveendra Seetharam (rseetharam@rim.com) |  | VAMOS_MStest |  |
| 3412 | 865.5 | VAMOS - BTS conformance testing |  | 201d? | 2010-11-26 A | 2011-09-02 A | 100% | 2010-11-26 | 2011-09-02 | 201d? | finish no earlier than 2011-09-02 | G1 | 1608h | 1608h | PCG-26 | Rel-9 | GP-48 | Paolo | VAMOS_BTStest | Nokia Siemens Networks | eddie.riddington@nsn.com |  | VAMOS_BTStest |  |

Notes:
- 3389: RP#47 completed / Impacted TSs and TRs: UTRA
- 3390: RP#47 completed / Impacted TSs and TRs: 25.101, 25.104, 25.133, 25.211, 25.212, 25.213, 25.214, 25.215, 25.319, 25.306, 25.321, 25.331, 25.423, 25.433
- 3391: RP#46 completed. RP#62 existing TS 25.317 replaced by new TS 25.327 / Impacted TSs and TRs: 25.101, 25.104, 25.133, 25.306, 25.308, 25.331, 25.423, 25.433, new 25.317 replaced by new TS 25.327
- 3392: RP#46 completed / Impacted TSs and TRs: 25.101, 25.104, 25.133, 25.211, 25.212, 25.213, 25.214, 25.215, 25.308, 25.321, 25.331, 26.306, 25.423, 25.433
- 3393: RP#46 completed / Impacted TSs and TRs: 25.101, 25.104, 25.211, 25.212, 25.213, 25.214, 25.215, 25.308, 25.306, 25.321, 25.331, 25.423, 25.433
- 3394: RP#46 completed / Impacted TSs and TRs: 25.102, 25.105, 25.123, 25.225, 25.423, 25.433
- 3395: -
- 3396: UTRA. RP#52 completed. Testing for Rel-9 UID_430016 Combination of DC-HSDPA with MIMO / Impacted TSs and TRs: UTRA 34.108, 34.121-1, 34.121-2, 34.123-1, 34.123-2, 34.123-3
- 3397: RP#58 completed. Testing for Rel-9 UID_430014 Dual-Cell HSUPA / Impacted TSs and TRs: UTRA 34.108, 34.121-1, 34.121-2, 34.123-1, 34.123-2, 34.123-3
- 3398: RP#55 completed. Testing for Rel-9 UID_430015 Support for different bands for Dual-Cell HSDPA / Impacted TSs and TRs: UTRA 34.108, 34.121-1, 34.121-2, 34.123-1, 34.123-2, 34.123-3
- 3399: - / Impacted TSs and TRs: LTE
- 3400: RP#46 completed / Impacted TSs and TRs: 36.104, 36.141, new 36.931
- 3401: RP#47 completed / Impacted TSs and TRs: 36.101, 36.211, 36.212, 36.213, 36.331
- 3402: RP#52 completed. Testing for UID_430029 (Enhanced Dual-Layer transmission for LTE) / Impacted TSs and TRs: 36.508, 36.521-1, 36.521-2
- 3403: RP#47 completed / Impacted TSs and TRs: LTE 25.413, 36.300, 36.413, 36.423, 48.018, New 36.902
- 3404: GP#46 still ongoing MS testing. Linked to Rel-10 RAN4 UID_450027 (AGNSS Minimum Performance for UTRAN)
- 3405: GP#45 completed (open performance requirements alignment GPS/Galileo) / Impacted TSs and TRs: 45.005
- 3406: GP#50 completed / Impacted TSs and TRs: 51.010-1, new 51.010-7
- 3407: Triggered by UID_50590 (MUROS) Study on Multi-User Reusing-One-Slot
- 3408: GP#46 completed. GP#40 WID approved / Impacted TSs and TRs: 45.001
- 3409: GP#49 completed. GP#40 WID approved / Impacted TSs and TRs: 24.008, 44.018, 45.002, 45.003, 45.004, 45.008, 48.008, 48.058
- 3410: GP#50 completed. GP#40 WID approved / Impacted TSs and TRs: 45.005
- 3411: GP#53 completed. GP#47 WID approved / Impacted TSs and TRs: 51.010-1, 51.010-2
- 3412: GP#51 completed. GP#48 WID approved / Impacted TSs and TRs: 51.021

| ID | WBS | Task | Type | Duration | Start | Finish | Complete | Baseline start | Baseline finish | Baseline duration | Constraint | Resources | Work | Actual work | Acronym | PCG approved | WI rapporteur name | WI rapporteur e-mail | Release | TSG approved | MCC resp | Acronym_3GU_Export | PCG stopped | TSG stopped | Special Focus Doc | Status Report |
| --- | --- | --- | --- | --- | --- | --- | --- | --- | --- | --- | --- | --- | --- | --- | --- | --- | --- | --- | --- | --- | --- | --- | --- | --- | --- | --- |
| 3413 | 866 | **Cell Broadcast protocol Base Station Controller – Cell Broadcast Centre (BSC-CBC)** |  | 222d? | 2009-05-15 A | 2010-03-19 A | 100% | 2009-05-15 | 2010-03-19 | 222d? |  | GP; C1 | 7024h | 7024h | CEBRO | PCG-23 | Ericsson | claes-goran.persson@ericsson.com | Rel-9 | GP-42 | Paolo | CEBRO |  |  |  |  |
| 3414 | 866.1 | GERAN part of Cell Broadcast protocol Base Station Controller – Cell Broadcast Centre |  | 212d? | 2009-05-15 A | 2010-03-05 A | 100% | 2009-05-15 | 2010-03-05 | 212d? | finish no earlier than 2010-03-05 | GP | 1696h | 1696h | CEBRO | PCG-23 | Ericsson | claes-goran.persson@ericsson.com | Rel-9 | GP-42 | Paolo |  |  |  |  |  |
| 3415 | 866.2 | CT1 part of Cell Broadcast protocol Base Station Controller – Cell Broadcast Centre |  | 222d? | 2009-05-15 A | 2010-03-19 A | 100% | 2009-05-15 | 2010-03-19 | 222d? | finish no earlier than 2010-03-19 | C1 | 1776h | 1776h | CEBRO | PCG-23 | Ericsson | claes-goran.persson@ericsson.com | Rel-9 | GP-42 | Frederic |  |  |  |  |  |
| 3416 | 867 | Hybrid Location |  | 136d? | 2009-05-18 A | 2009-11-20 A | 100% | 2009-05-18 | 2009-11-20 | 136d? | finish no earlier than 2009-11-20 | GP | 1088h | 1088h | HILT | PCG-23 | TruePosition | Matt Ward (mward@trueposition.com) | Rel-9 | GP-42 | Paolo | HILT |  |  |  |  |
| 3417 | 868 | (Small) Technical Enhancements and Improvements for Rel-9 |  | 325d? | 2008-09-15 A | 2009-12-10 A | 100% | 2008-09-15 | 2009-12-10 | 325d? | finish no earlier than 2009-12-10 | SP; CP; RP; GP | 10400h | 10400h | TEI9 | PCG-22 |  |  | Rel-9 | SP-42 | All | TEI9 |  |  |  |  |
| 3418 | 869 | Test - (Small) Technical Enhancements and Improvements for Rel-9 |  | 286d? | 2009-11-20 A | 2010-12-24 A | 100% | 2009-11-20 | 2010-12-24 | 286d? | finish no earlier than 2010-12-24 | R5; G3new | 4576h | 4576h | TEI9_Test | PCG-24 |  |  | Rel-9 | GP-44 | Ingbert | TEI9_Test |  |  |  |  |
| 3419 | 870 | **Deleted - Services Alignment and Migration** |  | 467d? | 2006-12-06 A | 2008-09-18 A | 100% | 2006-12-06 | 2008-09-18 | 467d? |  | S1 | 7472h | 7472h | ServAl |  | Telefónica O2 | chris.friel@O2.com | Rel-9 | SP-33 | Alain | ServAl | PCG-21 | SP-41 |  |  |
| 3420 | 870.1 | Deleted - Stage 1 for ServAl |  | 467d? | 2006-12-06 A | 2008-09-18 A | 100% | 2006-12-06 | 2008-09-18 | 467d? | finish no earlier than 2008-12-11 | S1 | 3736h | 3736h |  | PCG-21 | Telefónica O2 | chris.friel@O2.com | Rel-9 | SP-33 | Alain |  | PCG-21 | SP-41 |  |  |
| 3421 | 871 | Deleted - Harmonization of Gq'/Rx for Common IMS |  | 304d? | 2008-01-14 A | 2009-03-12 A | 100% | 2008-01-14 | 2009-03-12 | 304d? | finish no earlier than 2009-03-12 | S2 | 2432h | 2432h | IMS_Comm_GqRx_Harm | PCG-21 | Alcatel-Lucent | geoffrey.cristallo@alcatel-lucent.be | Rel-9 | SP-38 | Maurice | IMS_Comm_GqRx_Harm | PCG-22 | SP-43 |  |  |
| 3422 | 872 | Deleted - Support of WiMAX - LTE Mobility |  | 407d? | 2008-06-06 A | 2009-12-25 A | 100% | 2008-06-06 | 2009-12-25 | 407d? | start no earlier than 2008-06-06 | R2 | 3248h | 3248h | WiMAX_LTE_Mobility | PCG-21 | Samsung |  | Rel-9 | RP-38 | Yong-Jun | WiMAX_LTE_Mobility | PCG-21 | SP-39 |  |  |
| 3423 | 873 | Deleted - Support of WiMAX - UMTS Mobility |  | 407d? | 2008-06-06 A | 2009-12-25 A | 100% | 2008-06-06 | 2009-12-25 | 407d? | start no earlier than 2008-06-06 | R2 | 3248h | 3248h | WiMAX_UMTS_Mobility | PCG-21 | Intel |  | Rel-9 | RP-38 | Yong-Jun | WiMAX_UMTS_Mobility | PCG-21 | SP-39 |  |  |
| 3424 | 874 | Deleted - Definition of 3GPP UICC services over the new high-speed interface | milestone | 0d? | 2010-03-19 A | 2010-03-19 A | 100% | 2010-03-19 | 2010-03-19 | 0d? |  | C6 |  |  | UICCHS | PCG-21 | Gemalto | Denis.Lheriteau@gemalto.com | Rel-9 | CP-38 | Xavier | UICCHS | PCG-24 | CP-47 |  |  |
| 3425 | 875 | **Deleted - SAES Enhancements (non RAN aspects)** |  | 381d? | 2007-06-25 A | 2008-12-08 A | 100% | 2007-06-25 | 2008-12-08 | 381d? |  | S2 | 11664h | 11664h | SAES_Ph2 | PCG-21 | Nokia Siemens Networks |  | Rel-9 | SP-39 | Maurice | SAES_Ph2 | PCG-21 | SP-39 |  |  |
| 3426 | 875.1 | Deleted - Functions and procedures for SAE to support LTE MBMS |  | 381d? | 2007-06-25 A | 2008-12-08 A | 100% | 2007-06-25 | 2008-12-08 | 381d? | finish no earlier than 2008-12-08 | S2 | 3048h | 3048h | SAES_Ph2 |  |  |  | Rel-9 | SP-35 | Maurice |  | PCG-21 | SP-39 |  |  |
| 3427 | 875.2 | Deleted - CS over EPS |  | 194d? | 2008-03-12 A | 2008-12-08 A | 100% | 2008-03-12 | 2008-12-08 | 194d? | finish no earlier than 2008-12-08 | S2 | 1552h | 1552h | SAES_Ph2 | PCG-21 |  |  | Rel-9 | SP-39 | Maurice |  | PCG-21 | SP-39 |  |  |
| 3428 | 875.3 | **Deleted - SAE for generic support for non-3GPP accesses** |  | 251d? | 2007-06-25 A | 2008-06-09 A | 100% | 2007-06-25 | 2008-06-09 | 251d? |  | S2 | 4016h | 4016h | SAES_Ph2 | PCG-21 |  |  | Rel-9 | SP-39 | Maurice |  | PCG-21 | SP-39 |  |  |
| 3429 | 875.3.1 | Deleted - Single Radio Aspects of SAE for Optimized Handover with WiMAX |  | 251d? | 2007-06-25 A | 2008-06-09 A | 100% | 2007-06-25 | 2008-06-09 | 251d? | finish no earlier than 2008-06-09 | S2 | 2008h | 2008h | SAES_Ph2 | PCG-21 |  |  | Rel-9 | SP-39 | Maurice |  | PCG-21 | SP-39 |  |  |
| 3430 | 876 | Deleted - Lawful Interception in the 3GPP Rel-9 |  | 211d? | 2009-06-04 A | 2010-03-25 A | 100% | 2009-06-04 | 2010-03-25 | 211d? | finish no earlier than 2010-03-25 | S3 | 1688h | 1688h | LI9 | PCG-23 | PIDS, Nortel | Koen Jaspers, Ronald Ryan | Rel-9 | SP-44 | Mirko | LI9 | PCG-24 | SP-47 |  |  |
| 3431 | 877 | Release 9 Studies | milestone | 0d? | 2008-06-05 A | 2008-06-05 A | 100% | 2008-06-05 | 2010-03-19 | 468d? |  | CP; RP; SP |  |  |  |  |  |  | Rel-9 |  |  |  |  |  |  |  |
| 3432 | 878 | Study on Service Specific Access Control in EPS |  | 136d? | 2008-06-05 A | 2008-12-11 A | 100% | 2008-06-05 | 2008-12-11 | 136d? | start no earlier than 2008-06-05 | S1 | 1088h | 1088h | FS_SSAC | PCG-21 | NTT DoCoMo | Shin-ichi Isobe (isobes@nttdocomo.co.jp) | Rel-9 | SP-40 | Alain | FS_SSAC |  |  |  |  |
| 3433 | 879 | Study on CS Domain Services over EPS access |  | 492d? | 2007-04-25 A | 2009-03-12 A | 100% | 2007-04-25 | 2009-03-12 | 492d? | finish no earlier than 2009-03-12 | S2 | 3936h | 3936h | FS_CSoPS |  | T-Mobile | Karl-Heinz.Nenner@T-Mobile.net | Rel-9 | SP-35 | Maurice | FS_CSoPS |  |  |  |  |
| 3434 | 880 | Study on Extended Support of IMS Emergency Calls |  | 319d? | 2007-09-24 A | 2008-12-11 A | 100% | 2007-09-24 | 2008-12-11 | 319d? | finish no earlier than 2009-06-18 | S2 | 2552h | 2552h | FS_IMS-eCall |  | Qualcomm | Stephen Edge | Rel-9 | SP-37 | Maurice | FS_IMS-eCall |  |  | Public Safety (I-A) |  |
| 3435 | 881 | Study on Service Continuity for Emergency Voice Calls |  | 721d? | 2006-06-08 A | 2009-03-12 A | 100% | 2006-06-08 | 2009-03-12 | 721d? | finish no earlier than 2009-03-12 | S2 | 5768h | 5768h | FS_VCCEm |  | Nortel | Ricky Kaura (rkaura@nortel.com) | Rel-9 | SP-32 | Maurice | FS_VCCEm |  |  | Public Safety (I-A) |  |
| 3436 | 882 | Study on Security Aspects of Remote Provisioning and Change of Subscription for M2M Equipment |  | 1483.15d? | 2004-04-06 A | 2009-12-10 A | 100% | 2004-04-06 | 2009-12-10 | 1483.15d? | finish no earlier than 2009-12-10 | S3; C6 | 23730.4h | 23730.4h | FS_UM2M |  | Ericsson | vesa.lehtovirta@ericsson.com | Rel-9 | SP-37 | Mirko | FS_UM2M |  |  | MTC, M2M |  |
| 3437 | 883 | Study on System Maintenance over Itf-N |  | 602d? | 2007-06-07 A | 2009-09-24 A | 100% | 2007-06-07 | 2009-09-24 | 602d? | finish no earlier than 2009-09-24 | S5 | 4808h | 4808h | FS_OAM-Maint-Itf-N |  | ZTE | Shuqiang Huang (huangsq@zte.com.cn) | Rel-9 | SP-36 | Mirko | FS_OAM-Maint-Itf-N |  |  |  |  |
| 3438 | 884 | Study on Self-Organizing Networks (SON) related OAM interfaces for Home NodeB |  | 522d? | 2007-06-07 A | 2009-06-04 A | 100% | 2007-06-07 | 2009-06-04 | 522d? | finish no earlier than 2009-12-10 | S5 | 4168h | 4168h | FS_OAM-SON-HNB |  | Huawei | Zou Lan (zlan@huawei.com) | Rel-9 | SP-36 | Mirko | FS_OAM-SON-HNB |  |  | HNB, SON |  |
| 3439 | 885 | Study on Self-healing of Self-Organizing Networks (SON) |  | 416d? | 2008-02-22 A | 2009-09-24 A | 100% | 2008-02-22 | 2009-09-24 | 416d? | finish no earlier than 2009-09-24 | S5 | 3320.15h | 3320.15h | FS_OAM-SON-SH | PCG-21 | ZTE | zhu.weihong@zte.com.cn | Rel-9 | SP-39 | Mirko | FS_OAM-SON-SH |  |  | SON |  |
| 3440 | 886 | Study on Service Oriented Architecture (SOA) for IRP |  | 262d? | 2008-06-05 A | 2009-06-04 A | 100% | 2008-06-05 | 2009-06-04 | 262d? | finish no earlier than 2009-05-20 | S5 | 2088h | 2088h | FS_OAM_SOA_IRP | PCG-21 | Ericsson | edwin.tse@ericsson.com | Rel-9 | SP-40 | Mirko | FS_OAM_SOA_IRP |  |  |  |  |
| 3441 | 887 | Study on Evaluation of the inclusion of Path Loss Based Technology in the UTRAN |  | 516d? | 2007-12-17 A | 2009-12-04 A | 100% | 2007-12-17 | 2009-12-04 | 516d? | finish no earlier than 2009-09-18 | R4 | 4120h | 4120h | FS_RAN-Pathloss | PCG-21 | Polaris Wireless | Norman Shaw (nshaw@polariswireless.com) | Rel-9 | RP-38 | Issam | FS_RAN-Pathloss |  |  |  | RP-091080 |
| 3442 | 888 | Study on LTE-Advanced |  | 781.2d? | 2007-03-23 A | 2010-03-19 A | 100% | 2007-03-23 | 2010-03-19 | 781.2d? | finish no earlier than 2010-03-19 | R1; R2; R3; R4 | 24998.4h | 24998.4h | FS_RAN_LTEA | PCG-21 | NTT DoCoMo | Tetsushi Abe | Rel-9 | RP-39 | Patrick | FS_RAN_LTEA |  |  | CA | RP-100080 |
| 3443 | 889 | Study on 1.28 Mcps TDD Home NodeB |  | 387d? | 2008-02-20 A | 2009-12-04 A | 100% | 2008-02-20 | 2009-12-04 | 387d? | finish no earlier than 2009-12-04 | R4 | 3096h | 3096h | FS_RAN-HNBLCRTDD | PCG-21 | TD Tech | Li Rong (lirong@td-tech.com) | Rel-9 | RP-41 | Issam | FS_RAN-HNBLCRTDD |  |  | HNB | RP-091081 |
| 3444 | 890 | Study on E-UTRAN Mobility Evaluation and Enhancement |  | 126d? | 2008-12-05 A | 2009-05-29 A | 100% | 2008-12-05 | 2009-05-29 | 126d? | finish no earlier than 2009-05-29 | R1 | 1008h | 1008h | FS_EUTRAN_mob | PCG-22 | Qualcomm | Rajat Prakash (rprakash@qualcomm.com) | Rel-9 | RP-42 | Patrick | FS_EUTRAN_mob |  |  |  | RP-090426 |
| 3445 | 891 | Study on Minimization of drive-tests in Next Generation Networks |  | 196d? | 2009-03-06 A | 2009-12-04 A | 100% | 2009-03-06 | 2009-12-04 | 196d? | finish no earlier than 2009-12-04 | R2 | 1568h | 1568h | FS_NGN_min_drive-tests | PCG-22 | Qualcomm | Masato Kitazoe (mkitazoe@qualcomm.com) | Rel-9 | RP-43 | Yong-Jun | FS_NGN_min_drive-tests |  |  |  | RP-091084 |
| 3446 | 892 | Study on Enhanced Interference Management for HNBs |  | 61d? | 2009-03-06 A | 2009-05-29 A | 100% | 2009-03-06 | 2009-05-29 | 61d? | start no earlier than 2009-03-06 | R4 | 488h | 488h | FS_eInterfMgmt_HNB | PCG-22 | Qualcomm | Farhad Meshkati (fmeshkat@qualcomm.com) | Rel-9 | RP-43 | Issam | FS_eInterfMgmt_HNB |  |  | HNB | RP-090429 |
| 3447 | 893 | Study on Enhanced Interference Management Mechanisms for HNBs |  | 81d? | 2009-05-30 A | 2009-09-18 A | 100% | 2009-05-30 | 2009-09-18 | 81d? | finish no earlier than 2009-09-18 | R3 | 648h | 648h | FS_eInterfMgmtMchsm_HNB | PCG-23 | Qualcomm | Farhad Meshkati (fmeshkat@qualcomm.com) | Rel-9 | RP-44 | Juha | FS_eInterfMgmtMchsm_HNB |  |  | HNB | RP-090733 |
| 3448 | 894 | Deleted - Study on Protection against SMS and MMS spam |  | 862d? | 2006-06-08 A | 2009-09-24 A | 100% | 2006-06-08 | 2009-09-24 | 862d? | finish no earlier than 2009-09-24 | S3 | 6896h | 6896h | FS_CPSMal |  | Orange | eric.gauthier@orange.ch | Rel-9 | SP-32 | Mirko | FS_CPSMal | PCG-23 | SP-45 |  |  |
| 3449 | 895 | Release 8 Features |  | 914.3d? | 2006-09-19 A | 2010-03-19 A | 100% | 2006-09-19 | 2010-03-19 | 914.3d? | start no earlier than 2000-01-03 | CP; GP; RP; SP | 29257.6h | 29257.6h |  |  |  |  | Rel-8 |  |  |  |  |  |  |  |

Notes:
- 3413: CP#47 completed. GP#45 completed. GP#42 WID approved
- 3414: GP#45 completed. GP#42 WID approved / Impacted TSs and TRs: new 48.049
- 3415: CP#47 completed / Impacted TSs and TRs: 23.041
- 3416: GP#44 completed. GP#42 WID approved (Hybrid Integrated Location Technology=HILT) / Impacted TSs and TRs: 43.059, 48.071
- 3417: SP#46 completed
- 3418: GP#44 created
- 3419: SP#41 closed (no tangible result of this work; no CR against TR 22.983). Triggered by Study UID_370086 (FSServAl)
- 3420: SP#41 closed (no tangible result of this work; no CR against TR 22.983) / Impacted TSs and TRs: 22.983
- 3421: SP#43 stopped. LS_out to TISPAN informs about stopping this activity / Impacted TSs and TRs: 23.822, 23.203
- 3422: RP#39: No agreed WID / Impacted TSs and TRs: 36.306, 36.331, 36.413, 36.300, 36.214, 36.133, 36.304
- 3423: RP#39: No agreed WID / Impacted TSs and TRs: 25.306, 25.331, 25.413
- 3424: CP#47 work stopped/abandoned / Impacted TSs and TRs: 31.xyz
- 3425: SP#39 created to host Rel-9 Wis. BUT no agreed WID
- 3426: SP#39 SAE functionality moved to Rel-9. WID returned to SA2 for re-consideration & remove MBMS for EPS from Rel 8
- 3427: SP#39 SAE functionality moved to Rel-9. BUT no agreed WID
- 3428: SP#39 SAE functionality moved to Rel-9. BUT no agreed WID
- 3429: SP#39 SAE functionality moved to Rel-9. BUT no agreed WID
- 3430: SP#47 stopped. WI + new topics moved to Rel-10 / Impacted TSs and TRs: 33.106, 33.107, 33.108
- 3431: -
- 3432: SP#42 completed. Spin-off Feature UID_420020 (SSAC) / Impacted TSs and TRs: 22.986
- 3433: SP#43 completed. Linked to Combinational Services UID_31064, Services Alignment and Migration (ServAl) UID_330017 and 3GPP System Architecture Evolution (SAES) UID_3208 / Impacted TSs and TRs: 23.879
- 3434: SP#42 completed / Impacted TSs and TRs: 23.868
- 3435: SP#43 completed / Impacted TSs and TRs: 23.826
- 3436: SP#46 completed. Triggered by the SA1 Rel-8 Study on Facilitating Machine to Machine Communication in GSM and UMTS (FS_M2M) UID_7027 in TR 22.868. / Impacted TSs and TRs: 33.812
- 3437: SP#45 completed / Impacted TSs and TRs: 32.822
- 3438: SP#44 completed. Linked to SA5 TR 32.816 Study of Management for LTE and SAE (UID_340036) / Impacted TSs and TRs: 32.821
- 3439: SP#45 completed. Linked to SA5 TR 32.816 Study of Management for LTE and SAE (UID_340036) / Impacted TSs and TRs: 32.823
- 3440: SP#44 completed. Spin-off implementation WI UID_440064 Service Oriented Architecture (SOA) for IRP / Impacted TSs and TRs: 32.824
- 3441: RP#46 completed / Impacted TSs and TRs: 25.907
- 3442: RP#47 completed / Impacted TSs and TRs: 36.913 , New 36.814, 36.912, R2 36.806 (Relay architectures for E-UTRA), R4 36.815 (LTE-Advanced feasibility studies in RAN4)
- 3443: RP#46 completed / Impacted TSs and TRs: 25.866
- 3444: RP#44 closed (RP-090452 R1 LS to RAN on Conclusions for LTE Mobility Study Item - no further Rel-9 action / no TR needed) / Impacted TSs and TRs: none
- 3445: RP#46 completed / Impacted TSs and TRs: 36.805
- 3446: RP#44 completed. Linked to UID_420008 LTE FDD Home eNodeB RF Requirements. Spin-off RAN3 UID_440015 Study on Enhanced Interference Management Mechanisms for HNBs / Impacted TSs and TRs: 25.967
- 3447: RP#45 completed. Triggered by RAN4 UID_430027 Study on Enhanced Interference Management for HNBs / Impacted TSs and TRs: 25.967
- 3448: SP#45 work stopped/abandoned / Impacted TSs and TRs: 33.9xx
- 3449: -

| ID | WBS | Task | Duration | Start | Finish | Complete | Remaining | Baseline start | Baseline finish | Baseline duration | Total slack | Constraint | Resources | Work | Actual work | Acronym | WI rapporteur name | WI rapporteur e-mail | Release | TSG approved | MCC resp | Acronym_3GU_Export | PCG approved |
| --- | --- | --- | --- | --- | --- | --- | --- | --- | --- | --- | --- | --- | --- | --- | --- | --- | --- | --- | --- | --- | --- | --- | --- |
| 3450 | 896 | **3GPP System Architecture Evolution Specification - Evolved Packet System (non RAN aspects)** | 1618d? | 2006-04-12 A | 2012-06-15 | 99% | 0d? | 2006-04-12 | 2012-06-15 | 1618d? | 0d |  | S1; S2; S3; S5; C1; C3; C4; C6; IETF | 512323h | 510115h | SAES | T-Mobile | michael.kurz@t-mobile.at | Rel-8 | TSG-32 | Alain | SAES |  |
| 3451 | 896.1 | Requirements for evolution of the 3GPP system architecture | 395d? | 2006-06-08 A | 2007-12-12 A | 100% |  | 2006-06-08 | 2007-12-12 | 395d? |  | finish no earlier than 2007-11-30 | S1 | 3160h | 3160h | AIPN-SAE | T-Mobile | michael.kurz@t-mobile.at | Rel-8 | TSG-32 | Alain | AIPN-SAE |  |
| 3452 | 896.2 | **High level and common (for all accesses) functions** | 629d? | 2007-01-02 A | 2009-05-29 A | 100% |  | 2007-01-02 | 2009-05-29 | 629d? |  |  | S2; S3; C1; C3; C4 | 62664h | 62664h | EPS-ComF | Nokia Siemens Networks | balazs.bertenyi@nsn.com | Rel-8 | SP-37 | Maurice | EPS-ComF |  |
| 3453 | 896.2.1 | Stage 2 for High level functions | 370d? | 2007-01-02 A | 2008-06-02 A | 100% |  | 2007-01-02 | 2008-06-02 | 370d? |  | finish no earlier than 2008-06-02 | S2 | 2960h | 2960h | SAES-SA-HLF | Motorola | Irfan.Ali@motorola.com | Rel-8 | TSG-35 | Maurice | SAES-SA-HLF |  |
| 3454 | 896.2.2 | Stage 2 Security Architecture | 197d? | 2008-03-12 A | 2008-12-11 A | 100% |  | 2008-03-12 | 2008-12-11 | 197d? |  | finish no earlier than 2008-12-11 | S3 | 1576h | 1576h | SAES | Nokia Siemens Networks | marc.blommaert.ext@nsn.com | Rel-8 | SP-39 | Mirko |  | PCG-21 |
| 3455 | 896.2.3 | Stage 3 (CT1) for SAE impact on services, network functions and capabilities | 545d? | 2007-02-05 A | 2009-03-06 A | 100% |  | 2007-02-05 | 2009-03-06 | 545d? |  | finish no earlier than 2009-03-06 | C1 | 4360h | 4360h | SAES | Nokia Siemens Networks | robert.zaus@nsn.com | Rel-8 | TSG-34 | Frederic |  |  |
| 3456 | 896.2.4 | Stage 3 SAE impact on existing capabilities | 480d? | 2007-02-05 A | 2008-12-05 A | 100% |  | 2007-02-05 | 2008-12-05 | 480d? |  | finish no earlier than 2008-12-12 | C3 | 3840h | 3840h | SAES | Huawei | Wei Weihua (weiwh@huawei.com) | Rel-8 | TSG-34 | Adrian |  |  |
| 3457 | 896.2.5 | Stage 3 (CT4) of SAE impact on existing capabilities | 545d? | 2007-02-05 A | 2009-03-06 A | 100% |  | 2007-02-05 | 2009-03-06 | 545d? |  | finish no earlier than 2009-03-06 | C4 | 4360h | 4360h | SAES | Huawei | shahab.lavasani@huawei.com | Rel-8 | TSG-34 | Kimmo |  |  |
| 3458 | 896.2.6 | Stage 2/3 for Network selection procedures | 480d? | 2007-02-05 A | 2008-12-05 A | 100% |  | 2007-02-05 | 2008-12-05 | 480d? |  | finish no earlier than 2009-03-06 | C1 | 3840h | 3840h | SAES | Nokia Siemens Networks | robert.zaus@nsn.com | Rel-8 | TSG-34 | Frederic |  |  |
| 3459 | 896.2.7 | Stage 3 EPC interworking with external PDNs (SGi) | 605d? | 2007-02-05 A | 2009-05-29 A | 100% |  | 2007-02-05 | 2009-05-29 | 605d? |  | finish no earlier than 2009-05-29 | C3 | 4840h | 4840h | SAES-St3-intwk | Huawei | Wei Weihua (weiwh@huawei.com) | Rel-8 | TSG-34 | Adrian | SAES-St3-intwk |  |
| 3460 | 896.2.8 | Stage 3 PCC within SAE | 605d? | 2007-02-05 A | 2009-05-29 A | 100% |  | 2007-02-05 | 2009-05-29 | 605d? |  | finish no earlier than 2009-05-29 | C3 | 4840h | 4840h | SAES-St3-PCC | Ericsson | j.javier.pastor@ericsson.com | Rel-8 | TSG-34 | Adrian | SAES-St3-PCC |  |
| 3461 | 896.2.9 | Stage 3 for SAE / LTE identities | 545d? | 2007-02-05 A | 2009-03-06 A | 100% |  | 2007-02-05 | 2009-03-06 | 545d? |  | finish no earlier than 2009-03-06 | C4 | 4360h | 4360h | SAES | Huawei | shahab.lavasani@huawei.com | Rel-8 | TSG-34 | Kimmo |  |  |
| 3462 | 896.2.10 | Unified guidelines for Diameter usage within 3GPP | 316d? | 2007-09-21 A | 2008-12-05 A | 100% |  | 2007-09-21 | 2008-12-05 | 316d? |  | finish no earlier than 2008-12-05 | C3 | 2528h | 2528h | SAES-DIAM | Huawei | Javier Gonzalez Gallego | Rel-8 | CP-37 | Adrian | SAES-DIAM |  |
| 3463 | 896.3 | **SAE for LTE access** | 569d? | 2007-01-02 A | 2009-03-06 A | 100% |  | 2007-01-02 | 2009-03-06 | 569d? |  |  | S2; C1; C3; C4 | 80584h | 80584h | SAES-LTE | Motorola | Irfan.Ali@motorola.com | Rel-8 | TSG-35 | Maurice | SAES-LTE |  |
| 3464 | 896.3.1 | CT4 Stage 3 for protocol between EPCs | 545d? | 2007-02-05 A | 2009-03-06 A | 100% |  | 2007-02-05 | 2009-03-06 | 545d? |  | finish no earlier than 2009-03-06 | C4 | 4360h | 4360h | SAES-LTE | Huawei | shahab.lavasani@huawei.com | Rel-8 | TSG-34 | Kimmo |  |  |
| 3465 | 7.2.2.1 | **SAES-SA-FP_LTE with GTP variant** | 569d? | 2007-01-02 A | 2009-03-06 A | 100% |  | 2007-01-02 | 2009-03-06 | 569d? |  |  | S2; C4 | 16448h | 16448h | SAES-SA-FP_LTE-GTP | Nokia Siemens Networks | balazs.bertenyi@nsn.com | Rel-8 | TSG-35 | Maurice | SAES-SA-FP_LTE-GTP |  |
| 3466 | 896.3.2.1 | Stage 2 for SAES-SA-FP_LTE with GTP variant | 373d? | 2007-01-02 A | 2008-06-05 A | 100% |  | 2007-01-02 | 2008-06-05 | 373d? |  | finish no earlier than 2008-06-02 | S2 | 2984h | 2984h | SAES-SA-FP_LTE-GTP-St2 | Nokia Siemens Networks | balazs.bertenyi@nsn.com | Rel-8 | TSG-37 | Maurice | SAES-SA-FP_LTE-GTP-St2 |  |
| 3467 | 896.3.2.2 | CT4 Stage 3 for GTP v2 protocol | 545d? | 2007-02-05 A | 2009-03-06 A | 100% |  | 2007-02-05 | 2009-03-06 | 545d? |  | finish no earlier than 2009-03-06 | C4 | 4360h | 4360h | SAES-SA-FP_LTE-GTP | Huawei | shahab.lavasani@huawei.com | Rel-8 | TSG-34 | Kimmo | SAES-SA-FP_LTE-GTP |  |
| 3468 | 7.2.2.2 | **SAES-SA-FP_LTE with PMIP variant** | 569d? | 2007-01-02 A | 2009-03-06 A | 100% |  | 2007-01-02 | 2009-03-06 | 569d? |  |  | S2; C4 | 20288h | 20288h | SAES-SA-FP_LTE-IETF | Nokia Siemens Networks | balazs.bertenyi@nsn.com | Rel-8 | TSG-34 | Maurice | SAES-SA-FP_LTE-IETF |  |
| 3469 | 896.3.3.1 | Stage 2 for SAES-SA-FP_LTE with PMIP variant | 373d? | 2007-01-02 A | 2008-06-05 A | 100% |  | 2007-01-02 | 2008-06-05 | 373d? |  | finish no earlier than 2008-06-02 | S2 | 2984h | 2984h | SAES-SA-FP_LTE-IETF-St2 | Nokia Siemens Networks | balazs.bertenyi@nsn.com | Rel-8 | TSG-37 | Maurice | SAES-SA-FP_LTE-IETF-St2 |  |
| 3470 | 896.3.3.2 | CT4 Stage 3 for PMIP protocol within EPC | 545d? | 2007-02-05 A | 2009-03-06 A | 100% |  | 2007-02-05 | 2009-03-06 | 545d? |  | finish no earlier than 2009-03-06 | C4 | 4360h | 4360h | SAES-SA-FP_LTE-IETF | Huawei | shahab.lavasani@huawei.com | Rel-8 | CP-37 | Kimmo | SAES-SA-FP_LTE-IETF |  |
| 3471 | 896.3.3.3 | Mobile IPv4 (MIPv4) based Mobility protocols | 480d? | 2007-02-05 A | 2008-12-05 A | 100% |  | 2007-02-05 | 2008-12-05 | 480d? |  | finish no earlier than 2008-12-05 | C4 | 3840h | 3840h | SAES-SA-FP_LTE-IETF | Motorola | Lewis Milton | Rel-8 | CP-41 | Kimmo |  |  |
| 3472 | 896.3.4 | Stage 3 for UE Non-Access-Stratum (NAS) mobility procedures in idle and active mode | 545d? | 2007-02-05 A | 2009-03-06 A | 100% |  | 2007-02-05 | 2009-03-06 | 545d? |  | finish no earlier than 2009-03-06 | C1 | 4360h | 4360h | SAES-LTE | Nokia Siemens Networks | robert.zaus@nsn.com | Rel-8 | TSG-34 | Frederic |  |  |
| 3473 | 896.3.5 | Stage 3 for Session management, bearer control and QoS aspects | 545d? | 2007-02-05 A | 2009-03-06 A | 100% |  | 2007-02-05 | 2009-03-06 | 545d? |  | finish no earlier than 2009-03-06 | C1 | 4360h | 4360h | SAES-LTE | Nokia Siemens Networks | robert.zaus@nsn.com | Rel-8 | TSG-34 | Frederic |  |  |
| 3474 | 896.3.6 | Stage 3 for security aspects of LTE Access | 545d? | 2007-02-05 A | 2009-03-06 A | 100% |  | 2007-02-05 | 2009-03-06 | 545d? |  | finish no earlier than 2009-03-06 | C1 | 4360h | 4360h | SAES-LTE | Nokia Siemens Networks | robert.zaus@nsn.com | Rel-8 | TSG-34 | Frederic |  |  |
| 3475 | 896.3.7 | Stage 3 for QoS mechanisms | 480d? | 2007-02-05 A | 2008-12-05 A | 100% |  | 2007-02-05 | 2008-12-05 | 480d? |  | finish no earlier than 2008-12-12 | C3 | 3840h | 3840h | SAES-LTE | Ericsson | j.javier.pastor@ericsson.com | Rel-8 | TSG-34 | Adrian |  |  |
| 3476 | 896.3.8 | Stage 3 for EPC - HSS interface | 545d? | 2007-02-05 A | 2009-03-06 A | 100% |  | 2007-02-05 | 2009-03-06 | 545d? |  | finish no earlier than 2009-03-06 | C4 | 4360h | 4360h | SAES-LTE | Huawei | shahab.lavasani@huawei.com | Rel-8 | TSG-34 | Kimmo |  |  |

Notes:
- 3450: Role model for SAE/LTE system wide project management by SA2 in SP-060166
- 3451: SP#38 completed / Impacted TSs and TRs: 22.011, 22.246, New 22.278
- 3452: CP#44 completed
- 3453: SP#40 completed / Impacted TSs and TRs: New 23.402
- 3454: SP#42 completed / Impacted TSs and TRs: 33.210, 33.310, New 33.401
- 3455: CP#43 completed / Impacted TSs and TRs: 24.229, 27.007, New 24.305
- 3456: CP#42 completed / Impacted TSs and TRs: 29.061
- 3457: CP#43 completed / Impacted TSs and TRs: New (29.274, 29.275)
- 3458: CP#42 completed / Impacted TSs and TRs: 23.122, New 24.302
- 3459: CP#44 completed / Impacted TSs and TRs: 29.061
- 3460: CP#44 completed / Impacted TSs and TRs: 29.212, 29.213, 29.214, New 29.215
- 3461: CP#43 completed / Impacted TSs and TRs: 23.003
- 3462: CP#42 completed / Impacted TSs and TRs: New 29.909
- 3463: CP#43 completed
- 3464: CP#43 completed / Impacted TSs and TRs: 29.274, 29.275
- 3465: CP#43 completed
- 3466: SP#40 completed / Impacted TSs and TRs: 23.401, 23.060, 23.002, 23.246, 23.203, 23.107, 23.234, 23.271
- 3467: CP#43 completed / Impacted TSs and TRs: 29.274
- 3468: CP#43 completed
- 3469: SP#40 completed
- 3470: CP#43 completed / Impacted TSs and TRs: 29.275, 29.282
- 3471: CP#42 completed / Impacted TSs and TRs: 29.279
- 3472: CP#43 completed / Impacted TSs and TRs: 24.007, 24.301
- 3473: CP#43 completed / Impacted TSs and TRs: 24.007, 24.301
- 3474: CP#43 completed / Impacted TSs and TRs: 24.008, 24.301
- 3475: CP#42 completed / Impacted TSs and TRs: 29.213
- 3476: CP#43 completed / Impacted TSs and TRs: 29.272

| ID | WBS | Task | Type | Duration | Start | Finish | Complete | Baseline start | Baseline finish | Baseline duration | Constraint | Resources | Work | Actual work | Acronym | WI rapporteur name | WI rapporteur e-mail | Release | TSG approved | MCC resp | Acronym_3GU_Export | Impacted TSs and TRs | PCG approved | TSG stopped |
| --- | --- | --- | --- | --- | --- | --- | --- | --- | --- | --- | --- | --- | --- | --- | --- | --- | --- | --- | --- | --- | --- | --- | --- | --- |
| 3477 | 896.4 | **SAE for Interoperation between LTE and legacy cellular PS accesses** |  | 545d? | 2007-02-05 A | 2009-03-06 A | 100% | 2007-02-05 | 2009-03-06 | 545d? |  | S2; C1; C4 | 48872h | 48872h | SAES-SA-FP_3GPP | Motorola | Irfan.Ali@motorola.com | Rel-8 | TSG-35 | Maurice | SAES-SA-FP_3GPP |  |  |  |
| 3478 | 896.4.1 | Stage 2 for Interoperation between LTE and 2G/3G |  | 424d? | 2007-02-05 A | 2008-09-18 A | 100% | 2007-02-05 | 2008-09-18 | 424d? | finish no earlier than 2008-09-11 | S2 | 3392h | 3392h | EPSto2_3G | Motorola | Irfan.Ali@motorola.com | Rel-8 | SP-37 | Maurice | EPSto2_3G | 23.401, 23.402 |  |  |
| 3479 | 896.4.2 | Stage 3 for Inter-system mobility between E-UTRAN and 2G/3G |  | 545d? | 2007-02-05 A | 2009-03-06 A | 100% | 2007-02-05 | 2009-03-06 | 545d? | finish no earlier than 2009-03-06 | C1 | 4360h | 4360h | SAES-SA-FP_3GPP | Nokia Siemens Networks | robert.zaus@nsn.com | Rel-8 | CP-38 | Frederic | SAES-SA-FP_3GPP | 24.008, 24.301 | PCG-21 |  |
| 3480 | 896.4.3 | Stage 2 GPRS enhancements for LTE access |  | 272d? | 2007-09-04 A | 2008-09-18 A | 100% | 2007-09-04 | 2008-09-18 | 272d? | start no earlier than 2007-09-04 | S2 | 2176h | 2176h | SAES-GPRS_LTE | Vodafone | chris.pudney@vodafone.com | Rel-8 | TSG-34 | Maurice | SAES-GPRS_LTE | 23.401 |  |  |
| 3481 | 896.4.4 | Stage 2 GPRS for EPC (23.060, etc.) |  | 179d? | 2008-01-14 A | 2008-09-18 A | 100% | 2008-01-14 | 2008-09-18 | 179d? | finish no earlier than 2008-09-18 | S2 | 1432h | 1432h | SAES-SA-FP_3GPP | Nokia Siemens Networks | balazs.bertenyi@nsn.com | Rel-8 | SP-39 | Maurice |  | 23.060 | PCG-21 |  |
| 3482 | 896.4.5 | Stage 3 for EPC - GPRS |  | 545d? | 2007-02-05 A | 2009-03-06 A | 100% | 2007-02-05 | 2009-03-06 | 545d? | finish no earlier than 2009-03-06 | C4 | 4360h | 4360h | SAES-SA-FP_3GPP | Huawei | shahab.lavasani@huawei.com | Rel-8 | TSG-34 | Kimmo |  | 29.274, 29.275, 29.281 |  |  |
| 3483 | 896.4.6 | Stage 3 for EPC to UTRAN |  | 545d? | 2007-02-05 A | 2009-03-06 A | 100% | 2007-02-05 | 2009-03-06 | 545d? | finish no earlier than 2009-03-06 | C4 | 4360h | 4360h | SAES-SA-FP_3GPP | Huawei | shahab.lavasani@huawei.com | Rel-8 | CP-38 | Kimmo |  | 29.274, 29.275, 29.281 | PCG-21 |  |
| 3484 | 896.4.7 | Stage 3 for EPC to 3GPP2 |  | 545d? | 2007-02-05 A | 2009-03-06 A | 100% | 2007-02-05 | 2009-03-06 | 545d? | finish no earlier than 2009-03-06 | C4 | 4360h | 4360h | SAES-SA-FP_3GPP | Huawei | shahab.lavasani@huawei.com | Rel-8 | CP-38 | Kimmo |  | 29.277, 29.276 | PCG-21 |  |
| 3485 | 896.4.8 | Stage 2 for Interoperation between LTE and CDMA2000 |  | 329d? | 2007-06-18 A | 2008-09-18 A | 100% | 2007-06-18 | 2008-09-18 | 329d? | finish no earlier than 2008-04-25 | S2 | 2632h | 2632h | EPStoC2k | Motorola, Vodafone | Irfan.Ali@motorola.com, chris.pudney@vodafone.com | Rel-8 | CP-37 | Maurice | EPStoC2k | 23.401, 23.402 |  |  |
| 3486 | 896.4.9 | Stage 3 for Inter-system mobility between E-UTRAN and CDMA2000 |  | 545d? | 2007-02-05 A | 2009-03-06 A | 100% | 2007-02-05 | 2009-03-06 | 545d? | finish no earlier than 2009-03-06 | C1 | 4360h | 4360h | SAES-SA-FP_3GPP | Nokia Siemens Networks | robert.zaus@nsn.com | Rel-8 |  | Frederic |  | 24.301, 24.302 |  |  |
| 3487 | 896.4.10 | Stage 3 for MME - SGSN signalling free protocol |  | 545d? | 2007-02-05 A | 2009-03-06 A | 100% | 2007-02-05 | 2009-03-06 | 545d? | finish no earlier than 2009-03-06 | C4 | 4360h | 4360h | SAES-SA-FP_3GPP | Huawei | shahab.lavasani@huawei.com | Rel-8 | TSG-34 | Kimmo |  | 29.272, 29.274 |  |  |
| 3488 | 896.5 | **SAE for support for non-3GPP accesses** |  | 1429d? | 2007-01-02 A | 2012-06-15 A | 100% | 2007-01-02 | 2012-06-15 | 1429d? |  | S2; S3; C1; C4; IETF | 123829h | 123829h | SAES-SA-FP_n3GPP | Motorola | Irfan.Ali@motorola.com | Rel-8 | TSG-35 | Maurice | SAES-SA-FP_n3GPP |  |  |  |
| 3489 | 7.2.4.1 | Stage 2 for Host-based Mobility aspects |  | 373d? | 2007-01-02 A | 2008-06-05 A | 100% | 2007-01-02 | 2008-06-05 | 373d? | finish no earlier than 2008-04-11 | S2 | 2984h | 2984h | SAES-SA-FP_n3GPP-HBMob | Motorola | Irfan.Ali@motorola.com | Rel-8 |  | Maurice | SAES-SA-FP_n3GPP-HBMob | 23.402 |  |  |
| 3490 | 7.2.4.2 | Stage 2 for Network-based Mobility aspects |  | 448d? | 2007-01-02 A | 2008-09-18 A | 100% | 2007-01-02 | 2008-09-18 | 448d? | finish no earlier than 2008-09-18 | S2 | 3584h | 3584h | SAES-SA-FP_n3GPP-NBMob | Motorola | Irfan.Ali@motorola.com | Rel-8 |  | Maurice | SAES-SA-FP_n3GPP-NBMob | 23.402 |  |  |
| 3491 | 896.5.3 | Stage 3 for Mobility management based on DSMIPv6 |  | 480d? | 2007-02-05 A | 2008-12-05 A | 100% | 2007-02-05 | 2008-12-05 | 480d? | finish no earlier than 2008-12-05 | C1 | 3840h | 3840h | SAES-SA-FP_n3GPP | Nokia Siemens Networks | robert.zaus@nsn.com | Rel-8 |  | Frederic |  | 24.303 |  |  |
| 3492 | 896.5.4 | (IETF) Stage 3 for Mobility management based on DSMIPv6 (draft-ietf-mip6-hiopt) |  | 589d? | 2007-02-05 A | 2012-06-15 A | 100% | 2007-02-05 | 2012-06-15 | 589d? | finish no earlier than 2012-09-14 | C1-IETF | 4712h | 4712h | SAES-SA-FP_n3GPP | Mark Jones |  | Rel-8 | CP-52 | Frederic |  | RFC 6610 (was draft-ietf-mip6-hiopt) | PCG-27 |  |
| 3493 | 896.5.5 | (IETF) Stage 3 for Mobility management based on DSMIPv6 (RFC6275) |  | 356d? | 2007-02-05 A | 2011-07-29 A | 100% | 2007-02-05 | 2011-07-29 | 356d? | finish no earlier than 2011-07-29 | C1-IETF | 2848h | 2848h | SAES-SA-FP_n3GPP |  |  | Rel-8 | CP-52 | Frederic |  | RFC 6275 (was draft-ietf-mext-rfc3775bis) | PCG-27 |  |
| 3494 | 896.5.6 | Stage 3 for Mobility management based on MIP v4 |  | 480d? | 2007-02-05 A | 2008-12-05 A | 100% | 2007-02-05 | 2008-12-05 | 480d? | start no earlier than 2007-02-05 | C1 | 3840h | 3840h | SAES-SA-FP_n3GPP | Nokia Siemens Networks | robert.zaus@nsn.com | Rel-8 | CP-39 | Frederic |  | 24.304 | PCG-21 |  |
| 3495 | 896.5.7 | Stage 3 for Inter-system mobility between E-UTRAN and non 3GPP accesses |  | 545d? | 2007-02-05 A | 2009-03-06 A | 100% | 2007-02-05 | 2009-03-06 | 545d? | finish no earlier than 2009-03-06 | C1 | 4360h | 4360h | SAES-SA-FP_n3GPP | Nokia Siemens Networks | robert.zaus@nsn.com | Rel-8 | CP-38 | Frederic |  | 24.008, 24.301 | PCG-21 |  |
| 3496 | 896.5.8 | Stage 2 for Optimized Dual-Radio Handover with WiMAX |  | 249d? | 2007-06-25 A | 2008-06-05 A | 100% | 2007-06-25 | 2008-06-05 | 249d? | finish no earlier than 2008-06-09 | S2 | 1992h | 1992h | SAES-SA-FP_n3GPP-OptWIMAX | Motorola | Irfan.Ali@motorola.com | Rel-8 |  | Maurice | SAES-SA-FP_n3GPP-OptWIMAX | 23.402 |  |  |
| 3497 | 896.5.9 | Stage 2 Security aspects for non-3GPP Access |  | 197d? | 2008-03-12 A | 2008-12-11 A | 100% | 2008-03-12 | 2008-12-11 | 197d? | finish no earlier than 2008-12-11 | S3 | 1576h | 1576h | SAES-SA-FP_n3GPP | Nokia Siemens Networks | marc.blommaert.ext@nsn.com | Rel-8 | SP-39 | Mirko |  | 33.402, 33.210, 33.310 | PCG-21 |  |
| 3498 | 896.5.10 | Stage 3 security aspects for DSMIPv6 Access |  | 480d? | 2007-02-05 A | 2008-12-05 A | 100% | 2007-02-05 | 2008-12-05 | 480d? | finish no earlier than 2008-12-05 | C1 | 3840h | 3840h | SAES-SA-FP_n3GPP | Nokia Siemens Networks | robert.zaus@nsn.com | Rel-8 | CP-37 | Frederic |  | 24.303 |  |  |
| 3499 | 896.5.11 | Stage 3 security aspects for MIPv4 Access |  | 480d? | 2007-02-05 A | 2008-12-05 A | 100% | 2007-02-05 | 2008-12-05 | 480d? | finish no earlier than 2008-12-05 | C1 | 3840h | 3840h | SAES-SA-FP_n3GPP | Nokia Siemens Networks | robert.zaus@nsn.com | Rel-8 | CP-39 | Frederic |  | 24.304 | PCG-21 |  |
| 3500 | 896.5.12 | Stage 3 for Access to the EPC via non-3GPP access networks |  | 545d? | 2007-02-05 A | 2009-03-06 A | 100% | 2007-02-05 | 2009-03-06 | 545d? | finish no earlier than 2009-03-06 | C1 | 4360h | 4360h | SAES-SA-FP_n3GPP | Nokia Siemens Networks | robert.zaus@nsn.com | Rel-8 |  | Frederic |  | 24.302, 24.312 |  |  |
| 3501 | 896.5.13 | Stage 3 for interfaces within EPC |  | 383d? | 2007-09-19 A | 2009-03-06 A | 100% | 2007-09-19 | 2009-03-06 | 383d? | finish no earlier than 2009-03-06 | C4 | 3064h | 3064h | SAES-SA-FP_n3GPP | Huawei | shahab.lavasani@huawei.com | Rel-8 | CP-37 | Kimmo |  | 29.274, 29.281 |  |  |
| 3502 | 896.5.14 | Stage 3 for Interfaces EPC - non-3GPP IP access |  | 545d? | 2007-02-05 A | 2009-03-06 A | 100% | 2007-02-05 | 2009-03-06 | 545d? | finish no earlier than 2009-03-06 | C4 | 4360h | 4360h | SAES-SA-FP_n3GPP | Huawei | shahab.lavasani@huawei.com | Rel-8 | TSG-34 | Kimmo |  | 29.273, 29.275 |  |  |
| 3503 | 896.5.15 | (IETF) Stage 3 for Interfaces EPC - non-3GPP IP access |  | 1224.6d? | 2007-02-05 A | 2012-06-15 A | 100% | 2007-02-05 | 2012-06-15 | 1224.6d? | finish no earlier than 2012-06-15 | C4-IETF | 9788.8h | 9788.8h | SAES-SA-FP_n3GPP | Lionel Morand |  | Rel-8 | CP-52 | Kimmo |  | RFC 6611 (was draft-ietf-mip6-bootstrapping-integrated) | PCG-27 |  |
| 3504 | 896.5.16 | Stage 3 for AAA/HSS related |  | 480d? | 2007-02-05 A | 2008-12-05 A | 100% | 2007-02-05 | 2008-12-05 | 480d? | finish no earlier than 2008-12-05 | C4 | 3840h | 3840h | SAES-SA-FP_n3GPP | Huawei | shahab.lavasani@huawei.com | Rel-8 | TSG-34 | Kimmo |  | 29.273 |  |  |
| 3505 | 896.5.17 | Stage 3 for EPC - AAA interface |  | 480d? | 2007-02-05 A | 2008-12-05 A | 100% | 2007-02-05 | 2008-12-05 | 480d? | finish no earlier than 2008-12-05 | C4 | 3840h | 3840h | SAES-SA-FP_n3GPP | Huawei | shahab.lavasani@huawei.com | Rel-8 | TSG-34 | Kimmo |  | 29.273 |  |  |
| 3506 | 896.5.18 | Deleted (already covered) SAES-SA-FP_n3GPP Optimized Handover with CDMA | milestone | 0d? | 2007-06-25 A | 2007-06-25 A | 100% | 2007-06-25 | 2007-06-25 | 0d? | finish no earlier than 2007-06-25 | S2 |  |  | SAES-SA-FP_n3GPP-OptCDMA | Nokia Siemens Networks |  | Rel-8 |  | Maurice | SAES-SA-FP_n3GPP-OptCDMA |  |  | SP-37 |

Notes:
- 3477: CP#43 completed
- 3478: SP#41 completed
- 3479: CP#43 completed
- 3480: SP#41 completed
- 3481: SP#41 completed
- 3482: CP#43 completed
- 3483: CP#43 completed
- 3484: CP#43 completed
- 3485: SP#41 completed (except: Handover of multiple PDNs=>Rel-9)
- 3486: CP#43 completed
- 3487: CP#43 completed
- 3488: CP#43 completed. SP#39 retained in Rel-8 (in addition to the essential functionality defined in SP-070699). Replaces UID_340037
- 3489: SP#40 completed
- 3490: SP#41 completed
- 3491: CP#42 completed
- 3492: CP#56 completed
- 3493: SP#53/IETF#81 completed
- 3494: CP#42 completed
- 3495: CP#43 completed
- 3496: SP#40 completed
- 3497: SP#42 completed
- 3498: CP#42 completed
- 3499: CP#42 completed
- 3500: CP#43 completed
- 3501: CP#43 completed
- 3502: CP#43 completed
- 3503: CP#56 completed
- 3504: CP#42 completed
- 3505: CP#42 completed
- 3506: SP#37 stopped

| ID | WBS | Task | Type | Duration | Start | Finish | Complete | Baseline start | Baseline finish | Baseline duration | Constraint | Resources | Work | Actual work | Acronym | WI rapporteur name | Release | MCC resp | Acronym_3GU_Export | Impacted TSs and TRs | PCG approved | TSG approved | PCG stopped | TSG stopped | Special Focus Doc |
| --- | --- | --- | --- | --- | --- | --- | --- | --- | --- | --- | --- | --- | --- | --- | --- | --- | --- | --- | --- | --- | --- | --- | --- | --- | --- |
| 3507 | 896.6 | **Single Radio Voice Call Continuity for 3GPP (SRVCC)** |  | 569d? | 2007-01-02 A | 2009-03-06 A | 100% | 2007-01-02 | 2009-03-06 | 569d? |  | S2; C1; C4 | 19856h | 19856h | SAES-SRVCC | Nokia Siemens Networks | Rel-8 | Maurice | SAES-SRVCC |  |  |  |  |  |  |
| 3508 | 896.6.1 | Stage 2 for 2G/3G SRVCC |  | 448d? | 2007-01-02 A | 2008-09-18 A | 100% | 2007-01-02 | 2008-09-18 | 448d? | finish no earlier than 2008-09-15 | S2 | 3584h | 3584h | SAES-SRVCC | Nokia Siemens Networks | Rel-8 | Maurice |  | New 23.216 |  |  |  |  |  |
| 3509 | 896.6.2 | Stage 3 for SRVCC in EPS |  | 201d? | 2008-05-30 A | 2009-03-06 A | 100% | 2008-05-30 | 2009-03-06 | 201d? | finish no earlier than 2009-03-06 | C1 | 1608h | 1608h | SAES-SRVCC | Nokia Siemens Networks | Rel-8 | Frederic |  | 23.009, 24.008, New 24.301 | PCG-21 | CP-41 |  |  |  |
| 3510 | 896.6.3 | MME to MSC interface for SRVCC |  | 126d? | 2008-09-12 A | 2009-03-06 A | 100% | 2008-09-12 | 2009-03-06 | 126d? | finish no earlier than 2009-03-06 | C4 | 1008h | 1008h | SAES-SRVCC | Nokia Siemens Networks | Rel-8 | Kimmo |  | 23.003, 23.008, New (29.274, 29.277, 29.280) | PCG-21 | CP-41 |  |  |  |
| 3511 | 896.7 | Voice Call Continuity for CDMA2000 1X |  | 249d? | 2007-06-25 A | 2008-06-05 A | 100% | 2007-06-25 | 2008-06-05 | 249d? | finish no earlier than 2008-06-13 | S2 | 1992h | 1992h | SAES-VCC_1X | Nokia Siemens Networks | Rel-8 | Maurice | SAES-VCC_1X |  |  |  |  |  |  |
| 3512 | 896.8 | SAE impacts on IMS |  | 373d? | 2007-01-02 A | 2008-06-05 A | 100% | 2007-01-02 | 2008-06-05 | 373d? | finish no earlier than 2008-06-13 | S2 | 2984h | 2984h | SAES-SA_IMS | Nokia Siemens Networks | Rel-8 | Maurice | SAES-SA_IMS |  |  |  |  |  |  |
| 3513 | 896.9 | **CS Fallback in EPS** |  | 258d? | 2008-03-12 A | 2009-03-06 A | 100% | 2008-03-12 | 2009-03-06 | 258d? |  | S2; C1; C4 | 9384h | 9384h | SAES-CSFB | T-Mobile, Vodafone | Rel-8 | Maurice | SAES-CSFB |  | PCG-21 | SP-39 |  |  |  |
| 3514 | 896.9.1 | Stage 2 for CS Fallback in EPS |  | 62d? | 2008-03-12 A | 2008-06-05 A | 100% | 2008-03-12 | 2008-06-05 | 62d? | finish no earlier than 2008-12-05 | S2 | 496h | 496h | SAES-CSFB | T-Mobile, Vodafone | Rel-8 | Maurice |  | New (23.272, 23.401) | PCG-21 | SP-40 |  |  |  |
| 3515 | 896.9.2 | CT1 part of Stage 3 for CS Fallback in EPS |  | 201d? | 2008-05-30 A | 2009-03-06 A | 100% | 2008-05-30 | 2009-03-06 | 201d? | finish no earlier than 2009-03-06 | C1 | 1608h | 1608h | SAES-CSFB | NEC | Rel-8 | Frederic |  | 24.007, 24.008, 24.011, 29.018, New (24.301, 24.801, 29.118) | PCG-21 | CP-40 |  |  |  |
| 3516 | 896.9.3 | CT4 part of Stage 3 for CS Fallback in EPS |  | 136d? | 2008-05-30 A | 2008-12-05 A | 100% | 2008-05-30 | 2008-12-05 | 136d? | finish no earlier than 2008-12-05 | C4 | 1088h | 1088h | SAES-CSFB | NEC | Rel-8 | Kimmo |  | 23.007, 23.008, 29.274, New 29.277 | PCG-21 | CP-40 |  |  |  |
| 3517 | 896.10 | System enhancements for the use of IMS services in local breakout |  | 62d? | 2008-03-12 A | 2008-06-05 A | 100% | 2008-03-12 | 2008-06-05 | 62d? | finish no earlier than 2008-06-05 | S2 | 496h | 496h | SAES-IMS_LBO | Telecom Italia | Rel-8 | Maurice | SAES-IMS_LBO | 23.228, 23.221, 23.203 | PCG-21 | SP-39 |  |  |  |
| 3518 | 896.11 | **EPC Data Definitions** |  | 309d? | 2008-01-07 A | 2009-03-12 A | 100% | 2008-01-07 | 2009-03-12 | 309d? |  | S5 | 7144h | 7144h | EPC-OAM |  | Rel-8 | Mirko | EPC-OAM |  | PCG-21 | SP-39 |  |  |  |
| 3519 | 896.11.1 | EPC Network Resource Model (NRM) Integration Reference Point (IRP) |  | 309d? | 2008-01-07 A | 2009-03-12 A | 100% | 2008-01-07 | 2009-03-12 | 309d? | finish no earlier than 2009-03-12 | S5 | 2472h | 2472h | EPC-OAM | Huawei | Rel-8 | Mirko |  | New (32.751, 32.752, 32.753, 32.755) | PCG-21 | SP-38 |  |  |  |
| 3520 | 896.11.2 | Performance measurements for EPC |  | 275d? | 2008-02-22 A | 2009-03-12 A | 100% | 2008-02-22 | 2009-03-12 | 275d? | finish no earlier than 2009-03-12 | S5 | 2200h | 2200h | EPC-OAM | China Mobile | Rel-8 | Mirko |  | New 32.426 | PCG-21 | SP-39 |  |  |  |
| 3521 | 896.12 | EPC Charging |  | 309d? | 2008-01-07 A | 2009-03-12 A | 100% | 2008-01-07 | 2009-03-12 | 309d? | finish no earlier than 2009-03-12 | S5 | 2472h | 2472h | EPC-CH | Nokia Siemens Networks | Rel-8 | Mirko | EPC-CH | 32.240, 32.296, 32.251, 32.252, 32.298, 32.299 | PCG-21 | SP-38 |  |  |  |
| 3522 | 896.13 | Domain Name System Procedures for Evolved Packet System (DEPS) |  | 179.75d? | 2008-05-30 A | 2009-03-06 A | 100% | 2008-05-30 | 2009-03-06 | 179.75d? | finish no earlier than 2009-03-06 | C4 | 1438h | 1438h | SAES-DEPS | TeliaSonera | Rel-8 | Kimmo | SAES-DEPS | 23.003, New 29.303 | PCG-21 | CP-40 |  |  |  |
| 3523 | 896.14 | InterWorking Function (IWF) between MAP based and Diameter based interfaces |  | 126d? | 2008-09-12 A | 2009-03-06 A | 100% | 2008-09-12 | 2009-03-06 | 126d? | finish no earlier than 2009-03-06 | C4 | 1008h | 1008h | SAES-MAP2Diam | Huawei | Rel-8 | Kimmo | SAES-MAP2Diam | New 29.305 | PCG-21 | CP-41 |  |  |  |
| 3524 | 896.15 | **CT6 aspects of SAE** |  | 847d? | 2008-03-07 A | 2011-06-03 A | 100% | 2008-03-07 | 2011-06-03 | 847d? |  | C6 | 13480h | 13480h | SAES | Nokia | Rel-8 | Xavier |  |  | PCG-21 | SP-39 |  |  |  |
| 3525 | 896.15.1 | Core specification for CT6 aspects of SAE |  | 321d? | 2008-03-07 A | 2009-05-29 A | 100% | 2008-03-07 | 2009-05-29 | 321d? | finish no earlier than 2009-05-29 | C6 | 2568h | 2568h | SAES | Nokia | Rel-8 | Xavier |  | 31.102, 31.111 | PCG-21 | CP-39 |  |  |  |
| 3526 | 896.15.2 | Test interworking of LTE Terminals with the USIM |  | 526d? | 2008-12-05 A | 2010-12-10 A | 100% | 2008-12-05 | 2010-12-10 | 526d? | finish no earlier than 2010-12-10 | C6 | 4208h | 4208h | SAES-USIM_LTE-Test | Comprion | Rel-8 | Xavier | SAES-USIM_LTE-Test | 31.121, 31.124 | PCG-22 | CP-42 |  |  |  |
| 3527 | 896.15.3 | Test interworking of IP Multimedia Services Identity Module (ISIM) terminals with IP Multimedia Subsystem (IMS) |  | 186d? | 2010-09-17 A | 2011-06-03 A | 100% | 2010-09-17 | 2011-06-03 | 186d? | finish no earlier than 2011-06-03 | C6 | 1488h | 1488h | SAES-ISIM_IMS_Test | Comprion | Rel-8 | Xavier | SAES-ISIM_IMS_Test | 31.121, 31.124, New TS 31.134 | PCG-25 | CP-49 |  |  |  |
| 3528 | 896.16 | Issues for CT1 TR 24.801 |  | 420d? | 2007-01-04 A | 2008-12-05 A | 100% | 2007-01-04 | 2008-12-05 | 420d? | finish no earlier than 2008-12-05 | C1 | 3360h | 3360h | SAES | Nokia Siemens Networks | Rel-8 | Frederic |  | 24.801 | PCG-21 | CP-39 |  |  |  |
| 3529 | 896.17 | Issues for CT3 TR 29.804 |  | 420d? | 2007-02-05 A | 2008-09-12 A | 100% | 2007-02-05 | 2008-09-12 | 420d? | finish no earlier than 2008-12-12 | C3 | 3360h | 3360h | SAES | Ericsson | Rel-8 | Adrian |  | 29.804 | PCG-21 | CP-39 |  |  |  |
| 3530 | 896.18 | Deleted - Issues for CT4 TR 29.803 |  | 420d? | 2007-01-04 A | 2008-09-12 A | 100% | 2007-01-04 | 2008-09-12 | 420d? | finish no earlier than 2008-12-11 | C4 | 3360h | 3360h | SAES | Huawei | Rel-8 | Kimmo |  | 29.803 | PCG-21 | CP-39 | PCG-21 | CP-41 |  |
| 3531 | 896.19 | Deleted (covered by 380068): Functions and procedures for SAE to support LCS | milestone | 0d? | 2008-03-03 A | 2008-03-03 A | 100% | 2008-03-03 | 2008-03-03 | 0d? | finish no earlier than 2008-03-03 | S2 |  |  | SAES-SA-FP_LCS | Nokia Siemens Networks | Rel-8 | Maurice | SAES-SA-FP_LCS |  |  |  |  | SP-37 |  |
| 3532 | 896.20 | Deleted (covered by 380064): SAE aspects of Emergency Calls | milestone | 0d? | 2008-03-03 A | 2008-03-03 A | 100% | 2008-03-03 | 2008-03-03 | 0d? | start no earlier than 2008-03-03 | S2 |  |  | SAES-SA-EmCall | Nokia Siemens Networks | Rel-8 | Maurice | SAES-SA-EmCall |  |  |  |  | SP-37 | Public Safety (I-A) |

Notes:
- 3507: CP#43 completed. SP#38 WID approved (extract from SAE WID SP-070817). / WI rapporteur e-mail: curt.c.wong@nokia.com
- 3508: SP#41 completed. SP#38 WID approved / WI rapporteur e-mail: curt.c.wong@nokia.com
- 3509: CP#43 completed / WI rapporteur e-mail: robert.zaus@nsn.com
- 3510: CP#43 completed / WI rapporteur e-mail: Giorgi Gulbani
- 3511: SP#40 completed / WI rapporteur e-mail: balazs.bertenyi@nsn.com
- 3512: SP#40 completed / WI rapporteur e-mail: balazs.bertenyi@nsn.com
- 3513: CP#43 completed / WI rapporteur e-mail: sabine.demel@t-mobile.at, chris.pudney@vodafone.com
- 3514: SP#40 completed / WI rapporteur e-mail: sabine.demel@t-mobile.at, chris.pudney@vodafone.com
- 3515: CP#43 completed / WI rapporteur e-mail: yannick.lair@nectech.fr
- 3516: CP#42 completed / WI rapporteur e-mail: yannick.lair@nectech.fr
- 3517: SP#40 completed / WI rapporteur e-mail: mario.madella@telecomitalia.it
- 3518: SP#43 completed
- 3519: SP#43 completed / WI rapporteur e-mail: WANG, Xuelong
- 3520: SP#43 completed / WI rapporteur e-mail: Li Jian (lijian@chinamobile.com), Liang Shuangchun (liangshuangchun@cmdi.chinamobile.com)
- 3521: SP#43 completed / WI rapporteur e-mail: Gerald.Goermer@nsn.com
- 3522: CP#43 completed / WI rapporteur e-mail: jouni.korhonen@teliasonera.com
- 3523: CP#43 completed. Triggered by UID_380023 (FS_MAP2Diam) / WI rapporteur e-mail: liming49985@huawei.com
- 3524: CP#44 completed core specification / WI rapporteur e-mail: Rune Lindholm
- 3525: CP#44 completed (specified Network Measurement Results collection via USAT) / WI rapporteur e-mail: Rune Lindholm
- 3526: CP#50 completed. Steering of Roaming test cases have been introduced. Remaining issues CSG display testing (Provide Local Information, Call Control for EPS/PDN, Event Download (Access Technology Change - Multiple Access Technologies) / WI rapporteur e-mail: Udo Willenbrink (uwillenbrink@comprion.com )
- 3527: CP#52 completed. Linked to R5 UID_1273 Provisioning of IP-based multimedia services (24.229, 31.103), R8 UID_390021 CT6 aspects of SAE, UID_420018 Test interworking of LTE Terminals with the USIM, R UID_450018 Testing SMS over IMS in E-UTRAN (34.229). / WI rapporteur e-mail: Udo Willenbrink (uwillenbrink@comprion.com )
- 3528: CP#43 completed / WI rapporteur e-mail: robert.zaus@nsn.com
- 3529: CP#41 completed / WI rapporteur e-mail: j.javier.pastor@ericsson.com
- 3530: CP#41 Work stopped and continued in Normative specifications
- 3531: SP#37 stopped
- 3532: SP#37 stopped

| ID | WBS | Task | Type | Duration | Start | Finish | Complete | Remaining | Baseline start | Baseline finish | Baseline duration | Total slack | Constraint | Resources | Work | Actual work | Acronym | Release | TSG approved | MCC resp | TSG stopped | Acronym_3GU_Export | WI rapporteur name | WI rapporteur e-mail | PCG approved | Status Report | PCG stopped |
| --- | --- | --- | --- | --- | --- | --- | --- | --- | --- | --- | --- | --- | --- | --- | --- | --- | --- | --- | --- | --- | --- | --- | --- | --- | --- | --- | --- |
| 3533 | 896.21 | **Deleted - CT aspects of SAES** |  | 138d? | 2007-09-04 A | 2008-03-14 | 100% | 0d? | 2007-09-04 | 2008-03-14 | 138d? | 0d |  | C3; C1; C4 | 3312h | 1104h | SAES-St3 | Rel-8 | TSG-34 | Frederic | SP-37 | SAES-St3 |  |  |  |  |  |
| 3534 | 896.21.1 | Deleted - CT1 aspects of SAES | milestone | 0d? | 2007-09-04 A | 2007-09-04 A | 100% |  | 2007-09-04 | 2007-09-04 | 0d? |  | start no earlier than 2007-09-04 | C1 |  |  | SAES-St3 | Rel-8 |  | Frederic | SP-37 |  |  |  |  |  |  |
| 3535 | 896.21.2 | Deleted - Interoperability | milestone | 0d? | 2008-03-14 A | 2008-03-14 A | 100% |  | 2008-03-14 | 2008-03-14 | 0d? |  | start no earlier than 2008-03-14 | C1 |  |  | SAES-St3-interop | Rel-8 | TSG-34 | Frederic | SP-37 | SAES-St3-interop |  |  |  |  |  |
| 3536 | 896.21.3 | Deleted - CT3 aspects of SAES | milestone | 0d? | 2007-09-04 A | 2007-09-04 A | 100% |  | 2007-09-04 | 2007-09-04 | 0d? |  | start no earlier than 2007-09-04 | C3 |  |  | SAES | Rel-8 |  | Adrian | SP-37 |  |  |  |  |  |  |
| 3537 | 896.21.4 | Deleted - CT4 aspects of SAES | milestone | 0d? | 2007-09-04 A | 2007-09-04 A | 100% |  | 2007-09-04 | 2007-09-04 | 0d? |  | start no earlier than 2007-09-04 | C4 |  |  | SAES | Rel-8 |  | Kimmo | SP-37 |  |  |  |  |  |  |
| 3538 | 896.21.5 | Deleted - UE to EPC NAS signalling (incl. MBMS and QoS aspects) | milestone | 0d? | 2008-03-14 A | 2008-03-14 A | 100% |  | 2008-03-14 | 2008-03-14 | 0d? |  | start no earlier than 2008-03-14 | C1 |  |  | SAES-St3-sig | Rel-8 | TSG-34 | Frederic | SP-37 | SAES-St3-sig |  |  |  |  |  |
| 3539 | 896.21.6 | Deleted - User and Control plane protocols | milestone | 0d? | 2007-09-21 A | 2007-09-21 A | 100% |  | 2007-09-21 | 2007-09-21 | 0d? |  | start no earlier than 2007-09-21 | C4 |  |  | SAES-St3-prot | Rel-8 | TSG-34 | Kimmo | SP-37 | SAES-St3-prot |  |  |  |  |  |
| 3540 | 896.22 | Deleted - Architecture enhancements for non-3GPP accesses | milestone | 0d? | 2007-09-04 A | 2007-09-04 A | 100% |  | 2007-09-04 | 2007-09-04 | 0d? |  | start no earlier than 2007-09-04 | S2 |  |  | SAES-non_3GPP | Rel-8 | TSG-34 | Maurice | SP-34 | SAES-non_3GPP | Motorola | Irfan.Ali@motorola.com |  |  |  |
| 3541 | 896.23 | Deleted - Stage 2 of architecture for the 3GPP System Architecture Evolution | milestone | 0d? | 2007-10-02 A | 2007-10-02 A | 100% |  | 2007-10-02 | 2007-10-02 | 0d? |  | start no earlier than 2007-10-02 | S2 |  |  | SAES-St2 | Rel-8 |  | Maurice | SP-34 | SAES-St2 | Vodafone | chris.pudney@vodafone.com |  |  |  |
| 3542 | 896.24 | Deleted - SA aspects of System Architecture Evolution |  | 384d? | 2006-04-12 A | 2007-10-01 A | 100% |  | 2006-04-12 | 2007-10-01 | 384d? |  | finish no earlier than 2007-10-02 | S2 | 3072h | 3072h | SAES-SA | Rel-8 |  | Maurice | SP-34 | SAES-SA |  |  |  |  |  |
| 3543 | 897 | Conformance Test Aspects – Mobility management based on DSMIPv6 (Dual-Stack Mobile IPv6) |  | 261d? | 2009-09-18 A | 2010-09-17 A | 100% |  | 2009-09-18 | 2010-09-17 | 261d? |  | finish no earlier than 2010-09-17 | R5 | 2088h | 2088h | DSMIPv6_UEConTest | Rel-8 | RP-45 | Ingbert |  | DSMIPv6_UEConTest | Qualcomm | Lena Chaponniere (lchaponn@qualcomm.com) | PCG-23 | RP-100738 |  |
| 3544 | 898 | **IMS Centralized Service control** |  | 2392.1d? | 2005-11-01 A | 2014-12-09 A | 100% |  | 2005-11-01 | 2014-12-05 | 2387.1d? |  |  | S1; S2; C1; C3; C4; IETF | 239598h | 239598h | ICSRA | Rel-8 | SP-37 | Alain |  | ICSRA | AT&T | Randolph Wohlert (rwohlert@tri.sbc.com) |  |  |  |
| 3545 | 898.1 | Stage 1 for ICS Requirement and Architecture |  | 138d? | 2007-09-03 A | 2008-03-12 A | 100% |  | 2007-09-03 | 2008-03-12 | 138d? |  | finish no earlier than 2007-12-14 | S1 | 1104h | 1104h | ICSRA | Rel-8 | SP-38 | Alain |  |  | AT&T | Randolph Wohlert (rwohlert@tri.sbc.com) | PCG-21 |  |  |
| 3546 | 898.2 | Stage 2 for ICS Requirement and Architecture |  | 125d? | 2007-12-14 A | 2008-06-05 A | 100% |  | 2007-12-14 | 2008-06-05 | 125d? |  | start no earlier than 2007-12-14 | S2 | 1000h | 1000h | ICSRA-St2 | Rel-8 | SP-38 | Maurice |  | ICSRA-St2 | Alcatel-Lucent |  | PCG-21 |  |  |
| 3547 | 898.3 | **Stage 3 for ICSRA – Protocol, Addressing, Subscriber Data** |  | 2392.1d? | 2005-11-01 A | 2014-12-09 A | 100% |  | 2005-11-01 | 2014-12-05 | 2387.1d? |  |  | C1; C3; C4; IETF | 122674h | 122674h | ICSRA | Rel-8 |  | Frederic |  |  | Ericsson | sean.schneyer@ericsson.com |  |  |  |
| 3548 | 898.3.1 | CT1 aspects - Stage 3 for ICSRA |  | 201d? | 2008-05-30 A | 2009-03-06 A | 100% |  | 2008-05-30 | 2009-03-06 | 201d? |  | finish no earlier than 2009-03-06 | C1 | 1608h | 1608h | ICSRA | Rel-8 | CP-40 | Frederic |  |  | Ericsson | Sean Schneyer | PCG-21 |  |  |
| 3549 | 898.3.2 | (IETF) CT1 aspects - Stage 3 for ICSRA (draft-ietf-salud-alert-info-urns) |  | 1244d? | 2008-05-30 A | 2014-12-09 A | 100% |  | 2008-05-30 | 2014-12-05 | 1242d? |  | finish no earlier than 2014-12-09 | C1-IETF | 9952h | 9952h | ICSRA | Rel-8 | CP-52 | Frederic |  |  | Roland Jesske | Roland Jesske | PCG-27 |  |  |
| 3550 | 898.3.3 | (IETF) CT1 aspects - Stage 3 for ICSRA (RFC 6871) |  | 779d? | 2008-05-30 A | 2013-03-01 A | 100% |  | 2008-05-30 | 2013-03-01 | 779d? |  | finish no earlier than 2013-02-28 | C1-IETF | 6232h | 6232h | ICSRA | Rel-8 | CP-52 | Frederic |  |  | Andrew Allen |  | PCG-27 |  |  |
| 3551 | 898.3.4 | (IETF) CT1 aspects - Stage 3 for ICSRA (RFC 7195) |  | 1117d? | 2008-05-30 A | 2014-06-13 A | 100% |  | 2008-05-30 | 2014-06-13 | 1117d? |  | finish no earlier than 2014-06-13 | C1-IETF | 8936h | 8936h | ICSRA | Rel-8 | CP-52 | Frederic |  |  | Andrew Allen |  | PCG-27 |  |  |
| 3552 | 898.3.5 | (IETF) CT1 aspects - Stage 3 for ICSRA (RFC 7006) |  | 977d? | 2008-06-03 A | 2013-12-06 A | 100% |  | 2008-06-03 | 2013-12-06 | 977d? |  | finish no earlier than 2013-12-06 | C1-IETF | 7816h | 7816h | ICSRA | Rel-8 | CP-52 | Frederic |  |  | Andrew Allen |  | PCG-27 |  |  |
| 3553 | 898.3.6 | CT3 aspects - Stage 3 for ICSRA |  | 201d? | 2008-05-30 A | 2009-03-06 A | 100% |  | 2008-05-30 | 2009-03-06 | 201d? |  | finish no earlier than 2009-03-06 | C3 | 1608h | 1608h | ICSRA | Rel-8 | CP-40 | Adrian |  |  | Mavenir | Brett Wallis ( brett@mavenir.com) | PCG-21 |  |  |
| 3554 | 898.3.7 | CT4 aspects - Stage 3 for ICSRA |  | 136d? | 2008-05-30 A | 2008-12-05 A | 100% |  | 2008-05-30 | 2008-12-05 | 136d? |  | start no earlier than 2008-05-30 | C4 | 1088h | 1088h | ICSRA | Rel-8 | CP-40 | Kimmo |  |  | Ericsson | Sean Schneyer | PCG-21 |  |  |
| 3555 | 898.3.8 | (IETF) CT4 aspects - Stage 3 for ICSRA (RFC 7254) |  | 1034.8d? | 2005-11-01 A | 2014-06-13 A | 100% |  | 2005-11-01 | 2014-06-13 | 1034.8d? |  | finish no earlier than 2014-06-13 | C4-IETF | 8278.4h | 8278.4h | ICSRA | Rel-8 | CP-52 | Kimmo |  |  | Andrew Allen |  | PCG-27 |  |  |
| 3556 | 898.3.9 | Deleted - Stage 3 for ICSRA – I1 interface |  | 76d? | 2008-05-30 A | 2008-09-12 A | 100% |  | 2008-05-30 | 2008-09-12 | 76d? |  | finish no earlier than 2008-09-12 | C1 | 608h | 608h | ICSRA | Rel-8 | CP-40 | Frederic | CP-41 |  | Huawei | xupeili@huawei.com | PCG-21 |  | PCG-21 |

Notes:
- 3533: SP#37 stopped
- 3534: SP#37 stopped
- 3535: SP#37 stopped
- 3536: SP#37 stopped
- 3537: SP#37 stopped / Impacted TSs and TRs: 29.803
- 3538: SP#37 stopped
- 3539: SP#37 stopped
- 3540: SP#34 stopped. Replaced by UID_350027 and its children / Impacted TSs and TRs: 23.402
- 3541: SP#34 stopped. Replaced by UIDs 340018 and 340037. (SP#34 report discussion of SP-060917.) / Impacted TSs and TRs: 23.002, 23.060, 23.107, 23.203, 23.228, 23.234, 23.246, 23.271, 23.279
- 3542: SP#34 stopped
- 3543: RP#49 completed. Testing for CT1's UID_360022 (24.303) under Rel-8 Feature SAES / Impacted TSs and TRs: 36.508, 36.523-1, 36.523-2, 36.523-3
- 3544: CP#46 completed
- 3545: SP#39 completed / Impacted TSs and TRs: 22.101
- 3546: SP#40 completed / Impacted TSs and TRs: 23.292, 23.206
- 3547: CP#46 completed
- 3548: CP#46 completed / Impacted TSs and TRs: 24.229, new (24.292, 24.286)
- 3549: In RFC Editors Queue. Dec.14: 75->90; 7/3/16: 90%->100 / Impacted TSs and TRs: draft-ietf-salud-alert-info-urns
- 3550: CP#59 completed / Impacted TSs and TRs: RFC 6871 (was draft-ietf-mmusic-sdp-media-capabilities)
- 3551: CP#64 complete / Impacted TSs and TRs: RFC 7195 (was draft-ietf-mmusic-sdp-cs)
- 3552: CP#62 completed / Impacted TSs and TRs: RFC7006 (was draft-ietf-mmusic-sdp-miscellaneous-caps)
- 3553: CP#43 completed / Impacted TSs and TRs: new 29.292
- 3554: CP#42 completed / Impacted TSs and TRs: 23.003, 29.232, 23.018, 29.002
- 3555: CP#64 complete / Impacted TSs and TRs: RFC 7254 (was draft-montemurro-gsma-imei-urn)
- 3556: CP#41 work stopped / Impacted TSs and TRs: 24.293

| ID | WBS | Task | Duration | Start | Finish | Complete | Baseline start | Baseline finish | Baseline duration | Constraint | Resources | Work | Actual work | Acronym | Release | TSG approved | MCC resp | Acronym_3GU_Export | WI rapporteur name | WI rapporteur e-mail | PCG approved |
| --- | --- | --- | --- | --- | --- | --- | --- | --- | --- | --- | --- | --- | --- | --- | --- | --- | --- | --- | --- | --- | --- |
| 3557 | 899 | **IMS Multimedia Telephony and Supplementary Services** | 2002d? | 2007-05-02 A | 2014-12-09 A | 100% | 2007-05-02 | 2014-12-05 | 1997d? |  | S1; S5; C1; C3; C4; IETF | 272222h | 272222h | IMSTSS | Rel-8 | SP-37 | Alain | IMSTSS |  |  |  |
| 3558 | 899.1 | **General aspects of IMS Sup Services** | 395d? | 2007-09-03 A | 2009-03-06 A | 100% | 2007-09-03 | 2009-03-06 | 395d? |  | S1; C1; C3; C4 | 19232h | 19232h | IMSSS-Gal | Rel-8 | SP-37 | Alain | IMSSS-Gal | Ericsson | Susana Sabater |  |
| 3559 | 899.1.1 | Service and Capability for Core IMS - inclusion of TISPAN requirements | 75d? | 2007-09-03 A | 2007-12-14 A | 100% | 2007-09-03 | 2007-12-14 | 75d? | finish no earlier than 2007-12-14 | S1 | 600h | 600h | TISCAPR8 | Rel-8 | SP-37 | Alain | TISCAPR8 | Ericsson | Susana Sabater |  |
| 3560 | 899.1.2 | Documentation of TISPAN R1 and R2 in CT1 | 208d? | 2007-11-28 A | 2008-09-12 A | 100% | 2007-11-28 | 2008-09-12 | 208d? | finish no earlier than 2008-09-12 | C1 | 1664h | 1664h | REDOC_TIS-C1 | Rel-8 | CP-38 | Frederic | REDOC_TIS-C1 | Nokia Siemens Networks | peter.leis@nsn.com | PCG-21 |
| 3561 | 899.1.3 | Documentation of TISPAN R1 and R2 in CT3 | 333d? | 2007-11-28 A | 2009-03-06 A | 100% | 2007-11-28 | 2009-03-06 | 333d? | finish no earlier than 2009-03-06 | C3 | 2664h | 2664h | REDOC_TIS-C3 | Rel-8 | CP-38 | Adrian | REDOC_TIS-C3 | Nokia Siemens Networks | peter.leis@nsn.com | PCG-21 |
| 3562 | 899.1.4 | Documentation of TISPAN R1 and R2 in CT4 | 208d? | 2007-11-28 A | 2008-09-12 A | 100% | 2007-11-28 | 2008-09-12 | 208d? | finish no earlier than 2008-09-12 | C4 | 1664h | 1664h | REDOC_TIS-C4 | Rel-8 | CP-38 | Kimmo | REDOC_TIS-C4 | Nokia Siemens Networks | peter.leis@nsn.com | PCG-21 |
| 3563 | 899.2 | **IMS Multimedia Telephony Service** | 394d? | 2007-09-10 A | 2009-03-12 A | 100% | 2007-09-10 | 2009-03-12 | 394d? |  | S1; S5 | 9296h | 9296h | IMS-MMTel | Rel-8 | SP-37 | Alain | IMS-MMTel |  |  |  |
| 3564 | 899.2.1 | Merging TISPAN MMTel [requirements] for Common IMS | 65d? | 2007-09-10 A | 2007-12-07 A | 100% | 2007-09-10 | 2007-12-07 | 65d? | finish no earlier than 2007-12-07 | S1 | 520h | 520h | TMMTEL | Rel-8 | SP-37 | Alain | TMMTEL | Nokia Siemens Networks |  |  |
| 3565 | 899.2.2 | Multimedia Telephony Service and Supplementary Services (MMTel) offline Charging | 309d? | 2008-01-07 A | 2009-03-12 A | 100% | 2008-01-07 | 2009-03-12 | 309d? | finish no earlier than 2009-03-12 | S5 | 2472h | 2472h | MMTel-CH | Rel-8 | SP-38 | Mirko | MMTel-CH | Alcatel-Lucent | maryse.gardella@alcatel-lucent.com | PCG-21 |
| 3566 | 899.3 | **Call Completion on Busy Subscriber (CCBS)/Call Completion on Non-Reachable (CCNR) on IMS** | 1608d? | 2007-05-02 A | 2013-06-14 A | 100% | 2007-05-02 | 2013-06-14 | 1608d? |  | C1; C3; IETF | 71528h | 71528h | CCBS_CCNR | Rel-8 | SP-38 | Frederic | CCBS_CCNR | Deutsche Telekom | martin.huelsemann@telekom.de | PCG-21 |
| 3567 | 899.3.1 | CT1 part of Stage 3 CCBS_CCNR | 483d? | 2007-05-02 A | 2009-03-06 A | 100% | 2007-05-02 | 2009-03-06 | 483d? | finish no earlier than 2009-03-06 | C1 | 3864h | 3864h | CCBS_CCNR | Rel-8 | CP-38 | Frederic |  | Deutsche Telekom | martin.huelsemann@telekom.de | PCG-21 |
| 3568 | 899.3.2 | CT3 part of Stage 3 CCBS_CCNR | 418d? | 2007-05-02 A | 2008-12-05 A | 100% | 2007-05-02 | 2008-12-05 | 418d? | finish no earlier than 2008-12-05 | C3 | 3344h | 3344h | CCBS_CCNR | Rel-8 | CP-38 | Adrian |  | Deutsche Telekom | martin.huelsemann@telekom.de | PCG-21 |
| 3569 | 899.3.3 | (IETF) Stage 3 CCBS_CCNR [RFC 6910 (was draft-ietf-bliss-call-completion)] | 1608d? | 2007-05-02 A | 2013-06-14 A | 100% | 2007-05-02 | 2013-06-14 | 1608d? | finish no earlier than 2013-06-10 | C1-IETF; C3-IETF | 25728h | 25728h | CCBS_CCNR | Rel-8 | CP-52 | Frederic |  | Roland Jesske |  | PCG-27 |
| 3570 | 899.4 | **Flexible Alerting** | 288d? | 2008-01-30 A | 2009-03-06 A | 100% | 2008-01-30 | 2009-03-06 | 288d? |  | S1; C1 | 7582.4h | 7582.4h | FA | Rel-8 | SP-39 | Alain | FA | Nortel | milanpa@nortel.com | PCG-21 |
| 3571 | 899.4.1 | Stage 1 FA | 92d? | 2008-01-30 A | 2008-06-05 A | 100% | 2008-01-30 | 2008-06-05 | 92d? |  | S1 | 670.4h | 670.4h | FA | Rel-8 | SP-39 | Alain |  | Telecom Italia |  | PCG-21 |
| 3572 | 899.4.2 | Stage 3 FA | 288d? | 2008-01-30 A | 2009-03-06 A | 100% | 2008-01-30 | 2009-03-06 | 288d? | finish no earlier than 2009-03-06 | C1 | 2304h | 2304h | FA | Rel-8 | CP-39 | Frederic |  | Nortel | milanpa@nortel.com | PCG-21 |
| 3573 | 899.5 | **Communication Wait on IMS** | 1965d? | 2007-06-22 A | 2014-12-09 A | 100% | 2007-06-22 | 2014-12-05 | 1960d? |  | C1; C3; IETF | 61880h | 61880h | CW_IMS | Rel-8 | SP-38 | Frederic | CW_IMS | Deutsche Telekom | martin.huelsemann@telekom.de | PCG-21 |
| 3574 | 899.5.1 | CT1 part of Stage 3 CW-IMS | 331d? | 2007-11-30 A | 2009-03-06 A | 100% | 2007-11-30 | 2009-03-06 | 331d? | finish no earlier than 2009-03-06 | C1 | 2648h | 2648h | CW_IMS | Rel-8 | CP-38 | Frederic |  | Deutsche Telekom | martin.huelsemann@telekom.de | PCG-21 |
| 3575 | 899.5.2 | (IETF) Stage 3 CW-IMS (salud-alert-info-urns) | 1244d? | 2007-06-22 A | 2014-12-09 A | 100% | 2007-06-22 | 2014-12-05 | 1242d? | finish no earlier than 2014-12-09 | C1-IETF | 9952h | 9952h | CW_IMS | Rel-8 | CP-52 | Frederic |  | Roland Jesske | Roland Jesske | PCG-27 |
| 3576 | 899.5.3 | CT3 part of Stage 3 CW-IMS | 265d? | 2007-11-30 A | 2008-12-04 A | 100% | 2007-11-30 | 2008-12-04 | 265d? | finish no earlier than 2008-12-05 | C3 | 2120h | 2120h | CW_IMS | Rel-8 | CP-38 | Adrian |  | Deutsche Telekom | martin.huelsemann@telekom.de | PCG-21 |
| 3577 | 899.6 | **IMS Charging** | 389d? | 2007-09-17 A | 2009-03-12 A | 100% | 2007-09-17 | 2009-03-12 | 389d? |  | S5 | 6608h | 6608h | CH8_IMS | Rel-8 | SP-37 | Mirko | CH8 | Alcatel-Lucent | maryse.gardella@alcatel-lucent.com |  |
| 3578 | 899.6.1 | Add Interconnection Border Control Function (IBCF) to IMS Charging | 128d? | 2007-09-17 A | 2008-03-12 A | 100% | 2007-09-17 | 2008-03-12 | 128d? | finish no earlier than 2008-03-12 | S5 | 1024h | 1024h | CH8_IMS | Rel-8 | SP-37 | Mirko |  | Alcatel-Lucent | maryse.gardella@alcatel-lucent.com |  |
| 3579 | 899.6.2 | Advice of Charge (AoC) support in IMS Charging | 309d? | 2008-01-07 A | 2009-03-12 A | 100% | 2008-01-07 | 2009-03-12 | 309d? | finish no earlier than 2009-03-12 | S5 | 2472h | 2472h | CH8_IMS | Rel-8 | SP-38 | Mirko |  | Nokia Siemens Networks | Gerald.Goermer@nsn.com | PCG-21 |
| 3580 | 900 | **3GPP2 Input to Common IMS** | 200d? | 2008-03-07 A | 2008-12-11 A | 100% | 2008-03-07 | 2008-12-11 | 200d? |  | S1; S2; S3; C1; C3; C4 | 21453.2h | 21453.2h | CIMS_3GPP2 | Rel-8 | SP-39 | Alain | CIMS_3GPP2, IMS_Common | Nortel | Amar Deol (deola@nortelnetworks.com) | PCG-21 |
| 3581 | 900.1 | Stage 1 CIMS_3GPP2 | 30.65d? | 2008-03-12 A | 2008-06-05 A | 100% | 2008-03-12 | 2008-06-05 | 30.65d? | finish no earlier than 2008-06-12 | S1 | 245.2h | 245.2h | CIMS_3GPP2 | Rel-8 | SP-39 | Alain |  | Nortel | Amar Deol (deola@nortelnetworks.com) | PCG-21 |
| 3582 | 900.2 | Stage 2 CIMS_3GPP2 | 62d? | 2008-03-12 A | 2008-06-05 A | 100% | 2008-03-12 | 2008-06-05 | 62d? | finish no earlier than 2008-09-11 | S2 | 496h | 496h | CIMS_3GPP2 | Rel-8 | SP-39 | Maurice |  | Nortel | Amar Deol (deola@nortelnetworks.com) | PCG-21 |
| 3583 | 900.3 | Security CIMS_3GPP2 | 197d? | 2008-03-12 A | 2008-12-11 A | 100% | 2008-03-12 | 2008-12-11 | 197d? | finish no earlier than 2008-12-11 | S3 | 1576h | 1576h | CIMS_3GPP2 | Rel-8 | SP-39 | Mirko |  | Nortel | Amar Deol (deola@nortelnetworks.com) | PCG-21 |

Notes:
- 3557: SP#43 completed
- 3558: CP#43 completed
- 3559: SP#39 completed / Impacted TSs and TRs: 22.228, 22.115, 22.101
- 3560: CP#41 completed / Impacted TSs and TRs: 24.141, 24.147, 24.173, 24.229, 24.247, 24.341, 24.604, 24.605, 24.606, 24.607, 24.608, 24.610, 24.611, 24.616, 24.623, 24.628, 24.629, 24.647, 24.654
- 3561: CP#43 completed / Impacted TSs and TRs: 29.162, 29.163, 29.658
- 3562: CP#41 completed / Impacted TSs and TRs: 29.228, 29.229
- 3563: SP#43 completed
- 3564: SP#38 completed / Impacted TSs and TRs: 22.173
- 3565: CP#43 completed / Impacted TSs and TRs: 32.275, 32.298/299
- 3566: CP#43 completed
- 3567: CP#43 completed / Impacted TSs and TRs: 24.642, 24.229, 24.173
- 3568: CP#42 completed / Impacted TSs and TRs: 29.163
- 3569: CP#60 completed / Impacted TSs and TRs: RFC 6910 (was draft-ietf-bliss-call-completion)
- 3570: CP#43 completed
- 3571: SP#40 completed / Impacted TSs and TRs: 22.173
- 3572: CP#43 completed / Impacted TSs and TRs: 24.239, 24.173
- 3573: CP#43 completed
- 3574: CP#43 completed / Impacted TSs and TRs: 24.615, 24.229, 24.173
- 3575: In RFC Editors Queue. Dec.14: 75->90; 7/3/16: 90%->100 / Impacted TSs and TRs: draft-ietf-salud-alert-info-urns
- 3576: CP#42 completed / Impacted TSs and TRs: 29.163
- 3577: SP#39 completed / Impacted TSs and TRs: 32.260, 32.298
- 3578: SP#39 completed / Impacted TSs and TRs: 32.260, 32.298
- 3579: SP#43 completed / Impacted TSs and TRs: 32.240, 32.260, 32.296, 32.298, 32.299, new 32.280
- 3580: TSG#42 completed. Acronym changed from "CIMS_3GPP2, IMS_Common"
- 3581: SP#40 completed. Acronym changed from "CIMS_3GPP2, IMS_Common" / Impacted TSs and TRs: 22.228, 22.173, 22.101, 22.153
- 3582: SP#40 completed. Acronym changed from "CIMS_3GPP2, IMS_Common" / Impacted TSs and TRs: 23.002, 23.141, 23.203, 23.167, 23.228
- 3583: SP#42 completed [issues addressed under UID_370078 (IMS-Sec)]. Acronym changed from "CIMS_3GPP2, IMS_Common" / Impacted TSs and TRs: 33.141, 33.203, 33.210

| ID | WBS | Task | Duration | Start | Finish | Complete | Baseline start | Baseline finish | Baseline duration | Constraint | Resources | Work | Actual work | Acronym | PCG approved | WI rapporteur name | WI rapporteur e-mail | Release | TSG approved | MCC resp | Acronym_3GU_Export | TSG stopped |
| --- | --- | --- | --- | --- | --- | --- | --- | --- | --- | --- | --- | --- | --- | --- | --- | --- | --- | --- | --- | --- | --- | --- |
| 3584 | 900.4 | **Stage 3 CIMS_3GPP2** | 200d? | 2008-03-07 A | 2008-12-11 A | 100% | 2008-03-07 | 2008-12-11 | 200d? |  | C1; C3; C4 | 9536h | 9536h | REDOC_3GPP2 | PCG-21 | Alcatel-Lucent | orsic@alcatel-lucent.com | Rel-8 | CP-39 | Frederic | REDOC_3GPP2 |  |
| 3585 | 900.4.1 | Stage 3 CIMS_3GPP2 (CT1) | 196d? | 2008-03-07 A | 2008-12-05 A | 100% | 2008-03-07 | 2008-12-05 | 196d? | finish no earlier than 2008-12-11 | C1 | 1568h | 1568h | REDOC_3GPP2 | PCG-21 | Alcatel-Lucent | orsic@alcatel-lucent.com | Rel-8 | CP-39 | Frederic |  |  |
| 3586 | 900.4.2 | Stage 3 CIMS_3GPP2 (CT3) | 196d? | 2008-03-07 A | 2008-12-05 A | 100% | 2008-03-07 | 2008-12-05 | 196d? | finish no earlier than 2008-12-05 | C3 | 1568h | 1568h | REDOC_3GPP2 | PCG-21 | Alcatel-Lucent | orsic@alcatel-lucent.com | Rel-8 | CP-39 | Adrian |  |  |
| 3587 | 900.4.3 | Stage 3 CIMS_3GPP2 (CT4) | 200d? | 2008-03-07 A | 2008-12-11 A | 100% | 2008-03-07 | 2008-12-11 | 200d? | finish no earlier than 2008-12-11 | C4 | 1600h | 1600h | REDOC_3GPP2 | PCG-21 | Alcatel-Lucent | orsic@alcatel-lucent.com | Rel-8 | CP-39 | Kimmo |  |  |
| 3588 | 901 | **IMS Enhancements for support of Packet Cable access** | 388d? | 2006-12-06 A | 2008-05-30 A | 100% | 2006-12-06 | 2008-05-30 | 388d? |  | S2; S3; C1; C3; C4 | 58616h | 58616h | PktCbl |  | Cablelabs | Bernie McKibben (b.mckibben@cablelabs.com) | Rel-8 | TSG-35 | Maurice | PktCbl |  |
| 3589 | 901.1 | **IMS Enhancements for Cable Client Types and Deployment Models** | 345d? | 2007-02-05 A | 2008-05-30 A | 100% | 2007-02-05 | 2008-05-30 | 345d? |  | S2; C1 | 9752h | 9752h | PktCbl-Deploy |  | Cablelabs | Bernie McKibben (b.mckibben@cablelabs.com) | Rel-8 |  | Maurice | PktCbl-Deploy |  |
| 3590 | 901.1.1 | Architecture aspects of PktCbl-Deploy | 219d? | 2007-02-05 A | 2007-12-06 A | 100% | 2007-02-05 | 2007-12-06 | 219d? | finish no earlier than 2007-12-03 | S2 | 1752h | 1752h | PktCbl-Deploy |  | Cablelabs | Bernie McKibben (b.mckibben@cablelabs.com) | Rel-8 |  | Maurice |  |  |
| 3591 | 901.1.2 | CT1 aspects of PktCbl-Deploy | 310d? | 2007-03-26 A | 2008-05-30 A | 100% | 2007-03-26 | 2008-05-30 | 310d? | finish no earlier than 2008-06-15 | C1 | 2480h | 2480h | PktCbl-Deploy |  | Cablelabs | D.Hancock@CableLabs.com | Rel-8 |  | Frederic |  |  |
| 3592 | 901.2 | **IMS Inter-working aspects in Support of Cable Regulatory requirements** | 290d? | 2007-02-05 A | 2008-03-14 A | 100% | 2007-02-05 | 2008-03-14 | 290d? |  | S2; C1; C3 | 12320h | 12320h | PktCbl-Intw |  | Cablelabs | B.McKibben@CableLabs.com | Rel-8 |  | Maurice | PktCbl-Intw |  |
| 3593 | 901.2.1 | Architecture aspects of PktCbl-Interwork | 160d? | 2007-02-05 A | 2007-09-14 A | 100% | 2007-02-05 | 2007-09-14 | 160d? | start no earlier than 2007-02-05 | S2 | 1280h | 1280h | PktCbl-Intw |  | Cablelabs | B.McKibben@CableLabs.com | Rel-8 |  | Maurice |  |  |
| 3594 | 901.2.2 | CT1,CT3 aspects of PktCbl-Interwork | 255d? | 2007-03-26 A | 2008-03-14 A | 100% | 2007-03-26 | 2008-03-14 | 255d? | finish no earlier than 2008-03-15 | C1; C3 | 4080h | 4080h | PktCbl-Intw |  | Cablelabs | D.Hancock@CableLabs.com | Rel-8 |  | Frederic |  |  |
| 3595 | 901.3 | **IMS Enhancements for Security Requirements in Support of Cable Deployments** | 388d? | 2006-12-06 A | 2008-05-30 A | 100% | 2006-12-06 | 2008-05-30 | 388d? |  | S3; C1; C3; C4 | 21024h | 21024h | PktCbl-Sec |  | Cablelabs | s.dotson@cablelabs.com | Rel-8 | TSG-34 | Mirko | PktCbl-Sec |  |
| 3596 | 901.3.1 | SA3 aspects of PktCbl-Sec | 331d? | 2006-12-06 A | 2008-03-12 A | 100% | 2006-12-06 | 2008-03-12 | 331d? | finish no earlier than 2007-12-20 | S3 | 2648h | 2648h | PktCbl-Sec |  | Cablelabs | s.dotson@cablelabs.com | Rel-8 |  | Mirko |  |  |
| 3597 | 901.3.2 | CT1 aspects of PktCbl-Sec | 310d? | 2007-03-26 A | 2008-05-30 A | 100% | 2007-03-26 | 2008-05-30 | 310d? | finish no earlier than 2008-06-06 | C1 | 2480h | 2480h | PktCbl-Sec |  | Cablelabs | D.Hancock@CableLabs.com | Rel-8 |  | Frederic |  |  |
| 3598 | 901.3.3 | CT3 aspects of PktCbl-Sec | 180d? | 2007-03-26 A | 2007-11-30 A | 100% | 2007-03-26 | 2007-11-30 | 180d? | finish no earlier than 2008-03-15 | C3 | 1440h | 1440h | PktCbl-Sec | PCG-21 | Cablelabs | D.Hancock@CableLabs.com | Rel-8 | CP-38 | Adrian |  |  |
| 3599 | 901.3.4 | CT4 aspects of PktCbl-Sec | 255d? | 2007-03-26 A | 2008-03-14 A | 100% | 2007-03-26 | 2008-03-14 | 255d? | finish no earlier than 2008-03-14 | C4 | 2040h | 2040h | PktCbl-Sec |  | Cablelabs | D.Hancock@CableLabs.com | Rel-8 |  | Kimmo |  |  |
| 3600 | 902 | **IMS System enhancements for corporate network access** | 1901d? | 2007-06-22 A | 2014-09-12 A | 100% | 2007-06-22 | 2014-12-05 | 1960d? |  | S2; S1; C1; C4; IETF | 91240.9h | 91240.9h | IMS_Corp |  | Orange | Delphin Barankanira | Rel-8 |  | Maurice | IMS_Corp |  |
| 3601 | 902.1 | SA1 aspects of IMS_Corp | 23.6d? | 2008-03-12 A | 2008-06-05 A | 100% | 2008-03-12 | 2008-06-05 | 23.6d? | finish no earlier than 2008-06-05 | S1 | 188.8h | 188.8h | IMS_Corp | PCG-21 | Telecom Italia |  | Rel-8 | SP-39 | Alain |  |  |
| 3602 | 902.2 | SA2 aspects of IMS_Corp | 325d? | 2007-06-22 A | 2008-09-18 A | 100% | 2007-06-22 | 2008-09-18 | 325d? | finish no earlier than 2008-12-25 | S2 | 2600h | 2600h | IMS_Corp |  | Orange | Delphin Barankanira | Rel-8 |  | Maurice |  |  |
| 3603 | 902.3 | CT1 aspects of IMS_Corp | 532d? | 2008-03-07 A | 2010-03-19 A | 100% | 2008-03-07 | 2010-03-19 | 532d? | finish no earlier than 2010-03-19 | C1 | 4244.09h | 4244.09h | IMS_Corp | PCG-21 | Alcatel-Lucent | Keith Drage (drage@alcatel-lucent.com) | Rel-8 | CP-39 | Frederic |  |  |
| 3604 | 902.4 | (IETF) CT1 aspects of IMS_Corp (RFC 7316) | 825d? | 2011-06-29 A | 2014-09-12 A | 100% | 2011-06-29 | 2014-12-05 | 885d? | finish no earlier than 2014-09-12 | C1-IETF | 6600h | 6600h | IMS_Corp | PCG-27 | Keith Drage | Keith Drage (drage@alcatel-lucent.com) | Rel-8 | CP-53 | Frederic |  |  |
| 3605 | 902.5 | CT4 aspects of IMS_Corp | 196d? | 2008-02-26 A | 2008-12-05 A | 100% | 2008-02-26 | 2008-12-05 | 196d? | finish no earlier than 2008-12-11 | C4 | 1568h | 1568h | IMS_Corp | PCG-21 | Alcatel-Lucent | Keith Drage (drage@alcatel-lucent.com) | Rel-8 | CP-39 | Kimmo |  |  |
| 3606 | 903 | **Maintenance of TISPAN documentation** | 1829d? | 2007-07-02 A | 2014-06-13 A | 100% | 2007-07-02 | 2014-06-13 | 1829d? |  | S2; C1; C3; C4; IETF | 85904h | 85904h | MAINTISP | PCG-21 |  |  | Rel-8 | SP-38 | Maurice | MAINTISP |  |
| 3607 | 903.1 | Maintenance of TISPAN R2 | 86d? | 2007-11-09 A | 2008-03-07 A | 100% | 2007-11-09 | 2008-03-07 | 86d? | start no earlier than 2007-11-09 | C1; C3; C4 | 2064h | 2064h | MAINT_R2 | PCG-21 | Alcatel-Lucent | Keith Drage (drage@alcatel-lucent.com) | Rel-8 | CP-38 | Frederic | MAINT_R2 |  |
| 3608 | 903.2 | Deleted - (IETF) Maintenance of TISPAN R2 (avasarala-dispatch-comm-div-notification) | 1117d? | 2007-11-09 A | 2014-06-13 A | 100% | 2007-11-09 | 2014-06-13 | 1117d? | finish no earlier than 2014-06-13 | C1-IETF | 8936h | 8936h | MAINT_R2_IETF | PCG-27 | Andrew Allen |  | Rel-8 | CP-52 | Frederic | MAINT_R2_IETF | SP-69 |
| 3609 | 903.3 | Documentation of TISPAN NGN R1 and R2 in 3GPP SA2 | 104d? | 2008-01-14 A | 2008-06-05 A | 100% | 2008-01-14 | 2008-06-05 | 104d? | finish no earlier than 2008-06-20 | S2 | 832h | 832h | IMS_Comm_Doc | PCG-21 | Nokia Siemens Networks | jozsef.varga@nsn.com | Rel-8 | SP-38 | Maurice | IMS_Comm_Doc |  |
| 3610 | 903.4 | Maintenance of TISPAN release 2 common IMS | 114d? | 2007-07-02 A | 2007-12-06 A | 100% | 2007-07-02 | 2007-12-06 | 114d? | finish no earlier than 2007-12-06 | S2 | 912h | 912h | IMS_Comm_Mtce8 | PCG-21 | Telecom Italia | antonio.ascolese@telecomitalia.it | Rel-8 | SP-38 | Maurice | IMS_Comm_Mtce8 |  |

Notes:
- 3584: -
- 3585: CP#42 completed / Impacted TSs and TRs: 23.218, 24.141, 24.147, 24.173, 24.229, 24.238, 24.247, 24.604, 24.605, 24.606, 24.607, 24.608, 24.610, 24.611, 24.629, 24.930
- 3586: CP#42 completed / Impacted TSs and TRs: 29.163, 29.212, 29.213, 29.214
- 3587: CP#42 completed / Impacted TSs and TRs: 29.228, 29.229, 29.328, 29.329
- 3588: CP#40 completed
- 3589: CP#40 completed
- 3590: SP#38 completed / Impacted TSs and TRs: 23.228
- 3591: CP#40 completed
- 3592: CP#39 completed
- 3593: SP#37 completed / Impacted TSs and TRs: 23.228
- 3594: CP#39 completed / Impacted TSs and TRs: 24.229
- 3595: CP#40 completed
- 3596: SP#39 completed / Impacted TSs and TRs: 33.203, 33.210, 33.220
- 3597: CP#40 completed / Impacted TSs and TRs: 24.229
- 3598: CP#38 completed / Impacted TSs and TRs: 29.163
- 3599: CP#39 completed / Impacted TSs and TRs: 29.228, 29.229, 23.008
- 3600: CP#47 completed
- 3601: SP#40 completed
- 3602: no Stage 2 impacts / Impacted TSs and TRs: 23.228
- 3603: CP#47 completed / Impacted TSs and TRs: 24.229, 24.503
- 3604: CP#65 completed / Impacted TSs and TRs: RFC 7316 (was draft-vanelburg-dispatch-private-network-ind)
- 3605: CP#42 completed / Impacted TSs and TRs: 29.228, 29.229, 23.003, 23.008, 29.433
- 3606: SP#40 completed
- 3607: CP#39 completed / Impacted TSs and TRs: 24.406, 24.407, 24.410, 24.411, 24.423, 24.430, 24.447, 24.451, 24.454, 24.503, 24.505, 24.508, 24.516, 24.528, 24.529, 29.412, 29.421, 29.433, 29.458, 29.527, 29.624
- 3608: CP#64 Draft removed from 3GPP documentation / Impacted TSs and TRs: draft-avasarala-dispatch-comm-div-notification
- 3609: SP#40 completed / Impacted TSs and TRs: 23.228, 23.204, 23.167
- 3610: SP#38 completed / Impacted TSs and TRs: 23.506, 23.507,23.517, 23.521

| ID | WBS | Task | Type | Duration | Start | Finish | Complete | Baseline start | Baseline finish | Baseline duration | Constraint | Resources | Work | Actual work | Acronym | PCG approved | WI rapporteur name | WI rapporteur e-mail | Release | TSG approved | MCC resp | Acronym_3GU_Export | Impacted TSs and TRs |
| --- | --- | --- | --- | --- | --- | --- | --- | --- | --- | --- | --- | --- | --- | --- | --- | --- | --- | --- | --- | --- | --- | --- | --- |
| 3611 | 904 | **IMS Service Continuity** |  | 318d? | 2008-03-12 A | 2009-05-29 A | 100% | 2008-03-12 | 2009-05-29 | 318d? |  | S2; S1; C1 | 10712h | 10712h | IMS-Cont | PCG-21 | LG Electronics | JaeSeung SONG (anthonys@lge.com) | Rel-8 | SP-39 | Maurice | IMS-Cont |  |
| 3612 | 904.1 | Stage 1 IMS Service Continuity |  | 62d? | 2008-03-12 A | 2008-06-05 A | 100% | 2008-03-12 | 2008-06-05 | 62d? | start no earlier than 2008-03-12 | S1 | 496h | 496h | IMS-Cont | PCG-21 | LG Electronics | JaeSeung SONG (anthonys@lge.com) | Rel-8 | SP-39 | Alain |  |  |
| 3613 | 904.2 | Stage 2 IMS Service Continuity |  | 62d? | 2008-03-12 A | 2008-06-05 A | 100% | 2008-03-12 | 2008-06-05 | 62d? | finish no earlier than 2008-06-05 | S2 | 496h | 496h | IMS-Cont | PCG-21 | LG Electronics | JaeSeung SONG (anthonys@lge.com) | Rel-8 | SP-39 | Maurice |  | 23.237, 23.292 |
| 3614 | 904.3 | Stage 3 IMS Service Continuity |  | 261d? | 2008-05-30 A | 2009-05-29 A | 100% | 2008-05-30 | 2009-05-29 | 261d? | finish no earlier than 2009-05-29 | C1 | 2088h | 2088h | IMS-Cont | PCG-21 | Huawei | Lili Yang (kadyyang@huawei.com) | Rel-8 | CP-40 | Frederic |  | 24.237, 24.229, 24.216 |
| 3615 | 905 | **Security Enhancements for IMS** |  | 643.3d? | 2006-09-19 A | 2009-03-06 A | 100% | 2006-09-19 | 2009-03-06 | 643.3d? |  | S3; C1; C4 | 29847.2h | 29847.2h | IMS-Sec |  | Ericsson | Bengt.Sahlin@ericsson.com | Rel-8 | SP-37 | Mirko | IMS-Sec |  |
| 3616 | 905.1 | Stage 2 for IMS-Sec |  | 466d? | 2007-03-01 A | 2008-12-11 A | 100% | 2007-03-01 | 2008-12-11 | 466d? | finish no earlier than 2008-12-11 | S3 | 3728h | 3728h | IMS-Sec |  | Ericsson | Bengt.Sahlin@ericsson.com | Rel-8 |  | Mirko |  | 33.203, 33.141, 33.803 |
| 3617 | 905.2 | CT1 part of Stage 3 for IMS-Sec |  | 392d? | 2006-09-19 A | 2008-12-05 A | 100% | 2006-09-19 | 2008-12-05 | 392d? | finish no earlier than 2008-12-05 | C1 | 3136h | 3136h | IMS-Sec | PCG-21 | Ericsson |  | Rel-8 | CP-39 | Frederic |  |  |
| 3618 | 905.3 | CT4 part of Stage 3 for IMS-Sec |  | 457d? | 2007-06-07 A | 2009-03-06 A | 100% | 2007-06-07 | 2009-03-06 | 457d? | finish no earlier than 2009-03-06 | C4 | 3656h | 3656h | IMS-Sec | PCG-21 | Ericsson |  | Rel-8 | CP-39 | Kimmo |  |  |
| 3619 | 905.4 | CT1 part of Network Attachment Subsystem (NASS) Bundled Authentication |  | 343d? | 2007-11-14 A | 2009-03-06 A | 100% | 2007-11-14 | 2009-03-06 | 343d? | finish no earlier than 2009-03-06 | C1 | 2744h | 2744h | NBA | PCG-21 | Alcatel-Lucent | Keith Drage (drage@alcatel-lucent.com) | Rel-8 | CP-39 | Frederic | NBA | 24.229 |
| 3620 | 905.5 | CT4 part of Network Attachment Subsystem (NASS) Bundled Authentication |  | 143d? | 2007-11-14 A | 2008-05-30 A | 100% | 2007-11-14 | 2008-05-30 | 143d? | start no earlier than 2007-11-14 | C4 | 1144h | 1144h | NBA-CT4 | PCG-21 | Alcatel-Lucent |  | Rel-8 | CP-39 | Kimmo | NBA-CT4 | 29.229, 29.228, 23.008 |
| 3621 | 906 | **IMS initiated and controlled PSS and MBMS User Service** |  | 924d? | 2008-03-12 A | 2011-09-21 A | 100% | 2008-03-12 | 2011-09-21 | 924d? |  | S4; S3; IETF | 28108.8h | 28108.8h | IMS_PSS_MBMS_US |  | FT, Ericsson | olle.franceschi@ericsson.com | Rel-8 |  | Paolo | IMS_PSS_MBMS_US |  |
| 3622 | 906.1 | SA4, SA3 part of IMS initiated and controlled PSS and MBMS User Service | milestone | 0d? | 2008-03-12 A | 2008-03-12 A | 100% | 2008-03-12 | 2008-03-12 | 0d? | finish no earlier than 2009-03-12 | S4; S3 |  |  | IMS_PSS_MBMS_US |  | FT, Ericsson | olle.franceschi@ericsson.com | Rel-8 |  | Paolo |  | 26.234, 26.346, 33.246, New 26.237 |
| 3623 | 906.2 | (IETF) IMS initiated and controlled PSS and MBMS User Service (RFC 6080) |  | 743.6d? | 2008-03-12 A | 2011-09-21 A | 100% | 2008-03-12 | 2011-09-21 | 743.6d? | finish no earlier than 2011-09-21 | S4-IETF | 5932.8h | 5932.8h | IMS_PSS_MBMS_US | PCG-27 | Ericsson |  | Rel-8 | SP-52 | Paolo |  | RFC 6080 (was draft-ietf-sipping-config-framework) |
| 3624 | 907 | **Multimedia interworking between IMS and CS networks** |  | 836d? | 2005-09-23 A | 2008-12-05 A | 100% | 2005-09-23 | 2008-12-05 | 836d? |  | C3; C4 | 22800h | 22800h | MIW-IMS | PCG-36 | Vodafone | nico.gabriele@vodafone.com | Rel-8 | TSG#71 | Adrian | MIW-IMS |  |
| 3625 | 907.1 | Stage 1 and 2 defined in earlier Releases |  | 49d? | 2005-09-23 A | 2005-11-30 A | 100% | 2005-09-23 | 2005-11-30 | 49d? | start no earlier than 2005-09-23 | S2 | 392h | 392h | MIW-IMS |  | Vodafone | nico.gabriele@vodafone.com | Rel-8 |  | Maurice |  |  |
| 3626 | 907.2 | Stage 3 of MW-IMS |  | 571d? | 2005-09-23 A | 2007-11-30 A | 100% | 2005-09-23 | 2007-11-30 | 571d? | finish no earlier than 2007-09-14 | C3 | 4568h | 4568h | MIW-IMS-St3C3 |  | Vodafone | nico.gabriele@vodafone.com | Rel-8 |  | Adrian | MIW-IMS-St3 | 29.863, 29.163 |
| 3627 | 907.3 | Stage 3 for MW-IMS, MONA extension |  | 285d? | 2007-11-05 A | 2008-12-05 A | 100% | 2007-11-05 | 2008-12-05 | 285d? | finish no earlier than 2008-12-05 | C3 | 2280h | 2280h | MIW-IMS-St3C3_MONA | PCG-21 | Vodafone | Christer.Holmberg@ericsson.com | Rel-8 | CP-38 | Adrian |  | 29.863, 29.163 |
| 3628 | 907.4 | Mn interface (MGCF – IM MGW) |  | 273d? | 2007-11-21 A | 2008-12-05 A | 100% | 2007-11-21 | 2008-12-05 | 273d? | finish no earlier than 2008-12-19 | C4 | 2184h | 2184h | MIW-IMS-St3C4 | PCG-21 | Vodafone | Christer.Holmberg@ericsson.com | Rel-8 | CP-38 | Kimmo |  | 29.332 |
| 3629 | 908 | **IMS Stage 3 IETF Protocol Alignment - phase 2** |  | 1965d? | 2007-06-22 A | 2014-12-09 A | 100% | 2007-06-22 | 2014-12-05 | 1960d? |  | C1; IETF | 55368h | 55368h | IMSProtoc2 |  | Alcatel-Lucent | Keith Drage (drage@alcatel-lucent.com) | Rel-8 |  | Frederic | IMSProtoc2 |  |
| 3630 | 908.1 | CT1 aspects of IMS Stage 3 IETF Protocol Alignment - phase 2 |  | 446d? | 2007-06-22 A | 2009-03-06 A | 100% | 2007-06-22 | 2009-03-06 | 446d? | finish no earlier than 2009-03-06 | C1 | 3568h | 3568h | IMSProtoc2 |  | Alcatel-Lucent | Keith Drage (drage@alcatel-lucent.com) | Rel-8 |  | Frederic |  | 23.218, 24.229, 24.930 |
| 3631 | 908.2 | (IETF) IMS Stage 3 IETF Protocol Alignment (draft-bakker-sipping-3gpp-ims-xml-body-handling) |  | 715d? | 2007-06-22 A | 2012-12-07 A | 100% | 2007-06-22 | 2012-12-07 | 715d? | finish no earlier than 2012-12-07 | C1-IETF | 5720h | 5720h | IMSProtoc2 | PCG-27 | Andrew Allen |  | Rel-8 | CP-52 | Frederic |  | draft-bakker-sipping-3gpp-ims-xml-body-handling |
| 3632 | 908.3 | (IETF) IMS Stage 3 IETF Protocol Alignment (RFC 6544) |  | 587d? | 2007-06-22 A | 2012-06-15 A | 100% | 2007-06-22 | 2012-06-15 | 587d? | finish no earlier than 2012-04-20 | C1-IETF | 4688h | 4688h | IMSProtoc2 | PCG-27 | Keith Drage |  | Rel-8 | CP-52 | Frederic |  | RFC 6544 (was draft-ietf-mmusic-ice-tcp) |
| 3633 | 908.4 | (IETF) IMS Stage 3 IETF Protocol Alignment (draft-ietf-salud-alert-info-urns) |  | 1244d? | 2007-06-22 A | 2014-12-09 A | 100% | 2007-06-22 | 2014-12-05 | 1242d? | finish no earlier than 2014-12-09 | C1-IETF | 9952h | 9952h | IMSProtoc2 | PCG-27 | Roland Jesske | Roland Jesske | Rel-8 | CP-52 | Frederic |  | draft-ietf-salud-alert-info-urns |
| 3634 | 909 | **Interworking between User-to-User Signalling (UUS) and SIP** |  | 1850d? | 2007-11-30 A | 2014-12-09 A | 100% | 2007-11-30 | 2014-12-05 | 1845d? |  | C1; C3; IETF | 68624.4h | 68624.4h | UUSIW | PCG-21 | Huawei | Lili Yang (kadyyang@huawei.com) | Rel-8 | CP-38 | Kimmo | UUSIW |  |
| 3635 | 909.1 | CT1 part of Stage 3 MGCF UUSIW |  | 266d? | 2007-11-30 A | 2008-12-05 A | 100% | 2007-11-30 | 2008-12-05 | 266d? | finish no earlier than 2008-12-05 | C1 | 2128h | 2128h | UUSIW | PCG-21 | Huawei | Lili Yang (kadyyang@huawei.com) | Rel-8 | CP-38 | Frederic |  | 24.279, 24.229 |
| 3636 | 909.2 | (IETF) Stage 3 MGCF UUSIW (cuss-sip-uui) |  | 227.03d? | 2007-11-30 A | 2014-12-09 A | 100% | 2007-11-30 | 2014-12-05 | 225.03d? | finish no earlier than 2014-12-09 | C1-IETF; C3-IETF | 3632.4h | 3632.4h | UUSIW | PCG-27 | Roland Jesske | Roland Jesske | Rel-8 | CP-52 | Frederic |  | RFC 7433 |
| 3637 | 909.3 | (IETF) Stage 3 MGCF UUSIW (cuss-sip-uui-isdn) |  | 986.5d? | 2011-03-17 A | 2014-12-09 A | 100% | 2011-03-17 | 2014-12-05 | 984.5d? | finish no earlier than 2014-12-09 | C1-IETF; C3-IETF | 15784h | 15784h | UUSIW | PCG-28 | Keith Drage | Keith Drage (drage@alcatel-lucent.com) | Rel-8 | CP-55 | Frederic |  | RFC 7434 |
| 3638 | 909.4 | CT3 part of Stage 3 MGCF UUSIW |  | 335d? | 2007-11-30 A | 2009-03-12 A | 100% | 2007-11-30 | 2009-03-12 | 335d? | finish no earlier than 2009-03-12 | C3 | 2680h | 2680h | UUSIW | PCG-21 | Huawei | Lili Yang (kadyyang@huawei.com) | Rel-8 | CP-38 | Adrian |  | 29.163 |

Notes:
- 3611: CP#44 completed
- 3612: SP#40 completed
- 3613: SP#40 completed
- 3614: CP#44 completed
- 3615: CP#43 completed
- 3616: SP#42 completed. SP#46 withdrawn draft 33.178-100 and 33.978 from Rel-8 onwards
- 3617: CP#42 completed
- 3618: CP#43 completed
- 3619: CP#43 completed
- 3620: CP#40 completed
- 3621: SP#39 WID approved
- 3622: SP#43 completed
- 3623: SP#53/IETF#81 completed
- 3624: CP#42 completed
- 3625: SP#31 Moved from FS section Feb 2006
- 3626: Moved from Rel-7. Feature extended in Rel-8 by including Stage 3 covering MONA UID_380021
- 3627: CP#42 completed
- 3628: CP#42 completed
- 3629: CP#43 completed
- 3630: CP#43 completed
- 3631: CP#58 completed. ietf-draft discontinued. Documented within 3GPP
- 3632: CP#56 completed
- 3633: In RFC Editors Queue. Dec.14: 75->90; 7/3/16: 90%->100
- 3634: CP#43 completed
- 3635: CP#42 completed
- 3636: In RFC Editors Queue. Mar15: 90->100%. RFC updated (was draft-ietf-cuss-sip-uui). June 2015: RFC 7433 (was draft-ietf-cuss-sip-uui)
- 3637: In RFC Editors Queue. Dec.14: 75->90. Mar15: 90->100%. RFC updated (was draft-ietf-cuss-sip-uui-isdn). June 2015: RFC 7434 (was draft-ietf-cuss-sip-uui-isdn)
- 3638: CP#43 completed

| ID | WBS | Task | Type | Duration | Start | Finish | Complete | Baseline start | Baseline finish | Baseline duration | Constraint | Resources | Work | Actual work | Acronym | PCG approved | WI rapporteur name | WI rapporteur e-mail | Release | TSG approved | MCC resp | Acronym_3GU_Export | Impacted TSs and TRs | Special Focus Doc | Status Report |
| --- | --- | --- | --- | --- | --- | --- | --- | --- | --- | --- | --- | --- | --- | --- | --- | --- | --- | --- | --- | --- | --- | --- | --- | --- | --- |
| 3639 | 910 | **Support of Overlap signalling** |  | 331d? | 2007-11-30 A | 2009-03-06 A | 100% | 2007-11-30 | 2009-03-06 | 331d? |  | C3; C1; C4 | 15304.2h | 15304.2h | Overlap | PCG-21 | Deutsche Telekom | r.jesske@telekom.de | Rel-8 | CP-38 | Adrian | Overlap |  |  |  |
| 3640 | 910.1 | Stage 3 Overlap (CT1) |  | 331d? | 2007-11-30 A | 2009-03-06 A | 100% | 2007-11-30 | 2009-03-06 | 331d? | finish no earlier than 2009-03-06 | C1 | 2648h | 2648h | Overlap | PCG-21 | Deutsche Telekom | r.jesske@telekom.de | Rel-8 | CP-38 | Frederic |  | 24.229 |  |  |
| 3641 | 910.2 | Stage 3 Overlap (CT3) |  | 331d? | 2007-11-30 A | 2009-03-06 A | 100% | 2007-11-30 | 2009-03-06 | 331d? | finish no earlier than 2009-03-06 | C3 | 2648h | 2648h | Overlap | PCG-21 | Deutsche Telekom | r.jesske@telekom.de | Rel-8 | CP-38 | Adrian |  | 29.163 |  |  |
| 3642 | 910.3 | Stage 3 Overlap (CT4) |  | 258.02d? | 2007-11-30 A | 2008-12-05 A | 100% | 2007-11-30 | 2008-12-05 | 258.02d? | start no earlier than 2007-11-30 | C4 | 2064.16h | 2064.16h | Overlap | PCG-21 | Deutsche Telekom | r.jesske@telekom.de | Rel-8 | CP-38 | Kimmo |  | 29.228, 29.229 |  |  |
| 3643 | 911 | **AS/MRFC Stage 2 and 3** |  | 1203d? | 2007-11-14 A | 2012-06-15 A | 100% | 2007-11-14 | 2012-06-15 | 1203d? |  | C1; IETF | 28384h | 28384h | MRFC_TS | PCG-21 | Hewlett-Packard | mark.syrett@hp.com | Rel-8 | CP-38 | Frederic | MRFC_TS |  |  |  |
| 3644 | 911.1 | AS/MRFC Stage 2 |  | 278d? | 2007-11-14 A | 2008-12-05 A | 100% | 2007-11-14 | 2008-12-05 | 278d? | finish no earlier than 2008-12-05 | C1 | 2224h | 2224h | MRFC_TS | PCG-21 | Hewlett-Packard | mark.syrett@hp.com | Rel-8 | CP-38 | Frederic |  | 23.218 |  |  |
| 3645 | 911.2 | AS/MRFC Stage 3 |  | 278d? | 2007-11-14 A | 2008-12-05 A | 100% | 2007-11-14 | 2008-12-05 | 278d? | finish no earlier than 2008-12-05 | C1 | 2224h | 2224h | MRFC_TS | PCG-21 | Hewlett-Packard | mark.syrett@hp.com | Rel-8 | CP-38 | Frederic |  | 24.229, 24.147, 24.247 |  |  |
| 3646 | 911.3 | (IETF) AS/MRFC Stage 2 and 3 (RFC 6505) |  | 590d? | 2007-11-14 A | 2012-06-15 A | 100% | 2007-11-14 | 2012-06-15 | 590d? | finish no earlier than 2012-06-15 | C1-IETF | 4688h | 4688h | MRFC_TS | PCG-27 | Keith Drage |  | Rel-8 | CP-52 | Frederic |  | RFC 6505 (was draft-ietf-mediactrl-mixer-control-package) |  |  |
| 3647 | 912 | **IMS Restoration Procedures** |  | 201d? | 2008-05-30 A | 2009-03-06 A | 100% | 2008-05-30 | 2009-03-06 | 201d? |  | C4; C1 | 6432h | 6432h | IMS_RP | PCG-21 | Ericsson | german.blanco@ericsson.com | Rel-8 | SP-40 | Kimmo | IMS_RP |  |  |  |
| 3648 | 912.1 | IMS Restoration Procedures (CT4) |  | 201d? | 2008-05-30 A | 2009-03-06 A | 100% | 2008-05-30 | 2009-03-06 | 201d? | finish no earlier than 2009-03-06 | C4 | 1608h | 1608h | IMS_RP | PCG-21 | Ericsson | german.blanco@ericsson.com | Rel-8 | SP-40 | Kimmo |  | 23.380, 29.228, 29.229, 29.230, 23.008 |  |  |
| 3649 | 912.2 | IMS Restoration Procedures (CT1) |  | 201d? | 2008-05-30 A | 2009-03-06 A | 100% | 2008-05-30 | 2009-03-06 | 201d? | finish no earlier than 2009-03-06 | C1 | 1608h | 1608h | IMS_RP | PCG-21 | Ericsson | german.blanco@ericsson.com | Rel-8 | SP-40 | Frederic |  | 24.229 |  |  |
| 3650 | 913 | IMS Application Server Service Data Descriptions for AS interoperability |  | 125d? | 2008-09-12 A | 2009-03-06 A | 100% | 2008-09-12 | 2009-03-06 | 125d? | finish no earlier than 2009-03-06 | C4 | 1000h | 1000h | IMS_ASIO | PCG-21 | Alcatel-Lucent | nhberry@alcatel-lucent.com | Rel-8 | CP-41 | Kimmo | IMS_ASIO | 29.328, 29.329, 29.364 |  |  |
| 3651 | 914 | **I-WLAN Network Selection Principle (NSP)** |  | 451d? | 2007-06-14 A | 2009-03-06 A | 100% | 2007-06-14 | 2009-03-06 | 451d? |  | S1; C1; C6 | 13859.2h | 13859.2h | IWLANNSP |  | Telefónica O2 | chris.friel@O2.com | Rel-8 | TSG-34 | Alain | IWLANNSP |  | WLAN |  |
| 3652 | 914.1 | Stage 1 for I-WLAN NSP | milestone | 0d? | 2007-06-14 A | 2007-06-14 A | 100% | 2007-06-14 | 2007-06-14 | 0d? |  | S1 |  |  | IWLANNSP | PCG-21 | Telefónica O2 | chris.friel@O2.com | Rel-8 | SP-39 | Alain |  | 22.234 | WLAN |  |
| 3653 | 914.2 | CT1 part of Stage 3 for I-WLAN NSP |  | 261d? | 2008-03-07 A | 2009-03-06 A | 100% | 2008-03-07 | 2009-03-06 | 261d? | finish no earlier than 2008-12-05 | C1 | 2088h | 2088h | IWLANNSP | PCG-21 | Research In Motion | Adrian Buckley (abuckley@rim.com) | Rel-8 | CP-39 | Frederic |  | 24.234 | WLAN |  |
| 3654 | 914.3 | CT6 part of Stage 3 for I-WLAN NSP |  | 118.4d? | 2008-03-07 A | 2008-12-11 A | 100% | 2008-03-07 | 2008-12-11 | 118.4d? | finish no earlier than 2008-12-11 | C6 | 947.2h | 947.2h | IWLANNSP | PCG-21 | Research In Motion | Adrian Buckley (abuckley@rim.com) | Rel-8 | CP-39 | Xavier |  | 31.102, 31.111 | WLAN |  |
| 3655 | 915 | **Mobility between 3GPP-WLAN Interworking and 3GPP Systems** |  | 386d? | 2007-09-14 A | 2009-03-06 A | 100% | 2007-09-14 | 2009-03-06 | 386d? |  | S2; C1 | 9304h | 9304h | IWLAN_Mob |  | Orange | xiaobao.chen@orange-ftgroup.com | Rel-8 | SP-37 | Maurice | IWLAN_Mob |  | WLAN |  |
| 3656 | 915.1 | Stage 2 for Mobility between 3GPP-WLAN Interworking and 3GPP Systems |  | 190d? | 2007-09-14 A | 2008-06-05 A | 100% | 2007-09-14 | 2008-06-05 | 190d? | finish no earlier than 2008-09-08 | S2 | 1520h | 1520h | IWLAN_Mob | PCG-21 | Orange | xiaobao.chen@orange-ftgroup.com | Rel-8 | SP-38 | Maurice |  | new 23.327 | WLAN |  |
| 3657 | 915.2 | CT1 aspects of Mobility between 3GPP-WLAN Interworking and 3GPP Systems |  | 201d? | 2008-05-30 A | 2009-03-06 A | 100% | 2008-05-30 | 2009-03-06 | 201d? | finish no earlier than 2009-03-06 | C1 | 1608h | 1608h | IWLAN_Mob | PCG-21 | Orange | reina.nader@orange-ftgroup.com | Rel-8 | CP-40 | Frederic |  | 24.303, new 24.327 | WLAN |  |
| 3658 | 916 | Conformance Test Aspects – Mobility between 3GPP WLAN Interworking and 3GPP Systems |  | 206d? | 2009-12-04 A | 2010-09-17 A | 100% | 2009-12-04 | 2010-09-17 | 206d? | finish no earlier than 2010-09-17 | R5 | 1648h | 1648h | IWLAN_Mob_UEConTest | PCG-24 | Qualcomm | Patrick Stupar (pstupar@qualcomm.com) | Rel-8 | RP-46 | Ingbert | IWLAN_Mob_UEConTest | 34.108, 34.123-1, 34.123-2, 34.123-3 | WLAN | RP-100740 |
| 3659 | 917 | **Enhancements for Voice Group Call Service (VGCS) Applications (EVA)** |  | 919d? | 2006-03-15 A | 2009-09-18 A | 100% | 2006-03-15 | 2009-09-18 | 919d? |  | S1; C1; C4; G2 | 45559.5h | 45559.5h | EVA |  | Nortel | Amar Deol (deola@nortelnetworks.com) | Rel-8 |  | Alain | EVA |  |  |  |
| 3660 | 917.1 | SA1 aspects of EVA |  | 191d? | 2006-03-15 A | 2006-12-06 A | 100% | 2006-03-15 | 2006-12-06 | 191d? | finish no earlier than 2006-12-06 | S1 | 1528h | 1528h | EVA |  | Nortel | Amar Deol (deola@nortelnetworks.com) | Rel-8 |  | Alain |  | 42.068 |  |  |
| 3661 | 917.2 | VGCS/VBS and GPRS Interactions |  | 145d? | 2007-09-03 A | 2008-03-21 A | 100% | 2007-09-03 | 2008-03-21 | 145d? | finish no earlier than 2008-03-21 | S1 | 1160h | 1160h | EVA |  | Huawei | Ling Liu | Rel-8 | SP-37 | Alain |  | 42.068, 42.069 |  |  |
| 3662 | 917.3 | CT1 aspects of EVA |  | 862d? | 2006-06-02 A | 2009-09-18 A | 100% | 2006-06-02 | 2009-09-18 | 862d? | finish no earlier than 2009-12-04 | C1 | 6887.53h | 6887.53h | EVA |  | Nortel | milanpa@nortel.com | Rel-8 |  | Frederic |  | 43.068, 44.068 |  |  |
| 3663 | 917.4 | CT4 aspects of EVA |  | 391d? | 2006-06-02 A | 2007-11-30 A | 100% | 2006-06-02 | 2007-11-30 | 391d? | finish no earlier than 2007-06-01 | C4 | 3128h | 3128h | EVA |  | Nortel |  | Rel-8 |  | Kimmo |  | 29.002 |  |  |
| 3664 | 917.5 | GERAN2 aspects of EVA |  | 431d? | 2006-06-30 A | 2008-02-22 A | 100% | 2006-06-30 | 2008-02-22 | 431d? | finish no earlier than 2008-02-22 | G2 | 3448h | 3448h | EVA |  | Nortel | frank.billenkamp@nortel.com | Rel-8 |  | Gert |  | 44.018, 48.008 |  |  |

Notes:
- 3639: CP#43 completed
- 3640: CP#43 completed
- 3641: CP#43 completed
- 3642: CP#42 completed
- 3643: Triggered by Study UID_7048 (MRFC)
- 3644: CP#42 completed
- 3645: CP#42 completed
- 3646: CP#56 completed
- 3647: CP#43 completed. Triggered by Study TR 23.820 (FS_IMS_RP) UID_350018
- 3648: CP#43 completed
- 3649: CP#43 completed
- 3650: CP#43 completed. Triggered by UID_360030 (FS_IMS_ASIO)
- 3651: CP#43 completed
- 3652: SP#36 completed
- 3653: CP#43 completed
- 3654: CP#42 completed
- 3655: CP#43 completed
- 3656: SP#40 completed
- 3657: CP#43 completed
- 3658: RP#49 completed. Testing for Rel-8 UID_400013 CT1 aspects of mobility between 3GPP WLAN Interworking and 3GPP Systems (24.327)
- 3659: CP#45 completed
- 3660: SP#38 completed
- 3661: SP#39 completed
- 3662: CP#45 completed
- 3663: CP#38 completed
- 3664: GP#37 completed

| ID | WBS | Task | Type | Duration | Start | Finish | Complete | Baseline start | Baseline finish | Baseline duration | Constraint | Resources | Work | Actual work | Acronym | WI rapporteur name | WI rapporteur e-mail | Release | MCC resp | Acronym_3GU_Export | Impacted TSs and TRs | TSG stopped | Special Focus Doc | TSG approved | PCG approved | Status Report |
| --- | --- | --- | --- | --- | --- | --- | --- | --- | --- | --- | --- | --- | --- | --- | --- | --- | --- | --- | --- | --- | --- | --- | --- | --- | --- | --- |
| 3665 | 918 | **Personal Network Management** |  | 955d? | 2005-07-11 A | 2009-03-06 A | 100% | 2005-07-11 | 2009-03-06 | 955d? |  | S1; C1; S3 | 46368h | 46368h | PNM | Vodafone | armin.toepfer@vodafone.com | Rel-8 | Alain | PNM |  |  |  |  |  |  |
| 3666 | 918.1 | Stage 1 for PNM |  | 276d? | 2005-07-11 A | 2006-07-31 A | 100% | 2005-07-11 | 2006-07-31 | 276d? | start no earlier than 2005-07-11 | S1 | 2208h | 2208h | PNM | Vodafone | armin.toepfer@vodafone.com | Rel-8 | Alain |  | 22.259 |  |  |  |  |  |
| 3667 | 918.2 | Stage 2 for PNM |  | 445d? | 2007-03-26 A | 2008-12-05 A | 100% | 2007-03-26 | 2008-12-05 | 445d? | finish no earlier than 2008-12-05 | C1 | 3560h | 3560h | PNM | Vodafone | yang.lu@vodafone.com | Rel-8 | Frederic |  | 23.259 |  |  |  |  |  |
| 3668 | 918.3 | **Stage 3 for PNM** |  | 510d? | 2007-03-26 A | 2009-03-06 A | 100% | 2007-03-26 | 2009-03-06 | 510d? |  | C1; C4 | 15800h | 15800h | PNM | Vodafone | yang.lu@vodafone.com | Rel-8 | Frederic |  |  |  |  |  |  |  |
| 3669 | 918.3.1 | CT1 aspects of Stage 3 PNM |  | 510d? | 2007-03-26 A | 2009-03-06 A | 100% | 2007-03-26 | 2009-03-06 | 510d? | finish no earlier than 2008-12-05 | C1 | 4080h | 4080h | PNM | Vodafone | yang.lu@vodafone.com | Rel-8 | Frederic |  | 24.259, 24.229 |  |  |  |  |  |
| 3670 | 918.3.2 | Deleted - CT4 aspects of Stage 3 PNM |  | 445d? | 2007-03-26 A | 2008-12-05 A | 100% | 2007-03-26 | 2008-12-05 | 445d? | finish no earlier than 2008-12-11 | C4 | 3560h | 3560h | PNM | Vodafone | yang.lu@vodafone.com | Rel-8 | Kimmo |  |  | CP-42 |  |  |  |  |
| 3671 | 918.4 | Key establishment between a UICC hosting device and a remote device |  | 235d? | 2006-12-06 A | 2007-10-30 A | 100% | 2006-12-06 | 2007-10-30 | 235d? | finish no earlier than 2007-10-30 | S3 | 1880h | 1880h | PNM | Ericsson | Vesa.Lehtovirta@ericsson.com | Rel-8 | Mirko |  | 33.259 |  |  |  |  |  |
| 3672 | 918.5 | Deleted - Actual Requirements of PNM | milestone | 0d? | 2007-03-26 A | 2007-03-26 A | 100% | 2007-03-26 | 2007-03-26 | 0d? | finish no earlier than 2007-03-26 | C1 |  |  | PNM | Ericsson |  | Rel-8 | Frederic |  |  | SP-37 |  |  |  |  |
| 3673 | 919 | **eCall Data Transfer** |  | 637d? | 2006-09-28 A | 2009-03-06 A | 100% | 2006-09-28 | 2009-03-06 | 637d? |  | S1; C1 | 14840h | 14840h | EData | Airbiquity | rrobinson@airbiquity.com | Rel-8 | Alain | EData |  |  | Public Safety (I-A) |  |  |  |
| 3674 | 919.1 | eData Requirements |  | 380d? | 2006-09-28 A | 2008-03-12 A | 100% | 2006-09-28 | 2008-03-12 | 380d? | finish no earlier than 2006-12-07 | S1 | 3040h | 3040h | EData | Airbiquity | rrobinson@airbiquity.com | Rel-8 | Alain |  | 22.101, 22.105 |  | Public Safety (I-A) | SP-37 |  |  |
| 3675 | 919.2 | Transfer of data during an emergency call |  | 201d? | 2008-05-30 A | 2009-03-06 A | 100% | 2008-05-30 | 2009-03-06 | 201d? | finish no earlier than 2009-03-06 | C1 | 1608h | 1608h | EData | T-Mobile | Dieter Jacobsohn | Rel-8 | Frederic |  | 24.008 |  | Public Safety (I-A) | SP-40 | PCG-21 |  |
| 3676 | 920 | eCall data transfer Phase 2: Comparison of alternative in-band modem solutions and standardization of one in-band modem solution |  | 472d? | 2007-12-06 A | 2009-09-24 A | 100% | 2007-12-06 | 2009-09-24 | 472d? | finish no earlier than 2009-09-24 | S4 | 3768.09h | 3768.09h | eCall_Phase2 | Airbiquity | lhong@airbiquity.com & rrobinson@airbiquity.com | Rel-8 | Paolo | eCall_Phase2 | 26.267, 26.268, 26.269, 26.967, 26.969 |  | Public Safety (I-A) |  |  |  |
| 3677 | 921 | eCall Conformance Testing |  | 261d? | 2009-09-04 A | 2010-09-03 A | 100% | 2009-09-04 | 2010-09-03 | 261d? | finish no earlier than 2010-09-03 | G3new | 2088h | 2088h | eCall_MSTest | Ericsson, Qualcomm | Vikrant Jain (vikrantj@qualcomm.com) | Rel-8 | Ingbert | eCall_MSTest | 51.010-1, 51.010-2 |  | Public Safety (I-A) | GP-45 | PCG-23 |  |
| 3678 | 922 | Conformance Test Aspects – non-modem procedures of eCall sessions in UTRA |  | 186d? | 2009-09-18 A | 2010-06-04 A | 100% | 2009-09-18 | 2010-06-04 | 186d? | finish no earlier than 2010-06-04 | R5 | 1488h | 1488h | UMTS_eCall_UEConTest | Ericsson, Qualcomm | Shubhang Vora (svora@qualcomm.com) | Rel-8 | Ingbert | UMTS_eCall_UEConTest | 34.108, 34.123-1, 34.123-2, 34.123-3 |  | Public Safety (I-A) | RP-45 | PCG-23 | RP-100489 |
| 3679 | 923 | **IP Interconnection of Services** |  | 668d? | 2006-08-16 A | 2009-03-06 A | 100% | 2006-08-16 | 2009-03-06 | 668d? |  | S1; S2; S5; C3 | 44240h | 44240h | IPinterc | Telefónica O2 | chris.friel@O2.com | Rel-8 | Alain | IPinterc |  |  |  | SP-38 | PCG-21 |  |
| 3680 | 923.1 | Stage 1 for IPinterc |  | 70d? | 2007-12-06 A | 2008-03-12 A | 100% | 2007-12-06 | 2008-03-12 | 70d? | start no earlier than 2007-12-06 | S1 | 560h | 560h | IPinterc | Telefónica O2 | chris.friel@O2.com | Rel-8 | Alain |  | 22.101, 22.228 |  |  | SP-38 | PCG-21 |  |
| 3681 | 923.2 | **System enhancements for interconnection interfaces between two IMSs** |  | 668d? | 2006-08-16 A | 2009-03-06 A | 100% | 2006-08-16 | 2009-03-06 | 668d? |  | S2; S5; C3 | 22304h | 22304h | IMS_NNI | Telecom Italia | Mario Madella (mario.madella@telecomitalia.it) | Rel-8 | Maurice | IMS_NNI |  |  |  |  |  |  |
| 3682 | 923.2.1 | Stage 2 for IMS_NNI |  | 120d? | 2007-06-22 A | 2007-12-06 A | 100% | 2007-06-22 | 2007-12-06 | 120d? | finish no earlier than 2007-12-21 | S2 | 960h | 960h | IMS_NNI | Telecom Italia | Mario Madella (mario.madella@telecomitalia.it) | Rel-8 | Maurice |  | 23.002, 23.228 |  |  |  |  |  |
| 3683 | 923.2.2 | IMS inter-operator service interconnection interface |  | 461d? | 2007-06-01 A | 2009-03-06 A | 100% | 2007-06-01 | 2009-03-06 | 461d? | finish no earlier than 2009-03-06 | C3 | 3688h | 3688h | FBI2-IOPSI | Telecom Italia | antonio.ascolese@telecomitalia.it | Rel-8 | Adrian | FBI2-IOPSI | 29.865, 29.165 |  |  |  |  |  |
| 3684 | 923.2.3 | Charging harmonization for NGN between 3GPP and ATIS-TMOC |  | 51d? | 2006-09-28 A | 2006-12-07 A | 100% | 2006-09-28 | 2006-12-07 | 51d? | finish no earlier than 2006-12-07 | S5 | 408h | 408h | FBI2-TISP2-CH | Amdocs | yishai.brown@amdocs.com | Rel-8 | Mirko | FBI2-TISP2-CH | 32.297 |  |  |  |  |  |
| 3685 | 923.2.4 | Deleted - Protocol impact of FBI for TISPAN R2 |  | 152d? | 2006-08-16 A | 2007-03-15 A | 100% | 2006-08-16 | 2007-03-15 | 152d? | finish no earlier than 2007-03-15 | C1 | 1216h | 1216h | FBI2-TISP2-c1 | Ericsson |  | Rel-8 | Frederic | FBI2-TISP2-c1 |  | SP-38 |  |  |  |  |
| 3686 | 923.2.5 | Deleted (never approved) - Stage 2 of FBI for TISPAN R2 - Rel 8 | milestone | 0d? | 2007-11-30 A | 2007-11-30 A | 100% | 2007-11-30 | 2007-11-30 | 0d? | finish no earlier than 2007-11-30 | S2 |  |  | FBI2-TISP2-s2 | Nokia Siemens Networks |  | Rel-8 | Maurice | FBI2-TISP2-s2 |  | SP-36 |  |  |  |  |
| 3687 | 924 | **Support of (G)MSC-S – (G)MSC-S Nc Interface based on the SIP-I protocol** |  | 386d? | 2007-09-14 A | 2009-03-06 A | 100% | 2007-09-14 | 2009-03-06 | 386d? |  | C4; C3 | 14960h | 14960h | SIP_Nc | Vodafone | David.Hutton@vodafone.com | Rel-8 | Kimmo | SIP_Nc |  |  |  |  |  |  |
| 3688 | 924.1 | Stage 1 for SIP_Nc (covered by Feature IPinterc) |  | 70d? | 2007-12-06 A | 2008-03-12 A | 100% | 2007-12-06 | 2008-03-12 | 70d? | start no earlier than 2007-12-06 | S1 | 560h | 560h | SIP_Nc | Telefónica O2 | chris.friel@O2.com | Rel-8 | Alain |  | 22.101, 22.228 |  |  | CP-41 | PCG-21 |  |
| 3689 | 924.2 | SIP-I based circuit-switched core network; Stage 2 |  | 321d? | 2007-09-14 A | 2008-12-05 A | 100% | 2007-09-14 | 2008-12-05 | 321d? | finish no earlier than 2008-12-11 | C4 | 2568h | 2568h | SIP_Nc-St2 | Vodafone | David.Hutton@vodafone.com | Rel-8 | Kimmo | SIP_Nc-St2 | 23.231, 23.153, 23.205 |  |  |  |  |  |
| 3690 | 924.3 | Application of SIP-I Protocols to Circuit Switched (CS) core network architecture; Stage 3 |  | 321d? | 2007-09-14 A | 2008-12-05 A | 100% | 2007-09-14 | 2008-12-05 | 321d? | finish no earlier than 2008-12-11 | C4 | 2568h | 2568h | SIP_Nc-St3C4 | Vodafone | David.Hutton@vodafone.com | Rel-8 | Kimmo | SIP_Nc-St3 | 29.231, 29.232, 29.332 |  |  |  |  |  |
| 3691 | 924.4 | Interworking between the 3GPP CS domain with SIP-I as signalling protocol and other networks |  | 386d? | 2007-09-14 A | 2009-03-06 A | 100% | 2007-09-14 | 2009-03-06 | 386d? | finish no earlier than 2009-03-06 | C3 | 3088h | 3088h | SIP_Nc-St3C3 | Nokia Siemens Networks | Thomas.Belling@nsn.com | Rel-8 | Adrian |  | 29.235, 23.172, 23.202, 29.007, 29.163, 29.414 |  |  |  |  |  |

Notes:
- 3665: CP#43 completed
- 3666: SP#31 completed
- 3667: CP#42 completed
- 3668: CP#43 completed
- 3669: CP#43 completed
- 3670: CP#42 no impact on CT4 specs
- 3671: SP#37 completed
- 3672: SP#37 stopped
- 3673: SP#39 completed. Linked to SA4 Feature UID_34042 (eCall_Phase2)
- 3674: SP#39 completed
- 3675: CP#43 completed
- 3676: SP#45 completed. Triggered by Study UID_360015 (eCALLIBMS). Linked to SA1 Feature UID_330005 (EData)
- 3677: GP#47 completed. GP#43 WID approved. Testing for Rel-8 eCall_Phase2 (UID_34042) and EData (UID_330005)
- 3678: RP#48 completed. Testing for Rel-8 eCall_Phase2 (UID_34042) and Edata (UID_330005)
- 3679: SP#43 completed
- 3680: SP#39 completed.
- 3681: CP#43 completed
- 3682: SP#38 completed
- 3683: CP#43 completed
- 3684: SP#34 completed
- 3685: SP#38 stopped
- 3686: SP#36 stopped
- 3687: CP#43 completed. Stage 1 in Feature UID_380060 (IPinterc). CP#40 updated WID CP-070517=>CP-080282
- 3688: 22/07/08 Created. Stage 1 for SIP_Nc (covered by SA1 Feature UID_380060 Ipinterc)
- 3689: CP#42 completed
- 3690: CP#42 completed
- 3691: CP#43 completed. CP#42 target 12/08=>03/09

| ID | WBS | Task | Type | Duration | Start | Finish | Complete | Baseline start | Baseline finish | Baseline duration | Constraint | Resources | Work | Actual work | Acronym | WI rapporteur name | WI rapporteur e-mail | Release | TSG approved | MCC resp | Special Focus Doc | Acronym_3GU_Export | Impacted TSs and TRs | PCG approved | Status Report |
| --- | --- | --- | --- | --- | --- | --- | --- | --- | --- | --- | --- | --- | --- | --- | --- | --- | --- | --- | --- | --- | --- | --- | --- | --- | --- |
| 3692 | 925 | **Earthquake and Tsunami Warning System** |  | 440d? | 2007-09-10 A | 2009-05-15 A | 100% | 2007-09-10 | 2009-05-15 | 440d? |  | S1; S2; C1; C4; G2 | 21280h | 21280h | ETWS | NTT DoCoMo | kitaharar@nttdocomo.co.jp | Rel-8 | SP-37 | Alain | Public Safety (I-A) | ETWS |  |  |  |
| 3693 | 925.1 | Stage 1 for ETWS |  | 133d? | 2007-09-10 A | 2008-03-12 A | 100% | 2007-09-10 | 2008-03-12 | 133d? | finish no earlier than 2008-03-12 | S1 | 1064h | 1064h | ETWS | NTT DoCoMo | kitaharar@nttdocomo.co.jp | Rel-8 | SP-37 | Alain | Public Safety (I-A) |  | 22.168 |  |  |
| 3694 | 925.2 | SA2 aspects of ETWS |  | 179d? | 2008-01-14 A | 2008-09-18 A | 100% | 2008-01-14 | 2008-09-18 | 179d? | finish no earlier than 2008-09-08 | S2 | 1432h | 1432h | ETWS | NTT DoCoMo | tanakai@nttdocomo.co.jp | Rel-8 | SP-38 | Maurice | Public Safety (I-A) |  | 23.828, 23.401 | PCG-21 |  |
| 3695 | 925.3 | CT1 aspects of ETWS |  | 50.5d? | 2008-05-30 A | 2008-12-05 A | 100% | 2008-05-30 | 2008-12-05 | 50.5d? | finish no earlier than 2008-12-05 | C1 | 404h | 404h | ETWS | NTT DoCoMo | yamashitahi@s1.nttdocomo.co.jp | Rel-8 | CP-40 | Frederic | Public Safety (I-A) |  | 23.041 | PCG-21 |  |
| 3696 | 925.4 | CT4 aspects of ETWS |  | 50.5d? | 2008-09-26 A | 2008-12-05 A | 100% | 2008-09-26 | 2008-12-05 | 50.5d? | finish no earlier than 2008-12-05 | C4 | 404h | 404h | ETWS | NTT DoCoMo | yamashitahi@s1.nttdocomo.co.jp | Rel-8 | CP-40 | Kimmo | Public Safety (I-A) |  | 29.168 | PCG-21 |  |
| 3697 | 925.5 | ETWS primary notification message definition in GERAN |  | 47d? | 2009-03-12 A | 2009-05-15 A | 100% | 2009-03-12 | 2009-05-15 | 47d? | finish no earlier than 2009-05-15 | G2 | 376h | 376h | ETWS | Ericsson | claes-goran.persson@ericsson.com | Rel-8 | SP-43 | Gert | Public Safety (I-A) |  | 44.018, 44.060 | PCG-22 |  |
| 3698 | 926 | Conformance Test Aspects – UMTS Earthquake and Tsunami Warning System (ETWS) FDD |  | 207d? | 2009-05-29 A | 2010-03-12 A | 100% | 2009-05-29 | 2010-03-12 | 207d? | finish no earlier than 2010-03-12 | R5 | 1656h | 1656h | ETWS_UMTS_UEConTestFDD | NTT DoCoMo | Makoto Ito (itohm@nttdocomo.co.jp) | Rel-8 | RP-44 | Ingbert | Public Safety (I-A) | ETWS_UMTS_UEConTestFDD | 34.108, 34.123-1, 34.123-2 | PCG-23 | RP-100068 |
| 3699 | 927 | **In Case of Emergency numbers storage and easy access on UICC** |  | 519d? | 2007-03-13 A | 2009-03-06 A | 100% | 2007-03-13 | 2009-03-06 | 519d? |  | S1; C6 | 14552h | 14552h | ICE | Vodafone | armin.toepfer@vodafone.com | Rel-8 | SP-38 | Alain |  | ICE |  | PCG-21 |  |
| 3700 | 927.1 | Stage 1 for ICE |  | 262d? | 2007-03-13 A | 2008-03-12 A | 100% | 2007-03-13 | 2008-03-12 | 262d? | finish no earlier than 2008-03-12 | S1 | 2096h | 2096h | ICE | Vodafone | armin.toepfer@vodafone.com | Rel-8 | SP-38 | Alain |  |  | 22.030, 22.101 | PCG-21 |  |
| 3701 | 927.2 | CT6 aspects of ICE |  | 519d? | 2007-03-13 A | 2009-03-06 A | 100% | 2007-03-13 | 2009-03-06 | 519d? | finish no earlier than 2009-03-06 | C6 | 4152h | 4152h | ICE | Vodafone | armin.toepfer@vodafone.com | Rel-8 | SP-38 | Xavier |  |  | 31.102 | PCG-21 |  |
| 3702 | 928 | Local Charging Zone Requirements |  | 380d? | 2006-09-28 A | 2008-03-12 A | 100% | 2006-09-28 | 2008-03-12 | 380d? | finish no earlier than 2006-12-07 | S1 | 3040h | 3040h | LCZR | China Mobile | liuhongyfw@chinamobile.com | Rel-8 |  | Alain |  | LCZR | 22.115 |  |  |
| 3703 | 929 | **Customized Alerting Tone (CAT) service** |  | 729d? | 2006-12-06 A | 2009-09-18 A | 100% | 2006-12-06 | 2009-09-18 | 729d? |  | S1; C1; C3; C4 | 39854h | 39854h | CAT | China Mobile | fenglingjuan@chinamobile.com | Rel-8 | TSG-34 | Alain |  | CAT |  |  |  |
| 3704 | 929.1 | Stage 1 for CAT |  | 207d? | 2006-12-06 A | 2007-09-20 A | 100% | 2006-12-06 | 2007-09-20 | 207d? | start no earlier than 2006-12-06 | S1 | 1656h | 1656h | CAT | China Mobile | fenglingjuan@chinamobile.com | Rel-8 | SP-37 | Alain |  |  | 22.182 |  |  |
| 3705 | 929.2 | TISPAN requirements for customized multimedia information services |  | 71d? | 2007-09-03 A | 2007-12-10 A | 100% | 2007-09-03 | 2007-12-10 | 71d? | finish no earlier than 2007-12-10 | S1 | 568h | 568h | TISCMI | China Mobile | fenglingjuan@chinamobile.com | Rel-8 | SP-37 | Alain |  | TISCMI | 22.182 |  |  |
| 3706 | 929.3 | **IMS CAT Supplementary Service** |  | 399d? | 2008-03-12 A | 2009-09-18 A | 100% | 2008-03-12 | 2009-09-18 | 399d? |  | C1; C3 | 10814.4h | 10814.4h | CAT-SS | Nortel | milanpa@nortel.com | Rel-8 | CP-39 | Frederic |  | CAT-SS |  | PCG-21 |  |
| 3707 | 929.3.1 | IMS CAT SS |  | 164d? | 2008-04-21 A | 2008-12-04 A | 100% | 2008-04-21 | 2008-12-04 | 164d? | finish no earlier than 2008-12-05 | C1 | 1312h | 1312h | CAT-SS | Nortel | milanpa@nortel.com | Rel-8 | CP-39 | Frederic |  |  | 24.182 | PCG-21 |  |
| 3708 | 929.3.2 | CAT solution for voice and video call in CS domain |  | 389.8d? | 2008-03-12 A | 2009-09-18 A | 100% | 2008-03-12 | 2009-09-18 | 389.8d? | finish no earlier than 2009-09-11 | C3 | 3118.4h | 3118.4h | CAT-SS | Nortel | milanpa@nortel.com | Rel-8 | CP-39 | Adrian |  |  | 29.163 | PCG-21 |  |
| 3709 | 929.4 | **CAT Service in 3GPP CS domain** |  | 126d? | 2008-09-12 A | 2009-03-06 A | 100% | 2008-09-12 | 2009-03-06 | 126d? |  | C4; C1 | 3487.6h | 3487.6h | CAT-3G_CS | China Mobile | zhaoyuyi@chinamobile.com | Rel-8 | CP-41 | Kimmo |  | CAT-3G_CS | 23.205, 23.231, 29.002 | PCG-21 |  |
| 3710 | 929.4.1 | CT4 part of CAT Service in 3GPP CS domain |  | 126d? | 2008-09-12 A | 2009-03-06 A | 100% | 2008-09-12 | 2009-03-06 | 126d? | finish no earlier than 2009-03-06 | C4 | 1008h | 1008h | CAT-3G_CS | China Mobile | zhaoyuyi@chinamobile.com | Rel-8 | CP-41 | Kimmo |  |  | 23.205, 23.231, 29.002 | PCG-21 |  |
| 3711 | 929.4.2 | CT1 part of CAT Service in 3GPP CS domain |  | 57.95d? | 2008-09-12 A | 2008-12-05 A | 100% | 2008-09-12 | 2008-12-05 | 57.95d? | start no earlier than 2008-09-12 | C1 | 463.6h | 463.6h | CAT-3G_CS | China Mobile | zhaoyuyi@chinamobile.com | Rel-8 | CP-41 | Frederic |  |  | 24.008, 23.014 | PCG-21 |  |
| 3712 | 930 | **Service-Level Interworking for Messaging Services** |  | 509d? | 2007-03-26 A | 2009-03-06 A | 100% | 2007-03-26 | 2009-03-06 | 509d? |  | S1; S2; C3; C1 | 20800h | 20800h | MESSIW | Huawei | ling.liu@huawei.com; duanxiaoqin@huawei.com | Rel-8 | TSG-34 | Alain |  | MESSIW |  |  |  |
| 3713 | 930.1 | Stage 1 for MESSIW | milestone | 0d? | 2007-03-26 A | 2007-03-26 A | 100% | 2007-03-26 | 2007-03-26 | 0d? | finish no earlier than 2007-12-01 | S1 |  |  | MESSIW | Huawei | ling.liu@huawei.com | Rel-8 |  | Alain |  |  | 22.105, 22.340 |  |  |
| 3714 | 930.2 | Stage 2 for MESSIW |  | 227d? | 2007-04-26 A | 2008-03-07 A | 100% | 2007-04-26 | 2008-03-07 | 227d? | finish no earlier than 2008-03-07 | S2 | 1816h | 1816h | MESSIW | Huawei | patrice.hede@huawei.com | Rel-8 |  | Maurice |  |  | 23.811, 23.204 |  |  |
| 3715 | 930.3 | CT3 part of Stage 3 for MESSIW |  | 201d? | 2008-05-30 A | 2009-03-06 A | 100% | 2008-05-30 | 2009-03-06 | 201d? | finish no earlier than 2008-12-05 | C3 | 1608h | 1608h | MESSIW | Huawei | xupeili@huawei.com | Rel-8 | CP-40 | Adrian |  |  | 29.311 | PCG-21 |  |
| 3716 | 930.4 | CT1 part of Stage 3 for MESSIW |  | 136d? | 2008-05-30 A | 2008-12-05 A | 100% | 2008-05-30 | 2008-12-05 | 136d? | finish no earlier than 2008-12-12 | C1 | 1088h | 1088h | MESSIW | Huawei | xupeili@huawei.com | Rel-8 | CP-40 | Frederic |  |  | 24.229 | PCG-21 |  |

Notes:
- 3692: SP#43 Larger scope Feature UID_380057 (PWS) moved to Rel-9
- 3693: SP#39 completed
- 3694: SP#41 completed
- 3695: CP#42 completed
- 3696: CP#42 completed
- 3697: SP#44 completed with CT1 help (GERAN2 LS_in SP-090154)
- 3698: RP#47 completed. Testing for Rel-8 ETWS UID_370051
- 3699: CP#43 completed (ICE Graphics not included in Rel-8)
- 3700: SP#39 Stage 1 completed
- 3701: CP#43 completed (ICE Graphics not in Rel-8 / not explicitly in SA1 WID either)
- 3702: SP#39 Stage 1 completed
- 3703: CP#45 completed
- 3704: -
- 3705: SP#38 completed
- 3706: -
- 3707: CP#42 completed
- 3708: CP#45 completed. Triggered by Study UID_360031 (TR 29.882)
- 3709: -
- 3710: CP#43 completed. Triggered by Study UID_360031 (TR 29.882)
- 3711: CP#42 completed. Triggered by Study UID_360031 (TR 29.882)
- 3712: CP#43 completed
- 3713: SP#35 completed
- 3714: SP#39 completed
- 3715: CP#43 completed
- 3716: CP#42 completed

| ID | WBS | Task | Duration | Start | Finish | Complete | Baseline start | Baseline finish | Baseline duration | Constraint | Resources | Work | Actual work | Acronym | WI rapporteur name | WI rapporteur e-mail | Release | TSG approved | MCC resp | Special Focus Doc | Acronym_3GU_Export | Impacted TSs and TRs | PCG stopped | TSG stopped | PCG approved |
| --- | --- | --- | --- | --- | --- | --- | --- | --- | --- | --- | --- | --- | --- | --- | --- | --- | --- | --- | --- | --- | --- | --- | --- | --- | --- |
| 3717 | 931 | **Multimedia Priority Service** | 858d? | 2006-06-08 A | 2009-09-18 A | 100% | 2006-06-08 | 2009-09-18 | 858d? |  | S1; C1; C3; C4 | 43016h | 43016h | PRIOR_EMR | Telcordia | jgarraha@telcordia.com | Rel-8 | SP-34 | Alain | Public Safety (I-A) | PRIOR |  |  |  |  |
| 3718 | 931.1 | Service Requirements for PRIOR | 391d? | 2006-06-08 A | 2007-12-06 A | 100% | 2006-06-08 | 2007-12-06 | 391d? | finish no earlier than 2007-11-30 | S1 | 3128h | 3128h | PRIOR_EMR | Telcordia | jgarraha@telcordia.com | Rel-8 | SP-32 | Alain | Public Safety (I-A) | PRIOR-EMR | New 22.153 |  |  |  |
| 3719 | 931.2 | CT1 part of Stage 3 for PRIOR | 732d? | 2006-12-01 A | 2009-09-18 A | 100% | 2006-12-01 | 2009-09-18 | 732d? | finish no earlier than 2009-09-18 | C1 | 5856h | 5856h | PRIOR_EMR | Alcatel-Lucent | Keith Drage (drage@alcatel-lucent.com) | Rel-8 | CP-34 | Frederic | Public Safety (I-A) |  | 24.229 |  |  |  |
| 3720 | 931.3 | CT4 part of Stage 3 for PRIOR | 381d? | 2007-09-21 A | 2009-03-06 A | 100% | 2007-09-21 | 2009-03-06 | 381d? | finish no earlier than 2009-03-06 | C4 | 3048h | 3048h | PRIOR_EMR | Alcatel-Lucent | Keith Drage (drage@alcatel-lucent.com) | Rel-8 | CP-37 | Kimmo | Public Safety (I-A) |  | 23.008, 29.228, 29.229 |  |  |  |
| 3721 | 931.4 | Deleted - Stage 3 for PRIOR | 441d? | 2007-09-21 A | 2009-05-29 A | 100% | 2007-09-21 | 2009-05-29 | 441d? | finish no earlier than 2009-05-29 | C3 | 3528h | 3528h | PRIOR-EMR | Alcatel-Lucent | Keith Drage (drage@alcatel-lucent.com) | Rel-8 | CP-37 | Adrian | Public Safety (I-A) |  | 29.212, 29.213, 29.214, 29.163 | PCG-23 | CP-44 |  |
| 3722 | 932 | **Open Service Access (OSA) Rel-8** | 202d? | 2007-08-23 A | 2008-05-30 A | 100% | 2007-08-23 | 2008-05-30 | 202d? |  | S1; C5 | 25528h | 25528h | OSA8 | Orange | Song Dong | Rel-8 |  | Alain |  | OSA8 |  |  |  |  |
| 3723 | 932.1 | OSA Stage 1 - Service Requirements | 145d? | 2007-08-23 A | 2008-03-12 A | 100% | 2007-08-23 | 2008-03-12 | 145d? | finish no earlier than 2007-12-04 | S1 | 1160h | 1160h | OSA8 | Orange, AePONA | Song Dong | Rel-8 |  | Alain |  |  | 22.127 |  |  |  |
| 3724 | 932.2 | OSA Stage 1 - NGN Service Requirement | 140d? | 2007-09-03 A | 2008-03-14 A | 100% | 2007-09-03 | 2008-03-14 | 140d? | finish no earlier than 2008-03-14 | S1 | 1120h | 1120h | OSA8-IMSReq | Orange | Song Dong | Rel-8 | SP-37 | Alain |  | OSA8-IMS | 22.127 |  |  |  |
| 3725 | 932.3 | **Rel-8 OSA Stage 2/3 enhancements** | 157d? | 2007-10-25 A | 2008-05-30 A | 100% | 2007-10-25 | 2008-05-30 | 157d? |  | C5 | 20016h | 20016h | OSA8-IMS | Alcatel-Lucent | unmehopa@alcatel-lucent.com | Rel-8 |  | Kimmo |  |  | 23.198, 29.198, 29.199 |  |  |  |
| 3726 | 932.3.1 | Deleted - Ensure Parlay-X composable with identity management frameworks, in particular Liberty Alliance | 157d? | 2007-10-25 A | 2008-05-30 A | 100% | 2007-10-25 | 2008-05-30 | 157d? | finish no earlier than 2008-12-25 | C5 | 1256h | 1256h |  | Ericsson | catherine.mulligan@ericsson.com | Rel-8 | CP-37 | Kimmo |  |  | existing 29.199-xy | PCG-21 | CP-40 | PCG-21 |
| 3727 | 932.3.2 | Parlay-X Content Management web service (store/manage meta-data) | 157d? | 2007-10-25 A | 2008-05-30 A | 100% | 2007-10-25 | 2008-05-30 | 157d? | finish no earlier than 2008-12-04 | C5 | 1256h | 1256h | OSA8-IMS | Alcatel-Lucent | unmehopa@alcatel-lucent.com | Rel-8 | CP-37 | Kimmo |  |  | 29.199-21 |  |  |  |
| 3728 | 932.3.3 | Parlay-X Policy web service | 157d? | 2007-10-25 A | 2008-05-30 A | 100% | 2007-10-25 | 2008-05-30 | 157d? | finish no earlier than 2008-12-04 | C5 | 1256h | 1256h | OSA8-IMS | Alcatel-Lucent | unmehopa@alcatel-lucent.com | Rel-8 | CP-37 | Kimmo |  |  | 29.199-22 |  |  |  |
| 3729 | 932.3.4 | Parlay-X Terminal status web service | 157d? | 2007-10-25 A | 2008-05-30 A | 100% | 2007-10-25 | 2008-05-30 | 157d? | finish no earlier than 2008-05-30 | C5 | 1256h | 1256h | OSA8-IMS | Alcatel-Lucent | unmehopa@alcatel-lucent.com | Rel-8 | CP-37 | Kimmo |  |  | 29.199-08 |  |  |  |
| 3730 | 932.3.5 | Deleted - Identify communication format used by a particular application | 157d? | 2007-10-25 A | 2008-05-30 A | 100% | 2007-10-25 | 2008-05-30 | 157d? | finish no earlier than 2008-05-30 | C5 | 1256h | 1256h |  | Ericsson | catherine.mulligan@ericsson.com | Rel-8 | CP-37 | Kimmo |  |  | existing 29.199-xy | PCG-21 | CP-40 | PCG-21 |
| 3731 | 932.3.6 | Deleted - Security on User Profile Management - reuse GUP API (22.127 CR 0084 S1-071794) | 128d? | 2007-12-05 A | 2008-05-30 A | 100% | 2007-12-05 | 2008-05-30 | 128d? | finish no earlier than 2008-12-25 | C5 | 1024h | 1024h |  | Telecom Italia | vincenzo.amorino@telecomitalia.it | Rel-8 | CP-38 | Kimmo |  |  | PXWS Framework | PCG-21 | CP-40 | PCG-21 |
| 3732 | 932.3.7 | Deleted - Privacy on Subscriber Identity (Liberty Alliance, OASIS) (22.127 CR 0085 S1-071835) | 128d? | 2007-12-05 A | 2008-05-30 A | 100% | 2007-12-05 | 2008-05-30 | 128d? | finish no earlier than 2008-12-25 | C5 | 1024h | 1024h |  | Telecom Italia | vincenzo.amorino@telecomitalia.it | Rel-8 | CP-38 | Kimmo |  |  | PXWS Framework | PCG-21 | CP-40 | PCG-21 |
| 3733 | 932.3.8 | Deleted - Topology Hiding (22.127 CR 0086 S1-071838) | 128d? | 2007-12-05 A | 2008-05-30 A | 100% | 2007-12-05 | 2008-05-30 | 128d? | finish no earlier than 2008-12-25 | C5 | 1024h | 1024h |  | Telecom Italia | vincenzo.amorino@telecomitalia.it | Rel-8 | CP-38 | Kimmo |  |  | PXWS Framework | PCG-21 | CP-40 | PCG-21 |
| 3734 | 932.3.9 | Deleted - Subscriber event notification (22.127 CR 0087 S1-071836) | 128d? | 2007-12-05 A | 2008-05-30 A | 100% | 2007-12-05 | 2008-05-30 | 128d? | finish no earlier than 2008-12-25 | C5 | 1024h | 1024h |  | Telecom Italia | vincenzo.amorino@telecomitalia.it | Rel-8 | CP-38 | Kimmo |  |  | PXWS Framework | PCG-21 | CP-40 | PCG-21 |
| 3735 | 932.3.10 | Deleted - Event notification (22.127 CR 0088 S1-071762) | 128d? | 2007-12-05 A | 2008-05-30 A | 100% | 2007-12-05 | 2008-05-30 | 128d? | finish no earlier than 2008-12-25 | C5 | 1024h | 1024h |  | Telecom Italia | vincenzo.amorino@telecomitalia.it | Rel-8 | CP-38 | Kimmo |  |  | PXWS Framework | PCG-21 | CP-40 | PCG-21 |
| 3736 | 932.3.11 | Deleted - Access policy (22.127 CR 0089 S1-071763) | 128d? | 2007-12-05 A | 2008-05-30 A | 100% | 2007-12-05 | 2008-05-30 | 128d? | finish no earlier than 2008-12-25 | C5 | 1024h | 1024h |  | Telecom Italia | vincenzo.amorino@telecomitalia.it | Rel-8 | CP-38 | Kimmo |  |  | PXWS Framework | PCG-21 | CP-40 | PCG-21 |
| 3737 | 932.3.12 | Deleted - API usage accounting (22.127 CR 0090 S1-071792) | 128d? | 2007-12-05 A | 2008-05-30 A | 100% | 2007-12-05 | 2008-05-30 | 128d? | finish no earlier than 2008-12-25 | C5 | 1024h | 1024h |  | Telecom Italia | vincenzo.amorino@telecomitalia.it | Rel-8 | CP-38 | Kimmo |  |  | PXWS Framework | PCG-21 | CP-40 | PCG-21 |
| 3738 | 932.3.13 | Presence alignment with OMA and IETF (22.127 CR 0092 S1-071764) | 128d? | 2007-12-05 A | 2008-05-30 A | 100% | 2007-12-05 | 2008-05-30 | 128d? | finish no earlier than 2008-05-30 | C5 | 1024h | 1024h | OSA8-IMS | Alcatel-Lucent | unmehopa@alcatel-lucent.com | Rel-8 | CP-38 | Kimmo |  |  | 29.199-14/13 |  |  | PCG-21 |
| 3739 | 932.3.14 | Deleted - Service identification (22.127 CR 0095 S1-071837) | 128d? | 2007-12-05 A | 2008-05-30 A | 100% | 2007-12-05 | 2008-05-30 | 128d? | finish no earlier than 2008-05-30 | C5 | 1024h | 1024h |  | Ericsson | catherine.mulligan@ericsson.com | Rel-8 | CP-38 | Kimmo |  |  | existing 29.199-xy | PCG-21 | CP-40 | PCG-21 |
| 3740 | 932.3.15 | Framework Enterprise Operator (Service Subscription function) | 102d? | 2008-01-10 A | 2008-05-30 A | 100% | 2008-01-10 | 2008-05-30 | 102d? | finish no earlier than 2008-05-30 | C5 | 816h | 816h | OSA8-IMS | Alcatel-Lucent | unmehopa@alcatel-lucent.com | Rel-8 | CP-39 | Kimmo |  |  | 29.198-03 |  |  | PCG-21 |
| 3741 | 932.3.16 | Mobility Emergency Location | 102d? | 2008-01-10 A | 2008-05-30 A | 100% | 2008-01-10 | 2008-05-30 | 102d? | finish no earlier than 2008-05-30 | C5 | 816h | 816h | OSA8-IMS | Alcatel-Lucent | unmehopa@alcatel-lucent.com | Rel-8 | CP-39 | Kimmo |  |  | 29.198-06 |  |  | PCG-21 |
| 3742 | 932.3.17 | Connectivity Manager SCF | 102d? | 2008-01-10 A | 2008-05-30 A | 100% | 2008-01-10 | 2008-05-30 | 102d? |  | C5 | 816h | 816h | OSA8-IMS | Alcatel-Lucent | unmehopa@alcatel-lucent.com | Rel-8 | CP-39 | Kimmo |  |  | 29.198-10 |  |  | PCG-21 |
| 3743 | 932.3.18 | PAM Presence Agent | 102d? | 2008-01-10 A | 2008-05-30 A | 100% | 2008-01-10 | 2008-05-30 | 102d? | finish no earlier than 2008-05-30 | C5 | 816h | 816h | OSA8-IMS | Alcatel-Lucent | unmehopa@alcatel-lucent.com | Rel-8 | CP-39 | Kimmo |  |  | 29.198-14 |  |  | PCG-21 |

Notes:
- 3717: CP#45 completed
- 3718: SP#38 completed
- 3719: CP#45 completed
- 3720: CP#43 completed
- 3721: CP#44 stopped (Reason: No Rel-8 solution expected (LS sent to SA2, but not prioritized in SA2)
- 3722: SP#40 maintenance & new OSA work moved to OMA. Rel-9 onwards 3GPP references to 22.127 changed to OMA Parlay Service Access Requirements (OMA-RD-Parlay_Service_Access-V1_0-20100427-A).
- 3723: SP#40 maintenance & new OSA work moved to OMA. Rel-9 onwards 3GPP references to 22.127 changed to OMA Parlay Service Access Requirements (OMA-RD-Parlay_Service_Access-V1_0-20100427-A).
- 3724: SP#40 maintenance & new OSA work moved to OMA
- 3725: SP#40 maintenance & new OSA work moved to OMA
- 3726: CP#40: Work moved to OMA
- 3727: CP#40 completed
- 3728: CP#40 completed
- 3729: CP#40 completed
- 3730: CP#40: Work moved to OMA
- 3731: SP#38 SP-070853 R8 CRs 22.127 OSA Stage 1. CP#40: Work moved to OMA
- 3732: SP#38 SP-070853 R8 CRs 22.127 OSA Stage 1. CP#40: Work moved to OMA
- 3733: SP#38 SP-070853 R8 CRs 22.127 OSA Stage 1. CP#40: Work moved to OMA
- 3734: SP#38 SP-070853 R8 CRs 22.127 OSA Stage 1. CP#40: Work moved to OMA
- 3735: SP#38 SP-070853 R8 CRs 22.127 OSA Stage 1. CP#40: Work moved to OMA
- 3736: SP#38 SP-070853 R8 CRs 22.127 OSA Stage 1. CP#40: Work moved to OMA
- 3737: SP#38 SP-070853 R8 CRs 22.127 OSA Stage 1. CP#40: Work moved to OMA
- 3738: CP#40 completed
- 3739: SP#38 SP-070853 R8 CRs 22.127 OSA Stage 1. CP#40: Work moved to OMA
- 3740: CP#40 completed
- 3741: CP#40 completed
- 3742: CP#40 completed
- 3743: CP#40 completed

| ID | WBS | Task | Duration | Start | Finish | Complete | Remaining | Baseline start | Baseline finish | Baseline duration | Total slack | Constraint | Resources | Work | Actual work | Acronym | WI rapporteur name | Release | MCC resp | Acronym_3GU_Export | TSG approved | PCG approved | Status Report | Special Focus Doc |
| --- | --- | --- | --- | --- | --- | --- | --- | --- | --- | --- | --- | --- | --- | --- | --- | --- | --- | --- | --- | --- | --- | --- | --- | --- |
| 3744 | 933 | **Paging Permission with Access Control (PPACR)** | 389d? | 2007-06-12 A | 2008-12-05 A | 100% |  | 2007-06-12 | 2008-12-05 | 389d? |  |  | S1; C1 | 9000h | 9000h | PPACR | NTT DoCoMo | Rel-8 | Alain | PPACR |  |  |  |  |
| 3745 | 933.1 | Stage 1 for PPACR | 69d? | 2007-06-12 A | 2007-09-14 A | 100% |  | 2007-06-12 | 2007-09-14 | 69d? |  | finish no earlier than 2007-09-14 | S1 | 552h | 552h | PPACR-S1 | NTT DoCoMo | Rel-8 | Alain | PPACR-S1 | SP-37 |  |  |  |
| 3746 | 933.2 | Stage 3 for PPACR (CT1) | 278d? | 2007-11-14 A | 2008-12-05 A | 100% |  | 2007-11-14 | 2008-12-05 | 278d? |  | finish no earlier than 2008-12-05 | C1 | 2224h | 2224h | PPACR-CT1 | NTT DoCoMo | Rel-8 | Frederic | PPACR-CT1 | CP-38 | PCG-21 |  |  |
| 3747 | 934 | Conformance Test Aspects – Paging Permission with Access Control (PPAC) | 61d? | 2010-09-17 A | 2010-12-10 A | 100% |  | 2010-09-17 | 2010-12-10 | 61d? |  | finish no earlier than 2010-12-10 | R5 | 488h | 488h | PPAC_UEConTest | NTT DoCoMo | Rel-8 | Ingbert | PPAC_UEConTest | RP-49 | PCG-25 | RP-101074 |  |
| 3748 | 935 | **Charging for multi-phases services** | 70d? | 2007-12-06 A | 2008-03-12 | 99% | 0d? | 2007-12-06 | 2008-03-12 | 70d? | 0d |  | S1 | 560h | 560h | CHRGMPH | Telecom Italia | Rel-8 | Alain | CHRGMPH | SP-38 | PCG-21 |  |  |
| 3749 | 935.1 | Stage 1 for CHRGMPH | 70d? | 2007-12-06 A | 2008-03-12 A | 100% |  | 2007-12-06 | 2008-03-12 | 70d? |  | start no earlier than 2007-12-06 | S1 | 560h | 560h | CHRGMPH-s1 | Telecom Italia | Rel-8 | Alain | CHRGMPH-s1 | SP-38 | PCG-21 |  |  |
| 3750 | 936 | **Home NodeB / eNodeB** | 327d? | 2007-12-06 A | 2009-03-06 A | 100% |  | 2007-12-06 | 2009-03-06 | 327d? |  |  | S1; C1; C4 | 10952h | 10952h | HomeNB | Vodafone | Rel-8 | Alain | HomeNB | SP-38 | PCG-21 |  | HNB |
| 3751 | 936.1 | Stage 1 for Home NodeB / eNodeB | 70d? | 2007-12-06 A | 2008-03-12 A | 100% |  | 2007-12-06 | 2008-03-12 | 70d? |  | start no earlier than 2007-12-06 | S1 | 560h | 560h | HomeNB-S1 | Vodafone | Rel-8 | Alain | HomeNB-S1 | SP-38 | PCG-21 |  | HNB |
| 3752 | 936.2 | Support of Closed Subscriber Group (CSG) | 66d? | 2008-12-05 A | 2009-03-06 A | 100% |  | 2008-12-05 | 2009-03-06 | 66d? |  | finish no earlier than 2009-03-06 | C4 | 528h | 528h |  | CT#42 | Rel-8 | Kimmo |  | CP-42 | PCG-22 |  | HNB |
| 3753 | 936.3 | CSG and Idle Mode Mobility for LTE Home eNodeB | 126d? | 2008-09-12 A | 2009-03-06 A | 100% |  | 2008-09-12 | 2009-03-06 | 126d? |  | finish no earlier than 2009-03-06 | C1 | 1008h | 1008h | HomeNB-LTE | Huawei | Rel-8 | Frederic | HomeNB-LTE | CP-41 | PCG-21 |  | HNB |
| 3754 | 936.4 | CSG and Idle Mode Mobility for 3G Home NodeB | 126d? | 2008-09-12 A | 2009-03-06 A | 100% |  | 2008-09-12 | 2009-03-06 | 126d? |  | finish no earlier than 2009-03-06 | C1 | 1008h | 1008h | HomeNB-3G | Qualcomm | Rel-8 | Frederic | HomeNB-3G | CP-41 | PCG-21 |  | HNB |
| 3755 | 937 | **UTRA HNB** | 326d? | 2008-03-07 A | 2009-06-04 A | 100% |  | 2008-03-07 | 2009-06-04 | 326d? |  |  | RP; S5 | 11008h | 11008h | HNB |  | Rel-8 | Issam | HNB | SP-39 | PCG-21 |  | HNB |
| 3756 | 937.1 | Support of UTRA HNB | 201d? | 2008-05-30 A | 2009-03-06 A | 100% |  | 2008-05-30 | 2009-03-06 | 201d? |  | finish no earlier than 2009-03-06 | R2 | 1608h | 1608h | HNB-supp | Huawei | Rel-8 | Yong-Jun | HNB-supp | SP-40 | PCG-21 | RP-090040 | HNB |
| 3757 | 937.2 | UTRAN Architecture for 3G HNB | 136d? | 2008-05-30 A | 2008-12-05 A | 100% |  | 2008-05-30 | 2008-12-05 | 136d? |  | finish no earlier than 2008-12-05 | R3 | 1088h | 1088h | HNB-arch | Alcatel-Lucent | Rel-8 | Juha | HNB-arch | SP-40 | PCG-21 | RP-090042 | HNB |
| 3758 | 937.3 | FDD Home NodeB RF requirements | 261d? | 2008-03-07 A | 2009-03-06 A | 100% |  | 2008-03-07 | 2009-03-06 | 261d? |  | finish no earlier than 2009-03-06 | R4 | 2088h | 2088h | HNB-RF | Motorola | Rel-8 | Issam | HNB-RF | SP-39 | PCG-21 | RP-090041 | HNB |
| 3759 | 937.4 | 3G Home NodeB OAM&P Type 1 Management Interface | 127d? | 2008-12-11 A | 2009-06-04 A | 100% |  | 2008-12-11 | 2009-06-04 | 127d? |  | finish no earlier than 2009-06-04 | S5 | 1008h | 1008h | HNB-3G_OAM | Huawei | Rel-8 | Mirko | HNB-3G_OAM | SP-42 | PCG-22 |  | HNB |
| 3760 | 938 | **UTRA HNB – UE Conformance Testing** | 327d? | 2009-03-06 A | 2010-06-04 A | 100% |  | 2009-03-06 | 2010-06-04 | 327d? |  |  | R5 | 5224h | 5224h | HNB-UEConTest |  | Rel-8 | Ingbert | HNB-UEConTest | RP-43 | PCG-22 |  | HNB |
| 3761 | 938.1 | Conformance Test Aspects – UTRA HNB (FDD) | 326d? | 2009-03-06 A | 2010-06-04 A | 100% |  | 2009-03-06 | 2010-06-04 | 326d? |  | finish no earlier than 2010-06-04 | R5 | 2608h | 2608h | HNB-UEConTestFDD | Huawei | Rel-8 | Ingbert | HNB-UEConTestFDD | RP-43 | PCG-22 | RP-100482 | HNB |
| 3762 | 939 | Lawful Interception in the 3GPP Rel-8 | 524d? | 2007-03-12 A | 2009-03-12 A | 100% |  | 2007-03-12 | 2009-03-12 | 524d? |  | finish no earlier than 2009-03-12 | S3 | 4192h | 4192h | LI8 | BMWI, Verizon | Rel-8 | Mirko | LI8 |  |  |  |  |
| 3763 | 940 | **Generic Bootstrapping Architecture Push Function** | 258d? | 2008-03-12 A | 2009-03-06 A | 100% |  | 2008-03-12 | 2009-03-06 | 258d? |  |  | S3; C1; C4 | 10596.8h | 10596.8h | GBAPush | Ericsson | Rel-8 | Mirko | GBAPush | SP-39 | PCG-21 |  |  |
| 3764 | 940.1 | SA3 part of GBAPush (33.223) | 193d? | 2008-03-12 A | 2008-12-05 A | 100% |  | 2008-03-12 | 2008-12-05 | 193d? |  | finish no earlier than 2008-12-05 | S3 | 1544h | 1544h | GBAPush | Ericsson | Rel-8 | Mirko |  | SP-39 | PCG-21 |  |  |
| 3765 | 940.2 | CT1 part of GBAPush | 178.8d? | 2008-03-12 A | 2009-03-06 A | 100% |  | 2008-03-12 | 2009-03-06 | 178.8d? |  | finish no earlier than 2009-03-06 | C1 | 1430.4h | 1430.4h | GBAPush | Ericsson | Rel-8 | Frederic |  | SP-39 | PCG-21 |  |  |
| 3766 | 940.3 | CT4 part of GBAPush | 178.8d? | 2008-03-12 A | 2009-03-06 A | 100% |  | 2008-03-12 | 2009-03-06 | 178.8d? |  | finish no earlier than 2009-03-06 | C4 | 1430.4h | 1430.4h | GBAPush | Ericsson | Rel-8 | Kimmo |  | SP-39 | PCG-21 |  |  |
| 3767 | 941 | Requirements and Test methods for Wideband Terminals | 197d? | 2008-03-12 A | 2008-12-11 A | 100% |  | 2008-03-12 | 2008-12-11 | 197d? |  | start no earlier than 2008-03-12 | S4 | 1576h | 1576h | RETEM_WB_T | FT, Ericsson | Rel-8 | Paolo | RETEM_WB_T |  |  |  |  |
| 3768 | 942 | Extending PSS and MBMS User Services for optimized Mobile TV | 266d? | 2007-12-06 A | 2008-12-11 A | 100% |  | 2007-12-06 | 2008-12-11 | 266d? |  | finish no earlier than 2008-12-11 | S4 | 2128h | 2128h | PSS_MBMS_OMTV | Ericsson | Rel-8 | Paolo | PSS_MBMS_OMTV |  |  |  |  |

Notes:
- 3744: CP#42 completed. Triggered by Study UID_330016 (PPAC). / WI rapporteur e-mail: Morita Takashi
- 3745: SP#37 completed / Impacted TSs and TRs: 22.011 / WI rapporteur e-mail: Morita Takashi
- 3746: CP#42 completed / Impacted TSs and TRs: 24.008, 23.122, 24.301
- 3747: RP#50 completed / Impacted TSs and TRs: UTRA 34.108, 34.123-1, 34.123-2, 34.123-3 / WI rapporteur e-mail: Takao.Shimizu.rp@nttdocomo.com
- 3748: SP#39 Stage 1 completed / Impacted TSs and TRs: 22.115 / WI rapporteur e-mail: Marco.DeLuca1@telecomitalia.it
- 3749: SP#39 completed / Impacted TSs and TRs: 22.115 / WI rapporteur e-mail: Marco.DeLuca1@telecomitalia.it
- 3750: CP#43 completed / WI rapporteur e-mail: John Watson
- 3751: SP#39 completed / Impacted TSs and TRs: 22.011, 22.115 / WI rapporteur e-mail: John Watson
- 3752: CP#43 completed. SP#42 SP-080874 22.011CR0141 confirmed Requirement to support roaming subscribers with CSG home network subscription but did NOT confirmed requirement for home network independent support of roamers in CSG / Impacted TSs and TRs: 29.002, 29.272, 23.008, 23.003 / WI rapporteur e-mail: Hannu Hietalahti
- 3753: CP#43 completed / Impacted TSs and TRs: 23.122, new (24.285, 24.301, 24.801) / WI rapporteur e-mail: zhang.peng@huawei.com
- 3754: CP#43 completed / Impacted TSs and TRs: 23.122, 24.008, new 24.285 / WI rapporteur e-mail: Osok Song
- 3755: SP#44 completed
- 3756: RP#43 completed / Impacted TSs and TRs: 25.304, 25.306, 25.331, new 25.367 / WI rapporteur e-mail: Yang Xudong (yangxudong@huawei.com)
- 3757: RP#42 completed / Impacted TSs and TRs: 25.401, 25.410, 25.412, 25.413, 25.414, 25.415, new (25.467, 25.468, 25.469) / WI rapporteur e-mail: Martin Warner (mw15@alcatel-lucent.com)
- 3758: RP#43 completed / Impacted TSs and TRs: 25.104, 25.141, new 25.967 / WI rapporteur e-mail: Ying Cai (yingcai@motorola.com)
- 3759: SP#44 completed. Complements work in BroadBand Forum / Impacted TSs and TRs: new (32.581, 32.582, 32.583, 32.584) / WI rapporteur e-mail: Zou Lan (zlan@huawei.com)
- 3760: RP#48 FDD completed. Testing for Feature UID_390033 UTRA HNB
- 3761: RP#48 completed / Impacted TSs and TRs: 34.108, 34.123-1, 34.123-2, 34.123-3 / WI rapporteur e-mail: Trica Li (trica_li@huawei.com)
- 3762: SP#43 completed / Impacted TSs and TRs: 33.106, 33.107, 33.108 / WI rapporteur e-mail: berthold.wilhelm@bnetza.de, ron_ryan@verizon.net
- 3763: CP#43 completed / WI rapporteur e-mail: Rolf Blom
- 3764: SP#42 completed 33.223 as Rel-8. TS 33.224 moved to Rel-9 under new UID_420039 / Impacted TSs and TRs: 33.223 / WI rapporteur e-mail: Rolf Blom
- 3765: CP#43 completed / Impacted TSs and TRs: 24.109 / WI rapporteur e-mail: Rolf Blom
- 3766: CP#43 completed / Impacted TSs and TRs: 29.109 / WI rapporteur e-mail: Rolf Blom
- 3767: SP#42 completed. SP#39 WID approved. / Impacted TSs and TRs: 26.131, 26.132 / WI rapporteur e-mail: stephane.ragot@orange-ftgroup.com, wanqing.shi@sonyericsson.com
- 3768: SP#42 completed. SP#38 WID approved. / Impacted TSs and TRs: 26.234, 26.346, 26.946 / WI rapporteur e-mail: thorsten.lohmar@ericsson.com

| ID | WBS | Task | Duration | Start | Finish | Complete | Baseline start | Baseline finish | Baseline duration | Constraint | Resources | Work | Actual work | Acronym | PCG approved | WI rapporteur name | Release | TSG approved | MCC resp | Acronym_3GU_Export | TSG stopped | PCG stopped |
| --- | --- | --- | --- | --- | --- | --- | --- | --- | --- | --- | --- | --- | --- | --- | --- | --- | --- | --- | --- | --- | --- | --- |
| 3769 | 943 | **Encoding formats, transport formats and media description signalling for interworking, QoE, and other enhancements to MTSI-MHI** | 331d? | 2007-12-06 A | 2009-03-12 A | 100% | 2007-12-06 | 2009-03-12 | 331d? |  | S4; C3; C4 | 14936h | 14936h | MTSI_eMHI | PCG-21 | Ericsson, Qualcomm | Rel-8 | SP-40 | Paolo | MTSI_eMHI |  |  |
| 3770 | 943.1 | MTSI Video - Dynamic Rate Adaptation/Signalling of Image Size | 331d? | 2007-12-06 A | 2009-03-12 A | 100% | 2007-12-06 | 2009-03-12 | 331d? | finish no earlier than 2009-03-12 | S4 | 2648h | 2648h | MTSI_eMHI-DRASIS |  | Qualcomm, Samsung | Rel-8 |  | Paolo | MTSI_eMHI-DRASIS |  |  |
| 3771 | 943.2 | CT3 part of Enhancement of interworking between MTSI and CS networks | 201d? | 2008-05-30 A | 2009-03-06 A | 100% | 2008-05-30 | 2009-03-06 | 201d? | finish no earlier than 2009-03-06 | C3 | 1608h | 1608h | MTSI_eMHI | PCG-21 | Huawei | Rel-8 | CP-40 | Adrian |  |  |  |
| 3772 | 943.3 | CT4 part of Enhancement of interworking between MTSI and CS networks | 201d? | 2008-05-30 A | 2009-03-06 A | 100% | 2008-05-30 | 2009-03-06 | 201d? | finish no earlier than 2009-03-06 | C4 | 1608h | 1608h | MTSI_eMHI | PCG-21 | Huawei | Rel-8 | CP-40 | Kimmo |  |  |  |
| 3773 | 943.4 | Deleted - CT1 part of Enhancement of interworking between MTSI and CS networks | 141d? | 2008-05-30 A | 2008-12-12 A | 100% | 2008-05-30 | 2008-12-12 | 141d? | start no earlier than 2008-05-30 | C1 | 1128h | 1128h | MTSI_eMHI | PCG-21 | Huawei | Rel-8 | CP-40 | Frederic |  | CP-42 |  |
| 3774 | 944 | **Rel-8 Operations, Administration, Maintenance and Provisioning (OAM&P)** | 1445d? | 2007-06-07 A | 2012-12-07 A | 100% | 2007-06-07 | 2012-12-07 | 1445d? |  | S5; C1; C4; IETF | 120270h | 120270h | OAM8 |  |  | Rel-8 | TSG-34 | Mirko | OAM8 |  |  |
| 3775 | 944.1 | **Rel-8 Network Infrastructure Management** | 653d? | 2007-06-07 A | 2009-12-04 A | 100% | 2007-06-07 | 2009-12-04 | 653d? |  | S5 | 19464h | 19464h | OAM8-NIM |  |  | Rel-8 | TSG-34 | Mirko | OAM8-NIM |  |  |
| 3776 | 944.1.1 | Telecom Management Methodology | 461d? | 2007-06-07 A | 2009-03-12 A | 100% | 2007-06-07 | 2009-03-12 | 461d? | finish no earlier than 2009-03-12 | S5 | 3688h | 3688h | OAM8-NIM |  | Ericsson | Rel-8 |  | Mirko |  |  |  |
| 3777 | 944.1.2 | Advanced Alarming on Itf-N | 266d? | 2007-06-07 A | 2008-06-12 A | 100% | 2007-06-07 | 2008-06-12 | 266d? | finish no earlier than 2008-12-11 | S5 | 2128h | 2128h | OAM8-NIM |  | Nokia Siemens Networks | Rel-8 |  | Mirko |  |  |  |
| 3778 | 944.1.3 | CN CS Bearer Transport Network (BTN) relative NRM | 266d? | 2007-06-07 A | 2008-06-12 A | 100% | 2007-06-07 | 2008-06-12 | 266d? | finish no earlier than 2008-12-11 | S5 | 2128h | 2128h | OAM8-NIM |  | China Mobile | Rel-8 |  | Mirko |  |  |  |
| 3779 | 944.1.4 | Alignment with eTOM and M.3060 architectural concepts | 210d? | 2008-02-22 A | 2008-12-11 A | 100% | 2008-02-22 | 2008-12-11 | 210d? | start no earlier than 2008-02-22 | S5 | 1680h | 1680h | OAM8-NIM | PCG-21 | TeliaSonera | Rel-8 | SP-39 | Mirko |  |  |  |
| 3780 | 944.1.5 | IRP SOAP Solution Sets | 201d? | 2008-06-05 A | 2009-03-12 A | 100% | 2008-06-05 | 2009-03-12 | 201d? | finish no earlier than 2009-03-12 | S5 | 1608h | 1608h | OAM8-NIM | PCG-21 | Ericsson | Rel-8 | SP-40 | Mirko |  |  |  |
| 3781 | 944.1.6 | Create missing specifications for IRP XML definitions | 52d? | 2009-09-24 A | 2009-12-04 A | 100% | 2009-09-24 | 2009-12-04 | 52d? | finish no earlier than 2010-03-12 | S5 | 416h | 416h | OAM8-NIM | PCG-23 | ZTE | Rel-8 | SP-45 | Mirko |  |  |  |
| 3782 | 944.1.7 | Deleted - End point modelling for reference point | 324d? | 2007-09-17 A | 2008-12-11 A | 100% | 2007-09-17 | 2008-12-11 | 324d? | finish no earlier than 2008-12-11 | S5 | 2592h | 2592h | OAM8-NIM |  | Motorola | Rel-8 | SP-37 | Mirko |  | SP-41 | PCG-21 |
| 3783 | 944.2 | **Rel-8 Performance Management** | 461d? | 2007-06-07 A | 2009-03-12 A | 100% | 2007-06-07 | 2009-03-12 | 461d? |  | S5 | 13712h | 13712h | OAM8-PM |  |  | Rel-8 | TSG-34 | Mirko | OAM8-PM |  |  |
| 3784 | 944.2.1 | IP bearer network Performance measurement definitions | 396d? | 2007-06-07 A | 2008-12-11 A | 100% | 2007-06-07 | 2008-12-11 | 396d? | finish no earlier than 2008-12-11 | S5 | 3168h | 3168h | OAM8-PM |  | China Mobile | Rel-8 |  | Mirko |  |  |  |
| 3785 | 944.2.2 | HSUPA performance measurements | 396d? | 2007-06-07 A | 2008-12-11 A | 100% | 2007-06-07 | 2008-12-11 | 396d? | finish no earlier than 2008-12-11 | S5 | 3168h | 3168h | OAM8-PM |  | China Mobile | Rel-8 |  | Mirko |  |  |  |
| 3786 | 944.2.3 | Key Performance Indicators (KPIs) for UMTS and GSM | 461d? | 2007-06-07 A | 2009-03-12 A | 100% | 2007-06-07 | 2009-03-12 | 461d? | finish no earlier than 2009-03-12 | S5 | 3688h | 3688h | OAM8-PM |  | China Mobile | Rel-8 |  | Mirko |  |  |  |
| 3787 | 944.3 | **Rel-8 Trace Management** | 1249d? | 2008-03-07 A | 2012-12-07 A | 100% | 2008-03-07 | 2012-12-07 | 1249d? |  | C1; C4; IETF | 40854.4h | 40854.4h | OAM8-Trace |  |  | Rel-8 | TSG-34 | Mirko | OAM8-Trace |  |  |
| 3788 | 944.3.1 | CT1 part of Service Level Tracing in IMS | 196d? | 2008-03-07 A | 2008-12-05 A | 100% | 2008-03-07 | 2008-12-05 | 196d? | finish no earlier than 2008-12-05 | C1 | 1568h | 1568h | OAM8-Trace |  | Vodafone | Rel-8 |  | Frederic |  |  |  |
| 3789 | 944.3.2 | (IETF) Service Level Tracing in IMS (draft-dawes-sipping-debug) | 717d? | 2008-03-07 A | 2012-12-07 A | 100% | 2008-03-07 | 2012-12-07 | 717d? | finish no earlier than 2012-12-07 | C1-IETF | 5736h | 5736h | OAM8-Trace | PCG-27 | Peter Dawes | Rel-8 | CP-52 | Frederic |  |  |  |
| 3790 | 944.3.3 | (IETF) Service Level Tracing in IMS (draft-dawes-sipping-debug-event) | 98d? | 2008-03-07 A | 2011-12-09 A | 100% | 2008-03-07 | 2011-12-09 | 98d? | finish no earlier than 2011-12-09 | C1-IETF | 768.04h | 768.04h | OAM8-Trace | PCG-27 | Peter Dawes | Rel-8 | CP-53 | Frederic |  |  |  |
| 3791 | 944.3.4 | CT4 part of Service Level Tracing in IMS | 175.4d? | 2008-03-07 A | 2008-12-05 A | 100% | 2008-03-07 | 2008-12-05 | 175.4d? | finish no earlier than 2008-12-05 | C4 | 1403.2h | 1403.2h | OAM8-Trace | PCG-21 | Vodafone | Rel-8 | CP-40 | Frederic |  |  |  |
| 3792 | 944.3.5 | Deleted - CT3 part of Service Level Tracing in IMS | 175.4d? | 2008-03-07 A | 2008-12-05 A | 100% | 2008-03-07 | 2008-12-05 | 175.4d? | finish no earlier than 2008-12-05 | C3 | 1403.2h | 1403.2h | OAM8-Trace | PCG-21 | Vodafone | Rel-8 | CP-40 | Adrian |  | CP-42 | PCG-22 |

Notes:
- 3769: TSG#43 completed / WI rapporteur e-mail: olle.franceschi@ericsson.com, nleung@qualcomm.com
- 3770: SP#43 completed / Impacted TSs and TRs: 26.114 / WI rapporteur e-mail: nleung@qualcomm.com & kyunghun.jung@samsung.com
- 3771: CP#43 completed / Impacted TSs and TRs: 29.163 / WI rapporteur e-mail: Tingfang Tang (tagna_online@huawei.com)
- 3772: CP#43 completed / Impacted TSs and TRs: 29.332 / WI rapporteur e-mail: Tingfang Tang (tagna_online@huawei.com)
- 3773: CP#42 stopped (No CT1-impact). WID updated CP-080422=>CP-080774 / WI rapporteur e-mail: Tingfang Tang (tagna_online@huawei.com)
- 3774: OAM8 is an umbrella Feature also for OAM&P related TEI8 type of changes that are not part of any other dedicated feature/WI / Impacted TSs and TRs: TR 30.818
- 3775: -
- 3776: SP#43 completed / Impacted TSs and TRs: 32.155, 32.153 / WI rapporteur e-mail: thomas.tovinger@ericsson.com
- 3777: SP#40 completed / Impacted TSs and TRs: 32.121, 32.122, 32.123 / WI rapporteur e-mail: SUERBAUM, Clemens
- 3778: SP#40 completed / Impacted TSs and TRs: 32.632, 32.633, 32.635 / WI rapporteur e-mail: Li Jian (lijian@chinamobile.com)
- 3779: SP#42 completed / Impacted TSs and TRs: 32.101/2, 32-series / WI rapporteur e-mail: tommy.berggren@teliasonera.com
- 3780: SP#43 completed / Impacted TSs and TRs: 32.111-7, 32.617, 32.417, 32.367, 32.347, 32.111-1, 32.111-2, 32.111-3, 32.111-5, 32.307, 32.317, 32.341, 32.342, 32.343, 32.345, 32.361, 32.362, 32.363, 32.365, 32.411, 32.412, 32.413, 32.415, 32.611, 32.612, 32.613, 32.615, 32.625 / WI rapporteur e-mail: edwin.tse@ericsson.com
- 3781: SP#46 completed. Create missing XML definitions specs for IRPs (Advanced Alarm Management, Communication Surveillance, Self-Configuration of Network Elements, Software Management) needed for implementation of Rel-8 Notification Log IRP (TS 32.33x) / Impacted TSs and TRs: new (32.125, 32.355, 32.505, 32.535), 32.150, 32.153, 32.335 / WI rapporteur e-mail: Shuqiang Huang (huangsq@zte.com.cn)
- 3782: SP#41 Work stopped. Contributions related to E-UTRAN/EPC to be submitted to UID_380036 E-UTRAN NRM IRP/ UID_380037 EPC NRM IRP / Impacted TSs and TRs: 32.152, 32.62/3/4x, 32.73x / WI rapporteur e-mail: Yizhi Yao (yzyao@motorola.com)
- 3783: - / WI rapporteur e-mail: Li Jian (lijian@chinamobile.com)
- 3784: SP#42 completed / Impacted TSs and TRs: 32.321, 32.322, 32.323, 32.325 / WI rapporteur e-mail: lilianyuan@chinamobile.com
- 3785: SP#42 completed / Impacted TSs and TRs: 32.405 / WI rapporteur e-mail: Li Jian (lijian@chinamobile.com)
- 3786: SP#43 completed / Impacted TSs and TRs: 32.410 / WI rapporteur e-mail: Li Jian (lijian@chinamobile.com), Liang Shuangchun (liangshuangchun@cmdi.chinamobile.com)
- 3787: -
- 3788: CP#42 completed / Impacted TSs and TRs: 24.323, 24.229 / WI rapporteur e-mail: peter.dawes@vodafone.com
- 3789: CP#58 Removed from Rel-8, Rel-9 and Rel-10 (Not completed internet-draft) / Impacted TSs and TRs: Rel-11 remains draft-dawes-dispatch-debug / WI rapporteur e-mail: peter.dawes@vodafone.com
- 3790: CP#54 Draft removed from 3GPP documentation, covered by draft-dawes-sipping-debug / Impacted TSs and TRs: draft-dawes-sipping-debug-event / WI rapporteur e-mail: peter.dawes@vodafone.com
- 3791: CP#42 completed / Impacted TSs and TRs: 29.228, 29.229 / WI rapporteur e-mail: peter.dawes@vodafone.com
- 3792: CP#42 stopped (No CT3-impact) / WI rapporteur e-mail: peter.dawes@vodafone.com

| ID | WBS | Task | Type | Duration | Start | Finish | Complete | Baseline start | Baseline finish | Baseline duration | Constraint | Resources | Work | Actual work | Acronym | Release | MCC resp | Acronym_3GU_Export | WI rapporteur name | WI rapporteur e-mail | PCG approved | TSG approved | PCG stopped | TSG stopped | Status Report |
| --- | --- | --- | --- | --- | --- | --- | --- | --- | --- | --- | --- | --- | --- | --- | --- | --- | --- | --- | --- | --- | --- | --- | --- | --- | --- |
| 3793 | 945 | **Rel-8 Charging Management small Enhancements** |  | 716d? | 2006-03-16 A | 2008-12-11 A | 100% | 2006-03-16 | 2008-12-11 | 716d? |  | S5 | 12544h | 12544h | CH8 | Rel-8 | Mirko | CH8 |  |  |  |  |  |  |  |
| 3794 | 945.1 | Online charging correlation |  | 457d? | 2006-03-16 A | 2007-12-14 A | 100% | 2006-03-16 | 2007-12-14 | 457d? | start no earlier than 2006-03-16 | S5 | 3656h | 3656h | CH8 | Rel-8 | Mirko |  | Orange | Chahine, Rony |  |  |  |  |  |
| 3795 | 945.2 | SMS online charging |  | 137d? | 2007-06-07 A | 2007-12-14 A | 100% | 2007-06-07 | 2007-12-14 | 137d? | finish no earlier than 2007-12-14 | S5 | 1096h | 1096h | CH8 | Rel-8 | Mirko |  | Vodafone | Gavin.Wong@vodafone.com |  |  |  |  |  |
| 3796 | 945.3 | Introduce Online Charging from SMS-SC into the SMS Charging Specifications |  | 61d? | 2008-09-18 A | 2008-12-11 A | 100% | 2008-09-18 | 2008-12-11 | 61d? | finish no earlier than 2008-12-11 | S5 | 488h | 488h | CH8 | Rel-8 | Mirko |  | Acision | erik.gebler@acision.com | PCG-21 | SP-41 |  |  |  |
| 3797 | 945.4 | Deleted - WLAN Offline Charging |  | 244d? | 2008-01-07 A | 2008-12-11 A | 100% | 2008-01-07 | 2008-12-11 | 244d? | finish no earlier than 2008-12-11 | S5 | 1952h | 1952h | CH8 | Rel-8 | Mirko |  | Alcatel-Lucent | maryse.gardella@alcatel-lucent.com | PCG-21 | SP-38 | PCG-22 | SP-42 |  |
| 3798 | 946 | **Conferencing enhancements for Mp interface** |  | 266d? | 2007-11-30 A | 2008-12-05 A | 100% | 2007-11-30 | 2008-12-05 | 266d? |  | C4 | 6384h | 6384h | eMp | Rel-8 | Kimmo | eMp | Huawei | Chencheng@huawei.com | PCG-21 |  |  |  |  |
| 3799 | 946.1 | Stage 2 for eMp |  | 266d? | 2007-11-30 A | 2008-12-05 A | 100% | 2007-11-30 | 2008-12-05 | 266d? | finish no earlier than 2008-12-11 | C4 | 2128h | 2128h | eMp | Rel-8 | Kimmo |  | Huawei | Chencheng@huawei.com | PCG-21 | CP-38 |  |  |  |
| 3800 | 946.2 | Stage 3 for eMp |  | 266d? | 2007-11-30 A | 2008-12-05 A | 100% | 2007-11-30 | 2008-12-05 | 266d? | finish no earlier than 2008-12-05 | C4 | 2128h | 2128h | eMp | Rel-8 | Kimmo |  | Huawei | Chencheng@huawei.com | PCG-21 | CP-38 |  |  |  |
| 3801 | 947 | **Contact Manager for 3GPP UICC applications** |  | 642d? | 2006-06-22 A | 2008-12-05 A | 100% | 2006-06-22 | 2008-12-05 | 642d? |  | C6 | 13352h | 13352h | eUPHBOOK | Rel-8 | Xavier | eUPHBOOK | Gemalto | Jacques.seif@gemalto.com |  |  |  |  |  |
| 3802 | 947.1 | Requirements for Contact Manager |  | 392d? | 2006-06-22 A | 2007-12-21 A | 100% | 2006-06-22 | 2007-12-21 | 392d? | finish no earlier than 2007-12-21 | C6 | 3136h | 3136h | eUPHBOOK-St1 | Rel-8 | Xavier | eUPHBOOK-St1 | Gemalto | Jacques.seif@gemalto.com |  |  |  |  |  |
| 3803 | 947.2 | External interface for eUPHBOOK |  | 220d? | 2007-05-07 A | 2008-03-07 A | 100% | 2007-05-07 | 2008-03-07 | 220d? | finish no earlier than 2008-03-07 | C6 | 1760h | 1760h | eUPHBOOK-Ext_Spec | Rel-8 | Xavier | eUPHBOOK-Ext_Spec | Gemalto | Jacques.seif@gemalto.com |  |  |  |  |  |
| 3804 | 947.3 | Internal interface for eUPHBOOK |  | 415d? | 2007-05-07 A | 2008-12-05 A | 100% | 2007-05-07 | 2008-12-05 | 415d? | finish no earlier than 2008-12-05 | C6 | 3320h | 3320h | eUPHBOOK-Int_Spec | Rel-8 | Xavier | eUPHBOOK-Int_Spec | Gemalto | Jacques.seif@gemalto.com |  | CP-37 |  |  |  |
| 3805 | 947.4 | Deleted - Implementation of eUPHBOOK | milestone | 0d? | 2007-06-21 A | 2007-06-21 A | 100% | 2007-06-21 | 2007-06-21 | 0d? | start no earlier than 2007-06-21 | C6 |  |  | eUPHBOOK-St23 | Rel-8 | Xavier | eUPHBOOK-St23 | Giesecke & Devrient | Claus Dietze |  |  |  | SP-33 |  |
| 3806 | 948 | **Rel-8 LTE – 3G Long Term Evolution - Evolved Packet System RAN part** |  | 644d? | 2006-09-25 A | 2009-03-12 A | 100% | 2006-09-25 | 2009-03-12 | 644d? |  | RP; S5 | 50048h | 50048h | LTE | Rel-8 |  | LTE | NTT DoCoMo | Takehiro Nakamura (nakamurata@nttdocomo.co.jp) |  |  |  |  | RP-080741 |
| 3807 | 948.1 | LTE – Physical Layer |  | 380d? | 2006-09-25 A | 2008-03-07 A | 100% | 2006-09-25 | 2008-03-07 | 380d? | finish no earlier than 2007-09-14 | R1 | 3040h | 3040h | LTE-Phys | Rel-8 | Patrick | LTE-Phys | NTT DoCoMo | Sadayuki Abeta |  |  |  |  | RP-080741 |
| 3808 | 948.2 | LTE – Radio Interface Layer 2 and 3 Protocol Aspect |  | 575d? | 2006-09-25 A | 2008-12-05 A | 100% | 2006-09-25 | 2008-12-05 | 575d? | finish no earlier than 2008-12-11 | R2 | 4600h | 4600h | LTE-L23 | Rel-8 | Yong-Jun | LTE-L23 | Nokia Siemens Networks | benoist.sebire@nokia.com |  |  |  |  | RP-080741 |
| 3809 | 948.3 | LTE – eUTRAN Interfaces |  | 575d? | 2006-09-25 A | 2008-12-05 A | 100% | 2006-09-25 | 2008-12-05 | 575d? | finish no earlier than 2008-12-11 | R3 | 4600h | 4600h | LTE-interfaces | Rel-8 | Juha | LTE-interfaces | Ericsson | Martin Israelsson |  |  |  |  | RP-080741 |
| 3810 | 948.4 | LTE – Evolved UTRA and UTRAN RF Radio Transmission/Reception, System Performance Requirements and Conformance Testing |  | 575d? | 2006-09-25 A | 2008-12-05 A | 100% | 2006-09-25 | 2008-12-05 | 575d? | finish no earlier than 2008-12-11 | R4 | 4600h | 4600h | LTE-RF | Rel-8 | Issam | LTE-RF | Nokia Siemens Networks | Tuomo Saynajakangas |  |  |  |  | RP-080741 |
| 3811 | 948.5 | LTE – FDD repeaters |  | 386d? | 2007-09-14 A | 2009-03-06 A | 100% | 2007-09-14 | 2009-03-06 | 386d? | finish no earlier than 2009-03-06 | R4 | 3088h | 3088h | LTE-Repeaters | Rel-8 | Issam | LTE-Repeaters | Powerwave Technologies, Andrew Wireless | ralf.michanikl@andrew.com, Alf.Ahlstrom@pwav.com |  | RP-37 |  |  | RP-090037 |
| 3812 | 948.6 | **E-UTRAN Data Definitions** |  | 389d? | 2007-09-17 A | 2009-03-12 A | 100% | 2007-09-17 | 2009-03-12 | 389d? |  | S5 | 13096h | 13096h | E-UTRAN-OAM | Rel-8 | Mirko | E-UTRAN-OAM |  |  | PCG-21 | SP-39 |  |  |  |
| 3813 | 948.6.1 | Subscriber and Equipment Trace for E-UTRAN and EPC |  | 389d? | 2007-09-17 A | 2009-03-12 A | 100% | 2007-09-17 | 2009-03-12 | 389d? | finish no earlier than 2009-03-12 | S5 | 3112h | 3112h | E-UTRAN-OAM | Rel-8 | Mirko |  | Ericsson | robert.petersen@ericsson.com |  | SP-37 |  |  |  |
| 3814 | 948.6.2 | E-UTRAN Network Resource Model (NRM) Integration Reference Point (IRP) |  | 309d? | 2008-01-07 A | 2009-03-12 A | 100% | 2008-01-07 | 2009-03-12 | 309d? | finish no earlier than 2009-03-12 | S5 | 2472h | 2472h | E-UTRAN-OAM | Rel-8 | Mirko |  | Ericsson | ELMDAHL, Per | PCG-21 | SP-38 |  |  |  |
| 3815 | 948.6.3 | Performance measurements for E-UTRAN |  | 275d? | 2008-02-22 A | 2009-03-12 A | 100% | 2008-02-22 | 2009-03-12 | 275d? | finish no earlier than 2009-03-12 | S5 | 2200h | 2200h | E-UTRAN-OAM | Rel-8 | Mirko |  | Motorola, Huawei | Yizhi Yao (yzyao@motorola.com) | PCG-21 | SP-39 |  |  |  |
| 3816 | 948.6.4 | Key Performance Indicators (KPIs) for E-UTRAN |  | 275d? | 2008-02-22 A | 2009-03-12 A | 100% | 2008-02-22 | 2009-03-12 | 275d? | finish no earlier than 2009-03-12 | S5 | 2200h | 2200h | E-UTRAN-OAM | Rel-8 | Mirko |  | Ericsson | ulf.hubinette@ericsson.com | PCG-21 | SP-39 |  |  |  |

Notes:
- 3793: CH8 is an umbrella Feature also for OAM&P related TEI8 type of changes that are not part of any other dedicated feature/WI / Impacted TSs and TRs: TR 30.818
- 3794: SP#38 completed / Impacted TSs and TRs: 32.296
- 3795: SP#38 completed / Impacted TSs and TRs: 32.240, 32.299, new 32.274
- 3796: SP#42 completed. Linked to SA2 UID 32081 (Support of SMS over IP networks) and CT4 UID 340016 (Routeing of MT-SMS via the HPLMN). / Impacted TSs and TRs: 32.274, 32.299
- 3797: SP#42 stopped / Impacted TSs and TRs: 32.252, 32.298, 32.299
- 3798: CP#42 completed
- 3799: CP#42 completed / Impacted TSs and TRs: 23.333
- 3800: CP#42 completed / Impacted TSs and TRs: 29.333
- 3801: CP#42 completed. CP#40: WID updated CP-070622=>CP-080382. aka Enhanced USIM phonebook
- 3802: CP#38 completed / Impacted TSs and TRs: 21.111
- 3803: CP#39 completed / Impacted TSs and TRs: new 31.220
- 3804: CP#42 completed / Impacted TSs and TRs: new 31.221
- 3805: SP#33 stopped / Impacted TSs and TRs: 31.102
- 3806: RP#43 completed. Role model for SAE/LTE system wide project management by SA2 in SP-060166 / Impacted TSs and TRs: LTE 36.300, 36.938
- 3807: RP#39 completed / Impacted TSs and TRs: 36.201, 36.211, 36.212, 36.213, 36.214, 25.215, 25.225
- 3808: RP#42 completed / Impacted TSs and TRs: 36.302, 36.304, 36.306, 36.314, 36.321, 36.322, 36.323, 36.331, 25.302, 25.304, 25.331
- 3809: RP#42 completed / Impacted TSs and TRs: 36.401, 36.410, 36.411, 36.412, 36.413, 36.414, 36.420, 36.421, 36.422, 36.423, 36.424, 25.413
- 3810: RP#42 completed. RP#47 abandoned draft 36.801, 36.803, 36.804 / Impacted TSs and TRs: 36.101, 36.104, 36.113, 36.124, 36.133, 36.141, 36.942, 25.123, 25.133
- 3811: RP#43 completed. RP#47 create Rel-9 TR 36.956 (see R4-100386, RP-100320_RAN4 Report) / Impacted TSs and TRs: 36.106, 36.143, 25.113
- 3812: SP#43 completed
- 3813: SP#43 completed / Impacted TSs and TRs: 32.421, 2.422, 32.423, 2.441, 32.442, 32.443, 32.445
- 3814: SP#43 completed / Impacted TSs and TRs: new (32.761, 32.762, 32.763, 32.765)
- 3815: SP#43 completed / Impacted TSs and TRs: new 32.425
- 3816: SP#43 completed / Impacted TSs and TRs: new (32.450, 32.451)

| ID | WBS | Task | Duration | Start | Finish | Complete | Baseline start | Baseline finish | Baseline duration | Constraint | Resources | Work | Actual work | Acronym | PCG approved | WI rapporteur name | WI rapporteur e-mail | Release | TSG approved | MCC resp | Special Focus Doc | Acronym_3GU_Export | Status Report | PCG stopped | TSG stopped |
| --- | --- | --- | --- | --- | --- | --- | --- | --- | --- | --- | --- | --- | --- | --- | --- | --- | --- | --- | --- | --- | --- | --- | --- | --- | --- |
| 3817 | 948.7 | **Self-Organizing Networks (SON)** | 210d? | 2008-02-22 A | 2008-12-11 A | 100% | 2008-02-22 | 2008-12-11 | 210d? |  | S5 | 6720h | 6720h | LTE_SON-OAM | PCG-21 | Vodafone | GOMPAKIS, Panagiotis | Rel-8 | SP-39 | Mirko | SON | LTE_SON-OAM |  |  |  |
| 3818 | 948.7.1 | SON Concepts and requirements | 210d? | 2008-02-22 A | 2008-12-11 A | 100% | 2008-02-22 | 2008-12-11 | 210d? |  | S5 | 1680h | 1680h | LTE_SON-OAM | PCG-21 | Vodafone | GOMPAKIS, Panagiotis | Rel-8 | SP-39 | Mirko |  |  |  |  |  |
| 3819 | 948.7.2 | Self-Establishment of eNBs, including automated Software Management | 210d? | 2008-02-22 A | 2008-12-11 A | 100% | 2008-02-22 | 2008-12-11 | 210d? | start no earlier than 2008-02-22 | S5 | 1680h | 1680h | LTE_SON-OAM | PCG-21 | Nokia Siemens Networks | SUERBAUM, Clemens | Rel-8 | SP-39 | Mirko |  |  |  |  |  |
| 3820 | 948.7.3 | SON Automatic Neighbour Relations (ANR) List Management | 210d? | 2008-02-22 A | 2008-12-11 A | 100% | 2008-02-22 | 2008-12-11 | 210d? | finish no earlier than 2008-12-11 | S5 | 1680h | 1680h | LTE_SON-OAM | PCG-21 | Ericsson | edwin.tse@ericsson.com | Rel-8 | SP-39 | Mirko |  |  |  |  |  |
| 3821 | 949 | **Rel-8 LTE – Terminal Conformance Test Specification** | 657d? | 2007-06-01 A | 2009-12-04 A | 100% | 2007-06-01 | 2009-12-04 | 657d? |  | R5 | 14336h | 14336h | LTE-UEConTest |  |  |  | Rel-8 |  | Ingbert |  | LTE-UEConTest |  |  |  |
| 3822 | 949.1 | 3G LTE – Terminal Protocol Conformance Test Specifications | 657d? | 2007-06-01 A | 2009-12-04 A | 100% | 2007-06-01 | 2009-12-04 | 657d? | finish no earlier than 2009-12-04 | R5 | 5256h | 5256h | LTE-UEConTest_SIG |  | NEC, Motorola | david.lecompte@nectech.fr, Jacob.John@motorola.com | Rel-8 |  | Ingbert |  | LTE-UEConTest_SIG | RP-091060 |  |  |
| 3823 | 949.2 | LTE – Terminal Radio Transmission and Reception Conformance Test Specifications | 657d? | 2007-06-01 A | 2009-12-04 A | 100% | 2007-06-01 | 2009-12-04 | 657d? |  | R5 | 5256h | 5256h | LTE-UEConTest_RF |  | Agilent | andrea_leonardi@agilent.com | Rel-8 |  | Ingbert |  | LTE-UEConTest_RF | RP-091059 |  |  |
| 3824 | 950 | **Rel-8 Improvements of the Radio Interface** | 525d? | 2007-03-05 A | 2009-03-06 A | 100% | 2007-03-05 | 2009-03-06 | 525d? |  | RP | 18152h | 18152h | RInImp8 |  |  |  | Rel-8 |  | Issam |  | RInImp8 |  |  |  |
| 3825 | 950.1 | UMTS 1500 MHz | 140d? | 2007-03-05 A | 2007-09-14 A | 100% | 2007-03-05 | 2007-09-14 | 140d? | finish no earlier than 2007-09-14 | R4 | 1120h | 1120h | RInImp8-UMTS1500 |  | NTT DoCoMo | Takehiro Nakamura (nakamurata@nttdocomo.co.jp) | Rel-8 |  | Issam |  | RInImp8-UMTS1500 | RP-070526 |  |  |
| 3826 | 950.2 | UMTS 700 MHz FDD | 325d? | 2007-03-05 A | 2008-05-30 A | 100% | 2007-03-05 | 2008-05-30 | 325d? | finish no earlier than 2008-06-12 | R4 | 2600h | 2600h | RInImp8-UMTS700 |  | Nokia | Tuomo Saynajakangas | Rel-8 |  | Issam |  | RInImp8-UMTS700 | RP-080260 |  |  |
| 3827 | 950.3 | UMTS 1880 MHz TDD | 126d? | 2008-09-12 A | 2009-03-06 A | 100% | 2008-09-12 | 2009-03-06 | 126d? | finish no earlier than 2009-03-09 | R4 | 1008h | 1008h | RInImp9-UMTS1880TDD | PCG-21 | CATT | Yuexia Song (songyuexia@catt.cn) | Rel-8 | RP-41 | Issam |  | RInImp9-UMTS1880TDD | RP-090044 |  |  |
| 3828 | 950.4 | UMTS 2300 MHz TDD LCR | 195d? | 2007-12-17 A | 2008-09-12 A | 100% | 2007-12-17 | 2008-09-12 | 195d? | finish no earlier than 2008-09-12 | R4 | 1560h | 1560h | RInImp8-UMTS2300TDD | PCG-21 | CATT | Yuexia Song (songyuexia@catt.cn) | Rel-8 | RP-38 | Issam |  | RInImp8-UMTS2300TDD | RP-080517 |  |  |
| 3829 | 950.5 | Further Improved Minimum Performance Requirements for HSDPA UE (FDD) - Two-Branch Interference Cancellation | 265d? | 2007-03-05 A | 2008-03-07 A | 100% | 2007-03-05 | 2008-03-07 | 265d? | finish no earlier than 2008-03-12 | R4 | 2120h | 2120h | RInImp8-2BIC |  | AT&T | Marc Grant | Rel-8 |  | Issam |  | RInImp8-2BIC | RP-080041 |  |  |
| 3830 | 950.6 | CS Voice Service over HSPA | 167d? | 2007-07-19 A | 2008-03-07 A | 100% | 2007-07-19 | 2008-03-07 | 167d? |  | R2 | 1336h | 1336h | RInImp8-CsHspa |  | Nokia Siemens Networks | woonhee.hwang@nsn.com | Rel-8 | RP-37 | Yong-Jun |  | RInImp8-CsHspa | RP-080042 |  |  |
| 3831 | 950.7 | Performance requirements for 15 code reception with 16QAM/QPSK (FDD) | 126d? | 2007-06-11 A | 2008-03-07 A | 100% | 2007-06-11 | 2008-03-07 | 126d? | finish no earlier than 2008-06-12 | R4 | 1008h | 1008h | RInImp8-Hsdpa15codes |  | Vodafone | tim.frost@vodafone.com | Rel-8 | RP-37 | Issam |  | RInImp8-Hsdpa15codes | RP-080043 |  |  |
| 3832 | 950.8 | Deleted - UMTS 2300 MHz FDD/TDD | 400d? | 2007-03-05 A | 2008-09-12 A | 100% | 2007-03-05 | 2008-09-12 | 400d? | finish no earlier than 2008-12-11 | R4 | 3200h | 3200h | RInImp8-UMTS2300 |  | AT&T | Marc Grant | Rel-8 |  | Issam |  | RInImp8-UMTS2300 | RP-080515 | PCG-21 | RP-41 |
| 3833 | 951 | **Rel-8 Improvements of the Radio Interface - UE Conformance Testing** | 396d? | 2007-06-01 A | 2008-12-05 A | 100% | 2007-06-01 | 2008-12-05 | 396d? |  | R5 | 6256h | 6256h |  |  |  |  | Rel-8 |  | Ingbert |  |  |  |  |  |
| 3834 | 951.1 | Conformance Test Aspects – CS Voice Service over HSPA | 336d? | 2007-06-01 A | 2008-09-12 A | 100% | 2007-06-01 | 2008-09-12 | 336d? | finish no earlier than 2008-09-12 | R5 | 2688h | 2688h | RInImp8-CsHspa_UEConTest |  | Huawei | baoyi@huawei.com | Rel-8 |  | Ingbert |  | RInImp8-CsHspa_UEConTest | RP-080542 |  |  |
| 3835 | 951.2 | Conformance Test Aspects – Performance requirements for 15 code reception with 16QAM/QPSK (FDD) | 195d? | 2008-03-07 A | 2008-12-05 A | 100% | 2008-03-07 | 2008-12-05 | 195d? | finish no earlier than 2008-12-05 | R5 | 1560h | 1560h | RInImp8-UEConTest_Hsdpa15codes | PCG-21 | Ericsson | Mikael.Ziren@Ericsson.com | Rel-8 | RP-40 | Ingbert |  | RInImp8-UEConTest_ Hsdpa15codes | RP-080818 |  |  |
| 3836 | 952 | **Rel-8 RAN improvements** | 520d? | 2007-06-04 A | 2009-05-29 A | 100% | 2007-06-04 | 2009-05-29 | 520d? |  | RP | 37481.6h | 37481.6h |  |  |  |  | Rel-8 |  |  |  |  |  |  |  |
| 3837 | 952.1 | Combination of 64QAM and MIMO for HSDPA (FDD) | 205d? | 2007-06-04 A | 2008-09-12 A | 100% | 2007-06-04 | 2008-09-12 | 205d? | finish no earlier than 2008-09-12 | R1 | 1640h | 1640h | RANimp-64QamMimoHsdpa |  | Ericsson | Johan.Bergman@ericsson.com | Rel-8 |  | Patrick |  | RANimp-64QamMimoHsdpa | RP-080518 |  |  |
| 3838 | 952.2 | Improved L2 for uplink | 186d? | 2007-09-14 A | 2008-05-30 A | 100% | 2007-09-14 | 2008-05-30 | 186d? | finish no earlier than 2008-05-30 | R2 | 1488h | 1488h | RANimp-UplinkL2dataRates |  | Ericsson | Janne.Peisa@ericsson.com | Rel-8 | RP-37 | Yong-Jun |  | RANimp-UplinkL2dataRates | RP-080265 |  |  |
| 3839 | 952.3 | Enhanced Uplink for CELL_FACH State in FDD | 321d? | 2007-09-14 A | 2008-12-05 A | 100% | 2007-09-14 | 2008-12-05 | 321d? | finish no earlier than 2008-12-12 | R2 | 2568h | 2568h | RANimp-UplinkEnhState |  | Nokia Siemens Networks | markus.wimmer@nsn.com | Rel-8 | RP-37 | Yong-Jun |  | RANimp-UplinkEnhState | RP-080804 |  |  |
| 3840 | 952.4 | Enhanced UE Discontinuous Reception (DRX) for FDD | 261d? | 2007-09-14 A | 2008-09-12 A | 100% | 2007-09-14 | 2008-09-12 | 261d? | finish no earlier than 2008-09-12 | R2 | 2088h | 2088h | RANimp-DRX |  | Nokia | luis.barreto@nokia.com | Rel-8 | RP-37 | Yong-Jun |  | RANimp-DRX | RP-080520 |  |  |
| 3841 | 952.5 | Enhancements for Serving Radio Network Subsystem (SRNS) Relocation Procedure | 261d? | 2007-09-14 A | 2008-09-12 A | 100% | 2007-09-14 | 2008-09-12 | 261d? | finish no earlier than 2008-09-12 | R3 | 2088h | 2088h | RANimp-SrnsReloc |  | Nokia Siemens Networks | masatoshi.nakamata@nsn.com | Rel-8 | RP-37 | Juha |  | RANimp-SrnsReloc | RP-080521 |  |  |
| 3842 | 952.6 | Enhancements for FDD HSPA Evolution | 321d? | 2007-09-14 A | 2008-12-05 A | 100% | 2007-09-14 | 2008-12-05 | 321d? | finish no earlier than 2008-12-05 | R3; R2 | 5136h | 5136h | RANimp-HSPAEvo |  | Nokia Siemens Networks | masatoshi.nakamata@nsn.com | Rel-8 | RP-37 | Juha |  | RANimp-HSPAEvo | RP-080805 |  |  |
| 3843 | 952.7 | 64QAM for 1.28 Mcps TDD HSDPA | 264d? | 2007-12-04 A | 2008-12-05 A | 100% | 2007-12-04 | 2008-12-05 | 264d? | finish no earlier than 2008-12-05 | R1 | 2112h | 2112h | RANimp-64Qam1.28TDD | PCG-21 | ZTE | zfmail@zte.com.cn | Rel-8 | RP-38 | Patrick |  | RANimp-64Qam1.28TDD | RP-080806 |  |  |
| 3844 | 952.8 | Enhanced CELL_FACH state in 1.28 Mcps TDD | 264d? | 2007-12-04 A | 2008-12-05 A | 100% | 2007-12-04 | 2008-12-05 | 264d? | finish no earlier than 2008-12-12 | R2 | 2112h | 2112h | RANimp-EnhState1.28TDD | PCG-21 | ZTE | zhang.yincheng@zte.com.cn | Rel-8 | RP-38 | Yong-Jun |  | RANimp-EnhState1.28TDD | RP-080807 |  |  |
| 3845 | 952.9 | Continuous Connectivity for packet data users for 1.28 Mcps TDD | 321d? | 2008-03-07 A | 2009-05-29 A | 100% | 2008-03-07 | 2009-05-29 | 321d? | finish no earlier than 2009-05-29 | R1 | 2568h | 2568h | RANimp-LCRCPC | PCG-21 | TD Tech | chenying@td-tech.com | Rel-8 | RP-39 | Patrick |  | RANimp-LCRCPC | RP-090394 |  |  |
| 3846 | 952.10 | HSPA VoIP to WCDMA/GSM CS continuity | 261d? | 2008-03-07 A | 2009-03-06 A | 100% | 2008-03-07 | 2009-03-06 | 261d? | finish no earlier than 2009-03-06 | R2 | 2088h | 2088h | RANimp-HSPAVoIP | PCG-21 | Nokia | Simone.Provvedi@nokia.com | Rel-8 | RP-39 | Yong-Jun |  | RANimp-HSPAVoIP | RP-090050 |  |  |
| 3847 | 952.11 | HS-DSCH Serving Cell Change Enhancements | 196d? | 2008-03-07 A | 2008-12-05 A | 100% | 2008-03-07 | 2008-12-05 | 196d? | finish no earlier than 2008-12-12 | R2 | 1568h | 1568h | RANimp-HSDSCH | PCG-21 | Ericsson | henrik.enbuske@ericsson.com | Rel-8 | RP-39 | Yong-Jun |  | RANimp-HSDSCH | RP-080811 |  |  |
| 3848 | 952.12 | MIMO for 1.28 Mcps TDD. Linked to Rel-8 Study on Scope of future HSPA Evolution for 1.28 Mcps TDD (UID_370041) TR 25.824 | 351.6d? | 2008-01-24 A | 2009-05-29 A | 100% | 2008-01-24 | 2009-05-29 | 351.6d? | finish no earlier than 2009-05-29 | R1; R4 | 5625.6h | 5625.6h | RANimp-MIMOLCR | PCG-21 | CATT | wangke@datangmobile.cn | Rel-8 | RP-40 | Patrick |  | RANimp-MIMOLCR | RP-090313 |  |  |
| 3849 | 952.13 | Dual-Cell HSDPA operation on adjacent carriers | 140d? | 2008-11-17 A | 2009-05-29 A | 100% | 2008-11-17 | 2009-05-29 | 140d? | finish no earlier than 2009-05-29 | R1; R4 | 2240h | 2240h | RANimp-DCHSDPA | PCG-21 | Ericsson | johan.bergman@ericsson.com | Rel-8 | RP-40 | Patrick |  | RANimp-DCHSDPA | RP-080814 |  |  |

Notes:
- 3817: SP#42 completed (WT UID_390007 moved to Rel-9)
- 3818: SP#42 completed / Impacted TSs and TRs: new 32.500
- 3819: SP#42 completed / Impacted TSs and TRs: new (32.501, 32.502, 32.503, 32.531, 32.532, 32.533)
- 3820: SP#42 completed / Impacted TSs and TRs: 32.761, 32.762, 32.763, 32.765, new 32.511
- 3821: Testing for Feature UID_20068 (LTE)
- 3822: RP#46 completed / Impacted TSs and TRs: 36.521-1, 36.521-2, 36.508, 36.509, 36.523-1, 36.523-2, 36.523-3
- 3823: RP#46 completed. RP#50 TR 36.903 v100 for Approval / Impacted TSs and TRs: 36.521-1, 36.521-2, 36.521-3, new TR 36.903
- 3824: -
- 3825: RP#37 completed / Impacted TSs and TRs: 25.101, 25.104, 25.133, 25.141, 25.331, 25.942, 25.306, 25.307, 34.121
- 3826: RP#40 completed / Impacted TSs and TRs: 25.101, 25.104, 25.133, 25.141, 25.331, 25.942, 25.306, 25.307, 34.121
- 3827: RP#43 completed / Impacted TSs and TRs: 25.102, 25.105, 25.113, 25.123, 25.142, 34.124, 25.307
- 3828: RP#41 completed. RP#47 abandoned draft 25.828 / Impacted TSs and TRs: 25.102, 25.105, 25.113, 25.123, 25.142, 34.124, 25.306, 25.331, 34.122
- 3829: RP#39 completed / Impacted TSs and TRs: 25.101
- 3830: RP#39 completed / Impacted TSs and TRs: 25.323, 25.331, 25.322
- 3831: RP#39 completed / Impacted TSs and TRs: 25.101
- 3832: RP#41 stopped / Impacted TSs and TRs: 25.101, 25.104, 25.133, 25.141, 25.331, 25.942, 25.306, 25.307, 34.121
- 3833: 05/08: Linked to Feature UID_20028 (RInImp)
- 3834: RP#41 completed / Impacted TSs and TRs: 34.108, 34.123-1, 34.123-2, 34.123-3
- 3835: RP#42 completed / Impacted TSs and TRs: 34.121-1, 34.121-2
- 3836: -
- 3837: RP#41 completed / Impacted TSs and TRs: 25.308, 25.211, 25.212, 25.213, 25.306, 25.331, 25.433, 25.435, 25.423, 25.425, 25.101, 25.104, 25.141
- 3838: RP#40 completed. Linked to UID_370037 Enhanced Uplink for CELL_FACH State in FDD / Impacted TSs and TRs: 25.319, 25.301, 25.306, 25.321, 25.331, 25.433, 25.435, 25.423, 25.425, 25.427
- 3839: RP#42 completed. Linked to UID_370036 Improved L2 for uplink / Impacted TSs and TRs: 25.309, 25.211, 25.214, 25.321, 25.331, 25.423, 25.433
- 3840: RP#41 completed. Continuation of Rel-7 work item "Continuous connectivity for packet data users" UID_20046. / Impacted TSs and TRs: 25.306, 25.308, 25.321, 25.331, 25.423
- 3841: RP#41 completed. Linked to UID_370040 Enhancements for FDD HSPA Evolution / Impacted TSs and TRs: 25.306, 25.308, 25.321, 25.331, 25.423, 25.433, 25.214, 25.133
- 3842: RP#42 completed. Triggered by Rel-7 Study on Scope of future FDD HSPA Evolution (UID_20065) TR 25.999 / Impacted TSs and TRs: 25.401, 25.413, 25.420, 25.423, 25.427, 25.433, 25.446, 25.301, 25.346
- 3843: RP#42 completed. Linked to Rel-8 Study on Scope of future HSPA Evolution for 1.28 Mcps TDD (UID_370041) TR 25.824 / Impacted TSs and TRs: 25.102, 25.105, 25.123, 25.142, 25.201, 25.221, 25.222, 25.223, 25.224, 25.306, 25.308, 25.321, 25.331, 25.423, 25.433
- 3844: RP#42 completed. Linked to Rel-8 Study on Scope of future HSPA Evolution for 1.28 Mcps TDD (UID_370041) TR 25.824 / Impacted TSs and TRs: 25.123, 25.221, 25.222, 25.224, 25.301, 25.302, 25.304, 25.306, 25.308, 25.319, 25.321, 25.331, 25.401, 25.423, 25.425, 25.433, 25.435
- 3845: RP#44 completed. Linked to Rel-8 Study on Scope of future HSPA Evolution for 1.28 Mcps TDD (UID_370041) TR 25.824 / Impacted TSs and TRs: 25.929, 25.308, 25.319
- 3846: RP#43 completed / Impacted TSs and TRs: 25.331, 25.413
- 3847: RP#42 completed / Impacted TSs and TRs: 25.101, 25.104, 25.133, 25.212, 25.214, 25.308, 25.321, 25.331, 25.423, 25.433
- 3848: RP#43 completed / Impacted TSs and TRs: 25.201, 25.221, 25.222, 25.223, 25.224, 25.306, 25.308, 25.321, 25.331, 25.423, 25.433, 25.102, 25.105, 25.142
- 3849: RP#42 completed. Triggered by UID_390032 Study on Dual-Cell HSDPA (withdrawn TR 25.825 v100). / Impacted TSs and TRs: 25.101, 25.104, 25.133, 25.141, 25.211, 25.212, 25.213, 25.214, 25.215, 25.306, 25.308, 25.321, 25.331, 25.423, 25.433

| ID | WBS | Task | Duration | Start | Finish | Complete | Baseline start | Baseline finish | Baseline duration | Constraint | Resources | Work | Actual work | Release | MCC resp | Acronym | PCG approved | WI rapporteur name | TSG approved | Status Report | Acronym_3GU_Export |
| --- | --- | --- | --- | --- | --- | --- | --- | --- | --- | --- | --- | --- | --- | --- | --- | --- | --- | --- | --- | --- | --- |
| 3850 | 953 | **Rel-8 RAN improvements - UE Conformance Testing** | 602d? | 2008-05-30 A | 2010-09-17 A | 100% | 2008-05-30 | 2010-09-17 | 602d? |  | R5 | 29391.2h | 29391.2h | Rel-8 | Ingbert |  |  |  |  |  |  |
| 3851 | 953.1 | Conformance Test Aspects – Combination of 64QAM and MIMO for HSDPA (FDD) | 322d? | 2008-09-12 A | 2009-12-04 A | 100% | 2008-09-12 | 2009-12-04 | 322d? | finish no earlier than 2009-12-04 | R5 | 2576h | 2576h | Rel-8 | Ingbert | RANimp-UEConTest_64QamMimoHsdpa | PCG-21 | Ericsson | RP-41 | RP-091058 | RANimp-UEConTest_64QamMimoHsdpa |
| 3852 | 953.2 | Conformance Test Aspects – Improved L2 for uplink | 341d? | 2008-05-30 A | 2009-09-18 A | 100% | 2008-05-30 | 2009-09-18 | 341d? | finish no earlier than 2009-09-18 | R5 | 2728h | 2728h | Rel-8 | Ingbert | RANimp-UEConTest_UplinkL2dataRates | PCG-21 | Ericsson | RP-40 | RP-090712 | RANimp-UEConTest_UplinkL2dataRates |
| 3853 | 953.3 | Conformance Test Aspects – 1.28 Mcps TDD Improved L2 support for high data rates | 342d? | 2009-05-29 A | 2010-09-17 A | 100% | 2009-05-29 | 2010-09-17 | 342d? | finish no earlier than 2010-09-17 | R5 | 2736h | 2736h | Rel-8 | Ingbert | RANimp-UEConTest_ImprovedL2LCRTDD | PCG-23 | CATT | RP-44 | RP-100737 | RANimp-UEConTest_ImprovedL2LCRTDD |
| 3854 | 953.4 | Conformance Test Aspects – 64QAM for 1.28 Mcps TDD HSDPA | 261d? | 2008-05-30 A | 2009-05-29 A | 100% | 2008-05-30 | 2009-05-29 | 261d? | finish no earlier than 2009-05-29 | R5 | 2088h | 2088h | Rel-8 | Ingbert | RANimp-UEConTest_64Qam1.28TDD | PCG-21 | ZTE | RP-40 | RP-090415 | RANimp-UEConTest_64Qam1.28TDD |
| 3855 | 953.5 | Conformance Test Aspects – Dual-Cell HSDPA operation on adjacent carriers | 391d? | 2008-12-05 A | 2010-06-04 A | 100% | 2008-12-05 | 2010-06-04 | 391d? | finish no earlier than 2010-06-04 | R5 | 3128h | 3128h | Rel-8 | Ingbert | RANimp-UEConTest_DCHSDPA | PCG-22 | Qualcomm | RP-42 | RP-100479 | RANimp-UEConTest_DCHSDPA |
| 3856 | 953.6 | Conformance Test Aspects – Enhanced Uplink for CELL_FACH State in FDD | 326d? | 2009-03-06 A | 2010-06-04 A | 100% | 2009-03-06 | 2010-06-04 | 326d? | finish no earlier than 2010-06-04 | R5 | 2608h | 2608h | Rel-8 | Ingbert | RANimp-UEConTest_EnhancedRACHCellFACHState | PCG-22 | Nokia | RP-43 | RP-100483 | RANimp-UEConTest_EnhancedRACHCellFACHState |
| 3857 | 953.7 | Conformance Test Aspects – Receiver Type3i | 196d? | 2009-03-06 A | 2009-12-04 A | 100% | 2009-03-06 | 2009-12-04 | 196d? | finish no earlier than 2009-12-04 | R5 | 1568h | 1568h | Rel-8 | Ingbert | RANimp-UEConTest_ReceiverType3i | PCG-22 | Qualcomm | RP-43 | RP-091066 | RANimp-UEConTest_ReceiverType3i |
| 3858 | 953.8 | Conformance Test Aspects – Enhanced CELL_FACH State in LCR TDD | 341d? | 2009-05-30 A | 2010-09-17 A | 100% | 2009-05-30 | 2010-09-17 | 341d? | finish no earlier than 2010-09-17 | R5 | 2728h | 2728h | Rel-8 | Ingbert | RANimp-UEConTest_EnhancedCellFACHStateLCRTDD | PCG-23 | CATT | RP-44 | RP-100735 | RANimp-UEConTest_EnhancedCellFACHStateLCRTDD |
| 3859 | 953.9 | Conformance Test Aspects – Continuous Connectivity for packet data users for 1.28 Mcps TDD | 261d? | 2009-09-18 A | 2010-09-17 A | 100% | 2009-09-18 | 2010-09-17 | 261d? | finish no earlier than 2010-09-17 | R5 | 2088h | 2088h | Rel-8 | Ingbert | RANimp-UEConTest_CPCLCRTDD | PCG-23 | ZTE | RP-45 | RP-100739 | RANimp-UEConTest_CPCLCRTDD |
| 3860 | 953.10 | Conformance Test Aspects – MIMO for 1.28 Mcps TDD | 186d? | 2009-09-18 A | 2010-06-04 A | 100% | 2009-09-18 | 2010-06-04 | 186d? | finish no earlier than 2010-06-04 | R5 | 1488h | 1488h | Rel-8 | Ingbert | RANimp-UEConTest_MIMOLCRTDD | PCG-23 | ZTE | RP-45 | RP-100660 | RANimp-UEConTest_MIMOLCRTDD |
| 3861 | 953.11 | Conformance Test Aspects – HS-DSCH Serving Cell Change Enhancements | 131d? | 2009-09-18 A | 2010-03-19 A | 100% | 2009-09-18 | 2010-03-19 | 131d? | finish no earlier than 2010-03-12 | R5 | 1048h | 1048h | Rel-8 | Ingbert | HSDSCH_UEConTest | PCG-23 | Qualcomm | RP-45 | RP-100077 | HSDSCH_UEConTest |
| 3862 | 954 | 3.84 Mcps TDD MBMS over a Single Frequency Network (MBSFN) Integrated Mobile Broadcast | 395d? | 2007-06-04 A | 2008-12-05 A | 100% | 2007-06-04 | 2008-12-05 | 395d? |  | R1 | 3160h | 3160h | Rel-8 | Patrick | MBSFN-DOB |  | Ericsson |  | RP-080218 | MBSFN-DOB |
| 3863 | 955 | Conformance Test Aspects – 3.84 Mcps TDD MBMS over a Single Frequency Network (MBSFN) Integrated Mobile Broadcast | 211d? | 2009-05-30 A | 2010-03-19 A | 100% | 2009-05-30 | 2010-03-19 | 211d? | finish no earlier than 2010-03-19 | R5 | 1688h | 1688h | Rel-8 | Ingbert | MBSFN_IMB_UEConTest | PCG-23 | IPwireless | RP-44 | RP-100070 | MBSFN_IMB_UEConTest |
| 3864 | 956 | **GERAN support for GERAN - 3G Long Term Evolution interworking** | 1365d? | 2006-09-08 A | 2011-11-25 A | 100% | 2006-09-08 | 2011-11-25 | 1365d? |  | GP; G1; C1; G3new | 69960h | 69960h | Rel-8 | Paolo | GELTE |  | Nokia, Nokia Siemens Networks |  |  | GELTE |
| 3865 | 956.1 | G1 part of GERAN support for GERAN - 3G Long Term Evolution interworking | 641d? | 2006-09-08 A | 2009-02-20 A | 100% | 2006-09-08 | 2009-02-20 | 641d? | finish no earlier than 2009-02-20 | G1 | 5128h | 5128h | Rel-8 | Paolo | GELTE |  | Nokia, Nokia Siemens Networks |  |  |  |
| 3866 | 956.2 | G2 part of GERAN support for GERAN - 3G Long Term Evolution interworking | 641d? | 2006-09-08 A | 2009-02-20 A | 100% | 2006-09-08 | 2009-02-20 | 641d? | finish no earlier than 2009-02-20 | G2 | 5128h | 5128h | Rel-8 | Paolo | GELTE |  | Nokia, Nokia Siemens Networks |  |  |  |
| 3867 | 956.3 | CT1 part of GERAN support for GERAN - 3G Long Term Evolution interworking | 641d? | 2006-09-08 A | 2009-02-20 A | 100% | 2006-09-08 | 2009-02-20 | 641d? | finish no earlier than 2009-02-20 | C1 | 5128h | 5128h | Rel-8 | Paolo | GELTE |  | Nokia, Nokia Siemens Networks |  |  |  |
| 3868 | 956.4 | Testing for GERAN support for GERAN - 3G Long Term Evolution interworking | 1363d? | 2006-09-08 A | 2011-11-25 A | 100% | 2006-09-08 | 2011-11-25 | 1363d? | finish no earlier than 2011-11-25 | G3new | 10896h | 10896h | Rel-8 | Ingbert | GELTE |  | Renesas Mobile |  |  |  |
| 3869 | 957 | U-TDOA Enhancement | 131d? | 2007-05-18 A | 2007-11-16 A | 100% | 2007-05-18 | 2007-11-16 | 131d? | finish no earlier than 2007-05-18 | GP | 1048h | 1048h | Rel-8 | Paolo | GUTEN |  | TruePosition |  |  | GUTEN |
| 3870 | 958 | **GAN Enhancements** | 604.2d? | 2007-05-15 A | 2009-09-04 A | 100% | 2007-05-15 | 2009-09-04 | 604.2d? |  | GP | 9432h | 9432h | Rel-8 | Paolo | GANENH |  | T-Mobile |  |  | GANENH |
| 3871 | 958.1 | Update to GAN specifications | 126d? | 2007-08-31 A | 2008-02-22 A | 100% | 2007-08-31 | 2008-02-22 | 126d? | finish no earlier than 2008-02-22 | GP | 1008h | 1008h | Rel-8 | Paolo | GANENH-SPEC |  | T-Mobile |  |  | GANENH-SPEC |
| 3872 | 958.2 | Update TS 51.010 Mobile Station (MS) Conformance Specification for GAN Enhancements | 526d? | 2007-05-15 A | 2009-09-04 A | 100% | 2007-05-15 | 2009-09-04 | 526d? | finish no earlier than 2009-09-04 | G3new | 4208h | 4208h | Rel-8 | Ingbert | GANENH-MStest |  | T-Mobile |  |  | GANENH-MStest |
| 3873 | 959 | **AoIP (A-interface over IP)** | 2335d? | 2000-01-03 A | 2008-12-11 A | 100% | 2000-01-03 | 2008-12-11 | 2335d? |  | GP; S4; C4; C1; C3 | 119396h | 119396h | Rel-8 | Paolo | AoIP | PCG-21 | China Mobile, Ericsson |  |  | AoIP |
| 3874 | 959.1 | GERAN aspects of AoIP | 2321d? | 2000-01-03 A | 2008-11-21 A | 100% | 2000-01-03 | 2008-11-21 | 2321d? | finish no earlier than 2008-11-21 | GP | 18560h | 18560h | Rel-8 | Paolo | AoIP | PCG-21 | China Mobile, Ericsson | SP-40 |  |  |
| 3875 | 959.2 | Media Requirements for CS over IP based User Plane | 267d? | 2007-12-05 A | 2008-12-11 A | 100% | 2007-12-05 | 2008-12-11 | 267d? | finish no earlier than 2008-12-11 | S4 | 1996.09h | 1996.09h | Rel-8 | Paolo | AoIP-CSoIP | PCG-21 | China Mobile, Ericsson | SP-40 |  | AoIP-CSoIP |

Notes:
- 3850: Linked to Feature UID_20029 (RANimp)
- 3851: RP#46 completed. Testing for UID_360013 / Impacted TSs and TRs: 34.108, 34.121-1, 34.121-2, 34.123-1, 34.123-2 / WI rapporteur e-mail: leif.mattisson@ericsson.com
- 3852: RP#45 completed. Testing for UID_370036 / Impacted TSs and TRs: 34.108, 34.123-1, 34.123-2, 34.123-3 / WI rapporteur e-mail: leif.mattisson@ericsson.com
- 3853: RP#49 completed. Testing for Rel-7 UID_340039 Improved L2 support for high data rates and Rel-8 UID_370036 Improved L2 for uplink / Impacted TSs and TRs: 34.108, 34.123-1, 34.123-2, 34.123-3 / WI rapporteur e-mail: Xiaozhong Chen (chenxiaozhong@datangmobile.cn)
- 3854: RP#44 completed. Testing for UID_380075 / Impacted TSs and TRs: 34.108, 34.122, 34.123-1, 34.123-2, 34.123-3 / WI rapporteur e-mail: ma.zijiang@zte.com.cn
- 3855: RP#48 completed. Testing for UID_400052 / Impacted TSs and TRs: 34.108, 34.121-1, 34.121-2, 34.123-1, 34.123-2, 34.123-3 / WI rapporteur e-mail: Shubhang Vora (svora@qualcomm.com)
- 3856: RP#48 completed. Testing for UID_370037 / Impacted TSs and TRs: 34.108, 34.121-1, 34.121-2, 34.123-1, 34.123-2, 34.123-3 / WI rapporteur e-mail: jarkko.hellsten@nokia.com
- 3857: RP#46 completed. Testing for Receiver Type3i in 25.101 UE radio Tx and Rx FDD / Impacted TSs and TRs: 34.108, 34.121-1, 34.121-2 / WI rapporteur e-mail: Ashok Kumar Narayanaswamy (anarayan@qualcomm.com)
- 3858: RP#49 completed. Testing for UID_380076 / Impacted TSs and TRs: 34.108, 34.123-1, 34.123-2, 34.123-3 / WI rapporteur e-mail: Xiaozhong Chen (chenxiaozhong@datangmobile.cn)
- 3859: RP#49 completed. Testing for UID_390028 / Impacted TSs and TRs: 34.108, 34.123-1, 34.123-2, 34.123-3 / WI rapporteur e-mail: huang.he4@zte.com.cn
- 3860: PR#48 completed. Testing for UID_400050 / Impacted TSs and TRs: 34.108, 34.122, 34.123-1, 34.123-2, 34.123-3 / WI rapporteur e-mail: huang.chun2@zte.com.cn
- 3861: RP#47 completed. Testing for UID_390030 / Impacted TSs and TRs: 34.108, 34.121-1, 34.121-2, 34.123-1, 34.123-2, 34.123-3 / WI rapporteur e-mail: Shubhang Vora (svora@qualcomm.com)
- 3862: RP#42 completed. WID updated RP-070493=>RP-081124 (changed WI title "MBSFN Downlink Optimized Broadcast (DOB) 3.84 Mcps TDD" => "3.84Mcps TDD MBSFN Integrated Mobile Broadcast"). / Impacted TSs and TRs: 25.102, 25.105, 25.123, 25.201, 25.221, 25.222, 25.223, 25.224, 25.304, 25.306, 25.331, 25.346, 25.402, 25.433 / WI rapporteur e-mail: Lars.Lindbom@ericsson.com
- 3863: RP#47 completed. Testing for Rel-8 MBSFN-DOB UID_360008 / Impacted TSs and TRs: 34.108, 34.122, 34.123-1, 34.123-2, 34.123-3 / WI rapporteur e-mail: Phil Young (pyoung@ipwireless.com)
- 3864: GP#41 completed. GP#52 completed MS conformance testing / Impacted TSs and TRs: 44.018, 44.060, 45.002, 45.008, 45.010, 48.008, 48.018, 51.010 / WI rapporteur e-mail: sergio.parolari@nsn.com, vlora.rexhepi@nokia.com
- 3865: GP#41 completed / Impacted TSs and TRs: 43.055, 43.129, 43.246, 45.002, 45.008, 45.010 / WI rapporteur e-mail: sergio.parolari@nsn.com, vlora.rexhepi@nokia.com
- 3866: GP#41 completed / Impacted TSs and TRs: 44.018, 44.060, 48.008, 48.018 / WI rapporteur e-mail: sergio.parolari@nsn.com, vlora.rexhepi@nokia.com
- 3867: - / Impacted TSs and TRs: 24.008 / WI rapporteur e-mail: sergio.parolari@nsn.com, vlora.rexhepi@nokia.com
- 3868: GP#52 completed / Impacted TSs and TRs: 51.010 / WI rapporteur e-mail: deepa.kamath@renesasmobile.com
- 3869: GP#36 completed U-TDOA (Uplink Time Difference of Arrival) / Impacted TSs and TRs: 43.059, 45.008, 48.071 / WI rapporteur e-mail: Terry Brooks (terri.brooks@trueposition.com)
- 3870: GP#37 completed. GP#43 completed Testing / WI rapporteur e-mail: mohammed.versi@t-mobile.com
- 3871: GP#37 completed / Impacted TSs and TRs: 43.318, 44.318 / WI rapporteur e-mail: mohammed.versi@t-mobile.com
- 3872: GP#43 completed / Impacted TSs and TRs: 51.010 / WI rapporteur e-mail: mohammed.versi@t-mobile.com
- 3873: GP#40/TSG#42 completed . Triggered by TR 43.903 Study on A-interface over IP (AINTIP) UID_50589. / WI rapporteur e-mail: wangshuaiyu@chinamobile.com, paul.schliwa-bertling@ericsson.com
- 3874: GP#40 completed. GP#39 updated WID GP-080901=>GP-081362. / Impacted TSs and TRs: 48.001, 48.002, 48.008, 48.020, 49.008, 48.103 / WI rapporteur e-mail: wangshuaiyu@chinamobile.com, paul.schliwa-bertling@ericsson.com
- 3875: SP#42 completed / Impacted TSs and TRs: 26.102, 26.103, 26.202 / WI rapporteur e-mail: Karl.Hellwig@Ericsson.com

| ID | WBS | Task | Type | Duration | Start | Finish | Complete | Baseline start | Baseline finish | Baseline duration | Constraint | Resources | Work | Actual work | Acronym | PCG approved | WI rapporteur name | Release | TSG approved | MCC resp | Acronym_3GU_Export | Impacted TSs and TRs | Status Report | TSG stopped | Special Focus Doc | PCG stopped |
| --- | --- | --- | --- | --- | --- | --- | --- | --- | --- | --- | --- | --- | --- | --- | --- | --- | --- | --- | --- | --- | --- | --- | --- | --- | --- | --- |
| 3876 | 959.3 | **Core Network Impacts for A-Interface User Plane over IP** |  | 136d? | 2008-05-30 A | 2008-12-05 A | 100% | 2008-05-30 | 2008-12-05 | 136d? |  | C4; C1; C3 | 5440h | 5440h | AoIP-CN | PCG-21 | Ericsson | Rel-8 | CP-40 | Kimmo | AoIP-CN |  |  |  |  |  |
| 3877 | 959.3.1 | CT4 part of Core Network Impacts for A-Interface User Plane over IP |  | 136d? | 2008-05-30 A | 2008-12-05 A | 100% | 2008-05-30 | 2008-12-05 | 136d? | start no earlier than 2008-05-30 | C4 | 1088h | 1088h | AoIP-CN | PCG-21 | Ericsson | Rel-8 | CP-40 | Kimmo |  | 23.205, 23.153, 23.231, 29.232 |  |  |  |  |
| 3878 | 959.3.2 | CT1 part of Core Network Impacts for A-Interface User Plane over IP |  | 68d? | 2008-05-30 A | 2008-12-05 A | 100% | 2008-05-30 | 2008-12-05 | 68d? | finish no earlier than 2008-12-05 | C1 | 544h | 544h | AoIP-CN | PCG-21 | Ericsson | Rel-8 | CP-40 | Frederic |  | 23.009 |  |  |  |  |
| 3879 | 959.3.3 | CT3 part of Core Network Impacts for A-Interface User Plane over IP |  | 68d? | 2008-05-30 A | 2008-12-05 A | 100% | 2008-05-30 | 2008-12-05 | 68d? | finish no earlier than 2008-12-05 | C3 | 544h | 544h | AoIP-CN | PCG-21 | Ericsson | Rel-8 | CP-40 | Adrian |  | 29.007 |  |  |  |  |
| 3880 | 960 | New multicarrier BTS class |  | 261d? | 2007-08-31 A | 2008-08-29 A | 100% | 2007-08-31 | 2008-08-29 | 261d? | finish no earlier than 2008-08-29 | G1 | 2088h | 2088h | MCBTS |  | Alcatel-Lucent | Rel-8 |  | Paolo | MCBTS | 45.005, 45.050, 51.021 |  |  |  |  |
| 3881 | 961 | **Support for Additional Navigation Satellite Systems (ANSS) for LCS** |  | 150d? | 2008-05-16 A | 2008-12-11 A | 100% | 2008-05-16 | 2008-12-11 | 150d? |  | S1; G2; R2 | 5784h | 5784h | ANSS |  | Qualcomm | Rel-8 |  | Paolo | ANSS |  |  |  |  |  |
| 3882 | 961.1 | Stage 1 for ANSS for LCS |  | 1d? | 2008-12-11 A | 2008-12-11 A | 100% | 2008-12-11 | 2008-12-11 | 1d? | start no earlier than 2008-12-11 | S1 | 8h | 8h | ANSS | PCG-22 |  | Rel-8 | SP-42 | Alain |  | 22.071 |  |  |  |  |
| 3883 | 961.2 | GERAN2 part of Support for Additional Navigation Satellite Systems (ANSS) for LCS |  | 136d? | 2008-05-16 A | 2008-11-21 A | 100% | 2008-05-16 | 2008-11-21 | 136d? | start no earlier than 2008-05-16 | G2 | 1088h | 1088h | ANSS |  | Qualcomm | Rel-8 |  | Paolo |  | 43.059, 44.031, 49.031, 44.071, 48.031, 51.010 |  |  |  |  |
| 3884 | 961.3 | RAN2 part of Support for Additional Navigation Satellite Systems (ANSS) for LCS |  | 136d? | 2008-05-30 A | 2008-12-05 A | 100% | 2008-05-30 | 2008-12-05 | 136d? | finish no earlier than 2008-12-08 | R2 | 1088h | 1088h | RANimp-ANSS | PCG-21 | Qualcomm | Rel-8 | RP-40 | Yong-Jun | RANimp-ANSS | 25.305, 25.306, 25.331, 25.413, 25.423, 25.433, 25.453 | RP-080813 |  |  |  |
| 3885 | 962 | **Conformance testing for the Latency Reductions feature** |  | 532d? | 2008-02-22 A | 2010-03-05 A | 100% | 2008-02-22 | 2010-03-05 | 532d? |  | G1; G3new | 14848h | 14848h | CTLATRED | PCG-21 | Ericsson | Rel-8 |  | Paolo | CTLATRED |  |  |  |  |  |
| 3886 | 962.1 | MS conformance testing for the Latency Reductions feature |  | 532d? | 2008-02-22 A | 2010-03-05 A | 100% | 2008-02-22 | 2010-03-05 | 532d? | finish no earlier than 2010-03-05 | G3new | 4248h | 4248h | CTLATRED-MStest | PCG-21 | Ericsson | Rel-8 |  | Ingbert | CTLATRED-MStest | 51.010 |  |  |  |  |
| 3887 | 962.2 | BTS conformance testing for the Latency Reductions feature |  | 261d? | 2008-02-22 A | 2009-02-20 A | 100% | 2008-02-22 | 2009-02-20 | 261d? | finish no earlier than 2009-02-20 | G1 | 2088h | 2088h | CTLATRED-BTStest | PCG-21 | Ericsson | Rel-8 |  | Paolo | CTLATRED-BTStest | 51.021 |  |  |  |  |
| 3888 | 963 | MS conformance testing of changes introduced by WI "Support of Packet-switched Handover for GERAN A/Gb mode" |  | 196d? | 2008-02-22 A | 2008-11-21 A | 100% | 2008-02-22 | 2008-11-21 | 196d? | finish no earlier than 2008-11-21 | G3new | 1568h | 1568h | PSHCT-MStest | PCG-21 | Rohde & Schwarz | Rel-8 |  | Ingbert | PSHCT-MStest | 51.010 |  |  |  |  |
| 3889 | 964 | (Small) Technical Enhancements and Improvements for Rel-8 |  | 509d? | 2007-01-01 A | 2008-12-11 A | 100% | 2007-01-01 | 2008-12-11 | 509d? | finish no earlier than 2008-12-11 | SP; CP; RP; GP | 16288h | 16288h | TEI8 |  |  | Rel-8 |  | All | TEI8 |  |  |  |  |  |
| 3890 | 965 | (IETF) (Small) Technical Enhancements and Improvements for Rel-8 |  | 650d? | 2007-01-01 A | 2012-09-07 A | 100% | 2007-01-01 | 2012-09-07 | 650d? | finish no earlier than 2012-09-07 | C1-IETF | 5200h | 5200h | TEI8_IETF | PCG-27 | christer.holmberg@ericsson.com | Rel-8 | CP-52 | Frederic | TEI8_IETF | RFC 6714 (was draft-ietf-simple-msrp-cema) |  |  |  |  |
| 3891 | 966 | Test - (Small) Technical Enhancements and Improvements for Rel-8 |  | 993.6d? | 2007-03-07 A | 2010-12-24 A | 100% | 2007-03-07 | 2010-12-24 | 993.6d? | finish no earlier than 2010-12-24 | R5; G3new | 15897.6h | 15897.6h | TEI8_Test | PCG-21 |  | Rel-8 | RP-40 | Ingbert | TEI8_Test |  |  |  |  |  |
| 3892 | 967 | **Deleted - All-IP Network** |  | 448d? | 2004-06-28 A | 2006-03-15 A | 100% | 2004-06-28 | 2006-03-15 | 448d? |  | S1 | 7168h | 7168h | AIPN |  | NTT DoCoMo | Rel-8 |  | Alain | AIPN |  |  | SP-38 |  |  |
| 3893 | 967.1 | Deleted - Stage 1 |  | 448d? | 2004-06-28 A | 2006-03-15 A | 100% | 2004-06-28 | 2006-03-15 | 448d? | finish no earlier than 2006-03-15 | S1 | 3584h | 3584h | AIPN |  | NTT DoCoMo | Rel-8 |  | Alain |  | 22.258 |  | SP-38 |  |  |
| 3894 | 968 | Deleted - was Rel-7 - LCS for 3GPP Interworking WLAN | milestone | 0d? | 2007-09-28 A | 2007-09-28 A | 100% | 2007-09-28 | 2007-09-28 | 0d? | start no earlier than 2007-09-28 | S2 |  |  | LCS4_IWLAN |  | LG Electronics | Rel-8 | TSG-34 | Maurice | LCS4_IWLAN | 23.234, 23.271, 23.167 |  | SP-35 | WLAN |  |
| 3895 | 969 | Deleted - never approved- FBI Phase 2 | milestone | 0d | 2007-09-28 A | 2007-09-28 A | 100% | 2007-09-28 | 2007-09-28 | 0d | start no earlier than 2007-09-28 | S2 |  |  | FBI2 |  | Nokia Siemens Networks | Rel-8 |  | Maurice | FBI2 |  |  | SP-38 |  |  |
| 3896 | 970 | Deleted -Enhancements to BS30 Bearer service for Videotelephony | milestone | 0d? | 2007-03-15 A | 2007-03-15 A | 100% | 2007-03-15 | 2007-03-15 | 0d? | finish no earlier than 2007-03-15 | S1 |  |  | BS30 |  |  | Rel-8 |  | Alain | BS30 | 22.002, 22.004, 22.101, 22.105, 24.008 |  | SP-38 |  |  |
| 3897 | 971 | Deleted - IMS Enhancements Rel-8 |  | 75d? | 2007-09-03 A | 2007-12-14 A | 100% | 2007-09-03 | 2007-12-14 | 75d? |  | S1 | 600h | 600h | IMS8 |  | Telecom Italia | Rel-8 | SP-37 | Alain | IMS8 |  |  | SP-38 |  |  |
| 3898 | 972 | **Deleted - Contact Manager Conformance Test specifications** |  | 471d? | 2008-06-02 A | 2010-03-19 A | 100% | 2008-06-02 | 2010-03-19 | 471d? |  | C6 | 11304h | 11304h | eUPHBOOK-Test | PCG-21 | Comprion, Gemalto | Rel-8 | CP-40 | Xavier | eUPHBOOK-Test |  |  | CP-47 |  | PCG-24 |
| 3899 | 972.1 | Deleted - Contact Manager for 3GPP UICC applications test specifications |  | 471d? | 2008-06-02 A | 2010-03-19 A | 100% | 2008-06-02 | 2010-03-19 | 471d? | finish no earlier than 2010-03-19 | C6 | 3768h | 3768h | eUPHBOOK-Test | PCG-21 | Comprion | Rel-8 | CP-40 | Xavier |  | 31.320 (external interface for communication with the ME) |  | CP-47 |  | PCG-24 |
| 3900 | 972.2 | Deleted - Contact Manager API for Java™ Card test specification |  | 471d? | 2008-06-02 A | 2010-03-19 A | 100% | 2008-06-02 | 2010-03-19 | 471d? | finish no earlier than 2010-03-19 | C6 | 3768h | 3768h | eUPHBOOK-Test | PCG-21 | Gemalto | Rel-8 | CP-40 | Xavier |  | 31.321 (internal interface (API)) |  | CP-47 |  | PCG-24 |
| 3901 | 973 | Deleted - MS conformance testing of Support of Conversational Services in A/Gb mode via the PS domain |  | 401d? | 2008-02-25 A | 2009-09-04 A | 100% | 2008-02-25 | 2009-09-04 | 401d? | finish no earlier than 2009-09-04 | G3new | 3208h | 3208h | SCSAGBCT-MStest | PCG-21 | Nokia | Rel-8 |  | Ingbert | SCSAGBCT-MStest | 51.010 |  | GP-43 |  | PCG-23 |
| 3902 | 974 | Release 8 Studies | milestone | 0d? | 2005-10-07 A | 2005-10-07 A | 100% | 2005-10-07 | 2010-11-12 | 1332d? | start no earlier than 2000-01-03 | CP; GP; RP; SP |  |  |  |  |  | Rel-8 |  | All |  |  |  |  |  |  |
| 3903 | 975 | Study on Customised Alerting Tone (CAT) Requirements |  | 245d? | 2005-10-07 A | 2006-09-14 A | 100% | 2005-10-07 | 2006-09-14 | 245d? | start no earlier than 2005-10-07 | S1 | 1960h | 1960h | FS_CAT |  | China Mobile | Rel-8 |  | Alain | FS_CAT | 22.982 |  |  |  |  |
| 3904 | 976 | Study on Facilitating Machine to Machine Communication in GSM and UMTS (M2M) |  | 350d? | 2005-11-04 A | 2007-03-08 A | 100% | 2005-11-04 | 2007-03-08 | 350d? | finish no earlier than 2006-06-16 | S1 | 2800h | 2800h | FS_M2M |  | Siemens | Rel-8 |  | Alain | FS_M2M | 22.868 |  |  | MTC, M2M |  |
| 3905 | 977 | Study on Network Composition |  | 526d? | 2005-12-07 A | 2007-12-12 A | 100% | 2005-12-07 | 2007-12-12 | 526d? | finish no earlier than 2006-09-27 | S1 | 4208h | 4208h | FS_NetComp |  | Nokia Siemens Networks | Rel-8 |  | Alain | FS_NetComp | 22.980 |  |  |  |  |
| 3906 | 978 | Study on Requirements of IMS Multimedia Conferencing |  | 330d? | 2006-06-08 A | 2007-09-12 A | 100% | 2006-06-08 | 2007-09-12 | 330d? | finish no earlier than 2007-03-21 | S1 | 2640h | 2640h | FS_IMSconf |  | China Mobile | Rel-8 |  | Alain | FS_IMSconf | 22.948 |  |  |  |  |
| 3907 | 979 | Study on support of a Public Warning System |  | 140d? | 2007-09-03 A | 2008-03-14 A | 100% | 2007-09-03 | 2008-03-14 | 140d? |  | S1 | 1120h | 1120h | FS_PWS |  | T-Mobile | Rel-8 |  | Alain | FS_PWS | 22.968 |  |  | Public Safety (I-A) |  |
| 3908 | 980 | Study on Paging Permission with Access Control |  | 256d? | 2006-09-28 A | 2007-09-20 A | 100% | 2006-09-28 | 2007-09-20 | 256d? | finish no earlier than 2007-09-20 | S1 | 2048h | 2048h | FS_PPAC |  | NTT DoCoMo | Rel-8 |  | Alain | FS_PPAC | 22.908 |  |  |  |  |
| 3909 | 981 | Study on Non-3GPP access Network Selection Principles (NSP) |  | 392d? | 2006-12-06 A | 2008-06-05 A | 100% | 2006-12-06 | 2008-06-05 | 392d? | finish no earlier than 2007-11-19 | S1 | 3136h | 3136h | FS_N3GtoNSP |  | Telefónica O2 | Rel-8 | TSG-34 | Alain | FS_N3GtoNSP | 22.912 |  |  |  |  |
| 3910 | 982 | Study on Value Added Services for Short Message Service |  | 263d? | 2006-12-06 A | 2007-12-07 A | 100% | 2006-12-06 | 2007-12-07 | 263d? | finish no earlier than 2007-12-07 | S1 | 2104h | 2104h | FS_VAS4SMS |  | China Mobile | Rel-8 | TSG-34 | Alain | FS_VAS4SMS | 22.942 |  |  |  |  |
| 3911 | 983 | Study on Service continuity between mobile and WLAN networks |  | 262d? | 2006-12-06 A | 2007-12-06 A | 100% | 2006-12-06 | 2007-12-06 | 262d? | finish no earlier than 2008-12-25 | S1 | 2096h | 2096h | FS_SMLSWLAN |  | NEC | Rel-8 | TSG-34 | Alain | FS_SMLSWLAN | 22.937 |  |  | WLAN |  |
| 3912 | 984 | Study on Services Alignment and Migration |  | 331d? | 2006-12-06 A | 2008-03-12 A | 100% | 2006-12-06 | 2008-03-12 | 331d? | finish no earlier than 2007-09-20 | S1 | 2648h | 2648h | FS_ServAl |  | Telefónica O2 | Rel-8 | SP-37 | Alain | FS_ServAl | 22.983 |  |  |  |  |

Notes:
- 3876: CP#42 completed. Updated WID CP-080278=>CP-080722 / WI rapporteur e-mail: philip.hodges@ericsson.com
- 3877: CP#42 completed. Updated WID CP-080278=>CP-080722 / WI rapporteur e-mail: philip.hodges@ericsson.com
- 3878: CP#42 completed. Updated WID CP-080278=>CP-080722 / WI rapporteur e-mail: philip.hodges@ericsson.com
- 3879: CP#42 completed. Updated WID CP-080278=>CP-080722 / WI rapporteur e-mail: philip.hodges@ericsson.com
- 3880: GP#39 completed / WI rapporteur e-mail: thomas.bitzer@alcatel-lucent.de
- 3881: GP#40 completed / WI rapporteur e-mail: Mungal Dhanda
- 3882: SP#42 completed by 22.071 CR0077
- 3883: GP#40 completed / WI rapporteur e-mail: Mungal Dhanda
- 3884: RP#42 WI closed at 95%. Considers Rel-9 performance requirements / WI rapporteur e-mail: Etienne Chaponniere (echaponn@qualcomm.com)
- 3885: GP#45 completed / WI rapporteur e-mail: mats.y.samuelsson@ericsson.com, hakan.e.grunditz@ericsson.com
- 3886: GP#45 completed / WI rapporteur e-mail: hakan.e.grunditz@ericsson.com
- 3887: GP#41 completed / WI rapporteur e-mail: mats.y.samuelsson@ericsson.com
- 3888: GP#40 completed / WI rapporteur e-mail: Franz.Segerer@ROHDE-SCHWARZ.COM
- 3889: SP#42 completed
- 3890: CP#57 completed / WI rapporteur e-mail: christer.holmberg@ericsson.com
- 3891: -
- 3892: SP#38 stopped. 25/07/08 Moved UID_31059 Study on All-IP Network (FS_AIPN/was AIPFS) to Rel-7 out of the stopped Rel-8 Feature UID_31067 Deleted - All-IP Network (AIPN) / WI rapporteur e-mail: c.masyu@nttdocomo.co.jp
- 3893: 22.258 withdrawn, superseded by 22.278 (UID 320022). SP#38 stopped / WI rapporteur e-mail: c.masyu@nttdocomo.co.jp
- 3894: SP#35 stopped / WI rapporteur e-mail: dhshim@lge.com
- 3895: SP#38 stopped
- 3896: SP#38 stopped (no support) / WI rapporteur e-mail: andre.jarvis@three.co.uk
- 3897: SP#38 stopped
- 3898: CP#47 work stopped/abandoned / WI rapporteur e-mail: Udo Willenbrink, Jacques Seif
- 3899: CP#47 work stopped/abandoned / WI rapporteur e-mail: Udo Willenbrink (uwillenbrink@comprion.com )
- 3900: CP#47 work stopped/abandoned / WI rapporteur e-mail: jacques.seif@gemalto.com
- 3901: GP#43 work stopped/abandoned (completion 0%) / WI rapporteur e-mail: arsi.heino@nokia.com
- 3902: -
- 3903: Spin-off Rel-8 Feature Customized Alerting Tone (CAT) Service UID_340029 / WI rapporteur e-mail: Qing Huang (huangqing@chinamobile.com)
- 3904: SP#35 completed. Spin-off SA3 Study on Security Aspects of Remote Provisioning and Change of Subscription for M2M (UID_370053). SP#40 Spin-off new Feature UID_410030 (NIMTC) / WI rapporteur e-mail: Juergen Merkel
- 3905: SP#38 completed / WI rapporteur e-mail: joerg.swetina@neclab.eu
- 3906: SP#37 completed. Spin-off New Feature UID_370026 Value-Added Services for Short Message Service (VAS4SMS) / WI rapporteur e-mail: Qing Huang (huangqing@chinamobile.com)
- 3907: SP#39 completed. Spin-off Rel-9 Feature UID_380057 (PWS) / WI rapporteur e-mail: mark.younge@t-mobile.com
- 3908: SP#37 completed. Spin-off new Feature UID_370084 (PPACR) / WI rapporteur e-mail: Katsuhiro NOGUCHI (noguchi@nttdocomo.co.jp)
- 3909: SP#38 completed. Spin-off New Feature UID_380062 (N3GTONSP). SP#40 WID updated SP-060930=>SP-080318. TR re-approved with new # 22.812=>22.912 / WI rapporteur e-mail: chris.friel@O2.com
- 3910: SP#38 completed. Spin-off New Feature UID_370026 (VAS4SM) / WI rapporteur e-mail: Qing Huang (huangqing@chinamobile.com)
- 3911: SP#38 completed / WI rapporteur e-mail: joerg.swetina@neclab.eu
- 3912: SP#39 completed. Spin-off Rel-9 Feature UID_330017 Services Alignment and Migration (ServAl) / WI rapporteur e-mail: chris.friel@O2.com

| ID | WBS | Task | Duration | Start | Finish | Complete | Baseline start | Baseline finish | Baseline duration | Constraint | Resources | Work | Actual work | Acronym | WI rapporteur name | WI rapporteur e-mail | Release | MCC resp | Acronym_3GU_Export | Impacted TSs and TRs | PCG approved | TSG approved | Special Focus Doc | Status Report | PCG stopped | TSG stopped |
| --- | --- | --- | --- | --- | --- | --- | --- | --- | --- | --- | --- | --- | --- | --- | --- | --- | --- | --- | --- | --- | --- | --- | --- | --- | --- | --- |
| 3913 | 985 | **Study on 3GPP System Architecture Evolution** | 1115d? | 2004-12-03 A | 2009-03-12 A | 100% | 2004-12-03 | 2009-03-12 | 1115d? |  | S2; S3 | 34064h | 34064h | FS_SAE | Vodafone | chris.pudney@vodafone.com | Rel-8 | Maurice | FS_SAE |  |  |  |  |  |  |  |
| 3914 | 985.1 | Stage 2 Interim conclusion for RAN Work to start | 990d? | 2004-12-03 A | 2008-09-18 A | 100% | 2004-12-03 | 2008-09-18 | 990d? | finish no earlier than 2005-09-23 | S2 | 7920h | 7920h | FS_SAE | Vodafone | chris.pudney@vodafone.com | Rel-8 | Maurice |  | 23.882 |  |  |  |  |  |  |
| 3915 | 985.2 | Stage 2 study on 3GPP architectural development | 704d? | 2006-01-09 A | 2008-09-18 A | 100% | 2006-01-09 | 2008-09-18 | 704d? | finish no earlier than 2007-09-28 | S2 | 5632h | 5632h | FS_SAE | Vodafone | chris.pudney@vodafone.com | Rel-8 | Maurice |  | 23.882 |  |  |  |  |  |  |
| 3916 | 985.3 | Security study for Inter-access mobility between non-3GPP and 3GPP system | 334d? | 2007-09-03 A | 2009-03-12 A | 100% | 2007-09-03 | 2009-03-12 | 334d? | finish no earlier than 2009-03-12 | S3 | 2672h | 2672h | FS_SAE | Nokia | dajiang.zhang@nokia.com | Rel-8 | Mirko |  | 33.821, 33.822 |  |  |  |  |  |  |
| 3917 | 986 | Study on Stage 2 aspects of IMS Service Brokering | 589d? | 2006-06-19 A | 2008-09-18 A | 100% | 2006-06-19 | 2008-09-18 | 589d? | finish no earlier than 2008-09-18 | S2 | 4712h | 4712h | FS_ISB_ST2 | Telcordia | raquel@research.telcordia.com | Rel-8 | Maurice | FS_ISB_ST2 | 23.810 |  |  |  |  |  |  |
| 3918 | 987 | Study on IMS utilizing multicast bearer services | 447d? | 2006-03-22 A | 2007-12-06 A | 100% | 2006-03-22 | 2007-12-06 | 447d? | finish no earlier than 2007-12-03 | S2 | 3576h | 3576h | FS_MLTICAST-IMS | Nokia Siemens Networks |  | Rel-8 | Maurice | FS_MLTICAST-IMS | 23.847 |  |  |  |  |  |  |
| 3919 | 988 | Study on Multimedia Session Continuity | 291d? | 2007-04-26 A | 2008-06-05 A | 100% | 2007-04-26 | 2008-06-05 | 291d? | finish no earlier than 2008-06-05 | S2 | 2328h | 2328h | FS_MMSC | LG Electronics |  | Rel-8 | Maurice | FS_MMSC | 23.893 |  |  |  |  |  |  |
| 3920 | 989 | **Study on centralized IMS service control** | 363d? | 2006-10-23 A | 2008-03-12 A | 100% | 2006-10-23 | 2008-03-12 | 363d? |  | S2; S1 | 10856h | 10856h | FS_ICS | Ericsson | peter.bleckert@ericsson.com | Rel-8 | Alain | FS_ICS |  | PCG-21 | SP-38 |  |  |  |  |
| 3921 | 989.1 | Study on centralized IMS services requirements | 268d? | 2007-03-05 A | 2008-03-12 A | 100% | 2007-03-05 | 2008-03-12 | 268d? | start no earlier than 2007-03-05 | S1 | 2144h | 2144h | FS_ICS-S1 | NEC | joerg.swetina@neclab.eu | Rel-8 | Alain | FS_ICS-S1 | 22.892 |  | SP-37 |  |  |  |  |
| 3922 | 989.2 | Study on centralized IMS services control | 363d? | 2006-10-23 A | 2008-03-12 A | 100% | 2006-10-23 | 2008-03-12 | 363d? | finish no earlier than 2008-02-21 | S2 | 2904h | 2904h | FS_IMS_CSC | Alcatel-Lucent | andy.bennett@alcatel-lucent.com | Rel-8 | Maurice | FS_IMS_CSC | 23.892 |  |  |  |  |  |  |
| 3923 | 990 | Study on Architecture of IMS based Customized Alerting Tone (CAT) | 208d? | 2007-12-04 A | 2008-09-18 A | 100% | 2007-12-04 | 2008-09-18 | 208d? | finish no earlier than 2008-09-08 | S2 | 1664h | 1664h | FS_CAT-St2 | China Mobile | WANG, Jing (wangjing@chinamobilecom) | Rel-8 | Maurice | FS_CAT-St2 | 23.872 | PCG-21 | SP-38 |  |  |  |  |
| 3924 | 991 | Study on Home (e)NodeB Security | 321d? | 2007-12-20 A | 2009-03-12 A | 100% | 2007-12-20 | 2009-03-12 | 321d? | finish no earlier than 2009-03-10 | S3 | 2568h | 2568h | FS_HNB_Sec | Huawei | yangyanmei@huawei.com | Rel-8 | Mirko | FS_HNB_Sec | 33.820 | PCG-21 | SP-38 | HNB |  |  |  |
| 3925 | 992 | Study on Transferring of emergency call data – in-band modem solution | 265d? | 2006-12-07 A | 2007-12-12 A | 100% | 2006-12-07 | 2007-12-12 | 265d? | finish no earlier than 2008-09-18 | S4 | 2120h | 2120h | eCALLIBMS | Airbiquity | lhong@airbiquity.com | Rel-8 | Paolo | eCALLIBMS | 26.967 |  |  | Public Safety (I-A) |  |  |  |
| 3926 | 993 | Study on Element Operations Systems Function (EOSF) definition | 266d? | 2007-06-07 A | 2008-06-12 A | 100% | 2007-06-07 | 2008-06-12 | 266d? | finish no earlier than 2008-12-11 | S5 | 2128h | 2128h | OAM7-NIM-EOSF | China Mobile | Li Jian (lijian@chinamobile.com) | Rel-8 | Mirko | OAM7-NIM-EOSF | 32.819 |  |  |  |  |  |  |
| 3927 | 994 | Study on SA5 MTOSI XML Harmonization | 351d? | 2006-05-10 A | 2007-09-12 A | 100% | 2006-05-10 | 2007-09-12 | 351d? | finish no earlier than 2007-12-14 | S5 | 2808h | 2808h | OAM8-NIM-XML | Nortel | jduguay@nortel.com | Rel-8 | Mirko | OAM8-NIM-XML | 32.818 |  |  |  |  |  |  |
| 3928 | 995 | Study on Common Profile Storage (CPS) Framework of User Data for network services and management | 244d? | 2006-07-03 A | 2007-06-07 A | 100% | 2006-07-03 | 2007-06-07 | 244d? | finish no earlier than 2007-06-07 | S5 | 1952h | 1952h | OAM7-CPS | T-Mobile | istvan.aba@t-mobile.at | Rel-8 | Mirko | OAM7-CPS | 32.808 |  |  |  |  |  |  |
| 3929 | 996 | Study on Management for LTE and SAE | 526d? | 2006-12-07 A | 2008-12-11 A | 100% | 2006-12-07 | 2008-12-11 | 526d? | finish no earlier than 2008-12-11 | S5 | 4208h | 4208h | FS_OAM_LTE_SAE | Ericsson | robert.petersen@ericsson.com | Rel-8 | Mirko | FS_OAM_LTE_SAE | 32.816 |  | TSG-34 |  |  |  |  |
| 3930 | 997 | Study on Charging Aspects of 3GPP System Evolution | 179d? | 2007-04-02 A | 2007-12-06 A | 100% | 2007-04-02 | 2007-12-06 | 179d? | finish no earlier than 2007-12-06 | S5 | 1432h | 1432h | FS_SAEcharg | Nokia Siemens Networks | Gerald.Goermer@nsn.com | Rel-8 | Mirko | FS_SAEcharg | 32.820 |  |  |  |  |  |  |
| 3931 | 998 | Study on AS-MRFC media server control protocol | 583d? | 2006-03-22 A | 2008-06-13 A | 100% | 2006-03-22 | 2008-06-13 | 583d? | finish no earlier than 2008-06-13 | C1 | 4664h | 4664h | MRFC | Hewlett-Packard | mark.syrett@hp.com | Rel-8 | Frederic | MRFC | 24.880 |  |  |  |  |  |  |
| 3932 | 999 | Study on IMS Restoration Procedures | 310d? | 2007-03-26 A | 2008-05-30 A | 100% | 2007-03-26 | 2008-05-30 | 310d? | finish no earlier than 2008-05-30 | C4 | 2480h | 2480h | FS_IMS_RP | Ericsson | german.blanco@ericsson.com | Rel-8 | Kimmo | FS_IMS_RP | 23.820 |  |  |  |  |  |  |
| 3933 | 1000 | Study on IMS Application Server Service Data Descriptions for AS interoperability | 261d? | 2007-09-14 A | 2008-09-12 A | 100% | 2007-09-14 | 2008-09-12 | 261d? | finish no earlier than 2008-09-12 | C4 | 2088h | 2088h | FS_IMS_ASIO | Alcatel-Lucent | Jean-Jacques Trottin | Rel-8 | Kimmo | FS_IMS_ASIO | 29.864 |  |  |  |  |  |  |
| 3934 | 1001 | Study on Customized Alerting Tone (CAT) solution for voice and video call in CS domain | 261d? | 2007-09-14 A | 2008-09-12 A | 100% | 2007-09-14 | 2008-09-12 | 261d? |  | C4 | 626.4h | 626.4h | FS_CAT_VVC_CS | China Mobile | zhanghao@chinamobile.com | Rel-8 | Kimmo | FS_CAT_VVC_CS | 29.882 |  |  |  |  |  |  |
| 3935 | 1002 | Study on InterWorking Function between MAP based and Diameter based interfaces | 266d? | 2007-11-30 A | 2008-12-05 A | 100% | 2007-11-30 | 2008-12-05 | 266d? | finish no earlier than 2008-12-05 | C4 | 2128h | 2128h | FS_MAP2Diam | Huawei | liming49985@huawei.com | Rel-8 | Kimmo | FS_MAP2Diam | 29.805 | PCG-21 | CP-38 |  |  |  |  |
| 3936 | 1003 | Study on Scope of future HSPA Evolution for 1.28 Mcps TDD | 186d? | 2007-09-14 A | 2008-05-30 A | 100% | 2007-09-14 | 2008-05-30 | 186d? | finish no earlier than 2008-05-30 | R1 | 1488h | 1488h | FS_RAN-LCRTDDHSPAEvo | RITT | Xu Fei | Rel-8 | Patrick | FS_RAN-LCRTDDHSPAEvo | 25.824 |  | RP-37 |  | RP-080290 |  |  |
| 3937 | 1004 | Study on Synchronized E-DCH for UTRA FDD | 126d? | 2007-09-14 A | 2008-03-07 A | 100% | 2007-09-14 | 2008-03-07 | 126d? | finish no earlier than 2008-03-14 | R1 | 1008h | 1008h | FS_RAN-UplinkSync | Nokia Siemens Networks | Karri.Ranta-aho@nsn.com | Rel-8 | Patrick | FS_RAN-UplinkSync | 25.823 |  | RP-37 |  | RP-080068 |  |  |
| 3938 | 1005 | Study on Improved network controlled mobility between LTE and 3GPP2/mobile WiMAX radio technologies | 131d? | 2007-06-04 A | 2007-12-03 A | 100% | 2007-06-04 | 2007-12-03 | 131d? | finish no earlier than 2007-12-03 | R4 | 1048h | 1048h | FS_RAN-LTEmob | Motorola | hao.bi@Motorola.com | Rel-8 | Issam | FS_RAN-LTEmob | 36.938 |  |  |  | RP-070827 |  |  |
| 3939 | 1006 | Study on 3G Home NodeB/eNodeB | 325d? | 2007-03-05 A | 2008-05-30 A | 100% | 2007-03-05 | 2008-05-30 | 325d? | finish no earlier than 2008-05-30 | R4 | 2600h | 2600h | FS_RAN-HNBeNB | Motorola | howard.thomas@motorola.com | Rel-8 | Issam | FS_RAN-HNBeNB | 25.820 |  |  | HNB | RP-080289 |  |  |
| 3940 | 1007 | Study on A-interface over IP | 126d? | 2007-08-31 A | 2008-02-22 A | 100% | 2007-08-31 | 2008-02-22 | 126d? | finish no earlier than 2008-02-22 | GP | 1008h | 1008h | AINTIP | China Mobile, Ericsson | paul.schliwa-bertling@ericsson.com | Rel-8 | Paolo | AINTIP | 43.903 |  |  |  |  |  |  |
| 3941 | 1008 | Study on Multi-User Reusing-One-Slot | 782d? | 2007-11-16 A | 2010-11-12 A | 100% | 2007-11-16 | 2010-11-12 | 782d? | finish no earlier than 2010-11-12 | GP | 6248h | 6248h | MUROS | Nokia Siemens Networks | juergen.hofmann@nsn.com | Rel-8 | Paolo | MUROS | 45.914 |  |  |  |  |  |  |
| 3942 | 1009 | Study on Optimized Transmit Pulse Shape for Downlink EGPRS2-B | 657d? | 2007-11-16 A | 2010-05-21 A | 100% | 2007-11-16 | 2010-05-21 | 657d? | finish no earlier than 2010-05-27 | G1 | 5248.44h | 5248.44h | WIDER | Research In Motion, Nokia Siemens Networks | jdwyer@RIM.COM and eddie.riddington@nsn.com | Rel-8 | Paolo | WIDER | 45.913 |  |  |  |  |  |  |
| 3943 | 1010 | Deleted - Study on Mobility between 3GPP-WLAN Interworking and 3GPP Systems | 393d? | 2007-03-20 A | 2008-09-18 A | 100% | 2007-03-20 | 2008-09-18 | 393d? | finish no earlier than 2008-09-18 | S2 | 3144h | 3144h | FS_SM3GWLAN | Orange |  | Rel-8 | Maurice | FS_SM3GWLAN | withdrawn 23.827 |  |  | WLAN |  | PCG-21 | SP-41 |
| 3944 | 1011 | Deleted - equals 340035 -FS on Service continuity between mobile and WLAN networks | 75d? | 2007-09-03 A | 2007-12-14 A | 100% | 2007-09-03 | 2007-12-14 | 75d? | finish no earlier than 2007-12-14 | S1 | 600h | 600h | FSSCMobToW | BT | mike.meyerstein@bt.com | Rel-8 | Alain | FSSCMobToW | 22.937 |  | SP-37 |  |  | PCG-21 | SP-39 |
| 3945 | 1012 | Deleted - Study on Evaluation of LCS Control Plane Solution for EPS | 100d? | 2008-01-14 A | 2008-05-30 A | 100% | 2008-01-14 | 2008-05-30 | 100d? | finish no earlier than 2009-03-20 | S2 | 800h | 800h | FS_LCS_EPS | SiRF |  | Rel-8 | Maurice | FS_LCS_EPS | 23.891 |  | SP-38 |  |  | PCG-21 | SP-40 |
| 3946 | 1013 | Deleted - Study on HS-PDSCH serving cell change enhancements | 60d? | 2007-12-17 A | 2008-03-07 A | 100% | 2007-12-17 | 2008-03-07 | 60d? | finish no earlier than 2008-06-12 | R4 | 480h | 480h | FS_RAN-HSPDSCH | Qualcomm |  | Rel-8 | Issam | FS_RAN-HSPDSCH | none | PCG-21 | RP-38 |  | RP-080070 | PCG-21 | RP-39 |
| 3947 | 1014 | Deleted - Study on Dual-Cell HSDPA operation | 261d? | 2007-08-15 A | 2009-03-06 A | 100% | 2007-08-15 | 2009-03-06 | 261d? | finish no earlier than 2009-03-06 | R1 | 2088h | 2088h | FS_RAN-DCHS | Qualcomm | Josef Blanz | Rel-8 | Patrick | FS_RAN-DCHS | withdrawn 25.825 v100 | PCG-21 | RP-39 |  | RP-090066 | PCG-22 | RP-43 |
| 3948 | 1015 | Release 7 Features | 679d? | 2005-05-02 A | 2007-12-06 A | 100% | 2005-05-02 | 2007-12-06 | 679d? | start no earlier than 2000-01-01 | CP; GP; RP; SP | 21728h | 21728h |  |  |  | Rel-7 | All |  |  |  |  |  |  |  |  |

Notes:
- 3913: SP#43 completed
- 3914: SP#41 completed
- 3915: SP#41 completed
- 3916: SP#43 completed
- 3917: SP#41 completed. No spin-off activity proposed. [Note: IMS Service Brokering enhancements UID_31088 moved back from R8 to R7 to give a home to 22228CR0036_(Rel-7)_S1-051232. Hence, Rel-7 ISB has Stage 1 only (and is misaligned with Rel-7 Stages 2/3.]
- 3918: SP#38 completed
- 3919: SP#40 completed
- 3920: SP#39 completed
- 3921: SP#39 completed
- 3922: SP#39 completed
- 3923: SP#41 completed as Rel-8
- 3924: SP#43 completed. Linked to RAN4 Study on 3G Home NodeB/eNodeB (UID_350039) and to SA5 Study on Self-Organizing Networks (SON) related OAM interfaces for Home NodeB (UID_360007)
- 3925: SP#38 completed. Spin-off WID UID_34042 (eCall_Phase2)
- 3926: SP#40 completed. WID updated SP-050608=>SP-070307
- 3927: SP#37 completed. WID updated SP-050295=>SP-070305
- 3928: SP#36 completed. Spin-off New Feature UID_400034 User Data Convergence (UDC)
- 3929: SP#42 completed
- 3930: SP#38 completed
- 3931: CP#40 completed. Spin-off New Feature UID_380035 (MRFC_TS)
- 3932: CP#40 completed. Spin-off WID UID_400012 (IMS_RP)
- 3933: CP#41 completed. Linked to SA5 Study on Common Profile Storage framework UID_320006. Spin-off WID UID_410003 (IMS_ASIO)
- 3934: CP#41 completed. Spin-off WID under Feature CAT UID_340029
- 3935: CP#42 completed. Spin-off implementation Building Block UID_410007 (MAP2Diam) under the SAES Feature UID_320005
- 3936: RP#40 completed
- 3937: RP#39 completed
- 3938: RP#38 completed
- 3939: RP#40 completed
- 3940: GP#37 completed. Spin-off implementation Feature AoIP (A-interface over IP) UID_50591
- 3941: GP#48 completed as Rel-8. Spin-off implementation WI UID_420002 VAMOS (Voice services over Adaptive Multi-user channels on One Slot)
- 3942: GP#46 completed
- 3943: SP#41 stopped. Draft TR 23.827 content implemented in TS 23.327.
- 3944: SP#39 stopped
- 3945: SP#40 spin-off Feature UID_400038 (LCS_CPS_EPS). SP#40 FS stopped
- 3946: RP#39 stopped (no TR produced). Spin-off HS-DSCH Serving Cell Change Enhancements (UID_39003)
- 3947: RP#43 stopped (draft TR 25.825 v100 withdrawn). Conclusions in RP-090318 (RAN1 findings of the UTRA Multi-Carrier Evolution study). RP#42 New WI approved on Dual-Cell HSDPA operation on adjacent carriers (UID_400052)
- 3948: -

| ID | WBS | Task | Type | Duration | Start | Finish | Complete | Remaining | Baseline start | Baseline finish | Baseline duration | Total slack | Constraint | Resources | Work | Actual work | Acronym | WI rapporteur name | WI rapporteur e-mail | Release | MCC resp | Acronym_3GU_Export | TSG stopped | PCG approved | TSG approved | Status Report | Special Focus Doc |
| --- | --- | --- | --- | --- | --- | --- | --- | --- | --- | --- | --- | --- | --- | --- | --- | --- | --- | --- | --- | --- | --- | --- | --- | --- | --- | --- | --- |
| 3949 | 1016 | **Identification of Communication Services in IMS** |  | 620d? | 2005-05-02 A | 2007-09-14 A | 100% |  | 2005-05-02 | 2007-09-14 | 620d? |  |  | S2; S1; C1; S5 | 29048h | 29048h | ServID | Ericsson | stephen.terrill@ericsson.com | Rel-7 | Maurice | ServID |  |  |  |  |  |
| 3950 | 1016.1 | TR on ServID |  | 232d? | 2005-05-02 A | 2006-03-21 A | 100% |  | 2005-05-02 | 2006-03-21 | 232d? |  | finish no earlier than 2006-03-20 | S2 | 1856h | 1856h | ServID | Ericsson | stephen.terrill@ericsson.com | Rel-7 | Maurice |  |  |  |  |  |  |
| 3951 | 1016.2 | Stage 1,2 of ServID |  | 144d? | 2005-11-11 A | 2006-05-31 A | 100% |  | 2005-11-11 | 2006-05-31 | 144d? |  | start no earlier than 2005-11-11 | S1; S2 | 2304h | 2304h | ServID | Ericsson | stephen.terrill@ericsson.com | Rel-7 | Maurice |  |  |  |  |  |  |
| 3952 | 1016.3 | Stage 3 of ServID |  | 250d? | 2006-03-31 A | 2007-03-15 A | 100% |  | 2006-03-31 | 2007-03-15 | 250d? |  | finish no earlier than 2007-03-15 | C1 | 2000h | 2000h | ServID | Ericsson | christer.holmberg@ericsson.com | Rel-7 | Frederic |  |  |  |  |  |  |
| 3953 | 1016.4 | Charging of ServID |  | 381d? | 2006-03-31 A | 2007-09-14 A | 100% |  | 2006-03-31 | 2007-09-14 | 381d? |  | finish no earlier than 2007-09-14 | S5 | 3048h | 3048h | ServID | Orange | alain.bibas@orange-ft.com | Rel-7 | Mirko |  |  |  |  |  |  |
| 3954 | 1017 | **Supporting Globally Routable User Agent URIs in IMS** |  | 415d? | 2005-11-14 A | 2007-06-15 A | 100% |  | 2005-11-14 | 2007-06-15 | 415d? |  |  | S2; S1; C1 | 14920h | 14920h | GRUU | Research In Motion | Adrian Buckley (abuckley@rim.com) | Rel-7 | Maurice | GRUU |  |  |  |  |  |
| 3955 | 1017.1 | Deleted - TR on GRUU |  | 219d? | 2005-11-14 A | 2006-09-14 A | 100% |  | 2005-11-14 | 2006-09-14 | 219d? |  | finish no earlier than 2006-09-14 | S2 | 1752h | 1752h | GRUU | Research In Motion | Adrian Buckley (abuckley@rim.com) | Rel-7 | Maurice |  | SP-32 |  |  |  |  |
| 3956 | 1017.2 | Stage 1,2 of GRUU |  | 65d? | 2006-07-03 A | 2006-09-29 A | 100% |  | 2006-07-03 | 2006-09-29 | 65d? |  | start no earlier than 2006-07-03 | S1; S2 | 1040h | 1040h | GRUU | Research In Motion | Adrian Buckley (abuckley@rim.com) | Rel-7 | Maurice |  |  |  |  |  |  |
| 3957 | 1017.3 | Stage 3 of GRUU |  | 271d? | 2006-06-02 A | 2007-06-15 A | 100% |  | 2006-06-02 | 2007-06-15 | 271d? |  | finish no earlier than 2007-06-15 | C1 | 2168h | 2168h | GRUU | CableLabs | Bernie McKibben (b.mckibben@cablelabs.com) | Rel-7 | Frederic |  |  |  |  |  |  |
| 3958 | 1018 | **Multimedia Telephony Service for IMS** |  | 2855d? | 2006-02-01 A | 2016-12-15 | 77% | 660.08d? | 2006-02-01 | 2007-06-15 | 357d? | 347d |  | S1; C1; S4 | 79904h | 17320h | MTSI | Ericsson | peter.bleckert@ericsson.com | Rel-7 | Alain | MTSI |  | PCG-35 | RP-69 |  |  |
| 3959 | 1018.1 | Stage 1 of MTSI |  | 173d? | 2006-02-01 A | 2006-09-29 A | 100% |  | 2006-02-01 | 2006-09-29 | 173d? |  | start no earlier than 2006-02-01 | S1 | 1384h | 1384h | MTSI-REQ | Ericsson | peter.bleckert@ericsson.com | Rel-7 | Alain | MTSI-REQ |  |  |  |  |  |
| 3960 | 1018.2 | Stage 3 of MTSI |  | 330d? | 2006-03-10 A | 2007-06-14 A | 100% |  | 2006-03-10 | 2007-06-14 | 330d? |  | finish no earlier than 2007-06-15 | C1 | 2640h | 2640h | MTSI | Ericsson | christer.holmberg@ericsson.com | Rel-7 | Frederic | MTSI |  |  |  |  |  |
| 3961 | 1018.3 | Media handling and interaction in MTSI |  | 262d? | 2006-03-15 A | 2007-03-15 A | 100% |  | 2006-03-15 | 2007-03-15 | 262d? |  | finish no earlier than 2007-03-15 | S4 | 2096h | 2096h | MTSI-MHI | Ericsson | olle.franceschi@ericsson.com | Rel-7 | Paolo | MTSI-MHI |  |  |  |  |  |
| 3962 | 1018.4 | UE Conformance Test Aspects - Multimedia Telephony Services for IMS (MTSI) over fixed access |  | 329d? | 2015-09-15 A | 2016-12-15 | 50% | 164.5d? |  |  |  | 347d | finish no earlier than 2016-12-15 | R5 | 2632h | 1316h | MTSI_FIXED_ACCESS-UEConTest | Telecom Italia |  | Rel-7 |  |  |  | PCG-35 | RP-69 |  |  |
| 3963 | 1018.5 | UE Conformance Test Aspects – Multimedia Telephony Services for IMS (MTSI) over WLAN |  | 329d? | 2015-09-15 A | 2016-12-15 | 50% | 164.5d? |  |  |  | 347d | finish no earlier than 2016-12-15 | R5 | 2632h | 1316h | MTSI_WLAN-UEConTest | Ericsson |  | Rel-7 |  |  |  | PCG-35 | RP-69 |  |  |
| 3964 | 1018.6 | Deleted - duplicates UID7039 - IMS Multimedia Telephony Service | milestone | 0d? | 2007-06-15 A | 2007-06-15 A | 100% |  | 2007-06-15 | 2007-06-15 | 0d? |  | start no earlier than 2007-06-15 | S1 |  |  | MMTEL | Ericsson | peter.bleckert@ericsson.com | Rel-7 | Alain | MMTEL | SP-32 |  |  |  |  |
| 3965 | 1019 | Multimedia Telephony Service for IMS (MTSI) - UE Conformance Testing |  | 387d | 2007-09-19 A | 2009-03-12 A | 100% |  | 2007-09-19 | 2009-03-12 | 387d |  | finish no earlier than 2009-03-13 | R5 | 1664h | 1664h | MTSI-UEConTest | Ericsson, Motorola | Leif.Mattisson@ericsson.com, Jacob.John@motorola.com | Rel-7 | Ingbert | MTSI-UEConTest |  |  |  | RP-090056 |  |
| 3966 | 1020 | TISPAN requirements for Multimedia Telephony with PSTN/ISDN simulation services |  | 58d? | 2007-09-18 A | 2007-12-06 A | 100% |  | 2007-09-18 | 2007-12-06 | 58d? |  | start no earlier than 2007-09-18 | S1 | 464h | 464h | TMMTEL7 |  |  | Rel-7 | Alain | TMMTEL7 |  |  | SP-37 |  |  |
| 3967 | 1021 | **Maintenance of TISPAN release 1 common IMS** |  | 180d? | 2007-07-02 A | 2008-03-07 A | 100% |  | 2007-07-02 | 2008-03-07 | 180d? |  |  | S2 | 5808h | 5808h | MCIMSTR1 | Ericsson | Raymond Forbes | Rel-7 | Maurice | MCIMSTR1 |  | PCG-21 | SP-38 |  |  |
| 3968 | 1021.1 | SA1 aspects of MCIMSTR1 |  | 58d? | 2007-09-18 A | 2007-12-06 A | 100% |  | 2007-09-18 | 2007-12-06 | 58d? |  | finish no earlier than 2007-12-06 | S1 | 464h | 464h | MCIMSTR1-S1 | Telecom Italia | Marco.DeLuca1@telecomitalia.it | Rel-7 | Alain | MCIMSTR1-S1 |  | PCG-21 | SP-38 |  |  |
| 3969 | 1021.2 | SA2 aspects of MCIMSTR1 |  | 58d? | 2007-09-18 A | 2007-12-06 A | 100% |  | 2007-09-18 | 2007-12-06 | 58d? |  | finish no earlier than 2007-12-06 | S2 | 464h | 464h | MCIMSTR1-S2 | Ericsson | Raymond Forbes | Rel-7 | Maurice | MCIMSTR1-S2 |  | PCG-21 | SP-38 |  |  |
| 3970 | 1021.3 | SA1,SA2 part of Maintenance of TISPAN release 1 common IMS |  | 114d? | 2007-07-02 A | 2007-12-06 A | 100% |  | 2007-07-02 | 2007-12-06 | 114d? |  | finish no earlier than 2007-12-06 | S2; S1 | 1824h | 1824h | IMS_Comm_Mtce7 | BT, Ericsson | Dick Knight, Raymond Forbes | Rel-7 | Maurice | IMS_Comm_Mtce7 |  | PCG-21 | SP-38 |  |  |
| 3971 | 1021.4 | Maintenance of TISPAN R1 |  | 86d? | 2007-11-09 A | 2008-03-07 A | 100% |  | 2007-11-09 | 2008-03-07 | 86d? |  | start no earlier than 2007-11-09 | C1; C3; C4 | 2064h | 2064h | MAINT_R1 | Alcatel-Lucent | Keith Drage (drage@alcatel-lucent.com) | Rel-7 | Frederic | MAINT_R1 |  | PCG-21 | CP-38 |  |  |
| 3972 | 1022 | **PS domain and IMS impacts for supporting IMS Emergency calls (EMC1)** |  | 2934d? | 2000-09-18 A | 2011-12-09 A | 100% |  | 2000-09-18 | 2011-12-09 | 2934d? |  |  | S2; S1; C1; C4; IETF | 185422h | 185422h | EMC1 | Siemens | Rainer Liebhart | Rel-7 | Maurice | EMC1 |  |  |  |  | Public Safety (I-A) |
| 3973 | 10.1.1 | Service Requirements for IP-based emergency calls |  | 985d | 2000-09-18 A | 2004-06-25 A | 100% |  | 2000-09-18 | 2004-06-25 | 985d |  | finish no earlier than 2004-06-25 | S1 | 7880h | 7880h | EMC1 | Siemens | Rainer Liebhart | Rel-7 | Alain |  |  |  |  |  | Public Safety (I-A) |
| 3974 | 1022.2 | Study on Stage 2 for IMS-level solution |  | 668d? | 2003-02-26 A | 2005-09-16 A | 100% |  | 2003-02-26 | 2005-09-16 | 668d? |  | finish no earlier than 2005-09-16 | S2 | 5344h | 5344h | EMC1 | Siemens | Rainer Liebhart | Rel-7 | Maurice |  |  |  |  |  | Public Safety (I-A) |
| 3975 | 1022.3 | Study on Stage 2 for GPRS-level solution |  | 301d? | 2004-10-14 A | 2005-12-08 A | 100% |  | 2004-10-14 | 2005-12-08 | 301d? |  | finish no earlier than 2005-12-08 | S2 | 2408h | 2408h | EMC1 | Siemens | Rainer Liebhart | Rel-7 | Maurice |  |  |  |  |  | Public Safety (I-A) |
| 3976 | 1022.4 | Stage 2 Specification Phase - IMS-level |  | 200d? | 2005-09-05 A | 2006-06-09 A | 100% |  | 2005-09-05 | 2006-06-09 | 200d? |  | finish no earlier than 2006-06-09 | S2 | 1600h | 1600h | EMC1 | Siemens | Rainer Liebhart | Rel-7 | Maurice |  |  |  |  |  | Public Safety (I-A) |
| 3977 | 1022.5 | Deleted - Stage 2 Specification Phase - GPRS-level | milestone | 0d? | 2007-03-02 A | 2007-03-02 A | 100% |  | 2007-03-02 | 2007-03-02 | 0d? |  | start no earlier than 2007-03-02 | S2 |  |  | EMC1 | Siemens | Rainer Liebhart | Rel-7 | Maurice |  | SP-32 |  |  |  | Public Safety (I-A) |

Notes:
- 3949: WID approved SP#28. WID updated SP#32
- 3950: - / Impacted TSs and TRs: 23.816
- 3951: - / Impacted TSs and TRs: 22.228, 23.228, 23.203
- 3952: CP#32 approved WID / Impacted TSs and TRs: 23.218, 24.229
- 3953: - / Impacted TSs and TRs: 32.260, 32.298, 32.299
- 3954: SP#29 approved WID
- 3955: Abandoned
- 3956: SP#29 approved WID / Impacted TSs and TRs: 22.228, 23.228, 23.218, 24.229
- 3957: CP#32 approved WID / Impacted TSs and TRs: 24.229
- 3958: -
- 3959: - / Impacted TSs and TRs: 22.173
- 3960: - / Impacted TSs and TRs: 24.173
- 3961: - / Impacted TSs and TRs: 26.114
- 3962: tested: REL-7 SA/CT WI MTSI;1/1/16: Compl:0%->5%; 22/3/16: Compl:5%->15%...1/7/16: Compl:15%->30%;...
- 3963: tested: REL-7 WI MTSI; 1/1/16: Compl:0%->5%1/1/16: WID: RP-151334->RP-15177022/3/16: Compl:5%->10%...;...
- 3964: - / Impacted TSs and TRs: 22.173
- 3965: RP#43 completed. Linked UID_7038 (MTSI) / Impacted TSs and TRs: 34.123-1, 34.123-2, 34.123-3, 34.229-1, 34.229-2
- 3966: - / Impacted TSs and TRs: 22.273 (EI 181 002 maintenance)
- 3967: - / Impacted TSs and TRs: http://www.3gpp.org/specs/TISPAN-IMS-ansfer.htm
- 3968: - / Impacted TSs and TRs: 22.173, 22.273
- 3969: - / Impacted TSs and TRs: 23.406, 23.417, 23.508,23.509, 23.511
- 3970: SP#38 completed / Impacted TSs and TRs: 22.173, 22.273, 22.401, 23.406, 23.417, 23.508, 23.509, 23.511
- 3971: CP#39 completed / Impacted TSs and TRs: 24.404, 24.405, 24.406, 24.407, 24.408, 24.410, 24.411, 24.416, 29.421, 24.423, 24.428, 24.429, 29.433, 24.441, 24.403, 29.427, 24.430, 29.412
- 3972: - / Impacted TSs and TRs: EMC1
- 3973: - / Impacted TSs and TRs: 22.101
- 3974: - / Impacted TSs and TRs: 23.867
- 3975: - / Impacted TSs and TRs: 23.867
- 3976: - / Impacted TSs and TRs: 23.060, 23.167, 23.203, 23.221, 23.228, 23.234, 23.271, 23.406
- 3977: -

| ID | WBS | Task | Type | Duration | Start | Finish | Complete | Baseline start | Baseline finish | Baseline duration | Constraint | Resources | Work | Actual work | Acronym | WI rapporteur name | WI rapporteur e-mail | Release | MCC resp | Special Focus Doc | Impacted TSs and TRs | PCG approved | TSG approved | TSG stopped | Acronym_3GU_Export | Created at | Status Report |
| --- | --- | --- | --- | --- | --- | --- | --- | --- | --- | --- | --- | --- | --- | --- | --- | --- | --- | --- | --- | --- | --- | --- | --- | --- | --- | --- | --- |
| 3978 | 10.1 | **Emergency Call Enhancements for IP& PS Based Calls – stage 3** |  | 1549d? | 2006-01-09 A | 2011-12-09 A | 100% | 2006-01-09 | 2011-12-09 | 1549d? |  | C1; C4; IETF | 50829.8h | 50829.8h | EMC1 | Ericsson | alf.heidermark@ericsson.com | Rel-7 | Frederic | Public Safety (I-A) |  |  |  |  |  |  |  |
| 3979 | 10.1.2 | CT1 IMS aspects to support IMS Emergency sessions |  | 350.82d | 2006-01-09 A | 2007-06-15 A | 100% | 2006-01-09 | 2007-06-15 | 350.82d | finish no earlier than 2007-06-15 | C1 | 2806.57h | 2806.57h | EMC1 | Ericsson | alf.heidermark@ericsson.com | Rel-7 | Frederic | Public Safety (I-A) | 24.229 |  |  |  |  |  |  |
| 3980 | 1022.6.2 | (IETF) CT1 IMS aspects to support IMS Emergency sessions |  | 452d? | 2006-01-09 A | 2011-12-09 A | 100% | 2006-01-09 | 2011-12-09 | 452d? | finish no earlier than 2011-12-09 | C1-IETF | 3608h | 3608h | EMC1 | Keith Drage |  | Rel-7 | Frederic | Public Safety (I-A) | RFC 6442 (was draft-ietf-sipcore-location-conveyance) | PCG-27 | CP-52 |  |  |  |  |
| 3981 | 10.1.2 | Deleted - CT3 IMS aspects to support IMS Emergency sessions |  | 95d | 2006-05-08 A | 2006-09-15 A | 100% | 2006-05-08 | 2006-09-15 | 95d | finish no earlier than 2006-09-15 | C3 | 760h | 760h | EMC1 | Ericsson | alf.heidermark@ericsson.com | Rel-7 | Adrian | Public Safety (I-A) | 29.163 |  |  | CP-33 |  |  |  |
| 3982 | 10.1.5 | Deleted - CT3 PS domain aspects to support IMS Emergency sessions |  | 95d | 2006-05-08 A | 2006-09-15 A | 100% | 2006-05-08 | 2006-09-15 | 95d | start no earlier than 2006-05-08 | C3 | 760h | 760h | EMC1 | Ericsson | alf.heidermark@ericsson.com | Rel-7 | Adrian | Public Safety (I-A) | 29.061 |  |  | CP-33 |  |  |  |
| 3983 | 10.1.5 | CT1 PS domain aspects to support IMS Emergency sessions |  | 349.9d | 2006-01-09 A | 2007-06-15 A | 100% | 2006-01-09 | 2007-06-15 | 349.9d | finish no earlier than 2007-06-15 | C1 | 2799.2h | 2799.2h | EMC1 | Ericsson | alf.heidermark@ericsson.com | Rel-7 | Frederic | Public Safety (I-A) | 24.008, 24.234 |  |  |  |  |  |  |
| 3984 | 10.1.5 | CT4 PS domain aspects to support IMS Emergency sessions |  | 365d | 2006-01-09 A | 2007-06-01 A | 100% | 2006-01-09 | 2007-06-01 | 365d | finish no earlier than 2007-06-01 | C4 | 2920h | 2920h | EMC1-GPRSc4 | Ericsson | alf.heidermark@ericsson.com | Rel-7 | Kimmo | Public Safety (I-A) | 29.060 |  |  |  | EMC1-GPRSc4 |  |  |
| 3985 | 1023 | IMS Support of Conferencing |  | 355d? | 2005-11-04 A | 2007-03-15 A | 100% | 2005-11-04 | 2007-03-15 | 355d? | finish no earlier than 2007-03-15 | C1 | 2840h | 2840h | IMSconf | Alcatel-Lucent | Keith Drage (drage@alcatel-lucent.com) | Rel-7 | Frederic |  | 24.147, 24.229 |  |  |  | IMSconf |  |  |
| 3986 | 1024 | Performance Characterization of VoIMS over HSDPA\EUL channels |  | 713d? | 2005-03-15 A | 2007-12-06 A | 100% | 2005-03-15 | 2007-12-06 | 713d? | finish no earlier than 2007-12-06 | S4 | 5704h | 5704h | VoIMS-PCVoIMS | Alcatel-Lucent | mcgowan@alcatel-lucent.com | Rel-7 | Paolo |  | 26.935 |  |  |  | VoIMS-PCVoIMS |  |  |
| 3987 | 1025 | **WLAN-UMTS Interworking Phase 2** |  | 371d? | 2004-01-05 A | 2005-06-07 A | 100% | 2004-01-05 | 2005-06-07 | 371d? |  | S1; S2 | 6856h | 6856h | WLAN2 | Telenor | frederic.paint@telenor.com | Rel-7 | Alain | WLAN | 33.234 (SP-36 SA3 CRs approved) |  |  |  | WLAN2, WLAN-SC |  |  |
| 3988 | 1025.1 | Stage 1 on Session Continuity |  | 115d? | 2004-01-05 A | 2004-06-11 A | 100% | 2004-01-05 | 2004-06-11 | 115d? | start no earlier than 2004-01-05 | S1 | 920h | 920h | WLAN2 |  |  | Rel-7 | Alain | WLAN | 22.234 |  |  |  |  | SP-24 |  |
| 3989 | 1025.2 | Stage 2 on Session Continuity: covered by SAE | milestone | 0d? | 2005-06-07 A | 2005-06-07 A | 100% | 2005-06-07 | 2005-06-07 | 0d? | finish no earlier than 2005-06-07 | S2 |  |  | WLAN2 |  |  | Rel-7 | Maurice | WLAN |  |  |  |  |  |  |  |
| 3990 | 1026 | **WLAN Interworking – Private Network access from WLAN 3GPP IP Access** |  | 252d? | 2005-10-10 A | 2006-09-26 A | 100% | 2005-10-10 | 2006-09-26 | 252d? |  | S2; C1; C3; C4 | 17704h | 17704h | WLANPNA | NEC | Toshiyuki Tamura (tamurato@aj.jp.nec.com) | Rel-7 | Maurice | WLAN |  |  |  |  | WLANPNA |  |  |
| 3991 | 1026.1 | WLAN-PNA - Stage 2 |  | 185d? | 2005-10-10 A | 2006-06-23 A | 100% | 2005-10-10 | 2006-06-23 | 185d? | start no earlier than 2005-10-10 | S2 | 1480h | 1480h | WLANPNA-st2 | NEC | Toshiyuki Tamura (tamurato@aj.jp.nec.com) | Rel-7 | Maurice | WLAN | 23.234, 33.234 |  |  |  | WLANPNA-st2 |  |  |
| 3992 | 1026.2 | **WLAN-PNA - Stage 3** |  | 170d? | 2006-02-01 A | 2006-09-26 A | 100% | 2006-02-01 | 2006-09-26 | 170d? |  | C1; C3; C4 | 8160h | 8160h | WLANPNA-st3 | NEC |  | Rel-7 | Frederic | WLAN |  |  |  |  | WLANPNA-st3 |  |  |
| 3993 | 1026.2.1 | CT1 aspets for WLAN-PNA |  | 170d? | 2006-02-01 A | 2006-09-26 A | 100% | 2006-02-01 | 2006-09-26 | 170d? | start no earlier than 2006-02-01 | C1 | 1360h | 1360h | WLANPNA-st3 | NEC |  | Rel-7 | Frederic | WLAN | 24.234 |  |  |  |  |  |  |
| 3994 | 1026.2.2 | CT3 aspets for WLAN-PNA |  | 170d? | 2006-02-01 A | 2006-09-26 A | 100% | 2006-02-01 | 2006-09-26 | 170d? | start no earlier than 2006-02-01 | C3 | 1360h | 1360h | WLANPNA-st3 | NEC |  | Rel-7 | Adrian | WLAN | 29.161 |  |  |  |  |  |  |
| 3995 | 1026.2.3 | Deleted - CT4 aspets for WLAN-PNA |  | 170d? | 2006-02-01 A | 2006-09-26 A | 100% | 2006-02-01 | 2006-09-26 | 170d? | start no earlier than 2006-02-01 | C4 | 1360h | 1360h | WLANPNA-st3 | NEC |  | Rel-7 | Kimmo | WLAN | 29.234 |  |  | CP-32 |  |  |  |
| 3996 | 1027 | **Enhancements to support QoS provisioning over 3GPP/WLAN Interworking** |  | 520d? | 2005-03-14 A | 2007-03-09 A | 100% | 2005-03-14 | 2007-03-09 | 520d? |  | S2; C4; C1 | 16680h | 16680h | WLANQOS | Samsung |  | Rel-7 | Maurice | WLAN |  |  |  |  | WLANQOS |  |  |
| 3997 | 1027.1 | Deleted - TR on support of QoS on WLAN |  | 232d? | 2005-03-14 A | 2006-01-31 A | 100% | 2005-03-14 | 2006-01-31 | 232d? | start no earlier than 2005-03-14 | S2 | 1856h | 1856h | WLANQOS | Samsung |  | Rel-7 | Maurice | WLAN | 23.836 |  |  | SP-32 |  |  |  |
| 3998 | 1027.2 | Stage 2 on support of QoS over 3GPP/WLAN interworking |  | 108d? | 2006-02-01 A | 2006-06-30 A | 100% | 2006-02-01 | 2006-06-30 | 108d? | start no earlier than 2006-02-01 | S2 | 864h | 864h | WLANQOS | Samsung |  | Rel-7 | Maurice | WLAN | 23.234 |  |  |  |  |  |  |
| 3999 | 1027.3 | Stage 3 CT4 on support of QoS over 3GPP/WLAN Interworking |  | 121d? | 2006-09-22 A | 2007-03-09 A | 100% | 2006-09-22 | 2007-03-09 | 121d? | finish no earlier than 2007-03-09 | C4 | 968h | 968h | WLANQOS | Huawei | zhang.peng@huawei.com | Rel-7 | Kimmo | WLAN | 29.234, 23.008 |  |  |  |  |  |  |
| 4000 | 1027.4 | Stage 3 CT1 on support of QoS over 3GPP/WLAN Interworking |  | 64d? | 2006-09-04 A | 2006-11-30 A | 100% | 2006-09-04 | 2006-11-30 | 64d? | finish no earlier than 2006-11-30 | C1 | 512h | 512h | WLANQOS | Huawei | zhang.peng@huawei.com | Rel-7 | Frederic | WLAN | 24.234 |  | TSG-34 |  |  |  |  |
| 4001 | 1028 | **Location Services enhancements** |  | 906d? | 2004-06-28 A | 2007-12-17 A | 100% | 2004-06-28 | 2007-12-17 | 906d? |  | S1; S2; GP; C4; R2 | 81525.6h | 81525.6h | LCS3 |  |  | Rel-7 | Alain |  |  |  |  |  | LCS3 |  |  |
| 4002 | 1028.1 | Stage 2 for LCS3 (including IMS emergency location aspects) |  | 446d? | 2004-12-31 A | 2006-09-15 A | 100% | 2004-12-31 | 2006-09-15 | 446d? | finish no earlier than 2006-09-15 | S2 | 3568h | 3568h | LCS3 | SiRF | brodilitz@sirf.com | Rel-7 | Maurice |  | 23.271 |  |  |  |  |  |  |
| 4003 | 1028.2 | LCS Enhancements related to Location-Based Services |  | 695d? | 2005-01-03 A | 2007-08-31 A | 100% | 2005-01-03 | 2007-08-31 | 695d? | finish no earlier than 2007-08-31 | GP | 5560h | 5560h | LCS3-LBS | SiRF | kjudge@sirf.com | Rel-7 | Paolo |  | 43.059, 44.031, 48.008, 49.031 |  |  |  | LCS3-LBS |  |  |
| 4004 | 1028.3 | CT4 aspects for LCS UEPos-LBS |  | 240d? | 2006-01-02 A | 2006-12-01 A | 100% | 2006-01-02 | 2006-12-01 | 240d? | finish no earlier than 2006-12-01 | C4 | 1920h | 1920h | LCS3-UEPos-LBS | SiRF | brodilitz@sirf.com | Rel-7 | Kimmo |  | 24.030, 24.080, 29.002 |  |  |  | LCS3-UEPos-LBS |  |  |
| 4005 | 1028.4 | UE positioning - Velocity |  | 394d? | 2005-03-15 A | 2006-09-15 A | 100% | 2005-03-15 | 2006-09-15 | 394d? | finish no earlier than 2006-09-15 | R2 | 3152h | 3152h | LCS3-UEPos-Velocity | SiRF | BRodilitz@SiRF.com | Rel-7 | Yong-Jun |  | 25.305, 25.331, 25.410, 25.413, 25.453 |  |  |  | LCS3-UEPos-Velocity |  | RP-060459 |
| 4006 | 1028.5 | Inclusion of Uplink TDOA UE positioning method in the UTRAN specifications |  | 849d? | 2004-09-15 A | 2007-12-17 A | 100% | 2004-09-15 | 2007-12-17 | 849d? | finish no earlier than 2007-12-17 | R2 | 6792h | 6792h | LCS3-UEPos-UTDOA | TruePosition | Robert Gross (rgross@polariswireless.com) | Rel-7 | Yong-Jun |  | 25.305, 25.453, new TS 25.111 |  |  |  | LCS3-UEPos-UTDOA |  | RP-070797 |

Notes:
- 3978: -
- 3979: -
- 3980: CP#54 completed
- 3981: Cancelled for Rel-7 and there is no corresponding Rel-8 WI
- 3982: Cancelled for Rel-7 and there is no corresponding Rel-8 WI
- 3983: -
- 3984: -
- 3985: CP#35 revised WID
- 3986: -
- 3987: Created at SP#27 because of WLAN items belonging to Rel-7. Acronym changed from "WLAN2, WLAN-SC"
- 3988: Acronym changed from "WLAN2, WLAN-SC"
- 3989: Acronym changed from "WLAN2, WLAN-SC"
- 3990: -
- 3991: Approved at SP#29
- 3992: Approved at CP#29
- 3993: Approved at CP#29
- 3994: Approved at CP#29
- 3995: CT4#31; no impacts identified, therefore completed. CP-32 stopped
- 3996: Moved from FS section Feb 06. SP-30 updated WID
- 3997: SP#32 stopped
- 3998: SP#30 updated WID
- 3999: CP#33 approved WID
- 4000: CP#33 approved WID
- 4001: -
- 4002: SP#27 approved WID
- 4003: -
- 4004: -
- 4005: -
- 4006: -

| ID | WBS | Task | Duration | Start | Finish | Complete | Baseline start | Baseline finish | Baseline duration | Constraint | Resources | Work | Actual work | Acronym | WI rapporteur name | WI rapporteur e-mail | Release | MCC resp | Special Focus Doc | Acronym_3GU_Export | TSG stopped | TSG approved | Status Report | PCG approved |
| --- | --- | --- | --- | --- | --- | --- | --- | --- | --- | --- | --- | --- | --- | --- | --- | --- | --- | --- | --- | --- | --- | --- | --- | --- |
| 4007 | 1028.6 | **LCS for 3GPP Interworking WLAN** | 700d? | 2004-06-28 A | 2007-03-02 A | 100% | 2004-06-28 | 2007-03-02 | 700d? |  | S1; S2 | 17501.6h | 17501.6h | LCS3-IWLAN | Telcordia | Mike Loushine | Rel-7 | Alain | WLAN | LCS3-IWLAN |  |  |  |  |
| 4008 | 1028.6.1 | FS on 3GPP system to WLAN Interworking with LCS | 512.7d? | 2004-06-28 A | 2006-06-30 A | 100% | 2004-06-28 | 2006-06-30 | 512.7d? | finish no earlier than 2005-09-29 | S1 | 4101.6h | 4101.6h | LCS3-IWLAN-FSs1 | Telcordia | Mike Loushine | Rel-7 | Alain |  | LCS3-IWLAN-FSs1 |  |  |  |  |
| 4009 | 1028.6.2 | Deleted - Study of work on an LCS architecture for I-WLAN. | 180d? | 2006-06-26 A | 2007-03-02 A | 100% | 2006-06-26 | 2007-03-02 | 180d? | finish no earlier than 2007-03-02 | S2 | 1440h | 1440h | LCS3-IWLAN-FSs2 | LG Electronics | dhshim@lge.com ; phede@lge.com | Rel-7 | Maurice |  | LCS3-IWLAN-FSs2 | SP-35 |  |  |  |
| 4010 | 1028.6.3 | Stage 2 for LCS architecture for I-WLAN | 95d? | 2006-10-23 A | 2007-03-02 A | 100% | 2006-10-23 | 2007-03-02 | 95d? | finish no earlier than 2007-03-02 | S2 | 760h | 760h | LCS3-IWLAN | LG Electronics | dhshim@lge.com ; phede@lge.com | Rel-7 | Maurice |  | LCS3-IWLAN |  | TSG-34 |  |  |
| 4011 | 1028.7 | Deleted - UE positioning Rel-7 | 849d? | 2004-09-15 A | 2007-12-17 A | 100% | 2004-09-15 | 2007-12-17 | 849d? |  | RP | 6792h | 6792h | LCS3-UEpos |  |  | Rel-7 | Yong-Jun |  | LCS3-UEpos | RP-38 |  |  |  |
| 4012 | 1029 | **MBMS Enhancements** | 625d? | 2005-07-11 A | 2007-11-30 A | 100% | 2005-07-11 | 2007-11-30 | 625d? |  | S1; R1; C3 | 20844.6h | 20844.6h | MBMSE | China Mobile | liuhongyfw@chinamobile.com | Rel-7 | Alain |  | MBMSE |  |  |  |  |
| 4013 | 1029.1 | Stage 1 of MBMSE | 109d? | 2005-07-11 A | 2005-12-08 A | 100% | 2005-07-11 | 2005-12-08 | 109d? | finish no earlier than 2005-12-08 | S1 | 872h | 872h | MBMSE | China Mobile | liuhongyfw@chinamobile.com | Rel-7 | Alain |  |  |  | TSG-34 |  |  |
| 4014 | 1029.2 | MBMS FDD Physical layer Enhancements | 117.29d? | 2006-12-15 A | 2007-06-04 A | 100% | 2006-12-15 | 2007-06-04 | 117.29d? | finish no earlier than 2007-06-04 | R1 | 938.32h | 938.32h | MBMSE-RANPhysFDD | Ericsson | Lars.Lindbom@ericsson.com | Rel-7 | Patrick |  | MBMSE-RANPhysFDD |  | TSG-34 | RP-070290 |  |
| 4015 | 1029.3 | MBMS TDD Physical layer Enhancements | 117.29d? | 2006-12-15 A | 2007-06-04 A | 100% | 2006-12-15 | 2007-06-04 | 117.29d? | finish no earlier than 2007-06-04 | R1 | 938.32h | 938.32h | MBMSE-RANPhysTDD | IPWireless | Nicholas Anderson | Rel-7 | Patrick |  | MBMSE-RANPhysTDD |  | TSG-34 | RP-070291 |  |
| 4016 | 1029.4 | MBMS Low Chip Rate TDD Physical Layer Enhancement | 127d? | 2007-03-16 A | 2007-09-10 A | 100% | 2007-03-16 | 2007-09-10 | 127d? | finish no earlier than 2007-09-10 | R1 | 1016h | 1016h | MBMSE-RANPhysLCRTDD | RITT | Lin Hui | Rel-7 | Patrick |  | MBMSE-RANPhysLCRTDD |  |  | RP-070292 |  |
| 4017 | 1029.5 | MBMS Mz interface | 260d? | 2006-12-04 A | 2007-11-30 A | 100% | 2006-12-04 | 2007-11-30 | 260d? | finish no earlier than 2007-05-11 | C3 | 2080h | 2080h | MBMSMz | Huawei | Deng Tingting (ttdeng@huawei.com) | Rel-7 | Adrian |  | MBMSMz |  | TSG-34 |  |  |
| 4018 | 1030 | **MBMS - UE Conformance Testing** | 657d? | 2007-06-01 A | 2009-12-04 A | 100% | 2007-06-01 | 2009-12-04 | 657d? |  | R5 | 13848h | 13848h | MBMSE_UEConTest |  |  | Rel-7 | Ingbert |  | MBMSE_UEConTest |  | SP-40 |  | PCG-21 |
| 4019 | 1030.1 | Conformance Test Aspects – MBMS TDD Physical layer Enhancements – MBSFN for HCR and VHCR TDD | 336d? | 2007-06-01 A | 2008-09-12 A | 100% | 2007-06-01 | 2008-09-12 | 336d? | start no earlier than 2007-06-01 | R5 | 2688h | 2688h | MBMSE-RANPhysTDD_UEConTest | IPWireless | tspeight@ipwireless.com | Rel-7 | Ingbert |  | MBMSE-RANPhysTDD_UEConTest |  |  | RP-080541 |  |
| 4020 | 1030.2 | Conformance Test Aspects – MBMS LCR TDD Physical Layer Enhancement | 342d? | 2008-05-30 A | 2009-09-18 A | 100% | 2008-05-30 | 2009-09-18 | 342d? | finish no earlier than 2009-09-18 | R5 | 2728h | 2728h | MBMSE-RANPhysLCRTDD_UEConTest | CATT | chenxiaozhong@datangmobile.cn | Rel-7 | Ingbert |  | MBMSE-RANPhysLCRTDD_UEConTest |  | RP-40 | RP-090715 | PCG-21 |
| 4021 | 1030.3 | Conformance Test Aspects – MBSFN for FDD | 397d? | 2008-05-30 A | 2009-12-04 A | 100% | 2008-05-30 | 2009-12-04 | 397d? | finish no earlier than 2009-12-04 | R5 | 3176h | 3176h | MBMSE-UEConTest_RANPhysFDD | Huawei | Xiang Li (trica_li@huawei.com) | Rel-7 | Ingbert |  | MBMSE-UEConTest_RANPhysFDD |  | RP-40 | RP-091214 | PCG-21 |
| 4022 | 1031 | MBMS User Service Extensions | 392d? | 2005-12-07 A | 2007-06-07 A | 100% | 2005-12-07 | 2007-06-07 | 392d? | finish no earlier than 2007-06-07 | S4 | 3136h | 3136h | MBMSUSE | Ericsson | Thorsten.Lohmar@ericsson.com | Rel-7 | Paolo |  | MBMSUSE |  |  |  |  |
| 4023 | 1032 | **Advanced Global Navigation Satellite System (AGNSS) concept** | 830d? | 2004-06-28 A | 2007-08-31 A | 100% | 2004-06-28 | 2007-08-31 | 830d? |  | S1; S2; GP; R2 | 36129.6h | 36129.6h | LCS3-AGNSS | Alcatel | Michel.monnerat@thalesaleniaspace.com | Rel-7 | Alain |  | LCS3-AGNSS |  |  |  |  |
| 4024 | 1032.1 | Stage 1/2 for Towards AGNSS Concept | 1d? | 2007-02-16 A | 2007-02-16 A | 100% | 2007-02-16 | 2007-02-16 | 1d? | start no earlier than 2007-02-16 | S1; S2 | 16h | 16h | AGNSS | Alcatel | richard.couty@space.alcatel.fr | Rel-7 | Alain |  | AGNSS |  |  |  |  |
| 4025 | 1032.2 | Towards AGNSS Concept | 811.2d? | 2004-06-28 A | 2007-08-31 A | 100% | 2004-06-28 | 2007-08-31 | 811.2d? | finish no earlier than 2007-08-31 | GP | 6489.6h | 6489.6h | AGNSS-GP | Alcatel | richard.couty@space.alcatel.fr | Rel-7 | Paolo |  | AGNSS-GP |  |  |  |  |
| 4026 | 1032.3 | Global Navigation Satellite System (GNSS) in UTRAN | 383d? | 2005-12-15 A | 2007-06-04 A | 100% | 2005-12-15 | 2007-06-04 | 383d? | finish no earlier than 2007-06-04 | R2 | 3064h | 3064h | LCS3-GNSS-UTRAN | France Telecom | alain.abinakhoul@francetelecom.com | Rel-7 | Yong-Jun |  | LCS3-GNSS-UTRAN |  |  | RP-070482 |  |
| 4027 | 1033 | A-GPS Minimum Performance | 351d? | 2006-04-28 A | 2007-08-31 A | 100% | 2006-04-28 | 2007-08-31 | 351d? | finish no earlier than 2007-08-31 | G1; G3 | 5616h | 5616h | GAGR | Spirent | richard.catmur@spirentcom.com | Rel-7 | Paolo |  | GAGR |  |  |  |  |
| 4028 | 1034 | **Unstructured Supplementary Service Data (USSD) message delivery and transfer to USIM** | 376d? | 2004-03-05 A | 2005-08-12 A | 100% | 2004-03-05 | 2005-08-12 | 376d? |  | S1; C6 | 8778.4h | 8778.4h | USSD-USIM | Axalto | Christophe Dubois (cdubois@axalto.com) | Rel-7 | Alain |  | USSD-USIM |  |  |  |  |
| 4029 | 1034.1 | Stage 1 for USSD message delivery and transfer to USIM | 152d? | 2004-03-18 A | 2004-10-15 A | 100% | 2004-03-18 | 2004-10-15 | 152d? | start no earlier than 2004-03-18 | S1 | 1216h | 1216h | USSD-USIM | Axalto | Christophe Dubois (cdubois@axalto.com) | Rel-7 | Alain |  |  |  |  |  |  |
| 4030 | 1034.2 | Alignment with requirements regarding USSD usage | 193.3d? | 2004-03-05 A | 2005-08-12 A | 100% | 2004-03-05 | 2005-08-12 | 193.3d? | finish no earlier than 2005-08-12 | C6 | 1546.4h | 1546.4h | USSD-USIM | Axalto | Christophe Dubois (cdubois@axalto.com) | Rel-7 | Xavier |  |  |  |  |  |  |

Notes:
- 4007: -
- 4008: - / Impacted TSs and TRs: new TR 22.935
- 4009: SP#41 TR withdrawn. All work transferred to specs / Impacted TSs and TRs: 23.837
- 4010: - / Impacted TSs and TRs: 23.234, 23.271, 23.167
- 4011: -
- 4012: -
- 4013: - / Impacted TSs and TRs: 22.146, 22.246, 22.228
- 4014: - / Impacted TSs and TRs: 25.211, 25.212, 25.213, 25.101, 25.104, 25.331, 25.433, 25.346, 25.306
- 4015: - / Impacted TSs and TRs: 25.346, 25.221, 25.222, 25.223, 25.224, 25.306, 25.331, 25.402, 25.433, 25.102, 25.105, 25.123
- 4016: - / Impacted TSs and TRs: 25.346, 25.221, 25.222, 25.223, 25.224, 25.306, 25.331, 25.402, 25.433, 25.102, 25.105, 25.123
- 4017: - / Impacted TSs and TRs: 29.061
- 4018: Linked to Rel-7 Feature UID_31084 (MBMSE)
- 4019: RP#41 completed / Impacted TSs and TRs: 34.108, 34.122, 34.123-1/2/3
- 4020: RP#45 completed / Impacted TSs and TRs: 34.108, 34.123-1
- 4021: RP#46 completed / Impacted TSs and TRs: 34.108, 34.109, 34.121-1, 34.121-2, 34.123-1, 34.123-2, 34.123-3
- 4022: - / Impacted TSs and TRs: 26.346, 26.946
- 4023: -
- 4024: - / Impacted TSs and TRs: 22.071, 23.271
- 4025: GP#36 completed / Impacted TSs and TRs: 43.030, 43.059, 44.031, 44.035, 44.071, 48.008, 48.018, 48.031, 49.031
- 4026: - / Impacted TSs and TRs: 25.305, 25.331, 25.306, 25.413, 25.423, 25.433, 25.453, 25.302, 25.215, 25.401, 25.402, 25.450, 25.452
- 4027: - / Impacted TSs and TRs: 45.005, 51.010
- 4028: -
- 4029: - / Impacted TSs and TRs: 22.090
- 4030: - / Impacted TSs and TRs: 31.111, 31.115, 31.130

| ID | WBS | Task | Type | Duration | Start | Finish | Complete | Baseline start | Baseline finish | Baseline duration | Constraint | Resources | Work | Actual work | Acronym | WI rapporteur name | WI rapporteur e-mail | Release | MCC resp | Acronym_3GU_Export | Impacted TSs and TRs | TSG stopped |
| --- | --- | --- | --- | --- | --- | --- | --- | --- | --- | --- | --- | --- | --- | --- | --- | --- | --- | --- | --- | --- | --- | --- |
| 4031 | 1035 | **Combinational Services** |  | 296d? | 2005-01-17 A | 2006-03-06 A | 100% | 2005-01-17 | 2006-03-06 | 296d? |  | S1; S2; C1; S4 | 14648h | 14648h | CSICS | TeliaSonera | Robert.Frank@teliasonera.com | Rel-7 | Alain | CSICS |  |  |
| 4032 | 1035.1 | Stage 1 for CSICS |  | 104d? | 2005-01-17 A | 2005-06-09 A | 100% | 2005-01-17 | 2005-06-09 | 104d? | start no earlier than 2005-01-17 | S1 | 832h | 832h | CSICS | TeliaSonera | Robert.Frank@teliasonera.com | Rel-7 | Alain |  | 22.279 |  |
| 4033 | 1035.2 | Stage 2 for CSICS |  | 130d? | 2005-01-17 A | 2005-07-15 A | 100% | 2005-01-17 | 2005-07-15 | 130d? | start no earlier than 2005-01-17 | S2 | 1040h | 1040h | CSICS | TeliaSonera | Robert.Frank@teliasonera.com | Rel-7 | Maurice |  | 23.279 |  |
| 4034 | 1035.3 | Stage 3 for CSICS CN aspects |  | 221d? | 2005-05-02 A | 2006-03-06 A | 100% | 2005-05-02 | 2006-03-06 | 221d? | finish no earlier than 2006-03-06 | C1 | 1768h | 1768h | CSICS | Vodafone | peter.dawes@vodafone.com | Rel-7 | Frederic |  | 24.879, 24.279, 24.229, 24.008 |  |
| 4035 | 1035.4 | Stage 3 for codec aspects |  | 192d? | 2005-03-15 A | 2005-12-07 A | 100% | 2005-03-15 | 2005-12-07 | 192d? | finish no earlier than 2005-12-07 | S4 | 1536h | 1536h | CSICS-Codec | Ericsson | Per.Frojdh@ericsson.com | Rel-7 | Paolo | CSICS-Codec | 26.141, 26.235 |  |
| 4036 | 1036 | **CAMEL Trunk Triggers** |  | 251d? | 2004-12-17 A | 2005-12-05 A | 100% | 2004-12-17 | 2005-12-05 | 251d? |  | S1; C4 | 8032h | 8032h | TTCAMEL | Nortel | Amar Deol (deola@nortelnetworks.com) | Rel-7 | Alain | TTCAMEL |  |  |
| 4037 | 1036.1 | Stage 1 for CAMEL Trunk Triggers |  | 251d? | 2004-12-17 A | 2005-12-05 A | 100% | 2004-12-17 | 2005-12-05 | 251d? |  | S1 | 2008h | 2008h | TTCAMEL | Nortel | Amar Deol (deola@nortelnetworks.com) | Rel-7 | Alain |  | 22.078 |  |
| 4038 | 1036.2 | CAMEL Trunk Originated Trigger Detection Points |  | 251d? | 2004-12-17 A | 2005-12-05 A | 100% | 2004-12-17 | 2005-12-05 | 251d? | start no earlier than 2004-12-17 | C4 | 2008h | 2008h | CamelR7 | Nortel | David Hutton (dhutton@nortel.com) | Rel-7 | Kimmo | CamelR7 |  |  |
| 4039 | 1037 | **IMS Service Brokering enhancements** |  | 69d? | 2005-12-07 A | 2006-03-13 A | 100% | 2005-12-07 | 2006-03-13 | 69d? |  | S1 | 1104h | 1104h | ISB | Telcordia | jbakker@telcordia.com | Rel-7 | Alain | ISB | 22.228 |  |
| 4040 | 1037.1 | Stage 1 for ISB |  | 69d? | 2005-12-07 A | 2006-03-13 A | 100% | 2005-12-07 | 2006-03-13 | 69d? | finish no earlier than 2006-03-13 | S1 | 552h | 552h | ISB-s1 | Telcordia | jbakker@telcordia.com | Rel-7 | Alain | ISB-s1 | 22.228 |  |
| 4041 | 1038 | **Enhancements of VGCS for public authority officials** |  | 731d? | 2004-08-27 A | 2007-06-15 A | 100% | 2004-08-27 | 2007-06-15 | 731d? |  | S1; C1; C4; G2 | 49312h | 49312h | EVGCS |  |  | Rel-7 | Alain | EVGCS | 43.068, 44.068, 24.008, 29.002 |  |
| 4042 | 1038.1 | Stage 1 for Enhancements of VGCS for public authority officials | milestone | 0d? | 2004-08-27 A | 2004-08-27 A | 100% | 2004-08-27 | 2004-08-27 | 0d? | finish no earlier than 2004-08-27 | S1 |  |  | EVGCS | Siemens | joerg.swetina@neclab.eu | Rel-7 | Alain |  | 42.068, 43.068 |  |
| 4043 | 1038.2 | **Architecture and protocol aspects** |  | 731d? | 2004-08-27 A | 2007-06-15 A | 100% | 2004-08-27 | 2007-06-15 | 731d? |  | C1; C4 | 20752h | 20752h | EVGCS | Siemens | robert.zaus@nsn.com | Rel-7 | Frederic |  | 43.068, 44.068 |  |
| 4044 | 1038.2.1 | CT1 aspects of EVGCS |  | 731d? | 2004-08-27 A | 2007-06-15 A | 100% | 2004-08-27 | 2007-06-15 | 731d? | finish no earlier than 2006-09-15 | C1 | 5848h | 5848h | EVGCS | Siemens | robert.zaus@nsn.com | Rel-7 | Frederic |  | 43.068, 44.068, 24.008 |  |
| 4045 | 1038.2.2 | CT4 aspects of EVGCS |  | 401d? | 2004-08-27 A | 2006-03-10 A | 100% | 2004-08-27 | 2006-03-10 | 401d? | finish no earlier than 2006-03-10 | C4 | 3208h | 3208h | EVGCS | Siemens | robert.zaus@nsn.com | Rel-7 | Kimmo |  | 29.002 |  |
| 4046 | 1038.3 | GERAN2 aspects of EVGCS |  | 646d? | 2004-08-27 A | 2007-02-16 A | 100% | 2004-08-27 | 2007-02-16 | 646d? | finish no earlier than 2007-02-16 | G2 | 5168h | 5168h | EVGCS | Siemens | kenneth.isaacs@roke.co.uk | Rel-7 | Gert |  |  |  |
| 4047 | 1039 | **Improvements of VGCS for parallel use of services** |  | 523d? | 2005-03-15 A | 2007-03-15 A | 100% | 2005-03-15 | 2007-03-15 | 523d? |  | S1 | 12230.2h | 12230.2h | IVGCS |  |  | Rel-7 | Alain | IVGCS |  |  |
| 4048 | 1039.1 | Service Requirements for VGCS improvements |  | 62d? | 2005-03-15 A | 2005-06-08 A | 100% | 2005-03-15 | 2005-06-08 | 62d? | finish no earlier than 2005-06-08 | S1 | 496h | 496h | IVGCS | T-Mobile | kurt.bischinger@t-mobile.at | Rel-7 | Alain |  | 42.068 |  |
| 4049 | 1039.2 | Stage 2 modifications for VGCS improvements |  | 335d? | 2005-12-01 A | 2007-03-14 A | 100% | 2005-12-01 | 2007-03-14 | 335d? | start no earlier than 2005-12-01 | C1 | 2680h | 2680h | IVGCS | T-Mobile | kurt.bischinger@t-mobile.at | Rel-7 | Frederic |  | 43.068 |  |
| 4050 | 1039.3 | **Protocol aspects** |  | 336d? | 2005-12-01 A | 2007-03-15 A | 100% | 2005-12-01 | 2007-03-15 | 336d? |  | C1 | 5376h | 5376h | IVGCS | T-Mobile | Dieter Jacobsohn | Rel-7 | Frederic |  | 44.068 |  |
| 4051 | 1039.3.1 | CT1 aspects of IVGCS |  | 336d? | 2005-12-01 A | 2007-03-15 A | 100% | 2005-12-01 | 2007-03-15 | 336d? | finish no earlier than 2007-03-15 | C1 | 2688h | 2688h | IVGCS | T-Mobile |  | Rel-7 | Frederic |  | 43.068, 44.068 |  |
| 4052 | 1039.3.2 | Deleted - CT4 aspects of IVGCS | milestone | 0d? | 2007-03-09 A | 2007-03-09 A | 100% | 2007-03-09 | 2007-03-09 | 0d? | finish no earlier than 2007-03-09 | C4 |  |  | IVGCS-St3-c4 | T-mobile |  | Rel-7 | Kimmo | IVGCS-St3-c4 | 29.002 | CP-35 |
| 4053 | 1040 | **Open Service Access (OSA) Rel-7** |  | 584d? | 2005-03-15 A | 2007-06-08 A | 100% | 2005-03-15 | 2007-06-08 | 584d? |  | S1; C5 | 29776h | 29776h | OSA7 | AePONA | eamonn.murray@aepona.com | Rel-7 | Alain | OSA7 |  |  |
| 4054 | 1040.1 | **OSA Service Broker** |  | 449d? | 2005-03-15 A | 2006-12-01 A | 100% | 2005-03-15 | 2006-12-01 | 449d? |  | S1; C5 | 10176h | 10176h | OSA7-SB | AePONA | eamonn.murray@aepona.com | Rel-7 | Alain | OSA7-SB |  |  |
| 4055 | 1040.1.1 | Service Requirements for OSA Service Broker |  | 62d? | 2005-03-15 A | 2005-06-08 A | 100% | 2005-03-15 | 2005-06-08 | 62d? | finish no earlier than 2005-06-08 | S1 | 496h | 496h | OSA7 | AePONA | eamonn.murray@aepona.com | Rel-7 | Alain |  | 22.127 |  |
| 4056 | 1040.1.2 | Stage 2 OSA API Service Brokering |  | 156d? | 2006-04-28 A | 2006-12-01 A | 100% | 2006-04-28 | 2006-12-01 | 156d? |  | C5 | 1248h | 1248h | OSA7 | AePONA | damian.oneill@aepona.com | Rel-7 | Kimmo |  | 23.198 |  |
| 4057 | 1040.1.3 | Stage 3 OSA API Service Brokering |  | 156d? | 2006-04-28 A | 2006-12-01 A | 100% | 2006-04-28 | 2006-12-01 | 156d? | finish no earlier than 2006-12-01 | C5 | 1248h | 1248h | OSA7 | AePONA | damian.oneill@aepona.com | Rel-7 | Kimmo |  | 29.198-16 |  |

Notes:
- 4031: -
- 4032: -
- 4033: -
- 4034: -
- 4035: -
- 4036: -
- 4037: -
- 4038: -
- 4039: No CR submitted in rel-8 (according to CR database).
- 4040: No Rel-8 changes
- 4041: Moved from Rel-6 UID_50563 Enhancements of VGCS in public networks for communication of public authority officials
- 4042: Voice Group Call Service
- 4043: -
- 4044: -
- 4045: -
- 4046: -
- 4047: Voice Group Call Service
- 4048: -
- 4049: -
- 4050: Previous name (before CT32) was Architecture and protocol aspects
- 4051: -
- 4052: CT4#33 stage 2 solution is still open. ...
- 4053: -
- 4054: -
- 4055: -
- 4056: -
- 4057: -

| ID | WBS | Task | Type | Duration | Start | Finish | Complete | Baseline start | Baseline finish | Baseline duration | Constraint | Resources | Work | Actual work | Acronym | Impacted TSs and TRs | WI rapporteur name | WI rapporteur e-mail | Release | MCC resp | TSG approved | Acronym_3GU_Export | TSG stopped | Status Report |
| --- | --- | --- | --- | --- | --- | --- | --- | --- | --- | --- | --- | --- | --- | --- | --- | --- | --- | --- | --- | --- | --- | --- | --- | --- |
| 4058 | 1040.2 | **Rel-7 OSA Stage 2/3 enhancements** |  | 291d? | 2006-04-28 A | 2007-06-08 A | 100% | 2006-04-28 | 2007-06-08 | 291d? |  | C5 | 10256h | 10256h | OSA7 | 29.198/9, 23.198 | AePONA | damian.oneill@aepona.com | Rel-7 | Kimmo |  |  |  |  |
| 4059 | 1040.2.1 | Parlay X Message Broadcast Web Service |  | 156d? | 2006-04-28 A | 2006-12-01 A | 100% | 2006-04-28 | 2006-12-01 | 156d? | finish no earlier than 2006-12-01 | C5 | 1248h | 1248h | OSA7 | 29.199-15, 23.198 | ETRI |  | Rel-7 | Kimmo |  |  |  |  |
| 4060 | 1040.2.2 | Parlay X Geocoding Web Service |  | 156d? | 2006-04-28 A | 2006-12-01 A | 100% | 2006-04-28 | 2006-12-01 | 156d? | finish no earlier than 2006-12-01 | C5 | 1248h | 1248h | OSA7 | 29.199-16, 23.198 | ETRI |  | Rel-7 | Kimmo |  |  |  |  |
| 4061 | 1040.2.3 | Parlay X Application driven QoS Web Service |  | 226d? | 2006-04-28 A | 2007-03-09 A | 100% | 2006-04-28 | 2007-03-09 | 226d? | finish no earlier than 2007-03-09 | C5 | 1808h | 1808h | OSA7 | 29.199-17, 23.198 | BT |  | Rel-7 | Kimmo |  |  |  |  |
| 4062 | 1040.2.4 | Parlay-X Device Capabilities and Configuration |  | 162d? | 2006-10-26 A | 2007-06-08 A | 100% | 2006-10-26 | 2007-06-08 | 162d? | finish no earlier than 2007-06-09 | C5 | 1296h | 1296h | OSA7 | 29.199-18, 23.198 | Telenor |  | Rel-7 | Kimmo | TSG-34 |  |  |  |
| 4063 | 1040.2.5 | Parlay-X Multimedia Streaming Session Management Web Service |  | 97d? | 2006-10-26 A | 2007-03-09 A | 100% | 2006-10-26 | 2007-03-09 | 97d? | start no earlier than 2006-10-26 | C5 | 776h | 776h | OSA7 | 29.199-19, 23.198 | Telenor |  | Rel-7 | Kimmo | TSG-34 |  |  |  |
| 4064 | 1040.2.6 | Parlay-X Multimedia Multicast Control Web Service |  | 97d? | 2006-10-26 A | 2007-03-09 A | 100% | 2006-10-26 | 2007-03-09 | 97d? | start no earlier than 2006-10-26 | C5 | 776h | 776h | OSA7 | 29.199-20, 23.198 | ETRI |  | Rel-7 | Kimmo | TSG-34 |  |  |  |
| 4065 | 1040.2.7 | OSA API Conference Call Control SCF |  | 97d? | 2006-10-26 A | 2007-03-09 A | 100% | 2006-10-26 | 2007-03-09 | 97d? | start no earlier than 2006-10-26 | C5 | 776h | 776h | OSA7 | 29.198-04-5, 23.198 | Ericsson |  | Rel-7 | Kimmo | TSG-34 |  |  |  |
| 4066 | 1041 | **Selective Disabling of UE Capabilities** |  | 624.36d? | 2005-01-24 A | 2007-06-15 A | 100% | 2005-01-24 | 2007-06-15 | 624.36d? |  | S1; S2; C1 | 22341.5h | 22341.5h | SDoUE |  | Motorola |  | Rel-7 | Alain |  | SDoUE |  |  |
| 4067 | 1041.1 | Stage 1 of SDoUE |  | 393.6d? | 2005-01-24 A | 2006-12-08 A | 100% | 2005-01-24 | 2006-12-08 | 393.6d? | finish no earlier than 2006-12-08 | S1 | 3148.8h | 3148.8h | SDoUE-CR | 22.011 | Motorola |  | Rel-7 | Alain |  | SDoUE-CR |  |  |
| 4068 | 1041.2 | Deleted - TR on different possible architectures |  | 195d? | 2005-03-21 A | 2005-12-16 A | 100% | 2005-03-21 | 2005-12-16 | 195d? | finish no earlier than 2005-12-16 | S2 | 1560h | 1560h | SDoUE-FS | 23.805 abandonned at SP-30; descendant C1 24.305 | Vodafone | Gavin.Wong@vodafone.com | Rel-7 | Maurice |  | SDoUE-FS | SP-30 |  |
| 4069 | 1041.3 | Stage 3 of SDoUE |  | 331d? | 2006-03-10 A | 2007-06-15 A | 100% | 2006-03-10 | 2007-06-15 | 331d? | finish no earlier than 2007-06-15 | C1 | 2648h | 2648h | SDoUE | 24.305 | Ericsson | christian.herrero@ericsson.com | Rel-7 | Frederic |  |  |  |  |
| 4070 | 1042 | **Network selection enhancements (NSP)** |  | 328d? | 2006-03-15 A | 2007-06-15 A | 100% | 2006-03-15 | 2007-06-15 | 328d? |  | S1 | 6320h | 6320h | NSP |  | O2 | chris.friel@O2.com | Rel-7 | Alain |  | NSP |  |  |
| 4071 | 1042.1 | Stage 1 of NSP |  | 191d? | 2006-03-15 A | 2006-12-06 A | 100% | 2006-03-15 | 2006-12-06 | 191d? | start no earlier than 2006-03-15 | S1 | 1528h | 1528h | NSP-TS | 22.101, 22.011, 23.122, 24.008, 25.304, 31.102, 45.008 | O2 | chris.friel@O2.com | Rel-7 | Alain |  | NSP-TS |  |  |
| 4072 | 1042.2 | Procedural aspects of NSP |  | 271d? | 2006-06-02 A | 2007-06-15 A | 100% | 2006-06-02 | 2007-06-15 | 271d? | finish no earlier than 2007-06-15 | C1 | 2168h | 2168h | NSP-CR | 23.122, 24.008, 31.102 | Motorola | Andrew Howell | Rel-7 | Frederic |  | NSP-CR |  |  |
| 4073 | 1043 | Network selection enhancements (NSP) - UE Conformance Testing |  | 396d? | 2007-06-01 A | 2008-12-05 A | 100% | 2007-06-01 | 2008-12-05 | 396d? | finish no earlier than 2008-12-05 | R5 | 3168h | 3168h | NSP-CR_UEConTest | 34.108, 34.123-1, 34.123-2, 34.123-3 | Nokia | jarkko.hellsten@nokia.com | Rel-7 | Ingbert |  | NSP-CR_UEConTest |  | RP-080819 |
| 4074 | 1044 | **Access Class Barring and Overload Protection** |  | 650d? | 2004-03-15 A | 2006-09-08 A | 100% | 2004-03-15 | 2006-09-08 | 650d? |  | S2; C1 | 13968h | 13968h | ACBOP | 23.898 | Vodafone | chris.pudney@vodafone.com | Rel-7 | Maurice |  | ACBOP |  |  |
| 4075 | 1044.1 | TR on Stage 2 |  | 274d? | 2004-03-15 A | 2005-03-31 A | 100% | 2004-03-15 | 2005-03-31 | 274d? | finish no earlier than 2005-03-31 | S2 | 2192h | 2192h | ACBOP | 23.898 | NTT DoCoMo | Jean-Jacques Davidian (davidian@docomo.fr) | Rel-7 | Maurice |  |  |  |  |
| 4076 | 1044.2 | Stage 3 CN aspects of ACBOP |  | 172d? | 2005-06-06 A | 2006-01-31 A | 100% | 2005-06-06 | 2006-01-31 | 172d? | start no earlier than 2005-06-06 | C1 | 1376h | 1376h | ACBOP | 24.008 |  |  | Rel-7 | Frederic |  |  |  |  |
| 4077 | 1044.3 | Deleted - Potential impact on Iu interface Overload functionality | milestone | 0d? | 2004-03-15 A | 2004-03-15 A | 100% | 2004-03-15 | 2004-03-15 | 0d? | finish no earlier than 2004-03-15 | RP |  |  | ACBOP | 25.413 |  |  | Rel-7 | Issam |  |  | RP-25 |  |
| 4078 | 1044.4 | Deleted - Extra ACBOP information in RAN | milestone | 0d? | 2004-03-15 A | 2004-03-15 A | 100% | 2004-03-15 | 2004-03-15 | 0d? | finish no earlier than 2004-03-15 | RP |  |  | ACBOP | 25.331 |  |  | Rel-7 | Issam |  |  | RP-25 |  |
| 4079 | 1044.5 | Deleted - Extra ACBOP information in GERAN | milestone | 0d? | 2006-09-08 A | 2006-09-08 A | 100% | 2006-09-08 | 2006-09-08 | 0d? | start no earlier than 2006-09-08 | GP |  |  | ACBOP | 44.018 |  |  | Rel-7 | Paolo |  |  | RP-33 |  |
| 4080 | 1045 | **System enhancements for Fixed Broadband access to IMS** |  | 2117d? | 2003-11-05 A | 2011-12-09 A | 100% | 2003-11-05 | 2011-12-09 | 2117d? |  | S2; S3; S5; C1; C3; C4; IETF | 369944h | 369944h | FBI |  |  |  | Rel-7 | Maurice |  | FBI |  |  |
| 4081 | 1045.1 | **TISPAN Rel 1 related aspects** |  | 2117d? | 2003-11-05 A | 2011-12-09 A | 100% | 2003-11-05 | 2011-12-09 | 2117d? |  | S2; S3; C1; C3; C4; IETF | 239320h | 239320h | FBI-TIS1 |  |  |  | Rel-7 | Maurice |  | FBI-TIS1 |  |  |
| 4082 | 1045.1.1 | Stage 2 of FBI for TISPAN R1 |  | 365d? | 2004-10-14 A | 2006-03-08 A | 100% | 2004-10-14 | 2006-03-08 | 365d? | start no earlier than 2004-10-14 | S2 | 2920h | 2920h |  |  |  |  | Rel-7 | Maurice |  |  |  |  |

Notes:
- 4058: CP#34 updated WID CP-060607=>CP-070200
- 4059: -
- 4060: -
- 4061: -
- 4062: -
- 4063: -
- 4064: -
- 4065: -
- 4066: Moved from FS section Feb 06
- 4067: Moved from FS section Feb 06
- 4068: Moved from FS section Feb 06. Abandoned at SP-30
- 4069: -
- 4070: -
- 4071: -
- 4072: -
- 4073: RP#42 completed. Testing for Feature UID_7041 (NSP-CR)
- 4074: -
- 4075: -
- 4076: -
- 4077: -
- 4078: -
- 4079: -
- 4080: -
- 4081: -
- 4082: -

| ID | WBS | Task | Duration | Start | Finish | Complete | Baseline start | Baseline finish | Baseline duration | Constraint | Resources | Work | Actual work | WI rapporteur name | WI rapporteur e-mail | Release | MCC resp | PCG approved | TSG approved | Acronym | Acronym_3GU_Export | Special Focus Doc | TSG stopped |
| --- | --- | --- | --- | --- | --- | --- | --- | --- | --- | --- | --- | --- | --- | --- | --- | --- | --- | --- | --- | --- | --- | --- | --- |
| 4083 | 1045.1.2 | **Protocol impact of FBI for TISPAN R1** | 2117d? | 2003-11-05 A | 2011-12-09 A | 100% | 2003-11-05 | 2011-12-09 | 2117d? |  | S3; C1; C3; C4; IETF | 133840h | 133840h | Siemens | peter.leis@nsn.com | Rel-7 | Frederic |  |  |  |  |  |  |
| 4084 | 1045.1.2.1 | (IETF) CT aspects of FBI for TISPAN R1 | 2117d? | 2003-11-05 A | 2011-12-09 A | 100% | 2003-11-05 | 2011-12-09 | 2117d? | start no earlier than 2003-11-05 | C1-IETF; C3-IETF | 33872h | 33872h | Roland Jesske |  | Rel-7 | Frederic | PCG-27 | CP-52 |  |  |  |  |
| 4085 | 1045.1.2.2 | CT1 aspects of FBI for TISPAN R1 | 802d? | 2003-11-05 A | 2006-11-30 A | 100% | 2003-11-05 | 2006-11-30 | 802d? | finish no earlier than 2006-11-30 | C1 | 6416h | 6416h | Siemens | peter.leis@nsn.com | Rel-7 | Frederic |  |  |  |  |  |  |
| 4086 | 1045.1.2.3 | CT3 aspects of FBI for TISPAN R1 | 808d? | 2003-11-05 A | 2006-12-08 A | 100% | 2003-11-05 | 2006-12-08 | 808d? | finish no earlier than 2006-12-08 | C3 | 6464h | 6464h | Siemens | peter.leis@nsn.com | Rel-7 | Adrian |  |  |  |  |  |  |
| 4087 | 1045.1.2.4 | CT4 aspects of FBI for TISPAN R1 | 301d? | 2006-01-13 A | 2007-03-09 A | 100% | 2006-01-13 | 2007-03-09 | 301d? | finish no earlier than 2007-03-09 | C4 | 2408h | 2408h | Siemens | peter.leis@nsn.com | Rel-7 | Kimmo |  |  | FBI-TIS1-st3-c4 | FBI-TIS1-st3-c4 |  |  |
| 4088 | 1045.1.3 | Security Enhancements for FBI | 118d? | 2005-06-28 A | 2005-12-08 A | 100% | 2005-06-28 | 2005-12-08 | 118d? | start no earlier than 2005-06-28 | S3 | 944h | 944h | Ericsson | Bengt.Sahlin@ericsson.com | Rel-7 | Mirko |  |  | FBI-ISE | FBI-ISE |  |  |
| 4089 | 1045.2 | **PacketCable Related aspects** | 291d? | 2006-02-01 A | 2007-03-14 A | 100% | 2006-02-01 | 2007-03-14 | 291d? |  | S2; S5; C1 | 12072h | 12072h | CableLabs | Bernie McKibben (b.mckibben@cablelabs.com) | Rel-7 | Maurice |  |  | FBI-PCBL | FBI-PCBL |  |  |
| 4090 | 1045.2.1 | Stage 1,2 of FBI for PacketCable | 228d? | 2006-02-01 A | 2006-12-15 A | 100% | 2006-02-01 | 2006-12-15 | 228d? | finish no earlier than 2006-12-15 | S2 | 1824h | 1824h | CableLabs | Bernie McKibben (b.mckibben@cablelabs.com) | Rel-7 | Maurice |  |  |  |  |  |  |
| 4091 | 1045.2.2 | Protocol impact of FBI for PacketCable | 228d? | 2006-05-01 A | 2007-03-14 A | 100% | 2006-05-01 | 2007-03-14 | 228d? | finish no earlier than 2007-03-15 | C1 | 1824h | 1824h |  |  | Rel-7 | Frederic |  |  |  |  |  |  |
| 4092 | 1045.2.3 | SA5 Charging aspects of FBI for PacketCable | 180d? | 2006-03-31 A | 2006-12-07 A | 100% | 2006-03-31 | 2006-12-07 | 180d? | finish no earlier than 2006-12-07 | S5 | 1440h | 1440h | CableLabs | Bernie McKibben (b.mckibben@cablelabs.com) | Rel-7 | Mirko |  |  | FBI-PCBL-CH | FBI-PCBL-CH |  |  |
| 4093 | 1046 | **Support of SMS over generic 3GPP IP access** | 696d? | 2004-10-14 A | 2007-06-14 A | 100% | 2004-10-14 | 2007-06-14 | 696d? |  | S2; C4; C1 | 37544h | 37544h | Huawei | zhangwenlin@huawei.com | Rel-7 | Maurice |  |  | SMSIP | SMSIP | WLAN |  |
| 4094 | 1046.1 | FS on SMSIP | 173d? | 2004-10-14 A | 2005-06-13 A | 100% | 2004-10-14 | 2005-06-13 | 173d? | start no earlier than 2004-10-14 | S2 | 1384h | 1384h | Huawei | zhangwenlin@huawei.com | Rel-7 | Maurice |  |  |  |  | WLAN |  |
| 4095 | 1046.2 | Stage 2 for SMSIP | 333d? | 2005-06-08 A | 2006-09-15 A | 100% | 2005-06-08 | 2006-09-15 | 333d? | finish no earlier than 2006-09-15 | S2 | 2664h | 2664h | Huawei | zhangwenlin@huawei.com | Rel-7 | Maurice |  |  |  |  | WLAN |  |
| 4096 | 1046.3 | **Stage 3 for SMSIP** | 527d? | 2005-06-08 A | 2007-06-14 A | 100% | 2005-06-08 | 2007-06-14 | 527d? |  | C4; C1 | 16792h | 16792h | Nokia | jari.jansson@nokia.com | Rel-7 | Kimmo |  |  | SMSIP-St3 | SMSIP-St3 | WLAN |  |
| 4097 | 1046.3.1 | CT1 aspects for SMSIP | 527d? | 2005-06-08 A | 2007-06-14 A | 100% | 2005-06-08 | 2007-06-14 | 527d? | finish no earlier than 2007-06-15 | C1 | 4216h | 4216h | Nokia | jari.jansson@nokia.com | Rel-7 | Frederic |  |  |  |  | WLAN |  |
| 4098 | 1046.3.2 | CT4 aspects for SMSIP | 518d? | 2005-06-08 A | 2007-06-01 A | 100% | 2005-06-08 | 2007-06-01 | 518d? | finish no earlier than 2007-06-01 | C4 | 4144h | 4144h | Nokia | jari.jansson@nokia.com | Rel-7 | Kimmo |  |  | SMSIP-St3-c4 | SMSIP-St3-c4 | WLAN |  |
| 4099 | 1047 | **Evolution of Policy Control and Charging** | 817d? | 2004-10-14 A | 2007-11-30 A | 100% | 2004-10-14 | 2007-11-30 | 817d? |  | S2; S5; C3; C1 | 54112h | 54112h | Nokia | balazs.bertenyi@nsn.com | Rel-7 | Maurice |  |  | PCC | PCC |  |  |
| 4100 | 1047.1 | Deleted - TR for PCC | 315d? | 2004-10-14 A | 2005-12-29 A | 100% | 2004-10-14 | 2005-12-29 | 315d? | finish no earlier than 2005-12-28 | S2 | 2520h | 2520h | Nokia | balazs.bertenyi@nsn.com | Rel-7 | Maurice |  |  |  |  |  | SP-33 |
| 4101 | 1047.2 | Stage 2 for PCC | 315d? | 2005-07-04 A | 2006-09-15 A | 100% | 2005-07-04 | 2006-09-15 | 315d? | finish no earlier than 2006-09-15 | S2 | 2520h | 2520h | Nokia | balazs.bertenyi@nsn.com | Rel-7 | Maurice |  |  |  |  |  |  |
| 4102 | 1047.3 | Evolution of policy control and flow based bearer level charging | 109d? | 2006-08-01 A | 2006-12-29 A | 100% | 2006-08-01 | 2006-12-29 | 109d? | start no earlier than 2006-08-01 | S2 | 872h | 872h | Nokia | balazs.bertenyi@nsn.com | Rel-7 | Maurice |  |  |  |  |  |  |
| 4103 | 1047.4 | SA5 Charging aspects of PCC | 316d? | 2006-03-31 A | 2007-06-15 A | 100% | 2006-03-31 | 2007-06-15 | 316d? | finish no earlier than 2007-06-15 | S5 | 2528h | 2528h | Orange | alain.bibas@orange-ft.com | Rel-7 | Mirko |  |  | PCC-CH | PCC-CH |  |  |
| 4104 | 1047.5 | Gx reference point for Policy and Charging Control | 521d? | 2005-12-02 A | 2007-11-30 A | 100% | 2005-12-02 | 2007-11-30 | 521d? | finish no earlier than 2007-09-14 | C3 | 4168h | 4168h | Siemens | Thomas.Belling@nsn.com | Rel-7 | Adrian |  |  | PCC-Gx | PCC-Gx |  |  |
| 4105 | 1047.6 | **Rx reference point for PCC CT3 aspects** | 521d? | 2005-12-02 A | 2007-11-30 A | 100% | 2005-12-02 | 2007-11-30 | 521d? |  | C3; C1 | 15360h | 15360h | Ericsson | j.javier.pastor@ericsson.com | Rel-7 | Adrian |  |  | PCC-Rx | PCC-Rx |  |  |
| 4106 | 1047.6.1 | PCC-Rx CT3 aspects | 521d? | 2005-12-02 A | 2007-11-30 A | 100% | 2005-12-02 | 2007-11-30 | 521d? | finish no earlier than 2007-09-14 | C3 | 4168h | 4168h | Ericsson | j.javier.pastor@ericsson.com | Rel-7 | Adrian |  |  | PCC-Rx-c3 | PCC-Rx-c3 |  |  |
| 4107 | 1047.6.2 | PCC-Rx CT1 aspects | 357d? | 2005-12-02 A | 2007-06-15 A | 100% | 2005-12-02 | 2007-06-15 | 357d? | finish no earlier than 2007-06-15 | C1 | 2856h | 2856h | Ericsson | j.javier.pastor@ericsson.com | Rel-7 | Frederic |  |  | PCC-Rx-Gx-c1 | PCC-Rx-Gx-c1 |  |  |

Notes:
- 4083: -
- 4084: CP#54 completed / Impacted TSs and TRs: RFC 6432 (was draft-jesske-dispatch-update3326-reason-responses)
- 4085: - / Impacted TSs and TRs: 24.819, 24.229
- 4086: - / Impacted TSs and TRs: 29.163, 29.209
- 4087: CT4#32: a set of CRs on FBI for cable labs / Impacted TSs and TRs: 29.229
- 4088: Duplicated entry ("ACCSEC2", "Access Security Enhancements", SP-040865) deleted by A.Sultan / Impacted TSs and TRs: 33.203
- 4089: -
- 4090: - / Impacted TSs and TRs: 22.228, 23.228
- 4091: -
- 4092: 03/2006 SP#31 WID approved / Impacted TSs and TRs: 32.240, 32.260, 32.298, 32.299
- 4093: SP#33 updated WID (removed MMS)
- 4094: SP#33 updated WID / Impacted TSs and TRs: 23.804
- 4095: SP#33 updated WID / Impacted TSs and TRs: 23.204
- 4096: CP#34 updated WID
- 4097: CP#34 updated WID / Impacted TSs and TRs: 23.040, 24.229
- 4098: CP#34 updated WID / Impacted TSs and TRs: 23.008, 29.002
- 4099: SP-29 approved WID. SP-31 updated WID adding SA5 charging. 23.125 will be discontinued from Rel-7.
- 4100: SP-30: S2 has no intention for TR completion / Impacted TSs and TRs: 23.803
- 4101: SP-29 approved WID. SP-31 updated WID. 23.125 will be discontinued from Rel-7. / Impacted TSs and TRs: 23.203
- 4102: SP-29 approved WID. SP-31 updated WID. 23.125 will be discontinued from Rel-7. / Impacted TSs and TRs: 23.207, 23.002, 23.228
- 4103: SP-31 updated WID with SA5 charging. / Impacted TSs and TRs: 32.250, 32.251, 32.298, 32.299
- 4104: - / Impacted TSs and TRs: 29.212 (not progressed to Rel-7: 29.210, 29.207, 29.208)
- 4105: WID approved at CP#30, Revised at CP#31, Revised at CP#33
- 4106: - / Impacted TSs and TRs: 29.213, 29.214 (not progressed to Rel-7: 29.209, 29.211)
- 4107: - / Impacted TSs and TRs: 24.229

| ID | WBS | Task | Type | Duration | Start | Finish | Complete | Baseline start | Baseline finish | Baseline duration | Constraint | Resources | Work | Actual work | Acronym | WI rapporteur name | WI rapporteur e-mail | Release | MCC resp | Special Focus Doc | Acronym_3GU_Export | Impacted TSs and TRs | TSG stopped | TSG approved |
| --- | --- | --- | --- | --- | --- | --- | --- | --- | --- | --- | --- | --- | --- | --- | --- | --- | --- | --- | --- | --- | --- | --- | --- | --- |
| 4108 | 1048 | **Voice Call Continuity between CS and IMS (incl. I-WLAN)** |  | 641d? | 2004-12-31 A | 2007-06-15 A | 100% | 2004-12-31 | 2007-06-15 | 641d? |  | S2; S1; S5; C1; C4 | 43592h | 43592h | VCC | Alcatel-Lucent | Keith Drage (drage@alcatel-lucent.com) | Rel-7 | Maurice | WLAN | VCC |  |  |  |
| 4109 | 1048.1 | TR for Voice Call Continuity between CS and IMS (incl. I-WLAN) |  | 245d? | 2004-12-31 A | 2005-12-08 A | 100% | 2004-12-31 | 2005-12-08 | 245d? | finish no earlier than 2005-12-08 | S2 | 1960h | 1960h |  | Alcatel-Lucent | andy.bennett@alcatel-lucent.com | Rel-7 | Maurice | WLAN |  | 23.806 |  |  |
| 4110 | 1048.2 | Stage 1 for Voice Call Continuity between CS and IMS (incl. I-WLAN) |  | 140d? | 2005-03-17 A | 2005-09-28 A | 100% | 2005-03-17 | 2005-09-28 | 140d? | finish no earlier than 2005-09-28 | S1 | 1120h | 1120h |  | Alcatel-Lucent | andy.bennett@alcatel-lucent.com | Rel-7 | Alain | WLAN |  | 22.101 |  |  |
| 4111 | 1048.3 | Stage 2 for Voice Call Continuity between CS and IMS (incl. I-WLAN) |  | 264d? | 2005-09-06 A | 2006-09-08 A | 100% | 2005-09-06 | 2006-09-08 | 264d? | finish no earlier than 2006-09-08 | S2 | 2112h | 2112h |  | Alcatel-Lucent | andy.bennett@alcatel-lucent.com | Rel-7 | Maurice | WLAN |  | 23.206 |  |  |
| 4112 | 1048.4 | SA5 Charging for Voice Call Continuity between CS and IMS (incl. I-WLAN) |  | 325d? | 2006-03-17 A | 2007-06-14 A | 100% | 2006-03-17 | 2007-06-14 | 325d? | finish no earlier than 2007-06-14 | S5 | 2600h | 2600h | VCC-CH | Orange | alain.bibas@orange-ft.com | Rel-7 | Mirko | WLAN | VCC-CH | 32.250, 32.260 |  |  |
| 4113 | 1048.5 | **Stage 3 for Voice Call Continuity between CS and IMS (incl. I-WLAN)** |  | 358d? | 2006-02-01 A | 2007-06-15 A | 100% | 2006-02-01 | 2007-06-15 | 358d? |  | C1; C4 | 10160h | 10160h |  | Alcatel-Lucent | Keith Drage (drage@alcatel-lucent.com) | Rel-7 | Frederic | WLAN |  |  |  |  |
| 4114 | 1048.5.1 | CT1 aspects of Stage 3 for Voice Call Continuity between CS and IMS (incl. I-WLAN) |  | 358d? | 2006-02-01 A | 2007-06-15 A | 100% | 2006-02-01 | 2007-06-15 | 358d? | finish no earlier than 2007-06-15 | C1 | 2864h | 2864h |  | Alcatel-Lucent | Keith Drage (drage@alcatel-lucent.com) | Rel-7 | Frederic | WLAN |  | 24.206, 24.216 |  |  |
| 4115 | 1048.5.2 | CT4 aspects of Stage 3 for Voice Call Continuity between CS and IMS (incl. I-WLAN) |  | 196d? | 2006-06-09 A | 2007-03-09 A | 100% | 2006-06-09 | 2007-03-09 | 196d? | start no earlier than 2006-06-09 | C4 | 1568h | 1568h | VCC-St3-c4 | Alcatel-Lucent | Keith Drage (drage@alcatel-lucent.com) | Rel-7 | Kimmo | WLAN | VCC-St3-c4 | 23.003 |  |  |
| 4116 | 1048.5.3 | Deleted - CT3 aspects of Stage 3 for Voice Call Continuity between CS and IMS (incl. I-WLAN) | milestone | 0d? | 2006-11-02 A | 2006-11-02 A | 100% | 2006-11-02 | 2006-11-02 | 0d? | finish no earlier than 2006-11-02 | C3 |  |  |  | Alcatel-Lucent | Keith Drage (drage@alcatel-lucent.com) | Rel-7 | Adrian | WLAN |  | 29.163 | CP-33 |  |
| 4117 | 1049 | **One Tunnel solution for optimization of Packet Data Traffic** |  | 418d? | 2006-03-27 A | 2007-10-31 A | 100% | 2006-03-27 | 2007-10-31 | 418d? |  | S2 | 7048h | 7048h | OPTUNEL | Nokia | antti.j.pasanen@nokia.com | Rel-7 | Maurice |  | OPTUNEL |  |  |  |
| 4118 | 1049.1 | Deleted - Study on Stage 2 for One Tunnel solution |  | 125d? | 2006-03-27 A | 2006-09-15 A | 100% | 2006-03-27 | 2006-09-15 | 125d? | finish no earlier than 2005-09-12 | S2 | 1000h | 1000h | OPTUNEL-Study | Nokia | antti.j.pasanen@nokia.com | Rel-7 | Maurice |  | OPTUNEL-Study | 23.809 | SP-34 |  |
| 4119 | 1049.2 | One Tunnel Deployment Guideline |  | 268d? | 2006-10-23 A | 2007-10-31 A | 100% | 2006-10-23 | 2007-10-31 | 268d? | finish no earlier than 2007-10-31 | S2 | 2144h | 2144h | OPTUNEL-Guide | Huawei | lan.liu@huawei.com | Rel-7 | Maurice |  | OPTUNEL-Guide | 23.919 |  | TSG-34 |
| 4120 | 1049.3 | Stage 2 specification for One Tunnel solution |  | 70d? | 2006-09-11 A | 2006-12-15 A | 100% | 2006-09-11 | 2006-12-15 | 70d? | finish no earlier than 2006-12-15 | S2 | 560h | 560h | OPTUNEL-Stage2 | Nokia | antti.j.pasanen@nokia.com | Rel-7 | Maurice |  | OPTUNEL-Stage2 | 23.060 |  |  |
| 4121 | 1050 | **CSI Terminating Session handling** |  | 267d? | 2006-06-08 A | 2007-06-15 A | 100% | 2006-06-08 | 2007-06-15 | 267d? |  | S2; C1 | 6864h | 6864h | CSItermS | Samsung | Osok Song | Rel-7 | Maurice |  | CSItermS |  |  |  |
| 4122 | 1050.1 | Stage 2 of CStermS |  | 192d? | 2006-06-08 A | 2007-03-02 A | 100% | 2006-06-08 | 2007-03-02 | 192d? | start no earlier than 2006-06-08 | S2 | 1536h | 1536h |  | Samsung | Osok Song | Rel-7 | Maurice |  |  | 23.279 |  | TSG-34 |
| 4123 | 1050.2 | Stage 3 of CStermS |  | 132d? | 2006-12-14 A | 2007-06-15 A | 100% | 2006-12-14 | 2007-06-15 | 132d? | finish no earlier than 2007-06-15 | C1 | 1056h | 1056h |  | Samsung | chenho.chin@samsung.com | Rel-7 | Frederic |  |  | 24.229, 24.279 |  | TSG-34 |
| 4124 | 1050.3 | Deleted - duplicated with UID 340015 -Stage 3 CSI Terminating Session handling | milestone | 0d? | 2007-03-09 A | 2007-03-09 A | 100% | 2007-03-09 | 2007-03-09 | 0d? | start no earlier than 2007-03-09 | C1 |  |  |  | Samsung | chenho.chin@samsung.com | Rel-7 | Frederic |  |  | 24.229, 24.179, 24.279 | CP-34 | TSG-34 |
| 4125 | 1051 | Liberty Alliance and 3GPP Security Interworking |  | 451d? | 2005-03-10 A | 2006-11-30 A | 100% | 2005-03-10 | 2006-11-30 | 451d? | finish no earlier than 2006-11-30 | S3 | 3608h | 3608h | LibSec | Nokia | Silke.Holtmanns@nokia.com | Rel-7 | Mirko |  | LibSec | 33.980 |  |  |
| 4126 | 1052 | Trust Requirements for Open Platforms in 3GPP |  | 499d? | 2005-01-03 A | 2006-11-30 A | 100% | 2005-01-03 | 2006-11-30 | 499d? | finish no earlier than 2006-11-30 | S3 | 3992h | 3992h | TrustOP | Nokia | Silke.Holtmanns@nokia.com | Rel-7 | Mirko |  | TrustOP | 33.905 |  |  |
| 4127 | 1053 | Development of UEA2 and UIA2 |  | 268d? | 2004-12-01 A | 2005-12-09 A | 100% | 2004-12-01 | 2005-12-09 | 268d? | finish no earlier than 2005-12-09 | S3 | 2144h | 2144h | AlgUEA2 | TeliaSonera | per.christoffersson@teliasonera.com | Rel-7 | Mirko |  | AlgUEA2 | 35.919, 35.215, 35.216, 35.217, 35.218 |  |  |
| 4128 | 1054 | Lawful Interception in the 3GPP Rel-7 architecture |  | 118d? | 2005-06-28 A | 2005-12-08 A | 100% | 2005-06-28 | 2005-12-08 | 118d? | start no earlier than 2005-06-28 | S3 | 944h | 944h | LI-7A | BMWI | berthold.wilhelm@regtp.de | Rel-7 | Mirko |  | LI-7A | 33.106, 33.107, 33.108 |  |  |
| 4129 | 1055 | Key establishment between a UICC and a terminal |  | 201.45d? | 2005-12-07 A | 2006-09-28 A | 100% | 2005-12-07 | 2006-09-28 | 201.45d? | finish no earlier than 2006-09-28 | S3 | 1611.6h | 1611.6h | KeyEstUTerm | Gemalto | mireille.pauliac@gemplus.com | Rel-7 | Mirko |  | KeyEstUTerm | 33.110 |  |  |
| 4130 | 1056 | NDS Authentication Framework Extension for Transport Layer Security |  | 50d? | 2006-09-28 A | 2006-12-06 A | 100% | 2006-09-28 | 2006-12-06 | 50d? | finish no earlier than 2006-09-28 | S3 | 400h | 400h | NDSAFTLS | Nokia | tiina.s.koskinen@nokia.com | Rel-7 | Mirko |  | NDSAFTLS | 33.310 |  |  |
| 4131 | 1057 | **Security enhancements** |  | 319d? | 2005-09-12 A | 2006-11-30 A | 100% | 2005-09-12 | 2006-11-30 | 319d? |  | S3; C1; C4 | 16376h | 16376h | SEC7 |  |  | Rel-7 | Mirko |  | SEC7 |  |  |  |
| 4132 | 1057.1 | HTTPS connection between a UICC and a NAF |  | 1d? | 2005-09-12 A | 2005-09-12 A | 100% | 2005-09-12 | 2005-09-12 | 1d? | start no earlier than 2005-09-12 | S3; C1 | 16h | 16h | SEC7-HSUN | Gemalto | JSeif@axalto.com, mireille.pauliac@gemplus.com | Rel-7 | Mirko |  | SEC7-HSUN | 33.918, 33.222, 24.109 |  |  |
| 4133 | 1057.2 | 2G GBA: 2G SIM usage in 3GPP GAA framework |  | 61d? | 2005-09-12 A | 2005-12-05 A | 100% | 2005-09-12 | 2005-12-05 | 61d? | finish no earlier than 2005-12-05 | S3 | 488h | 488h | SEC7-2GGBA | Nokia | Silke.Holtmanns@nokia.com | Rel-7 | Mirko |  | SEC7-2GGBA | 33.920, 33.220 |  |  |
| 4134 | 1057.3 | Generic Authentication Architecture usage extensions and optimizations |  | 319d? | 2005-09-12 A | 2006-11-30 A | 100% | 2005-09-12 | 2006-11-30 | 319d? | finish no earlier than 2006-11-30 | S3 | 2552h | 2552h | SEC7-GAA2 | Nokia | Silke.Holtmanns@nokia.com | Rel-7 | Mirko |  | SEC7-GAA2 | 33.220, 29.109, 24.109, (33.223 goes to R8) |  |  |

Notes:
- 4108: WID approved SP#27; updated SP#28; updated SP#32
- 4109: -
- 4110: -
- 4111: -
- 4112: 03/2006 SP#31 WID approved
- 4113: -
- 4114: -
- 4115: -
- 4116: -
- 4117: -
- 4118: TR for Info SP-33. SP-34: S2 Report intention to discontinue TR
- 4119: -
- 4120: -
- 4121: Triggered by the abandoned Study UID_32117
- 4122: -
- 4123: CP-34 approved WID. CP-35 updated WID
- 4124: CP-34 approved WID
- 4125: WID approved SP#27.
- 4126: WID approved SP#26.
- 4127: WID approved SP#26, Dependant on Funding Availability.
- 4128: -
- 4129: -
- 4130: TLS profile is moved to Rel-8
- 4131: -
- 4132: -
- 4133: -
- 4134: 33.223 goes to R8

| ID | WBS | Task | Duration | Start | Finish | Complete | Baseline start | Baseline finish | Baseline duration | Constraint | Resources | Work | Actual work | Acronym | WI rapporteur name | WI rapporteur e-mail | Release | MCC resp | Acronym_3GU_Export | Impacted TSs and TRs | PCG approved | TSG approved | TSG stopped |
| --- | --- | --- | --- | --- | --- | --- | --- | --- | --- | --- | --- | --- | --- | --- | --- | --- | --- | --- | --- | --- | --- | --- | --- |
| 4135 | 1057.4 | **SS7 TCAP security Gateway** | 241d? | 2005-09-12 A | 2006-08-14 A | 100% | 2005-09-12 | 2006-08-14 | 241d? |  | S3; C4 | 5664h | 5664h | SEC7-NDS-TCAPsec | Siemens | marc.blommaert.ext@nsn.com | Rel-7 | Mirko | SEC7-NDS-TCAPsec |  |  |  |  |
| 4136 | 1057.4.1 | SA3 aspects of SEC7-NDS-TCAPsec | 130d? | 2005-09-12 A | 2006-03-10 A | 100% | 2005-09-12 | 2006-03-10 | 130d? | finish no earlier than 2006-03-10 | S3 | 1040h | 1040h | SEC7-NDS-TCAPsec-SA3 | Siemens | marc.blommaert.ext@nsn.com | Rel-7 | Mirko | SEC7-NDS-TCAPsec-SA3 | 33.204 |  |  |  |
| 4137 | 1057.4.2 | TCAPsec Gateway | 96d? | 2006-04-03 A | 2006-08-14 A | 100% | 2006-04-03 | 2006-08-14 | 96d? | start no earlier than 2006-04-01 | C4 | 768h | 768h | SEC7-TCAP | Siemens | Ulrich.wiehe@gksag.de | Rel-7 | Kimmo | SEC7-TCAP | 29.204, 29.002 |  |  |  |
| 4138 | 1058 | IMS Stage 3 IETF Protocol Alignment | 589d? | 2004-12-10 A | 2007-03-14 A | 100% | 2004-12-10 | 2007-03-14 | 589d? | finish no earlier than 2007-03-15 | C1 | 4712h | 4712h | IMSProtoc |  |  | Rel-7 | Frederic | IMSProtoc | 24.930 | PCG-36 | TSG#71 |  |
| 4139 | 1059 | **Interoperability between VGCS/VBS and A/Gb flexibility** | 253d? | 2006-03-22 A | 2007-03-09 A | 100% | 2006-03-22 | 2007-03-09 | 253d? |  | C1; C4 | 7344h | 7344h | VGCSFlex | Siemens | robert.zaus@nsn.com | Rel-7 | Frederic | VGCSFlex |  |  |  |  |
| 4140 | 1059.1 | CT1 aspects of VGCSFlex | 159d? | 2006-03-22 A | 2006-10-30 A | 100% | 2006-03-22 | 2006-10-30 | 159d? | finish no earlier than 2006-10-30 | C1 | 1272h | 1272h |  | Siemens | robert.zaus@nsn.com | Rel-7 | Frederic |  | 43.068, 43.069 |  |  |  |
| 4141 | 1059.2 | CT4 aspects of VGCSFlex | 253d? | 2006-03-22 A | 2007-03-09 A | 100% | 2006-03-22 | 2007-03-09 | 253d? | finish no earlier than 2007-03-09 | C4 | 2024h | 2024h | VGCSFlex-c4 | Siemens | robert.zaus@nsn.com | Rel-7 | Kimmo | VGCSFlex-c4 | 29.002 |  |  |  |
| 4142 | 1060 | DIAMETER on the GGSN Gi interface | 586d? | 2004-09-10 A | 2006-12-08 A | 100% | 2004-09-10 | 2006-12-08 | 586d? | finish no earlier than 2006-12-08 | C3 | 4688h | 4688h | DIAMGi | Vodafone | Nico.Gabriele@vodafone.com | Rel-7 | Adrian | DIAMGi | 29.061 |  |  |  |
| 4143 | 1061 | DIAMETER on the PDG Wi interface | 586d? | 2004-09-10 A | 2006-12-08 A | 100% | 2004-09-10 | 2006-12-08 | 586d? | finish no earlier than 2006-12-08 | C3 | 4688h | 4688h | DIAMWi | Vodafone | Nico.Gabriele@vodafone.com | Rel-7 | Adrian | DIAMWi | 29.161 |  |  |  |
| 4144 | 1062 | Interworking between the 3GPP CS domain with BICC or ISUP as signalling protocol and external SIP-I networks | 478d? | 2006-09-22 A | 2008-07-22 A | 100% | 2006-09-22 | 2008-07-22 | 478d? | finish no earlier than 2007-09-14 | C3 | 3824h | 3824h | ExtSIPI | Siemens | Thomas.Belling@nsn.com | Rel-7 | Adrian | ExtSIPI | 29.164 |  |  |  |
| 4145 | 1063 | PDU multiplexing at Nb Interface with IP transport | 427d? | 2006-12-04 A | 2008-07-22 A | 100% | 2006-12-04 | 2008-07-22 | 427d? | start no earlier than 2006-12-04 | C3 | 3416h | 3416h | NbIPMux | Alcatel-Lucent | Jean.Rzeznik@alcatel-lucent.fr | Rel-7 | Adrian | NbIPMux | 29.414 |  | TSG-34 |  |
| 4146 | 1064 | **Mp (MRFC - MRFP) interface** | 345d? | 2006-02-13 A | 2007-06-08 A | 100% | 2006-02-13 | 2007-06-08 | 345d? |  | C4; C1 | 9904h | 9904h | Mp | Ericsson | philip.hodges@ericsson.com | Rel-7 | Kimmo | Mp |  |  |  |  |
| 4147 | 1064.1 | CT1 aspects of Mp | 1d | 2006-02-13 A | 2006-02-13 A | 100% | 2006-02-13 | 2006-02-13 | 1d | finish no earlier than 2006-02-13 | C1 | 8h | 8h |  | Ericsson | philip.hodges@ericsson.com | Rel-7 | Frederic |  | 24.229 |  |  |  |
| 4148 | 1064.2 | Deleted - CT3 aspects of Mp | 1d | 2006-09-22 A | 2006-09-22 A | 100% | 2006-09-22 | 2006-09-22 | 1d | start no earlier than 2006-09-22 | C3 | 8h | 8h |  | Ericsson | philip.hodges@ericsson.com | Rel-7 | Adrian |  | 29.162 |  |  | CP-33 |
| 4149 | 1064.3 | Procedures description | 201d? | 2006-06-02 A | 2007-03-09 A | 100% | 2006-06-02 | 2007-03-09 | 201d? | finish no earlier than 2007-03-09 | C4 | 1608h | 1608h | Mp-PROCc4 | Huawei | Chencheng@huawei.com | Rel-7 | Kimmo | Mp-PROCc4 | 23.333 |  |  |  |
| 4150 | 1064.4 | Stage 3 for Mp (MRFC - MRFP) interface | 345d | 2006-02-13 A | 2007-06-08 A | 100% | 2006-02-13 | 2007-06-08 | 345d | finish no earlier than 2007-06-08 | C4 | 2760h | 2760h | Mp-St3c4 | Ericsson | philip.hodges@ericsson.com | Rel-7 | Kimmo | Mp-St3c4 | 29.333 |  |  |  |
| 4151 | 1065 | Routeing of MT-SMS via the HPLMN | 71d? | 2006-12-01 A | 2007-03-09 A | 100% | 2006-12-01 | 2007-03-09 | 71d? | finish no earlier than 2007-03-09 | C4; C1 | 1136h | 1136h | SMSviaH | Vodafone | Nick.Russell@vodafone.com | Rel-7 | Kimmo | SMSviaH | 23.040, 29.002 |  | TSG-34 |  |
| 4152 | 1066 | Mobile Termination whilst the MS is moving to another MSC | 60d? | 2007-03-09 A | 2007-05-31 A | 100% | 2007-03-09 | 2007-05-31 | 60d? | start no earlier than 2007-03-09 | C4 | 480h | 480h | MTmovMS | Alcatel-Lucent | bruno.landais@alcatel-lucent.fr | Rel-7 | Kimmo | MTmovMS | 23.008, 23.012, 23.018, 23.078, 23.079, 29.002 |  |  |  |
| 4153 | 1067 | ISIM API for Java Card | 620d? | 2005-03-14 A | 2007-07-27 A | 100% | 2005-03-14 | 2007-07-27 | 620d? | finish no earlier than 2007-07-27 | C6 | 4960h | 4960h | APIJAVA | Sun | Sebastian Hans | Rel-7 | Xavier | APIJAVA | 31.103, 102 241 |  |  |  |
| 4154 | 1068 | Rel-7 (U)SIM API Testing (TS 31.213) | 211d? | 2009-05-30 A | 2010-03-19 A | 100% | 2009-05-30 | 2010-03-19 | 211d? | finish no earlier than 2010-03-12 | C6 | 1688h | 1688h | USIM_API_Test | Sagem Orga | gerrit.hartbrod@sagem-orga.com | Rel-7 | Xavier | USIM_API_Test | 31.213 | PCG-23 | CP-44 |  |
| 4155 | 1069 | High speed interface between the UICC and the ME | 311d? | 2006-09-22 A | 2007-11-30 A | 100% | 2006-09-22 | 2007-11-30 | 311d? | finish no earlier than 2007-11-30 | C6 | 2488h | 2488h | HSI | Gemalto | jacques.seif@GEMALTO.COM | Rel-7 | Xavier | HSI | 31.101 |  |  |  |
| 4156 | 1070 | Video Codec Performance Requirements | 634d? | 2005-01-03 A | 2007-06-07 A | 100% | 2005-01-03 | 2007-06-07 | 634d? | finish no earlier than 2007-06-07 | S4 | 5072h | 5072h | VICPer | Siemens | juergen.pandel@siemens.com | Rel-7 | Paolo | VICPer | 26.234, 26.235, 26.346, 26.140, 26.902 |  |  |  |
| 4157 | 1071 | Dynamic and Interactive Multimedia Scenes | 583d? | 2005-03-15 A | 2007-06-07 A | 100% | 2005-03-15 | 2007-06-07 | 583d? | finish no earlier than 2007-06-07 | S4 | 4664h | 4664h | DIMS | Streamezzo | gaelle.martin-cocher@streamezzo.com | Rel-7 | Paolo | DIMS | 26.140, 26.142, 26.234, 26.244, 23.346 |  |  |  |
| 4158 | 1072 | 3G-324M Video Telephony Call Setup Times Improvements | 341d? | 2005-06-08 A | 2006-09-27 A | 100% | 2005-06-08 | 2006-09-27 | 341d? | finish no earlier than 2006-09-27 | S4 | 2728h | 2728h | VTCSTI | Vodafone | edward.hall@vodafone.co.uk | Rel-7 | Paolo | VTCSTI | 26.911 |  |  |  |

Notes:
- 4135: -
- 4136: -
- 4137: -
- 4138: TR 24.930: Signalling flows for the session setup in the IM CN subsystem based on Session Initiation Protocol (SIP)
- 4139: Voice Group Call Service
- 4140: -
- 4141: -
- 4142: -
- 4143: -
- 4144: -
- 4145: -
- 4146: -
- 4147: -
- 4148: CP#34: CT3 not involved in Mp interface definition
- 4149: -
- 4150: -
- 4151: WID approved in CP#34
- 4152: -
- 4153: -
- 4154: CP#47 completed. Update of Rel-6 (U)SIM API for Java Card Testing UID_43007 under Rel-6 UICC/USIM enhancements and interworking UID_1800
- 4155: Following ETSI publication of TS 102 600, expected to be completed at CT6 meeting 45
- 4156: -
- 4157: -
- 4158: -

| ID | WBS | Task | Duration | Start | Finish | Complete | Baseline start | Baseline finish | Baseline duration | Constraint | Resources | Work | Actual work | Acronym | WI rapporteur name | WI rapporteur e-mail | Release | MCC resp | Acronym_3GU_Export | TSG stopped |
| --- | --- | --- | --- | --- | --- | --- | --- | --- | --- | --- | --- | --- | --- | --- | --- | --- | --- | --- | --- | --- |
| 4159 | 1073 | **Optimizations for Multimedia Telephony over IMS** | 2d? | 2005-09-28 A | 2005-09-29 A | 100% | 2005-09-28 | 2005-09-28 | 0d? |  | S4 | 32h | 32h | OMTIMS | Ericsson | olle.franceschi@ericsson.com | Rel-7 | Paolo | OMTIMS |  |
| 4160 | 1073.1 | Deleted - Characterisation of Adaptive Jitter Management Performance for VoIP Services | 2d? | 2005-09-28 A | 2005-09-29 A | 100% | 2005-09-28 | 2005-09-28 | 0d? | finish no earlier than 2005-09-29 | S4 | 16h | 16h | OMTIMS-CAJMP | Lucent | dhuo@lucent.com | Rel-7 | Paolo | OMTIMS-CAJMP | SP-35 |
| 4161 | 1074 | End-to-End Multimedia Services Performance Metrics | 382d? | 2005-09-28 A | 2007-03-15 A | 100% | 2005-09-28 | 2007-03-15 | 382d? | finish no earlier than 2007-03-15 | S4 | 3056h | 3056h | E2EMSPM | China Mobile | zhangyanyf@chinamobile.com | Rel-7 | Paolo | E2EMSPM |  |
| 4162 | 1075 | Packet Switched Streaming Enhancements | 261d? | 2006-06-08 A | 2007-06-07 A | 100% | 2006-06-08 | 2007-06-07 | 261d? | finish no earlier than 2007-06-07 | S4 | 2088h | 2088h | PSSe | Ericsson | olle.franceschi@ericsson.com | Rel-7 | Paolo | PSSe |  |
| 4163 | 1076 | **Rel-7 Operations, Administration, Maintenance and Provisioning (OAM&P)** | 472.86d? | 2005-09-02 A | 2007-06-26 A | 100% | 2005-09-02 | 2007-06-26 | 472.86d? |  | S5 | 82725.8h | 82725.8h | OAM7 | Huawei | Christian.Toche@huawei.com | Rel-7 | Mirko | OAM7 |  |
| 4164 | 1076.1 | **Rel-7 Network Infrastructure Management** | 465d? | 2005-09-02 A | 2007-06-14 A | 100% | 2005-09-02 | 2007-06-14 | 465d? |  | S5 | 41800h | 41800h | OAM7-NIM |  |  | Rel-7 | Mirko | OAM7-NIM |  |
| 4165 | 1076.1.1 | Enhance NRM to accommodate NGN (IMS as basis of the Next Generation Network) | 465d? | 2005-09-02 A | 2007-06-14 A | 100% | 2005-09-02 | 2007-06-14 | 465d? | finish no earlier than 2007-06-14 | S5 | 3720h | 3720h |  | Motorola |  | Rel-7 | Mirko |  |  |
| 4166 | 1076.1.2 | Co-operative Element Management interface (CO-OP) (Study + Implementation) | 400d? | 2005-09-02 A | 2007-03-15 A | 100% | 2005-09-02 | 2007-03-15 | 400d? | finish no earlier than 2007-03-15 | S5 | 3200h | 3200h |  | Motorola |  | Rel-7 | Mirko |  |  |
| 4167 | 1076.1.3 | Network Management (NM) Itf-N performance criteria | 465d? | 2005-09-02 A | 2007-06-14 A | 100% | 2005-09-02 | 2007-06-14 | 465d? | finish no earlier than 2007-06-14 | S5 | 3720h | 3720h |  | China Mobile |  | Rel-7 | Mirko |  |  |
| 4168 | 1076.1.4 | Delta synchronization between IRP Manager and IRP Agent (Study + Implementation) | 465d? | 2005-09-02 A | 2007-06-14 A | 100% | 2005-09-02 | 2007-06-14 | 465d? | finish no earlier than 2007-06-14 | S5 | 3720h | 3720h |  | Siemens |  | Rel-7 | Mirko |  |  |
| 4169 | 1076.1.5 | Subscription Management (SuM) IRP Solution Sets | 330d? | 2005-09-02 A | 2006-12-07 A | 100% | 2005-09-02 | 2006-12-07 | 330d? | finish no earlier than 2006-12-07 | S5 | 2640h | 2640h |  | Ericsson |  | Rel-7 | Mirko |  |  |
| 4170 | 1076.1.6 | Integration Reference Point (IRP) Security Management | 400d? | 2005-09-02 A | 2007-03-15 A | 100% | 2005-09-02 | 2007-03-15 | 400d? | finish no earlier than 2007-03-15 | S5 | 3200h | 3200h |  | Huawei | Christian.Toche@huawei.com | Rel-7 | Mirko |  |  |
| 4171 | 1076.1.7 | Partial suspension of Itf-N during maintenance/testing (Study + Implementation) | 465d? | 2005-09-02 A | 2007-06-14 A | 100% | 2005-09-02 | 2007-06-14 | 465d? | finish no earlier than 2007-06-14 | S5 | 3720h | 3720h |  | Siemens |  | Rel-7 | Mirko |  |  |
| 4172 | 1076.1.8 | Deleted - Management of Legacy Equipment | 336d? | 2005-09-02 A | 2006-12-15 A | 100% | 2005-09-02 | 2006-12-15 | 336d? | finish no earlier than 2006-12-15 | S5 | 2688h | 2688h |  | Siemens |  | Rel-7 | Mirko |  | SP-35 |
| 4173 | 1076.1.9 | Deleted - Rules for Vendor Specific Extensions | 400d? | 2005-09-02 A | 2007-03-15 A | 100% | 2005-09-02 | 2007-03-15 | 400d? | finish no earlier than 2007-03-15 | S5 | 3200h | 3200h |  | Siemens |  | Rel-7 | Mirko |  | SP-35 |
| 4174 | 1076.1.10 | Backward and Forward Compatibility of IRP systems | 465d? | 2005-09-02 A | 2007-06-14 A | 100% | 2005-09-02 | 2007-06-14 | 465d? | finish no earlier than 2007-06-14 | S5 | 3720h | 3720h |  | Ericsson |  | Rel-7 | Mirko |  |  |
| 4175 | 1076.1.11 | Repeater Network Resource Model (NRM) definition | 214d? | 2006-02-13 A | 2006-12-07 A | 100% | 2006-02-13 | 2006-12-07 | 214d? | finish no earlier than 2006-12-07 | S5 | 1712h | 1712h |  | China Mobile |  | Rel-7 | Mirko |  |  |
| 4176 | 1076.1.12 | UTRAN radio channel power monitoring | 284d? | 2006-02-13 A | 2007-03-15 A | 100% | 2006-02-13 | 2007-03-15 | 284d? | finish no earlier than 2007-03-15 | S5 | 2272h | 2272h |  | China Mobile |  | Rel-7 | Mirko |  |  |
| 4177 | 1076.1.13 | Notification XML Schema | 71d? | 2006-12-07 A | 2007-03-15 A | 100% | 2006-12-07 | 2007-03-15 | 71d? | finish no earlier than 2007-03-15 | S5 | 568h | 568h |  | Huawei | Christian.Toche@huawei.com | Rel-7 | Mirko |  |  |
| 4178 | 1076.2 | **Rel-7 Performance Management** | 465d? | 2005-09-02 A | 2007-06-14 A | 100% | 2005-09-02 | 2007-06-14 | 465d? |  | S5 | 22992h | 22992h | OAM7-PM |  |  | Rel-7 | Mirko | OAM7-PM |  |
| 4179 | 1076.2.1 | Performance measurements definition for CN CS | 400d? | 2005-09-02 A | 2007-03-15 A | 100% | 2005-09-02 | 2007-03-15 | 400d? | finish no earlier than 2007-03-15 | S5 | 3200h | 3200h |  | China Mobile |  | Rel-7 | Mirko |  |  |
| 4180 | 1076.2.2 | Enhancement UTRAN performance measurements definition | 465d? | 2005-09-02 A | 2007-06-14 A | 100% | 2005-09-02 | 2007-06-14 | 465d? | finish no earlier than 2007-06-14 | S5 | 3720h | 3720h |  | China Mobile |  | Rel-7 | Mirko |  |  |
| 4181 | 1076.2.3 | Add TDD specific counters in Performance measurement | 330d? | 2005-09-02 A | 2006-12-07 A | 100% | 2005-09-02 | 2006-12-07 | 330d? | finish no earlier than 2006-12-15 | S5 | 2640h | 2640h |  | CATT |  | Rel-7 | Mirko |  |  |
| 4182 | 1076.2.4 | ATM bearer network Performance measurements | 400d? | 2005-09-02 A | 2007-03-15 A | 100% | 2005-09-02 | 2007-03-15 | 400d? | finish no earlier than 2007-03-15 | S5 | 3200h | 3200h |  | ZTE |  | Rel-7 | Mirko |  |  |
| 4183 | 1076.2.5 | Performance measurements definition for IMS | 465d? | 2005-09-02 A | 2007-06-14 A | 100% | 2005-09-02 | 2007-06-14 | 465d? | finish no earlier than 2007-06-14 | S5 | 3720h | 3720h |  | China Mobile |  | Rel-7 | Mirko |  |  |
| 4184 | 1076.2.6 | HSDPA performance measurements | 349d? | 2006-02-13 A | 2007-06-14 A | 100% | 2006-02-13 | 2007-06-14 | 349d? | finish no earlier than 2007-06-14 | S5 | 2792h | 2792h |  | China Mobile |  | Rel-7 | Mirko |  |  |

Notes:
- 4159: Aug2015: 99%->100 / Impacted TSs and TRs: 26.235, 26.236
- 4160: SP-35 stopped
- 4161: - / Impacted TSs and TRs: 26.944
- 4162: - / Impacted TSs and TRs: 26.234, 26.244
- 4163: OAM7 is an umbrella Feature also for OAM&P related TEI7 type of changes that are not part of any other dedicated feature/WI / Impacted TSs and TRs: TR 30.817
- 4164: -
- 4165: - / Impacted TSs and TRs: 32.731/2/3/5, 32.631/2/3/5
- 4166: - / Impacted TSs and TRs: 32.806, 32.814, 32.101
- 4167: - / Impacted TSs and TRs: 32.811
- 4168: - / Impacted TSs and TRs: 32.391/2/3/5
- 4169: - / Impacted TSs and TRs: 32.307/317/607/667/665, 32.101, 32.175
- 4170: - / Impacted TSs and TRs: 32.372/3/5, 32.111,32.30x,32.32x,32.33x,32.34x,32.35x,32.36x,32.41x,32.60x,32.61x,32.66x
- 4171: - / Impacted TSs and TRs: 32.381/2/3/5
- 4172: Request to TSG#35 to STOP the WI / Impacted TSs and TRs: new 32.xxx
- 4173: Request to TSG#35 to STOP the WI / Impacted TSs and TRs: 32.62n; For n = 1 to 5
- 4174: - / Impacted TSs and TRs: 32.154
- 4175: - / Impacted TSs and TRs: 32.721/2/3/5
- 4176: - / Impacted TSs and TRs: 32.405, 32.64n; For n = 1 to 5
- 4177: 12/2006 SP#34 WID approved / Impacted TSs and TRs: New 32.325/345/365/415, CR to 32.335/615/665
- 4178: -
- 4179: - / Impacted TSs and TRs: 32.407, 32.408
- 4180: - / Impacted TSs and TRs: 32.405
- 4181: - / Impacted TSs and TRs: 32.405
- 4182: - / Impacted TSs and TRs: No impact on 32.404, 32.405, 32.406, 32.407
- 4183: - / Impacted TSs and TRs: 32.404,32.409,32.437, 32.632/3/4/5
- 4184: - / Impacted TSs and TRs: 32.405

| ID | WBS | Task | Type | Duration | Start | Finish | Complete | Baseline start | Baseline finish | Baseline duration | Constraint | Resources | Work | Actual work | Acronym | WI rapporteur name | Release | MCC resp | Acronym_3GU_Export | TSG stopped | WI rapporteur e-mail | Status Report |
| --- | --- | --- | --- | --- | --- | --- | --- | --- | --- | --- | --- | --- | --- | --- | --- | --- | --- | --- | --- | --- | --- | --- |
| 4185 | 44.5 | **Rel-7 Trace Management** |  | 472.86d? | 2005-09-02 A | 2007-06-26 A | 100% | 2005-09-02 | 2007-06-26 | 472.86d? |  | S5 | 14150.9h | 14150.9h | OAM7-Trace | Vodafone | Rel-7 | Mirko | OAM7-Trace |  |  |  |
| 4186 | 1076.3.1 | End-to-end Service Level tracing for IMS |  | 350d? | 2005-11-11 A | 2007-03-15 A | 100% | 2005-11-11 | 2007-03-15 | 350d? | finish no earlier than 2007-03-15 | S5 | 2800h | 2800h |  | Vodafone | Rel-7 | Mirko |  | SP-31 |  |  |
| 4187 | 1076.3.2 | Trace record content for UTRAN TDD |  | 330d? | 2005-09-02 A | 2006-12-07 A | 100% | 2005-09-02 | 2006-12-07 | 330d? | finish no earlier than 2006-12-07 | S5 | 2640h | 2640h |  | Nokia | Rel-7 | Mirko |  |  |  |  |
| 4188 | 1076.3.3 | IRP for Subscriber and Equipment Trace Management |  | 465d? | 2005-09-02 A | 2007-06-14 A | 100% | 2005-09-02 | 2007-06-14 | 465d? | finish no earlier than 2007-06-14 | S5 | 3720h | 3720h |  | Nokia | Rel-7 | Mirko |  |  |  |  |
| 4189 | 1076.3.4 | Deleted - SIP enhancements for trace | milestone | 0d? | 2007-06-15 A | 2007-06-26 A | 100% | 2007-06-15 | 2007-06-26 | 0d? | start no earlier than 2007-06-15 | C1 |  |  |  |  | Rel-7 | Frederic |  | CP-32 |  |  |
| 4190 | 1076.3.5 | Deleted - duplicated with UID 35063 - IRP for Subscriber and Equipment Trace Management |  | 336d? | 2005-09-02 A | 2006-12-15 A | 100% | 2005-09-02 | 2006-12-15 | 336d? | finish no earlier than 2006-12-15 | S5 | 2688h | 2688h |  | Nokia | Rel-7 | Mirko |  | SP-33 |  |  |
| 4191 | 1077 | **Rel-7 Charging Management small Enhancements** |  | 279d? | 2006-05-22 A | 2007-06-14 A | 100% | 2006-05-22 | 2007-06-14 | 279d? |  | S5 | 5952h | 5952h | CH7 | Orange | Rel-7 | Mirko | CH7 |  | alain.bibas@orange-ft.com |  |
| 4192 | 1077.1 | Alternate Charged Party (ACP) for IMS |  | 279d? | 2006-05-22 A | 2007-06-14 A | 100% | 2006-05-22 | 2007-06-14 | 279d? | finish no earlier than 2007-06-14 | S5 | 2232h | 2232h | CH7-IMS-ACP | Lucent | Rel-7 | Mirko | CH7-IMS-ACP |  | njmazzarella@alcatel-lucent.com |  |
| 4193 | 1077.2 | Align 3GPP Charging with OMA PoC Enabler Release 2.0 |  | 186d? | 2006-09-28 A | 2007-06-14 A | 100% | 2006-09-28 | 2007-06-14 | 186d? | finish no earlier than 2007-06-14 | S5 | 1488h | 1488h | CH7-PoC | Siemens | Rel-7 | Mirko | CH7-PoC |  | Gerald.Goermer@nsn.com |  |
| 4194 | 8.5 | **Multiple-Input Multiple-Output (MIMO) antennas** |  | 1301d? | 2003-03-14 A | 2008-03-07 A | 100% | 2003-03-14 | 2008-03-07 | 1301d? |  | R1; R5 | 55848h | 55848h | MIMO | Alcatel-Lucent | Rel-7 | Patrick | MIMO |  | hchuang@Alcatel-Lucent.com |  |
| 4195 | 1078.1 | MIMO - Physical layer |  | 915d? | 2003-09-12 A | 2007-03-15 A | 100% | 2003-09-12 | 2007-03-15 | 915d? | finish no earlier than 2007-03-15 | R1 | 7320h | 7320h | MIMO-Phys | Alcatel-Lucent | Rel-7 | Patrick | MIMO-Phys |  | hchuang@Alcatel-Lucent.com | RP-070037 |
| 4196 | 1078.2 | MIMO - Layer 2,3 aspects |  | 915d? | 2003-09-12 A | 2007-03-15 A | 100% | 2003-09-12 | 2007-03-15 | 915d? | finish no earlier than 2007-03-15 | R2 | 7320h | 7320h | MIMO-L23 | Alcatel-Lucent | Rel-7 | Yong-Jun | MIMO-L23 |  | hchuang@Alcatel-Lucent.com | RP-070037 |
| 4197 | 1078.3 | MIMO - Iub/Iur Protocol Aspects |  | 1045d? | 2003-03-14 A | 2007-03-15 A | 100% | 2003-03-14 | 2007-03-15 | 1045d? | finish no earlier than 2007-03-15 | R3 | 8360h | 8360h | MIMO-IurIub | Alcatel-Lucent | Rel-7 | Juha | MIMO-IurIub |  | hchuang@Alcatel-Lucent.com | RP-070037 |
| 4198 | 1078.4 | MIMO - RF Radio Transmission/Reception, System Performance Requirements and Conformance Testing |  | 982d? | 2003-12-12 A | 2007-09-17 A | 100% | 2003-12-12 | 2007-09-17 | 982d? | finish no earlier than 2007-09-17 | R4 | 7856h | 7856h | MIMO-RF | Alcatel-Lucent | Rel-7 | Issam | MIMO-RF |  | ngm@Alcatel-Lucent.com | RP-070531 |
| 4199 | 1078.5 | **UE Conformance Testing for Multiple Input Multiple Output antennas (MIMO)** |  | 261d? | 2007-03-09 A | 2008-03-07 A | 100% | 2007-03-09 | 2008-03-07 | 261d? |  | R5 | 4176h | 4176h | MIMO-UEConTest | Qualcomm | Rel-7 | Ingbert | MIMO-UEConTest |  | svora@qualcomm.com |  |
| 4200 | 1078.5.1 | Conformance Test Aspects – Multiple Input Multiple Output Antennas (MIMO) for FDD |  | 261d? | 2007-03-09 A | 2008-03-07 A | 100% | 2007-03-09 | 2008-03-07 | 261d? | finish no earlier than 2008-03-07 | R5 | 2088h | 2088h | MIMO-UEConTest_FDD | Qualcomm | Rel-7 | Ingbert | MIMO-UEConTest_FDD |  | svora@qualcomm.com |  |
| 4201 | 1079 | **Rel-7 Improvements of the Radio Interface** |  | 709d? | 2004-09-15 A | 2007-06-04 A | 100% | 2004-09-15 | 2007-06-04 | 709d? |  | RP; GP | 40520h | 40520h |  |  | Rel-7 | Issam |  |  |  |  |
| 4202 | 1079.1 | Extended UMTS 1.7/2.1 GHz |  | 198d? | 2006-03-15 A | 2006-12-15 A | 100% | 2006-03-15 | 2006-12-15 | 198d? | finish no earlier than 2006-12-15 | R4 | 1584h | 1584h | RInImp-UMTS1721Ext | Ericsson | Rel-7 | Issam | RInImp-UMTS1721Ext |  | johan.skold@ericsson.com | RP-060681 |
| 4203 | 1079.2 | UMTS 2.6 GHz 7.68 Mcps TDD |  | 67d? | 2006-06-15 A | 2006-09-15 A | 100% | 2006-06-15 | 2006-09-15 | 67d? | finish no earlier than 2006-09-15 | R4 | 536h | 536h | RInImp-UMTS26VHCRTDD | IPWireless | Rel-7 | Issam | RInImp-UMTS26VHCRTDD |  | Shin Horng Wong (shwong@ipwireless.com) | RP-060451 |
| 4204 | 1079.3 | UMTS 2.6 GHz |  | 195d? | 2004-09-15 A | 2005-06-14 A | 100% | 2004-09-15 | 2005-06-14 | 195d? | finish no earlier than 2005-06-14 | R4 | 1560h | 1560h | RInImp-UMTS2600 | Nokia | Rel-7 | Issam | RInImp-UMTS2600 |  | jussi.numminen@nokia.com | RP-050184 |
| 4205 | 1079.4 | UMTS 2.6 GHz TDD |  | 261d? | 2004-12-15 A | 2005-12-14 A | 100% | 2004-12-15 | 2005-12-14 | 261d? | finish no earlier than 2005-12-15 | R4 | 2088h | 2088h | RInImp-UMTS2600TDD | IPWireless | Rel-7 | Issam | RInImp-UMTS2600TDD |  | Shin Horng Wong (shwong@ipwireless.com) | RP-050661 |
| 4206 | 1079.5 | UMTS 900 MHz |  | 261d? | 2004-12-15 A | 2005-12-14 A | 100% | 2004-12-15 | 2005-12-14 | 261d? | finish no earlier than 2005-12-15 | R4 | 2088h | 2088h | RInImp-UMTS900 | Nortel | Rel-7 | Issam | RInImp-UMTS900 |  | Yannick Li (yli@nortelnetworks.com) | RP-050662 |
| 4207 | 1079.6 | UMTS 1700 MHz |  | 197d? | 2005-03-15 A | 2005-12-14 A | 100% | 2005-03-15 | 2005-12-14 | 197d? | finish no earlier than 2005-12-15 | R4 | 1576h | 1576h | RInImp-UMTS1700 | NTT DoCoMo | Rel-7 | Issam | RInImp-UMTS1700 |  | Takehiro Nakamura (nakamurata@nttdocomo.co.jp) | RP-050824 |
| 4208 | 1079.7 | UE Antenna Performance Evaluation Method and Requirements |  | 644d? | 2004-12-15 A | 2007-06-04 A | 100% | 2004-12-15 | 2007-06-04 | 644d? | finish no earlier than 2007-06-04 | R4; GP | 10304h | 10304h | RInImp-UEAnt | TeliaSonera | Rel-7 | Issam | RInImp-UEAnt |  | Christian.Bergljung@TeliaSonera.com | RP-070281 |
| 4209 | 1079.8 | Improved Performance Requirements for HSDPA UE based on Rx Diversity (type 1) & LMMSE equalizer (type 2) | milestone | 0d? | 2005-03-15 A | 2005-03-15 A | 100% | 2005-03-15 | 2005-03-15 | 0d? | finish no earlier than 2005-03-15 | R4 |  |  | RInImp-HSPerf-Type3 | Cingular | Rel-7 | Issam | RInImp-HSPerf-Type3 |  | Marc Grant | RP-060015 |

Notes:
- 4185: -
- 4186: 07/2005: OMA (Stage 1), Stage 2/3 SA5, CT1/3/4 / Impacted TSs and TRs: 32.101, 32.421, 32.422, 32.423
- 4187: - / Impacted TSs and TRs: 32.421, 32.422, 32.423
- 4188: - / Impacted TSs and TRs: 32.441, 32.442, 32.443, 32.445, 32.632, 32.633, 32.635
- 4189: combined with UID 11067
- 4190: - / Impacted TSs and TRs: 32.421,32.422,32.423. 3 new 32.4x1,2,3
- 4191: CH7 is an umbrella Feature also for OAM&P related TEI7 type of changes that are not part of any other dedicated feature/WI / Impacted TSs and TRs: TR 30.817
- 4192: - / Impacted TSs and TRs: 32.240, 32.260, 32.298, 32.299
- 4193: 09/2006 SP#33 WID approved / Impacted TSs and TRs: 32.240, 32.272, 32.299, 32.298
- 4194: Completed Sep 2007; SR in RP-070037and RP-070531 / Impacted TSs and TRs: 25.876, 25.996
- 4195: Completed Sep 2007; SR in RP-070037 / Impacted TSs and TRs: 25.211, 25.212, 25.213, 25.214, 25.215, 25.221
- 4196: Completed Sep 2007; SR in RP-070037 / Impacted TSs and TRs: 25.876
- 4197: Completed Sep 2007; SR in RP-070037
- 4198: Completed Sep 2007; SR in RP-070531
- 4199: BB place holder for a number of RAN5 Tasks
- 4200: - / Impacted TSs and TRs: TS 34.108, TS 34.109, TS 34.121-1, TS 34.121-2, TS 34.123-1, TS 34.123-2, TS 34.123-3
- 4201: Generic feature
- 4202: RP#34 completed. Introduction of Band X (Extended UMTS 1.7/2.1 GHz) in 25.307 / Impacted TSs and TRs: 25.806, 25.101, 25.104, 25.133, 24.141, 25.331, 25.306, 25.307, 25.423, 25.461, 25.463, 34.121
- 4203: RP#33 completed / Impacted TSs and TRs: 25.102, 25.105, 25.123, 25.113, 25.142, 34.124
- 4204: RP#28 completed / Impacted TSs and TRs: 25.101, 25.104, 25.133, 25.141, 25.331, 25.942, 25.306, 25.307, 34.121
- 4205: RP#30 completed / Impacted TSs and TRs: 25.102, 25.105, 25.113, 25.123, 25.142, 25.331, 25.942, 25.306, 25.307, 34.122, 34.124
- 4206: RP#30 completed / Impacted TSs and TRs: 25.101, 25.104, 25.113, 25.133, 25.141, 25.331, 25.942, 25.306, 25.307, 34.121
- 4207: RP#30 completed / Impacted TSs and TRs: 25.101, 25.104, 25.113, 25.133, 25.141, 25.306, 25.307, 25.331, 34.121
- 4208: RP#36 completed / Impacted TSs and TRs: 25.101, new TR (25.914, 25.963)
- 4209: RP#27 completed / Impacted TSs and TRs: 25.101

| ID | WBS | Task | Type | Duration | Start | Finish | Complete | Baseline start | Baseline finish | Baseline duration | Constraint | Deadline | Resources | Work | Actual work | Acronym | WI rapporteur name | WI rapporteur e-mail | Release | MCC resp | Acronym_3GU_Export | Status Report | TSG stopped | PCG stopped | Created at |
| --- | --- | --- | --- | --- | --- | --- | --- | --- | --- | --- | --- | --- | --- | --- | --- | --- | --- | --- | --- | --- | --- | --- | --- | --- | --- |
| 4210 | 1079.9 | **Additional minimum UE performance requirement for non-HSDPA channels based on type 1 enhanced receiver (Rx Diversity)** |  | 327d? | 2005-09-15 A | 2006-12-15 A | 100% | 2005-09-15 | 2006-12-15 | 327d? |  |  | R4 | 7344h | 7344h | RInImp-RxDiv | Qualcomm | Serge Willenegger (sergew@qualcomm.com) | Rel-7 | Issam | RInImp-RxDiv |  |  |  |  |
| 4211 | 1079.9.1 | Additional minimum UE performance requirement for DL physical channels in support of DCH/HS-DSCH operation based on type 1 enhanced receiver (RX-Diversity) |  | 195d? | 2005-09-15 A | 2006-06-14 A | 100% | 2005-09-15 | 2006-06-14 | 195d? | finish no earlier than 2006-06-15 |  | R4 | 1560h | 1560h | RInImp-RxDiv-DCH | Cingular | Marc Grant | Rel-7 | Issam | RInImp-RxDiv-DCH | RP-060235 |  |  |  |
| 4212 | 1079.9.2 | Additional minimum UE performance requirement for downlink physical channels in support of MTCH and MCCH operation based on type 1 enhanced receiver (Rx-Diversity) |  | 198d? | 2006-03-15 A | 2006-12-15 A | 100% | 2006-03-15 | 2006-12-15 | 198d? | finish no earlier than 2006-12-15 |  | R4 | 1584h | 1584h | RInImp-RxDiv-MBMS | Qualcomm | Serge Willenegger (sergew@qualcomm.com) | Rel-7 | Issam | RInImp-RxDiv-MBMS | RP-060678 |  |  |  |
| 4213 | 1079.9.3 | Additional minimum UE performance requirement for downlink physical channels in support of E-DCH operation based on type 1 enhanced receiver (Rx-Diversity) |  | 198d? | 2006-03-15 A | 2006-12-15 A | 100% | 2006-03-15 | 2006-12-15 | 198d? | finish no earlier than 2006-12-15 |  | R4 | 1584h | 1584h | RInImp-RxDiv-EDCH | Qualcomm | Serge Willenegger (sergew@qualcomm.com) | Rel-7 | Issam | RInImp-RxDiv-EDCH | RP-060679 |  |  |  |
| 4214 | 1079.10 | Deleted Improved support of gaming over HSDPA/EDCH |  | 262d? | 2005-12-15 A | 2006-12-15 A | 100% | 2005-12-15 | 2006-12-15 | 262d? | finish no earlier than 2006-12-15 |  | R2 | 2096h | 2096h | RInImp-Gaming | Cingular | Don Zelmer (dz1069@att.com) | Rel-7 | Yong-Jun | RInImp-Gaming | RP-060680 | RP-34 |  |  |
| 4215 | 1079.11 | Deleted (not approved at PCG) - UMTS 2.6 GHz FDD DL External | milestone | 0d? | 2005-09-15 A | 2005-09-15 A | 100% | 2005-09-15 | 2005-09-15 | 0d? | finish no earlier than 2005-09-15 |  | R4 |  |  | RInImp-UMTS2600Ext | T-mobile | han.van.bussel@t-mobile.de | Rel-7 | Issam | RInImp-UMTS2600Ext |  | RP-31 | PCG-16 |  |
| 4216 | 1080 | **Rel-7 Improvements of the Radio Interface - UE Conformance Testing** |  | 741d? | 2005-11-11 A | 2008-09-12 A | 100% | 2005-11-11 | 2008-09-12 | 741d? |  |  | R5 | 17568h | 17568h |  |  |  | Rel-7 | Ingbert |  |  |  |  |  |
| 4217 | 16.5.1 | UE Conformance Test for UMTS 2600 MHz |  | 146d | 2005-11-11 A | 2006-06-02 A | 100% | 2005-11-11 | 2006-06-02 | 146d | finish no earlier than 2006-06-02 | 2006-06-02 | R5 | 1168h | 1168h | RInImp-UMTS2600_Test | Nokia | Aleksi.Heino@nokia.com | Rel-7 | Ingbert | RInImp-UMTS2600_Test |  |  |  | Fri 7/11/05 |
| 4218 | 16.5.1 | UE Conformance Test for UMTS 900 MHz (band VIII) |  | 146d | 2005-11-11 A | 2006-06-02 A | 100% | 2005-11-11 | 2006-06-02 | 146d | finish no earlier than 2006-06-02 | 2006-06-02 | R5 | 1168h | 1168h | RInImp-UMTS900_Test | Qualcomm | hanye@qualcomm.com | Rel-7 | Ingbert | RInImp-UMTS900_Test |  |  |  | Fri 11/03/05 |
| 4219 | 1080.3 | Conformance Test Aspects – Improved Performance of HSDPA Receiver type 3 |  | 191d? | 2006-03-10 A | 2006-12-01 A | 100% | 2006-03-10 | 2006-12-01 | 191d? | finish no earlier than 2006-12-01 |  | R5 | 1528h | 1528h | RInImp-HSPerf-Type3_Test | Motorola | carolyn.taylor@motorola.com | Rel-7 | Ingbert | RInImp-HSPerf-Type3_Test |  |  |  |  |
| 4220 | 1080.4 | UE antenna Over The Air (OTA) conformance testing |  | 518d? | 2006-09-20 A | 2008-09-12 A | 100% | 2006-09-20 | 2008-09-12 | 518d? | finish no earlier than 2008-09-12 |  | R5 | 4144h | 4144h | RInImp-UEAnt_Test | Nokia | Aleksi.Heino@nokia.com | Rel-7 | Ingbert | RInImp-UEAnt_Test | RP-080535 |  |  |  |
| 4221 | 1080.5 | UE conformance testing for FDD Inter-Band Operation |  | 131d? | 2006-06-02 A | 2006-12-01 A | 100% | 2006-06-02 | 2006-12-01 | 131d? | finish no earlier than 2006-12-01 |  | R5 | 1048h | 1048h | RInImp-InterBand_Test | NEC, Motorola | Jacob.John@motorola.com | Rel-7 | Ingbert | RInImp-InterBand_Test |  |  |  |  |
| 4222 | 1080.6 | Conformance Test Aspects – Extended UMTS 1.7/2.1 GHz |  | 131d? | 2006-12-01 A | 2007-06-01 A | 100% | 2006-12-01 | 2007-06-01 | 131d? | finish no earlier than 2007-06-01 |  | R5 | 1048h | 1048h | RInImp-UEConTest_UMTS1721Ext | Motorola | carolyn.taylor@motorola.com | Rel-7 | Ingbert | RInImp-UEConTest_UMTS1721Ext | RP-070312 |  |  |  |
| 4223 | 1080.7 | Conformance Test Aspects – Minimum UE performance requirement for downlink physical channels in support of E-DCH operation based on type 1 enhanced receiver (Rx-Diversity) |  | 136d? | 2007-06-01 A | 2007-12-07 A | 100% | 2007-06-01 | 2007-12-07 | 136d? | finish no earlier than 2007-12-07 |  | R5 | 1088h | 1088h | RInImp-UEConTest_RxDivEDCH | Motorola | carolyn.taylor@motorola.com | Rel-7 | Ingbert | RInImp-UEConTest_RxDivEDCH | RP-070810 |  |  |  |
| 4224 | 1080.8 | Conformance Test Aspects – Minimum UE performance requirement for downlink physical channels in support of MTCGH and MCCH operation based on type 1 enhanced receiver (Rx-Diversity) |  | 201d? | 2007-06-01 A | 2008-03-07 A | 100% | 2007-06-01 | 2008-03-07 | 201d? | finish no earlier than 2008-03-07 |  | R5 | 1608h | 1608h | RInImp-UEConTest_RxDivMBMS | Ericsson | leif.mattisson@ericsson.com | Rel-7 | Ingbert | RInImp-UEConTest_RxDivMBMS | RP-080056 |  |  |  |
| 4225 | 1081 | **Rel-7 RAN improvements** |  | 653d? | 2004-12-15 A | 2007-06-15 A | 100% | 2004-12-15 | 2007-06-15 | 653d? |  |  | RP; S5 | 39512h | 39512h |  |  |  | Rel-7 |  |  |  |  |  |  |
| 4226 | 1081.1 | Optimization of channelisation code utilisation for 1.28 Mcps TDD |  | 523d? | 2004-12-15 A | 2006-12-15 A | 100% | 2004-12-15 | 2006-12-15 | 523d? | finish no earlier than 2006-12-15 |  | R1 | 4184h | 4184h | RANimp-RABSE-CodOptLCRTDD | UTStarcom | Ka Leong Lo (kaleong.lo@UTSTAR.COM) | Rel-7 | Patrick | RANimp-RABSE-CodOptLCRTDD | RP-060682 |  |  |  |
| 4227 | 1081.2 | Delay optimization for procedures applicable to CS and PS Connections |  | 394d? | 2005-03-15 A | 2006-09-15 A | 100% | 2005-03-15 | 2006-09-15 | 394d? | finish no earlier than 2006-09-15 |  | R2 | 3152h | 3152h | RANimp-DelayOpt | Nokia | juho.pirskanen@nokia.com | Rel-7 | Yong-Jun | RANimp-DelayOpt | RP-060453 |  |  |  |
| 4228 | 1081.3 | Improved support of IMS Realtime Services using HSDPA/HSUPA |  | 197d? | 2005-03-15 A | 2005-12-14 A | 100% | 2005-03-15 | 2005-12-14 | 197d? | start no earlier than 2005-03-15 |  | R2 | 1576h | 1576h | RANimp-IMSRealTime | Cingular | Don Zelmer (dz1069@att.com) | Rel-7 | Yong-Jun | RANimp-IMSRealTime | RP-050667 |  |  |  |
| 4229 | 1081.4 | UE Performance Requirements for MBMS (TDD) |  | 328d? | 2005-03-15 A | 2006-06-15 A | 100% | 2005-03-15 | 2006-06-15 | 328d? | finish no earlier than 2006-06-15 |  | R4 | 2624h | 2624h | MBMS-RAN-RF-TDD | IPwireless | shwong@ipwireless.com | Rel-7 | Issam | MBMS-RAN-RF-TDD | RP-060477 |  |  |  |
| 4230 | 1081.5 | Continuous connectivity for packet data users |  | 524d? | 2005-03-14 A | 2007-03-15 A | 100% | 2005-03-14 | 2007-03-15 | 524d? | finish no earlier than 2007-03-15 |  | R1 | 4192h | 4192h | RANimp-CPC | Siemens | Joern.Krause@siemens.com | Rel-7 | Patrick | RANimp-CPC | RP-070033 |  |  |  |
| 4231 | 1081.6 | Extended WCDMA Cell Range |  | 198d? | 2006-03-15 A | 2006-12-15 A | 100% | 2006-03-15 | 2006-12-15 | 198d? | finish no earlier than 2006-12-15 |  | R3 | 1584h | 1584h | RANimp-ExtCell | Ericsson | Muhammad Kazmi | Rel-7 | Juha | RANimp-ExtCell | RP-060685 |  |  |  |
| 4232 | 1081.7 | 7.68 Mcps TDD Enhanced Uplink |  | 198d? | 2006-03-15 A | 2006-12-15 A | 100% | 2006-03-15 | 2006-12-15 | 198d? | finish no earlier than 2006-12-15 |  | R1 | 1584h | 1584h | RANimp-VHCRTDD-EDCH | IPwireless | nanderson@ipwireless.com | Rel-7 | Patrick | RANimp-VHCRTDD-EDCH | RP-060684 |  |  |  |
| 4233 | 1081.8 | Enhanced CELL_FACH State in FDD |  | 181d? | 2006-09-25 A | 2007-06-04 A | 100% | 2006-09-25 | 2007-06-04 | 181d? | finish no earlier than 2007-06-04 |  | R2 | 1448h | 1448h | RANimp-EnhState | Nokia | juho.pirskanen@nokia.com | Rel-7 | Yong-Jun | RANimp-EnhState | RP-070286 |  |  |  |
| 4234 | 1081.9 | 64QAM for HSDPA (FDD) |  | 110d? | 2006-12-15 A | 2007-06-04 A | 100% | 2006-12-15 | 2007-06-04 | 110d? | finish no earlier than 2007-06-04 |  | R1 | 880h | 880h | RANimp-64QamDownlink | Ericsson | Johan.Bergman@ericsson.com | Rel-7 | Patrick | RANimp-64QamDownlink | RP-070287 |  |  |  |
| 4235 | 1081.10 | Improved L2 support for high data rates |  | 122d? | 2006-12-15 A | 2007-06-04 A | 100% | 2006-12-15 | 2007-06-04 | 122d? | finish no earlier than 2007-06-04 |  | R2 | 976h | 976h | RANimp-L2DataRates | Ericsson | Janne.Peisa@ericsson.com | Rel-7 | Yong-Jun | RANimp-L2DataRates | RP-070289 |  |  |  |
| 4236 | 1081.11 | Introduction of 16QAM in HSUPA (FDD) |  | 110d? | 2006-12-15 A | 2007-06-04 A | 100% | 2006-12-15 | 2007-06-04 | 110d? | finish no earlier than 2007-06-04 |  | R1 | 880h | 880h | RANimp-16QamUplink | Nokia | Karri.Ranta-aho@nsn.com | Rel-7 | Patrick | RANimp-16QamUplink | RP-070288 |  |  |  |

Notes:
- 4210: - / Impacted TSs and TRs: 25.101
- 4211: RP#32 completed / Impacted TSs and TRs: 25.101
- 4212: RP#34 completed / Impacted TSs and TRs: 25.101
- 4213: RP#34 completed / Impacted TSs and TRs: 25.101
- 4214: RP#34 stopped. SR in RP-060680
- 4215: This item was conditionnaly approved pending decision of PCG#16 who decided not to approve it / Impacted TSs and TRs: 25.101, 25.104, 25.133, 25.141, 25.331, 25.942, 25.306, 25.307, 34.121
- 4216: Linked to Feature UID_20028 (RInImp)
- 4217: RP#32 completed / Impacted TSs and TRs: 34.108, 34.121
- 4218: RP#32 completed / Impacted TSs and TRs: 34.108, 34.121
- 4219: RP#34 completed / Impacted TSs and TRs: 34.121, 34.108
- 4220: RP#41 completed (GERAN aspects might need to be included later) / Impacted TSs and TRs: 34.114
- 4221: RP#34 completed / Impacted TSs and TRs: 34.108, 34.123-1, 34.123-2, 34.123-3
- 4222: RP#36 completed / Impacted TSs and TRs: 34.108, 34.121-1, 34.121-2
- 4223: RP#38 completed
- 4224: RP#39 completed / Impacted TSs and TRs: 34.121-1, 34.121-2
- 4225: Generic feature
- 4226: RP#34 completed
- 4227: RP#33 completed / Impacted TSs and TRs: 25.815, 25.321, 25.322, 25.331
- 4228: RP#30 completed
- 4229: RP#32 completed / Impacted TSs and TRs: 25.102, 25.123
- 4230: RP#35 completed / Impacted TSs and TRs: 25.903, 25.201, 25.211, 25.212, 25.214, 25.308, 25.321, 25.331, 25.423, 25.433, 25.101, 25.133
- 4231: RP#34 completed / Impacted TSs and TRs: 25.133, 25.423, 25.425, 25.433, 25.435, 25.453, 25.331
- 4232: RP#34 completed / Impacted TSs and TRs: 25.201, 25.202, 25.221, 25.222, 25.223, 25.224, 25.225, 25.331, 23.321, 25.306, 25.302, 25.401, 25.420, 25.423, 25.427, 25.433, 25.102, 25.105, 25.142
- 4233: RP#36 completed / Impacted TSs and TRs: 25.308, 25.304, 25.306, 25.321, 25.331, 25.433, 25.435, 25.423, 25.425,
- 4234: RP#36 completed / Impacted TSs and TRs: 25.308, 25.211, 25.212, 25.213, 25.306, 25.331, 25.433, 25.435, 25.423, 25.425, 25.101, 25.104, 25.141
- 4235: RP#36 completed / Impacted TSs and TRs: 25.301, 25.308,25.306, 25.321, 25.322, 25.331, 25.433, 25.435, 25.423, 25.425, 25.999
- 4236: RP#36 completed / Impacted TSs and TRs: 25.319, 25.101, 25.104, 25.133, 25.141, 25.211, 25.212, 25.213, 25.214, 25.306, 25.321, 25.331, 25.423, 25.433

| ID | WBS | Task | Duration | Start | Finish | Complete | Baseline start | Baseline finish | Baseline duration | Constraint | Resources | Work | Actual work | Acronym | WI rapporteur name | WI rapporteur e-mail | Release | MCC resp | Status Report | Acronym_3GU_Export | PCG approved | TSG approved |
| --- | --- | --- | --- | --- | --- | --- | --- | --- | --- | --- | --- | --- | --- | --- | --- | --- | --- | --- | --- | --- | --- | --- |
| 4237 | 1081.12 | **Interface to control Tower Mounted Amplifiers (TMAs)** | 271d? | 2006-06-02 A | 2007-06-15 A | 100% | 2006-06-02 | 2007-06-15 | 271d? |  | R3; S5 | 5984h | 5984h | RANImp-TMA | Vodafone | alexej.kulakov@vodafone.com | Rel-7 | Juha | RP-070140 | RANImp-TMA |  |  |
| 4238 | 1081.12.1 | RAN3 part of Interface to control Tower Mounted Amplifiers (TMAs) | 206d? | 2006-06-02 A | 2007-03-16 A | 100% | 2006-06-02 | 2007-03-16 | 206d? |  | R3 | 840h | 840h |  | Vodafone | alexej.kulakov@vodafone.com | Rel-7 | Juha | RP-070140 |  |  |  |
| 4239 | 1081.12.2 | OAM aspects to Interface to control TMAs | 101d? | 2007-01-26 A | 2007-06-15 A | 100% | 2007-01-26 | 2007-06-15 | 101d? | finish no earlier than 2007-06-15 | S5 | 808h | 808h | RANImp-TMA-OAM | Vodafone | Adrian.Neal@vodafone.com | Rel-7 | Mirko |  | RANImp-TMA-OAM |  |  |
| 4240 | 1082 | **Rel-7 RAN improvements - UE Conformance Testing** | 784d? | 2006-09-20 A | 2009-09-18 A | 100% | 2006-09-20 | 2009-09-18 | 784d? |  | R5 | 25472h | 25472h |  |  |  | Rel-7 | Ingbert |  |  |  |  |
| 4241 | 1082.1 | Conformance Test Aspects - 3.84 Mcps and 7.68 Mcps TDD Enhanced Uplink | 518d? | 2006-09-20 A | 2008-09-12 A | 100% | 2006-09-20 | 2008-09-12 | 518d? | finish no earlier than 2008-09-12 | R5 | 4144h | 4144h | RANimp-UEConTest_EDCHTDH | IPWireless | tspeight@ipwireless.com | Rel-7 | Ingbert | RP-080536 | RANimp-UEConTest_EDCHTDH |  |  |
| 4242 | 1082.2 | Conformance Test Aspects – 64QAM for HSDPA (FDD) | 257d? | 2007-03-09 A | 2008-03-03 A | 100% | 2007-03-09 | 2008-03-03 | 257d? | finish no earlier than 2008-03-03 | R5 | 2056h | 2056h | RANimp-UEConTest_64QamDownlink | Ericsson | leif.mattisson@ericsson.com | Rel-7 | Ingbert | RP-080059 | RANimp-UEConTest_64QamDownlink |  |  |
| 4243 | 1082.3 | Conformance Test Aspects – 16QAM for HSUPA (FDD) | 321d? | 2007-03-09 A | 2008-05-30 A | 100% | 2007-03-09 | 2008-05-30 | 321d? | finish no earlier than 2008-05-30 | R5 | 2568h | 2568h | RANimp-UEConTest_16QamUplink | Motorola | carolyn.taylor@motorola.com | Rel-7 | Ingbert | RP-080281 | RANimp-UEConTest_16QamUplink |  |  |
| 4244 | 1082.4 | Conformance Test Aspects – Improved L2 support for high data rates | 321d? | 2007-03-09 A | 2008-05-30 A | 100% | 2007-03-09 | 2008-05-30 | 321d? | finish no earlier than 2008-05-30 | R5 | 2568h | 2568h | RANimp-UEConTest_L2DataRates | Ericsson | leif.mattisson@ericsson.com | Rel-7 | Ingbert | RP-080256 | RANimp-UEConTest_L2DataRates |  |  |
| 4245 | 1082.5 | Conformance Test Aspects – Continuous connectivity for packet data users | 321d? | 2007-03-09 A | 2008-05-30 A | 100% | 2007-03-09 | 2008-05-30 | 321d? | finish no earlier than 2008-05-30 | R5 | 2568h | 2568h | RANimp-UEConTest_CPC | Nokia | jarkko.hellsten@nokia.com | Rel-7 | Ingbert | RP-080282 | RANimp-UEConTest_CPC |  |  |
| 4246 | 1082.6 | Conformance Test Aspects – Enhanced CELL_FACH state in FDD | 662d? | 2007-03-09 A | 2009-09-18 A | 100% | 2007-03-09 | 2009-09-18 | 662d? | finish no earlier than 2009-09-18 | R5 | 5296h | 5296h | RANimp-UEConTest_EnhancedCellFACHState | Nokia | jarkko.hellsten@nokia.com | Rel-7 | Ingbert | RP-090711 | RANimp-UEConTest_EnhancedCellFACHState |  |  |
| 4247 | 1083 | **7.68 Mcps TDD option** | 783d? | 2004-09-15 A | 2007-09-14 A | 100% | 2004-09-15 | 2007-09-14 | 783d? |  | R1; R2; R3; R4; R5 | 49552h | 49552h | VHCRTDD | IPwireless | Martin Beale (mbeale@ipwireless.com) | Rel-7 | Patrick | RP-060684 | VHCRTDD |  |  |
| 4248 | 1083.1 | VHCRTDD: Stage 2 | 391d? | 2004-09-15 A | 2006-03-15 A | 100% | 2004-09-15 | 2006-03-15 | 391d? | finish no earlier than 2006-03-15 | R1 | 3128h | 3128h | VHCRTDD-Stage2 | IPwireless | Martin Beale (mbeale@ipwireless.com) | Rel-7 | Patrick | RP-060684 | VHCRTDD-Stage2 |  |  |
| 4249 | 1083.2 | VHCRTDD: Physical Layer | 391d? | 2004-09-15 A | 2006-03-15 A | 100% | 2004-09-15 | 2006-03-15 | 391d? | finish no earlier than 2006-03-15 | R1 | 3128h | 3128h | VHCRTDD-Phys | IPwireless | Martin Beale (mbeale@ipwireless.com) | Rel-7 | Patrick | RP-060684 | VHCRTDD-Phys |  |  |
| 4250 | 1083.3 | VHCRTDD: Layer 2 and layer 3 protocol aspects | 391d? | 2004-09-15 A | 2006-03-15 A | 100% | 2004-09-15 | 2006-03-15 | 391d? | finish no earlier than 2006-03-15 | R2 | 3128h | 3128h | VHCRTDD-L23 | IPwireless | drichards@ipwireless.com | Rel-7 | Yong-Jun | RP-060684 | VHCRTDD-L23 |  |  |
| 4251 | 1083.4 | VHCRTDD: UTRAN Iub/Iur Protocol Aspects | 391d? | 2004-09-15 A | 2006-03-15 A | 100% | 2004-09-15 | 2006-03-15 | 391d? | finish no earlier than 2006-03-15 | R3 | 3128h | 3128h | VHCRTDD-IurIub | IPwireless | Peter Legg (plegg@ipwireless.com) | Rel-7 | Juha | RP-060684 | VHCRTDD-IurIub |  |  |
| 4252 | 1083.5 | VHCRTDD: RF Radio Transmission/ Reception, System Performance Requirements and Conformance Testing | 457d? | 2004-09-15 A | 2006-06-15 A | 100% | 2004-09-15 | 2006-06-15 | 457d? | finish no earlier than 2006-06-15 | R4 | 3656h | 3656h | VHCRTDD-RF | IPwireless | Shin Horng Wong (shwong@ipwireless.com) | Rel-7 | Issam | RP-060684 | VHCRTDD-RF |  |  |
| 4253 | 1083.6 | Conformance Test Aspects - 7.68 Mcps TDD | 258d? | 2006-09-20 A | 2007-09-14 A | 100% | 2006-09-20 | 2007-09-14 | 258d? | finish no earlier than 2007-09-10 | R5 | 2064h | 2064h | VHCRTDD-UEConTest | IPWireless | tspeight@ipwireless.com | Rel-7 | Ingbert | RP-070307 | VHCRTDD-UEConTest |  |  |
| 4254 | 1084 | **3.84 Mcps TDD Enhanced Uplink** | 394d? | 2005-03-15 A | 2006-09-15 A | 100% | 2005-03-15 | 2006-09-15 | 394d? |  | RP | 18384h | 18384h | EDCHTDD | IPwireless | nanderson@ipwireless.com | Rel-7 |  | RP-060462 | EDCHTDD |  |  |
| 4255 | 1084.1 | EDCHTDD: Stage 2 | 328d? | 2005-03-15 A | 2006-06-15 A | 100% | 2005-03-15 | 2006-06-15 | 328d? | finish no earlier than 2006-06-15 | R2 | 2624h | 2624h | EDCHTDD-Stage2 | IPwireless | nanderson@ipwireless.com | Rel-7 | Yong-Jun | RP-060462 | EDCHTDD-Stage2 |  |  |
| 4256 | 1084.2 | EDCHTDD: Physical Layer | 394d? | 2005-03-15 A | 2006-09-15 A | 100% | 2005-03-15 | 2006-09-15 | 394d? | finish no earlier than 2006-09-15 | R1 | 3152h | 3152h | EDCHTDD-Phys | IPwireless | nanderson@ipwireless.com | Rel-7 | Patrick | RP-060462 | EDCHTDD-Phys |  |  |
| 4257 | 1084.3 | EDCHTDD: Layer 2 and 3 Protocol Aspects | 394d? | 2005-03-15 A | 2006-09-15 A | 100% | 2005-03-15 | 2006-09-15 | 394d? | finish no earlier than 2006-09-15 | R2 | 3152h | 3152h | EDCHTDD-L23 | IPwireless | drichards@ipwireless.com | Rel-7 | Yong-Jun | RP-060462 | EDCHTDD-L23 |  |  |
| 4258 | 1084.4 | EDCHTDD: UTRAN Iub/Iur Protocol Aspects | 394d? | 2005-03-15 A | 2006-09-15 A | 100% | 2005-03-15 | 2006-09-15 | 394d? | finish no earlier than 2006-09-15 | R3 | 3152h | 3152h | EDCHTDD-IurIub | Interdigital | jim.miller@interdigital.com | Rel-7 | Juha | RP-060462 | EDCHTDD-IurIub |  |  |
| 4259 | 1084.5 | EDCHTDD: RF Radio Transmission/ Reception, System Performance Requirements and Conformance Testing | 394d? | 2005-03-15 A | 2006-09-15 A | 100% | 2005-03-15 | 2006-09-15 | 394d? | finish no earlier than 2006-09-15 | R4 | 3152h | 3152h | EDCHTDD-RF | IPwireless | Shin Horng Wong (shwong@ipwireless.com) | Rel-7 | Issam | RP-060462 | EDCHTDD-RF |  |  |
| 4260 | 1085 | **1.28 Mcps TDD Enhanced Uplink** | 653d? | 2006-03-15 A | 2008-09-12 A | 100% | 2006-03-15 | 2008-09-12 | 653d? |  | R1; R2; R3; R4; R5 | 35656h | 35656h | LCRTDD-EDCH | CATT | Haijing Hu | Rel-7 | Patrick | RP-070296 | LCRTDD-EDCH |  |  |
| 4261 | 1085.1 | 1.28 Mcps TDD Enhanced Uplink: Physical Layer | 262d? | 2006-03-15 A | 2007-03-15 A | 100% | 2006-03-15 | 2007-03-15 | 262d? | finish no earlier than 2007-03-15 | R1 | 2096h | 2096h | LCRTDD-EDCH-Phys | CATT | Ke Wang | Rel-7 | Patrick | RP-070038 | LCRTDD-EDCH-Phys |  |  |
| 4262 | 1085.2 | 1.28 Mcps TDD Enhanced Uplink: Layer 2 and 3 Protocol Aspects | 262d? | 2006-03-15 A | 2007-03-15 A | 100% | 2006-03-15 | 2007-03-15 | 262d? | finish no earlier than 2007-03-15 | R2 | 2096h | 2096h | LCRTDD-EDCH-L23 | CATT | Haiyang Quan | Rel-7 | Yong-Jun | RP-070038 | LCRTDD-EDCH-L23 |  |  |
| 4263 | 1085.3 | 1.28 Mcps TDD Enhanced Uplink: UTRAN Iub/Iur Protocol Aspects | 262d? | 2006-03-15 A | 2007-03-15 A | 100% | 2006-03-15 | 2007-03-15 | 262d? | finish no earlier than 2007-03-15 | R3 | 2096h | 2096h | LCRTDD-EDCH-IubIur | CATT | Yincheng Zhang | Rel-7 | Juha | RP-070038 | LCRTDD-EDCH-IubIur |  |  |
| 4264 | 1085.4 | 1.28 Mcps TDD Enhanced Uplink: RF Radio Transmission/ Reception, System Performance Requirements and Conformance Testing | 328d? | 2006-03-15 A | 2007-06-15 A | 100% | 2006-03-15 | 2007-06-15 | 328d? | finish no earlier than 2007-06-15 | R4 | 2624h | 2624h | LCRTDD-EDCH-RF | CATT | Yuexia Song (songyuexia@catt.cn) | Rel-7 | Issam | RP-070296 | LCRTDD-EDCH-RF |  |  |
| 4265 | 1085.5 | 1.28 Mcps TDD Enhanced Uplink - UE Conformance Testing | 257d? | 2007-09-20 A | 2008-09-12 A | 100% | 2007-09-20 | 2008-09-12 | 257d? | finish no earlier than 2008-09-11 | R5 | 624h | 624h | LCRTDD-EDCH-UEConTest | CATT | chenxiaozhong@datangmobile.cn | Rel-7 | Ingbert | RP-080539 | LCRTDD-EDCH-UEConTest |  |  |
| 4266 | 1086 | Conformance Test Aspects – Multiple Band and Multiple Frequency operation for LCR TDD | 263d? | 2010-09-17 A | 2011-09-16 A | 100% | 2010-09-17 | 2011-09-16 | 263d? | finish no earlier than 2011-12-09 | R5 | 2091.37h | 2091.37h | LCRTDD_MB_MF_UEConTest | CATR | Ms Jun Chen (chenjun@catr.cn) | Rel-7 | Ingbert | RP-110968 | LCRTDD_MB_MF_UEConTest | PCG-25 | RP-49 |
| 4267 | 1087 | MS Antenna Performance Evaluation Method and Requirements | 731d? | 2005-01-28 A | 2007-11-16 A | 100% | 2005-01-28 | 2007-11-16 | 731d? | finish no earlier than 2007-11-16 | GP | 5848h | 5848h | APEMR | TeliaSonera | Ulf.Tegth@teliasonera.com | Rel-7 | Paolo |  | APEMR |  |  |

Notes:
- 4237: RP#35 completed
- 4238: RP#35 completed
- 4239: SP#36 completed / Impacted TSs and TRs: 32.642, 32.643, 32.645 – Align with RAN 25.466
- 4240: Linked to Feature UID_20029 (RANimp)
- 4241: RP#41 completed / Impacted TSs and TRs: 34.108, 34.122, 34.123-1, 34.123-2, 34.123-3
- 4242: RP#39 completed / Impacted TSs and TRs: 34.108, 34.121-1, 34.121-2, 34.123-1, 34.123-2, 34.123-3
- 4243: RP#40 completed / Impacted TSs and TRs: 34.108, 34.121-1, 34.121-2, 34.123-1, 34.123-2, 34.123-3
- 4244: RP#40 completed / Impacted TSs and TRs: 34.108, 34.123-1, 34.123-2, 34.123-3
- 4245: RP#40 completed / Impacted TSs and TRs: 34.108, 34.121-1, 34.121-2, 34.123-1, 34.123-2, 34.123-3
- 4246: RP#45 completed / Impacted TSs and TRs: 34.108, 34.123-1, 34.123-2, 34.123-3
- 4247: RP#31 completed
- 4248: RP#31 completed / Impacted TSs and TRs: 25.202
- 4249: RP#31 completed / Impacted TSs and TRs: 25.221, 25.222, 25.223, 25.224,25.225
- 4250: RP#31 completed / Impacted TSs and TRs: 25.301, 25.302, 25.305, 25.306, 25.321, 25.331
- 4251: RP#31 completed / Impacted TSs and TRs: 25.401, 25.420, 25.423, 25.425, 25.427, 25.430, 25.433, 25.435
- 4252: RP#32 completed / Impacted TSs and TRs: 25.102, 25.105, 25.123, 25.133, 25.142
- 4253: RP#37 completed / Impacted TSs and TRs: 34.108, 34.122, 34.123-1, 34.123-2, 34.123-3
- 4254: RP#33 completed
- 4255: RP#33 completed
- 4256: RP#33 completed / Impacted TSs and TRs: 25.201, 25.221,25.222, 25.223, 25.224, 25.225
- 4257: RP#33 completed / Impacted TSs and TRs: 25.301, 25.302, 25.306, 25.321, 25.331
- 4258: RP#33 completed / Impacted TSs and TRs: 25.401, 25.420, 25.423, 25.427, 25.430, 25.433, 25.435
- 4259: RP#33 completed / Impacted TSs and TRs: 25.102, 25.105, 25.123, 25.142
- 4260: RP#35 completed
- 4261: RP#35 completed / Impacted TSs and TRs: 25.201, 25.221, 25.222, 25.223, 25.224, 25.225
- 4262: RP#35 completed / Impacted TSs and TRs: 25.301, 25.302, 25.306, 25.321, 25.331
- 4263: RP#35 completed / Impacted TSs and TRs: 25.401, 25.420, 25.423, 25.425, 25.427, 25.430, 25.433, 25.435
- 4264: RP#36 completed / Impacted TSs and TRs: 25.102, 25.105, 25.123, 25.142
- 4265: RP#41 completed / Impacted TSs and TRs: 34.108, 34.122, 34.123-1/2/3
- 4266: RP#53 completed. Core specification was introduced via Rel-7 CR under TEI7 (RP#37 RP-070650) and via 2 Rel-8 work items: RInImp9-UMTS1880TDD and RInImp8-UMTS2300TDD. / Impacted TSs and TRs: UTRA 34.108, 34.123-1, 34.123-2, 34.123-3
- 4267: GP#36 completed for R7 / Impacted TSs and TRs: 25.914, 25.144, 45.005

| ID | WBS | Task | Type | Duration | Start | Finish | Complete | Remaining | Baseline start | Baseline finish | Baseline duration | Total slack | Constraint | Resources | Work | Actual work | Acronym | WI rapporteur name | WI rapporteur e-mail | Release | MCC resp | Acronym_3GU_Export | TSG stopped |
| --- | --- | --- | --- | --- | --- | --- | --- | --- | --- | --- | --- | --- | --- | --- | --- | --- | --- | --- | --- | --- | --- | --- | --- |
| 4268 | 1088 | **Lower 700 MHz Inclusion in the GERAN Specifications** |  | 390d? | 2005-01-03 A | 2006-06-30 | 99% | 0d? | 2005-01-03 | 2006-06-30 | 390d? | 0d |  | GP | 11112h | 9372h | GSM710 | UTC | dcotton@mtview.union-tel.com | Rel-7 | Paolo | GSM710 |  |
| 4269 | 1088.1 | Inclusion of the 698 – 746 MHz band into GERAN core specifications |  | 129d? | 2005-01-03 A | 2005-06-30 A | 100% |  | 2005-01-03 | 2005-06-30 | 129d? |  | finish no earlier than 2005-06-30 | G1 | 1032h | 1032h | GSM710-core |  |  | Rel-7 | Paolo | GSM710-core |  |
| 4270 | 1088.2 | **Aspects of GSM710** |  | 217.5d? | 2005-08-31 A | 2006-06-30 | 100% | 0d? | 2005-08-31 | 2006-06-30 | 217.5d? | 0d |  | G1; G3new | 6960h | 5220h | GSM-710-test |  |  | Rel-7 | Paolo | GSM-710-test |  |
| 4271 | 1088.2.1 | G1 aspects of GSM710 |  | 217.5d? | 2005-08-31 A | 2006-06-30 A | 100% |  | 2005-08-31 | 2006-06-30 | 217.5d? |  | finish no earlier than 2006-06-30 | G1 | 1740h | 1740h |  |  |  | Rel-7 | Paolo |  |  |
| 4272 | 1088.2.2 | G3 aspects of GSM710 |  | 217.5d? | 2005-08-31 A | 2006-06-30 A | 100% |  | 2005-08-31 | 2006-06-30 | 217.5d? |  | finish no earlier than 2006-06-30 | G3new | 1740h | 1740h |  |  |  | Rel-7 | Ingbert |  |  |
| 4273 | 1089 | **Support of Conversational Services in A/Gb mode via the PS domain** |  | 626d? | 2005-04-08 A | 2007-08-31 A | 100% |  | 2005-04-08 | 2007-08-31 | 626d? |  |  | GP | 15442.8h | 15442.8h | SCSAGB | Ericsson | gunnar.hedby@ericsson.com | Rel-7 | Paolo | SCSAGB |  |
| 4274 | 1089.1 | Minimise the transfer delay between the SGSN and the MS |  | 604.95d? | 2005-04-08 A | 2007-08-31 A | 100% |  | 2005-04-08 | 2007-08-31 | 604.95d? |  | finish no earlier than 2007-08-31 | GP | 4839.6h | 4839.6h | SCSAGB-MTD | Ericsson | gunnar.hedby@ericsson.com | Rel-7 | Paolo | SCSAGB-MTD |  |
| 4275 | 1089.2 | Definition of radio resource management functionality for Support of Conversational Services in A/Gb mode via the PS domain |  | 626d? | 2005-04-08 A | 2007-08-31 A | 100% |  | 2005-04-08 | 2007-08-31 | 626d? |  | finish no earlier than 2007-08-31 | G1 | 5008h | 5008h | SCSAGB-RRM | Ericsson | gunnar.hedby@ericsson.com | Rel-7 | Paolo | SCSAGB-RRM |  |
| 4276 | 1089.3 | Support of Conversational Services in A/Gb mode via the PS domain – RLC Non-Persistent mode |  | 101d? | 2006-06-30 A | 2006-11-17 A | 100% |  | 2006-06-30 | 2006-11-17 | 101d? |  | finish no earlier than 2006-11-17 | G2 | 808h | 808h | SCSAGB-RLCNP | Ericsson | gunnar.hedby@ericsson.com | Rel-7 | Gert | SCSAGB-RLCNP |  |
| 4277 | 1089.4 | Deleted- Radio Channel Support | milestone | 0d? | 2006-07-17 A | 2006-07-17 A | 100% |  | 2006-07-17 | 2006-07-17 | 0d? |  | start no earlier than 2006-07-17 | G2 |  |  | SCSAGB-RCHS | Ericsson | gunnar.hedby@ericsson.com | Rel-7 | Gert | SCSAGB-RCHS | SP-32 |
| 4278 | 1089.5 | Deleted- Modifications to FLO | milestone | 0d? | 2006-07-17 A | 2006-07-17 A | 100% |  | 2006-07-17 | 2006-07-17 | 0d? |  | start no earlier than 2006-07-17 | G2 |  |  | SCSAGB-FLO | Ericsson | gunnar.hedby@ericsson.com | Rel-7 | Gert | SCSAGB-FLO | SP-32 |
| 4279 | 1090 | **Addition of new frequency band to GSM (T-GSM810)** |  | 626d? | 2005-04-08 A | 2007-08-31 A | 100% |  | 2005-04-08 | 2007-08-31 | 626d? |  |  | GP | 12112h | 12112h | TGSM810 | Huawei | chende@huawei.com | Rel-7 | Paolo | TGSM810 |  |
| 4280 | 1090.1 | Changes to core specification |  | 106d? | 2005-04-08 A | 2005-09-02 A | 100% |  | 2005-04-08 | 2005-09-02 | 106d? |  | finish no earlier than 2005-09-02 | GP | 848h | 848h | TGSM810-Core | Huawei | chende@huawei.com | Rel-7 | Paolo | TGSM810-Core |  |
| 4281 | 1090.2 | Changes to MS testing specification |  | 626d? | 2005-04-08 A | 2007-08-31 A | 100% |  | 2005-04-08 | 2007-08-31 | 626d? |  | finish no earlier than 2007-08-31 | G3new | 5008h | 5008h | TGSM810-MStest | Huawei | chende@huawei.com | Rel-7 | Ingbert | TGSM810-MStest |  |
| 4282 | 1090.3 | Changes to BTS testing specification |  | 156d? | 2005-04-08 A | 2005-11-11 A | 100% |  | 2005-04-08 | 2005-11-11 | 156d? |  | finish no earlier than 2005-11-11 | G1 | 1248h | 1248h | TGSM810-BTStest | Huawei | chende@huawei.com | Rel-7 | Paolo | TGSM810-BTStest |  |
| 4283 | 1091 | **Handover of dedicated and shared resources while in Dual Transfer Mode** |  | 421d? | 2005-04-08 A | 2006-11-17 A | 100% |  | 2005-04-08 | 2006-11-17 | 421d? |  |  | GP | 12672h | 12672h | HODSRDTM | Nokia | rami.vaittinen@nokia.com | Rel-7 | Paolo | HODSRDTM |  |
| 4284 | 1091.1 | GERAN2 part of Handover of dedicated and shared resources while in Dual Transfer Mode |  | 321d? | 2005-04-08 A | 2006-06-30 A | 100% |  | 2005-04-08 | 2006-06-30 | 321d? |  | finish no earlier than 2006-06-30 | G2 | 2568h | 2568h | HODSRDTM-G2 | Nokia | rami.vaittinen@nokia.com | Rel-7 | Gert | HODSRDTM-G2 |  |
| 4285 | 1091.2 | Deleted - MS Conformance Testing |  | 421d? | 2005-04-08 A | 2006-11-17 A | 100% |  | 2005-04-08 | 2006-11-17 | 421d? |  | finish no earlier than 2006-11-17 | G3new | 3368h | 3368h | HODSRDTM-MStest | Nokia | rami.vaittinen@nokia.com | Rel-7 | Ingbert | HODSRDTM-MStest | GP-32 |
| 4286 | 1091.3 | Deleted - BTS conformance testing |  | 421d? | 2005-04-08 A | 2006-11-17 A | 100% |  | 2005-04-08 | 2006-11-17 | 421d? |  | finish no earlier than 2006-11-17 | G1 | 3368h | 3368h | HODSRDTM-BTStest | Nokia | rami.vaittinen@nokia.com | Rel-7 | Paolo | HODSRDTM-BTStest | GP-32 |
| 4287 | 1092 | **Mobile Station Receive Diversity (DARP Phase II)** |  | 526d? | 2005-11-11 A | 2007-11-16 A | 100% |  | 2005-11-11 | 2007-11-16 | 526d? |  |  | GP | 16360h | 16360h | MSRD2 | Nokia | kent.pedersen@nokia.com | Rel-7 | Paolo | MSRD2 |  |
| 4288 | 1092.1 | Performance Requirements for Mobile Station Receive Diversity, DARP Phase II |  | 331d? | 2005-11-11 A | 2007-02-16 A | 100% |  | 2005-11-11 | 2007-02-16 | 331d? |  | finish no earlier than 2007-02-16 | GP | 2648h | 2648h | MSRD2-PerfReq | Nokia | kent.pedersen@nokia.com | Rel-7 | Paolo | MSRD2-PerfReq |  |
| 4289 | 1092.2 | Capability signalling of Mobile Station Receive Diversity, DARP Phase II |  | 331d? | 2005-11-11 A | 2007-02-16 A | 100% |  | 2005-11-11 | 2007-02-16 | 331d? |  | finish no earlier than 2007-02-16 | GP | 2648h | 2648h | MSRD2-CapSig | Nokia | kent.pedersen@nokia.com | Rel-7 | Paolo | MSRD2-CapSig |  |
| 4290 | 1092.3 | Test Scenarios for Mobile Station Receive Diversity, DARP Phase II |  | 331d? | 2005-11-11 A | 2007-02-16 A | 100% |  | 2005-11-11 | 2007-02-16 | 331d? |  | finish no earlier than 2007-02-16 | GP | 2648h | 2648h | MSRD2-TestSc | Nokia | kent.pedersen@nokia.com | Rel-7 | Paolo | MSRD2-TestSc |  |
| 4291 | 1092.4 | MS conformance test of DARP Phase II (MSRD) |  | 526d? | 2005-11-11 A | 2007-11-16 A | 100% |  | 2005-11-11 | 2007-11-16 | 526d? |  | finish no earlier than 2007-11-16 | GP | 4208h | 4208h | MSRD2-Msconf | Nokia | kent.pedersen@nokia.com | Rel-7 | Ingbert | MSRD2-Msconf |  |

Notes:
- 4268: -
- 4269: Completed / Impacted TSs and TRs: 24.008, 43.022, 44.018, 44.118, 45, 001, 45.005,
- 4270: -
- 4271: - / Impacted TSs and TRs: 51.021
- 4272: - / Impacted TSs and TRs: 51.010
- 4273: Originally started Nov. 2003 as GP-030443
- 4274: -
- 4275: -
- 4276: - / Impacted TSs and TRs: 43.955, 43.064, 44.060, 45.001, 45.002, 45.003, 45.005, 45.010, 51.010, 51.021
- 4277: -
- 4278: -
- 4279: - / Impacted TSs and TRs: 45.005, 45.050, 24.008, 45.008, 45.001, 43.022, 43.030, 44.018, 44.060, 51.010-1, 51.021
- 4280: - / Impacted TSs and TRs: 45.005, 45.050, 24.008, 45.008, 45.001, 43.022, 43.030, 44.018, 44.060
- 4281: - / Impacted TSs and TRs: 51010-1
- 4282: - / Impacted TSs and TRs: 51021
- 4283: GP#30 completed. Started at GP#24
- 4284: GP#30 completed / Impacted TSs and TRs: 43.055, 44.018, 44.060
- 4285: Stopped, no work done. 12/2008 Marked as stopped ("deleted") / Impacted TSs and TRs: 51-010
- 4286: Stopped, no work done. 12/2008 Marked as stopped ("deleted") / Impacted TSs and TRs: 51.026
- 4287: GP#36 completed
- 4288: GP#33 completed / Impacted TSs and TRs: 45.005
- 4289: GP#33 completed / Impacted TSs and TRs: 24.008
- 4290: GP#33 completed / Impacted TSs and TRs: 45.005
- 4291: GP#36 completed / Impacted TSs and TRs: 51.010

| ID | WBS | Task | Type | Duration | Start | Finish | Complete | Remaining | Baseline start | Baseline finish | Baseline duration | Total slack | Constraint | Resources | Work | Actual work | Acronym | WI rapporteur name | WI rapporteur e-mail | Release | MCC resp | Acronym_3GU_Export | TSG stopped |
| --- | --- | --- | --- | --- | --- | --- | --- | --- | --- | --- | --- | --- | --- | --- | --- | --- | --- | --- | --- | --- | --- | --- | --- |
| 4292 | 1093 | **Downlink Dual Carrier** |  | 947d? | 2006-01-20 A | 2009-09-04 A | 100% |  | 2006-01-20 | 2009-09-04 | 947d? |  |  | GP | 15446.6h | 15446.6h | GDCDL | Nokia Siemens Networks | leonardo.provvedi@roke.co.uk | Rel-7 | Paolo | GDCDL |  |
| 4293 | 1093.1 | Downlink Dual Carrier Stage 2 |  | 116d? | 2006-01-20 A | 2006-06-30 A | 100% |  | 2006-01-20 | 2006-06-30 | 116d? |  | finish no earlier than 2006-06-30 | G1 | 928h | 928h | GDCDL-Stage2 | Nokia Siemens Networks | leonardo.provvedi@roke.co.uk | Rel-7 | Paolo | GDCDL-Stage2 |  |
| 4294 | 1093.2 | Downlink Dual Carrier Stage 3 |  | 421d? | 2006-01-20 A | 2007-08-31 A | 100% |  | 2006-01-20 | 2007-08-31 | 421d? |  | finish no earlier than 2007-08-31 | G1 | 3368h | 3368h | GDCDL-Stage3 | Nokia Siemens Networks | leonardo.provvedi@roke.co.uk | Rel-7 | Paolo | GDCDL-Stage3 |  |
| 4295 | 1093.3 | Downlink Dual Carrier – MS Conformance Test |  | 446.82d? | 2006-01-20 A | 2009-09-04 A | 100% |  | 2006-01-20 | 2009-09-04 | 446.82d? |  | finish no earlier than 2009-09-04 | G3new | 3574.6h | 3574.6h | GDCDL-MStest | Nokia Siemens Networks | leonardo.provvedi@roke.co.uk | Rel-7 | Ingbert | GDCDL-MStest |  |
| 4296 | 1094 | Support of SIGTRAN in GERAN |  | 116d? | 2006-01-20 A | 2006-06-30 A | 100% |  | 2006-01-20 | 2006-06-30 | 116d? |  | finish no earlier than 2006-06-30 | GP | 928h | 928h | GSIGT | Ericsson | peter.ostrup@ericsson.com | Rel-7 | Ingbert | GSIGT |  |
| 4297 | 1095 | **Latency Reductions** |  | 306d? | 2006-06-30 A | 2007-08-31 A | 100% |  | 2006-06-30 | 2007-08-31 | 306d? |  |  | GP | 7344h | 7344h | LATRED | Ericsson | Hakan.Persson@Ericsson.com | Rel-7 | Paolo | LATRED |  |
| 4298 | 1095.1 | Improved Ack/Nack reporting |  | 306d? | 2006-06-30 A | 2007-08-31 A | 100% |  | 2006-06-30 | 2007-08-31 | 306d? |  | finish no earlier than 2007-08-31 | G2 | 2448h | 2448h | LATRED-ACKNAR | Ericsson | Hakan.Persson@Ericsson.com | Rel-7 | Gert | LATRED-ACKNAR |  |
| 4299 | 1095.2 | Reduced TTI |  | 306d? | 2006-06-30 A | 2007-08-31 A | 100% |  | 2006-06-30 | 2007-08-31 | 306d? |  | finish no earlier than 2007-08-31 | G2 | 2448h | 2448h | LATRED-REDTTI | Ericsson | Hakan.Persson@Ericsson.com | Rel-7 | Gert | LATRED-REDTTI |  |
| 4300 | 1096 | PS Handover between GERAN/UTRAN mode and GAN Mode |  | 166d? | 2006-06-30 A | 2007-02-16 A | 100% |  | 2006-06-30 | 2007-02-16 | 166d? |  | finish no earlier than 2007-02-16 | G2 | 1328h | 1328h | GUGAN | Ericsson | John.Diachina@Ericsson.com | Rel-7 | Gert | GUGAN |  |
| 4301 | 1097 | **Higher Uplink performance for GERAN Evolution** |  | 1227d? | 2006-09-08 A | 2011-05-20 A | 100% |  | 2006-09-08 | 2011-05-20 | 1227d? |  |  | GP | 37184h | 37184h | HUGE | Nokia Siemens Networks, Ericsson | eddie.riddington@nokia.com, stefan.g.eriksson@ericsson.com | Rel-7 | Paolo | HUGE |  |
| 4302 | 1097.1 | Stage 2 for HUGE |  | 261d? | 2006-09-08 A | 2007-09-07 A | 100% |  | 2006-09-08 | 2007-09-07 | 261d? |  | finish no earlier than 2007-09-07 | G1 | 2088h | 2088h | HUGE-Stage2 | Nokia Siemens Networks, Ericsson | eddie.riddington@nokia.com, stefan.g.eriksson@ericsson.com | Rel-7 | Paolo | HUGE-Stage2 |  |
| 4303 | 1097.2 | Layer 1 Support for HUGE |  | 381d? | 2006-09-08 A | 2008-02-22 A | 100% |  | 2006-09-08 | 2008-02-22 | 381d? |  | finish no earlier than 2008-02-22 | G1 | 3048h | 3048h | HUGE-Layer1 | Nokia Siemens Networks, Ericsson | eddie.riddington@nokia.com, stefan.g.eriksson@ericsson.com | Rel-7 | Paolo | HUGE-Layer1 |  |
| 4304 | 1097.3 | Layer 2/3 Support for HUGE |  | 256d? | 2006-09-08 A | 2007-08-31 A | 100% |  | 2006-09-08 | 2007-08-31 | 256d? |  | finish no earlier than 2007-08-31 | G2 | 2048h | 2048h | HUGE-Layer23 | Nokia Siemens Networks, Ericsson | eddie.riddington@nokia.com, stefan.g.eriksson@ericsson.com | Rel-7 | Gert | HUGE-Layer23 |  |
| 4305 | 1097.4 | Performance requirements for HUGE |  | 516d? | 2006-09-08 A | 2008-08-29 A | 100% |  | 2006-09-08 | 2008-08-29 | 516d? |  | finish no earlier than 2008-08-29 | G1 | 4128h | 4128h | HUGE-Perfreq | Nokia Siemens Networks, Ericsson | eddie.riddington@nokia.com, stefan.g.eriksson@ericsson.com | Rel-7 | Paolo | HUGE-Perfreq |  |
| 4306 | 1097.5 | BTS Conformance Test for HUGE |  | 782d? | 2006-09-08 A | 2009-09-04 A | 100% |  | 2006-09-08 | 2009-09-04 | 782d? |  | finish no earlier than 2009-09-04 | G1 | 6248h | 6248h | HUGE-BTStest | Nokia Siemens Networks, Ericsson | eddie.riddington@nokia.com, stefan.g.eriksson@ericsson.com | Rel-7 | Paolo | HUGE-BTStest |  |
| 4307 | 1097.6 | MS Conformance Test for HUGE |  | 1226d? | 2006-09-08 A | 2011-05-20 A | 100% |  | 2006-09-08 | 2011-05-20 | 1226d? |  | finish no earlier than 2011-05-20 | G3new | 9808h | 9808h | HUGE-Mstest | Nokia Siemens Networks, Ericsson | eddie.riddington@nokia.com, stefan.g.eriksson@ericsson.com | Rel-7 | Ingbert | HUGE-Mstest |  |
| 4308 | 1098 | **REduced symbol Duration, Higher Order modulation and Turbo coding (RED HOT) for downlink** |  | 1177d? | 2006-11-17 A | 2011-05-20 A | 100% |  | 2006-11-17 | 2011-05-20 | 1177d? |  |  | GP | 28808h | 28808h | REDHOT | Ericsson, Nokia Siemens Networks, Marvell | stefan.g.eriksson@ericsson.com | Rel-7 | Paolo | REDHOT |  |
| 4309 | 1098.1 | Stage 2 for REDHOT |  | 206d? | 2006-11-17 A | 2007-08-31 A | 100% |  | 2006-11-17 | 2007-08-31 | 206d? |  | finish no earlier than 2007-08-31 | G1 | 1648h | 1648h | REDHOT-Stage2 | Ericsson, Nokia Siemens Networks, Marvell | stefan.g.eriksson@ericsson.com | Rel-7 | Paolo | REDHOT-Stage2 |  |
| 4310 | 1098.2 | Stage 3 for REDHOT |  | 391d? | 2006-11-17 A | 2008-05-16 A | 100% |  | 2006-11-17 | 2008-05-16 | 391d? |  | finish no earlier than 2008-05-16 | G1 | 3128h | 3128h | REDHOT-Stage3 | Ericsson, Nokia Siemens Networks, Marvell | stefan.g.eriksson@ericsson.com | Rel-7 | Paolo | REDHOT-Stage3 |  |
| 4311 | 1098.3 | BTS Conformance Tests for REDHOT |  | 651d? | 2006-11-17 A | 2009-05-15 A | 100% |  | 2006-11-17 | 2009-05-15 | 651d? |  | finish no earlier than 2009-05-15 | G1 | 5208h | 5208h | REDHOT-BTStest | Ericsson, Nokia Siemens Networks, Marvell | stefan.g.eriksson@ericsson.com | Rel-7 | Paolo | REDHOT-BTStest |  |
| 4312 | 1098.4 | MS Conformance Tests for REDHOT |  | 1176d? | 2006-11-17 A | 2011-05-20 A | 100% |  | 2006-11-17 | 2011-05-20 | 1176d? |  | finish no earlier than 2011-05-20 | G3new | 9408h | 9408h | REDHOT-Mstest | Ericsson, Nokia Siemens Networks, Marvell | stefan.g.eriksson@ericsson.com | Rel-7 | Ingbert | REDHOT-Mstest |  |
| 4313 | 1099 | (Small) Technical Enhancements and Improvements for Rel-7 | milestone | 0d? | 2007-03-26 A | 2007-03-26 A | 100% |  | 2007-03-26 | 2007-03-26 | 0d? |  | start no earlier than 2007-03-26 | SP; CP; RP; GP |  |  | TEI7 |  |  | Rel-7 | All | TEI7 |  |
| 4314 | 1100 | Test - (Small) Technical Enhancements and Improvements for Rel-7 |  | 389d? | 2006-06-02 A | 2007-11-28 A | 100% |  | 2006-06-02 | 2007-11-28 | 389d? |  | finish no earlier than 2010-06-04 | R5 | 3112h | 3112h | TEI7_Test |  |  | Rel-7 | Ingbert | TEI7_Test |  |
| 4315 | 1101 | **Deleted - PS domain and IMS support for IMS Emergency sessions** |  | 63.69d? | 2006-06-23 A | 2006-09-21 | 99% | 0d? | 2006-06-23 | 2006-09-21 | 63.69d? | 0d |  | S2 |  |  | IMS-EMER | Nokia | curt.c.wong@nokia.com | Rel-7 | Maurice | IMS-EMER | SP-30 |
| 4316 | 1101.1 | Deleted - IMS aspects to support IMS Emergency sessions | milestone | 0d? | 2006-06-23 A | 2006-09-21 A | 100% |  | 2006-06-23 | 2006-09-21 | 0d? |  | start no earlier than 2006-06-23 | S2 |  |  |  | Nokia | curt.c.wong@nokia.com | Rel-7 | Maurice |  | SP-30 |
| 4317 | 1101.2 | Deleted - PS domain aspects to support IMS Emergency sessions | milestone | 0d? | 2006-06-23 A | 2006-09-21 A | 100% |  | 2006-06-23 | 2006-09-21 | 0d? |  | start no earlier than 2006-06-23 | S2 |  |  |  | Nokia | curt.c.wong@nokia.com | Rel-7 | Maurice |  | SP-30 |

Notes:
- 4292: GP#35 completed
- 4293: GP#30 completed / Impacted TSs and TRs: 43.055, 43.064
- 4294: GP#35 completed / Impacted TSs and TRs: 24.008, 44.018, 44.060, 45.001, 45.002, 45.005, 45.008
- 4295: GP#43 completed / Impacted TSs and TRs: 51.010
- 4296: GP#30 completed / Impacted TSs and TRs: 48.001, 48.006, 43.059, 49.031
- 4297: GP#35 completed / Impacted TSs and TRs: 45.001, 45.002, 45.003, 45.005, 45.010, 43.055, 43.064, 44.060, 51.010-1, 51.021
- 4298: GP#35 completed / Impacted TSs and TRs: 45.001, 45.002, 45.003, 45.005, 45.010, 43.055, 43.064, 44.060, 51.010-1, 51.021
- 4299: GP#35 completed / Impacted TSs and TRs: 45.001, 45.002, 45.003, 45.005, 45.010, 43.055, 43.064, 44.060, 51.010-1, 51.021
- 4300: GP#33 completed / Impacted TSs and TRs: 43.318, 44.318, 43.129, 25.306, 24.008, 44.060, 25.331, 51.010
- 4301: GP#39 completed
- 4302: GP#35 completed / Impacted TSs and TRs: 43.055, 43.064
- 4303: GP#37 completed / Impacted TSs and TRs: 45.001, 45.002, 45.003, 45.004, 45.008
- 4304: GP#35 completed / Impacted TSs and TRs: 24.008, 44.018, 44.060
- 4305: GP#39 completed / Impacted TSs and TRs: 45.005
- 4306: GP#43 completed / Impacted TSs and TRs: 51.021
- 4307: GP#50 completed / Impacted TSs and TRs: 51.010
- 4308: GP#38 completed
- 4309: GP#35 completed / Impacted TSs and TRs: 43.055, 43.064
- 4310: GP#38 completed / Impacted TSs and TRs: 24.008, 44.018, 44.060, 45.001, 45.002, 45.003, 45.004, 45.005, 45.008
- 4311: GP#42 completed / Impacted TSs and TRs: 51.021
- 4312: GP#50 completed / Impacted TSs and TRs: 51.010
- 4313: -
- 4314: -
- 4315: Approved at SP#29 / Impacted TSs and TRs: 23.867, 23.abc, 23.060, 23.002, 23.271
- 4316: Approved at SP#29 / Impacted TSs and TRs: 23.867, 23.abc, 23.060, 23.002, 23.271
- 4317: Approved at SP#29 / Impacted TSs and TRs: 23.867, 23.abc, 23.060, 23.002, 23.271

| ID | WBS | Task | Type | Duration | Start | Finish | Complete | Remaining | Baseline start | Baseline finish | Baseline duration | Total slack | Constraint | Resources | Work | Actual work | Acronym | Impacted TSs and TRs | Release | MCC resp | TSG stopped | Acronym_3GU_Export | WI rapporteur name | WI rapporteur e-mail | PCG approved | TSG approved | Special Focus Doc |
| --- | --- | --- | --- | --- | --- | --- | --- | --- | --- | --- | --- | --- | --- | --- | --- | --- | --- | --- | --- | --- | --- | --- | --- | --- | --- | --- | --- |
| 4318 | 16.7 | **Deleted - IMS Local services** |  | 0d? | 2006-01-06 A | 2006-01-06 | 99% | 0d? | 2006-01-06 | 2006-01-06 | 0d? | 0d |  | S2 |  |  | IMSLocal | 23.228 | Rel-7 | Maurice | SP-28 | IMSLocal |  |  |  |  |  |
| 4319 | 16.7.1 | Deleted - Stage 2 | milestone | 0d | 2006-01-06 A | 2006-01-06 A | 100% |  | 2006-01-06 | 2006-01-06 | 0d |  | start no earlier than 2006-01-06 | S2 |  |  |  |  | Rel-7 | Maurice | SP-26 |  |  |  |  |  |  |
| 4320 | 1102.2 | Deleted - Stage 3 for IMS Local services | milestone | 0d? | 2006-01-06 A | 2006-01-06 A | 100% |  | 2006-01-06 | 2006-01-06 | 0d? |  | finish no earlier than 2006-01-06 | C1 |  |  |  |  | Rel-7 | Frederic | SP-25 |  | Lucent | Keith Drage (drage@alcatel-lucent.com) |  |  |  |
| 4321 | 1103 | Deleted - IMS Phase 3 | milestone | 0d? | 2006-01-06 A | 2006-01-06 A | 100% |  | 2006-01-06 | 2006-01-06 | 0d? |  | start no earlier than 2006-01-06 | S2 |  |  |  |  | Rel-7 | Maurice | SP-25 |  |  |  |  |  |  |
| 4322 | 1104 | Deleted - Improvements of Radio Interface | milestone | 0d? | 2004-09-15 A | 2004-09-15 A | 100% |  | 2004-09-15 | 2004-09-15 | 0d? |  | start no earlier than 2004-09-15 | RP |  |  |  |  | Rel-7 | Issam | SP-24 |  |  |  | PCG-36 | RP-70 |  |
| 4323 | 1105 | Deleted: Generic User Profile Phase 2 | milestone | 0d | 2005-08-08 A | 2006-06-30 A | 100% |  | 2005-08-08 | 2006-06-30 | 0d |  |  | C4 |  |  |  |  | Rel-7 | Kimmo | SP-27 |  |  |  |  |  |  |
| 4324 | 30.4 | Deleted - Stage 3 - Common objects | milestone | 0d | 2005-08-08 A | 2006-06-30 A | 100% |  | 2005-08-08 | 2006-06-30 | 0d |  | finish no earlier than 2006-06-30 | C4 |  |  |  | 24.241 | Rel-7 | Kimmo | SP-27 |  |  |  |  |  |  |
| 4325 | 1107 | Release 7 Studies |  | 841d? | 2004-06-28 A | 2007-09-17 A | 100% |  | 2004-06-28 | 2007-09-17 | 841d? |  |  | CP; GP; RP; SP | 26912h | 26912h |  |  | Rel-7 | All |  |  |  |  |  |  |  |
| 4326 | 1108 | Study on Multimedia Telephony Capabilities for IMS |  | 276d? | 2005-07-11 A | 2006-07-31 A | 100% |  | 2005-07-11 | 2006-07-31 | 276d? |  |  | S1 | 2145.6h | 2145.6h | MITE | 22.973 | Rel-7 | Alain |  | MITE | Ericsson | peter.bleckert@ericsson.com |  |  |  |
| 4327 | 1109 | Study on Behaviour of Multi system UEs |  | 384d? | 2004-06-28 A | 2005-12-15 A | 100% |  | 2004-06-28 | 2005-12-15 | 384d? |  | start no earlier than 2004-06-28 | S1 | 3072h | 3072h | BMSU | 22.936 | Rel-7 | Alain |  | BMSU | Qualcomm | dwilliams@qualcomm.com |  |  |  |
| 4328 | 1110 | Study on Combining CS calls and IMS sessions |  | 189d? | 2004-06-28 A | 2005-03-17 A | 100% |  | 2004-06-28 | 2005-03-17 | 189d? |  | start no earlier than 2004-06-28 | S1 | 1512h | 1512h | IRTSD-CS_IMS | 22.979 | Rel-7 | Alain |  | IRTSD-CS_IMS | TeliaSonera | robert.frank@teliasonera.com |  |  |  |
| 4329 | 1111 | Study on All-IP Network |  | 188d? | 2004-06-28 A | 2005-03-16 A | 100% |  | 2004-06-28 | 2005-03-16 | 188d? |  | start no earlier than 2004-06-28 | S1 | 1504h | 1504h | FS_AIPN | 22.978 | Rel-7 | Alain |  | FS_AIPN | NTT DoCoMo | Shin-ichi Isobe (isobes@nttdocomo.co.jp) |  |  |  |
| 4330 | 1112 | Study on Videotelephony teleservice |  | 231d? | 2005-03-01 A | 2006-01-17 A | 100% |  | 2005-03-01 | 2006-01-17 | 231d? |  |  | S1 | 1848h | 1848h | VidTel | 22.903 | Rel-7 | Alain |  | VidTel | T-Mobile | michael.kurz@t-mobile.at |  |  |  |
| 4331 | 1113 | Study on Network Selection Principles |  | 193d? | 2005-03-15 A | 2005-12-08 A | 100% |  | 2005-03-15 | 2005-12-08 | 193d? |  |  | S1 | 1544h | 1544h | NetSel | 22.811 | Rel-7 | Alain |  | NetSel | O2 | chris.friel@O2.com |  |  |  |
| 4332 | 1114 | Study on Multimedia Priority Service |  | 851d? | 2003-03-28 A | 2006-06-30 A | 100% |  | 2003-03-28 | 2006-06-30 | 851d? |  | finish no earlier than 2005-12-16 | S1 | 6808h | 6808h | PRIOR-MM | 22.953 | Rel-7 | Alain |  | PRIOR-MM | Telcordia | James Garrahan (jgarraha@telcordia.com) |  |  | Public Safety (I-A) |
| 4333 | 1115 | Study on Transferring of emergency Call data |  | 190d? | 2005-07-11 A | 2006-03-31 A | 100% |  | 2005-07-11 | 2006-03-31 | 190d? |  | finish no earlier than 2005-12-08 | S1 | 1520h | 1520h | eCALL | 22.967 | Rel-7 | Alain |  | eCALL | Motorola | jian.j.wu@motorola.com |  |  | Public Safety (I-A) |
| 4334 | 1116 | Study on Enhancement of E2E QoS |  | 281.4d? | 2004-06-28 A | 2005-09-15 A | 100% |  | 2004-06-28 | 2005-09-15 | 281.4d? |  | finish no earlier than 2005-12-01 | S2 | 2251.2h | 2251.2h | QoS7 | 23.802 | Rel-7 | Maurice |  | QoS7 | Huawei | Robert Jaksa |  |  |  |
| 4335 | 1117 | Study on SOAP/HTTP IRP Solution Sets |  | 330d? | 2005-09-02 A | 2006-12-07 A | 100% |  | 2005-09-02 | 2006-12-07 | 330d? |  | finish no earlier than 2006-12-07 | S5 | 2640h | 2640h | OAM7-NIM-XML | 32.809 | Rel-7 | Mirko |  | OAM7-NIM-XML | Nortel | Suzèle Lariven (lariven@nortel.com) |  |  |  |
| 4336 | 1118 | Study on Itf-N Implementation Conformance Statement (ICS) template |  | 400d? | 2005-09-02 A | 2007-03-15 A | 100% |  | 2005-09-02 | 2007-03-15 | 400d? |  | finish no earlier than 2007-03-15 | S5 | 3200h | 3200h | OAM7-NIM-ICS | 32.812 | Rel-7 | Mirko |  | OAM7-NIM-ICS | China Mobile | Li Yewen (liyewen@chinamobile.com) |  |  |  |
| 4337 | 1119 | Study on IRP Information Model |  | 400d? | 2005-09-02 A | 2007-03-15 A | 100% |  | 2005-09-02 | 2007-03-15 | 400d? |  | finish no earlier than 2007-03-15 | S5 | 3200h | 3200h | OAM7-NIM-IM | 32.810 | Rel-7 | Mirko |  | OAM7-NIM-IM | Motorola | trevor.pirt@motorola.com |  |  |  |
| 4338 | 1120 | Study on Bandwidth Saving at Nb Interface with IP transport |  | 261d? | 2006-03-10 A | 2007-03-09 A | 100% |  | 2006-03-10 | 2007-03-09 | 261d? |  | finish no earlier than 2007-03-09 | C3 | 2088h | 2088h | BSNbIP | 29.814 | Rel-7 | Adrian |  | BSNbIP | Siemens | Thomas.Belling@siemens.com |  |  |  |
| 4339 | 1121 | Study on Routeing of MT-SMS via the HPLMN |  | 301d? | 2005-10-07 A | 2006-12-01 A | 100% |  | 2005-10-07 | 2006-12-01 | 301d? |  | finish no earlier than 2006-12-01 | C4 | 2408h | 2408h | SMS7 | 23.840 | Rel-7 | Kimmo |  | SMS7 | Vodafone | Nick.Russell@vodafone.com |  |  |  |
| 4340 | 1122 | Feasibility Study on the TCAPsec Gateway concept |  | 96d? | 2005-10-28 A | 2006-03-10 A | 100% |  | 2005-10-28 | 2006-03-10 | 96d? |  | finish no earlier than 2006-03-10 | C4 | 768h | 768h | FS_SEC7-TCAP | 29.800 | Rel-7 | Kimmo |  | FS_SEC7-TCAP | Siemens | Ulrich.wiehe@gksag.de |  |  |  |
| 4341 | 1123 | Study on using M2PA in 3GPP network |  | 318d? | 2006-03-22 A | 2007-06-08 A | 100% |  | 2006-03-22 | 2007-06-08 | 318d? |  | finish no earlier than 2007-06-08 | C4 | 2544h | 2544h | FS-M2PA | 29.801 | Rel-7 | Kimmo |  | FS-M2PA | China Mobile | zhaoyuyi@chinamobile.com |  |  |  |

Notes:
- 4318: -
- 4319: DAB - Not yet required in SA2 as it exists in previous releases
- 4320: -
- 4321: -
- 4322: Stage 2 description of Interim conclusion
- 4323: Created at TSG#27 by A. Sultan because of the move to Rel-7 of "Common Objects".
- 4324: No progress in CN4#26. This have to be moved to Rel-7. It was deleted from WID
- 4325: -
- 4326: Spin-off Feature UID_7038 (MTSI)
- 4327: -
- 4328: -
- 4329: 07/08 Moved to Rel-7 as Study out of stopped Rel-8 Feature UID_31067 All-IP Network (AIPN)
- 4330: -
- 4331: Spin-off Feature Network selection enhancements (NSP-CR) UID_7041
- 4332: Spin-off Feature PRIOR UID_340044
- 4333: -
- 4334: -
- 4335: SP#34 completed
- 4336: SP#35 completed
- 4337: SP#35 completed
- 4338: Moved to FS at CT32 (in line with slides)
- 4339: Previously known as "Study of a SMS Centre for MT SMS"
- 4340: TR 29.800 content moved to TS 29.204 under implementation WI UID_310005 TCAPsec Gateway
- 4341: -

| ID | WBS | Task | Type | Duration | Start | Finish | Complete | Remaining | Baseline start | Baseline finish | Baseline duration | Total slack | Constraint | Resources | Work | Actual work | Acronym | Impacted TSs and TRs | WI rapporteur name | WI rapporteur e-mail | Release | MCC resp | Acronym_3GU_Export | Status Report | TSG stopped | Special Focus Doc |
| --- | --- | --- | --- | --- | --- | --- | --- | --- | --- | --- | --- | --- | --- | --- | --- | --- | --- | --- | --- | --- | --- | --- | --- | --- | --- | --- |
| 4342 | 1124 | **Study on Support of (G)MSC-S - (G)MSC-S Nc Interface based on the SIP-I protocol** |  | 350d? | 2006-05-15 A | 2007-09-14 A | 100% |  | 2006-05-15 | 2007-09-14 | 350d? |  |  | C4; C3 | 10600h | 10600h | NcSIP | 29.802 | Vodafone | david.hutton@vodafone.com | Rel-7 | Kimmo | NcSIP |  |  |  |
| 4343 | 1124.1 | CT4 aspects of NcSIP |  | 275d? | 2006-05-15 A | 2007-06-01 A | 100% |  | 2006-05-15 | 2007-06-01 | 275d? |  | finish no earlier than 2007-06-01 | C4 | 2200h | 2200h |  | 29.802 | Vodafone | david.hutton@vodafone.com | Rel-7 | Kimmo |  |  |  |  |
| 4344 | 1124.2 | CT3 aspects of NcSIP |  | 350d? | 2006-05-15 A | 2007-09-14 A | 100% |  | 2006-05-15 | 2007-09-14 | 350d? |  | finish no earlier than 2007-09-14 | C3 | 2800h | 2800h |  | 29.802 | Ericsson | ragnar.huslende@ericsson.com | Rel-7 | Adrian |  |  |  |  |
| 4345 | 1125 | Study on Evolved UTRA and UTRAN |  | 458d? | 2004-12-15 A | 2006-09-15 A | 100% |  | 2004-12-15 | 2006-09-15 | 458d? |  | finish no earlier than 2006-09-15 | RP | 3664h | 3664h | RANFS-Evo | 25.912 | NTT DoCoMo | nakamurata@NTTDOCOMO.CO.JP | Rel-7 | Issam | RANFS-Evo | RP-060472 |  |  |
| 4346 | 1126 | Study on Performance Evaluation of the UE behaviour in high speed trains with speeds up to 350 kmph |  | 328d? | 2005-03-15 A | 2006-06-15 A | 100% |  | 2005-03-15 | 2006-06-15 | 328d? |  | finish no earlier than 2006-06-15 | R4 | 2624h | 2624h | RANFS-HSTrains | none | Vodafone | Mike.vogel@vodafone.com,tim.frost@vodafone.com | Rel-7 | Issam | RANFS-HSTrains | RP-060412 |  |  |
| 4347 | 1127 | Study on UTRA Tower Mounted Amplifier (FDD) |  | 195d? | 2005-06-15 A | 2006-03-14 A | 100% |  | 2005-06-15 | 2006-03-14 | 195d? |  | finish no earlier than 2006-03-15 | R4 | 1560h | 1560h | RANFS-TMA | 25.818 | Ericsson | Klas.Sjerling@ericsson.com | Rel-7 | Issam | RANFS-TMA | RP-060035 |  |  |
| 4348 | 1128 | Study on Continuous connectivity for packet data users |  | 132d? | 2005-03-15 A | 2005-09-14 A | 100% |  | 2005-03-15 | 2005-09-14 | 132d? |  | finish no earlier than 2005-09-15 | R1 | 1056h | 1056h | RANFS-cont-packet | none | Siemens | joerg.gustrau@siemens.com | Rel-7 | Patrick | RANFS-cont-packet | RP-050427 |  |  |
| 4349 | 1129 | Study on Improvement of the Multimedia Broadcast Multicast Service (MBMS) in UTRAN |  | 262d? | 2005-12-15 A | 2006-12-15 A | 100% |  | 2005-12-15 | 2006-12-15 | 262d? |  | finish no earlier than 2006-12-15 | R2 | 2096h | 2096h | RANFS-MBMSImp | 25.905 | LG Electronics | leego@lge.com | Rel-7 | Yong-Jun | RANFS-MBMSImp | RP-060692 |  |  |
| 4350 | 1130 | Deleted - Study on Performance Improvements in Small Cells using HSDPA/EDCH |  | 131d? | 2005-12-15 A | 2006-06-15 A | 100% |  | 2005-12-15 | 2006-06-15 | 131d? |  | finish no earlier than 2006-06-15 | R1; R4 | 2096h | 2096h | SMALLCELLS | none | Cingular | Marc Grant | Rel-7 | Issam | SMALLCELLS | RP-060263 | SP-69 | Small cell |
| 4351 | 1131 | Study on Further Improved Performance Requirements for UMTS/HSDPA UE (FDD) |  | 383d? | 2005-12-15 A | 2007-06-04 A | 100% |  | 2005-12-15 | 2007-06-04 | 383d? |  | finish no earlier than 2007-06-04 | R4 | 3064h | 3064h | RANFS-IC | 25.963 | Cingular | Marc Grant | Rel-7 | Issam | RANFS-IC | RP-070499 |  |  |
| 4352 | 1132 | Study on Scope of future FDD HSPA Evolution |  | 394d? | 2006-03-15 A | 2007-09-17 A | 100% |  | 2006-03-15 | 2007-09-17 | 394d? |  | finish no earlier than 2007-09-17 | RP | 3152h | 3152h | RANFS-HSPAEvo | 25.999 | Cingular | Don Zelmer (dz1069@att.com) | Rel-7 | Issam | RANFS-HSPAEvo | RP-070533 |  |  |
| 4353 | 1133 | Study on Dynamically reconfiguring a FDD UE receiver to reduce power consumption when desired Quality of Service is met | milestone | 0d? | 2007-06-22 A | 2007-06-22 A | 100% |  | 2007-06-22 | 2007-06-22 | 0d? |  |  | R4 |  |  | FSUEPow | 25.906 | Nokia | Chris.callender@nokia.com, tiina.s.koskinen@nokia.com | Rel-7 | Issam | FSUEPow | RP-070534 |  |  |
| 4354 | 1134 | Study on Future GERAN Evolution |  | 486d? | 2005-04-08 A | 2007-02-16 A | 100% |  | 2005-04-08 | 2007-02-16 | 486d? |  | finish no earlier than 2007-02-16 | GP | 3888h | 3888h | FGE | 45.912 | Nokia | eddie.riddington@nokia.com | Rel-7 | Paolo | FGE |  |  |  |
| 4355 | 1135 | Study on GAN Enhancements | milestone | 0d? | 2007-08-31 A | 2007-08-31 A | 100% |  | 2007-08-31 | 2007-08-31 | 0d? |  | start no earlier than 2007-08-31 | GP |  |  | EGAN | 43.902 | T-Mobile | janne.linkola@t-mobile.com | Rel-7 | Paolo | EGAN |  |  |  |
| 4356 | 1136 | Deleted - Study on IMS with real time services deployment |  | 316d? | 2004-06-28 A | 2005-09-12 A | 100% |  | 2004-06-28 | 2005-09-12 | 316d? |  |  | S1 | 2528h | 2528h | IRTSD |  |  |  | Rel-7 | Alain | IRTSD |  | SP-30 |  |
| 4357 | 1137 | Deleted - Covered by SI - Personal Network (PN) and Personal Area Network (PAN) | milestone | 0d? | 2005-12-08 A | 2005-12-20 A | 100% |  | 2005-12-08 | 2005-12-20 | 0d? |  | start no earlier than 2005-12-08 | S1 |  |  | PNPAN |  | Vodafone | armin.toepfer@vodafone.com | Rel-7 | Alain | PNPAN |  | SP-30 |  |
| 4358 | 1138 | Deleted - Study on Customised Alerting Tone (CAT) Requirements (was duplicated) | milestone | 0d? | 2006-06-30 A | 2006-06-30 A | 100% |  | 2006-06-30 | 2006-06-30 | 0d? |  | start no earlier than 2006-06-30 | S1 |  |  |  |  |  |  | Rel-7 | Alain |  |  | SP-31 |  |
| 4359 | 1139 | Deleted - IMS security extensions (covered by UID33027) | milestone | 0d? | 2005-12-08 A | 2005-12-08 A | 100% |  | 2005-12-08 | 2005-12-08 | 0d? |  | start no earlier than 2005-12-08 | S3 |  |  | IMS-SE |  | Ericsson | Bengt.Sahlin@ericsson.com | Rel-7 | Mirko | IMS-SE |  | SP-30 |  |
| 4360 | 1140 | **Deleted - Study on applicability of GALILEO for LCS** |  | 0d? | 2005-06-30 A | 2005-06-30 | 99% | 0d? | 2005-06-30 | 2005-06-30 | 0d? | 0d |  | S2 |  |  | Galileo |  |  |  | Rel-7 | Maurice | Galileo |  | SP-25 |  |
| 4361 | 1140.1 | Deleted - TR on Stage 2 | milestone | 0d? | 2005-06-30 A | 2005-06-30 A | 100% |  | 2005-06-30 | 2005-06-30 | 0d? |  | finish no earlier than 2005-06-30 | S2 |  |  |  |  |  |  | Rel-7 | Maurice |  |  | SP-25 |  |
| 4362 | 1140.2 | Deleted - GERAN review of the TR | milestone | 0d? | 2005-06-30 A | 2005-06-30 A | 100% |  | 2005-06-30 | 2005-06-30 | 0d? |  | start no earlier than 2005-06-30 | GP |  |  |  |  |  |  | Rel-7 | Paolo |  |  | SP-26 |  |
| 4363 | 1141 | Deleted - Study on Stage 2 (IMS services using CS bearers) |  | 316d? | 2004-06-28 A | 2005-09-12 A | 100% |  | 2004-06-28 | 2005-09-12 | 316d? |  | finish no earlier than 2005-09-12 | S2 | 2528h | 2528h | IRTSD-IMSCS | 23.899 | Nortel | Mark Watson | Rel-7 | Maurice | IRTSD-IMSCS |  | SP-30 |  |
| 4364 | 1142 | **Deleted - VoIMS bearer related enhancements** |  | 0d? | 2006-07-21 A | 2006-07-21 | 99% | 0d? | 2006-07-21 | 2006-07-21 | 0d? | 0d |  | S2 |  |  | VoIMS |  |  |  | Rel-7 | Maurice | VoIMS |  | SP-32 |  |
| 4365 | 1142.1 | Deleted - Study on enhancement of radio performance for VoIMS | milestone | 0d? | 2006-07-21 A | 2006-07-21 A | 100% |  | 2006-07-21 | 2006-07-21 | 0d? |  | start no earlier than 2006-07-21 | S2 |  |  |  | 23.807 | Nortel | Laurence Lautier (lautierl@nortel.com) | Rel-7 | Maurice |  |  | SP-32 |  |
| 4366 | 1143 | Deleted - Study on IMS enhancements and optimizations for real time communication. |  | 430d? | 2005-10-10 A | 2007-06-01 A | 100% |  | 2005-10-10 | 2007-06-01 | 430d? |  | finish no earlier than 2007-06-01 | S2 | 3440h | 3440h | IMS-RT | 23.818 | Ericsson | stephen.terrill@ericsson.com | Rel-7 | Maurice | IMS-RT |  | SP-35 |  |
| 4367 | 1144 | Deleted - Study on Terminating Session handling |  | 255d? | 2006-01-09 A | 2006-12-29 A | 100% |  | 2006-01-09 | 2006-12-29 | 255d? |  | finish no earlier than 2006-12-29 | S2 | 2040h | 2040h | CSIterm | 23.819 | Samsung |  | Rel-7 | Maurice | CSIterm |  | SP-32 |  |
| 4368 | 1145 | Deleted eCALLIBMS - Study on Transferring of emergency call data – in-band modem solution (moved to Rel-8) | milestone | 0d? | 2007-06-22 A | 2007-06-22 A | 100% |  | 2007-06-22 | 2007-06-22 | 0d? |  | start no earlier than 2007-06-22 | S4 |  |  |  | 26.967 | Airbiquity | lhong@airbiquity.com | Rel-7 | Paolo |  |  | SP-38 | Public Safety (I-A) |
| 4369 | 1146 | Deleted - Study on IRP usage scenarios |  | 330d? | 2005-09-02 A | 2006-12-07 A | 100% |  | 2005-09-02 | 2006-12-07 | 330d? |  | finish no earlier than 2006-12-07 | S5 | 2640h | 2640h | OAM-Study | 32.8xy | Lucent |  | Rel-7 | Mirko | OAM-Study |  | SP-32 |  |
| 4370 | 1147 | Deleted - Study on Interference Cancellation for UTRA FDD UE (covered by UID 20053) |  | 1d? | 2007-03-28 A | 2007-03-28 A | 100% |  | 2007-03-28 | 2007-03-28 | 1d? |  | start no earlier than 2007-03-28 | R4 | 8h | 8h | RANFS-InterfCanc |  |  |  | Rel-7 | Issam | RANFS-InterfCanc |  | SP-38 |  |
| 4371 | 1148 | Deleted - Study on enhanced support of Video Telephony | milestone | 0d? | 2006-06-30 A | 2006-06-30 A | 100% |  | 2006-06-30 | 2006-06-30 | 0d? |  | start no earlier than 2006-06-30 | GP |  |  | VIDGER |  | Ericsson | stefan.g.eriksson@ericsson.com | Rel-7 | Paolo | VIDGER |  | SP-32 |  |
| 4372 | 1149 | Release 6 Features |  | 915d? | 2002-06-28 A | 2005-12-30 A | 100% |  | 2002-06-28 | 2005-12-30 | 915d? |  |  | NP; GP; RP; SP; TP | 36600h | 36600h |  |  |  |  | Rel-6 | All |  |  |  |  |

Notes:
- 4342: -
- 4343: -
- 4344: -
- 4345: RP#33 (Sep 2006) completed. SR in RP-060472
- 4346: RP#32 (Jun 2006) completed. SR in RP-060412
- 4347: RP#31 (Mar 2006) completed. SR in RP-060035
- 4348: RP#29 (Sep 2006) completed. SR in RP-050427
- 4349: RP#34 completed
- 4350: RP#32 (Jun 2006) stopped at 0% completion
- 4351: RP#36 (May 2007) completed. SR in RP-070499
- 4352: RP#37 (Sep 2007) completed. SR in RP-070533
- 4353: RP#37 (Sep 2007) completed. SR in RP-070534
- 4354: GP#33 completed
- 4355: GP#35 completed
- 4356: -
- 4357: -
- 4358: Awaiting MCC SA3 input
- 4359: -
- 4360: -
- 4361: -
- 4362: -
- 4363: SP-30: S2 has no intention for TR completion
- 4364: Created by MCC to group all VoIMS related items, after consultation of chairs
- 4365: WID approved SP#28. SA2#52 stopped
- 4366: abandoned at 65%
- 4367: SP#32 Jun 2006 Study abandoned => spin-off Implementation work UID_320029
- 4368: SP-38 stopped
- 4369: -
- 4370: Deleted. Same as FS on Further Improved Performance Requirements for UMTS/HSDPA UE (FDD)
- 4371: FS CLOSED at G#28 (no input)
- 4372: -

| ID | WBS | Task | Type | Duration | Start | Finish | Complete | Baseline start | Baseline finish | Baseline duration | Constraint | Resources | Work | Actual work | Release | Acronym | WI rapporteur name | WI rapporteur e-mail | MCC resp | Acronym_3GU_Export | Impacted TSs and TRs | Created at | TSG stopped |
| --- | --- | --- | --- | --- | --- | --- | --- | --- | --- | --- | --- | --- | --- | --- | --- | --- | --- | --- | --- | --- | --- | --- | --- |
| 4373 | 8 | **Rel-6 Improvements of Radio Interface** |  | 1645d? | 2000-08-14 A | 2006-12-01 A | 100% | 2000-08-14 | 2006-12-01 | 1645d? |  | R2; R4; R5 | 87632h | 87632h | Rel-6 |  |  |  |  |  |  |  |  |
| 4374 | 1150.1 | Improved support of IMS Realtime Services using HSDPA/EDCH |  | 197d? | 2005-03-15 A | 2005-12-14 A | 100% | 2005-03-15 | 2005-12-14 | 197d? | finish no earlier than 2005-12-14 | R2 | 1576h | 1576h | Rel-6 | RInImp-IMSRealTime | Cingular | Don Zelmer (dz1069@att.com) | Yong-Jun | RInImp-IMSRealTime |  |  |  |
| 4375 | 1150.2 | Improving Receiver Performance Requirements for the FDD UE |  | 401d | 2002-03-08 A | 2003-09-19 A | 100% | 2002-03-08 | 2003-09-19 | 401d | start no earlier than 2002-03-08 | R4 | 3208h | 3208h | Rel-6 | RInImp-UERecPerf | Intel | shimon.moshavi@INTEL.COM | Issam | RInImp-UERecPerf | 25.101 |  |  |
| 4376 | 8.2 | **Base station classification for FDD** |  | 603d | 2000-08-14 A | 2002-12-04 A | 100% | 2000-08-14 | 2002-12-04 | 603d |  | R4 | 9648h | 9648h | Rel-6 | RInImp-BSClass-FDD |  |  | Issam | RInImp-BSClass-FDD |  |  |  |
| 4377 | 8.2.1 | FDD Base station classification |  | 603d | 2000-08-14 A | 2002-12-04 A | 100% | 2000-08-14 | 2002-12-04 | 603d | finish no earlier than 2002-12-04 | R4 | 4824h | 4824h | Rel-6 |  | Nokia | antti.toskala@nokia.com | Issam |  | 25.104, 25.141 |  |  |
| 4378 | 1150.4 | UMTS-850 |  | 266d | 2002-12-06 A | 2003-12-12 A | 100% | 2002-12-06 | 2003-12-12 | 266d | finish no earlier than 2003-12-15 | R4 | 2128h | 2128h | Rel-6 | RInImp-UMTS850 | Cingular | Don Zelmer (dz1069@att.com) | Issam | RInImp-UMTS850 | 25.101, 25.104, 25.133, 25.141, 25.307, 25.331, 25.942 |  |  |
| 4379 | 1150.5 | DS-CDMA introduction in the 800 MHz band |  | 196d | 2003-03-14 A | 2003-12-12 A | 100% | 2003-03-14 | 2003-12-12 | 196d | finish no earlier than 2003-12-15 | R4 | 1568h | 1568h | Rel-6 | RInImp-UMTS800 | NTT DoCoMo | Takehiro Nakamura (nakamurata@nttdocomo.co.jp) | Issam | RInImp-UMTS800 | 25.101, 25.104, 25.133, 25.141, 25.307, 25.331 |  |  |
| 4380 | 1150.6 | UMTS 1.7/2.1 GHz | milestone | 0d? | 2003-03-14 A | 2003-03-14 A | 100% | 2003-03-14 | 2003-03-14 | 0d? |  | R4 |  |  | Rel-6 | RInImp-UMTS1721 | Nokia | jussi.numminen@NOKIA.COM | Issam | RInImp-UMTS1721 | 25.101, 25.104, 25.133, 25.141, 25.307, 25.331 |  |  |
| 4381 | 1150.7 | Conformance Test Aspects – UMTS 1.7/2.1 GHz Band |  | 191d? | 2006-03-10 A | 2006-12-01 A | 100% | 2006-03-10 | 2006-12-01 | 191d? | finish no earlier than 2006-12-01 | R5 | 1528h | 1528h | Rel-6 | RInImp-UMTS1721_Test | Motorola | carolyn.taylor@motorola.com | Ingbert | RInImp-UMTS1721_Test | TS34.121, TS34.108 |  |  |
| 4382 | 1150.8 | **Improved Receiver Performance Requirements for HSDPA** |  | 711d | 2003-09-19 A | 2006-06-09 A | 100% | 2003-09-19 | 2006-06-09 | 711d |  | R4; R5 | 28496h | 28496h | Rel-6 | RInImp-HSPerf | Nokia | jussi.numminen@NOKIA.COM | Issam | RInImp-HSPerf |  |  |  |
| 4383 | 1150.8.1 | Improved Minimum Performance Requirements for HSDPA UE categories 7 and 8 |  | 453d | 2004-09-15 A | 2006-06-09 A | 100% | 2004-09-15 | 2006-06-09 | 453d |  | R4 | 3624h | 3624h | Rel-6 | RInImp-HSPerf-10code | Nokia | jussi.numminen@nokia.com | Issam | RInImp-HSPerf-10code | 25.101 |  |  |
| 4384 | 1150.8.2 | Testing of Improved Minimum Performance for HSDPA |  | 650d | 2003-09-19 A | 2006-03-16 A | 100% | 2003-09-19 | 2006-03-16 | 650d | finish no earlier than 2006-03-16 | R5 | 5200h | 5200h | Rel-6 | RInImp-HSPerf-10Code_Test | Motorola | carolyn.taylor@motorola.com | Ingbert | RInImp-HSPerf-10Code_Test | 34.108, 34.121, 34.122, 34.123-1, 34.123-2, 34.123-3 | 19/9/2003 |  |
| 4385 | 1150.8.3 | Performance Requirements of Receive Diversity for HSDPA |  | 387d | 2003-12-15 A | 2005-06-07 A | 100% | 2003-12-15 | 2005-06-07 | 387d |  | R4 | 3096h | 3096h | Rel-6 | RInImp-HSPerf-RxDiv | NTT DoCoMo | Takehiro Nakamura (nakamurata@nttdocomo.co.jp) | Issam | RInImp-HSPerf-RxDiv | 25.101 |  |  |
| 4386 | 1150.8.4 | Testing of Performance of Receiver diversity for HSDPA |  | 650d | 2003-09-19 A | 2006-03-16 A | 100% | 2003-09-19 | 2006-03-16 | 650d | finish no earlier than 2006-03-16 | R5 | 5200h | 5200h | Rel-6 | RInImp-HSPerf-RxDiv_Test | Motorola | carolyn.taylor@motorola.com | Ingbert | RInImp-HSPerf-RxDiv_Test | 34.108, 34.121, 34.122, 34.123-1, 34.123-2, 34.123-3 | 19/9/2003 |  |
| 4387 | 1151 | **Rel-6 RAN Feasibility Studies** |  | 1196d? | 2000-08-14 A | 2005-03-14 A | 100% | 2000-08-14 | 2005-03-14 | 1196d? |  | RP | 43048h | 43048h | Rel-6 |  |  |  |  |  |  |  |  |
| 4388 | 1151.1 | FS of the improved access to UE measurement data for CRNC to support TDD RRM |  | 270d? | 2002-12-06 A | 2003-12-18 A | 100% | 2002-12-06 | 2003-12-18 | 270d? | finish no earlier than 2003-09-19 | R3 | 2160h | 2160h | Rel-6 | RANimp-RRMopt-FSUEMsD | Interdigital | jim.miller@interdigital.com | Juha | RANimp-RRMopt-FSUEMsD | 25.801, 25.423 | SP-24 |  |
| 4389 | 1151.2 | FS on Radio link performance enhancements |  | 1067d | 2000-08-14 A | 2004-09-14 A | 100% | 2000-08-14 | 2004-09-14 | 1067d | finish no earlier than 2004-09-14 | R1 | 8536h | 8536h | Rel-6 | RInImp-Rlperf | Nokia | antti.toskala@nokia.com | Patrick | RInImp-Rlperf | 25.899 |  |  |
| 4390 | 1151.3 | FS on Improvement of inter-frequency and inter-system measurements for 1.28 Mcps TDD |  | 461d | 2001-12-14 A | 2003-09-19 A | 100% | 2001-12-14 | 2003-09-19 | 461d | start no earlier than 2001-12-14 | R1 | 3688h | 3688h | Rel-6 | RInImp-IfIsMLCR | Samsung | Li Xiao Qiang (xqli@samsung.co.kr) | Patrick | RInImp-IfIsMLCR | 25.888 |  |  |
| 4391 | 1151.4 | FS for the analysis of OFDM for UTRAN enhancement |  | 526d | 2002-06-10 A | 2004-06-14 A | 100% | 2002-06-10 | 2004-06-14 | 526d | start no earlier than 2002-06-10 | R1 | 4208h | 4208h | Rel-6 | RInImp-FSOFDM | Nortel | Sarah Boumendil | Patrick | RInImp-FSOFDM | 25.892 |  |  |
| 4392 | 1151.5 | FS on Uplink Enhancements for Dedicated Transport Channels |  | 396d | 2002-09-06 A | 2004-03-12 A | 100% | 2002-09-06 | 2004-03-12 | 396d | finish no earlier than 2004-03-12 | R1 | 3168h | 3168h | Rel-6 | RInImp-FSUpDTrCh | Nokia | Karri.Ranta-aho@nsn.com | Patrick | RInImp-FSUpDTrCh | 25.896 |  |  |
| 4393 | 1151.6 | FS on Analysis on Higher Chip Rates for UTRA TDD evolutions |  | 528d | 2002-09-06 A | 2004-09-14 A | 100% | 2002-09-06 | 2004-09-14 | 528d | finish no earlier than 2004-09-14 | R1 | 4224h | 4224h | Rel-6 | RInImp-FSVHCRTDD | IPWireless | mbeale@ipwireless.com | Patrick | RInImp-FSVHCRTDD | 25.895 |  |  |
| 4394 | 1151.7 | FS on Low Output Powers for general purpose FDD BSs |  | 128d | 2003-06-13 A | 2004-03-12 A | 100% | 2003-06-13 | 2004-03-12 | 128d | finish no earlier than 2004-03-12 | R3 | 1024h | 1024h | Rel-6 | RInImp-FSLoPw | Telefónica | Ana Burgos (burgos_a@tsm.es) | Juha | RInImp-FSLoPw | 25.807 |  |  |
| 4395 | 1151.8 | FS on Uplink enhancements for UTRA TDD |  | 462d | 2003-06-06 A | 2005-03-14 A | 100% | 2003-06-06 | 2005-03-14 | 462d | finish no earlier than 2005-03-14 | R1 | 3696h | 3696h | Rel-6 | RInImp-FSUpEnhTDD | Interdigital | Marian.Rudolf@InterDigital.com | Patrick | RInImp-FSUpEnhTDD | 25.804 |  |  |
| 4396 | 8.8 | FS on UE antenna efficiency test methods performance requirements (2) |  | 131d | 2002-03-08 A | 2002-09-06 A | 100% | 2002-03-08 | 2002-09-06 | 131d | finish no earlier than 2002-09-06 | R4 | 1048h | 1048h | Rel-6 | RInImp-UEAnTM2 | Allgon | Alf Ahlström (alf.ahlstrom@pwav.com) | Issam | RInImp-UEAnTM2 |  |  |  |
| 4397 | 9.4 | Deleted - FS on the evolution of the UTRAN architecture |  | 592d | 2002-09-09 A | 2004-12-14 A | 100% | 2002-09-09 | 2004-12-14 | 592d | finish no earlier than 2004-12-15 | R3 | 4736h | 4736h | Rel-6 | RANimp-FSEvo | Nokia | woonhee.hwang@nsn.com, Antti.Toskala@nokia.com | Juha | RANimp-FSEvo |  |  | RP-26 |

Notes:
- 4373: -
- 4374: -
- 4375: -
- 4376: -
- 4377: -
- 4378: Introduction of UMTS850 (Band V) in 25.307
- 4379: Introduction of UMTS800 in 25.307
- 4380: Introduction of UMTS1700/2100 (Band IV)
- 4381: -
- 4382: -
- 4383: Approved at RP#25 as RP-040375
- 4384: -
- 4385: -
- 4386: -
- 4387: -
- 4388: -
- 4389: Study finished at RP#25
- 4390: -
- 4391: -
- 4392: -
- 4393: Study finished at RP#25
- 4394: -
- 4395: -
- 4396: The RInImp-UEAnTM FS was re-opened at TSG RP#15 upon request from WG4
- 4397: Study Closed, work will continue within the FS on evolved UTRA and UTRAN

| ID | WBS | Task | Type | Duration | Start | Finish | Complete | Baseline start | Baseline finish | Baseline duration | Constraint | Deadline | Resources | Work | Actual work | Acronym | WI rapporteur name | WI rapporteur e-mail | Release | MCC resp | Acronym_3GU_Export | Impacted TSs and TRs | Created at | TSG stopped |
| --- | --- | --- | --- | --- | --- | --- | --- | --- | --- | --- | --- | --- | --- | --- | --- | --- | --- | --- | --- | --- | --- | --- | --- | --- |
| 4398 | 1152 | **FDD Enhanced Uplink** |  | 915d | 2004-03-15 A | 2007-09-14 A | 100% | 2004-03-15 | 2007-09-14 | 915d |  |  | R2; R1; R3; R4; R5 | 49800h | 49800h | EDCH | Ericsson | Joakim Bergström | Rel-6 | Yong-Jun | EDCH |  |  |  |
| 4399 | 1152.1 | FDD Enhanced Uplink - Stage 2 |  | 197d | 2004-03-15 A | 2004-12-14 A | 100% | 2004-03-15 | 2004-12-14 | 197d | finish no earlier than 2004-12-14 |  | R2 | 1576h | 1576h | EDCH-Stage2 |  |  | Rel-6 | Yong-Jun | EDCH-Stage2 | 25.309 |  |  |
| 4400 | 1152.2 | FDD Enhanced Uplink - Physical Layer |  | 261d | 2004-03-15 A | 2005-03-14 A | 100% | 2004-03-15 | 2005-03-14 | 261d | finish no earlier than 2005-03-14 |  | R1 | 2088h | 2088h | EDCH-Phys | Nokia | Karri.Ranta-aho@nsn.com | Rel-6 | Patrick | EDCH-Phys | 25.211, 25.212, 25.213, 25.214, 25.215 |  |  |
| 4401 | 1152.3 | FDD Enhanced Uplink - Layer 2 and 3 Protocol Aspects |  | 261d | 2004-03-15 A | 2005-03-14 A | 100% | 2004-03-15 | 2005-03-14 | 261d | finish no earlier than 2005-03-14 |  | R2 | 2088h | 2088h | EDCH-L23 | Ericsson | Joakim Bergström | Rel-6 | Yong-Jun | EDCH-L23 | 25.301, 25.302, 25.306, 25.321, 25.331 |  |  |
| 4402 | 1152.4 | FDD Enhanced Uplink - UTRAN Iub/Iur Protocol Aspects |  | 261d | 2004-03-15 A | 2005-03-14 A | 100% | 2004-03-15 | 2005-03-14 | 261d | finish no earlier than 2005-03-14 |  | R3 | 2088h | 2088h | EDCH-IurIub | Nortel | Saso Stojanovski | Rel-6 | Juha | EDCH-IurIub | 25.401, 25.420, 25.423, 25.430, 25.433 |  |  |
| 4403 | 1152.5 | FDD Enhanced Uplink - RF Radio Transmission/ Reception, System Performance Requirements and Conformance Testing |  | 74d | 2004-03-15 A | 2004-06-24 A | 100% | 2004-03-15 | 2004-06-24 | 74d |  |  | R4 | 592h | 592h | EDCH-RF | Ericsson | thomas.unshelm@ericsson.com | Rel-6 | Issam | EDCH-RF | 25.101, 25.104, 25.133, 25.141 |  |  |
| 4404 | 1152.6 | Conformance Test Aspects – FDD Enhanced Uplink |  | 596d | 2005-06-03 A | 2007-09-14 A | 100% | 2005-06-03 | 2007-09-14 | 596d | finish no earlier than 2007-09-14 | 2006-06-02 | R5 | 4768h | 4768h | EDCH_Test | Ericsson | Leif.Mattisson@ericsson.com | Rel-6 | Ingbert | EDCH_Test | 34.108, 34.109, 34.121, 34.123-1, 34.123-2, 34.123-3 | Fri 03/06/05 |  |
| 4405 | 1153 | **Rel-6 RAN improvements** |  | 656d? | 2002-09-09 A | 2005-03-14 A | 100% | 2002-09-09 | 2005-03-14 | 656d? |  |  | RP; S5 | 36720h | 36720h |  |  |  | Rel-6 |  |  |  |  |  |
| 4406 | 9.2 | **RAB support enhancement** |  | 522d? | 2003-03-14 A | 2005-03-14 A | 100% | 2003-03-14 | 2005-03-14 | 522d? |  |  | R2 | 9360h | 9360h |  | Nokia | Jussi Kähtävä (juha.mikola@nokia.com) | Rel-6 | Yong-Jun |  | 25.862 |  |  |
| 4407 | 1153.1.1 | Optimization of downlink channelisation code utilisation |  | 262d | 2004-03-12 A | 2005-03-14 A | 100% | 2004-03-12 | 2005-03-14 | 262d | finish no earlier than 2005-03-14 |  | R1 | 2096h | 2096h | RANimp-RABSE-CodeOptFDD | Nortel | Sarah Boumendil | Rel-6 | Patrick | RANimp-RABSE-CodeOptFDD |  |  |  |
| 4408 | 1153.1.2 | optimization of channelisation code utilisation for 3.84 Mcps TDD |  | 261d | 2004-03-15 A | 2005-03-14 A | 100% | 2004-03-15 | 2005-03-14 | 261d | finish no earlier than 2005-03-15 |  | R1 | 2088h | 2088h | RANimp-RABSE-CodOptTDD | IPWireless | Nicholas Anderson | Rel-6 | Patrick | RANimp-RABSE-CodOptTDD |  |  |  |
| 4409 | 1153.1.3 | HS-DPCCH ACK/NACK Enhancement |  | 65d? | 2004-09-15 A | 2004-12-14 A | 100% | 2004-09-15 | 2004-12-14 | 65d? | finish no earlier than 2004-12-15 |  | R1 | 520h | 520h | RANimp-RABSE-ACKNACK | Nokia | Jussi Kähtävä (juha.mikola@nokia.com) | Rel-6 | Patrick | RANimp-RABSE-ACKNACK | 25.212, 25.214, 24.331, 25.433 |  |  |
| 4410 | 1153.1.4 | Deleted - Iu enhancements for IMS support in RAN |  | 320d? | 2003-03-14 A | 2004-06-03 A | 100% | 2003-03-14 | 2004-06-03 | 320d? | start no earlier than 2003-03-14 |  | R3 | 2560h | 2560h | RANimp-RABSE-IuEnhIMS | Nortel | Philippe.Godin@nortelnetworks.com | Rel-6 | Juha | RANimp-RABSE-IuEnhIMS |  |  | RP-24 |
| 4411 | 1153.1.5 | Deleted - Improvement of RRM across RNS and RNS/BSS | milestone | 0d? | 2003-12-05 A | 2003-12-05 A | 100% | 2003-12-05 | 2003-12-05 | 0d? | finish no earlier than 2003-12-05 |  | R3 |  |  | RANimp-RRM1 | Nokia | antti.toskala@nokia.com | Rel-6 | Juha | RANimp-RRM1 |  |  | RP-23 |
| 4412 | 9.1 | Beamforming Enhancements |  | 66d | 2003-09-19 A | 2003-12-19 A | 100% | 2003-09-19 | 2003-12-19 | 66d | finish no earlier than 2004-03-12 |  | R1 | 528h | 528h | RANimp-BFE | Nokia | Jussi Kähtävä (juha.mikola@nokia.com) | Rel-6 | Patrick | RANimp-BFE | 24.215, 25.423, 25.425, 25.433, 25.435 |  |  |
| 4413 | 1153.3 | **Rel-6 RRM optimization for Iur and Iub** |  | 126d | 2003-09-19 A | 2004-03-12 A | 100% | 2003-09-19 | 2004-03-12 | 126d |  |  | R3 | 2016h | 2016h | RANimp-RRMopt-UEMsD | Ericsson | Gert-Jan.van.Lieshout@eln.ericsson.se | Rel-6 | Juha | RANimp-RRMopt-UEMsD |  |  |  |
| 4414 | 1153.3.1 | Improved access to UE measurement data for CRNC to support TDD RRM |  | 126d | 2003-09-19 A | 2004-03-12 A | 100% | 2003-09-19 | 2004-03-12 | 126d | finish no earlier than 2004-03-15 |  | R3 | 1008h | 1008h |  | Interdigital | jim.miller@interdigital.com | Rel-6 | Juha |  | 25.423 |  | RP-22 |
| 4415 | 1153.4 | **Remote Control of Electrical Tilting Antennas** |  | 395d? | 2003-03-14 A | 2004-09-16 A | 100% | 2003-03-14 | 2004-09-16 | 395d? |  |  | R3; S5 | 10624h | 10624h | RANimp-TiltAnt | Vodafone | Andreas.Hauser@vodafone.com | Rel-6 | Juha | RANimp-TiltAnt |  |  |  |
| 4416 | 1153.4.1 | Tilting Antenna - RAN aspects |  | 393d? | 2003-03-14 A | 2004-09-14 A | 100% | 2003-03-14 | 2004-09-14 | 393d? | finish no earlier than 2004-09-14 |  | R3 | 3144h | 3144h |  | Vodafone | Andreas.Hauser@vodafone.com | Rel-6 | Juha |  | 25.460, 25.461, 25.462, 25.463 |  |  |
| 4417 | 1153.4.2 | OAM&P impacts |  | 145d | 2004-02-27 A | 2004-09-16 A | 100% | 2004-02-27 | 2004-09-16 | 145d | finish no earlier than 2004-09-16 |  | S5 | 1160h | 1160h | RANimp-TiltAnt-OAM | Vodafone | Adrian.Neal@vodafone.com | Rel-6 | Mirko | RANimp-TiltAnt-OAM | 32.804, 32.64x | SP-24 |  |
| 4418 | 1153.5 | Network Assisted Cell Change (NACC) from UTRAN to GERAN - network-side aspects |  | 462d? | 2002-09-09 A | 2004-06-15 A | 100% | 2002-09-09 | 2004-06-15 | 462d? | finish no earlier than 2004-06-15 |  | R3 | 3696h | 3696h | RANimp-NACC | Vodafone | Brendan.McWilliams@gb.vodafone.co.uk | Rel-6 | Juha | RANimp-NACC |  |  |  |
| 4419 | 12 | **Location Services enhancements 2** |  | 1024d? | 2001-01-15 A | 2004-12-16 A | 100% | 2001-01-15 | 2004-12-16 | 1024d? |  |  | S2; S5; N4; R2; R4; R5; OMA | 175184h | 175184h | LCS2 | Nokia | Jan Kåll | Rel-6 | Maurice | LCS2 |  |  |  |
| 4420 | 12.1 | **Improvement on Le interface** |  | 653d? | 2002-06-17 A | 2004-12-15 A | 100% | 2002-06-17 | 2004-12-15 | 653d? |  |  | S2; OMA | 15096h | 15096h |  | Nokia | Jan Kåll | Rel-6 | Maurice |  |  |  |  |
| 4421 | 1154.1.1 | Stage 2 for Improvement on Le interface |  | 331d? | 2002-06-17 A | 2003-09-22 A | 100% | 2002-06-17 | 2003-09-22 | 331d? | start no earlier than 2002-06-17 |  | S2 | 2648h | 2648h |  | Nokia | Jan Kåll | Rel-6 | Maurice |  | 23.002,23.271 |  |  |
| 4422 | 1154.1.2 | Stage 3 - impacts MLP (Mobile Location Protocol) |  | 250d? | 2004-01-01 A | 2004-12-15 A | 100% | 2004-01-01 | 2004-12-15 | 250d? | finish no earlier than 2004-12-15 |  | OMA | 2000h | 2000h |  | OMA | OMA-LIAISON@mail.openmobilealliance.org | Rel-6 |  |  |  |  |  |

Notes:
- 4398: -
- 4399: -
- 4400: -
- 4401: -
- 4402: -
- 4403: -
- 4404: -
- 4405: Generic feature
- 4406: building block without particular end date
- 4407: -
- 4408: WIDS modified in RP#26, RP-040551
- 4409: Approved at RP#25 as RP-040390
- 4410: Closed RP#24 due to the lack of progress
- 4411: abandoned RP-23
- 4412: -
- 4413: -
- 4414: -
- 4415: -
- 4416: Finished at RP#25
- 4417: SP#25 09/2004 completed
- 4418: -
- 4419: -
- 4420: -
- 4421: -
- 4422: -

| ID | WBS | Task | Type | Duration | Start | Finish | Complete | Baseline start | Baseline finish | Baseline duration | Constraint | Resources | Work | Actual work | WI rapporteur name | WI rapporteur e-mail | Release | MCC resp | Acronym | Acronym_3GU_Export | TSG stopped |
| --- | --- | --- | --- | --- | --- | --- | --- | --- | --- | --- | --- | --- | --- | --- | --- | --- | --- | --- | --- | --- | --- |
| 4423 | 12.2 | **Enhanced support for anonymity and user privacy** |  | 638d? | 2002-07-08 A | 2004-12-15 A | 100% | 2002-07-08 | 2004-12-15 | 638d? |  | S2; OMA | 14248h | 14248h | Nokia | Jan Kåll | Rel-6 | Maurice |  |  |  |
| 4424 | 1154.2.1 | Stage 2 for Enhanced support for anonymity and user privacy |  | 255d? | 2002-07-08 A | 2003-06-27 A | 100% | 2002-07-08 | 2003-06-27 | 255d? | finish no earlier than 2003-06-27 | S2 | 2040h | 2040h | Nokia | Jan Kåll | Rel-6 | Maurice |  |  |  |
| 4425 | 1154.2.2 | Stage 3 - impacts MLP and RLP |  | 250d? | 2004-01-01 A | 2004-12-15 A | 100% | 2004-01-01 | 2004-12-15 | 250d? | finish no earlier than 2004-12-15 | OMA | 2000h | 2000h | OMA | OMA-LIAISON@mail.openmobilealliance.org | Rel-6 |  |  |  |  |
| 4426 | 12.3 | **Enhanced inter-GMLC interface** |  | 648d? | 2002-06-24 A | 2004-12-15 A | 100% | 2002-06-24 | 2004-12-15 | 648d? |  | S2; OMA | 14888h | 14888h | Nokia | Jan Kåll | Rel-6 | Maurice |  |  |  |
| 4427 | 1154.3.1 | Stage 2 for Enhanced inter-GMLC interface |  | 315d? | 2002-06-24 A | 2003-09-05 A | 100% | 2002-06-24 | 2003-09-05 | 315d? | finish no earlier than 2003-09-05 | S2 | 2520h | 2520h | Nokia | Jan Kåll | Rel-6 | Maurice |  |  |  |
| 4428 | 1154.3.2 | Stage 3 - definition of RLP and PCP |  | 250d? | 2004-01-01 A | 2004-12-15 A | 100% | 2004-01-01 | 2004-12-15 | 250d? | finish no earlier than 2004-12-15 | OMA | 2000h | 2000h | OMA | OMA-LIAISON@mail.openmobilealliance.org | Rel-6 |  |  |  |  |
| 4429 | 12.4 | **Location Services support for IMS public identities** |  | 473d? | 2003-02-24 A | 2004-12-15 A | 100% | 2003-02-24 | 2004-12-15 | 473d? |  | S2; OMA | 11488h | 11488h | Nokia | Jan Kåll | Rel-6 | Maurice |  |  |  |
| 4430 | 1154.4.1 | Stage 2 for Location Services support for IMS public identities |  | 240d? | 2003-02-24 A | 2004-01-23 A | 100% | 2003-02-24 | 2004-01-23 | 240d? | finish no earlier than 2004-01-23 | S2 | 1920h | 1920h | Nokia | Jan Kåll | Rel-6 | Maurice |  |  |  |
| 4431 | 1154.4.2 | OMA Stage 3 for Location Services support for IMS public identities - impacts MLP, RLP and PCP |  | 250d? | 2004-01-01 A | 2004-12-15 A | 100% | 2004-01-01 | 2004-12-15 | 250d? | finish no earlier than 2004-12-15 | OMA | 2000h | 2000h | OMA | OMA-LIAISON@mail.openmobilealliance.org | Rel-6 |  |  |  |  |
| 4432 | 12.5 | **New area event for location service triggering reports** |  | 663d? | 2002-06-03 A | 2004-12-15 A | 100% | 2002-06-03 | 2004-12-15 | 663d? |  | S2; N4; OMA | 22024h | 22024h | Nokia | Jan Kåll | Rel-6 | Maurice |  |  |  |
| 4433 | 1154.5.1 | Stage 2 for New area event for location service triggering reports |  | 280d? | 2002-06-03 A | 2003-06-27 A | 100% | 2002-06-03 | 2003-06-27 | 280d? | finish no earlier than 2003-06-27 | S2 | 2240h | 2240h | Nokia | Jan Kåll | Rel-6 | Maurice |  |  |  |
| 4434 | 1154.5.2 | Stage 3 for UE-CN signalling |  | 234d? | 2003-10-09 A | 2004-08-31 A | 100% | 2003-10-09 | 2004-08-31 | 234d? | start no earlier than 2003-10-09 | N4 | 1872h | 1872h | Nokia |  | Rel-6 | Kimmo |  |  |  |
| 4435 | 1154.5.3 | Stage 3 for New area event for location service triggering reports - impacts MLP, RLP and PCP |  | 250d? | 2004-01-01 A | 2004-12-15 A | 100% | 2004-01-01 | 2004-12-15 | 250d? | finish no earlier than 2004-12-15 | OMA | 2000h | 2000h | OMA | OMA-LIAISON@mail.openmobilealliance.org | Rel-6 |  |  |  |  |
| 4436 | 12.7 | **UE positioning for Location Services enhancements 2** |  | 957d? | 2001-01-15 A | 2004-09-14 A | 100% | 2001-01-15 | 2004-09-14 | 957d? |  | R2; R4; R5 | 36456h | 36456h |  |  | Rel-6 | Issam | LCS2-UEpos | LCS2-UEpos |  |
| 4437 | 12.8 | Open SMLC-SRNC Interface within the UTRAN to support UTRAN Rel-4 positioning methods |  | 700d? | 2001-01-15 A | 2003-09-19 A | 100% | 2001-01-15 | 2003-09-19 | 700d? | finish no earlier than 2003-09-19 | R2 | 5600h | 5600h | Siemens | Meik.Kottkamp@siemens.com | Rel-6 | Yong-Jun | LCS-Rel4Pos | LCS-Rel4Pos |  |
| 4438 | 1154.6.2 | A-GPS minimum performance specification |  | 333d? | 2003-06-06 A | 2004-09-14 A | 100% | 2003-06-06 | 2004-09-14 | 333d? | finish no earlier than 2004-09-14 | R4; R5 | 5328h | 5328h | AT&T Wireless | donglin.shen@attws.com | Rel-6 | Issam | LCS-UEPos-AGPSPerf | LCS-UEPos-AGPSPerf |  |
| 4439 | 12.7.2 | Deleted - FS on Enhancements to OTDOA Positioning using advanced blanking methods |  | 320d | 2002-07-01 A | 2003-09-19 A | 100% | 2002-07-01 | 2003-09-19 | 320d | finish no earlier than 2003-09-19 | R2 | 2560h | 2560h | Cambridge Positioning Systems | david.bartlett@cursor-system.com | Rel-6 | Yong-Jun | LCS2-UEpos-FSBlank | LCS2-UEpos-FSBlank | RP-38 |
| 4440 | 1154.6.4 | Deleted - UE positioning enhancements - other methods | milestone | 0d? | 2003-09-26 A | 2003-09-26 A | 100% | 2003-09-26 | 2003-09-26 | 0d? | finish no earlier than 2003-09-26 | R2 |  |  | Siemens | Meik.Kottkamp@siemens.com | Rel-6 | Yong-Jun | LCS2-UEpos-enh | LCS2-UEpos-enh | RP-24 |
| 4441 | 1154.7 | LCS charging |  | 455d? | 2003-03-21 A | 2004-12-16 A | 100% | 2003-03-21 | 2004-12-16 | 455d? | start no earlier than 2003-03-21 | S5 | 3640h | 3640h | France Telecom | alain.bibas@orange-ft.com | Rel-6 | Mirko | LCS2-CH | LCS2-CH |  |
| 4442 | 14 | **Rel-6 Security enhancements** |  | 1018d? | 2001-01-03 A | 2004-11-26 A | 100% | 2001-01-03 | 2004-11-26 | 1018d? |  | S3 | 28824h | 28824h | Vodafone | Peter.Howard@vodafone.com | Rel-6 | Mirko | SEC16 | SEC1, Rel-6 |  |
| 4443 | 14.1 | **Enhanced HE control of security (including positive authentication reporting)** |  | 712d | 2001-01-03 A | 2003-09-25 A | 100% | 2001-01-03 | 2003-09-25 | 712d |  | S3 | 14064h | 14064h | Vodafone | Peter.Howard@vodafone.com | Rel-6 | Mirko |  |  |  |
| 4444 | 14.1.1 | Deleted - SEC1 Stage 2 (Enhanced HE control of security) |  | 378d | 2001-01-03 A | 2002-06-14 A | 100% | 2001-01-03 | 2002-06-14 | 378d | finish no earlier than 2002-06-14 | S3 | 3024h | 3024h |  |  | Rel-6 | Mirko |  |  | SP-16 |
| 4445 | 14.1.3 | **Rel-6 Network Domain Security** |  | 334d | 2002-06-17 A | 2003-09-25 A | 100% | 2002-06-17 | 2003-09-25 | 334d |  | S3 | 5344h | 5344h | Telenor | Geir-myrdahl.koien@telenor.com | Rel-6 | Mirko | SEC1-NDS | SEC1-NDS |  |
| 4446 | 14.1.3.1 | Rel-6 IP network layer security (NDS/IP) |  | 334d | 2002-06-17 A | 2003-09-25 A | 100% | 2002-06-17 | 2003-09-25 | 334d | finish no earlier than 2003-09-25 | S3 | 2672h | 2672h |  |  | Rel-6 | Mirko | SEC1-NDS-IP | SEC1-NDS-IP |  |
| 4447 | 1155.2 | Network Domain Security; Authentication Framework (NDS/AF) |  | 521d? | 2002-02-15 A | 2004-02-13 A | 100% | 2002-02-15 | 2004-02-13 | 521d? | finish no earlier than 2004-02-13 | S3 | 4168h | 4168h | Nokia | tommi.viitanen@nokia.com | Rel-6 | Mirko | SEC1-NDS-AF | SEC1-NDS-AF |  |
| 4448 | 1155.3 | Key Management of group keys for Voice Group Call Services |  | 306d | 2003-09-26 A | 2004-11-26 A | 100% | 2003-09-26 | 2004-11-26 | 306d | finish no earlier than 2004-11-26 | S3 | 2448h | 2448h | Vodafone | benno.tietz@vodafone.com | Rel-6 | Mirko | SECGKYV | SECGKYV |  |
| 4449 | 1156 | Network Domain Security; MAP application layer security (NDS/MAPsec) |  | 127d? | 2004-07-06 A | 2004-12-29 A | 100% | 2004-07-06 | 2004-12-29 | 127d? | finish no earlier than 2003-12-26 | S3 | 1016h | 1016h | Vodafone | Peter.Howard@vodafone.com | Rel-6 | Mirko | MAPSEC | MAPSEC |  |

Notes:
- 4423: -
- 4424: - / Impacted TSs and TRs: 23.002,23.271
- 4425: -
- 4426: -
- 4427: - / Impacted TSs and TRs: 23.002,23.271
- 4428: -
- 4429: -
- 4430: - / Impacted TSs and TRs: 23.002,23.271
- 4431: -
- 4432: -
- 4433: - / Impacted TSs and TRs: 23.002,23.271
- 4434: Current stage 3 fullfills stage 2
- 4435: -
- 4436: -
- 4437: - / Impacted TSs and TRs: 25.305, 25.401, 25.450, 25.452, 25.453
- 4438: RP#25 completed (FDD) / Impacted TSs and TRs: new 25.171, 34.171 (testing)
- 4439: RP#38 Work stopped / Impacted TSs and TRs: new TR 25.894
- 4440: RP#24 Work stopped
- 4441: SP#26 completed / Impacted TSs and TRs: new TS 32.271
- 4442: SP#9 approved WID. Acronym changed from "SEC1, Rel-6"
- 4443: SP#9 approved WID S3-000490 (Enhanced home control of security by HE) / Impacted TSs and TRs: 33.102
- 4444: Marked as stopped 12/2008
- 4445: SP#9 approved WID S3-000606 (Network Domain Security) / Impacted TSs and TRs: 33.102, 33.103, 33.105
- 4446: SP#9 approved WID S3-000626 (Access security for IP-based services) / Impacted TSs and TRs: 33.210
- 4447: SP#19 approved WID / Impacted TSs and TRs: 33.810
- 4448: - / Impacted TSs and TRs: 42.068, 43.068, 44.068, 42.069, 43.069, 44.069, 31.102, 24.008, 48.008, 42.009, 43.020, New TSs (55.236, 55.205) MILENAGE algorithms
- 4449: SP#19 approved WID. Marked as closed 12/2008 (was marked 20% complete) / Impacted TSs and TRs: 33.200

| ID | WBS | Task | Type | Duration | Start | Finish | Complete | Baseline start | Baseline finish | Baseline duration | Constraint | Resources | Work | Actual work | Acronym | Release | MCC resp | Acronym_3GU_Export | Impacted TSs and TRs | WI rapporteur name | WI rapporteur e-mail | TSG stopped |
| --- | --- | --- | --- | --- | --- | --- | --- | --- | --- | --- | --- | --- | --- | --- | --- | --- | --- | --- | --- | --- | --- | --- |
| 4450 | 16 | **IMS Phase 2** |  | 1840d? | 2000-08-28 A | 2007-09-14 A | 100% | 2000-08-28 | 2007-09-14 | 1840d? |  | S1; S2; S3; S5; NP; R5 | 210576h | 210576h | IMS2 | Rel-6 | Alain | IMS2 |  |  |  |  |
| 4451 | 1157.1 | Enhancements to the Cx and Sh interfaces |  | 323d? | 2003-06-06 A | 2004-08-31 A | 100% | 2003-06-06 | 2004-08-31 | 323d? | finish no earlier than 2004-08-31 | N4 | 2584h | 2584h | IMS2-CCR | Rel-6 | Kimmo | IMS2-CCR |  |  |  |  |
| 4452 | 1157.2 | Conformance Test Aspects – IMS Call Control Rel-6 enhancements |  | 396d? | 2006-03-10 A | 2007-09-14 A | 100% | 2006-03-10 | 2007-09-14 | 396d? | finish no earlier than 2007-09-14 | R5 | 3168h | 3168h | IMS2_CCR_Test | Rel-6 | Ingbert | IMS2_CCR_Test | 34.229-1, 34.229-2, 34.229-3, 34.108 | Ericsson | Jacob.John@motorola.com, Leif.Mattisson@ericsson.com |  |
| 4453 | 16.12 | **IMS Group Management** |  | 715d? | 2002-03-14 A | 2004-12-08 A | 100% | 2002-03-14 | 2004-12-08 | 715d? |  | S1 | 12680h | 12680h | IMSGM | Rel-6 | Alain | IMSGM |  | Nokia | juha.kalliokulju@nokia.com |  |
| 4454 | 16.12.1 | Stage 1 - TS on IMS group management |  | 193d | 2002-03-14 A | 2002-12-09 A | 100% | 2002-03-14 | 2002-12-09 | 193d | finish no earlier than 2002-12-09 | S1 | 1544h | 1544h |  | Rel-6 | Alain |  |  | Nokia | juha.kalliokulju@nokia.com |  |
| 4455 | 1157.3.2 | Stage 2 for IMS Group Management |  | 158d? | 2003-05-26 A | 2003-12-31 A | 100% | 2003-05-26 | 2003-12-31 | 158d? | finish no earlier than 2003-12-31 | S2 | 1264h | 1264h |  | Rel-6 | Maurice |  | 23.228 |  |  |  |
| 4456 | 1157.3.3 | Stage 3 for IMS Group management (e.g. chat) |  | 519d? | 2002-12-13 A | 2004-12-08 A | 100% | 2002-12-13 | 2004-12-08 | 519d? | finish no earlier than 2004-12-08 | N1 | 4152h | 4152h |  | Rel-6 | Frederic |  |  | Lucent | Keith Drage (drage@alcatel-lucent.com) |  |
| 4457 | 1157.4 | **IMS Conferencing** |  | 548d? | 2002-11-04 A | 2004-12-08 A | 100% | 2002-11-04 | 2004-12-08 | 548d? |  | N1 | 10960h | 10960h |  | Rel-6 | Frederic |  |  |  |  |  |
| 4458 | 1157.4.1 | Stage 2 for IMS Conferencing |  | 303d? | 2002-11-04 A | 2003-12-31 A | 100% | 2002-11-04 | 2003-12-31 | 303d? | finish no earlier than 2003-12-31 | S2 | 2424h | 2424h |  | Rel-6 | Maurice |  | 23.228 |  |  |  |
| 4459 | 1157.4.2 | Stage 3 for IMS Conferencing |  | 519d? | 2002-12-13 A | 2004-12-08 A | 100% | 2002-12-13 | 2004-12-08 | 519d? | finish no earlier than 2004-12-08 | N1 | 4152h | 4152h |  | Rel-6 | Frederic |  |  | Lucent | Keith Drage (drage@alcatel-lucent.com) |  |
| 4460 | 16.11 | **IMS Messaging** |  | 992d? | 2002-03-14 A | 2005-12-30 A | 100% | 2002-03-14 | 2005-12-30 | 992d? |  | S1 | 23912h | 23912h | IMSM | Rel-6 | Alain | IMSM |  | Nokia | juha.kalliokulju@nokia.com |  |
| 4461 | 16.11.1 | TR on support of messaging in the IMS |  | 193d | 2002-03-14 A | 2002-12-09 A | 100% | 2002-03-14 | 2002-12-09 | 193d | finish no earlier than 2002-12-09 | S1 | 1544h | 1544h | IMSM-TR | Rel-6 | Alain | IMSM-TR | New 22.940 | Nokia | juha.kalliokulju@nokia.com |  |
| 4462 | 1157.5.2 | Stage 1 22.340 |  | 23d? | 2002-11-11 A | 2002-12-11 A | 100% | 2002-11-11 | 2002-12-11 | 23d? | finish no earlier than 2002-12-11 | S1 | 184h | 184h | IMSM-TS | Rel-6 | Alain | IMSM-TS | 22.340 | Nokia | juha.kalliokulju@nokia.com |  |
| 4463 | 1157.5.3 | CRs to 22.140 & 22.228 |  | 263d? | 2002-03-14 A | 2003-03-17 A | 100% | 2002-03-14 | 2003-03-17 | 263d? | finish no earlier than 2003-03-17 | S1 | 2104h | 2104h | IMSM-CR | Rel-6 | Alain | IMSM-CR | 22.140,22.228 | Nokia | juha.kalliokulju@nokia.com |  |
| 4464 | 16.11.3 | Stage 2 for IMS Messaging |  | 477d | 2002-11-04 A | 2004-08-31 A | 100% | 2002-11-04 | 2004-08-31 | 477d | finish no earlier than 2004-08-31 | S2 | 3816h | 3816h |  | Rel-6 | Maurice |  | 23.228 |  |  |  |
| 4465 | 1157.5.5 | Stage 3 for IMS Messaging |  | 519d? | 2002-12-13 A | 2004-12-08 A | 100% | 2002-12-13 | 2004-12-08 | 519d? | finish no earlier than 2004-12-08 | N1 | 4152h | 4152h |  | Rel-6 | Frederic |  |  | Lucent | Keith Drage (drage@alcatel-lucent.com) |  |
| 4466 | 1157.5.6 | SIP/SIMPLE Instant messaging |  | 522d? | 2004-01-01 A | 2005-12-30 A | 100% | 2004-01-01 | 2005-12-30 | 522d? | finish no earlier than 2005-06-30 | OMA | 4176h | 4176h |  | Rel-6 |  |  |  |  | OMA-LIAISON@mail.openmobilealliance.org |  |
| 4467 | 1157.6 | **Additional SIP Capabilities support not covered by Rel-5** |  | 680d? | 2002-11-11 A | 2005-06-17 A | 100% | 2002-11-11 | 2005-06-17 | 680d? |  | N1 | 13392h | 13392h |  | Rel-6 | Frederic |  |  |  |  |  |
| 4468 | 1157.6.1 | Stage 2 for add SIP cap (e.g. forking) |  | 335d? | 2002-11-11 A | 2004-02-20 A | 100% | 2002-11-11 | 2004-02-20 | 335d? | finish no earlier than 2004-02-20 | S2 | 2680h | 2680h |  | Rel-6 | Maurice |  | 23.228 |  |  |  |
| 4469 | 1157.6.2 | Stage 3 for Additional SIP Capabilities |  | 454d? | 2002-12-13 A | 2004-09-08 A | 100% | 2002-12-13 | 2004-09-08 | 454d? | finish no earlier than 2004-09-08 | N1 | 3632h | 3632h |  | Rel-6 | Frederic |  |  | Lucent | Keith Drage (drage@alcatel-lucent.com) |  |
| 4470 | 1157.6.3 | Procedured associated with IMS-ALG |  | 205d? | 2004-09-06 A | 2005-06-17 A | 100% | 2004-09-06 | 2005-06-17 | 205d? | start no earlier than 2004-09-06 | N1 | 1640h | 1640h |  | Rel-6 | Frederic |  |  |  |  |  |
| 4471 | 1157.7 | Review additional SIP Capabilities against IMS |  | 454d? | 2002-12-13 A | 2004-09-08 A | 100% | 2002-12-13 | 2004-09-08 | 454d? | finish no earlier than 2004-09-08 | N1 | 3632h | 3632h |  | Rel-6 | Frederic |  |  | Lucent | Keith Drage (drage@alcatel-lucent.com) |  |
| 4472 | 16.5 | **Interworking between IMS and IP networks** |  | 1118d? | 2000-08-28 A | 2004-12-08 A | 100% | 2000-08-28 | 2004-12-08 | 1118d? |  | N3 | 31712h | 31712h | IMS-CCR-IWIP | Rel-6 | Gwiho | IMS-CCR-IWIP | 23.821, 29.061, 29.162 | BT | nigel.holland@bt.com |  |
| 4473 | 16.5.1 | Interworking for 3GPP_SIP and IETF_SIP |  | 730d | 2000-08-28 A | 2003-06-13 A | 100% | 2000-08-28 | 2003-06-13 | 730d | finish no earlier than 2003-06-13 | N3 | 5840h | 5840h |  | Rel-6 | Gwiho |  | New 29.962 | Siemens | Thomas.Belling@nsn.com |  |
| 4474 | 16.5.2 | Interworking for IPv6 to IPv4 |  | 1118d | 2000-08-28 A | 2004-12-08 A | 100% | 2000-08-28 | 2004-12-08 | 1118d | finish no earlier than 2004-12-08 | N3 | 8944h | 8944h |  | Rel-6 | Gwiho |  | 29.163 |  |  |  |
| 4475 | 1157.8.3 | Interworking for IPv6 to IPv4 (SIP / SDP aspects) |  | 87d? | 2004-05-11 A | 2004-09-08 A | 100% | 2004-05-11 | 2004-09-08 | 87d? | finish no earlier than 2004-09-08 | N1 | 696h | 696h |  | Rel-6 | Frederic |  |  |  |  |  |
| 4476 | 16.8.1 | stage 3 of interworking with non-IMS IP networks |  | 911d | 2001-03-14 A | 2004-09-08 A | 100% | 2001-03-14 | 2004-09-08 | 911d | finish no earlier than 2004-09-08 | N1 | 7288h | 7288h |  | Rel-6 | Frederic |  |  |  |  |  |
| 4477 | 16.6.1 | Interworking between IMS and CS networks |  | 929d? | 2000-08-28 A | 2004-03-18 A | 100% | 2000-08-28 | 2004-03-18 | 929d? | finish no earlier than 2004-03-18 | N3 | 7432h | 7432h | IMS-CCR-IWCS | Rel-6 | Gwiho | IMS-CCR-IWCS | 29.163, 29.061, 24.228, and New CN4 specification | Vodafone | Brendan.McWilliams@gb.vodafone.co.uk |  |
| 4478 | 16.10 | Mn interface (IM-MGW to MGCF) enhancements (CN4 Part) |  | 418d | 2001-08-07 A | 2004-09-01 A | 100% | 2001-08-07 | 2004-09-01 | 418d | finish no earlier than 2004-09-01 | N4 | 3344h | 3344h | IMS-CCR-Mn | Rel-6 | Kimmo | IMS-CCR-Mn |  |  |  |  |
| 4479 | 1157.11 | Study of subscriber and operators relationship in IMS and related ISIM requirements for Rel 6” |  | 20d? | 2002-11-15 A | 2002-12-12 A | 100% | 2002-11-15 | 2002-12-12 | 20d? | finish no earlier than 2002-12-12 | S1 | 160h | 160h |  | Rel-6 | Alain |  |  | Nokia | juha.kalliokulju@nokia.com |  |
| 4480 | 1157.12 | Lawful Interception in Rel-6 architecture |  | 269d? | 2002-12-09 A | 2003-12-18 A | 100% | 2002-12-09 | 2003-12-18 | 269d? | finish no earlier than 2003-12-18 | S3 | 2152h | 2152h | SEC1-LI | Rel-6 | Mirko | SEC1-LI, Rel-6 | 33.106, 33.107, 33.108 | Reg TP, Nortel | berthold.wilhelm@regtp.de, Ron Ryan |  |
| 4481 | 1157.13 | IMS Subscription and access scenarios |  | 130d? | 2002-12-16 A | 2003-06-13 A | 100% | 2002-12-16 | 2003-06-13 | 130d? | start no earlier than 2002-12-16 | S1 | 1040h | 1040h |  | Rel-6 | Alain |  | 22.800 | TeliaSonera | FRANK, Robert |  |
| 4482 | 1157.14 | IMS charging |  | 455d? | 2003-03-21 A | 2004-12-16 A | 100% | 2003-03-21 | 2004-12-16 | 455d? | finish no earlier than 2004-12-16 | S5 | 3640h | 3640h | IMS2-CH | Rel-6 | Mirko | IMS2-CH | 32.260 | Ericsson | Patrik TEPPO |  |
| 4483 | 1157.15 | IMS Management objects |  | 306d? | 2004-09-03 A | 2005-11-04 A | 100% | 2004-09-03 | 2005-11-04 | 306d? | finish no earlier than 2005-03-04 | N1 | 2448h | 2448h |  | Rel-6 | Frederic |  | 24.167 |  |  |  |
| 4484 | 1157.16 | Deleted - Stage 2 of IMS Phase 2 | milestone | 0d? | 2003-09-19 A | 2003-09-19 A | 100% | 2003-09-19 | 2003-09-19 | 0d? | finish no earlier than 2003-09-19 | S2 |  |  |  | Rel-6 | Maurice |  |  |  |  | SP-21 |

Notes:
- 4450: -
- 4451: Shared public user identities need to be solved. If email approval CR is accepted. Work 100% done....
- 4452: -
- 4453: -
- 4454: -
- 4455: -
- 4456: Depends on CN decision on CPCP in Rel-6. Complete, if unresolved IETF dependencies are dropped (-> LS to CN plenary)
- 4457: -
- 4458: -
- 4459: Depends on CN decision on IETF dependenciES in CP-150Rel-6. Higher figure if CPCP is dropped (-> LS to CN plenary)
- 4460: -
- 4461: -
- 4462: -
- 4463: -
- 4464: -
- 4465: -
- 4466: Updated according to SP-040232
- 4467: -
- 4468: -
- 4469: -
- 4470: -
- 4471: -
- 4472: [DAB 14.02.02] - end date pushed back to March 2003
- 4473: [DAB - 20.08.03] - CN Part of TR Complete @ CN#20
- 4474: -
- 4475: -
- 4476: -
- 4477: [DAB - 25.05.04] - CN3 consider this work to be complete
- 4478: TISPAN issue is open
- 4479: -
- 4480: Acronym changed from "SEC1-LI, Rel6"
- 4481: -
- 4482: SP#26 12/2004 completed
- 4483: -
- 4484: -

| ID | WBS | Task | Type | Duration | Start | Finish | Complete | Baseline start | Baseline finish | Baseline duration | Constraint | Resources | Work | Actual work | Acronym | WI rapporteur name | WI rapporteur e-mail | Release | MCC resp | Acronym_3GU_Export | Impacted TSs and TRs | Created at | TSG stopped |
| --- | --- | --- | --- | --- | --- | --- | --- | --- | --- | --- | --- | --- | --- | --- | --- | --- | --- | --- | --- | --- | --- | --- | --- |
| 4485 | 1158 | **3GPP Enablers for services like Push to Talk over Cellular (PoC)** |  | 459d? | 2003-09-08 A | 2005-06-09 A | 100% | 2003-09-08 | 2005-06-09 | 459d? |  | S2; S4; S5 | 18040h | 18040h | PoC | Ericsson | Shabnam Sultana | Rel-6 | Maurice | PoC |  |  |  |
| 4486 | 1158.1 | Feasibility Study on 3GPP Enablers for services like Push to Talk over Cellular (PoC) |  | 322d? | 2003-09-08 A | 2004-11-30 A | 100% | 2003-09-08 | 2004-11-30 | 322d? | finish no earlier than 2004-11-30 | S2 | 2576h | 2576h |  | Ericsson | Shabnam Sultana | Rel-6 | Maurice |  | 23.979 | SP-24 |  |
| 4487 | 1158.2 | Dependencies on OMA PoC |  | 303d? | 2004-01-01 A | 2005-02-28 A | 100% | 2004-01-01 | 2005-02-28 | 303d? | finish no earlier than 2004-12-30 | OMA | 2424h | 2424h |  |  | OMA-LIAISON@mail.openmobilealliance.org | Rel-6 |  |  |  | SP-24 |  |
| 4488 | 1158.3 | Selection of one or more PoC codec(s) for PoC |  | 69d? | 2004-09-13 A | 2004-12-16 A | 100% | 2004-09-13 | 2004-12-16 | 69d? | start no earlier than 2004-09-13 | S4 | 552h | 552h |  |  |  | Rel-6 | Paolo |  | 26.235, 26.236 | SP-25 |  |
| 4489 | 1158.4 | PoC charging |  | 184d? | 2004-09-27 A | 2005-06-09 A | 100% | 2004-09-27 | 2005-06-09 | 184d? | finish no earlier than 2005-06-09 | S5 | 1472h | 1472h | PoC-CH | Siemens | Gerald.Goermer@nsn.com | Rel-6 | Mirko | PoC-CH | 32.272 |  |  |
| 4490 | 1159 | Study on Interworking aspects and migration scenarios for IPv4 based IMS Implementations |  | 210d? | 2003-09-08 A | 2004-06-25 A | 100% | 2003-09-08 | 2004-06-25 | 210d? | finish no earlier than 2004-06-25 | S2 | 1680h | 1680h | IPv4IMS | Siemens | Alexander Milinski | Rel-6 | Maurice | IPv4IMS | 23.981 |  |  |
| 4491 | 16.3 | **Interoperability and Commonality between IMS using different IP-connectivity Networks** |  | 325d? | 2002-09-16 A | 2003-12-12 A | 100% | 2002-09-16 | 2003-12-12 | 325d? |  | S2 | 9176h | 9176h | IMSCOOP |  |  | Rel-6 | Maurice | IMSCOOP | 23.864 |  |  |
| 4492 | 16.3.1 | Stage 2 for Interoperability |  | 272d | 2002-09-16 A | 2003-09-30 A | 100% | 2002-09-16 | 2003-09-30 | 272d | finish no earlier than 2003-09-30 | S2 | 2176h | 2176h |  | Nokia | balazs.bertenyi@nsn.com | Rel-6 | Maurice |  | 23.864 |  |  |
| 4493 | 1160.2 | Stage 2 for commonality |  | 265d? | 2002-09-16 A | 2003-09-19 A | 100% | 2002-09-16 | 2003-09-19 | 265d? | start no earlier than 2002-09-16 | S2 | 2120h | 2120h |  | Nokia | balazs.bertenyi@nsn.com | Rel-6 | Maurice |  | 23.864 |  |  |
| 4494 | 16.3.2 | Stage 3 for Interoperability and Commonality between IMS using different IP-connectivity Networks |  | 305d | 2002-10-14 A | 2003-12-12 A | 100% | 2002-10-14 | 2003-12-12 | 305d | finish no earlier than 2003-12-12 | N1 | 2440h | 2440h |  | Lucent | Keith Drage (drage@alcatel-lucent.com) | Rel-6 | Frederic |  |  |  |  |
| 4495 | 17 | **Support of Push Services** |  | 823d | 2001-01-03 A | 2004-02-27 A | 100% | 2001-01-03 | 2004-02-27 | 823d |  | S1 | 11390.6h | 11390.6h | PUSH | NTT Comware | Yoshinori Kitada | Rel-6 | Alain | PUSH | 23.976 |  |  |
| 4496 | 17.1 | Stage 1 for Support of Push Services |  | 378d | 2001-01-03 A | 2002-06-14 A | 100% | 2001-01-03 | 2002-06-14 | 378d | finish no earlier than 2002-06-14 | S1 | 3024h | 3024h |  |  |  | Rel-6 | Alain |  |  |  |  |
| 4497 | 17.3 | TR 23.976 on Push Architecture |  | 340d | 2002-11-11 A | 2004-02-27 A | 100% | 2002-11-11 | 2004-02-27 | 340d | finish no earlier than 2004-02-27 | S2 | 2720h | 2720h |  | Research In Motion | Nick Alfano | Rel-6 | Maurice |  | 23.976 |  |  |
| 4498 | 18 | **Rel-6 Multimedia Messaging (MMS) enhancements** |  | 865d? | 2002-08-15 A | 2005-12-07 A | 100% | 2002-08-15 | 2005-12-07 | 865d? |  | T2; S1; S4; S5; OMA | 59616h | 59616h | MMS6 | Siemens | Josef.Laumen@SAL.SIEMENS.DE | Rel-6 | Kimmo | MMS6 |  |  |  |
| 4499 | 18.1 | **Definition of service requirements for MMS6** |  | 286d? | 2002-11-15 A | 2003-12-19 A | 100% | 2002-11-15 | 2003-12-19 | 286d? |  | S1 | 4576h | 4576h | MMS6-SR |  |  | Rel-6 | Alain | MMS6-SR | 22.140 |  |  |
| 4500 | 1162.1.1 | Definition of service requirements charging |  | 286d? | 2002-11-15 A | 2003-12-19 A | 100% | 2002-11-15 | 2003-12-19 | 286d? | finish no earlier than 2003-12-20 | S1 | 2288h | 2288h |  | Siemens | Josef.Laumen@SAL.SIEMENS.DE | Rel-6 | Alain |  | 22.140 |  |  |
| 4501 | 18.2 | Technical realization of MMS6 |  | 591d | 2002-09-06 A | 2004-12-10 A | 100% | 2002-09-06 | 2004-12-10 | 591d | finish no earlier than 2004-12-10 | T2 | 4728h | 4728h |  | Siemens | Josef.Laumen@SAL.SIEMENS.DE | Rel-6 | Kimmo |  | 23.140 |  |  |
| 4502 | 18.3 | OMA dependencies |  | 446d | 2003-08-15 A | 2005-04-29 A | 100% | 2003-08-15 | 2005-04-29 | 446d | finish no earlier than 2004-12-10 | OMA | 3568h | 3568h |  |  |  | Rel-6 | Kimmo |  | OMA specs |  |  |
| 4503 | 18.4 | MMS formats and codecs for MMS6 |  | 865d | 2002-08-15 A | 2005-12-07 A | 100% | 2002-08-15 | 2005-12-07 | 865d | finish no earlier than 2005-12-07 | S4 | 6920h | 6920h | MMS6-Codec | Nokia | roberto.castagno@nokia.com | Rel-6 | Paolo | MMS6-Codec | 26.140, 26.936 |  |  |
| 4504 | 1162.5 | Handling of private addressing schemes in MMS |  | 263d | 2003-12-10 A | 2004-12-10 A | 100% | 2003-12-10 | 2004-12-10 | 263d | finish no earlier than 2004-12-10 | T2 | 2104h | 2104h |  | T-Mobile | Steffen.Habermann@T-MOBILE.DE | Rel-6 | Kimmo |  | 23.140 |  |  |
| 4505 | 1162.6 | MMS charging |  | 390d? | 2003-03-21 A | 2004-09-16 A | 100% | 2003-03-21 | 2004-09-16 | 390d? | start no earlier than 2003-03-21 | S5 | 3120h | 3120h | MMS6-CH |  |  | Rel-6 | Mirko | MMS6-CH | 32.270 |  |  |
| 4506 | 1162.7 | Deleted - FS Multiple MMS Relay/Server Architecture | milestone | 0d | 2004-12-10 A | 2004-12-10 A | 100% | 2004-12-10 | 2004-12-10 | 0d | finish no earlier than 2004-12-10 | T2 |  |  |  | Telefónica Móviles | Juan Gorospe (gorospe_j@tsm.es) | Rel-6 | Kimmo |  | probably Annex to 23.140 |  | TP-26 |
| 4507 | 19 | **Rel-6 MExE enhancements** |  | 326d | 2002-03-08 A | 2003-06-06 A | 100% | 2002-03-08 | 2003-06-06 | 326d |  | T2 | 7328h | 7328h | MEXE6 |  |  | Rel-6 | Kimmo | MEXE6 |  |  |  |
| 4508 | 19.1 | MExE Rel-6 Improvements and Investigations |  | 264d | 2002-03-08 A | 2003-03-12 A | 100% | 2002-03-08 | 2003-03-12 | 264d | finish no earlier than 2003-03-12 | T2 | 2112h | 2112h | MEXE6-ENHANC | TTPCom | Lars Brenk ( (lsb_ttpcom@HOTMAIL.COM) | Rel-6 | Kimmo | MEXE6-ENHANC |  |  |  |
| 4509 | 19.2 | MExE Run-Time Independent Framework Feasibility Study |  | 326d | 2002-03-08 A | 2003-06-06 A | 100% | 2002-03-08 | 2003-06-06 | 326d | finish no earlier than 2003-06-06 | T2 | 2608h | 2608h | MEXE6-RTIF | Nokia Siemens Networks | balazs.bertenyi@nokia.com | Rel-6 | Kimmo | MEXE6-RTIF | 22.857 |  |  |
| 4510 | 21 | Subscription Management |  | 650d | 2002-09-20 A | 2005-03-17 A | 100% | 2002-09-20 | 2005-03-17 | 650d | finish no earlier than 2005-03-17 | S5 | 5200h | 5200h | SuM | T-Mobile | istvan.aba@t-mobile.at | Rel-6 | Mirko | SuM | 32.140/1, 32.171/2/5, 32.803 |  |  |

Notes:
- 4485: -
- 4486: -
- 4487: Updated according to SP-040232
- 4488: Completed
- 4489: SP#28 06/2005 completed
- 4490: -
- 4491: -
- 4492: No contributions assumed that no more will be done in 3GPP hence work may need to be done in 3GPP2
- 4493: -
- 4494: -
- 4495: Changed from FS to actual support of Push
- 4496: -
- 4497: -
- 4498: -
- 4499: -
- 4500: -
- 4501: -
- 4502: -
- 4503: -
- 4504: -
- 4505: SP#25 09/2004 completed
- 4506: originally it was intended to create a FS TR but most likely the work will become an Annex of 23.140
- 4507: -
- 4508: -
- 4509: -
- 4510: SP#27 03/2005 completed

| ID | WBS | Task | Duration | Start | Finish | Complete | Baseline start | Baseline finish | Baseline duration | Constraint | Resources | Work | Actual work | Acronym | WI rapporteur name | WI rapporteur e-mail | Release | MCC resp | Acronym_3GU_Export |
| --- | --- | --- | --- | --- | --- | --- | --- | --- | --- | --- | --- | --- | --- | --- | --- | --- | --- | --- | --- |
| 4511 | 22 | **Presence Capability** | 1233d? | 2001-03-19 A | 2005-12-07 A | 100% | 2001-03-19 | 2005-12-07 | 1233d? |  | S1; S2; S3; S4; N1; N3; N4; OMA | 111784h | 111784h | PRESNC | Motorola | Mark Cataldo | Rel-6 | Alain | PRESNC |
| 4512 | 22.1 | Stage 1 for Presence Capability | 610d | 2001-03-19 A | 2003-07-18 A | 100% | 2001-03-19 | 2003-07-18 | 610d | finish no earlier than 2003-07-18 | S1 | 4880h | 4880h |  | Motorola | Mark Cataldo | Rel-6 | Alain |  |
| 4513 | 22.2 | Stage 2 for Presence Capability | 268d | 2001-09-12 A | 2002-09-20 A | 100% | 2001-09-12 | 2002-09-20 | 268d | finish no earlier than 2002-09-20 | S2 | 2144h | 2144h |  | Nokia | balazs.bertenyi@nsn.com | Rel-6 | Maurice |  |
| 4514 | 22.3 | Stage 3 for Presence Capability | 703d | 2002-04-01 A | 2004-12-08 A | 100% | 2002-04-01 | 2004-12-08 | 703d | finish no earlier than 2004-12-08 | N1; N4 | 11248h | 11248h |  | Lucent | Keith Drage (drage@alcatel-lucent.com) | Rel-6 | Frederic |  |
| 4515 | 1165.4 | Stage 3 (CN3 Part Pk interface) | 770d? | 2002-04-01 A | 2005-03-11 A | 100% | 2002-04-01 | 2005-03-11 | 770d? | finish no earlier than 2005-03-11 | N3 | 6160h | 6160h |  | Lucent | Keith Drage (drage@alcatel-lucent.com) | Rel-6 | Gwiho |  |
| 4516 | 1165.5 | Media Codecs and Formats for IMS Messaging and Presence | 650d? | 2003-06-12 A | 2005-12-07 A | 100% | 2003-06-12 | 2005-12-07 | 650d? | finish no earlier than 2005-12-07 | S4 | 5200h | 5200h | PRESNC-COFIMP | Nokia | harri.honko@nokia.com | Rel-6 | Paolo | PRESNC-COFIMP |
| 4517 | 22.4 | Security aspects of Presence Capability | 79d | 2002-08-26 A | 2002-12-12 A | 100% | 2002-08-26 | 2002-12-12 | 79d | finish no earlier than 2002-12-12 | S3 | 632h | 632h |  | Ericsson | krister.boman@erv.ericsson.se | Rel-6 | Mirko |  |
| 4518 | 1165.7 | SIMPLE Presence | 326d? | 2004-01-01 A | 2005-03-31 A | 100% | 2004-01-01 | 2005-03-31 | 326d? | finish no earlier than 2004-12-30 | OMA | 2608h | 2608h |  |  | OMA-LIAISON@mail.openmobilealliance.org | Rel-6 |  |  |
| 4519 | 25 | **Enhanced A/Gb feasibility study** | 51d? | 2002-08-30 A | 2002-11-08 A | 100% | 2002-08-30 | 2002-11-08 | 51d? |  | GP | 3264h | 3264h | AGbEnFS | Vodafone | jose-luis.carrizo@vodafone.co.uk | Rel-6 | Paolo | AGbEnFS |
| 4520 | 25.1 | **Feasibility study on A/Gb enhancements** | 51d? | 2002-08-30 A | 2002-11-08 A | 100% | 2002-08-30 | 2002-11-08 | 51d? |  | G2 | 2856h | 2856h | AGbEnFS-FS | Vodafone | jose-luis.carrizo@vodafone.co.uk | Rel-6 | Gert | AGbEnFS-FS |
| 4521 | 25.1.1 | Requirements for the support of conversational services | 51d | 2002-08-30 A | 2002-11-08 A | 100% | 2002-08-30 | 2002-11-08 | 51d | finish no earlier than 2002-11-08 | GP | 408h | 408h |  |  |  | Rel-6 | Paolo |  |
| 4522 | 1166.1.2 | Identification of the different building blocks for the provision of conversational services on the existing A/Gb protocol stack | 51d? | 2002-08-30 A | 2002-11-08 A | 100% | 2002-08-30 | 2002-11-08 | 51d? | finish no earlier than 2002-11-08 | GP | 408h | 408h |  |  |  | Rel-6 | Paolo |  |
| 4523 | 1166.1.3 | Outline of impact and feasibility of these building blocks and their different solutions | 51d? | 2002-08-30 A | 2002-11-08 A | 100% | 2002-08-30 | 2002-11-08 | 51d? | finish no earlier than 2002-11-08 | GP | 408h | 408h |  |  |  | Rel-6 | Paolo |  |
| 4524 | 25.1.4 | Impact on 3GPP architecture and requirement to co-ordinatge with other TSGs (CN, SA) | 51d | 2002-08-30 A | 2002-11-08 A | 100% | 2002-08-30 | 2002-11-08 | 51d | finish no earlier than 2002-11-08 | GP | 408h | 408h |  |  |  | Rel-6 | Paolo |  |
| 4525 | 25.1.5 | Standardisation effort | 51d | 2002-08-30 A | 2002-11-08 A | 100% | 2002-08-30 | 2002-11-08 | 51d | finish no earlier than 2002-11-08 | GP | 408h | 408h |  |  |  | Rel-6 | Paolo |  |
| 4526 | 25.1.6 | Dependency to other features of Enhanced A/Gb feasibility study | 51d | 2002-08-30 A | 2002-11-08 A | 100% | 2002-08-30 | 2002-11-08 | 51d | finish no earlier than 2002-11-08 | GP | 408h | 408h |  |  |  | Rel-6 | Paolo |  |
| 4527 | 26 | **Flexible Layer One for GERAN** | 1171d | 2000-01-03 A | 2004-06-25 A | 100% | 2000-01-03 | 2004-06-25 | 1171d |  | GP; S3 | 86648h | 86648h | FLOGER | Nokia | benoist.sebire@nokia.com | Rel-6 | Paolo | FLOGER |
| 4528 | 26.1 | **Realisation of a Flexible Layer One** | 1126d | 2000-01-03 A | 2004-04-23 A | 100% | 2000-01-03 | 2004-04-23 | 1126d |  | GP | 42816h | 42816h | FLOGER-Real | Nokia | benoist.sebire@nokia.com | Rel-6 | Paolo | FLOGER-Real |
| 4529 | 26.1.1 | Technical Report on Realisation of a Flexible Layer One | 471d | 2002-04-19 A | 2004-02-06 A | 100% | 2002-04-19 | 2004-02-06 | 471d | finish no earlier than 2004-02-06 | GP | 3768h | 3768h |  | Nokia | benoist.sebire@nokia.com | Rel-6 | Paolo |  |
| 4530 | 26.1.2 | Architecture in 45.001 and 43.051 | 526d | 2002-04-19 A | 2004-04-23 A | 100% | 2002-04-19 | 2004-04-23 | 526d | finish no earlier than 2004-04-23 | G1 | 4208h | 4208h |  | Nokia | benoist.sebire@nokia.com | Rel-6 | Paolo |  |
| 4531 | 26.1.3 | Multiplexing in 45.002 | 526d | 2002-04-19 A | 2004-04-23 A | 100% | 2002-04-19 | 2004-04-23 | 526d | finish no earlier than 2004-04-23 | G1 | 4208h | 4208h |  | Nokia | benoist.sebire@nokia.com | Rel-6 | Paolo |  |
| 4532 | 26.1.4 | Channel Coding in 45.003 for Realisation of a Flexible Layer One | 526d | 2002-04-19 A | 2004-04-23 A | 100% | 2002-04-19 | 2004-04-23 | 526d | finish no earlier than 2004-04-23 | G1 | 4208h | 4208h |  | Nokia | benoist.sebire@nokia.com | Rel-6 | Paolo |  |
| 4533 | 26.1.5 | Performance Requirements in 45.005 for Realisation of a Flexible Layer One | 1126d | 2000-01-03 A | 2004-04-23 A | 100% | 2000-01-03 | 2004-04-23 | 1126d | finish no earlier than 2004-04-23 | G1 | 9000h | 9000h |  | Nokia | benoist.sebire@nokia.com | Rel-6 | Paolo |  |
| 4534 | 26.1.6 | Radio subsystem link control in 45.008 for Realisation of a Flexible Layer One | 526d | 2002-04-19 A | 2004-04-23 A | 100% | 2002-04-19 | 2004-04-23 | 526d | finish no earlier than 2004-04-23 | G1 | 4208h | 4208h |  | Nokia | benoist.sebire@nokia.com | Rel-6 | Paolo |  |
| 4535 | 26.1.7 | Requirements in 44.004 | 526d | 2002-04-19 A | 2004-04-23 A | 100% | 2002-04-19 | 2004-04-23 | 526d | finish no earlier than 2004-04-23 | G2 | 4208h | 4208h |  | Nokia | benoist.sebire@nokia.com | Rel-6 | Gert |  |

Notes:
- 4511: merged "Presence Service Enhancements" (UID31028, PRES1) to this feature as no answer was provided on why Presence and Presence Encmts had same target completion date
- 4512: TP#16 moved Stage 1 to Rel-6 TS 22.141 (existed already in Rel-5) / Impacted TSs and TRs: 22.141
- 4513: - / Impacted TSs and TRs: 23.002, 24.229, New 23.141
- 4514: Dependency to 2 IETF drafts, no known work at the moment / Impacted TSs and TRs: New N1 (24.141, 24.841), N4 (29.002, 29.228, 29.230, 29.328)
- 4515: - / Impacted TSs and TRs: 29.061, 29.161
- 4516: - / Impacted TSs and TRs: 26.141, 26.936
- 4517: SP#17 approved WID S3-020429
- 4518: SP#24 OMA LS_in update in SP-040232 OMA dependencies on 3GPP deliverables
- 4519: - / Impacted TSs and TRs: None
- 4520: - / Impacted TSs and TRs: None
- 4521: - / Impacted TSs and TRs: None
- 4522: - / Impacted TSs and TRs: None
- 4523: - / Impacted TSs and TRs: None
- 4524: - / Impacted TSs and TRs: None
- 4525: - / Impacted TSs and TRs: None
- 4526: - / Impacted TSs and TRs: None
- 4527: -
- 4528: -
- 4529: -
- 4530: -
- 4531: -
- 4532: -
- 4533: -
- 4534: -
- 4535: -

| ID | WBS | Task | Type | Duration | Start | Finish | Complete | Baseline start | Baseline finish | Baseline duration | Constraint | Resources | Work | Actual work | Acronym | WI rapporteur name | WI rapporteur e-mail | Release | MCC resp | Acronym_3GU_Export | Impacted TSs and TRs | TSG stopped |
| --- | --- | --- | --- | --- | --- | --- | --- | --- | --- | --- | --- | --- | --- | --- | --- | --- | --- | --- | --- | --- | --- | --- |
| 4536 | 26.2 | **Signalling and protocol support for a Flexible Layer One** |  | 571d | 2002-04-19 A | 2004-06-25 A | 100% | 2002-04-19 | 2004-06-25 | 571d |  | G2 | 13704h | 13704h | FLOGER-SigPro | Nokia | benoist.sebire@nokia.com | Rel-6 | Gert | FLOGER-SigPro |  |  |
| 4537 | 26.2.1 | Modifications to RLC/MAC in 44.060 and 44.160 |  | 571d | 2002-04-19 A | 2004-06-25 A | 100% | 2002-04-19 | 2004-06-25 | 571d | finish no earlier than 2004-06-25 | G2 | 4568h | 4568h |  | Nokia | benoist.sebire@nokia.com | Rel-6 | Gert |  |  |  |
| 4538 | 26.2.2 | Modifications to RRC in 44.118 and 44.018 |  | 571d | 2002-04-19 A | 2004-06-25 A | 100% | 2002-04-19 | 2004-06-25 | 571d | finish no earlier than 2004-06-25 | G2 | 4568h | 4568h |  | Nokia | benoist.sebire@nokia.com | Rel-6 | Gert |  |  |  |
| 4539 | 26.3 | **Security for a Flexible Layer One** |  | 356d | 2002-04-19 A | 2003-08-29 A | 100% | 2002-04-19 | 2003-08-29 | 356d |  | S3; G2 | 11392h | 11392h | FLOGER-SecFLO | Nokia | benoist.sebire@nokia.com | Rel-6 | Mirko | FLOGER-SecFLO |  |  |
| 4540 | 26.3.1 | Ciphering in 44.060, 44.160, 44.018, 44.118 |  | 356d | 2002-04-19 A | 2003-08-29 A | 100% | 2002-04-19 | 2003-08-29 | 356d | finish no earlier than 2003-08-29 | S3; G2 | 5696h | 5696h |  | Nokia | benoist.sebire@nokia.com | Rel-6 | Mirko |  | 44.060, 44.160, 44.018, 44.118 |  |
| 4541 | 26.4 | **Deleted - GERAN MS Conformance test for the Flexible Layer One - DELETE** |  | 0d | 2004-02-06 A | 2004-02-06 A | 100% | 2004-02-06 | 2004-02-06 | 0d |  | G4; G5 |  |  | FLOGER-Msconf | Nokia | benoist.sebire@nokia.com | Rel-6 | Paolo | FLOGER-Msconf |  | GP-27 |
| 4542 | 26.4.1 | Deleted at TSG #27 - MS Test in 51.010 | milestone | 0d | 2004-02-06 A | 2004-02-06 A | 100% | 2004-02-06 | 2004-02-06 | 0d | finish no earlier than 2004-02-06 | G4; G5 |  |  |  | Nokia | benoist.sebire@nokia.com | Rel-6 | Paolo |  |  | GP-22 |
| 4543 | 26.5 | **Deleted - GERAN BTS Conformance test for the Flexible Layer One - DELETE** |  | 0d | 2004-02-06 A | 2004-02-06 A | 100% | 2004-02-06 | 2004-02-06 | 0d |  | G3new |  |  | FLOGER-BTSconf | Nokia | benoist.sebire@nokia.com | Rel-6 | Ingbert | FLOGER-BTSconf |  | GP-27 |
| 4544 | 26.5.1 | Deleted at TGS #27 - BTS Test in 51.021 - DELETE | milestone | 0d | 2004-02-06 A | 2004-02-06 A | 100% | 2004-02-06 | 2004-02-06 | 0d | finish no earlier than 2004-02-06 | G3new |  |  |  | Nokia | benoist.sebire@nokia.com | Rel-6 | Ingbert |  |  | GP-22 |
| 4545 | 27 | Uplink TDOA feasibility study |  | 151d | 2001-11-30 A | 2002-06-28 A | 100% | 2001-11-30 | 2002-06-28 | 151d | finish no earlier than 2002-06-28 | GP | 1208h | 1208h | TDOAF | TruePosition | Bob Gross (rlgross@trueposition.com) | Rel-6 | Paolo | TDOAF | 45.811 |  |
| 4546 | 28 | **Multimedia Broadcast and Multicast Service** |  | 1781d? | 2001-05-11 A | 2008-03-07 A | 100% | 2001-05-11 | 2008-03-07 | 1781d? |  | S1; S2; S3; S4; S5; N1; N3; R2; R4; R5; T1; GP; G2; G3new | 391176h | 391176h | MBMS |  |  | Rel-6 | Alain | MBMS |  |  |
| 4547 | 28.1 | Stage 1 for Multimedia Broadcast and Multicast Service |  | 232d | 2001-05-11 A | 2002-04-01 A | 100% | 2001-05-11 | 2002-04-01 | 232d | finish no earlier than 2002-04-01 | S1 | 1856h | 1856h |  |  |  | Rel-6 | Alain |  | 22.146, 22.101 |  |
| 4548 | 28.2 | **Stage 2 for Multimedia Broadcast and Multicast Service** |  | 648d | 2001-09-24 A | 2004-03-17 A | 100% | 2001-09-24 | 2004-03-17 | 648d |  | S2 | 10408h | 10408h |  |  |  | Rel-6 | Maurice |  |  |  |
| 4549 | 28.2.1 | TR on MBMS Architectural Study |  | 240d | 2001-09-24 A | 2002-08-23 A | 100% | 2001-09-24 | 2002-08-23 | 240d | finish no earlier than 2002-08-23 | S2 | 1920h | 1920h |  |  |  | Rel-6 | Maurice |  | 23.846 |  |
| 4550 | 28.2.2 | Stage 2 MBMS Specification Work |  | 413d | 2002-08-19 A | 2004-03-17 A | 100% | 2002-08-19 | 2004-03-17 | 413d | finish no earlier than 2004-03-17 | S2 | 3304h | 3304h |  |  |  | Rel-6 | Maurice |  | 23.246 |  |
| 4551 | 28.4 | Support of the MBMS in CN protocols |  | 647d | 2002-06-18 A | 2004-12-08 A | 100% | 2002-06-18 | 2004-12-08 | 647d | finish no earlier than 2004-12-08 | N1 | 5176h | 5176h |  |  |  | Rel-6 | Frederic |  |  |  |
| 4552 | 1169.4 | Gmb interface for MBMS (CN3 part) |  | 334d | 2003-08-29 A | 2004-12-08 A | 100% | 2003-08-29 | 2004-12-08 | 334d | finish no earlier than 2004-12-08 | N3 | 2672h | 2672h |  |  |  | Rel-6 | Gwiho |  | 29.061 |  |
| 4553 | 28.5 | Security aspects of MBMS |  | 710d | 2002-07-01 A | 2005-03-18 A | 100% | 2002-07-01 | 2005-03-18 | 710d | finish no earlier than 2005-03-18 | S3 | 5680h | 5680h |  |  | adrian.escott@three.co.uk | Rel-6 | Mirko |  | New 33.246 |  |
| 4554 | 1169.6 | MBMS Charging |  | 108d? | 2005-01-11 A | 2005-06-09 A | 100% | 2005-01-11 | 2005-06-09 | 108d? | start no earlier than 2005-01-11 | S5 | 864h | 864h | MBMS-CH |  |  | Rel-6 | Mirko | MBMS-CH | 32.273 |  |
| 4555 | 28.1 | **MBMS User Services** |  | 743d? | 2003-05-13 A | 2006-03-16 A | 100% | 2003-05-13 | 2006-03-16 | 743d? |  | S1; S4 | 19520h | 19520h |  |  |  | Rel-6 | Alain |  |  |  |
| 4556 | 28.1 | Stage 1 for MBMS User Services |  | 233d | 2003-05-13 A | 2004-04-01 A | 100% | 2003-05-13 | 2004-04-01 | 233d | start no earlier than 2003-05-13 | S1 | 1864h | 1864h |  |  |  | Rel-6 | Alain |  | 22.246 |  |
| 4557 | 1169.7.2 | Definition of MBMS user services, media codecs, formats and transport/application protocols using MBMS |  | 721d? | 2003-06-12 A | 2006-03-16 A | 100% | 2003-06-12 | 2006-03-16 | 721d? | finish no earlier than 2006-03-16 | S4 | 5768h | 5768h | MBMS-TSMBMS | Nokia | igor.curcio@nokia.com | Rel-6 | Paolo | MBMS-TSMBMS | 26.346, 26.936, 26.946 |  |
| 4558 | 28.3 | **Introduction of MBMS in RAN** |  | 967d? | 2002-01-01 A | 2005-09-14 A | 100% | 2002-01-01 | 2005-09-14 | 967d? |  | R2; R4 | 23728h | 23728h | MBMS-RAN | Nokia | juho.pirskanen@nokia.com | Rel-6 | Yong-Jun | MBMS-RAN |  |  |
| 4559 | 1169.8.1 | Introduction of MBMS in RAN (physical & upper layers, access network interfaces) |  | 771d? | 2002-01-01 A | 2004-12-14 A | 100% | 2002-01-01 | 2004-12-14 | 771d? | finish no earlier than 2004-12-14 | R2 | 6168h | 6168h |  | Nokia | juho.pirskanen@nokia.com | Rel-6 | Yong-Jun |  | 25.346, 25.304, 25.321, 25.322, 25.323 |  |
| 4560 | 1169.8.2 | UE Performance Requirements for MBMS |  | 261d? | 2004-09-15 A | 2005-09-14 A | 100% | 2004-09-15 | 2005-09-14 | 261d? | finish no earlier than 2005-09-15 | R4 | 2088h | 2088h | MBMS-RAN-RF | Ericsson | Torgny.Palenius@ericsson.com | Rel-6 | Issam | MBMS-RAN-RF | 25.101, 25.133 |  |

Notes:
- 4536: -
- 4537: -
- 4538: -
- 4539: -
- 4540: -
- 4541: -
- 4542: -
- 4543: -
- 4544: -
- 4545: -
- 4546: SP#13 Title renamed
- 4547: -
- 4548: -
- 4549: -
- 4550: -
- 4551: -
- 4552: -
- 4553: SP#17 approved WID S3-020433
- 4554: SP#28 completed
- 4555: -
- 4556: -
- 4557: -
- 4558: -
- 4559: -
- 4560: RP#25 approved WID RP-040370

| ID | WBS | Task | Type | Duration | Start | Finish | Complete | Baseline start | Baseline finish | Baseline duration | Constraint | Deadline | Resources | Work | Actual work | Acronym | Release | MCC resp | Acronym_3GU_Export | Impacted TSs and TRs | WI rapporteur name | WI rapporteur e-mail | Created at | TSG stopped |
| --- | --- | --- | --- | --- | --- | --- | --- | --- | --- | --- | --- | --- | --- | --- | --- | --- | --- | --- | --- | --- | --- | --- | --- | --- |
| 4561 | 1169.9 | **MBMS UE Conformance Testing** |  | 521d? | 2006-03-10 A | 2008-03-07 A | 100% | 2006-03-10 | 2008-03-07 | 521d? |  |  | R5; T1 | 34400h | 34400h | MBMS-UEConTest | Rel-6 | Ingbert | MBMS-UEConTest |  |  |  |  |  |
| 4562 | 16.5.1 | RF/RRM Conformance Test Aspects – MBMS (FDD) |  | 461d | 2006-06-02 A | 2008-03-07 A | 100% | 2006-06-02 | 2008-03-07 | 461d | finish no earlier than 2008-03-07 | 2006-06-02 | R5; T1 | 7376h | 7376h | MBMS-RAN-RF_Test | Rel-6 | Ingbert | MBMS-RAN-RF_Test | 34.108, 34.109, 34.121-1, 34.121-2 | Ericsson | leif.mattisson@ericsson.com | Fri 11/03/05 |  |
| 4563 | 1169.9.2 | Conformance Test Aspects - MBMS for 3.84 Mcps and 7.68 Mcps TDD |  | 318d? | 2006-09-20 A | 2007-12-07 A | 100% | 2006-09-20 | 2007-12-07 | 318d? | finish no earlier than 2007-12-07 |  | R5; T1 | 5088h | 5088h | MBMS-UEConTest_TDH | Rel-6 | Ingbert | MBMS-UEConTest_TDH | 34.108, 34.122, 34.123-1, 34.123-2, 34.123-3 | IPWireless | Timothy Speight (tspeight@ipwireless.com) |  |  |
| 4564 | 1169.9.3 | Signalling Conformance Test Aspects – MBMS for LCR TDD |  | 318d? | 2006-09-20 A | 2007-12-07 A | 100% | 2006-09-20 | 2007-12-07 | 318d? | finish no earlier than 2007-12-07 |  | R5; T1 | 5088h | 5088h | MBMS-UEConTest_SIGTDL | Rel-6 | Ingbert | MBMS-UEConTest_SIGTDL | 34.108, 34.123-1, 34.123-2, 34.123-3 | Datang | zhaojian@datangmobile.cn |  |  |
| 4565 | 1169.9.4 | Conformance Test Aspects – MBMS |  | 396d? | 2006-03-10 A | 2007-09-14 A | 100% | 2006-03-10 | 2007-09-14 | 396d? | finish no earlier than 2007-09-14 |  | R5; T1 | 6336h | 6336h | MBMS_Test | Rel-6 | Ingbert | MBMS_Test | 34.108, 34.123-1, 34.123-2, 34.123-3 | Qualcomm | Shubhang Vora (svora@qualcomm.com) |  |  |
| 4566 | 16.5.1 | Conformance Test Aspects - 1.28 Mcps TDD MBMS RF/RRM |  | 136d | 2007-06-01 A | 2007-12-07 A | 100% | 2007-06-01 | 2007-12-07 | 136d | finish no earlier than 2007-12-07 | 2006-06-02 | R5; T1 | 2176h | 2176h | MBMS-UEConTest_RFTDL | Rel-6 | Ingbert | MBMS-UEConTest_RFTDL | 34.108, 34.109, 34.122 | Datang | chenxiaozhong@datangmobile.cn | Fri 11/03/05 |  |
| 4567 | 28.6 | **Support of MBMS in GERAN** |  | 892d? | 2001-08-30 A | 2005-01-28 A | 100% | 2001-08-30 | 2005-01-28 | 892d? |  |  | GP; G2; G3new | 87400h | 87400h | MBMS-GERAN | Rel-6 | Paolo | MBMS-GERAN |  |  |  |  |  |
| 4568 | 28.6.1 | MBMS Impact on the logical and physical channels |  | 631d | 2002-08-30 A | 2005-01-28 A | 100% | 2002-08-30 | 2005-01-28 | 631d | finish no earlier than 2005-01-28 |  | GP | 5048h | 5048h |  | Rel-6 | Paolo |  |  |  |  |  |  |
| 4569 | 28.6.4 | MBMS Re-synchronisation at cell change |  | 631d | 2002-08-30 A | 2005-01-28 A | 100% | 2002-08-30 | 2005-01-28 | 631d | finish no earlier than 2005-01-28 |  | G2 | 5048h | 5048h |  | Rel-6 | Gert |  |  |  |  |  |  |
| 4570 | 1169.10.3 | Simultaneous support of MBMS services |  | 631d? | 2002-08-30 A | 2005-01-28 A | 100% | 2002-08-30 | 2005-01-28 | 631d? | finish no earlier than 2005-01-28 |  | GP | 5048h | 5048h |  | Rel-6 | Paolo |  |  |  |  |  |  |
| 4571 | 1169.10.4 | Simultaneous support of MBMS and non-MBMS services |  | 892d? | 2001-08-30 A | 2005-01-28 A | 100% | 2001-08-30 | 2005-01-28 | 892d? | finish no earlier than 2005-01-28 |  | GP | 7136h | 7136h |  | Rel-6 | Paolo |  |  |  |  |  |  |
| 4572 | 1169.10.5 | MBMS Resynchronization at cell change |  | 892d? | 2001-08-30 A | 2005-01-28 A | 100% | 2001-08-30 | 2005-01-28 | 892d? | finish no earlier than 2005-01-28 |  | GP | 7136h | 7136h |  | Rel-6 | Paolo |  |  |  |  |  |  |
| 4573 | 28.6.5 | MBMS Decision making process between point-to-point or point-to-multipoint configurations |  | 631d | 2002-08-30 A | 2005-01-28 A | 100% | 2002-08-30 | 2005-01-28 | 631d | finish no earlier than 2005-01-28 |  | GP | 5048h | 5048h |  | Rel-6 | Paolo |  |  |  |  |  |  |
| 4574 | 28.6.6 | MBMS channel allocations procedures to multiple MSs |  | 631d | 2002-08-30 A | 2005-01-28 A | 100% | 2002-08-30 | 2005-01-28 | 631d | finish no earlier than 2005-01-28 |  | GP | 5048h | 5048h |  | Rel-6 | Paolo |  |  |  |  |  |  |
| 4575 | 28.6.7 | MBMS Changes to the Gb interface |  | 631d | 2002-08-30 A | 2005-01-28 A | 100% | 2002-08-30 | 2005-01-28 | 631d | finish no earlier than 2005-01-28 |  | GP | 5048h | 5048h |  | Rel-6 | Paolo |  |  |  |  |  |  |
| 4576 | 28.6.8 | GERAN specific changes to the Iu-ps interface for MBMS |  | 631d | 2002-08-30 A | 2005-01-28 A | 100% | 2002-08-30 | 2005-01-28 | 631d | finish no earlier than 2005-01-28 |  | GP | 5048h | 5048h |  | Rel-6 | Paolo |  |  |  |  |  |  |
| 4577 | 28.6.9 | Interaction between MBMS and Iu-flex |  | 631d | 2002-08-30 A | 2005-01-28 A | 100% | 2002-08-30 | 2005-01-28 | 631d | finish no earlier than 2005-01-28 |  | GP | 5048h | 5048h |  | Rel-6 | Paolo |  |  |  |  |  |  |
| 4578 | 28.6.10 | MBMS Security aspects |  | 631d | 2002-08-30 A | 2005-01-28 A | 100% | 2002-08-30 | 2005-01-28 | 631d | finish no earlier than 2005-01-28 |  | GP | 5048h | 5048h |  | Rel-6 | Paolo |  |  |  |  |  |  |
| 4579 | 1169.10.12 | MBMS-GERAN - MS conformance tests |  | 786d? | 2002-01-25 A | 2005-01-28 A | 100% | 2002-01-25 | 2005-01-28 | 786d? | finish no earlier than 2005-01-28 |  | G3new | 6288h | 6288h |  | Rel-6 | Ingbert |  |  |  |  |  |  |
| 4580 | 1169.10.13 | Deleted - MS conformance tests - G5 | milestone | 0d? | 2003-06-27 A | 2003-06-27 A | 100% | 2003-06-27 | 2003-06-27 | 0d? | start no earlier than 2003-06-27 |  | G5 |  |  |  | Rel-6 | Paolo |  |  |  |  |  | GP-19 |
| 4581 | 29 | **Speech Recognition and Speech Enabled Services** |  | 1105d? | 2001-10-08 A | 2005-12-30 A | 100% | 2001-10-08 | 2005-12-30 | 1105d? |  |  | S1; S2; S4; OMA | 46696h | 46696h | SRSES | Rel-6 | Alain | SRSES |  |  |  |  |  |
| 4582 | 29.1 | Speech Enabled Services Based on Distributed Speech Recognition (DSR) |  | 115d | 2001-10-08 A | 2002-03-15 A | 100% | 2001-10-08 | 2002-03-15 | 115d | finish no earlier than 2002-03-15 |  | S1 | 920h | 920h | DSR | Rel-6 | Alain | DSR | 22.977, 22.941, 23.207, 22.243 | Qualcomm | Dwilliams@qualcomm.com |  |  |
| 4583 | 29.2 | TR on Architectural impacts |  | 212d | 2003-05-12 A | 2004-03-02 A | 100% | 2003-05-12 | 2004-03-02 | 212d | finish no earlier than 2004-03-02 |  | S2 | 1696h | 1696h |  | Rel-6 | Maurice |  | 23.877 |  |  |  |  |
| 4584 | 1170.3 | Codec Work to Support Speech Recognition Framework for Automated Voice Services |  | 568d? | 2002-10-15 A | 2004-12-16 A | 100% | 2002-10-15 | 2004-12-16 | 568d? | finish no earlier than 2004-12-16 |  | S4 | 4544h | 4544h | SRSES-Codec | Rel-6 | Paolo | SRSES-Codec | 26.235, 26.236, 26.243, 26.177, 26.943 | Motorola | David Pearce (bdp003@motorola.com) |  |  |
| 4585 | 1170.4 | Multimodal support |  | 522d? | 2004-01-01 A | 2005-12-30 A | 100% | 2004-01-01 | 2005-12-30 | 522d? | finish no earlier than 2005-06-30 |  | OMA | 4176h | 4176h |  | Rel-6 | Paolo |  |  |  | OMA-LIAISON@mail.openmobilealliance.org | SP-24 |  |
| 4586 | 1170.5 | Deleted - SES codec negotiation at Session Description Protocol (SDP) | milestone | 0d? | 2003-06-04 A | 2003-06-04 A | 100% | 2003-06-04 | 2003-06-04 | 0d? | start no earlier than 2003-06-04 |  | N1 |  |  |  | Rel-6 | Frederic |  |  |  |  |  | NP-23 |

Notes:
- 4561: -
- 4562: -
- 4563: -
- 4564: -
- 4565: -
- 4566: -
- 4567: -
- 4568: -
- 4569: -
- 4570: -
- 4571: -
- 4572: -
- 4573: -
- 4574: -
- 4575: -
- 4576: -
- 4577: -
- 4578: -
- 4579: -
- 4580: -
- 4581: -
- 4582: -
- 4583: -
- 4584: -
- 4585: -
- 4586: Abandoned NP-23

| ID | WBS | Task | Type | Duration | Start | Finish | Complete | Baseline start | Baseline finish | Baseline duration | Constraint | Resources | Work | Actual work | Acronym | Release | MCC resp | Acronym_3GU_Export | WI rapporteur name | WI rapporteur e-mail | Created at | TSG stopped | Special Focus Doc |
| --- | --- | --- | --- | --- | --- | --- | --- | --- | --- | --- | --- | --- | --- | --- | --- | --- | --- | --- | --- | --- | --- | --- | --- |
| 4587 | 30 | **Generic User Profile Rel-6** |  | 889d | 2001-10-08 A | 2005-03-03 A | 100% | 2001-10-08 | 2005-03-03 | 889d |  | S1; S3; N4 | 38519.8h | 38519.8h | GUP | Rel-6 | Alain | GUP |  |  |  |  |  |
| 4588 | 30.1 | Stage 1 - Requirements for Generic User Profile |  | 430d | 2001-10-08 A | 2003-05-30 A | 100% | 2001-10-08 | 2003-05-30 | 430d | finish no earlier than 2002-12-09 | S1 | 3440h | 3440h |  | Rel-6 | Alain |  | T-Mobile | kurt.bischinger@t-mobile.at |  |  |  |
| 4589 | 30.3 | Stage 2 - Architecture |  | 355d | 2002-01-28 A | 2003-06-06 A | 100% | 2002-01-28 | 2003-06-06 | 355d | finish no earlier than 2003-06-06 | S2 | 2840h | 2840h |  | Rel-6 | Maurice |  | Nokia | harri.o.koskinen@nokia.com |  |  |  |
| 4590 | 30.2 | Stage 2 - Data Description Method |  | 586d | 2002-12-05 A | 2005-03-03 A | 100% | 2002-12-05 | 2005-03-03 | 586d | finish no earlier than 2005-03-03 | N4 | 4688h | 4688h |  | Rel-6 | Kimmo |  | T-Mobile | kurt.bischinger@t-mobile.at |  |  |  |
| 4591 | 30.5 | Stage 3 - Network |  | 468.98d | 2003-05-19 A | 2005-03-03 A | 100% | 2003-05-19 | 2005-03-03 | 468.98d | finish no earlier than 2005-03-03 | N4 | 3751.83h | 3751.83h |  | Rel-6 | Kimmo |  |  |  |  |  |  |
| 4592 | 30.6 | Security aspects of GUP |  | 308d | 2002-07-16 A | 2003-09-18 A | 100% | 2002-07-16 | 2003-09-18 | 308d | finish no earlier than 2003-09-18 | S3 | 2464h | 2464h |  | Rel-6 | Mirko |  | Lucent | Bradley Owen (bvowen@lucent.com) |  |  |  |
| 4593 | 31 | **Digital Rights Management** |  | 690d? | 2001-10-08 A | 2004-05-28 A | 100% | 2001-10-08 | 2004-05-28 | 690d? |  | S1; OMA | 15672h | 15672h | DRM | Rel-6 | Alain | DRM |  |  |  |  |  |
| 4594 | 31.1 | Requirements for Digital Rights Management |  | 179d | 2001-10-08 A | 2002-06-13 A | 100% | 2001-10-08 | 2002-06-13 | 179d | finish no earlier than 2002-06-13 | S1 | 1432h | 1432h |  | Rel-6 | Alain |  | Openwave | nicholas.wood@openwave.com |  |  |  |
| 4595 | 1172.2 | Stage 2 for Digital Rights Management |  | 107d? | 2004-01-01 A | 2004-05-28 A | 100% | 2004-01-01 | 2004-05-28 | 107d? | finish no earlier than 2004-05-28 | OMA | 856h | 856h |  | Rel-6 |  |  |  | OMA-LIAISON@mail.openmobilealliance.org | SP-24 |  |  |
| 4596 | 1172.3 | Stage 3 for Digital Rights Management |  | 107d? | 2004-01-01 A | 2004-05-28 A | 100% | 2004-01-01 | 2004-05-28 | 107d? | finish no earlier than 2004-05-28 | OMA | 856h | 856h |  | Rel-6 |  |  |  | OMA-LIAISON@mail.openmobilealliance.org | SP-24 |  |  |
| 4597 | 31.3 | Security for Digital Rights Management |  | 186d | 2002-06-17 A | 2003-03-03 A | 100% | 2002-06-17 | 2003-03-03 | 186d | finish no earlier than 2003-03-03 | OMA | 1488h | 1488h |  | Rel-6 |  |  |  |  |  |  |  |
| 4598 | 1172.5 | Deleted - Monitoring of Stages 2 and 3 progress (actual work to be done by OMA) | milestone | 0d? | 2003-03-21 A | 2003-03-21 A | 100% | 2003-03-21 | 2003-03-21 | 0d? | start no earlier than 2002-08-19 | S1 |  |  |  | Rel-6 | Alain |  |  |  |  | SP-19 |  |
| 4599 | 32 | **WLAN-UMTS Interworking Rel-6** |  | 1495d? | 2000-01-03 A | 2005-09-22 A | 100% | 2000-01-03 | 2005-09-22 | 1495d? |  | S1; S2; S3; S5; N1; N3; N4; T3 | 129192h | 129192h | WLAN | Rel-6 | Alain | WLAN | Telenor | frederic.paint@telenor.com |  |  | WLAN |
| 4600 | 32.1 | Technical Report on WLAN-UMTS Interworking |  | 901d? | 2000-01-03 A | 2003-06-13 A | 100% | 2000-01-03 | 2003-06-13 | 901d? | finish no earlier than 2003-06-13 | S1 | 7200h | 7200h | WLAN-TR | Rel-6 | Alain | WLAN-TR | T-mobile | Mark.Younge@t-mobile.com |  |  | WLAN |
| 4601 | 1173.2 | Stage 1 for WLAN-UMTS Interworking Rel-6 |  | 375d? | 2003-01-06 A | 2004-06-11 A | 100% | 2003-01-06 | 2004-06-11 | 375d? |  | S1 | 920h | 920h | WLAN-TS | Rel-6 | Alain | WLAN-TS | Telenor | frederic.paint@telenor.com | SP-24 |  | WLAN |
| 4602 | 32.2 | Architecture Definition for scenarii 2 and 3 |  | 571d | 2002-03-25 A | 2004-05-31 A | 100% | 2002-03-25 | 2004-05-31 | 571d | finish no earlier than 2004-05-31 | S2 | 4568h | 4568h |  | Rel-6 | Maurice |  |  |  |  |  | WLAN |
| 4603 | 32.3 | Security aspects of WLAN-UMTS Interworking |  | 125d | 2002-09-30 A | 2003-03-21 A | 100% | 2002-09-30 | 2003-03-21 | 125d | finish no earlier than 2003-03-21 | S3 | 1000h | 1000h |  | Rel-6 | Mirko |  | Ericsson, BT | luis.lopez-soria@ece.ericsson.se, colin.blanchard@bt.com |  |  | WLAN |
| 4604 | 1173.5 | Stage 3 - CN4 aspects |  | 334d? | 2003-05-23 A | 2004-09-01 A | 100% | 2003-05-23 | 2004-09-01 | 334d? | finish no earlier than 2004-09-01 | N4 | 2672h | 2672h | WLAN-IW | Rel-6 | Kimmo | WLAN-IW | Nokia | raquel.rodriguez@nokia.com |  |  | WLAN |
| 4605 | 1173.6 | Stage 3 - CN3 aspects (Wi Interface for Scenario 3) |  | 355d? | 2003-05-23 A | 2004-09-30 A | 100% | 2003-05-23 | 2004-09-30 | 355d? | start no earlier than 2003-05-23 | N3 | 2840h | 2840h |  | Rel-6 | Gwiho |  |  |  | SP-24 |  | WLAN |
| 4606 | 1173.7 | Stage 3 for scenario 2 |  | 339d? | 2003-05-23 A | 2004-09-08 A | 100% | 2003-05-23 | 2004-09-08 | 339d? | finish no earlier than 2004-09-08 | N1 | 2712h | 2712h |  | Rel-6 | Frederic |  |  |  |  |  | WLAN |
| 4607 | 1173.8 | Stage 3 for scenario 3 |  | 404d? | 2003-05-23 A | 2004-12-08 A | 100% | 2003-05-23 | 2004-12-08 | 404d? | finish no earlier than 2004-12-08 | N1 | 3232h | 3232h |  | Rel-6 | Frederic |  |  |  | SP-24 |  | WLAN |
| 4608 | 1173.9 | WLAN charging |  | 655d? | 2003-03-21 A | 2005-09-22 A | 100% | 2003-03-21 | 2005-09-22 | 655d? | finish no earlier than 2005-09-22 | S5 | 5240h | 5240h | WLAN-CH | Rel-6 | Mirko | WLAN-CH | Nokia | Benni ALEXANDER |  |  | WLAN |
| 4609 | 1173.10 | USIM enhancements for WLAN Interworking |  | 391d? | 2003-09-05 A | 2005-03-04 A | 100% | 2003-09-05 | 2005-03-04 | 391d? | finish no earlier than 2005-03-04 | T3 | 3128h | 3128h |  | Rel-6 | Xavier |  | Axalto | Jabellan@axalto.com |  |  | WLAN |
| 4610 | 33 | **Priority Service** |  | 347d? | 2002-05-30 A | 2003-09-26 A | 100% | 2002-05-30 | 2003-09-26 | 347d? |  | S1 | 6464h | 6464h | PRIOR1 | Rel-6 | Alain | PRIOR1 | Telcordia | James Garrahan (jgarraha@telcordia.com) |  |  | Public Safety (I-A) |
| 4611 | 33.1 | Feasibility Study on Priority Service |  | 1d | 2002-06-14 A | 2002-06-14 A | 100% | 2002-06-14 | 2002-06-14 | 1d | finish no earlier than 2002-06-14 | S1 | 8h | 8h | PRIOR-FS | Rel-6 | Alain | PRIOR-FS | Telcordia | James Garrahan (jgarraha@telcordia.com) |  |  | Public Safety (I-A) |
| 4612 | 33.2 | Stage 1 - Requirements for Priority Service |  | 340d | 2002-05-30 A | 2003-09-17 A | 100% | 2002-05-30 | 2003-09-17 | 340d | finish no earlier than 2003-09-17 | S1 | 2720h | 2720h | PRIOR-SR | Rel-6 | Alain | PRIOR-SR | Telcordia | James Garrahan (jgarraha@telcordia.com) |  |  | Public Safety (I-A) |
| 4613 | 1174.3 | Priority service implementation guide |  | 131d? | 2003-03-28 A | 2003-09-26 A | 100% | 2003-03-28 | 2003-09-26 | 131d? | finish no earlier than 2003-09-26 | S1 | 1048h | 1048h |  | Rel-6 | Alain |  | Telcordia | James Garrahan (jgarraha@telcordia.com) |  |  | Public Safety (I-A) |

Notes:
- 4587: -
- 4588: - / Impacted TSs and TRs: 22.240, 22.228
- 4589: - / Impacted TSs and TRs: 23.240
- 4590: TR approved in CN#26 / Impacted TSs and TRs: 23.241
- 4591: - / Impacted TSs and TRs: 29.240
- 4592: SP#19 approved WID / Impacted TSs and TRs: 33.102, 33.203, 33.210
- 4593: Foreseen start and completion dates introduced by MCC (no indication at all on the WID)
- 4594: -
- 4595: -
- 4596: -
- 4597: SA3 acknowledge role in WI at SA3#20. Active contribution S3#24, S3#25. S3 WID approved SP#17
- 4598: Replaced by UID 60005 and 60006
- 4599: -
- 4600: - / Impacted TSs and TRs: 22.934
- 4601: - / Impacted TSs and TRs: 22.101, 22.105
- 4602: - / Impacted TSs and TRs: 23.234
- 4603: SP#17 approved WID S3-020451 / Impacted TSs and TRs: 21.133, 33.106, 33.107, 33.108, 33.200, 33.203, 33.210, New 33.234
- 4604: WID approved at CN#19 / Impacted TSs and TRs: 29.234, 29.061
- 4605: - / Impacted TSs and TRs: 29.161
- 4606: -
- 4607: -
- 4608: - / Impacted TSs and TRs: 32.252
- 4609: - / Impacted TSs and TRs: 31.102
- 4610: -
- 4611: - / Impacted TSs and TRs: 22.950
- 4612: -
- 4613: - / Impacted TSs and TRs: 22.952

| ID | WBS | Task | Type | Duration | Start | Finish | Complete | Baseline start | Baseline finish | Baseline duration | Constraint | Deadline | Resources | Work | Actual work | Acronym | WI rapporteur name | WI rapporteur e-mail | Release | MCC resp | Acronym_3GU_Export | Created at | TSG stopped |
| --- | --- | --- | --- | --- | --- | --- | --- | --- | --- | --- | --- | --- | --- | --- | --- | --- | --- | --- | --- | --- | --- | --- | --- |
| 4614 | 34 | **Network Sharing** |  | 820d? | 2003-01-20 A | 2006-03-10 A | 100% | 2003-01-20 | 2006-03-10 | 820d? |  |  | S1; S2; N1; R2; R5 | 44936h | 44936h | NTShar | T-Mobile | michele.zarri@t-mobile.co.uk | Rel-6 | Alain | NTShar |  |  |
| 4615 | 34.1 | Technical Report on Network Sharing |  | 240d? | 2003-01-20 A | 2003-12-19 A | 100% | 2003-01-20 | 2003-12-19 | 240d? |  |  | S1 | 1920h | 1920h | NTShar-TR | T-Mobile | michele.zarri@t-mobile.co.uk | Rel-6 | Alain | NTShar-TR |  |  |
| 4616 | 1175.2 | Stage 1 - CRs to implement Network Sharing |  | 240d? | 2003-01-20 A | 2003-12-19 A | 100% | 2003-01-20 | 2003-12-19 | 240d? | finish no earlier than 2003-12-19 |  | S1 | 1920h | 1920h | NTSharCR | T-Mobile | michele.zarri@t-mobile.co.uk | Rel-6 | Alain | NTSharCR |  |  |
| 4617 | 1175.3 | Stage 2 for Network Sharing |  | 372d? | 2003-02-27 A | 2004-07-30 A | 100% | 2003-02-27 | 2004-07-30 | 372d? | finish no earlier than 2004-07-30 |  | S2 | 2976h | 2976h |  | T-Mobile | michele.zarri@t-mobile.co.uk | Rel-6 | Maurice |  |  |  |
| 4618 | 1175.4 | Network sharing - stage 3 |  | 404d? | 2003-05-23 A | 2004-12-08 A | 100% | 2003-05-23 | 2004-12-08 | 404d? | finish no earlier than 2004-12-08 |  | N1 | 3232h | 3232h |  | T-Mobile | michele.zarri@t-mobile.co.uk | Rel-6 | Frederic |  |  |  |
| 4619 | 1175.5 | Enhancement of the support of network sharing in the UTRAN | milestone | 0d | 2003-09-19 A | 2003-09-19 A | 100% | 2003-09-19 | 2003-09-19 | 0d |  |  | R2 |  |  | NTShar-UTRANEnh | TeliaSonera | Anders.Dahlen@TeliaSonera.com | Rel-6 | Yong-Jun | NTShar-UTRANEnh |  |  |
| 4620 | 16.5.1 | Conformance Test Aspects – Network Sharing |  | 261d | 2005-03-11 A | 2006-03-10 A | 100% | 2005-03-11 | 2006-03-10 | 261d | finish no earlier than 2006-03-10 | 2006-03-10 | R5 | 2088h | 2088h | NTShar-UTRANEnh_Test | TeliaSonera | Niklas.Wiren@TeliaSonera.com | Rel-6 | Ingbert | NTShar-UTRANEnh_Test | Fri 11/03/05 |  |
| 4621 | 35 | **QoS Improvements** |  | 628d? | 2002-07-15 A | 2004-12-08 A | 100% | 2002-07-15 | 2004-12-08 | 628d? |  |  | S2; N3 | 18152h | 18152h | QoS1 | Nokia |  | Rel-6 | Maurice | QoS1 |  |  |
| 4622 | 35.1 | FS on Dynamic Policy control enhancements for end-to-end QoS |  | 465d | 2002-07-15 A | 2004-04-23 A | 100% | 2002-07-15 | 2004-04-23 | 465d | finish no earlier than 2004-04-23 |  | S2 | 3720h | 3720h |  | Nortel | Claire Mousset | Rel-6 | Maurice |  |  |  |
| 4623 | 1176.2 | Definition of the Gq interface |  | 214d? | 2003-07-01 A | 2004-04-23 A | 100% | 2003-07-01 | 2004-04-23 | 214d? | finish no earlier than 2004-04-23 |  | S2 | 1712h | 1712h |  |  | Janne Rinne | Rel-6 | Maurice |  |  |  |
| 4624 | 1176.3 | Gq interface specification for Dynamic Policy control enhancements – Stage 3 |  | 334d | 2003-08-29 A | 2004-12-08 A | 100% | 2003-08-29 | 2004-12-08 | 334d | finish no earlier than 2004-12-08 |  | N3 | 2672h | 2672h |  | Nokia | Anna.Sillanpaai@nokia.com | Rel-6 | Gwiho |  |  |  |
| 4625 | 36 | **Subscriber certificates** |  | 728d? | 2002-02-25 A | 2004-12-08 A | 100% | 2002-02-25 | 2004-12-08 | 728d? |  |  | S3; S2; N1; N4; T3; OMA | 44512h | 44512h | SEC1-SC | Nokia | valtteri.niemi@nokia.com | Rel-6 | Mirko | SEC1-SC |  |  |
| 4626 | 36.1 | Stage 1 of Subscriber certificates |  | 144d | 2002-02-25 A | 2002-09-12 A | 100% | 2002-02-25 | 2002-09-12 | 144d | finish no earlier than 2002-09-12 |  | S3 | 1152h | 1152h |  | Nokia | valtteri.niemi@nokia.com | Rel-6 | Mirko |  |  |  |
| 4627 | 36.2 | Architecture review |  | 24d | 2002-10-14 A | 2002-11-14 A | 100% | 2002-10-14 | 2002-11-14 | 24d | finish no earlier than 2002-11-14 |  | S2 | 192h | 192h |  | Nokia |  | Rel-6 | Maurice |  |  |  |
| 4628 | 1177.3 | Stage 3 for Subscriber certificates |  | 313d? | 2003-09-19 A | 2004-11-30 A | 100% | 2003-09-19 | 2004-11-30 | 313d? | finish no earlier than 2004-11-30 |  | N4; T3 | 5008h | 5008h |  | Nokia | Lauri Laitinen | Rel-6 | Kimmo |  |  |  |
| 4629 | 1177.4 | Stage 3 Ua & Ub interfaces |  | 288d? | 2003-11-03 A | 2004-12-08 A | 100% | 2003-11-03 | 2004-12-08 | 288d? | finish no earlier than 2004-12-08 |  | N1 | 2304h | 2304h |  | Nokia |  | Rel-6 | Frederic |  |  |  |
| 4630 | 1177.5 | OMA dependencies on Subscriber certificates |  | 114d? | 2004-01-01 A | 2004-06-08 A | 100% | 2004-01-01 | 2004-06-08 | 114d? | finish no earlier than 2004-06-08 |  | OMA | 912h | 912h |  | Nokia | OMA-LIAISON@mail.openmobilealliance.org | Rel-6 |  |  | SP-24 |  |
| 4631 | 1178 | **Rel-6 Open Service Access (OSA) enhancements** |  | 616d? | 2002-10-31 A | 2005-03-10 A | 100% | 2002-10-31 | 2005-03-10 | 616d? |  |  | N5 | 22576h | 22576h | OSA3 | Alcatel | Chelo.Abarca@alcatel.fr | Rel-6 | Kimmo | OSA3 |  |  |
| 4632 | 1178.1 | Scope of the Open Service Access Release 6 |  | 66d? | 2003-03-28 A | 2003-06-27 A | 100% | 2003-03-28 | 2003-06-27 | 66d? | finish no earlier than 2003-06-27 |  | S1 | 528h | 528h |  |  |  | Rel-6 | Alain |  |  |  |
| 4633 | 1178.2 | OSA Stage 2 |  | 150d? | 2004-08-13 A | 2005-03-10 A | 100% | 2004-08-13 | 2005-03-10 | 150d? | finish no earlier than 2005-03-10 |  | N5 | 1200h | 1200h |  |  |  | Rel-6 | Kimmo |  |  |  |
| 4634 | 1178.3 | Multi Media Messaging function |  | 487d? | 2002-10-31 A | 2004-09-10 A | 100% | 2002-10-31 | 2004-09-10 | 487d? | finish no earlier than 2004-09-10 |  | N5 | 3896h | 3896h |  |  |  | Rel-6 | Kimmo |  |  |  |
| 4635 | 1178.4 | Policy management extensions |  | 292d? | 2002-10-31 A | 2003-12-12 A | 100% | 2002-10-31 | 2003-12-12 | 292d? | finish no earlier than 2003-12-12 |  | N5 | 2336h | 2336h |  |  |  | Rel-6 | Kimmo |  |  |  |
| 4636 | 1178.5 | TS on Presence and Availability Management (from the PRESNC WI) |  | 367d? | 2002-10-31 A | 2004-03-26 A | 100% | 2002-10-31 | 2004-03-26 | 367d? | finish no earlier than 2004-03-26 |  | N5 | 2936h | 2936h |  |  |  | Rel-6 | Kimmo |  |  |  |
| 4637 | 1178.6 | OSA interfaces at different levels of abstractions (Parlay X, Web services) |  | 305d? | 2003-07-14 A | 2004-09-10 A | 100% | 2003-07-14 | 2004-09-10 | 305d? | finish no earlier than 2004-09-10 |  | N5 | 2440h | 2440h |  |  |  | Rel-6 | Kimmo |  |  |  |
| 4638 | 1178.7 | Introduction of migration support mechanism |  | 290d? | 2002-10-31 A | 2003-12-10 A | 100% | 2002-10-31 | 2003-12-10 | 290d? | finish no earlier than 2003-12-12 |  | N5 | 2320h | 2320h |  |  |  | Rel-6 | Kimmo |  |  |  |
| 4639 | 1178.8 | Framework Function for Federation |  | 225d? | 2003-02-03 A | 2003-12-12 A | 100% | 2003-02-03 | 2003-12-12 | 225d? | finish no earlier than 2003-12-12 |  | N5 | 1800h | 1800h |  |  |  | Rel-6 | Kimmo |  |  |  |
| 4640 | 1178.9 | OMA potential overlaps with 3GPP OSA Stage 3 (Web services) |  | 196d? | 2003-12-18 A | 2004-09-16 A | 100% | 2003-12-18 | 2004-09-16 | 196d? | start no earlier than 2003-12-18 |  | OMA | 1568h | 1568h |  |  |  | Rel-6 |  |  | SP-24 |  |
| 4641 | 1178.10 | Deleted - TR on Presence and Availability Management (from the PRESNC WI) | milestone | 0d? | 2004-09-17 A | 2004-09-17 A | 100% | 2004-09-17 | 2004-09-17 | 0d? | start no earlier than 2004-09-17 |  | N5 |  |  |  |  |  | Rel-6 | Kimmo |  |  | NP-24 |

Notes:
- 4614: -
- 4615: - / Impacted TSs and TRs: 22.951
- 4616: - / Impacted TSs and TRs: 22.011, 22.101, 22.115, 22.129
- 4617: - / Impacted TSs and TRs: 23.002, 23.060, 23.221, 23.236, new TS 23.251, TR 23.851
- 4618: - / Impacted TSs and TRs: 23.008, 23.122, 24.007, 24.008, 29.018
- 4619: - / Impacted TSs and TRs: 25.401, 25.413, 25.331, 25.304
- 4620: - / Impacted TSs and TRs: 34.108, 34.123-1, 34.123-2, 34.123-3
- 4621: - / Impacted TSs and TRs: 23.107, 23.207, 23.221
- 4622: - / Impacted TSs and TRs: 23.917 withdrawn (Contents all in 23.207)
- 4623: - / Impacted TSs and TRs: 23.207
- 4624: [DAB - 25.05.04] - Delayed to Sept - possibly Dec 2004 / Impacted TSs and TRs: 29.207, 29.208, 29.209
- 4625: SP#14 approved WID
- 4626: - / Impacted TSs and TRs: New (33.220, 33.221, 33.222, 33.246, 33.919)
- 4627: -
- 4628: Finished in CN4#26 / Impacted TSs and TRs: 23.003, 23.008, 29.109, 29.230, T3 31.102, 31.103, 31.111
- 4629: - / Impacted TSs and TRs: 24.109
- 4630: Updated according to SP-040420
- 4631: CN#25: Updated WID NP-040351 replaces NP-040144. / Impacted TSs and TRs: 22.127, 23.198, 29.198, 29.199, 29.998
- 4632: -
- 4633: Inherited by CN5 from SA2 at TSG#25 Sep 2004. SA2's 23.127 (OSA/VHE Stage 2) replaced from Rel-6 onwards by a new CN5 TS 23.198 (Stage 2 OSA-only). / Impacted TSs and TRs: 23.198 OSA Stage 2-ONLY replaces 23.127 (OSA/VHE) from Rel-6 onwards
- 4634: - / Impacted TSs and TRs: 29.198-15
- 4635: - / Impacted TSs and TRs: 29.198, 29.998
- 4636: N5#26: Split WI into TS & TR. / Impacted TSs and TRs: 29.198-14
- 4637: - / Impacted TSs and TRs: 29.199
- 4638: - / Impacted TSs and TRs: 29.198, 29.998
- 4639: - / Impacted TSs and TRs: 29.198, 29.998
- 4640: TSG#25 Approved CN5 29.199 Parlay X Web services. Ongoing 3GPP/OMA co-ordination to avoid OMA producing conflicting/OVERLAPING specs (NP-040283/SP-040493).
- 4641: N5#26:TR Completion 09/04; consistent with CN1 delayed Rel-6 completion.

| ID | WBS | Task | Duration | Start | Finish | Complete | Baseline start | Baseline finish | Baseline duration | Constraint | Resources | Work | Actual work | Acronym | WI rapporteur name | WI rapporteur e-mail | Release | MCC resp | Acronym_3GU_Export | TSG stopped |
| --- | --- | --- | --- | --- | --- | --- | --- | --- | --- | --- | --- | --- | --- | --- | --- | --- | --- | --- | --- | --- |
| 4642 | 39 | **Addition of frequency bands to GSM (TAPS)** | 676d | 2002-06-28 A | 2005-01-28 A | 100% | 2002-06-28 | 2005-01-28 | 676d |  | GP | 16640h | 16640h | TAPS | Nokia | Torben Themsen | Rel-6 | Paolo | TAPS |  |
| 4643 | 39.1 | **Addition of frequency bands to GSM – Changes to core specs** | 26d | 2002-11-15 A | 2002-12-20 A | 100% | 2002-11-15 | 2002-12-20 | 26d |  | G1 | 416h | 416h | TAPS-Specs | Nokia | Torben Themsen | Rel-6 | Paolo | TAPS-Specs |  |
| 4644 | 39.1.1 | Changes to core specs | 26d | 2002-11-15 A | 2002-12-20 A | 100% | 2002-11-15 | 2002-12-20 | 26d | finish no earlier than 2002-12-20 | G1 | 208h | 208h |  | Nokia | Torben Themsen | Rel-6 | Paolo |  |  |
| 4645 | 39.2 | **Deleted - Addition of frequency bands to GSM – Changes for conformance tests** | 676d | 2002-06-28 A | 2005-01-28 A | 100% | 2002-06-28 | 2005-01-28 | 676d |  | G4 | 10816h | 10816h | TAPS-Conf | Nokia | Torben Themsen | Rel-6 | Paolo | TAPS-Conf | GP-23 |
| 4646 | 39.2.1 | Deleted - 51.010-1 Add testing | 676d | 2002-06-28 A | 2005-01-28 A | 100% | 2002-06-28 | 2005-01-28 | 676d | finish no earlier than 2005-01-28 | G4 | 5408h | 5408h |  | Nokia | Torben Themsen | Rel-6 | Paolo |  | GP-23 |
| 4647 | 40 | **Seamless support of streaming services in A/Gb mode** | 1426d? | 2000-01-03 A | 2005-06-17 A | 100% | 2000-01-03 | 2005-06-17 | 1426d? |  | GP; S3 | 70312h | 70312h | SSStrea | Vodafone | José Luis Carrizo Martínez | Rel-6 | Paolo | SSStrea |  |
| 4648 | 40.1 | **Identification of requirements for streaming** | 46d? | 2003-06-27 A | 2003-08-29 A | 100% | 2003-06-27 | 2003-08-29 | 46d? |  | G1 | 736h | 736h |  | Vodafone | José Luis Carrizo Martínez | Rel-6 | Paolo |  |  |
| 4649 | 1180.1.1 | Requirements for streaming | 46d? | 2003-06-27 A | 2003-08-29 A | 100% | 2003-06-27 | 2003-08-29 | 46d? | finish no earlier than 2003-08-29 | G1 | 368h | 368h |  | Vodafone | José Luis Carrizo Martínez | Rel-6 | Paolo |  |  |
| 4650 | 40.2 | **Performance study of cell change mechanisms** | 956d? | 2000-01-03 A | 2003-08-29 A | 100% | 2000-01-03 | 2003-08-29 | 956d? |  | G1 | 30568h | 30568h |  | Vodafone | José Luis Carrizo Martínez | Rel-6 | Paolo |  |  |
| 4651 | 1180.2.1 | Performance of NACC | 956d? | 2000-01-03 A | 2003-08-29 A | 100% | 2000-01-03 | 2003-08-29 | 956d? | finish no earlier than 2003-08-29 | G1 | 7640h | 7640h |  | Vodafone | José Luis Carrizo Martínez | Rel-6 | Paolo |  |  |
| 4652 | 1180.2.2 | Performance of cell change in DTM for the PS domain | 956d? | 2000-01-03 A | 2003-08-29 A | 100% | 2000-01-03 | 2003-08-29 | 956d? | finish no earlier than 2003-08-29 | G1 | 7640h | 7640h |  | Vodafone | José Luis Carrizo Martínez | Rel-6 | Paolo |  |  |
| 4653 | 1180.2.3 | Handover for Seamless support of streaming services in A/Gb mode | 956d? | 2000-01-03 A | 2003-08-29 A | 100% | 2000-01-03 | 2003-08-29 | 956d? | finish no earlier than 2003-08-29 | G1 | 7640h | 7640h |  | Vodafone | José Luis Carrizo Martínez | Rel-6 | Paolo |  |  |
| 4654 | 40.3 | **Reduction of service interruption times and packet loss during mobility procedures** | 516d? | 2003-06-27 A | 2005-06-17 A | 100% | 2003-06-27 | 2005-06-17 | 516d? |  | G2 | 10800h | 10800h |  | Vodafone | José Luis Carrizo Martínez | Rel-6 | Gert |  |  |
| 4655 | 1180.3.1 | optimizations of existing mechanisms/procedures | 106d? | 2003-06-27 A | 2003-11-21 A | 100% | 2003-06-27 | 2003-11-21 | 106d? | finish no earlier than 2003-11-21 | G2 | 848h | 848h |  | Vodafone | José Luis Carrizo Martínez | Rel-6 | Gert |  |  |
| 4656 | 1180.3.2 | Inter-system NACC | 106d? | 2003-06-27 A | 2003-11-21 A | 100% | 2003-06-27 | 2003-11-21 | 106d? | finish no earlier than 2003-11-21 | G2 | 848h | 848h |  | Vodafone | José Luis Carrizo Martínez | Rel-6 | Gert |  |  |
| 4657 | 1180.3.3 | PS Handover (within GERAN and between GERAN and UTRAN) | 516d? | 2003-06-27 A | 2005-06-17 A | 100% | 2003-06-27 | 2005-06-17 | 516d? | finish no earlier than 2003-11-21 | G2 | 4128h | 4128h |  | Vodafone | José Luis Carrizo Martínez | Rel-6 | Gert |  |  |
| 4658 | 1180.3.4 | Dependency to other features of Reduction of service interruption times and packet loss during mobility procedures | 106d? | 2003-06-27 A | 2003-11-21 A | 100% | 2003-06-27 | 2003-11-21 | 106d? | finish no earlier than 2003-11-21 | G2 | 848h | 848h |  | Vodafone | José Luis Carrizo Martínez | Rel-6 | Gert |  |  |
| 4659 | 40.5 | **Deleted - MS conformance testing for Seamless support of streaming services in A/Gb mode** | 31d? | 2003-12-19 A | 2004-01-30 A | 100% | 2003-12-19 | 2004-01-30 | 31d? |  | G3new | 496h | 496h |  | Vodafone | José Luis Carrizo Martínez | Rel-6 | Ingbert |  | GP-27 |
| 4660 | 1180.4.1 | Deleted - MS conformance tests for Seamless support of streaming services in A/Gb mode | 31d? | 2003-12-19 A | 2004-01-30 A | 100% | 2003-12-19 | 2004-01-30 | 31d? | finish no earlier than 2004-01-30 | G4; G5 | 496h | 496h |  | Vodafone | José Luis Carrizo Martínez | Rel-6 | Ingbert |  | GP-27 |
| 4661 | 1180.5 | GERAN A/Gb mode security enhancements | 612d? | 2002-09-26 A | 2005-01-28 A | 100% | 2002-09-26 | 2005-01-28 | 612d? | finish no earlier than 2005-01-28 | S3 | 4896h | 4896h |  | Vodafone | peter.howard@vodafone.com | Rel-6 | Mirko |  |  |
| 4662 | 41 | Performance characterisation of default codecs for PS conversational multimedia application | 455d | 2002-09-13 A | 2004-06-10 A | 100% | 2002-09-13 | 2004-06-10 | 455d | finish no earlier than 2004-06-10 | S4 | 3640h | 3640h | CODCAR | Nokia | pasi.s.ojala@nokia.com | Rel-6 | Paolo | CODCAR |  |
| 4663 | 43 | Study on Privacy Capability | 83d | 2003-11-10 A | 2004-03-03 A | 100% | 2003-11-10 | 2004-03-03 | 83d | start no earlier than 2003-11-10 | S1 | 664h | 664h | PrivCap | Lucent | Michael Boote (mboote@alcatel-lucent.com) | Rel-6 | Alain | PrivCap |  |
| 4664 | 44 | **Rel-6 Operations, Administration, Maintenance and Provisioning (OAM&P)** | 652d? | 2002-09-12 A | 2005-03-11 A | 100% | 2002-09-12 | 2005-03-11 | 652d? |  | S5 | 42635.5h | 42635.5h | OAM6 |  |  | Rel-6 | Mirko | OAM6 |  |
| 4665 | 44.1 | Principles, high level Requirements and Architecture | 526d | 2002-09-12 A | 2004-09-16 A | 100% | 2002-09-12 | 2004-09-16 | 526d | finish no earlier than 2004-09-16 | S5 | 4208h | 4208h |  | Motorola |  | Rel-6 | Mirko |  |  |
| 4666 | 44.2 | Performance Management | 591d | 2002-09-12 A | 2004-12-16 A | 100% | 2002-09-12 | 2004-12-16 | 591d | finish no earlier than 2004-12-16 | S5 | 4728h | 4728h |  | Nortel |  | Rel-6 | Mirko |  |  |
| 4667 | 44.4 | Network Infrastructure Management | 591d | 2002-09-12 A | 2004-12-16 A | 100% | 2002-09-12 | 2004-12-16 | 591d | finish no earlier than 2004-12-16 | S5 | 4728h | 4728h |  | Ericsson | thomas.tovinger@ericsson.com | Rel-6 | Mirko |  |  |

Notes:
- 4642: -
- 4643: -
- 4644: -
- 4645: -
- 4646: -
- 4647: -
- 4648: -
- 4649: -
- 4650: -
- 4651: -
- 4652: -
- 4653: -
- 4654: Completed at GERP#17
- 4655: -
- 4656: -
- 4657: -
- 4658: -
- 4659: Marked as stopped 10/2009
- 4660: Marked as stopped 10/2009
- 4661: SP#19 approved WID / Impacted TSs and TRs: 33.102
- 4662: - / Impacted TSs and TRs: 26.935
- 4663: - / Impacted TSs and TRs: 22.949
- 4664: SP#26: Updated WID SP-040766 was SP-020445. Completion delayed 12/04->03/05 due to OAM-Trace in CN1/4.
- 4665: SP#25 09/2004 completed / Impacted TSs and TRs: 32.101, 32.102
- 4666: SP#26 12/2004 completed / Impacted TSs and TRs: 32.401, 32.403, 52.402, 32.411, 32.412, 32.413, 32.432, 32.435, 32.436
- 4667: SP#26 12/2004 completed / Impacted TSs and TRs: 32.150/1/2, 32.805, 32.111-5, 32.313/4, 32.331/2/3/4/5, 32.341/2/3/4, 32.351/2/3/4, 32.361/2/3/4, 32.371/2/3/4, 32.804, 32.675, 32.690, 32.695, 32.71/2/3/4/5, 32.741/2/3/4/5

| ID | WBS | Task | Duration | Start | Finish | Complete | Baseline start | Baseline finish | Baseline duration | Constraint | Resources | Work | Actual work | Acronym | WI rapporteur name | WI rapporteur e-mail | Release | MCC resp | Acronym_3GU_Export | Impacted TSs and TRs | Created at | TSG stopped |
| --- | --- | --- | --- | --- | --- | --- | --- | --- | --- | --- | --- | --- | --- | --- | --- | --- | --- | --- | --- | --- | --- | --- |
| 4668 | 44.5 | **Rel-6 Trace Management** | 646d? | 2002-09-20 A | 2005-03-11 A | 100% | 2002-09-20 | 2005-03-11 | 646d? |  | S5; N4; R3 | 23877.9h | 23877.9h | OAM-Trace | Nokia | kari.t.ronka@nokia.com | Rel-6 | Mirko | OAM-Trace |  |  |  |
| 4669 | 1183.4.1 | Subscriber and UE trace management | 585d | 2002-09-20 A | 2004-12-16 A | 100% | 2002-09-20 | 2004-12-16 | 585d | finish no earlier than 2004-12-16 | S5 | 4680h | 4680h |  | Nokia | kari.t.ronka@nokia.com | Rel-6 | Mirko |  | 32.421, 32.422, 32.423, 52.008 |  |  |
| 4670 | 1183.4.2 | Subscriber and equipment trace in UTRAN | 268d? | 2003-06-06 A | 2004-06-15 A | 100% | 2003-06-06 | 2004-06-15 | 268d? | finish no earlier than 2004-06-15 | R3 | 2144h | 2144h | OAM-Trace-RAN | Nortel | Yann Sehedi (sehedic@nortelnetworks.com) | Rel-6 | Juha | OAM-Trace-RAN | 25.413, 25.420, 25.423 |  |  |
| 4671 | 1183.4.3 | Trace Management, Stage3 | 193.74d? | 2004-06-09 A | 2005-03-11 A | 100% | 2004-06-09 | 2005-03-11 | 193.74d? | finish no earlier than 2005-03-11 | N4 | 1549.92h | 1549.92h |  | Nokia | seppo.kauntola@nokia.com | Rel-6 | Kimmo |  | 23.205, 29.232, 29.060, 29.002, 29.228 |  |  |
| 4672 | 1184 | **Rel-6 Charging Management** | 666d? | 2002-11-21 A | 2005-06-09 A | 100% | 2002-11-21 | 2005-06-09 | 666d? |  | S5; S2; N3 | 67152h | 67152h | CH | T-Mobile | karl-heinz.nenner@t-mobile.de | Rel-6 | Mirko | CH |  |  |  |
| 4673 | 1184.1 | Charging architecture and principles | 390d? | 2003-03-21 A | 2004-09-16 A | 100% | 2003-03-21 | 2004-09-16 | 390d? | start no earlier than 2003-03-21 | S5 | 3120h | 3120h |  |  |  | Rel-6 | Mirko |  | 32.240 |  |  |
| 4674 | 1184.2 | Charging Data Record (CDR) file format and transfer | 260d? | 2003-03-21 A | 2004-03-18 A | 100% | 2003-03-21 | 2004-03-18 | 260d? | start no earlier than 2003-03-21 | S5 | 2080h | 2080h |  |  |  | Rel-6 | Mirko |  | 32.297 |  |  |
| 4675 | 1184.3 | CDR parameter description | 580d? | 2003-03-21 A | 2005-06-09 A | 100% | 2003-03-21 | 2005-06-09 | 580d? | finish no earlier than 2005-06-09 | S5 | 4640h | 4640h |  |  |  | Rel-6 | Mirko |  | 32.298 |  |  |
| 4676 | 1184.4 | Diameter charging applications | 390d? | 2003-03-21 A | 2004-09-16 A | 100% | 2003-03-21 | 2004-09-16 | 390d? | start no earlier than 2003-03-21 | S5 | 3120h | 3120h |  |  |  | Rel-6 | Mirko |  | 32.299 |  |  |
| 4677 | 1184.5 | Online Charging System (OCS) architecture study | 130d? | 2003-03-21 A | 2003-09-18 A | 100% | 2003-03-21 | 2003-09-18 | 130d? | start no earlier than 2003-03-21 | S5 | 1040h | 1040h |  |  |  | Rel-6 | Mirko |  | 32.815 |  |  |
| 4678 | 1184.6 | OCS: Applications and interfaces | 455d? | 2003-03-21 A | 2004-12-16 A | 100% | 2003-03-21 | 2004-12-16 | 455d? | start no earlier than 2003-03-21 | S5 | 3640h | 3640h |  |  |  | Rel-6 | Mirko |  | 32.296 |  |  |
| 4679 | 1184.7 | **Charging Management for Bearer level** | 390d? | 2003-03-21 A | 2004-09-16 A | 100% | 2003-03-21 | 2004-09-16 | 390d? |  | S5 | 11440h | 11440h | CH-BC | Nokia | Benni ALEXANDER | Rel-6 | Mirko | CH-BC |  |  |  |
| 4680 | 1184.7.1 | CS domain charging | 260d? | 2003-03-21 A | 2004-03-18 A | 100% | 2003-03-21 | 2004-03-18 | 260d? | start no earlier than 2003-03-21 | S5 | 2080h | 2080h |  |  |  | Rel-6 | Mirko |  | 32.250 |  |  |
| 4681 | 1184.7.2 | PS domain charging | 390d? | 2003-03-21 A | 2004-09-16 A | 100% | 2003-03-21 | 2004-09-16 | 390d? | start no earlier than 2003-03-21 | S5 | 3120h | 3120h |  |  |  | Rel-6 | Mirko |  | 32.251 |  |  |
| 4682 | 1184.7.3 | CDR transfer | 390d? | 2003-03-21 A | 2004-09-16 A | 100% | 2003-03-21 | 2004-09-16 | 390d? | start no earlier than 2003-03-21 | S5 | 3120h | 3120h |  |  |  | Rel-6 | Mirko |  | 32.295 |  |  |
| 4683 | 1184.8 | Charging Management for the Service domain | 580d? | 2003-03-21 A | 2005-06-09 A | 100% | 2003-03-21 | 2005-06-09 | 580d? | finish no earlier than 2005-06-09 | S5 | 4640h | 4640h |  | Siemens | Gerald.Goermer@nsn.com | Rel-6 | Mirko |  | 32.252, 32.270, 32.271, 32.272 |  |  |
| 4684 | 1184.9 | **Overall architectural aspects of IP flow based bearer level charging** | 602d? | 2002-11-21 A | 2005-03-11 A | 100% | 2002-11-21 | 2005-03-11 | 602d? |  | S2; N3 | 17448h | 17448h | CH-FBC |  |  | Rel-6 | Maurice | CH-FBC | 23.125 |  |  |
| 4685 | 1184.9.1 | Overall definition of FBC architecture | 334d? | 2002-11-21 A | 2004-03-02 A | 100% | 2002-11-21 | 2004-03-02 | 334d? | start no earlier than 2002-11-21 | S2 | 2672h | 2672h |  |  |  | Rel-6 | Maurice |  |  | SP-24 |  |
| 4686 | 1184.9.2 | Study on providing policy control with FBC | 130d? | 2004-02-02 A | 2004-07-30 A | 100% | 2004-02-02 | 2004-07-30 | 130d? | start no earlier than 2004-02-01 | S2 | 1040h | 1040h |  |  |  | Rel-6 | Maurice |  |  | SP-24 |  |
| 4687 | 1184.9.3 | Gx interface for flow based charging | 223d? | 2004-02-02 A | 2004-12-08 A | 100% | 2004-02-02 | 2004-12-08 | 223d? | start no earlier than 2004-02-01 | N3 | 1784h | 1784h |  | Nokia | juha.a.rasanen@nokia.com | Rel-6 | Gwiho |  | 29.210 | SP-25 |  |
| 4688 | 1184.9.4 | Rx interface for flow based charging | 290d? | 2004-02-02 A | 2005-03-11 A | 100% | 2004-02-02 | 2005-03-11 | 290d? | finish no earlier than 2005-03-11 | N3 | 2320h | 2320h |  | Nortel | Javier Gonzalez Gallego | Rel-6 | Gwiho |  | 29.209 | SP-25 |  |
| 4689 | 13 | **Rel-6 UICC/USIM enhancements and interworking** | 1164d? | 2000-09-25 A | 2005-03-10 A | 100% | 2000-09-25 | 2005-03-10 | 1164d? |  | T3 | 43088h | 43088h | USAT1 |  |  | Rel-6 | Xavier | USAT1 |  |  |  |
| 4690 | 13.1 | **UICC API** | 777d | 2002-03-20 A | 2005-03-10 A | 100% | 2002-03-20 | 2005-03-10 | 777d |  | T3 | 15024h | 15024h | USAT1-API |  |  | Rel-6 | Xavier | USAT1-API |  |  |  |
| 4691 | 13.1.1 | Rel-6 Java API Test specification | 59d | 2002-03-20 A | 2002-06-10 A | 100% | 2002-03-20 | 2002-06-10 | 59d | finish no earlier than 2002-09-20 | T3 | 472h | 472h |  | Microelectrónica Española | Mario Pérez | Rel-6 | Xavier |  |  |  |  |
| 4692 | 1185.1.2 | 2G/3G Java Card™ API based applet interworking | 255d | 2003-03-17 A | 2004-03-05 A | 100% | 2003-03-17 | 2004-03-05 | 255d | finish no earlier than 2004-02-19 | T3 | 2040h | 2040h |  | Oberthur Card Systems | Stéphane Andrau | Rel-6 | Xavier |  |  |  |  |
| 4693 | 1185.1.3 | (U)SIM API for Java Card Testing | 519d | 2003-03-17 A | 2005-03-10 A | 100% | 2003-03-17 | 2005-03-10 | 519d | finish no earlier than 2005-03-10 | T3 | 4152h | 4152h |  | Axalto | Christophe Begassat (cbegassat@axalto.com) | Rel-6 | Xavier |  | 31.213 |  |  |
| 4694 | 13.1.2 | Deleted - Java API Test specification (TS 43.019 Rel-5) | 268d | 2002-05-30 A | 2003-06-09 A | 100% | 2002-05-30 | 2003-06-09 | 268d | finish no earlier than 2003-09-17 | T3 | 2144h | 2144h |  | Microelectrónica Española | Mario Pérez | Rel-6 | Xavier |  |  |  | TP-20 |

Notes:
- 4668: SP#26 12/2004 SA5 completed 12/04. Signalling Based Trace Activation for IMS (SIP) moved to Rel-7. Reason: CN1 cannot complete 24.229 trace without IETF dependency => estimate 05/2005.
- 4669: SP#26 12/2004 completed
- 4670: -
- 4671: -
- 4672: SP#28 Target 09/2005 for WLAN Charging 32.252
- 4673: SP#25 09/2004 completed
- 4674: SP#23 03/2004 completed
- 4675: SP#28 06/2005 completed
- 4676: SP#25 09/2004 completed
- 4677: SP#21 09/2003 completed
- 4678: SP#26 12/2004 completed
- 4679: SP#28 Target 09/2005 for WLAN Charging 32.252
- 4680: SP#23 03/2004 completed
- 4681: SP#25 09/2004 completed
- 4682: SP#25 09/2004 completed
- 4683: SP#26: Updated WID SP-040778 was SP-030050. Target completion 06/2005. Consisting of MMS-CH, LCS-CH, WLAN-CH, POC-CH, MBMS-CH
- 4684: -
- 4685: -
- 4686: -
- 4687: -
- 4688: -
- 4689: -
- 4690: 8/3/2001: test spec is based on R99 core spec, so deleted from Workplan
- 4691: -
- 4692: -
- 4693: -
- 4694: MOVED to Rel-5 WP
